# COSTED BL14-001 12 GeV CR13-015,14-001

How a schedule from Primavera P6 changed from version to version. A marks actual dates.

## Version 1 (data date 2006-09-30, saved 2024-04-28, file 12_GeV_BL14-001_15_November_13_PMK.xer)

| ID | WBS | Task | Duration | Start | Finish | Predecessors | Complete | Total float | Constraint |
| --- | --- | --- | --- | --- | --- | --- | --- | --- | --- |
|  | 0M | **1.M MILESTONES** |  | 2004-03-31 | 2017-09-29 |  |  |  |  |
|  | 1.01M | **1.01 LEVEL 1 MILESTONES** |  | 2004-03-31 | 2017-09-29 |  |  |  |  |
| 1-1M |  | CD-0 (Approve Mission Need) | 0d | 2004-03-31 A | 2004-03-31 A |  | 100% |  |  |
| 1-2M |  | CD-1 (Approve Preliminary Baseline Range) | 0d | 2006-02-15 A | 2006-02-15 A | 1-1M FS+399d | 100% |  | finish on or after 2005-09-30 |
| 1-5M |  | CD-2 (Approve Performance Baseline) | 0d | 2008-01-02 | 2008-01-02 | 121224030, 121223030, 1241176M, 1241056M, 1241016M, 121224022, 123221007ALOE, 1241096M, 3R-3M, 1241136M, 121221055 |  | 0d | mandatory finish 2007-12-28 |
| 1-6M |  | CD-3 (Approve Start of Constr) | 0d | 2008-09-30 | 2008-09-30 | 1142030, 3R-05M, 117908LOE, 3R-08M, 122311908LOE, 1212112908LOE, 1211005M5, 1152945LOE, 123221025, 1212111120, 122312070 FS-40d, 1212111908LOE |  | 0d | mandatory finish 2008-09-30 |
| 1-7M |  | CD-4A ( Approve Accelerator Completion & Start of Operations) | 0d | 2014-12-23 | 2014-12-23 | 2-S10M, 2-S01M, 2-S02M, 23221023Da, 23641914LOE, 2-S09M, 2-S03M, 2-S11M, 2-S05M, 2-S06M, 13421050M, 23221140LOEa, 23221023Ga, 2-S04M, 281315030, 281315030a, 23642914LOE, 23643914LOE, 28000, 2-S07M, 3C-13M, 23224087, 23224087a, 2-S08M, 3A-59M |  | 0d | mandatory finish 2014-12-23 |
| 1-8M |  | CD-4B (Approve Proj Compltn & Start of Operations) | 0d | 2017-09-29 | 2017-09-29 | 2-08M, 1-7M, 28005, 2831916LOE, 28010, 28025, 28015, 2-06M, 28020 |  | 0d | mandatory finish 2017-09-29 |
|  | 1.02A | **1.02A LEVEL 2 ACCELERATOR MILESTONES** |  | 2010-07-14 | 2014-06-25 |  |  |  |  |
| 2-01M |  | Klystron Mass Production Authorization | 0d | 2010-07-14 | 2010-07-14 | 132111049 |  | 154d | start on or before 2011-06-30 |
| 2-02M |  | Start Accelerator Installation Shutdown (IPL) | 0d | 2012-05-14 | 2012-05-14 | 13445005, 13421030a, 1317015, 13411200a, 13411140a, 13416049B, 13456030M FS+130d, 13454040 FS-50d, 13446010b, 13435010, 13454047, 13444015, 13432015, 13411070M, 13416049A, 13416035M, 13444025, 13444020, 13411145, 13414055, 13456022LOEa, 13434005a, 13411196, 13414030M FS-175d, 13414095M FS-99d, 13425030, 13456029, 13451095, 13441010, 13433005, 13421070M, 13456042, 13456047 FS-40d, 13451100a, 13451105a, 13417015 |  | 0d | mandatory start 2012-05-14 |
| 2-26M |  | Accel Installtn Comptd Except for All Power Supplies | 0d | 2013-10-29 | 2013-10-29 | 4A-07M, 4A-09M, 4A-08M |  | 22d |  |
| 2-03M |  | Accelerator Commissioned | 0d | 2013-12-20 | 2013-12-20 | 2812005, 2811005 |  | 0d | finish on or before 2013-12-31 |
| 2-25M |  | Box Supply Installtn Comptd | 0d | 2014-06-25 | 2014-06-25 | 13222100, 13222035, 23222230a, 2813224000a, 13222230, 23222230, 23222195, 23221022c, 2813221000a, 13222100A, 13222195, 2813221000, 23222142, 13222067, 13221025 FS-2d, 2813224000, 23222035, 23222067a, 13222065, 13222140, 13222160, 23222100A, 13222142, 13221025A, 23222035a, 23222195a |  | 0d |  |
|  | 1.02H | **1.02H LEVEL 2 HALLS A, B & C MILESTONES** |  | 2006-10-02 | 2016-02-10 |  |  |  |  |
| 2-04M |  | Design Report on Superconducting Magnets | 0d | 2006-10-02 | 2006-10-02 |  |  | 247d | finish on or before 2007-09-28 |
| 2-05M |  | Design Review on Superconducting Magnets | 0d | 2008-05-30 | 2008-05-30 | 12221060M, 122311045M, 122312080, 122312050M, 12221045M |  | 43d | finish on or before 2008-07-31 |
| 2-06M |  | Award First Superconducting Magnet Contract | 0d | 2009-03-16 | 2009-03-16 | 3R-05M, 14312000M |  | 98d | finish on or before 2009-07-31 |
| 2-07M |  | Start Installation for Existing Halls | 0d | 2012-05-14 | 2012-05-14 | 2-02M, 14368010M |  | 54d | start on or before 2012-07-31 |
| 2-08M |  | Installation of Experimental Equipment into H-A is Completed | 0d | 2013-10-11 | 2013-10-11 | 14132020, 3A-43M, 14153020, 24153020, 14151010a, 24152025, 14152025 |  | 48d | finish on or before 2013-12-31 |
| 2-09M |  | Hall-A Beam Commissioning Completed | 0d | 2014-03-05 | 2014-03-05 | 2811020, 2812065, 2821X000 |  | 18d | finish on or before 2014-03-31 |
| 2-27M |  | Hall C Q1 Magnet Delivered | 0d | 2014-06-30 | 2014-06-30 | 24312053M |  | 87d | finish on or before 2014-10-31 |
| 2-28M |  | Hall C HB Magnet Delivered | 0d | 2014-07-23 | 2014-07-23 | 24311160 FS-7d |  | 49d | finish on or before 2014-09-30 |
| 2-34M |  | Hall B Torus Cold Mass Delivered | 0d | 2014-09-30 | 2014-09-30 | 14271012, 14273005, 14271020, 14271000, 24271740M, 14273000 |  | 0d | finish on or before 2014-09-30 |
| 2-35M |  | Hall B Solenoid Cryostated Coil Delivered | 0d | 2014-11-26 | 2014-11-26 | 14271080, 242781005LOE, 24272075k, 24272075n |  | 17d | finish on or before 2014-12-31 |
| 2-29M |  | Hall C Dipole Delivered | 0d | 2015-05-18 | 2015-05-18 | 24314030a |  | 0d | finish on or before 2015-06-30 |
| 2-30M |  | Hall C Q2 Magnet Delivered | 0d | 2015-06-19 | 2015-06-19 | 24313019a FS-72d |  | 18d | finish on or before 2015-07-31 |
| 2-31M |  | Hall C Q3 Magnet Delivered | 0d | 2015-08-26 | 2015-08-26 | 24313019a FS-25d, 14313019a |  | 6d | finish on or before 2015-09-30 |
| 2-36M |  | Installtn of Expermntl Equipmnt into H-B is Comptd | 0d | 2015-12-18 | 2015-12-18 | 28223040, 24212000 FS-250d, 24211095 FS-250d, 24264065M, 24264360, 24264395, 242742020, 24254005, 14247015, 24273012a, 242711.5010a, 14211051o FS-250d, 24264995, 24264003LOE FS-500d, 14235015, 242711.5010, 24272085 FS-500d, 24273007, 242751435, 14254020, 14254008, 24254105, 14241015, 242742020a, 24211090 FS-250d, 14211080 FS-250d, 24264281, 242211620, 24272075r, 24273012, 242742030, 14254010, 24254070, 24254080, 24243010, 14242060M, 14211040C, 24264860M, 14264235, 24264410, 14264002LOE FS-500d, 14264000dLOE FS-500d, 14271028LOEA, 24271725 LOE, 24271735, 24273022, 242781025, 14251005, 24254115, 24264878, 24264470, 242241457, 14234005, 24271730, 242742025, 242751450, 14254025, 24254050, 24254090, 24242060M, 14244025, 24244035, 242711.5010b, 28223030, 28223025, 24212005 FS-250d, 14212005s FS-250d, 14211025a, 24264006LOE FS-500d, 24264230, 14264360, 242241452, 242223570, 24232025, 242711.5025, 24273017, 242781010LOE FS-500d, 24254020, 24254060, 14252010, 24244030, 14247010, 24247060M, 14264345, 24264440, 14264000bLOE FS-500d, 242241462, 242232685M, 24231000, 24235015, 14254007, 24254040, 24254035, 242742030a, 24264888, 24264345, 14264280, 24264390, 14264410, 14264230, 24264500, 242223575, 24233070M, 24272410, 24272405, 24254000, 14244010, 242751435a |  | 3d | finish on or before 2015-12-31 |
| 2-32M |  | Installtn of Expermntl Equipmnt into H-C is Comptd | 0d | 2015-12-23 | 2015-12-23 | 14362812LOE FS-500d, 24363041, 24363046, 24315090, 14314P4TLOE, 14314P4LOE FS-502d, 143118P3LOE FS-502d, 243118P6LOE FS-500d, 143128P5TLOE, 24312915LOE5 FS-500d, 24315015Bba, 24368540, 24368515, 24314P6LOE FS-500d, 24311170, 24311165, 24313P6LOE5 FS-500d, 14368335M, 24368505, 24315015Bb, 14315050LOEg FS-500d, 24315015Ba, 24311071, 243161000, 143248P1LOE5 FS-500d, 14368425, 24368450 FS-5d, 24368590LOE FS-500d, 243128PC13LOE FS-500d, 243128P6LOE5, 24353010a, 24368565, 24368455, 24368052, 24368475, 14315095 FS-2d, 24314110 FS-500d, 243128PC13LOE5 FS-500d, 24313270M FS-50d, 143238P1LOEb FS-500d, 24368110, 24368570, 24368545, 24362000, 24315007 FS-2d, 24314051M, 24311072a, 24312050d, 24353010, 24315050LOEg FS-500d, 143128PC13LOE, 14353010, 28236030, 24311168, 24312055, 143218P2LOE FS-500d, 243238P1LOEb, 14351020 FS-2d |  | 0d | finish on or before 2015-12-31 |
| 2-33M |  | Hall C Beam Commissioning Complete | 0d | 2016-02-08 | 2016-02-08 | 2823X000, 2812035, 2811050 |  | 38d | finish on or before 2016-03-31 |
| 2-37M |  | Hall B Beam Commissioning Complete | 0d | 2016-02-10 | 2016-02-10 | 2822X000, 2811035, 2812020 |  | 36d | finish on or before 2016-03-31 |
|  | 1.02D1 | **1.02D LEVEL 2 HALL D MILESTONES** |  | 2010-11-29 | 2014-12-11 |  |  |  |  |
| 2-10M |  | Start Hall-D Installation | 0d | 2010-11-29 | 2010-11-29 | 2-16M |  | 1d | start on or before 2010-11-30 |
| 2-11M |  | Installation of Hall-D Solenoid Completed | 0d | 2013-02-20 | 2013-02-20 | 151250M |  | 91d | finish on or before 2013-06-28 |
| 2-12M |  | Hall-D Equipment Installation Completed | 0d | 2014-09-30 | 2014-09-30 | 3A-53M, 282462045, 282462010, 1546182, 1543013E, 2543144, 251666, 15221012E, 1562180, 2562180, 2562790 FS-500d, 1562670a, 1562260, 1562335, 2562780, 2562835, 2562355, 2562495, 2562445, 2531375, 2532060, 2532195, 1553075, 2553011, 2553210, 25211217a, 2532170aa, 2562355b, 282443025a5a, 282446000a, 282462050, 2546655, 2541000, 2543185, 25221010, 2562170, 2562181, 1562650, 1562330, 1562670, 2562281, 2562420, 2562630, 2531370, 2531227aa, 2532115, 25211260a, 2546620b, 2553011a, 13326000, 282443025a, 282446000, 282432015, 2546640, 15211210, 25211255LOE5, 25221005, 1562630, 1562405, 2562855, 2562510, 2562460, 2562006LOE, 2531089, 2532000, 2532014E FS-500d, 2553029, 2541015a, 2543144a, 2543160a, 2562181a, 2562181b, 2562355a, 2562445a, 13326015, 2546465, 2546565, 2546610, 2546620, 2541015, 25211250, 25221000, 25221010LOE, 2562235, 1562625, 1562635, 1562595a, 1562600, 1562595, 2562860, 2562335, 2562625, 2562635, 2531227aa5, 2531360, 2531380, 2531400, 2531178 FS-100d, 2532220, 2532240, 2553157, 2546650a, 282443025a5, 25213030, 282462030, 2541154, 2541155, 2543160, 2562175, 2562206, 1562645, 1562270, 2562482, 2562216, 2562785 FS-500d, 2562595a, 2532170a, 2532255, 2532110, 2546610a, 2546620a, 2562335a, 2562335b, 2562482a, 13326010, 282432010, 282432005, 282462015, 282462040, 2546630, 2542085, 2542090, 2543165, 25211217, 2562165, 1562685, 1562400, 2562895, 2562900, 2562685, 2562014E, 2531385, 2531395, 2531088, 2532245, 2532175a, 2532075, 2532090, 2543165a, 2971000, 282462025, 2546615, 2546625, 2546645, 1541013E, 2542037, 25212010, 25212185 FS-103d, 1562260a, 2562637, 2532225, 2532085, 2532180, 2553075, 295222000, 282432025, 282462020, 282462035, 2546650, 2542080, 2543143, 25211255LOE, 25211260, 1562655, 1562665, 2562885, 2562615LOE FS-245d, 2562091M, 2531365 FS-500d, 2532235, 25212185a FS-103d, 2562895a |  | 0d | finish on or before 2014-09-30 |
| 2-13M |  | Hall-D Beam Commissioning Completed | 0d | 2014-12-11 | 2014-12-11 | 2824X000, 28241000a, 2812050, 2811065, 28241000 |  | 8d | finish on or before 2014-12-31 |
|  | 1.02C | **1.02C LEVEL 2 CIVIL MILESTONES** |  | 2008-09-04 | 2015-10-02 |  |  |  |  |
| 2-14M |  | Design of Conventional Facilties Completed | 0d | 2008-09-04 | 2008-09-04 | 3C-02M FS+40d, 1241075M, 1241155M, 1241195M, 1241115M, 3C-01M |  | 18d | finish on or before 2008-09-30 |
| 2-15M |  | Ready for Equipment-CHL Addition (RFE) (doesn't Include Elect & Cooling Water Util Distrbtn) | 0d | 2010-03-12 | 2010-03-12 | 1621010 FS+60d |  | 141d | finish on or before 2010-09-30 |
| 2-16M |  | Ready for Equipment - H-D (RFE) | 0d | 2010-11-24 | 2010-11-24 | 16331032, 16331030 |  | 1d | finish on or before 2010-11-30 |
| 2-17M |  | Accelerator Tunnel Extension Completed (existing tunnel) | 0d | 2011-11-01 | 2011-11-01 | 16333030 |  | 183d | finish on or before 2012-07-31 |
| 2-38M |  | Conventional Facilt's Comptd | 0d | 2015-10-02 | 2015-10-02 | 16222035M, 16333035, 1621020, 16332035, 16113030M, 26115045M, 26112030M, 1621015b, 16331035M, 26114030M, 16111030M, 1621030, 16122030M |  | 56d | finish on or before 2015-12-31 |
|  | 1.02PM | **1.02PM LEVEL 2 PROJECT MANAGEMENT MILESTONES-1** |  | 2005-09-29 | 2008-06-30 |  |  |  |  |
| 2-18M |  | Preliminary Hazard Assessment Submitted to DOE | 0d | 2005-09-29 A | 2005-09-29 A |  | 100% |  |  |
| 2-19M |  | EA Completed | 0d | 2006-10-02 | 2006-10-02 | 1-2M |  | 1d | finish on or before 2006-10-02 |
| 2-20M |  | Completion of Land Transfer | 0d | 2006-10-02 | 2006-10-02 | 1-2M |  | 184d | finish on or before 2007-06-29 |
| 2-21M |  | PEP Issued | 0d | 2006-10-02 | 2006-10-02 | 1-2M |  | 184d | finish on or before 2007-09-28 |
| 2-22M |  | OECM EVMS Contractor Certification REVIEW CompleteD | 0d | 2008-01-31 | 2008-01-31 | 1252015 |  | 0d | mandatory finish 2008-01-31 |
| 2-23M |  | Accelerator Safety Envelope (ASE) Completed | 0d | 2008-06-30 | 2008-06-30 | 1251908LOEB FS-65d, 9-080M FS+125d |  | 1d | finish on or before 2008-06-30 |
| 2-24M |  | Safety Assessmnt Document (SAD) Completed | 0d | 2008-06-30 | 2008-06-30 | 9-080M FS+125d, 1251908LOEB FS-65d |  | 1d | finish on or before 2008-06-30 |
|  | 1.02R | **1.02R LEVEL 2 REVIEW MILESTONES** |  |  |  |  |  |  |  |
|  | 1.02S | **1.02S LEVEL 2 STIMULUS MILESTONES** |  | 2009-01-08 | 2010-10-01 |  |  |  |  |
| 2-S02M |  | Award Central Helium Liquifer 4.5K Coldbox Subcontract | 0d | 2009-01-08 | 2009-01-08 | 1331.02000 FS-185d |  | 120d | start on or before 2009-06-30 |
| 2-S01M |  | Award 4 Meter Dipole Magnet Subcontract | 0d | 2009-01-13 | 2009-01-13 | 13451060M |  | 117d | start on or before 2009-06-30 |
| 2-S03M |  | Award Quad Magnets Subcontracts | 0d | 2009-08-03 | 2009-08-03 | 13452030M |  | -23d | start on or before 2009-06-30 |
| 2-S04M |  | Award Cryomodules Spaceframes Subcontract | 0d | 2009-08-04 | 2009-08-04 | 131121010 |  | 19d | start on or before 2009-08-31 |
| 2-S10M |  | Award North & South Access Building Subcontract | 0d | 2009-10-01 | 2009-10-01 | 16111000M |  | 162d | start on or before 2010-05-31 |
| 2-S07M |  | Award High-Voltage Cathode Power Supply Subcontract | 0d | 2009-10-08 | 2009-10-08 | 1321121010 |  | 72d | start on or before 2010-01-29 |
| 2-S05M |  | Award Cryomodules Vacuum Vessels Subcontract | 0d | 2009-11-03 | 2009-11-03 | 131136010 |  | 17d | start on or before 2009-11-30 |
| 2-S08M |  | Award Central Helium Liquifer Compressors Subcontract | 0d | 2010-01-12 | 2010-01-12 | 1331.01010 FS-77d, 1331.01000 FS-240d |  | 31d | start on or before 2010-02-26 |
| 2-S06M |  | Award End Can Subcontract | 0d | 2010-02-03 | 2010-02-03 | 131135010 |  | -25d | start on or before 2009-12-21 |
| 2-S11M |  | Award Final Stimulus Subcontract | 0d | 2010-09-30 | 2010-09-30 | 1-6M |  | 0d | mandatory finish 2010-09-30 |
| 2-S09M |  | Award Box Power Supply Subcontract | 0d | 2010-10-01 | 2010-10-01 | 13221004M |  | -129d | start on or before 2010-03-31 |
|  | 1.03A | **1.03A LEVEL 3 ACCELERATOR MILESTONES** |  | 2009-04-21 | 2014-02-07 |  |  |  |  |
| 32-01M |  | Award Initial Major Acc contract | 0d | 2009-04-21 | 2009-04-21 | 132111025M |  | -37d | start on or before 2009-02-27 |
| 3A-01M |  | Start Linac Installtn | 0d | 2009-10-01 | 2009-10-01 | 9-100M |  | 431d | start on or before 2011-06-30 |
| 32-02M |  | Vendor Dsgn Review of 4K Coldbox | 0d | 2010-01-29 | 2010-01-29 | 1331.02025, 1331.02000 FS-65d |  | 0d | finish on or before 2010-01-31 |
| 32-03M |  | Start Accel Component Assy | 0d | 2010-03-18 | 2010-03-18 | 9-100M FS+110d |  | 73d | start on or before 2010-06-30 |
| 3A-02M |  | Start LLRF Installtn | 0d | 2010-10-01 | 2010-10-01 | 9-110M |  | 161d | start on or before 2011-05-31 |

| ID | WBS | Task | Duration | Start | Finish | Predecessors | Total float | Constraint |
| --- | --- | --- | --- | --- | --- | --- | --- | --- |
| 3A-03M |  | Start Pwr (rf) Installtn | 0d | 2011-01-04 | 2011-01-04 | 4A-03M | 267d | start on or before 2012-01-31 |
| 3A-29M |  | West Arc Removl Comptd | 0d | 2011-05-13 | 2011-05-13 | 4A-01M | 60d |  |
| 3A-34M |  | Start West Arc Installtn | 0d | 2011-05-13 | 2011-05-13 | 3A-29M | 60d |  |
| 3A-21M |  | Start Pwr (Mag) Installtn | 0d | 2011-06-13 | 2011-06-13 | 13224020, 9-110M FS+170d, 13224010, 13224005, 13224030, 13224025, 13224015 | 324d | start on or before 2012-09-28 |
| 3A-20M |  | Start Cryomodule Installtn | 0d | 2011-08-12 | 2011-08-12 | 131401000, 3A-01M, 13643172M | 83d | start on or before 2012-09-28 |
| 3A-04M |  | Start 2nd Cryogenics Plant Commssng | 0d | 2011-10-03 | 2011-10-03 | 3C-07M, 1331.07000a, 1331.01000, 1331.02001, 1331.09000 FS+60d, 1331.1000a, 1331.1000b, 1331.02000, 1331.12000, 1331.08000, 1331.02070, 1331.01110, 1331.02012, 12131.11010, 16222035M, 1621015b FS+130d, 9-120M, 1621020 FS+130d, 1331.06000, 1331.03000, 1331.07000b, 1331.01005A, 1331.02015 | 40d | start on or before 2011-11-30 |
| 3A-07M |  | Start PSS Installtn | 0d | 2012-01-23 | 2012-01-23 | 16331032, 3A-09M, 16332030, 16331030, 13643040b, 13643040c | 6d | start on or before 2012-01-31 |
| 3A-09M |  | Start I&C/Sfty Installtn | 0d | 2012-01-23 | 2012-01-23 | 13643090, 13643085 | 6d | start on or before 2012-01-31 |
| 3A-08M |  | Start MPS Installtn | 0d | 2012-03-19 | 2012-03-19 | 13641014, 3A-09M, 16332030, 16331032, 16331030 | 30d | start on or before 2012-04-30 |
| 3A-59M |  | Test Lab Ready for Renovation | 0d | 2012-05-01 | 2012-05-01 | 1312410010 | 0d | mandatory finish 2012-05-01 |
| 3A-12M |  | Start H-D BL Installtn | 0d | 2012-05-14 | 2012-05-14 | 2-02M | 402d |  |
| 3A-13M |  | Start West Arc Removl | 0d | 2012-05-14 | 2012-05-14 | 2-02M | 200d |  |
| 3A-14M |  | Start East Arc Removl | 0d | 2012-05-14 | 2012-05-14 | 3A-13M, 2-02M | 200d |  |
| 3A-16M |  | Start H-A BL Removl | 0d | 2012-05-14 | 2012-05-14 | 2-02M | 313d |  |
| 3A-17M |  | Start H-B BL Removl | 0d | 2012-05-14 | 2012-05-14 | 2-02M | 315d |  |
| 3A-18M |  | Start H-C BL Removl | 0d | 2012-05-14 | 2012-05-14 | 2-02M | 320d |  |
| 3A-19M |  | Start S/R Removl | 0d | 2012-05-14 | 2012-05-14 | 2-02M | 307d |  |
| 3A-22M |  | Start Trim Supply Installtn | 0d | 2012-05-14 | 2012-05-14 | 2-02M | 216d |  |
| 3A-30M |  | East Arc Removl Comptd | 0d | 2012-08-13 | 2012-08-13 | 13427020 | 193d |  |
| 3A-36M |  | Start East Arc Installtn | 0d | 2012-08-14 | 2012-08-14 | 2-02M, 3A-30M | 193d |  |
| 3A-28M |  | H-A BL Removl Comptd | 0d | 2012-10-19 | 2012-10-19 | 13427035 | 201d |  |
| 3A-37M |  | Start H-A BL Installtn | 0d | 2012-10-22 | 2012-10-22 | 3A-28M, 2-02M, 3A-16M | 201d |  |
| 3A-31M |  | H-B BL Removl Comptd | 0d | 2012-11-02 | 2012-11-02 | 13427042 | 290d |  |
| 3A-38M |  | Start H-B BL Installtn | 0d | 2012-11-05 | 2012-11-05 | 3A-31M, 2-02M, 3A-17M | 292d |  |
| 3A-32M |  | H-C BL Removl Comptd | 0d | 2012-11-09 | 2012-11-09 | 13427050 | 346d |  |
| 3A-33M |  | Start H-C BL Installtn | 0d | 2012-11-12 | 2012-11-12 | 3A-32M, 2-02M | 347d |  |
| 3A-52M |  | East arc Installtn Comptd | 0d | 2013-02-14 | 2013-02-14 | 13427032 | 168d |  |
| 3A-10M |  | LLRF Installtn Comptd | 0d | 2013-02-15 | 2013-02-15 | 132121070M | 167d |  |
| 3A-23M |  | Start Box Supply Installtn | 0d | 2013-03-12 | 2013-03-12 | 13221024a FS-320d, 13221030, 16111025, 23221024ba FS-320d, 13221020a FS-207d | 126d |  |
| 3A-56M |  | West arc Installtn Comptd | 0d | 2013-03-12 | 2013-03-12 | 13427030 | 151d |  |
| 3A-40M |  | HPA Installtn Comptd | 0d | 2013-04-03 | 2013-04-03 | 132111057M, 132112090M, 132111115M | 135d |  |
| 3A-41M |  | Pwr (rf) Installtn Comptd | 0d | 2013-04-03 | 2013-04-03 | 3A-40M, 3A-10M, 132113090M | 135d |  |
| 3A-58M |  | End of Long Accel Constr Down | 0d | 2013-09-13 | 2013-09-13 | 13417170, 23417065 FS-15d, 13411150LOE, 23411145 FS-25d, 23427016LOE FS-45d, 13427021a, 13427024a, 132113135, 1352020, 23643355 FS-40d, 13643360, 23613913LOE FS-100d, 13422123, 23223125a FS-100d, 23612913LOE FS-100d, 23463050a FS-20d, 23447010 FS-5d, 13417030, 23417165 FS-15d, 13458045, 23611026b FS-15d, 23427016LOEa FS-45d, 23417150 FS-45d, 13416049, 23463050 FS-20d, 23223125 FS-100d, 13643355, 13436040, 13417035, 13417150, 13427050, 13427030, 2363913LOE FS-100d, 1367050, 13611026b, 13417040a, 13417020, 13427016LOE, 13422123b, 13422060, 13223125, 232111914LOE FS-500d, 2365913LOE FS-100d, 13447010, 23417170 FS-15d, 13427022a, 13427023a, 23223125b FS-100d, 23411145a FS-25d | 0d | mandatory finish 2013-09-13 |
| 3A-43M |  | H-A BL Installtn Comptd | 0d | 2013-10-11 | 2013-10-11 | 13427040, 23427040, 13221115, 23427040a | 48d |  |
| 3A-47M |  | Cryomodule Installtn Comptd | 0d | 2013-10-11 | 2013-10-11 | 281315025a, 281315015, 181315025, 281315025 | 21d |  |
| 3A-54M |  | S/R Installtn Comptd | 0d | 2013-10-29 | 2013-10-29 | 13417040a, 23417145, 23417145a | 14d |  |
| 3A-44M |  | H-B BL Installtn Comptd | 0d | 2013-11-11 | 2013-11-11 | 23427047, 13221115, 23427047a, 13427047 | 126d |  |
| 32-05M |  | Start Accel Beam Commssng | 0d | 2013-11-14 | 2013-11-14 | 2-26M FS-11d, 2811001 FS-20d, 1363015b, 13461045M, 2363015aa, 1363015aa | 0d |  |
| 3A-46M |  | H-C BL Installtn Comptd | 0d | 2013-11-15 | 2013-11-15 | 23427057, 13427057, 13221115 | 122d |  |
| 3A-42M |  | MPS Installtn Comptd | 0d | 2013-12-20 | 2013-12-20 | 13641100M, 13641080M, 13641045M, 23641045M, 23641080M | 100d |  |
| 3A-49M |  | PSS Installtn Comptd | 0d | 2014-01-15 | 2014-01-15 | 13643165, 23643105a, 23643140a, 13643172M, 23643117, 13643105, 13643070, 23643105, 13643345, 23643165, 23643170M, 23643117a, 13643075, 13643140, 13643170M, 13643120, 23643140, 23643117b | 61d |  |
| 3A-48M |  | Trim Supply Installtn Comptd | 0d | 2014-02-04 | 2014-02-04 | 13224110, 23223015, 13223025, 23223051Q FS-15d, 23223060a, 13224003LOE FS-100d, 13223015, 23223025, 23223015a, 23224003LOE FS-100d, 13223060, 2813224005, 23223025a | 35d |  |
| 3A-53M |  | H-D BL Installtn Comptd | 0d | 2014-02-07 | 2014-02-07 | 2365035M, 23458065a, 1365035M, 1365065M, 2365065M, 2532020, 2367025aa, 1363020b, 13458065, 23458065, 13221115, 1366055M, 1363020a, 2366055M, 13643185M, 2367025a, 2562435 | 46d |  |
|  | 1.03C | **1.03C LEVEL 3 CIVIL MILESTONES** |  | 2007-11-30 | 2013-08-30 |  |  |  |
| 3C-01M |  | Civil A-E Dsgns of H-D Complex & CHL Addition are Comptd. | 0d | 2007-11-30 | 2007-11-30 | 1243040M | 15d | finish on or before 2007-12-31 |
| 3C-02M |  | Civil Dsgn Work by Facilt's Management for the Accel projects (does not Include CHL) is Comptd. | 0d | 2008-07-09 | 2008-07-09 | 1241030, 1241110, 1241190, 1241070, 1241150 | 16d | finish on or before 2008-07-31 |
| 3C-04M |  | Civil Constr Contract Award of the CHL Bldng Addition, Doesn't Include the Elect & Cooling Water Utility distrib. | 0d | 2009-01-16 | 2009-01-16 | 1621005 | 72d | finish on or before 2009-04-30 |
| 3C-03M |  | Civil Constr Contract Award for P- I of the H-D Complex conventional Facilt's. | 0d | 2009-02-02 | 2009-02-02 | 16331005 | 62d | finish on or before 2009-04-30 |
| 3C-06M |  | Civil Sitework & Utility Distrbtn Associated with P- I of the H-D complex Comptd. | 0d | 2010-05-28 | 2010-05-28 | 16331010A, 16331010C, 16331010F, 16331010G, 16331010L FS-23d, 16331010H, 16331010J, 16331010K, 16331010, 16331010D, 16331010B | 1382d |  |
| 3C-09M |  | Start Installtn, RFE of H-D Cryo Plant Bldng Comptd. | 0d | 2011-02-28 | 2011-02-28 | 16332040F | 87d | finish on or before 2011-06-30 |
| 3C-11M |  | Civil Constr Electrical Distrbtn Upgrades at the N&S Access Bldngs & at the N&S Linac bldgs Comptd . | 0d | 2011-03-18 | 2011-03-18 | 16122025, 16111030M | 278d | finish on or before 2012-04-30 |
| 3C-07M |  | Civil Constr Elect & Cooling Water Utility Distrbtn to Supprt CHL#2 Comptd. | 0d | 2011-05-27 | 2011-05-27 | 16222035M, 16222030 | 23d | finish on or before 2011-06-30 |
| 3C-10M |  | Start Installtn, RFE of Tagger Area portion of the Underground Accel Tunnel Comptd. | 0d | 2011-11-30 | 2011-11-30 | 16332030, 16332010U | 17d | finish on or before 2011-12-30 |
| 3C-08M |  | Civil Constr N&S Access Bldng Additions & BSW Service bldng Addition Comptd. | 0d | 2012-02-21 | 2012-02-21 | 16113025, 16111025 | 49d | finish on or before 2012-04-30 |
| 3C-13M |  | Blue Crab End of Occupation | 0d | 2013-08-30 | 2013-08-30 | 197111110, 197111065, 197111130, 197111105, 197111145, 197111085, 197111059 | 0d | mandatory finish 2013-08-30 |
|  | 1.03P | **1.03P LEVEL 3 PHYSICS MILESTONES** |  | 2009-05-20 | 2016-02-10 |  |  |  |
| 32-12M |  | H-D Expermntl Equipment Dsgn Comptd | 0d | 2009-05-20 | 2009-05-20 | 12353045M | 92d | finish on or before 2009-09-30 |
| 3P-23M |  | Hall D Life Safety Systems Operational | 0d | 2011-09-02 | 2011-09-02 | 16332015 FS-20d | 21d | finish on or before 2011-10-03 |
| 3P-01M |  | Start Expermntl Equipmnt Installtn into H-A | 0d | 2012-05-07 | 2012-05-07 | 14151005, 14152015 | 5d | start on or before 2012-05-14 |
| 3P-02M |  | Removl of Expermntl Equipmnt Prior to major Installtns of New Equipmnt in H-B is Comptd. | 0d | 2012-05-14 | 2012-05-14 | 3P-03M | 33d | finish on or before 2012-06-29 |
| 3P-03M |  | Start Removl of Expermntl Equipmnt from H-B Prior to major Installtns of New Equipmnt | 0d | 2012-05-14 | 2012-05-14 | 2-02M | -10d | start on or before 2012-04-30 |
| 3P-04M |  | Start Removl of Expermntl Equipmnt from H-C Prior to major Installtns of New Equipmnt | 0d | 2012-05-14 | 2012-05-14 | 2-02M | 12d | start on or before 2012-05-31 |
| 3P-07M |  | Start Expermntl Equipmnt Installtn into H-C | 0d | 2012-05-14 | 2012-05-14 | 2-02M, 14368010M | 233d |  |
| 3P-08M |  | Start Expermntl Equipmnt Installtn into H-B | 0d | 2012-05-14 | 2012-05-14 | 3P-03M, 3P-02M | 119d | start on or before 2012-10-31 |
| 3P-24M |  | Start Hall D Cooldown | 0d | 2012-11-12 | 2012-11-12 | 13321050, 18241010 FS-14d, 181332000, 13327000 | 8d | start on or before 2012-11-26 |
| 3P-12M |  | Start E-B Commssng of H-A Detctr's, Electrnc's, & BL Devices | 0d | 2014-02-28 | 2014-02-28 | 2811019, 2-03M FS+40d | 19d | start on or after 2014-02-01 |
| 3P-25M |  | 10 GeV Beam to Hall D Tagger | 0d | 2014-03-14 | 2014-03-14 | 3A-53M, 3P-12M, 4A-12M, 23641100, 23641085, 3A-49M | 21d | finish on or before 2014-04-14 |
| 3P-16M |  | Start E-B Commssng of H-D Detctr's, Electrnc's, & BL Devices | 0d | 2014-11-19 | 2014-11-19 | 2-03M FS+100d, 23611065M, 2-25M FS-120d, 2-12M, 23614045M, 2811064 | 8d | start on or after 2014-04-01 |
| 3P-26M |  | Torus Assembled and Tested | 0d | 2015-10-01 | 2015-10-01 | 24264788M | 17d |  |
| 3P-20M |  | Start E-B Commssng of H-B Detctr's, Electrnc's, & BL Devices | 0d | 2016-01-28 | 2016-01-28 | 2811034, 2-03M, 2-25M | 36d | start on or after 2014-10-01 |

| ID | WBS | Task | Duration | Start | Finish | Predecessors | Complete | Total float | Constraint |
| --- | --- | --- | --- | --- | --- | --- | --- | --- | --- |
| 3P-18M |  | Start E-B Commssng of H-C Detctr's, Electrnc's, & BL Devices | 0d | 2016-02-02 | 2016-02-02 | 2-25M, 2811049, 24368500, 2-03M |  | 38d | start on or after 2014-09-01 |
| 3P-22M |  | E-B Commssng of H-C Detctr's, Electrnc's, & BL Devices Comptd | 0d | 2016-02-08 | 2016-02-08 | 2812035, 2823X000, 2811050 |  | 42d |  |
| 3P-21M |  | E-B Commssng of H-B Detctr's, Electrnc's, & BL Devices Comptd | 0d | 2016-02-10 | 2016-02-10 | 14234020LOE, 2811035, 2812020, 2822X000 |  | 40d |  |
|  | 1.03R | **1.03R LEVEL 3 REVIEW MILESTONES** |  | 2006-06-27 | 2009-09-30 |  |  |  |  |
| 3R-1M |  | FY06 Lehman Review | 0d | 2006-06-27 A | 2006-06-27 A |  | 100% |  |  |
| 3R-2M |  | CD-2 Review IPR | 0d | 2007-06-29 | 2007-06-29 | 2-19M, 2-20M, 11111000M, 2-21M, 121411015M |  | 0d | mandatory finish 2007-06-29 |
| 3R-3M |  | CD-2 Review EIR | 0d | 2007-08-15 | 2007-08-15 | 1212121130M, 3R-2M |  | 0d | mandatory finish 2007-08-15 |
| 3R-07M |  | EVMS Assessment | 0d | 2007-09-17 | 2007-09-17 | 3R-2M |  | 0d | mandatory start 2007-09-17 |
| 3R-08M |  | OECM EVMS Contractor CERTIFICATION Completed | 0d | 2008-01-31 | 2008-01-31 | 2-22M |  | 105d | finish on or before 2008-06-30 |
| 3R-05M |  | CD-3 Review IPR | 0d | 2008-07-31 | 2008-07-31 | 1135025, 1132890M FS-45d, 11111005RKC, 12225045, 1152005A, 1154001RKC, 1155001RKC, 1132800M FS-45d, 1141005RKC5, 1251006RKC, 121221140, 1212111170, 12224005, 121221120, 12131.10010, 1152001RKC, 1132865M FS-45d, 1132895, 1132841 FS-45d, 1132021RKC, 121221145, 121111010M, 121613027, 12163170, 121642170, 2-05M, 2-23M, 3C-01M, 1155020, 123221908LOE, 121224999, 12166027, 2-24M, 19005RKC, 1155025, 1155030, 1132875M FS-45d, 1242040M, 12162027, 12131.04020, 19001RKC, 1152040, 1154025, 1141005RKC, 121223050, 12165027, 12131.03010, 12131.11010, 1132831M FS-45d, 1112015M, 121221135, 12167027, 121614027, 121611041, 121612022 |  | 0d | mandatory finish 2008-07-31 |
| 3R-06M |  | PED Complete (30 Sep 09) (IPL 521224170M) | 0d | 2009-09-30 | 2009-09-30 | 12361010, 12223040M, 1222241035M, 12222065, 1222223041M, 122322015b, 122325020, 122324015, 1212122110M, 1212127065M, 1211020M, 121138060, 121614035M, 12162040M, 12156040M, 12156045, 121324000, 12131.09000, 121411110M, 32-12M, 1241035M, 12223045, 12232020, 122323015, 122311055a, 122312095, 1212124170, 1212122170, 1212123050, 1212126170, 1212112020, 1211020M10, 12166035, 121643140, 12131.07015b, 121416005a, 121456999, 1233039, 1233040M, 12353045M, 12226010a, 12225020, 12222015M, 12222055, 12222060, 12236040, 122311056, 1212127170, 1212121170, 12165030, 12163050M, 12156035, 12131.08000, 121416010, 121454015a, 126080M, 12323040M, 12351055M, 12226020a, 12222055b, 12222000a, 1222223040, 122153010, 1212125025M, 1212123055M, 121613040M, 121611055M, 121643045A, 121642010A, 121322000, 12131.03020, 12131.07015, 12361005, 12321018M, 12225040, 12222015a, 12236025, 12236060, 121221150, 1212123170, 1212121095, 1212112145M, 1211020M5, 12115005M, 121113005, 121643080A, 121643010A, 121642015A, 12151020M, 121323000, 121414016, 121446999, 12222070, 12222080, 12236830LOE, 122152020, 1212121145M, 1211020M15, 121114010M, 12167028, 121612030, 121612035, 121643065A, 121414015a, 121425015, 12322018M, 1234180M, 12226015a, 12225050, 12222045, 1222232030, 12232015, 12236020, 1212127060, 1212113170, 12165035, 121414020a, 121434999, 12222035M, 12236015b, 12236010b, 121223060a, 12156002, 121325000, 12131.04025 |  | 0d | mandatory finish 2009-09-30 |
|  | 1.04A | **1.04A LEVEL 4 ACCELERATOR MILESTONES** |  | 2011-01-04 | 2014-03-14 |  |  |  |  |
| 4A-03M |  | Start HPA Installtn | 0d | 2011-01-04 | 2011-01-04 | 1321122050 FS+182d, 3A-01M |  | 168d |  |
| 4A-01M |  | Start Precurser Maint Down (6 mo dur, ~1yr before Installtn Down) (IPL534213075,534213105,534213135,53427000M,5348065M) | 0d | 2011-05-13 | 2011-05-13 | 13434007, 13427063LOE, 13427180a, 13427055, 13421095, 13421046ab, 13433015, 13421046b, 13421090, 13456045 |  | 0d | mandatory start 2011-05-13 |
| 4A-04M |  | End of Precurser Maint Down (6 mo dur, ~1 yr before Installtn Down) | 0d | 2011-11-11 | 2011-11-11 | 13427060, 131502005a FS+15d, 14368171, 14341007, 13427062LOE, 13436035, 13427115M, 14368170, 13221093a |  | 0d | mandatory finish 2011-11-11 |
| 4A-07M |  | Linac Installtn Comptd | 0d | 2013-10-11 | 2013-10-11 | 1331.1005, 2331.1005, 1331.02066, 1331.11000, 181331000, 3A-47M, 3A-41M, 1331.02080 |  | 34d |  |
| 4A-10M |  | Start Accel Hot Chkout | 0d | 2013-10-15 | 2013-10-15 | 3C-11M, 13221095, 13213020M, 3A-54M FS-25d, 3A-52M, 3A-58M, 4A-09M FS-20d, 9-140M FS+10d, 23454055 FS-20d, 1351080, 1352035, 2367055 FS-34d, 1367055, 3A-10M, 13643185M, 23454055b FS-20d, 1363014a, 1363025b, 23224100a FS-40d, 1366030M, 1367025a, 13454055, 13224100, 13221097LOE, 23213020M FS-45d, 1363025a, 3A-41M, 3A-56M, 23224100 FS-40d, 1353095, 13642030M, 13643175M, 13612035M, 3A-47M FS-20d, 3A-40M, 13454050, 13611065M, 23454055a FS-20d |  | 0d |  |
| 4A-09M |  | I&C/Sfty for Accelerator Installtn Comptd | 0d | 2013-10-25 | 2013-10-25 | 2365065M, 23643170M, 23613035M, 23612035M |  | 11d |  |
| 4A-08M |  | Accelerator Beam Transport Comptd | 0d | 2013-10-29 | 2013-10-29 | 3A-52M, 3A-56M, 3A-54M |  | 22d |  |
| 4A-06M |  | Pwr (Mag) Installtn Comptd | 0d | 2014-02-04 | 2014-02-04 | 2-25M FS-180d, 3A-48M |  | 35d |  |
| 4A-11M |  | Beam Transport to Halls Comptd | 0d | 2014-02-07 | 2014-02-07 | 3A-44M, 3A-46M, 3A-43M, 3A-53M, 3A-42M |  | 73d |  |
| 4A-12M |  | I&C/Sfty Installtn Comptd | 0d | 2014-03-14 | 2014-03-14 | 23643280, 23641100M, 2-25M FS-120d, 2365035M, 23643185M, 23642030M |  | 21d |  |
|  | 1.04P | **1.04P Level 4 PHYSICS MILESTONE** |  |  |  |  |  |  |  |
|  | 1.09FA | **1.09FA LEVEL 9 FUNDING AVAILABLE MILESTONES** |  | 2006-10-02 | 2014-10-01 |  |  |  |  |
| 9-070M |  | FY07 Funds Available | 0d | 2006-10-02 | 2006-10-02 |  |  | 0d | mandatory start 2006-10-01 |
| 9-080M |  | FY08 Funds Available | 0d | 2007-10-01 | 2007-10-01 |  |  | 0d | mandatory start 2007-10-01 |
| 9-090M |  | FY09 Funds Available | 0d | 2008-10-01 | 2008-10-01 |  |  | 0d | mandatory start 2008-10-01 |
| 9-150M |  | End of R&D Funds | 0d | 2008-10-01 | 2008-10-01 | 1152040, 1135025, 1132831M, 1132875M, 11114070M, 1152035, 1154040, 1152055, 1154025, 1155005A, 1132897, 1132900, 1141015, 1141011, 1132865M, 1132815, 1132800M, 1154060, 1141005RKC, 117908LOE, 1152030, 1154045, 1114010, 1141005RKC5, 1154055, 1155020, 1132895, 1132905, 1132890M, 1142030, 1141012, 1154050, 1155010A, 1155025, 1155030, 1132851M |  | 0d | mandatory start 2008-10-01 |
| 9-100M |  | FY10 Funds Available | 0d | 2009-10-01 | 2009-10-01 | 15221190, 15221012A, 15221185, 15221310, 15221191, 14312010a, 14312010, 14312011, 14312002 |  | 0d | mandatory start 2009-10-01 |
| 9-110M |  | FY11 Funds Available | 0d | 2010-10-01 | 2010-10-01 | 15212075, 1102231000, 11022325000, 11022321000, 15222025, 11022324000, 15222110, 16223008, 11022322000, 15212070, 16331017, 11022323000 |  | 0d | mandatory start 2010-10-01 |
| 9-120M |  | FY12 Funds Available | 0d | 2011-10-03 | 2011-10-03 | 13322005, 1563030, 13325005, 13326005, 13323010, 13221010J, 1316010, 13324010, 13322006, 142211020a, 142213133a, 142211010a |  | 0d | mandatory start 2011-10-01 |
| 9-130M |  | FY13 Funds Available | 0d | 2012-10-01 | 2012-10-01 | 13222061, 13221125A, 132127040, 14212025, 13463012, 1563006, 14212012E, 14211085, 14211012E, 13224053, 13221021, 14212005sA, 13422065, 13223035A, 132122020f, 1563017a, 1563016, 1563025, 1563011, 14312034, 14324003a, 13221021A, 13221026, 13414028, 14321900a, 132121060f, 1321122210 |  | 0d | mandatory start 2012-10-01 |
| 9-140M |  | FY14 Funds Available | 0d | 2013-10-01 | 2013-10-01 | 1-5M, 1961010, 1622000, 16332055, 16331040, 16111035, 1131010, 1135030, 13447040, 13224055, 132124015, 132125025, 1331.07005, 13325020, 1351950, 131137055, 131115020, 13641950, 13642913LOE, 13643950, 1365950, 12226025, 1212113175, 1212112150, 121134025, 121135025, 12115010, 121641175, 121642175, 12131.10015, 12131.01010, 121441015, 181331005, 18223025, 182443025, 182432055, 1547125, 15231055, 15213010, 15213015, 15221182, 1562210, 1562225, 1562120, 1562690, 15311013E, 1532010a, 15512055, 15512120, 15511120, 14264308, 142241555, 142241255, 142241530, 142241560, 142211370, 142211870, 142211855, 142211800, 142211520, 142213342, 142231325, 142231005, 142231014, 142231265a, 142232620, 142232232, 142232640, 142232390, 142232227, 142223017, 142223120, 142223515, 14231030, 14233005, 14271085, 142762000, 142781000, 14243015, 14243005, 14247065, 14368333, 14368027, 14368510, 14342045, 14341070, 14341110, 14311086g, 14312913LOE, 14328010b, 14324005, 14324003, 14355035, 14132913LOE, 2-11M, 3C-08M, 16113035, 16122035, 171913LOEA, 13451950, 13222240, 13223130, 132122035, 132111914LOE, 1331.03005, 1331.01115, 13326020, 1312000, 131138070, 131131025, 131139030, 131133135, 131114135, 13643913LOE, 13611085, 13611950, 1362035M, 123211060, 123213015, 1243060, 1212127175, 121133025, 121138065, 121124025, 121121015, 121125025, 12165040, 121322005, 12131.11015, 121454020, 1813221000, 18223005, 18223015, 182446025, 182431010, 182432040, 182432000, 182432075, 182432045, 182432060, 182432070, 182432030, 182432005, 1546540, 1547205, 1547190, 1541120, 1541080, 1542055, 1544080, 15231015, 15231150, 15213001a, 1562140a, 1562345, 1562250, 1532013E, 1553110, 15511100, 142241647c, 142241375a, 142242225, 142242135a, 142242245, 142211020, 142211013E, 142213012E, 142231430a, 142231015, 142231330a, 142232655, 142232247, 142232615, 142232255, 14233075, 14273015, 14273020, 1427.10000, 14368383, 14362950, 14363035, 14364040, 14364055, 1433015, 14341090, 14341115a, 14341000, 14341050, 14314115, 14312005, 14312042, 14328005b, 14328010a, 14352000a, 14354030, 14355010, 14153025, 2-18M, 197111150, 195221505, 16112025, 16115025, 1152060, 1154065, 1114015, 117910, 110324000, 13417175, 13427185, 13421950, 13452055, 1331.08005, 1331.09005, 1331.02100, 13327005, 13322015, 1356950, 13613030, 13611913LOE, 13614950, 12332030, 12345010, 123511055, 1222242020, 122311060, 122152025, 1212123175, 1212121135B, 121131025, 121137025, 121116025, 121111015, 121613045, 12163175, 12152035, 12151025, 12154025, 12155055, 12131.04030, 12131.07020, 121414025, 121432010, 121433010, 121452025, 1811070, 18223000, 182446035, 182432010, 182432050, 1547115, 1548010, 1542013E, 15221057a, 15221160baa, 1562065, 1562255, 1562097, 1562370, 1531033, 1552010, 1552040, 1553017, 1553034a, 15512110a, 15512136, 15511110, 14264545, 14264998, 142242060, 142242165a, 142242125, 142211010, 142211430, 142211470, 142211110, 142211950, 142213322P, 142231013E, 142232305, 142232385, 142232665, 142232265, 142232320P, 142232025, 142223530, 14232030, 14231065, 14231125, 14234025, 14235020, 14271045, 142761000, 142771000, 14251010, 14247006, 14247035, 14365020, 14365055, 14363021b, 14364075, 14341015, 14341045, 14341030, 14321905, 14321015M, 14328015, 14325028, 14323015, 14323005a, 14351025, 14151040, 1951000, 16112035, 19010, 13444950, 13454060, 132127045, 1331.1010, 1315000, 13114025, 131301015, 131302015, 13641913LOE, 13613913LOE, 13611025, 1362950, 123212040, 123222035, 1241200, 122231025, 122254020, 122363025, 122312100, 1252910, 121223065, 121113015, 121115015, 121614040, 121416015, 121451060, 1811001, 18223030, 182443030, 182432085, 182432020, 157030, 1548015, 15231060, 15231120, 15212205, 15213010a, 15211255, 1561170, 1562135, 1562015M, 1562359, 1562393, 1531035, 1531105, 1531005ca, 1532077, 1532075c, 1532210, 1532065c, 1553020, 15512110, 15512170, 14212030, 142241415a, 142241565, 142241535, 142241305a, 142242175, 142211400a, 142211445, 142211115a, 142231275, 142231475, 142232234, 142232180, 142232635, 142232396, 142223022, 14271060, 14366025, 14366007, 14368280LOE, 14368120M, 14362070, 14363065, 14364080, 14341120, 14341095, 14341005, 14315045F, 14312032, 14313220, 14328005ba, 14328005a, 14322015, 14325027c, 14323005b, 14351005, 14353015, 14152030, 2-14M, 3P-08M, 19524000, 16115030, 16115050, 1155035, 111121010, 13416050, 13463055, 13426000, 13425035, 13456050, 13221023B, 13213025, 132123030, 1321122215, 132111950, 132113140, 1331.11005, 131116030, 131121050, 1363030a, 1363913LOE, 1366950, 1367060, 13611025c, 13614015, 1231000, 12353050, 1242045, 122325025, 1212122175, 1212125030, 1212126175, 121132025, 12114010, 121126025, 12153025, 121324005, 12131.05020, 121411120, 121421025, 121456020, 181321060, 182446030, 1546570, 1547195, 1547130, 1548040, 1542060, 1543115, 15231025, 15221057b, 15221160bb, 1562145, 1562413, 1531027, 1532067c, 1532075, 1553033, 1553095, 15512005a, 15512035, 14211095, 14264328, 14264204M, 142241395a, 142241345a, 142241595, 142241550, 142241575, 142242110, 142211160v, 142211105h, 142211540, 142211550, 142213220, 142232625, 142232605, 142232560, 142232525, 142223570, 142223319, 14271090, 14254030, 14241020, 14244040, 14366005, 14363060, 14342050, 14342060, 14341025, 14341100, 14341097, 14315046b, 14312025, 14312950, 14312050c, 14313P4LOE, 14328020, 14324010, 14324015, 14325030, 3R-1M, 195222290, 16333040, 16114035, 1121000, 13441015, 13435020, 13422130, 13221022b, 132121075, 1321121085, 1331.06005, 1353100, 1314000, 131135070, 131113000, 131111025, 13642950, 13613950, 13612950, 123221030, 122212050, 122151015, 1212111175, 121136025, 121114015, 12167030, 12156050, 121323005, 121325005, 12131.03025, 12131.06015, 12131.08010, 12131.09005, 121446010, 1831950, 181332005, 181315030, 18223010, 182446040, 182446005, 18241050, 182432025, 1548035, 15231013E, 15231030, 15231065, 15231002, 15213005, 15221315, 1562140, 1562675, 1562420, 1562275, 1531245, 1552050, 1553055, 1553035, 1553045, 1553060, 1553002, 15512013E, 14261000, 14263000, 142241400a, 142241472, 142241545, 142241382a, 142241405ba, 142241655, 142242215, 142242030, 142242195, 142211410, 142213042M, 142213330b, 142213360, 142232330a, 142232680, 142232295, 142743000, 142751000, 14242065, 14247025, 14365023, 14365035, 14365040, 14368265, 14364060, 14364045, 14364016, 14341060, 14315046, 14315105, 14311950, 14312015, 14312045, 14321910, 14328010ba, 14322020, 14325015, 14325027a, 14353020, 9-150M, 195212265, 1621035, 1132910, 1161000, 1112020, 172913LOE, 13433020, 13436070, 13414105, 13462020, 13458070, 13224115, 1331.12005, 13323025, 1355950, 131134025, 131136070, 131123035, 1363950, 13612913LOE, 13614020, 126085, 12361015, 123232040, 12333025, 122153015, 121221155, 1212121175, 121123015, 121444025, 121422000, 121424015, 18223020, 182443020, 1543142, 1545130, 15231045, 15221159b, 15222115, 1562610LOE, 1562475, 1562061, 1562125, 1563035, 1531140, 1531037, 1531100, 1532075ba, 15512100, 15512175, 14264375, 142241580, 142242165b, 142242010, 142211380, 142211160t, 142211535, 142211185, 142211890, 142213322, 142232370a, 142232650, 142232515, 142232610, 142232546, 142232660, 142232285, 142232555, 142232630, 14233007, 14271030, 14271075c, 142741000, 14252015, 14247005, 14366020, 14366030, 14367010, 14364065, 14364035, 14341075, 14341020a, 14341055, 14315100, 14315043, 14314030a, 14311072a, 143118P4LOE, 14312036, 14313280, 14321900, 14352010, 14354035, 14355015, 2-04M, 3R-06M, 195221510, 16112020a, 1142035, 1141025, 171950, 13446015, 13432020, 13411950, 13461055, 13221140, 13324020, 13321075, 1354950, 1352040, 1316015, 131132035, 131112000, 131122115, 1365913LOE, 12331015, 12224010, 122132015, 1251910, 121224070, 1212124175, 121122015, 12166040, 121611060, 121612040, 12162045, 121643175, 182446045, 182431000, 182432035, 182432015, 182432080, 182432065, 157045, 1548030, 1541150, 1541060, 1543150, 151255, 15231070, 15231020, 1562096, 1562013E, 1562090, 1562005LOE, 1531005c, 1531175, 1532015, 1553030, 1553013E, 15512050, 14264886, 14264202M, 142241410a, 142241527, 142241302, 142241600, 142241540, 142242155, 142242205, 142211130, 142213320, 142213242a, 142213320P, 142231420, 142231330b, 142232645, 142232010, 142232015, 142232690, 142223037, 142223575, 14231105, 14231095, 14271025Q, 142791000, 14365025, 14366010, 14368028, 14362065, 14363025, 14341035, 14341105, 14341010, 14341040, 14315037b, 14314100, 14312020, 14321900b, 14322010, 14322013, 14325010, 14325027b, 14323020, 14354025, 18223035, 182431015, 182432090 |  | 0d | mandatory start 2013-10-01 |
| 9-155M |  | FY15 Funds Available | 0d | 2014-10-01 | 2014-10-01 |  |  | 0d | mandatory start 2014-10-01 |
|  | 0 | **1.0 CONCEPTUAL & ADVANCED CONCEPTUAL DESIGN REVIEW ACTIVITIES** |  | 2006-10-02 | 2013-08-30 |  |  |  |  |
| 19001 |  | FY06 Obligations RKC (Oct-Dec 06) | 58d | 2006-10-02 | 2006-12-22 | 9-070M |  | 0d | finish on 2006-12-22 |
| 19002RKC |  | FY06 Obligations Exp over $50k RKC (Oct-Dec 06) | 58d | 2006-10-02 | 2006-12-22 | 9-070M |  | 0d | finish on 2006-12-22 |
| 19001RKC |  | FY06 Obligations RKC (Jan-Sep 06) | 189d | 2007-01-02 | 2007-09-28 | 19001 |  | 0d | mandatory start 2007-01-02 |
| 19005RKC |  | FY06 Obligations Exp over $50k RKC (Jan-Sep 06) | 189d | 2007-01-02 | 2007-09-28 | 19002RKC |  | 0d | mandatory start 2007-01-02 |
| 19010 |  | Re-Baseline Actuals Adjustment | 1d | 2013-08-30 | 2013-08-30 | 9-130M FS+227d |  | 20d |  |
|  | 1 | **1.0.1 ACCELERATOR SYSTEMS** |  |  |  |  |  |  |  |
|  | 1 | **1.0.1.1 CRYOMODULES** |  |  |  |  |  |  |  |
|  | 2 | **1.0.1.2 POWER SYSTEMS** |  |  |  |  |  |  |  |
|  | 3 | **1.0.1.3 CRYOGENICS** |  |  |  |  |  |  |  |
|  | 4 | **1.0.1.4 BEAM TRANSPORT** |  |  |  |  |  |  |  |
|  | 5 | **1.0.1.5 EXTRACTION** |  |  |  |  |  |  |  |
|  | 6 | **1.0.1.6 INSTRUMENTATION, CONTROLS, & SAFETY SYSTEMS** |  |  |  |  |  |  |  |
|  | 2 | **1.0.2 HALLS A. B, & C** |  |  |  |  |  |  |  |
|  | 1 | **1.0.2.1 HALL A** |  |  |  |  |  |  |  |
|  | 2 | **1.0.2.2 HALL B** |  |  |  |  |  |  |  |
|  | 3 | **1.0.2.3 HALL C** |  |  |  |  |  |  |  |
|  | 3 | **1.0.3 HALL D** |  |  |  |  |  |  |  |
|  | 4 | **1.0.4 CIVIL** |  |  |  |  |  |  |  |
|  | 1 | **1.1 R&D** |  | 2006-10-02 | 2013-08-30 |  |  |  |  |
|  | 1 | **1.1.1 ACCELERATOR SYSTEMS** |  | 2006-10-02 | 2013-08-30 |  |  |  |  |
|  | 1 | **1.1.1.1 CRYOMODULES** |  | 2006-10-02 | 2013-08-30 |  |  |  |  |
|  | 1 | **1.1.1.1.1 FY06/07 R&D Plan** |  | 2006-10-02 | 2007-04-11 |  |  |  |  |
| 11111005RKC |  | FY06 Obligations RKC | 120d | 2006-10-02 | 2007-03-30 | 9-070M |  | 333d |  |
| 11111000M |  | 12 GeV R&D & CDs (Finish 1 Month Later) (R&D PLAN) | 0d | 2007-04-11 | 2007-04-11 | 111123015 |  | 56d |  |
|  | 1 | **1.1.1.1.1.1 R1 Testing in FEL** |  |  |  |  |  |  |  |
|  | 2 | **1.1.1.1.1.2 RF Window** |  |  |  |  |  |  |  |
|  | 3 | **1.1.1.1.1.3 Cavity Processing** |  |  |  |  |  |  |  |
|  | 4 | **1.1.1.1.1.4 Tuner** |  |  |  |  |  |  |  |
|  | 2 | **1.1.1.1.2 Post R1 Plan** |  | 2006-10-02 | 2013-08-30 |  |  |  |  |
|  | 1 | **1.1.1.1.2.1 Cavity** |  | 2006-10-02 | 2013-08-30 |  |  |  |  |
| 111121000 |  | Fab. C100 Niobium Cavities x 2 (CAVITY) | 11d | 2006-10-02 | 2006-10-16 | 9-070M |  | 34d |  |
| 111121005M |  | Cavity Fabrication Complete (Finish 9/29/06) (CAVITY) | 0d | 2006-10-16 | 2006-10-16 | 111121000 |  | 34d |  |
| 111121010 |  | Re-Baseline Actuals Adjustment | 1d | 2013-08-30 | 2013-08-30 | 9-130M FS+227d |  | 20d |  |
|  | 2 | **1.1.1.1.2.2 Power Coupler** |  | 2006-10-02 | 2007-01-02 |  |  |  |  |
| 111122000 |  | Fabricate FPC for HTB Testing (PWR CPLR) | 59d | 2006-10-02 | 2007-01-02 | 9-070M |  | 13d |  |

| ID | WBS | Task | Duration | Start | Finish | Predecessors | Total float | Constraint |
| --- | --- | --- | --- | --- | --- | --- | --- | --- |
| 111122005M |  | Power Coupler Prototype Fab Complete (PWR CPLR) | 0d | 2007-01-02 | 2007-01-02 | 111122000 | 13d |  |
|  | 3 | **1.1.1.1.2.3 Evaluation** |  | 2006-10-17 | 2007-04-11 |  |  |  |
| 111123000 |  | Conduct VTA Test C100 Cavities (EVALUATION) | 47d | 2006-10-17 | 2006-12-22 | 111121005M, 111121000 | 34d |  |
| 111123005 |  | Conduct Integrated Test in HTB (EVALUATION) | 30d | 2007-02-01 | 2007-03-15 | 111122005M FS+20d, 111124000, 111123000 | 13d |  |
| 111123010M |  | Integrated Testing Complete (EVALUATION) | 0d | 2007-03-15 | 2007-03-15 | 111123005 | 13d |  |
| 111123015 |  | 1/4 Cryomodule CR Accounting Change Request (Finish by 4/30/07) | 19d | 2007-03-16 | 2007-04-11 | 111123010M | 13d | finish on or before 2007-04-30 |
|  | 4 | **1.1.1.1.2.4 Tuner** |  | 2006-10-17 | 2006-12-15 |  |  |  |
| 111124000 |  | Procure Prototype Components (TUNER) | 42d | 2006-10-17 | 2006-12-15 | 111121000 | 39d |  |
|  | 3 | **1.1.1.1.3 Critical Decisions** |  |  |  |  |  |  |
|  | 1 | **1.1.1.1.3.1 CD2A** |  |  |  |  |  |  |
|  | 2 | **1.1.1.1.3.2 CD2B** |  |  |  |  |  |  |
|  | 3 | **1.1.1.1.3.3 CD3A** |  |  |  |  |  |  |
|  | 4 | **1.1.1.1.3.4 CD3B** |  |  |  |  |  |  |
|  | 5 | **1.1.1.1.3.5 CD4** |  |  |  |  |  |  |
|  | 4 | **1.1.1.1.4 HOM MEASUREMENTS** |  | 2008-03-13 | 2008-07-11 |  |  |  |
| 11114000 |  | Prepare for HTB test | 16d | 2008-03-13 | 2008-04-03 | 9-080M FS+107d | 56.5d |  |
| 11114005 |  | Procure/fabricate/modify HOM hardware | 13.5d | 2008-03-24 | 2008-04-10 | 11114000 FS-9d | 56.5d |  |
| 11114010 |  | Assemble HTB | 6d | 2008-04-10 | 2008-04-18 | 11114005 | 56.5d |  |
| 11114015M |  | HTB Assembly Completed | 0d | 2008-04-18 | 2008-04-18 | 11114010 | 56.5d |  |
| 11114020 |  | Install into CMTF/Cooldown | 5d | 2008-04-18 | 2008-04-25 | 11114015M | 56.5d |  |
| 11114025 |  | Perform HOM measurements in HTB | 5d | 2008-04-25 | 2008-05-02 | 11114020 | 56.5d |  |
| 11114030M |  | Q's measured and analyzed Completed | 0d | 2008-05-02 | 2008-05-02 | 11114025 | 56.5d |  |
| 11114035 |  | Perform thermal measurements | 5d | 2008-05-02 | 2008-05-09 | 11114030M | 56.5d |  |
| 11114045 |  | Data Analysis | 14d | 2008-05-09 | 2008-05-30 | 11114035 | 56.5d |  |
| 11114050M |  | Interim report Completed | 0d | 2008-05-09 | 2008-05-09 | 11114035 | 80.5d |  |
| 11114040 |  | WarmUp & Disassemble | 10d | 2008-05-30 | 2008-06-13 | 11114045 | 56.5d |  |
| 11114055 |  | VTA tests: prep and execution | 14.5d | 2008-06-13 | 2008-07-03 | 11114050M, 11114040 | 56.5d |  |
| 11114060 |  | Disassemble and store components | 4.5d | 2008-07-07 | 2008-07-11 | 11114055 | 56.5d |  |
| 11114065 |  | Data Analysis | 4.5d | 2008-07-07 | 2008-07-11 | 11114055 | 56.5d |  |
| 11114070M |  | Final Report and All Tasks Completed | 0d | 2008-07-11 | 2008-07-11 | 11114060, 11114065 | 56.5d |  |
|  | 5 | **1.1.1.1.5 WAVEGUIDE FUNDAMENTAL POWER COUPLER TESTS** |  | 2008-06-02 | 2008-12-18 |  |  |  |
| 11115000 |  | Developement of Documentation & Detail Plans | 20d | 2008-06-02 | 2008-06-27 | 9-080M FS+163d | 368d |  |
| 11115005 |  | Vendor Fab 15 Waveguide Fundamental Power Couplers | 120d | 2008-06-30 | 2008-12-18 | 11115000 | 368d |  |
|  | 2 | **1.1.1.2 POWER SYSTEMS** |  | 2007-03-15 | 2013-08-30 |  |  |  |
| 1112000 |  | Conduct Interlock Check Out (POWER SYSTEMS) | 10d | 2007-03-15 | 2007-03-28 | 9-070M FS+108d | 269d |  |
| 1112005 |  | Conduct RF - Cavity System Tests (POWER SYSTEMS) | 44d | 2007-04-16 | 2007-06-15 | 1112000 FS+12d | 269d |  |
| 1112010 |  | Report Writing (POWER SYSTEMS) | 13d | 2007-05-30 | 2007-06-15 | 1112005 FS-13d | 269d |  |
| 1112015M |  | Report sent to DOE (POWER SYSTEMS) | 0d | 2007-06-29 | 2007-06-29 | 1112010 FS+10d | 269d |  |
| 1112020 |  | Re-Baseline Actuals Adjustment | 1d | 2013-08-30 | 2013-08-30 | 9-130M FS+227d | 20d |  |
|  | 3 | **1.1.1.3 CRYOGENICS** |  |  |  |  |  |  |
|  | 4 | **1.1.1.4 BEAM TRANSPORT** |  | 2007-11-01 | 2013-08-30 |  |  |  |
| 1114000 |  | Fabricate QP and QR Laminations | 62d | 2007-11-01 | 2008-02-08 | 9-080M FS+23d | 78d |  |
| 1114005 |  | Fabricate Coils and Assemble magnets | 81d | 2007-12-03 | 2008-04-04 | 1114000 FS-42d | 78d |  |
| 1114010 |  | Test and measure QP and QR | 60d | 2008-03-18 | 2008-06-10 | 1114005 FS-14d | 78d |  |
| 1114015 |  | Re-Baseline Actuals Adjustment | 1d | 2013-08-30 | 2013-08-30 | 9-130M FS+227d | 20d |  |
|  | 5 | **1.1.1.5 EXTRACTION** |  |  |  |  |  |  |
|  | 6 | **1.1.1.6 INSTRUMENTATION, CONTROLS, & SAFETY SYSTEMS** |  |  |  |  |  |  |
|  | 2 | **1.1.2 HALL A** |  | 2013-08-30 | 2013-08-30 |  |  |  |
|  | 1 | **1.1.2.1 MAGNET** |  | 2013-08-30 | 2013-08-30 |  |  |  |
| 1121000 |  | Re-Baseline Actuals Adjustment | 1d | 2013-08-30 | 2013-08-30 | 9-130M FS+227d | 20d |  |
|  | 2 | **1.1.2.2 DETECTOR** |  |  |  |  |  |  |
|  | 3 | **1.1.2.3 COMPUTING** |  |  |  |  |  |  |
|  | 4 | **1.1.2.4 ELECTRONICS** |  |  |  |  |  |  |
|  | 5 | **1.1.2.5 BEAMLINE** |  |  |  |  |  |  |
|  | 6 | **1.1.2.6 INFRASTRUCTURE** |  |  |  |  |  |  |
|  | 3 | **1.1.3 HALL B** |  | 2006-10-02 | 2013-08-30 |  |  |  |
|  | 1 | **1.1.3.1 TORUS MAGNET R&D** |  | 2007-06-18 | 2013-08-30 |  |  |  |
| 1131005 |  | Conduct SC Magnet Cable Testing | 20d | 2007-06-18 | 2007-07-16 | 9-070M FS+174d | 162d |  |
| 1131010 |  | Re-Baseline Actuals Adjustment | 1d | 2013-08-30 | 2013-08-30 | 9-130M FS+227d | 20d |  |
|  | 2 | **1.1.3.2 DETECTOR R&D** |  | 2006-10-02 | 2013-08-30 |  |  |  |
| 1132021RKC |  | FY06 Obligations RKC | 120d | 2006-10-02 | 2007-03-30 | 9-070M | 333d |  |
| 1132026M |  | FY07-HTCC -R&D Plans & Initial Safety Assessment (DTCTR R&D) | 0d | 2006-10-02 | 2006-10-02 | 9-070M | 1d |  |
| 1132028 |  | FY07-HTCC - Testing of the prototype (DTCTR R&D) | 61d | 2006-10-02 | 2007-01-04 | 1132026M | 1d |  |
| 1132033M |  | FY07-EC -R&D Plans & Initial Safety Assessment (DTCTR R&D) | 0d | 2006-10-02 | 2006-10-02 | 9-070M | 1d |  |
| 1132035 |  | FY07-EC - Fullscale prototype design (DTCTR R&D) | 79d | 2006-10-02 | 2007-01-31 | 1132033M | 1d |  |
| 1132054M |  | FY07-DC Plans & Initial Safety Assessment (DTCTR R&D) | 0d | 2006-10-02 | 2006-10-02 | 9-070M | 1d |  |
| 1132055 |  | FY07-DC - Mechanical protoptyping (DTCTR R&D) | 125d | 2006-10-02 | 2007-04-06 | 1132054M | 1d |  |
| 1132060 |  | FY07-DC - Electrical prototyping (DTCTR R&D) | 125d | 2006-10-02 | 2007-04-06 | 9-070M | 1d |  |
| 1132069M |  | FY07-FTOF -R&D Plans & Initial Safety Assessment (DTCTR R&D) | 0d | 2006-10-02 | 2006-10-02 | 9-070M | 1d |  |
| 1132070 |  | FY07-FTOF - Building the prototype (DTCTR R&D) | 98d | 2006-10-02 | 2007-02-28 | 1132069M | 1d |  |

| ID | WBS | Task | Duration | Start | Finish | Predecessors | Total float | Constraint |
| --- | --- | --- | --- | --- | --- | --- | --- | --- |
| 1132079M |  | FY07-CTOF -R&D Plans & Initial Safety Assessment (DTCTR R&D) | 0d | 2006-10-02 | 2006-10-02 | 9-070M | 1d |  |
| 1132080 |  | FY07-CTOF - Design of the prototype (DTCTR R&D) | 55d | 2006-10-02 | 2006-12-19 | 1132079M | 1d |  |
| 1132094M |  | FY07-SVT -R&D Plans & Initial Safety Assessment (DTCTR R&D) | 0d | 2006-10-02 | 2006-10-02 | 9-070M | 1d |  |
| 1132095 |  | FY07-SVT - prototyping (DTCTR R&D) | 125d | 2006-10-02 | 2007-04-06 | 1132094M | 1d |  |
| 1132085 |  | FY07-CTOF - Building the prototype (DTCTR R&D) | 67d | 2006-12-20 | 2007-04-03 | 1132080 | 1d |  |
| 1132030 |  | FY07-HTCC - Analysis of the prototype (DTCTR R&D) | 186d | 2007-01-05 | 2007-09-28 | 1132028 | 1d |  |
| 1132045 |  | FY07-EC - Manufacturing the box and fixtures for the full scale protoptye (DTCTR R&D) | 65d | 2007-02-01 | 2007-05-03 | 1132035 | 1d |  |
| 1132075 |  | FY07-FTOF - Testing and data analysis from the prototype (DTCTR R&D) | 149d | 2007-03-01 | 2007-09-28 | 1132070 | 1d |  |
| 1132090 |  | FY07-CTOF - Testing of the prototype (DTCTR R&D) | 125d | 2007-04-04 | 2007-09-28 | 1132085, 1132080 | 1d |  |
| 1132065 |  | FY07-DC - Testing & analysis of the prototype (DTCTR R&D) | 122d | 2007-04-09 | 2007-09-28 | 1132055, 1132060 | 1d |  |
| 1132100 |  | FY07-SVT - testing of the prototype (DTCTR R&D) | 122d | 2007-04-09 | 2007-09-28 | 1132095 | 1d |  |
| 1132050 |  | FY07-EC - Assembly & testing of the protoptype (DTCTR R&D) | 103d | 2007-05-04 | 2007-09-28 | 1132045 | 1d |  |
| 1132030M |  | FY07-HTCC -R&D Report (DTCTR R&D) | 0d | 2007-09-28 | 2007-09-28 | 1132030 | 1d |  |
| 1132050M |  | FY07-EC -R&D Report (DTCTR R&D) | 0d | 2007-09-28 | 2007-09-28 | 1132050 | 1d |  |
| 1132065M |  | FY07-DC -R&D Report (DTCTR R&D) | 0d | 2007-09-28 | 2007-09-28 | 1132065 | 1d |  |
| 1132075M |  | FY07-FTOF -R&D Report (DTCTR R&D) | 0d | 2007-09-28 | 2007-09-28 | 1132075 | 1d |  |
| 1132090M |  | FY07-CTOF-R&D Report (DTCTR R&D) | 0d | 2007-09-28 | 2007-09-28 | 1132090 | 1d |  |
| 1132100M |  | FY07-SVT -R&D Report (DTCTR R&D) | 0d | 2007-09-28 | 2007-09-28 | 1132100 | 1d |  |
| 1132805 |  | FY08-EC - Fullscale Proto Dsgn (DETCTR R&D) | 79d | 2007-10-01 | 2008-01-31 | 1132834M, 1132050M | 1d |  |
| 1132820 |  | FY08-DC - Mech protoptyping (DETCTR R&D) | 125d | 2007-10-01 | 2008-04-07 | 1132065M, 1132854M | 1d |  |
| 1132825 |  | FY08-DC - Elect Prototypng (DETCTR R&D) | 125d | 2007-10-01 | 2008-04-07 | 1132065M | 1d |  |
| 1132827M |  | FY08-HTCC -R&D Plans & Initl Sfty Assessmnt (DETCTR R&D) | 0d | 2007-10-01 | 2007-10-01 | 9-080M, 1132030M | 1d |  |
| 1132829 |  | FY08-HTCC - Testing of Proto (DETCTR R&D) | 61d | 2007-10-01 | 2008-01-04 | 1132827M | 1d |  |
| 1132834M |  | FY08-EC -R&D Plans & Initl Sfty Assessmnt (DETCTR R&D) | 0d | 2007-10-01 | 2007-10-01 | 9-080M | 1d |  |
| 1132835 |  | FY08-FTOF - Fab Proto (DETCTR R&D) | 98d | 2007-10-01 | 2008-02-28 | 1132869M | 1d |  |
| 1132845 |  | FY08-CTOF - Dsgn of Proto (DETCTR R&D) | 55d | 2007-10-01 | 2007-12-18 | 1132879M | 1d |  |
| 1132854M |  | FY08-DC Plans & Initl Sfty Assessmnt (DETCTR R&D) | 0d | 2007-10-01 | 2007-10-01 | 9-080M | 1d |  |
| 1132860 |  | FY08-SVT - Prototypng (DETCTR R&D) | 125d | 2007-10-01 | 2008-04-07 | 1132894M | 1d |  |
| 1132869M |  | FY08-FTOF -R&D Plans & Initl Sfty Assessmnt (DETCTR R&D) | 0d | 2007-10-01 | 2007-10-01 | 1132075M | 1d |  |
| 1132879M |  | FY08-CTOF -R&D Plans & Initl Sfty Assessmnt (DETCTR R&D) | 0d | 2007-10-01 | 2007-10-01 | 1132090M | 1d |  |
| 1132894M |  | FY08-SVT -R&D Plans & Initl Sfty Assessmnt (DETCTR R&D) | 0d | 2007-10-01 | 2007-10-01 | 1132100M | 1d |  |
| 1132895 |  | FY08-DC- Protoype Testing & Data Analysis (DETCTR R&D) | 150d | 2007-10-01 | 2008-05-12 | 9-080M, 1132894M | 56d |  |
| 1132897 |  | FY08-SVT- Protoype Testing & Data Analysis (DETCTR R&D) | 150d | 2007-10-01 | 2008-05-12 | 1132894M, 9-080M | 98d |  |
| 1132850 |  | FY08-CTOF - Fab Proto (DETCTR R&D) | 67d | 2007-12-19 | 2008-04-02 | 1132845 | 1d |  |
| 1132841 |  | FY08-HTCC - Analysis of Proto (DETCTR R&D) | 186d | 2008-01-07 | 2008-09-29 | 1132829 | 1d |  |
| 1132810 |  | FY08-EC - Manufacturing Box & Fixtures for Full Scale Proto (DETCTR R&D) | 65d | 2008-02-01 | 2008-05-02 | 1132805 | 1d |  |
| 1132840 |  | FY08-FTOF - Testing & Data Analysis from Proto (DETCTR R&D) | 149d | 2008-02-29 | 2008-09-29 | 1132835 | 1d |  |
| 1132900 |  | SVT Readout (DETCTR R&D) | 128d | 2008-04-01 | 2008-09-30 | 9-080M FS+120d | 0d |  |
| 1132905 |  | CTOF PMT's & Mag Sheild Tests (DETCTR R&D) | 128d | 2008-04-01 | 2008-09-30 | 9-080M FS+120d | 0d |  |
| 1132855 |  | FY08-CTOF - Testing of Proto (DETCTR R&D) | 125d | 2008-04-03 | 2008-09-29 | 1132845, 1132850 | 1d |  |
| 1132830 |  | FY08-DC - Testing & Analysis of Proto (DETCTR R&D) | 122d | 2008-04-08 | 2008-09-29 | 1132825, 1132820 | 1d |  |
| 1132865 |  | FY08-SVT - Testing of Proto (DETCTR R&D) | 122d | 2008-04-08 | 2008-09-29 | 1132860 | 1d |  |
| 1132815 |  | FY08-EC - Assy & Testing of protoptype (DETCTR R&D) | 103d | 2008-05-05 | 2008-09-29 | 1132810 | 1d |  |
| 1132800M |  | FY08-SVT -R&D Report (DETCTR R&D) | 0d | 2008-09-29 | 2008-09-29 | 1132865 | 1d |  |
| 1132831M |  | FY08-HTCC -R&D Report (DETCTR R&D) | 0d | 2008-09-29 | 2008-09-29 | 1132841 | 1d |  |
| 1132851M |  | FY08-EC -R&D Report (DETCTR R&D) | 0d | 2008-09-29 | 2008-09-29 | 1132815 | 1d |  |
| 1132865M |  | FY08-DC -R&D Report (DETCTR R&D) | 0d | 2008-09-29 | 2008-09-29 | 1132830 | 1d |  |
| 1132875M |  | FY08-FTOF -R&D Report (DETCTR R&D) | 0d | 2008-09-29 | 2008-09-29 | 1132840 | 1d |  |
| 1132890M |  | FY08-CTOF-R&D Report (DETCTR R&D) | 0d | 2008-09-29 | 2008-09-29 | 1132855 | 1d |  |
| 1132910 |  | Re-Baseline Actuals Adjustment | 1d | 2013-08-30 | 2013-08-30 | 9-130M FS+227d | 20d |  |
|  | 3 | **1.1.3.3 COMPUTING R&D** |  |  |  |  |  |  |
|  | 4 | **1.1.3.4 ELECTRONICS** |  |  |  |  |  |  |
|  | 5 | **1.1.3.5 BEAMLINE** |  | 2006-10-02 | 2013-08-30 |  |  |  |
| 1135010 |  | BL - Conduct rates studies and beam line optimization at HTCC (BEAMLINE) | 125d | 2006-10-02 | 2007-04-06 | 9-070M | 203d |  |
| 1135015 |  | BL - Conduct rates studies and optimization of the beam line at FDC (BEAMLINE) | 149d | 2006-10-02 | 2007-05-10 | 9-070M | 179d |  |
| 1135020M |  | BL -R&D Report (BEAMLINE) | 0d | 2007-05-11 | 2007-05-11 | 1135010, 1135015 | 179d |  |
| 1135025 |  | BL- Rates Studies & Beam Line Optimztn of Forward Detctr | 125d | 2008-01-02 | 2008-06-27 | 1135020M, 9-080M FS+58d | 23d |  |
| 1135030 |  | Re-Baseline Actuals Adjustment | 1d | 2013-08-30 | 2013-08-30 | 9-130M FS+227d | 20d |  |
|  | 6 | **1.1.3.6 INFRASTRUCTURE** |  |  |  |  |  |  |
|  | 4 | **1.1.4 HALL C** |  | 2006-10-02 | 2013-08-30 |  |  |  |
|  | 1 | **1.1.4.1 MAGNET** |  | 2006-10-02 | 2013-08-30 |  |  |  |
| 1141005RKC |  | FY06 Obligations RKC | 120d | 2006-10-02 | 2007-03-30 | 9-070M | 333d |  |
| 1141015 |  | Build a Test Device to Measure Heat Distribution at the HB Magnet | 163d | 2006-10-02 | 2007-05-31 | 9-070M | 100d |  |
| 1141020 |  | Cable reshaping and testing for HB and Q1 magnets | 129d | 2006-10-02 | 2007-04-12 | 9-070M | 134d |  |
| 1141010 |  | Design a scale cross section model of the HB magnet FY 07 | 84d | 2007-06-01 | 2007-09-28 | 9-070M | 0d | start on or after 2007-06-01 |
| 1141011 |  | Design a scale cross section model of the HB magnet FY 08 | 142d | 2007-10-01 | 2008-04-30 | 1141010 | 86d |  |
| 1141013 |  | Prepare Tooling for Coil Winding & Wind Several Subcoils for the HB Magnet | 99d | 2007-12-03 | 2008-04-30 | 1141010 FS+43d | 0d |  |
| 1141012 |  | Fab 1 full HB Coil & Test Mech, Elect & Insulation Properities @ Room Temp | 106d | 2008-05-01 | 2008-09-30 | 1141010, 1141013 | 0d |  |
| 1141025 |  | Re-Baseline Actuals Adjustment | 1d | 2013-08-30 | 2013-08-30 | 9-130M FS+227d | 20d |  |
|  | 2 | **1.1.4.2 DETECTOR** |  | 2006-10-02 | 2013-08-30 |  |  |  |

| ID | WBS | Task | Duration | Start | Finish | Predecessors | Total float | Constraint |
| --- | --- | --- | --- | --- | --- | --- | --- | --- |
| 1141005RKC5 |  | FY06 Obligations RKC | 120d | 2006-10-02 | 2007-03-30 | 9-070M | 333d |  |
| 1142020 |  | Continue exploration of alternative calorimeter designs (DTCTR) | 195d | 2006-10-02 | 2007-07-17 | 9-070M | 425d |  |
| 1142025 |  | In beam test of new prototype quartz hodoscope (DTCTR) | 130d | 2006-10-02 | 2007-04-13 | 9-070M | 353d |  |
| 1142030 |  | Test Blocks & PMT's and Map Out Optmal Placement (DTCTR) | 65d | 2008-04-08 | 2008-07-09 | 9-080M FS+125d | 58d |  |
| 1142035 |  | Re-Baseline Actuals Adjustment | 1d | 2013-08-30 | 2013-08-30 | 9-130M FS+227d | 20d |  |
|  | 3 | **1.1.4.3 COMPUTING** |  |  |  |  |  |  |
|  | 4 | **1.1.4.4 ELECTRONICS** |  |  |  |  |  |  |
|  | 5 | **1.1.4.5 BEAMLINE** |  |  |  |  |  |  |
|  | 6 | **1.1.4.6 INFRASTRUCTURE** |  |  |  |  |  |  |
|  | 5 | **1.1.5 HALL D** |  | 2006-10-02 | 2013-08-30 |  |  |  |
|  | 1 | **1.1.5.1 MAGNET** |  |  |  |  |  |  |
|  | 2 | **1.1.5.2 DETECTOR** |  | 2006-10-02 | 2013-08-30 |  |  |  |
| 1152001RKC |  | FY06 Obligations RKC | 120d | 2006-10-02 | 2007-03-30 | 9-070M | 333d |  |
| 1152005 |  | Drift chamber prototyping (DTCTR) | 80d | 2006-10-02 | 2007-02-01 | 9-070M | 206d |  |
| 1152010 |  | BCAL prototyping (DTCTR) | 80d | 2006-10-02 | 2007-02-01 | 9-070M | 462d |  |
| 1152015LOE |  | BCAL postdoc (DTCTR) | 79d | 2006-10-02 | 2007-02-01 | 9-070M | 591d |  |
| 1152020 |  | UPV prototyping (DTCTR) | 247d | 2006-10-02 | 2007-09-28 | 9-070M | 353d |  |
| 1152025 |  | CER prototyping (DTCTR) | 79d | 2006-10-02 | 2007-02-01 | 9-070M | 354d |  |
| 1152015LOEA |  | BCAL postdoc (DTCTR) | 40d | 2007-02-01 | 2007-03-30 | 1152015LOE | 591d | start on or after 2007-02-01 |
| 1152025A |  | CER prototyping (DTCTR) | 167d | 2007-02-01 | 2007-09-28 | 1152025 | 354d | start on or after 2007-02-01 |
| 1152005A |  | Drift chamber prototyping (DTCTR) | 167d | 2007-02-02 | 2007-09-28 | 1152005 | 206d | start on or after 2007-02-02 |
| 1152010A |  | BCAL prototyping (DTCTR) | 168d | 2007-02-02 | 2007-10-01 | 1152010 | 462d | start on or after 2007-02-02 |
| 1152040 |  | BCAL Evaluation & Testing of Module 2 (H-D DETCTR) | 115d | 2007-10-01 | 2008-03-24 | 9-080M | 42d |  |
| 1152945LOE |  | FY08 UPV University Supprt (H-D DETCTR) | 248d | 2007-10-01 | 2008-09-30 | 9-080M | 0d |  |
| 1152030 |  | FY08 DC Chamb Prototypng (H-D DETCTR) | 220d | 2007-11-07 | 2008-09-29 | 9-080M FS+27d | 1d |  |
| 1152035 |  | CDC University Supprt (H-D DETCTR) | 220d | 2007-11-07 | 2008-09-29 | 9-080M FS+27d | 1d |  |
| 1152055 |  | Invstg common solutn for Gain Monitrng/Calibr Sys in H-D for Calirim's & TOF | 149d | 2008-03-03 | 2008-09-30 | 9-080M FS+99d | 0d |  |
| 1152060 |  | Re-Baseline Actuals Adjustment | 1d | 2013-08-30 | 2013-08-30 | 9-130M FS+227d | 20d |  |
|  | 3 | **1.1.5.3 COMPUTING** |  |  |  |  |  |  |
|  | 4 | **1.1.5.4 ELECTRONICS** |  | 2006-10-02 | 2013-08-30 |  |  |  |
| 1154001RKC |  | FY06 Obligations RKC | 120d | 2006-10-02 | 2007-03-30 | 9-070M | 333d |  |
| 1154005 |  | FADC development (ELCTRNICS) | 79d | 2006-10-02 | 2007-02-01 | 9-070M | 114d |  |
| 1154010 |  | Trigger development (ELCTRNICS) | 79d | 2006-10-02 | 2007-02-01 | 9-070M | 454d |  |
| 1154005A |  | FADC development (ELCTRNICS) | 167d | 2007-02-02 | 2007-09-28 | 1154005 | 113d | start on or after 2007-02-02 |
| 1154010A |  | Trigger development (ELCTRNICS) | 167d | 2007-02-02 | 2007-09-28 | 1154010 | 453d | start on or after 2007-02-02 |
| 1154015 |  | Logic & HV Supprt (Electrnc's) | 220d | 2007-10-01 | 2008-08-20 | 9-080M | 3d |  |
| 1154020 |  | Develop a Clock Distrbtn Sys to FADC Boards (Electrnc's) | 65d | 2007-10-01 | 2008-01-10 | 9-080M | 23d |  |
| 1154025 |  | Develop Clock Distrbtn for TDCs (Electrnc's) | 130d | 2007-10-01 | 2008-04-14 | 9-080M | 76d |  |
| 1154035 |  | Collection of Track Counts into Trigger (Electrnc's) | 130d | 2007-10-01 | 2008-04-14 | 9-080M | 3d |  |
| 1154045 |  | Develop Signal Distrbtn to All Crates (Electrnc's) | 130d | 2007-10-01 | 2008-04-14 | 9-080M | 118d |  |
| 1154050 |  | Evaluate Backplane Use of Crates for Dataways, especially FADCs (Electrnc's) | 130d | 2007-10-01 | 2008-04-14 | 9-080M | 118d |  |
| 1154030 |  | Collection of Energy Sums into Trigger (Electrnc's) | 130d | 2008-01-11 | 2008-07-16 | 1154020, 9-080M | 23d |  |
| 1154040 |  | Proto Dsgn for Master Trigger (Electrnc's) | 130d | 2008-03-25 | 2008-09-25 | 9-080M, 1154035 FS-15d, 1154030 FS-100d | 3d |  |
| 1154055 |  | Specify HV & Low Voltage Supplies (Electrnc's) | 65d | 2008-06-25 | 2008-09-25 | 1154015 FS-40d | 3d |  |
| 1154060 |  | Specify Discriminators & Logic for DAQ/Trigger Integration (Electrnc's) | 65d | 2008-06-25 | 2008-09-25 | 1154015 FS-40d | 3d |  |
| 1154065 |  | Re-Baseline Actuals Adjustment | 1d | 2013-08-30 | 2013-08-30 | 9-130M FS+227d | 20d |  |
|  | 5 | **1.1.5.5 BEAMLINE** |  | 2006-10-02 | 2013-08-30 |  |  |  |
| 1155001RKC |  | FY06 Obligations RKC | 120d | 2006-10-02 | 2007-03-30 | 9-070M | 333d |  |
| 1155005 |  | Hodoscope prototyping (BEAMLINE) | 79d | 2006-10-02 | 2007-02-01 | 9-070M | 174d |  |
| 1155010 |  | Conduct Diamond studies (BEAMLINE) | 80d | 2006-10-02 | 2007-02-01 | 9-070M | 133d |  |
| 1155005A |  | Hodoscope prototyping (BEAMLINE) | 167d | 2007-02-02 | 2007-09-28 | 1155005 | 173d | start on or after 2007-02-02 |
| 1155010A |  | Conduct Diamond studies (BEAMLINE) | 167d | 2007-02-02 | 2007-09-28 | 1155010 | 133d |  |
| 1155015 |  | Proto SiPM Readout for Microscope (BL) | 60d | 2007-10-01 | 2008-01-03 | 9-080M | 86d |  |
| 1155025 |  | Proto Mounting Schemes for Thin Crystals (BL) | 60d | 2007-10-01 | 2008-01-03 | 9-080M | 146d |  |
| 1155030 |  | Check Current Sensitivity of Active Collimator Electrnc's (BL) | 60d | 2007-10-01 | 2008-01-03 | 9-080M | 146d |  |
| 1155020 |  | Proto Microscope Mounting Frame (BL) | 60d | 2008-01-04 | 2008-03-31 | 1155015 | 86d |  |
| 1155035 |  | Re-Baseline Actuals Adjustment | 1d | 2013-08-30 | 2013-08-30 | 9-130M FS+227d | 20d |  |
|  | 6 | **1.1.5.6 INFRASTRUCTURE** |  |  |  |  |  |  |
|  | 7 | **1.1.5.7 CRYOGENICS** |  |  |  |  |  |  |
|  | 6 | **1.1.6 CIVIL** |  | 2013-08-30 | 2013-08-30 |  |  |  |
|  | 1 | **1.1.6.1 HALL D** |  | 2013-08-30 | 2013-08-30 |  |  |  |
| 1161000 |  | Re-Baseline Actuals Adjustment | 1d | 2013-08-30 | 2013-08-30 | 9-130M FS+227d | 20d |  |
|  | 7 | **1.1.7 R&D PROJECT MANAGEMENT** |  | 2006-10-02 | 2013-08-30 |  |  |  |
| 117000LOE |  | FY07 R&D Project Management | 247d | 2006-10-02 | 2007-09-28 | 9-070M | 0d |  |
| 117908LOE |  | FY08 R&D Project Management | 248d | 2007-10-01 | 2008-09-30 | 117000LOE | 0d |  |
| 117910 |  | Re-Baseline Actuals Adjustment | 1d | 2013-08-30 | 2013-08-30 | 9-130M FS+227d | 20d |  |
|  | 2 | **1.2 PED** |  | 2006-10-02 | 2013-08-30 |  |  |  |
|  | 1 | **1.2.1 ACCELERATOR SYSTEMS** |  | 2006-10-02 | 2013-08-30 |  |  |  |
|  | 1 | **1.2.1.1 CRYOMODULES** |  | 2006-10-02 | 2013-08-30 |  |  |  |
| 1211005M5 |  | FY07 Internal Intermediate Design and Safety Review | 0d | 2007-06-25 | 2007-06-25 | 111123010M FS+71d | 315d |  |

| ID | WBS | Task | Duration | Start | Finish | Predecessors | Total float |
| --- | --- | --- | --- | --- | --- | --- | --- |
| 1211020M |  | FY09 Cvity String Pre-Construction Dsgn & Stfy Review for CM | 0d | 2009-04-28 | 2009-04-28 | 121116020M, 121111010M, 121113010M, 121115010M | 108d |
| 1211020M10 |  | FY09 Cryomodule Pre-construction Dsgn & Sfty Review for CM | 0d | 2009-09-29 | 2009-09-29 | 121135020M, 121133020M, 121134020M, 121131020M, 121132020M, 121136020M, 121138020M, 121137020M | -24d |
| 1211020M15 |  | FY09 Cryomodule Misc Pre-construction Dsgn & Sfty Review for CM | 0d | 2009-09-29 | 2009-09-29 | 12115005M, 12114005M | 1d |
| 1211020M5 |  | FY09 Space Frame Pre-construction Dsgn & Sfty Review for CM | 0d | 2009-09-29 | 2009-09-29 | 121126020M, 121121010M, 121124020M, 121125020M, 121122010M, 121123010M | 1d |
|  | 1 | **1.2.1.1.1 CAVITY STRING ASSEMBLY** |  | 2007-08-15 | 2013-08-30 |  |  |
|  | 1 | **1.2.1.1.1.1 CAVITIES** |  | 2007-11-12 | 2013-08-30 |  |  |
| 121111005 |  | FY08 Final Dsgn Cavity | 140d | 2007-11-12 | 2008-06-10 | 9-080M FS+30d | 36d |
| 121111010M |  | FY08 Final Dsgn Comptd for Cavity | 0d | 2008-06-10 | 2008-06-10 | 121111005 | 36d |
| 121111015 |  | Re-Baseline Actuals Adjustment | 1d | 2013-08-30 | 2013-08-30 | 9-130M FS+227d | 20d |
|  | 2 | **1.2.1.1.1.2 NIOBIUM** |  |  |  |  |  |
|  | 3 | **1.2.1.1.1.3 FUNDAMENTAL POWER COUPLER** |  | 2008-03-13 | 2013-08-30 |  |  |
| 121113005 |  | FY08 Final Dsgn FPC | 140d | 2008-03-13 | 2008-09-29 | 9-080M FS+107d | 230d |
| 121113010M |  | FY08 Final Dsgn Comptd for FPC | 0d | 2008-09-29 | 2008-09-29 | 9-080M, 121113005 | 249d |
| 121113015 |  | Re-Baseline Actuals Adjustment | 1d | 2013-08-30 | 2013-08-30 | 9-130M FS+227d | 20d |
|  | 4 | **1.2.1.1.1.4 MISC. CAVITY STRING COMPONENTS** |  | 2009-03-04 | 2013-08-30 |  |  |
| 121114005 |  | Final Dsgn, Misc Cavity String Components | 140d | 2009-03-04 | 2009-09-18 | 121111010M, 9-090M FS+100d | 8d |
| 121114010M |  | FY09 Final Dsgn Comptd for Misc Cavity String Components | 0d | 2009-09-18 | 2009-09-18 | 121114005 | 8d |
| 121114015 |  | Re-Baseline Actuals Adjustment | 1d | 2013-08-30 | 2013-08-30 | 9-130M FS+227d | 20d |
|  | 5 | **1.2.1.1.1.5 HOM/FIELD PROBES** |  | 2007-10-01 | 2013-08-30 |  |  |
| 121115005 |  | Final Dsgn HOM/Field Probes | 140d | 2007-10-01 | 2008-04-28 | 9-080M | 356d |
| 121115010M |  | FY08 Final Dsgn Comptd for HOM/Field Probes | 0d | 2008-04-28 | 2008-04-28 | 121115005 | 356d |
| 121115015 |  | Re-Baseline Actuals Adjustment | 1d | 2013-08-30 | 2013-08-30 | 9-130M FS+227d | 20d |
|  | 6 | **1.2.1.1.1.6 HELIUM VESSELS** |  | 2007-08-15 | 2013-08-30 |  |  |
| 121116005 |  | Design Helium Headers Preliminary (HELIUM VESSLS) | 28d | 2007-08-15 | 2007-09-25 | 121124005, 121133005 | 97d |
| 121116015 |  | Final Phase Final Dsgn, Helium Headers | 140d | 2008-10-01 | 2009-04-28 | 9-090M | 108d |
| 121116010 |  | Design Helium Headers Initial Phase Final Design (HELIUM VESSLS) | 12d | 2008-11-26 | 2008-12-15 | 9-090M FS+40d, 121133010, 121124010 | 7d |
| 121116020M |  | FY08 Final Dsgn Comptd for Helium Headers | 0d | 2009-04-28 | 2009-04-28 | 121116015 | 108d |
| 121116025 |  | Re-Baseline Actuals Adjustment | 1d | 2013-08-30 | 2013-08-30 | 9-130M FS+227d | 20d |
|  | 2 | **1.2.1.1.2 SPACE FRAME ASSEMBLY** |  | 2006-10-02 | 2013-08-30 |  |  |
|  | 1 | **1.2.1.1.2.1 TUNER ASSEMBLY** |  | 2009-03-13 | 2013-08-30 |  |  |
| 121121005 |  | Final Dsgn, Tuner | 140d | 2009-03-13 | 2009-09-29 | 9-090M FS+107d | 1d |
| 121121010M |  | FY08 Final Dsgn Comptd for Tuner | 0d | 2009-09-29 | 2009-09-29 | 121121005 | 1d |
| 121121015 |  | Re-Baseline Actuals Adjustment | 1d | 2013-08-30 | 2013-08-30 | 9-130M FS+227d | 20d |
|  | 2 | **1.2.1.1.2.2 HEADER ASSEMBLY, SUPPLY & RETURN** |  | 2008-10-01 | 2013-08-30 |  |  |
| 121122005 |  | Final Dsgn, Header Assy (Supply & Return) | 140d | 2008-10-01 | 2009-04-28 | 9-090M | 108d |
| 121122010M |  | FY08 Final Dsgn Comptd for Header Assy (Supply & Return) | 0d | 2009-04-28 | 2009-04-28 | 121122005 | 108d |
| 121122015 |  | Re-Baseline Actuals Adjustment | 1d | 2013-08-30 | 2013-08-30 | 9-130M FS+227d | 20d |
|  | 3 | **1.2.1.1.2.3 MAGNETIC SHIELD ASSEMBLY** |  | 2008-10-01 | 2013-08-30 |  |  |
| 131133010XD |  | Prcrmnt Prep for Magnetic Shield | 59d | 2008-10-01 | 2008-12-24 | 9-090M | 101d |
| 121123005 |  | Final Dsgn, Magnetic Shield | 140d | 2009-01-05 | 2009-07-23 | 9-090M FS+60d | 48d |
| 121123010M |  | FY08 Final Dsgn Comptd for Magnetic Shield | 0d | 2009-07-23 | 2009-07-23 | 121123005 | 48d |
| 121123015 |  | Re-Baseline Actuals Adjustment | 1d | 2013-08-30 | 2013-08-30 | 9-130M FS+227d | 20d |
|  | 4 | **1.2.1.1.2.4 THERMAL SHEILD ASSEMBLY, MLI BLANKETS 2&** |  | 2007-07-06 | 2013-08-30 |  |  |
| 121124005 |  | Design Thermal Shield Preliminary (THRML SHLD) | 28d | 2007-07-06 | 2007-08-15 | 121135005, 121131005 | 97d |
| 121124010 |  | Design Thermal Shield Initial Phase Final Design (THRML SHLD) | 12d | 2008-07-03 | 2008-07-21 | 121131010, 121135010 | 97d |
| 121124015 |  | Dsgn Thermal Shield, Final Phase Final Dsgn | 140d | 2008-10-01 | 2009-04-28 | 9-090M | 108d |
| 121124020M |  | FY08 Final Dsgn Comptd for Thermal Shield | 0d | 2009-04-28 | 2009-04-28 | 121124015 | 108d |
| 121124025 |  | Re-Baseline Actuals Adjustment | 1d | 2013-08-30 | 2013-08-30 | 9-130M FS+227d | 20d |
|  | 5 | **1.2.1.1.2.5 SEALS & MISC. SPACE FRAME COMPONENTS** |  | 2008-03-26 | 2013-08-30 |  |  |
| 121125005 |  | Design Seals & Misc Space Frame Preliminary (SEALS) | 28d | 2008-03-26 | 2008-05-05 | 121136005 FS+120d, 121116005 FS+120d, 121134005 FS+120d | 97d |
| 121125010 |  | Design Seals & Misc Space Frame Initial Phase Final Design (SEALS) | 12d | 2008-12-16 | 2009-01-08 | 121136010, 121116010, 121134010 | 7d |
| 121125015 |  | Final Phase Final Dsgn, Seals & Misc Space Frame | 140d | 2009-03-13 | 2009-09-29 | 9-090M FS+107d | 1d |
| 121125020M |  | FY08 Final Dsgn Comptd for Seals & Misc Space Frame | 0d | 2009-09-29 | 2009-09-29 | 121125015 | 1d |
| 121125025 |  | Re-Baseline Actuals Adjustment | 1d | 2013-08-30 | 2013-08-30 | 9-130M FS+227d | 20d |
|  | 6 | **1.2.1.1.2.6 SPACE FRAME** |  | 2006-10-02 | 2013-08-30 |  |  |
| 121126005 |  | Design Space Frame Preliminary (SPC FRM) | 184d | 2006-10-02 | 2007-06-29 | 9-070M | 97d |
| 121126010 |  | Design Space Frame Initial Phase Final Design (SPC FRM) | 12d | 2008-06-13 | 2008-07-01 | 121138005 | 97d |
| 121126015 |  | Final Phase Final Dsgn, Space Frame | 140d | 2009-02-03 | 2009-08-20 | 9-090M FS+80d | 28d |
| 121126020M |  | FY08 Final Dsgn Comptd for Space Frame | 0d | 2009-08-20 | 2009-08-20 | 121126015 | 28d |
| 121126025 |  | Re-Baseline Actuals Adjustment | 1d | 2013-08-30 | 2013-08-30 | 9-130M FS+227d | 20d |
|  | 3 | **1.2.1.1.3 CRYOMODULE ASSEMBLY** |  | 2006-10-02 | 2013-08-30 |  |  |
|  | 1 | **1.2.1.1.3.1 ALIGNMENT FIDUCIALS** |  | 2007-07-02 | 2013-08-30 |  |  |
| 121131005 |  | Design Alignment Fiducials Preliminary (ALGNMT FIDUCLS) | 3.5d | 2007-07-02 | 2007-07-06 | 121126005, 121132005 | 97d |
| 121131010 |  | Design Alignment Fiducials Initial Phase Final Design (ALGNMT FIDUCLS) | 1.5d | 2008-07-01 | 2008-07-02 | 121126010, 121132010 | 97d |
| 121131015 |  | Final Phase Final Dsgn, Alignment Fiducials | 140d | 2008-10-01 | 2009-04-28 | 9-090M | 83d |
| 121131020M |  | FY08 Final Dsgn Comptd for Alignment Fiducials | 0d | 2009-04-28 | 2009-04-28 | 121131015 | 83d |
| 121131025 |  | Re-Baseline Actuals Adjustment | 1d | 2013-08-30 | 2013-08-30 | 9-130M FS+227d | 20d |
|  | 2 | **1.2.1.1.3.2 VACUUM TANK ASSEMBLY** |  | 2006-10-02 | 2013-08-30 |  |  |
| 121132005 |  | Design Vacuum Tank Preliminary (VAC TNK ASSMBLY) | 28d | 2006-10-02 | 2006-11-08 | 9-070M | 253d |
| 121132010 |  | Design Vacuum Tank Initial Phase Final Design (VAC TNK ASSMBLY) | 12d | 2008-06-13 | 2008-07-01 | 121138005 | 97d |

| ID | WBS | Task | Duration | Start | Finish | Predecessors | Total float |
| --- | --- | --- | --- | --- | --- | --- | --- |
| 121132015 |  | Final Phase Final Dsgn, Vac Tank | 140d | 2009-03-13 | 2009-09-29 | 9-090M FS+107d | -24d |
| 121132020M |  | FY08 Final Dsgn Comptd for Vac Tank | 0d | 2009-09-29 | 2009-09-29 | 121132015 | -24d |
| 121132025 |  | Re-Baseline Actuals Adjustment | 1d | 2013-08-30 | 2013-08-30 | 9-130M FS+227d | 20d |
|  | 3 | **1.2.1.1.3.3 END CAN ASSEMBLY** |  | 2007-07-06 | 2013-08-30 |  |  |
| 121133005 |  | Design End Cans Preliminary (END CAN ASSMBLY) | 28d | 2007-07-06 | 2007-08-15 | 121131005, 121135005 | 97d |
| 121133010 |  | Design End Cans Initial Phase Final Design (END CAN ASSMBLY) | 12d | 2008-07-03 | 2008-07-21 | 121135010, 121131010 | 97d |
| 121133015 |  | Final Phase Final Dsgn, End Cans | 140d | 2008-10-01 | 2009-04-28 | 9-090M | 83d |
| 121133020M |  | FY08 Final Dsgn Comptd for End Cans | 0d | 2009-04-28 | 2009-04-28 | 121133015 | 83d |
| 121133025 |  | Re-Baseline Actuals Adjustment | 1d | 2013-08-30 | 2013-08-30 | 9-130M FS+227d | 20d |
|  | 4 | **1.2.1.1.3.4 BEAM LINE ASSEMBLY WITHIN CM** |  | 2007-08-15 | 2013-08-30 |  |  |
| 121134005 |  | Design Transition Beamline Preliminary (BEAMLINE ASSMBLY) | 28d | 2007-08-15 | 2007-09-25 | 121133005, 121124005 | 97d |
| 121134010 |  | Design Transition Beamline Initial Phase Final Design (BEAMLINE ASSMBLY) | 12d | 2008-07-22 | 2008-08-06 | 121133010, 121124010 | 97d |
| 121134015 |  | Final Phase Final Dsgn, Transition BL in CM | 140d | 2009-03-13 | 2009-09-29 | 9-090M FS+107d | -24d |
| 121134020M |  | FY08 Final Dsgn Comptd for Transition BL in CM | 0d | 2009-09-29 | 2009-09-29 | 121134015 | -24d |
| 121134025 |  | Re-Baseline Actuals Adjustment | 1d | 2013-08-30 | 2013-08-30 | 9-130M FS+227d | 20d |
|  | 5 | **1.2.1.1.3.5 STANDS** |  | 2007-07-02 | 2013-08-30 |  |  |
| 121135005 |  | Design Stands Preliminary (STANDS) | 0.7d | 2007-07-02 | 2007-07-02 | 121126005, 121132005 | 99.8d |
| 121135010 |  | Design Stands Initial Phase Final Design (STANDS) | 0.3d | 2008-07-01 | 2008-07-01 | 121126010, 121132010 | 98.2d |
| 121135015 |  | Final Phase Final Dsgn, Stands | 140d | 2009-03-11 | 2009-09-25 | 9-090M FS+105d | -22d |
| 121135020M |  | FY08 Final Dsgn Comptd for Stands | 0d | 2009-09-25 | 2009-09-25 | 121135015 | -22d |
| 121135025 |  | Re-Baseline Actuals Adjustment | 1d | 2013-08-30 | 2013-08-30 | 9-130M FS+227d | 20d |
|  | 6 | **1.2.1.1.3.6 WIRING INCL HOM & FP CABLES** |  | 2007-08-15 | 2013-08-30 |  |  |
| 121136005 |  | Design Wiring Preliminary (WIRING) | 28d | 2007-08-15 | 2007-09-25 | 121133005, 121124005 | 97d |
| 121136010 |  | Design Wiring Initial Phase Final Design (WIRING) | 12d | 2008-07-22 | 2008-08-06 | 121133010, 121124010 | 97d |
| 121136015 |  | Final Phase Final Dsgn, Wiring | 140d | 2009-03-13 | 2009-09-29 | 9-090M FS+107d | -24d |
| 121136020M |  | FY08 Final Dsgn Comptd for Wiring | 0d | 2009-09-29 | 2009-09-29 | 121136015 | -24d |
| 121136025 |  | Re-Baseline Actuals Adjustment | 1d | 2013-08-30 | 2013-08-30 | 9-130M FS+227d | 20d |
|  | 7 | **1.2.1.1.3.7 FEEDTHROUGHS INCL WARM/COLD HOM/FP** |  | 2008-03-26 | 2013-08-30 |  |  |
| 121137005 |  | Design Feedthroughs Preliminary (FEEDTHRU) | 28d | 2008-03-26 | 2008-05-05 | 121136005 FS+120d, 121134005 FS+120d, 121116005 FS+120d | 97d |
| 121137015 |  | Final Phase Final Dsgn, Feedthroughs | 140d | 2008-10-01 | 2009-04-28 | 9-090M | 83d |
| 121137010 |  | Design Feedthroughs Initial Phase Final Design (FEEDTHRU) | 12d | 2008-12-16 | 2009-01-08 | 121136010, 121116010, 121134010 | 7d |
| 121137020M |  | FY08 Final Dsgn Comptd for Feedthroughs | 0d | 2009-04-28 | 2009-04-28 | 121137015 | 83d |
| 121137025 |  | Re-Baseline Actuals Adjustment | 1d | 2013-08-30 | 2013-08-30 | 9-130M FS+227d | 20d |
|  | 8 | **1.2.1.1.3.8 HOM LOADS** |  | 2008-05-05 | 2013-08-30 |  |  |
| 121138005 |  | Design HOM Loads Preliminary (HOM LOADS) | 28d | 2008-05-05 | 2008-06-13 | 121125005, 121137005 | 97d |
| 121138010 |  | Design HOM Loads Initial Phase Final Design (HOM LOADS) | 12d | 2009-01-09 | 2009-01-27 | 121137010, 121125010 | 7d |
| 121138015 |  | Final Phase Final Dsgn, HOM Loads | 140d | 2009-03-13 | 2009-09-29 | 121138010, 9-090M FS+107d | -24d |
| 121138025 |  | Computational Analysis | 5d | 2009-03-16 | 2009-03-23 | 11114070M FS+165d | 74.5d |
| 121138030 |  | Fabricate Test Hardware | 10d | 2009-03-23 | 2009-04-06 | 121138025 | 74.5d |
| 121138035 |  | Measure (First) HOM Damping in VTA | 10d | 2009-04-06 | 2009-04-20 | 121138030 | 74.5d |
| 121138040 |  | Evaluate (First) Measurement results | 5d | 2009-04-20 | 2009-04-27 | 121138035 | 74.5d |
| 121138045 |  | Modify Test Hardware | 10d | 2009-04-27 | 2009-05-11 | 121138040 | 74.5d |
| 121138050 |  | Measure (Second) HOM Damping in VTA | 10d | 2009-05-11 | 2009-05-26 | 121138045 | 74.5d |
| 121138055 |  | Evaluate (Second) Measurement results | 5d | 2009-05-26 | 2009-06-02 | 121138050 | 74.5d |
| 121138060 |  | Document HOM damping results and final | 10d | 2009-06-02 | 2009-06-16 | 121138055 | 74.5d |
| 121138020M |  | FY08 Final Dsgn Comptd for HOM Loads | 0d | 2009-09-29 | 2009-09-29 | 121138015 | -24d |
| 121138065 |  | Re-Baseline Actuals Adjustment | 1d | 2013-08-30 | 2013-08-30 | 9-130M FS+227d | 20d |
|  | 4 | **1.2.1.1.4 INSTALLATION & ASSEMBLY TOOLING** |  | 2008-10-01 | 2013-08-30 |  |  |
| 12114000 |  | Final Dsgn of Installtn & Assy Tooling | 140d | 2008-10-01 | 2009-04-28 | 9-090M | 108d |
| 12114005M |  | FY08 Final Dsgn Comptd for Installtn & Assy Tooling | 0d | 2009-04-28 | 2009-04-28 | 12114000 | 108d |
| 12114010 |  | Re-Baseline Actuals Adjustment | 1d | 2013-08-30 | 2013-08-30 | 9-130M FS+227d | 20d |
|  | 5 | **1.2.1.1.5 CRYOMODULE TEST INSTRUMENTATION & INTERLOCKS** |  | 2009-03-13 | 2013-08-30 |  |  |
| 12115000 |  | Final Dsgn of Instrmenttn & Interlocks | 140d | 2009-03-13 | 2009-09-29 | 9-090M FS+107d | 1d |
| 12115005M |  | FY08 Final Dsgn Comptd for Instrmenttn & Interlocks | 0d | 2009-09-29 | 2009-09-29 | 12115000 | 1d |
| 12115010 |  | Re-Baseline Actuals Adjustment | 1d | 2013-08-30 | 2013-08-30 | 9-130M FS+227d | 20d |
|  | 2 | **1.2.1.2 POWER SYSTEMS** |  | 2006-10-02 | 2013-08-30 |  |  |
|  | 1 | **1.2.1.2.1 RF** |  | 2006-10-02 | 2013-08-30 |  |  |
|  | 1 | **1.2.1.2.1.1 POWER** |  | 2006-10-02 | 2013-08-30 |  |  |
|  | 1 | **1.2.1.2.1.1.1 KLYSTRONS** |  | 2006-10-02 | 2013-08-30 |  |  |
| 1212111000M |  | Start Klystron PED effort (KLYSTRONS) | 0d | 2006-10-02 | 2006-10-02 | 9-070M | 0d |
| 1212111007LOE |  | FY07 Project administration (KLYSTRONS) | 247d | 2006-10-02 | 2007-09-28 | 1212111000M | 0d |
| 1212111010 |  | Refine klystron specifications w/driver (KLYSTRONS) | 100d | 2006-10-02 | 2007-03-02 | 1212111000M | 8d |
| 1212111015M |  | Specifications revision complete (KLYSTRONS) | 0d | 2007-03-02 | 2007-03-02 | 1212111010 | 8d |
| 1212111030 |  | Internal design & safety review of klystron specifications (KLYSTRONS) | 10d | 2007-03-05 | 2007-03-16 | 1212111015M | 8d |
| 1212111035M |  | Preliminary internal design & safety review complete (KLYSTRONS) | 0d | 2007-03-16 | 2007-03-16 | 1212111030 | 8d |
| 1212111040 |  | Revise preliminary klystron specifications per design & safety review (KLYSTRONS) | 20d | 2007-03-19 | 2007-04-13 | 1212111035M | 8d |
| 1212111020 |  | Update budgetary pricing through vendor requests (KLYSTRONS) | 20d | 2007-04-16 | 2007-05-11 | 1212111015M, 1212111040, 1212111035M | 8d |
| 1212111025M |  | Budgetary pricing received from vendors (KLYSTRONS) | 0d | 2007-05-11 | 2007-05-11 | 1212111020 | 8d |
| 1212111045 |  | Revise costbook based on new pricing (KLYSTRONS) | 5d | 2007-05-14 | 2007-05-18 | 1212111025M | 8d |
| 1212111050M |  | Klystron preliminary design complete (KLYSTRONS) | 0d | 2007-05-18 | 2007-05-18 | 1212111040, 1212111045 | 8d |

| ID | WBS | Task | Duration | Start | Finish | Predecessors | Total float |
| --- | --- | --- | --- | --- | --- | --- | --- |
| 1212111055 |  | Begin final design (FY07 continuing into FY08) (KLYSTRONS) | 92d | 2007-05-21 | 2007-09-28 | 1212111050M | 8d |
| 1212111070 |  | Develop Final Klystron Spec's (Klystrons) | 60d | 2007-10-01 | 2008-01-03 | 1212111055, 9-080M | 8d |
| 1212111908LOE |  | FY08 Proj Admin (Klystrons) | 248d | 2007-10-01 | 2008-09-30 | 9-080M, 1212111007LOE | 0d |
| 1212111075 |  | Write Final Rquirmnts/Prcrmnt Packages (Klystrons) | 60d | 2008-01-04 | 2008-03-31 | 1212111070 | 8d |
| 1212111080M |  | Comp klystron PED 2008 (KLYSTRONS) | 0d | 2008-03-31 | 2008-03-31 | 1212111075 | 81d |
| 1212111085 |  | Release Prcrmnt Package for Klystron Solicitation (Klystrons) | 40d | 2008-04-01 | 2008-05-27 | 1212111075 | 8d |
| 1212111170 |  | Pre-Constrctn Dsgn Review (Klystrons) | 5d | 2008-04-01 | 2008-04-07 | 1212111080M | 81d |
| 1212111100 |  | Eng-Receive & Evaluate Klystron Proposals (Klystrons) | 10d | 2008-05-28 | 2008-06-10 | 1212111085 | 8d |
| 1212111110 |  | Des-Receive & Evaluate Klystron Proposals (Klystrons) | 10d | 2008-06-11 | 2008-06-24 | 1212111100 | 8d |
| 1212111115 |  | Release Best & Final for Klystrons (Klystrons) | 20d | 2008-08-07 | 2008-09-04 | 1212111110 FS+30d | 8d |
| 1212111120 |  | Final Klystron Evaluation (Klystrons)+ | 10d | 2008-09-05 | 2008-09-18 | 1212111115 | 8d |
| 1212111175 |  | Re-Baseline Actuals Adjustment | 1d | 2013-08-30 | 2013-08-30 | 9-130M FS+227d | 20d |
|  | 2 | **1.2.1.2.1.1.2 DC POWER** |  | 2006-10-02 | 2013-08-30 |  |  |
| 1212112000M |  | FY07 Begin DC Power PED efforts (DC POWER) | 0d | 2006-10-02 | 2006-10-02 | 9-070M | 160d |
| 1212112005 |  | Develop preliminary requirements for klystron HVPS (DC POWER) | 15d | 2006-10-02 | 2006-10-20 | 1212112000M | 160d |
| 1212112010M |  | Preliminary HVPS requirements document complete (DC POWER) | 0d | 2006-10-20 | 2006-10-20 | 1212112005 | 160d |
| 1212112015 |  | Develop aux power supply requirements preliminary designs (includes rack configuration) (DC POWER) | 80d | 2006-10-23 | 2007-02-23 | 1212112010M | 548d |
| 1212112025 |  | Conduct internal design & safety review (DC POWER) | 10d | 2006-10-30 | 2006-11-10 | 1212112010M FS+5d | 160d |
| 1212112030M |  | Internal design & safety review complete (DC POWER) | 0d | 2006-11-10 | 2006-11-10 | 1212112025, 1212112010M | 160d |
| 1212112035 |  | Revise requirements based on review outcome (DC POWER) | 10d | 2006-11-13 | 2006-11-28 | 1212112030M, 1212112025 | 160d |
| 1212112040M |  | Requirements revised (DC POWER) | 0d | 2006-11-28 | 2006-11-28 | 1212112035 | 160d |
| 1212112045 |  | Request budgetary pricing for HVPS (DC POWER) | 20d | 2006-11-29 | 2007-01-03 | 1212112035, 1212112040M | 160d |
| 1212112065 |  | Build & test preliminary designs (fil/mod anode) (DC POWER) | 40d | 2006-12-20 | 2007-02-23 | 1212112060M FS-20d | 160d |
| 1212112050M |  | Budgetary pricing received (DC POWER) | 0d | 2007-01-03 | 2007-01-03 | 1212112045 | 160d |
| 1212112080 |  | Update costbook (DC POWER) | 5d | 2007-01-04 | 2007-01-10 | 1212112050M | 160d |
| 1212112085M |  | Costbook pricing updated (DC POWER) | 0d | 2007-01-10 | 2007-01-10 | 1212112080 | 160d |
| 1212112055 |  | Procure components for preliminary design tests (DC POWER) | 10d | 2007-01-11 | 2007-01-25 | 1212112085M | 160d |
| 1212112060M |  | Components received for preliminary design tests (DC POWER) | 0d | 2007-01-25 | 2007-01-25 | 1212112055 | 160d |
| 1212112020 |  | Develop preliminary layout/packaging designs (DC POWER) | 100d | 2007-02-26 | 2007-07-17 | 1212112010M, 1212112015 | 548d |
| 1212112070 |  | Revise preliminary designs (DC POWER) | 10d | 2007-02-26 | 2007-03-09 | 1212112060M, 1212112040M, 1212112065 | 160d |
| 1212112075M |  | Preliminary designs revised (DC POWER) | 0d | 2007-03-09 | 2007-03-09 | 1212112070 | 160d |
| 1212112090M |  | FY08 Begin DC Pwr PED (DC POWER) | 0d | 2007-10-01 | 2007-10-01 | 9-080M, 1212112075M | 18d |
| 1212112908LOE |  | FY08 Office Supprt for Document Prep (DC POWER) | 248d | 2007-10-01 | 2008-09-30 | 1212111007LOE, 9-080M | 0d |
| 1212112100 |  | Dsgn & Test filament Pwr Supply (DC POWER) | 60d | 2008-04-01 | 2008-06-24 | 1212112090M FS+120d | 131d |
| 1212112110 |  | Dsgn & Test Mods anode Pwr Supply (DC POWER) | 60d | 2008-05-28 | 2008-08-20 | 1212112105 FS-40d | 143d |
| 1212112105 |  | Prep Documentation for Fab:/Prcrmnt filament (DC POWER) | 20d | 2008-06-25 | 2008-07-23 | 1212112100 | 143d |
| 1212112130 |  | PROC Dsgn HPA/Rack Sys & Inj. Upgrade(DC POWER) | 145d | 2008-06-25 | 2009-01-28 | 1212112100 | 131d |
| 1212112130a |  | FY08 LAB/EXP Dsgn HPA/Rack Sys & Inj. Upgrade(DC POWER) | 68d | 2008-06-25 | 2008-09-30 | 1212112100 | 131d |
| 1212112115 |  | FY08 Prep Documentation for Fab/Prcrmnt: Mods anode (DC POWER) | 28d | 2008-08-21 | 2008-09-30 | 1212112110 | 143d |
| 1212112120 |  | PROC Dsgn & Test Ion Pump Pwr Supply (DC POWER) | 78d | 2008-09-12 | 2009-01-09 | 1212112115a FS-15d | 143d |
| 1212112120a |  | FY08 LAB Dsgn & Test Ion Pump Pwr Supply (DC POWER) | 13d | 2008-09-12 | 2008-09-30 | 1212112115a FS-15d | 143d |
| 1212112115a |  | FY09 Prep Documentation for Fab/Prcrmnt: Mods anode (DC POWER) | 2d | 2008-10-01 | 2008-10-02 | 1212112115 | 143d |
| 1212112120b |  | FY09 LAB Dsgn & Test Ion Pump Pwr Supply (DC POWER) | 65d | 2008-10-01 | 2009-01-09 | 1212112120a | 143d |
| 1212112130b |  | FY09 LAB/EXP Dsgn HPA/Rack Sys & Inj. Upgrade(DC POWER) | 77d | 2008-10-01 | 2009-01-28 | 1212112130a | 131d |
| 1212112125 |  | Prep Documentation for Fab/Prcrmnt; ION (DC POWER) | 20d | 2009-01-12 | 2009-02-09 | 1212112120, 1212112120b | 143d |
| 1212112135 |  | Prep Documentation for Fab/Prcrmnt (DC POWER) | 20d | 2009-01-29 | 2009-02-26 | 1212112130, 1212112130b | 131d |
| 1212112140 |  | Prep Final Rquirmnts Package for HV PS Prcrmnt (DC POWER) | 20d | 2009-02-27 | 2009-03-26 | 1212112135, 1212112125 | 131d |
| 1212112145M |  | Finish 2008 DC Pwr PED (DC POWER)+ | 0d | 2009-03-26 | 2009-03-26 | 1212112140 | 131d |
| 1212112150 |  | Re-Baseline Actuals Adjustment | 1d | 2013-08-30 | 2013-08-30 | 9-130M FS+227d | 20d |
|  | 3 | **1.2.1.2.1.1.3 WAVEGUIDE COMPONENTS** |  | 2006-10-02 | 2013-08-30 |  |  |
| 1212113000M |  | Begin waveguide PED effort (WVGUIDE COMPON) | 0d | 2006-10-02 | 2006-10-02 | 9-070M | 429d |
| 1212113005 |  | Develop preliminary waveguide requirements and layout (WVGUIDE COMPON) | 120d | 2006-10-02 | 2007-03-30 | 1212113000M | 429d |
| 1212113010 |  | Conduct internal design & safety review (WVGUIDE COMPON) | 10d | 2007-04-02 | 2007-04-13 | 1212113005, 1212113000M | 429d |
| 1212113015M |  | Design & safety review complete (WVGUIDE COMPON) | 0d | 2007-04-13 | 2007-04-13 | 1212113005, 1212113000M, 1212113010 | 429d |
| 1212113020 |  | Revise preliminary designs (WVGUIDE COMPON) | 5d | 2007-04-16 | 2007-04-20 | 1212113015M | 429d |
| 1212113025M |  | Requirements revised (WVGUIDE COMPON) | 0d | 2007-04-20 | 2007-04-20 | 1212113020 | 429d |
| 1212113030 |  | Request budgetary pricing for waveguide components (WVGUIDE COMPON) | 20d | 2007-04-23 | 2007-05-18 | 1212113025M | 429d |
| 1212113035M |  | Receive budgetary pricing (WVGUIDE COMPON) | 0d | 2007-05-18 | 2007-05-18 | 1212113030 | 429d |
| 1212113040 |  | Revise costbook pricing (WVGUIDE COMPON) | 5d | 2007-05-21 | 2007-05-25 | 1212113035M | 429d |
| 1212113045M |  | Costbook revised (WVGUIDE COMPON) | 0d | 2007-05-25 | 2007-05-25 | 1212113040 | 429d |
| 1212113050M |  | Begin final design (WVGUIDE COMPON) | 0d | 2007-05-29 | 2007-05-29 | 1212113045M | 429d |
| 1212113055 |  | Final design FY07 Phase (WVGUIDE COMPON) | 59d | 2007-05-29 | 2007-08-20 | 1212113050M | 429d |
| 1212113060M |  | Begin 2008 Waveguide Systems PED (WVGUIDE COMPON) | 0d | 2008-06-25 | 2008-06-25 | 9-080M FS+180d, 1212113055 | 221d |
| 1212113065 |  | Office Admin Supprt (WVGUIDE COMPON) | 65d | 2008-06-25 | 2008-09-25 | 1212113060M | 246d |
| 1212113070 |  | Develop Rquirmnts Package for circulator (WVGUIDE COMPON) | 30d | 2008-06-25 | 2008-08-06 | 1212113060M | 221d |
| 1212113075 |  | Develop Rquirmnts Package for HOM Filter (WVGUIDE COMPON) | 0d | 2008-08-14 | 2008-08-14 | 1212113070 FS+5d | 221d |
| 1212113080 |  | FY08 LAB/EXPDevelop Rquirmnts Packages for Custom Waveguide pcs (WVGUIDE COMPON) | 33d | 2008-08-14 | 2008-09-30 | 1212113075 | 221d |
| 1212113080a |  | FY09 LAB/EXP Develop Rquirmnts Packages for Custom Waveguide pcs (WVGUIDE COMPON) | 17d | 2008-10-01 | 2008-10-23 | 1212113080 | 221d |
| 1212113085 |  | Revise Vend Pricing for Waveguide Compnts (WVGUIDE COMPON) | 5d | 2008-10-24 | 2008-10-30 | 1212113080a | 221d |
| 1212113090M |  | Waveguide PED Comp 2008 (WVGUIDE COMPON)++ | 0d | 2008-10-30 | 2008-10-30 | 1212113065, 1212113085 | 221d |

| ID | WBS | Task | Duration | Start | Finish | Predecessors | Total float | Constraint |
| --- | --- | --- | --- | --- | --- | --- | --- | --- |
| 1212113170 |  | Pre-Constrctn Dsgn Review (WVGUIDE COMPON)+ | 5d | 2008-10-31 | 2008-11-06 | 1212113090M | 221d |  |
| 1212113175 |  | Re-Baseline Actuals Adjustment | 1d | 2013-08-30 | 2013-08-30 | 9-130M FS+227d | 20d |  |
|  | 2 | **1.2.1.2.1.2 CONTROL** |  | 2006-10-02 | 2013-08-30 |  |  |  |
|  | 1 | **1.2.1.2.1.2.1 FIELD CONTROL (RF/DSP)** |  | 2006-10-02 | 2013-08-30 |  |  |  |
| 1212121030M |  | Begin Preliminary Digital Board Design (FLD CNTL) | 0d | 2006-10-02 | 2006-10-02 | 9-070M | 34d |  |
| 1212121035 |  | Develop Detailed Specification (FLD CNTL) | 20d | 2006-10-02 | 2006-10-27 | 1212121030M | 34d |  |
| 1212121060M |  | Start Preliminary RF Board design (FLD CNTL) | 0d | 2006-10-02 | 2006-10-02 | 9-070M | 14d |  |
| 1212121065 |  | Develop RF Board Detailed specification (FLD CNTL) | 20d | 2006-10-02 | 2006-10-27 | 1212121060M | 14d |  |
| 1212121125 |  | Prepare for EIR (FLD CNTL) | 58d | 2006-10-02 | 2006-12-22 |  | 158d |  |
| 1212121040 |  | Develop Preliminary Design Digital Board (FLD CNTL) | 60d | 2006-10-30 | 2007-02-01 | 1212121035 | 34d |  |
| 1212121070 |  | Preliminary RF Board Design Complete (FLD CNTL) | 40d | 2006-10-30 | 2007-01-03 | 1212121065 | 14d |  |
| 1212121000M |  | Preliminary Integrated LLRF System Design (FLD CNTL) | 0d | 2006-12-05 | 2006-12-05 | 9-070M FS+44d | 131.5d |  |
| 1212121005 |  | Develop Preliminary System Design (FLD CNTL) | 80d | 2006-12-05 | 2007-04-05 | 1212121000M | 591d |  |
| 1212121015 |  | Update LLRF Model (FLD CNTL) | 60d | 2006-12-05 | 2007-03-08 | 1212121000M | 131.5d |  |
| 1212121130M |  | Field Control Ready for Baseline (FLD CNTL) | 0d | 2006-12-22 | 2006-12-22 | 1212121125 | 158d |  |
| 1212121075 |  | Procure RF Board validation unit (FLD CNTL) | 4d | 2007-01-04 | 2007-01-09 | 1212121070 | 14d |  |
| 1212121010 |  | Investigate Comparitive System Designs (FLD CNTL) | 60d | 2007-01-10 | 2007-04-05 | 1212121000M FS+20d | 591d |  |
| 1212121045 |  | Procure Digital Board validation unit (FLD CNTL) | 4d | 2007-02-02 | 2007-02-07 | 1212121040 | 34d |  |
| 1212121050 |  | Conduct Digital Board Validation Tests (FLD CNTL) | 40d | 2007-02-08 | 2007-04-05 | 1212121045 | 34d |  |
| 1212121110M |  | Start Cost & Schedule Update (FLD CNTL) | 0d | 2007-02-08 | 2007-02-08 | 1212121045, 1212121075 | 106.5d |  |
| 1212121115 |  | Update PED Cost and Schedule (FLD CNTL) | 45d | 2007-02-08 | 2007-04-12 | 1212121110M | 106.5d |  |
| 1212121120 |  | Update Construction Cost and Schedule (FLD CNTL) | 30d | 2007-02-08 | 2007-03-22 | 1212121110M | 124d |  |
| 1212121080 |  | Conduct RF Board Validation tests (FLD CNTL) | 40d | 2007-03-09 | 2007-05-03 | 1212121075 FS+40d | 14d |  |
| 1212121055M |  | Digital Board Validation Tests complete (FLD CNTL) | 0d | 2007-04-05 | 2007-04-05 | 1212121050 | 167d |  |
| 1212121020 |  | Develop Preliminary Design (FLD CNTL) | 2.5d | 2007-04-13 | 2007-04-17 | 1212121115, 1212121015 | 106.5d |  |
| 1212121020M |  | Preliminary Design Complete (FLD CNTL) | 0d | 2007-04-17 | 2007-04-17 | 1212121020 | 106.5d |  |
| 1212121025 |  | Conduct Preliminary Design & Safety Review 1.2.1.2.1.2 LLRF (FLD CNTL) | 20d | 2007-04-17 | 2007-05-15 | 1212121120, 1212121020M, 1212121020 | 106.5d |  |
| 1212121085M |  | RF Board Validation Tests complete (FLD CNTL) | 0d | 2007-05-03 | 2007-05-03 | 1212121080 | 14d |  |
| 1212121100 |  | Conduct Field Control System Validation (FLD CNTL) | 100d | 2007-05-04 | 2007-09-25 | 1212121085M, 1212121050 | 14d |  |
| 1212121090M |  | Start Field Control System Test (FLD CNTL) | 0d | 2007-07-31 | 2007-07-31 | 1212121005, 1212121010, 1212121055M FS+80d | 511d |  |
| 1212121095 |  | Modify Field Control Firmware (FLD CNTL) | 28d | 2007-07-31 | 2007-09-07 | 1212121090M | 511d |  |
| 1212121105M |  | Field Control System validation complete (FLD CNTL) | 0d | 2007-09-25 | 2007-09-25 | 1212121100, 1212121025 | 14d |  |
| 1212121135 |  | Validation Testing on Cavity Phase 1 (FLD CONT) | 43d | 2007-10-01 | 2007-11-30 | 9-080M, 1212121105M | 11d |  |
| 1212121135B |  | PROC Validation Testing on Cavity Phase 2 (FLD CONT) | 169d | 2008-08-01 | 2009-04-09 | 1212121135 FS+163d | 1112d |  |
| 1212121135Ba |  | FY08 LAB Validation Testing on Cavity Phase 2A (FLD CONT) | 42d | 2008-08-01 | 2008-09-30 | 1212121135 FS+163d | 11d |  |
| 1212121135Bb |  | FY09 LAB Validation Testing on Cavity Phase 2B (FLD CONT) | 127d | 2008-10-01 | 2009-04-09 | 1212121135Ba | 11d |  |
| 1212121140 |  | Assess Hardware Dsgn (FLD CONT) | 87d | 2009-02-12 | 2009-06-16 | 1212121135Bb FS-40d | 11d |  |
| 1212121170 |  | Pre-Constrctn Dsgn Review (FLD CONT) | 20d | 2009-05-01 | 2009-05-29 | 1212121135Bb FS+15d | 86d |  |
| 1212121145 |  | Update Documentation and Procurement Prep (FLD CONT)+ | 86d | 2009-05-14 | 2009-09-15 | 1212121140 FS-23d | 11d |  |
| 1212121145M |  | Documentation Ready for Prcrmnt (FLD CONT)+ | 0d | 2009-09-15 | 2009-09-15 | 1212121145 | 11d |  |
| 1212121175 |  | Re-Baseline Actuals Adjustment | 1d | 2013-08-30 | 2013-08-30 | 9-130M FS+227d | 20d |  |
|  | 2 | **1.2.1.2.1.2.2 RESONANCE CONTROL & INTERLOCKS** |  | 2007-01-04 | 2013-08-30 |  |  |  |
| 1212122000M |  | Start Preliminary Integrated System Design (RESON CNTL & INTRLCKS) | 0d | 2007-01-04 | 2007-01-04 | 9-070M FS+60d | 86d |  |
| 1212122005 |  | Prepare Preliminary Integrated System Design (RESON CNTL & INTRLCKS) | 40d | 2007-01-04 | 2007-03-02 | 1212122000M | 244d |  |
| 1212122015 |  | Develop Detailed Preliminary Integrated System Design specification (RESON CNTL & INTRLCKS) | 20d | 2007-01-04 | 2007-02-01 | 1212122000M | 86d |  |
| 1212122020M |  | Interlock and Step Chassis (RESON CNTL & INTRLCKS) | 0d | 2007-02-02 | 2007-02-02 | 1212122015 | 86d |  |
| 1212122025 |  | Develop Interlock Preliminary Design (RESON CNTL & INTRLCKS) | 60d | 2007-02-02 | 2007-04-27 | 1212122020M | 184d |  |
| 1212122010M |  | Preliminary Integrated System Design Complete (RESON CNTL & INTRLCKS) | 0d | 2007-03-02 | 2007-03-02 | 1212122005 | 244d |  |
| 1212122030 |  | Build Design Interlock validation unit (RESON CNTL & INTRLCKS) | 10d | 2007-04-30 | 2007-05-11 | 1212122025 | 184d |  |
| 1212122045M |  | Start PZT Driver chassis design (RESON CNTL & INTRLCKS) | 0d | 2007-05-03 | 2007-05-03 | 1212122020M FS+63d | 86d |  |
| 1212122050 |  | Develop PZT Driver chassis Preliminary Design (RESON CNTL & INTRLCKS) | 65d | 2007-05-03 | 2007-08-03 | 1212122045M | 86d |  |
| 1212122070M |  | Start Cost & Schedule Update (RESON CNTL & INTRLCKS) | 0d | 2007-05-03 | 2007-05-03 | 1212122010M, 1212122045M | 201d |  |
| 1212122075 |  | Update PED Cost and Schedule (RESON CNTL & INTRLCKS) | 10d | 2007-05-03 | 2007-05-16 | 1212122070M | 201d |  |
| 1212122080 |  | Update Construction Cost and Schedule (RESON CNTL & INTRLCKS) | 10d | 2007-05-17 | 2007-05-31 | 1212122075 | 201d |  |
| 1212122085M |  | Resonance Control Ready for Baseline (RESON CNTL & INTRLCKS) | 0d | 2007-05-31 | 2007-05-31 | 1212122080 | 201d |  |
| 1212122035 |  | Interlock Validation Testing (RESON CNTL & INTRLCKS) | 60d | 2007-08-01 | 2007-10-24 | 1212122030 FS+55d | 184d |  |
| 1212122055 |  | Build PZT Driver chassis validation unit (RESON CNTL & INTRLCKS) | 10d | 2007-08-06 | 2007-08-17 | 1212122050 | 86d |  |
| 1212122060 |  | Conduct PZT Driver chassis Validation testing (RESON CNTL & INTRLCKS) | 60d | 2007-08-20 | 2007-11-12 | 1212122055 | 86d |  |
| 1212122040M |  | Interlock Validation Completed (RESON CNTL & INTRLCKS) | 0d | 2007-10-24 | 2007-10-24 | 1212122035 | 184d |  |
| 1212122095 |  | Cavity Interlock Tests P-1(RESON CNTL & INTRLCKS) | 25d | 2007-10-25 | 2007-11-30 | 1212122040M | 184d |  |
| 1212122065M |  | PZT Driver chassis Validation test complete (RESON CNTL & INTRLCKS) | 0d | 2007-11-12 | 2007-11-12 | 1212122060 | 86d |  |
| 1212122090 |  | Resonance Cavity Tests P-1 (RESON CNTL & INTRLCKS) | 12d | 2007-11-13 | 2007-11-30 | 9-080M, 1212122085M, 1212122065M | 86d |  |
| 1212122095B |  | FY08 Cavity Interlock Tests P-2 (RESON CNTL & INTRLCKS) | 21d | 2008-09-02 | 2008-09-30 | 1212122095 | 0d | start on 2008-09-02 |
| 1212122090B |  | FY08 LAB/EXP Resonance Cavity Tests P-2 (RESON CNTL & INTRLCKS) | 5d | 2008-09-24 | 2008-09-30 | 1212122090 FS+200d | 86d |  |
| 1212122090Ba |  | FY08 LAB/EXP Resonance Cavity Tests P-2 (RESON CNTL & INTRLCKS) | 142d | 2008-10-01 | 2009-04-30 | 1212122090B | 86d |  |
| 1212122095Ba |  | FY09 Cavity Interlock Tests P-2 (RESON CNTL & INTRLCKS) | 96d | 2008-10-01 | 2009-02-25 | 1212122095B | 7d |  |
| 1212122100 |  | Resonance & Interlock Dsgn Assessmnt (RESON CNTL & INTRLCKS) | 107d | 2009-01-21 | 2009-06-22 | 1212122095Ba FS-25d | 7d |  |
| 1212122170 |  | Pre-Constrctn Dsgn Review (RESON CNTL & INTRLCKS) | 20d | 2009-05-01 | 2009-05-29 | 1212122090Ba, 1212122095Ba | 86d |  |
| 1212122105 |  | Update Documentation and Procurement Prep (RESON CNTL & INTRLCKS) | 86d | 2009-05-20 | 2009-09-21 | 1212122100 FS-23d | 7d |  |
| 1212122110M |  | Documentation Ready for Prcrmnt (RESON CNTL & INTRLCKS)+ | 0d | 2009-09-21 | 2009-09-21 | 1212122105 | 7d |  |

| ID | WBS | Task | Duration | Start | Finish | Predecessors | Total float |
| --- | --- | --- | --- | --- | --- | --- | --- |
| 1212122175 |  | Re-Baseline Actuals Adjustment | 1d | 2013-08-30 | 2013-08-30 | 9-130M FS+227d | 20d |
|  | 3 | **1.2.1.2.1.2.3 PACKAGE/INTERFACE** |  | 2007-03-15 | 2013-08-30 |  |  |
| 1212123000M |  | Start Preliminary Integrated System Design (PKG/INTRFC) | 0d | 2007-03-15 | 2007-03-15 | 9-070M FS+108d | 301d |
| 1212123005 |  | Develop Preliminary Integrated System Design (PKG/INTRFC) | 40d | 2007-03-15 | 2007-05-09 | 1212123000M | 321d |
| 1212123015M |  | Start Cost & Schedule Update (PKG/INTRFC) | 0d | 2007-03-15 | 2007-03-15 | 1212123000M | 301d |
| 1212123020 |  | Update PED Cost and Schedule (PKG/INTRFC) | 30d | 2007-03-15 | 2007-04-25 | 1212123015M | 301d |
| 1212123025 |  | Update Construction Cost and Schedule (PKG/INTRFC) | 30d | 2007-04-26 | 2007-06-07 | 1212123020 | 301d |
| 1212123010M |  | Preliminary Integrated Design Complete (PKG/INTRFC) | 0d | 2007-05-09 | 2007-05-09 | 1212123005 | 321d |
| 1212123030M |  | Racks-Interface Ready for Baseline (PKG/INTRFC) | 0d | 2007-06-07 | 2007-06-07 | 1212123025, 1212123010M | 301d |
| 1212123035 |  | Dsgn Chassis Pwr Supply (PKG/INTRFC) | 20d | 2007-10-01 | 2007-10-26 | 9-080M | 69d |
| 1212123040 |  | Proc & Test PS P-1 (PKG/INTRFC) | 23d | 2007-10-29 | 2007-11-30 | 1212123035 | 69d |
| 1212123040B |  | Proc & Test PS P-2 (PKG/INTRFC) | 60d | 2008-02-22 | 2008-05-15 | 1212123040 FS+50d | 69d |
| 1212123045 |  | Final Dsgn Rack Layout with FC, Res & PS (PKG/INTRFC) | 95d | 2008-05-16 | 2008-09-30 | 1212123030M, 1212123040B | 69d |
| 1212123050 |  | Update Documentation and Procurement Prep(PKG/INTRFC) | 179d | 2008-10-01 | 2009-06-23 | 1212123045 | 69d |
| 1212123170 |  | Pre-Constrctn Dsgn Review (PKG/INTRFC) | 20d | 2009-05-01 | 2009-05-29 | 1212123045 FS+142d | 86d |
| 1212123055M |  | Rack Documentation Ready for Prcrmnt (PKG/INTRFC)+ | 0d | 2009-06-23 | 2009-06-23 | 1212123050 | 69d |
| 1212123175 |  | Re-Baseline Actuals Adjustment | 1d | 2013-08-30 | 2013-08-30 | 9-130M FS+227d | 20d |
|  | 4 | **1.2.1.2.1.2.4 CPU & SOFTWARE** |  | 2006-11-01 | 2013-08-30 |  |  |
| 1212124000M |  | Start Preliminary Integrated System Design (CPU & SW)100 | 0d | 2006-11-01 | 2006-11-01 | 9-070M FS+22d | 172d |
| 1212124005 |  | Develop Preliminary Integrated System Design (CPU & SW)100 | 80d | 2006-11-01 | 2007-03-06 | 1212124000M | 191d |
| 1212124020M |  | Start Embedded IOC Design (CPU & SW)100 | 0d | 2007-01-02 | 2007-01-02 | 1212124000M FS+36d | 173d |
| 1212124025 |  | Develop Preliminary Embedded IOC Design (CPU & SW)85 | 60d | 2007-01-02 | 2007-03-28 | 1212124020M | 173d |
| 1212124010M |  | Preliminary Integrated Design Complete (CPU & SW)100 | 0d | 2007-03-06 | 2007-03-06 | 1212124005 | 191d |
| 1212124015 |  | Refine Embedded IOC Detailed specification (CPU & SW)30 | 20d | 2007-03-07 | 2007-04-03 | 1212124010M | 191d |
| 1212124030M |  | Start Validation Unit Testing (CPU & SW) | 0d | 2007-03-29 | 2007-03-29 | 1212124025 | 173d |
| 1212124045M |  | Start Cost & Schedule Update (CPU & SW)100 | 0d | 2007-04-03 | 2007-04-03 | 1212124000M FS+99d | 172d |
| 1212124050 |  | Update PED Cost and Schedule (CPU & SW)100 | 20d | 2007-04-03 | 2007-04-30 | 1212124045M | 172d |
| 1212124035 |  | Conduct Validation Testing w Digital Board (CPU & SW) | 42d | 2007-04-06 | 2007-06-05 | 1212121055M, 1212124030M | 167d |
| 1212124055 |  | Update Construction Cost and Schedule (CPU & SW)100 | 20d | 2007-05-01 | 2007-05-29 | 1212124015, 1212124050 | 172d |
| 1212124060M |  | Controls Ready for Baseline (CPU & SW)100 | 0d | 2007-05-29 | 2007-05-29 | 1212124055 | 172d |
| 1212124040M |  | Validation Tests Complete (CPU & SW) | 0d | 2007-06-05 | 2007-06-05 | 1212124060M, 1212124035 | 167d |
| 1212124065 |  | Program EPICS Interface P-1 (CPU&SW) | 43d | 2007-10-01 | 2007-11-30 | 9-080M, 1212124040M | 86d |
| 1212124065B |  | Program EPICS Interface P-2 (CPU&SW) | 54d | 2008-06-02 | 2008-08-15 | 1212124065 FS+120d | 86d |
| 1212124070M |  | EPICS Ready for Test (CPU&SW) | 0d | 2008-08-15 | 2008-08-15 | 1212124065B | 86d |
| 1212124075 |  | Cavity Tests & Modifications (CPU&SW) | 133d | 2008-09-15 | 2009-04-01 | 1212124070M FS+19d | 86d |
| 1212124080M |  | CPU & Software tested on Cavity (CPU&SW)++ | 0d | 2009-04-15 | 2009-04-15 | 1212124075 FS+10d | 86d |
| 1212124170 |  | Pre-Constrctn Dsgn Review (CPU&SW)++ | 20d | 2009-05-01 | 2009-05-29 | 1212124080M FS+11d | 86d |
| 1212124175 |  | Re-Baseline Actuals Adjustment | 1d | 2013-08-30 | 2013-08-30 | 9-130M FS+227d | 20d |
|  | 5 | **1.2.1.2.1.2.5 TEST STAND** |  | 2007-03-15 | 2013-08-30 |  |  |
| 1212125000M |  | Start Cost & Schedule Update (TEST STAND) | 0d | 2007-03-15 | 2007-03-15 | 9-070M FS+108d | 26d |
| 1212125005 |  | Update PED Cost and Schedule (TEST STAND) | 30d | 2007-03-15 | 2007-04-25 | 1212125000M | 26d |
| 1212125010 |  | Update Construction Cost and Schedule (TEST STAND) | 30d | 2007-04-26 | 2007-06-07 | 1212125005 | 26d |
| 1212125015M |  | Test Stand Ready for Baseline (TEST STAND) | 0d | 2007-06-07 | 2007-06-07 | 1212125010 | 26d |
| 1212125020 |  | Dsgn & Fab RF Test Stand (Test STAND)-seeNotebook Entry | 369d | 2008-04-08 | 2009-09-28 | 9-080M FS+125d, 1212125015M FS+180d | 2d |
| 1212125025M |  | RF Test Stand Ready for Production Tests (TEST STAND)+ | 0d | 2009-09-28 | 2009-09-28 | 1212125020 | 2d |
| 1212125030 |  | Re-Baseline Actuals Adjustment | 1d | 2013-08-30 | 2013-08-30 | 9-130M FS+227d | 20d |
|  | 6 | **1.2.1.2.1.2.6 MASTER OSCILLATOR** |  | 2007-03-15 | 2013-08-30 |  |  |
| 1212126000M |  | Start Cost & Schedule Update (MSTR OSC) | 0d | 2007-03-15 | 2007-03-15 | 9-070M FS+108d | 570d |
| 1212126005 |  | Update PED Cost and Schedule (MSTR OSC) | 30d | 2007-03-15 | 2007-04-25 | 1212126000M | 570d |
| 1212126010 |  | Update Construction Cost and Schedule (MSTR OSC) | 30d | 2007-04-26 | 2007-06-07 | 1212126005 | 570d |
| 1212126015M |  | MO Ready for Baseline (MSTR OSC) | 0d | 2007-06-07 | 2007-06-07 | 1212126010 | 570d |
| 1212126170 |  | Pre-Constrctn Dsgn Review (MSTR OSC) | 5d | 2007-06-08 | 2007-06-14 | 1212126010, 1212126015M | 570d |
| 1212126175 |  | Re-Baseline Actuals Adjustment | 1d | 2013-08-30 | 2013-08-30 | 9-130M FS+227d | 20d |
|  | 7 | **1.2.1.2.1.2.7 HPA CONTROL** |  | 2006-11-01 | 2013-08-30 |  |  |
| 1212127000M |  | Start Preliminary Integrated System Design (HPA CNTRL) | 0d | 2006-11-01 | 2006-11-01 | 9-070M FS+22d | 243d |
| 1212127005 |  | Develop Preliminary System Design (HPA CNTRL) | 50d | 2006-11-01 | 2007-01-22 | 1212127000M | 276d |
| 1212127010M |  | Preliminary Design Complete (HPA CNTRL) | 0d | 2007-01-22 | 2007-01-22 | 1212127005 | 276d |
| 1212127020M |  | Start Cost & Schedule Update (HPA CNTRL) | 0d | 2007-04-03 | 2007-04-03 | 9-070M FS+121d | 187d |
| 1212127025 |  | Update PED Cost and Schedule (HPA CNTRL) | 20d | 2007-04-03 | 2007-04-30 | 1212127020M | 187d |
| 1212127030 |  | Update Construction Cost and Schedule (HPA CNTRL) | 20d | 2007-05-01 | 2007-05-29 | 1212127025 | 187d |
| 1212127035M |  | HPA Controls Ready for Baseline (HPA CNTRL) | 0d | 2007-05-29 | 2007-05-29 | 1212127030, 1212127010M | 187d |
| 1212127015 |  | Develop Detailed specification P-1 (HPA CNTRL) | 43d | 2007-10-01 | 2007-11-30 | 1212127000M, 1212112090M | 18d |
| 1212127015B |  | Develop Detailed specification P-2 (HPA CNTRL) | 40d | 2007-12-03 | 2008-02-06 | 1212127015 | 18d |
| 1212127040 |  | Dsgn HPA Control Board & Chassis (HPA CNTL) | 142d | 2008-02-07 | 2008-08-27 | 9-080M, 1212127035M, 1212127015B | 18d |
| 1212127045 |  | PROC Test & Validate Dsgn (HPA CNTL) | 97d | 2008-09-12 | 2009-02-06 | 1212127040 FS+10d | 35d |
| 1212127045a |  | FY08 LAB/EXP Test & Validate Dsgn (HPA CNTL) | 13d | 2008-09-12 | 2008-09-30 | 1212127040 FS+10d | 18d |
| 1212127045b |  | FY09 LAB/EXP Test & Validate Dsgn (HPA CNTL) | 84d | 2008-10-01 | 2009-02-06 | 1212127045a | 18d |
| 1212127050M |  | HPA Control Dsgn Tested (HPA CNTL) | 0d | 2009-03-04 | 2009-03-04 | 1212127045, 1212127045b FS+17d | 18d |
| 1212127055 |  | Assess & Modify Dsgn (HPA CNTL) | 108d | 2009-03-05 | 2009-08-05 | 1212127050M | 18d |
| 1212127170 |  | Pre-Constrctn Dsgn Review (HPA CNTL) + | 20d | 2009-05-01 | 2009-05-29 | 1212127050M FS+41d | 86d |

| ID | WBS | Task | Duration | Start | Finish | Predecessors | Total float |
| --- | --- | --- | --- | --- | --- | --- | --- |
| 1212127060 |  | Update Documentation and Procurement Prep (HPA CNTL) | 66d | 2009-06-03 | 2009-09-03 | 1212127055 FS-45d | 18d |
| 1212127065M |  | HPA control Documentation Ready for Prcrmnt (HPA CNTL)++ | 0d | 2009-09-03 | 2009-09-03 | 1212127060 | 18d |
| 1212127175 |  | Re-Baseline Actuals Adjustment | 1d | 2013-08-30 | 2013-08-30 | 9-130M FS+227d | 20d |
|  | 3 | **1.2.1.2.1.3 INSTALLATION (PED)** |  |  |  |  |  |
|  | 4 | **1.2.1.2.1.4 SYSTEM OPERATION** |  |  |  |  |  |
|  | 2 | **1.2.1.2.2 MAGNET POWER** |  | 2006-10-02 | 2013-08-30 |  |  |
|  | 1 | **1.2.1.2.2.1 BOX SUPPLIES - PED** |  | 2006-10-02 | 2013-08-30 |  |  |
| 121221000M |  | Begin Box PS PED (BOX SUP) | 0d | 2006-10-02 | 2006-10-02 | 9-070M | 150d |
| 121221005 |  | Conduct Spec & Cost Review of Other Projects (BOX SUP) | 30d | 2006-10-02 | 2006-11-10 | 121221000M | 150d |
| 121221010 |  | Travel _ Visit Other Projects (BOX SUP) | 30d | 2006-10-02 | 2006-11-10 | 121221000M | 150d |
| 121221015 |  | Refine/Update Preliminary Performance Requirements (BOX SUP) | 20d | 2006-11-13 | 2006-12-12 | 121221005, 121221010 | 150d |
| 121221020M |  | Preliminary Preformance Requirements Update Complete (BOX SUP) | 0d | 2006-12-12 | 2006-12-12 | 121221015 | 150d |
| 121221025M |  | Begin Preliminary Design Box Power Supplies (BOX SUP) | 0d | 2006-12-13 | 2006-12-13 | 121221020M | 150d |
| 121221030 |  | Develop Preliminary PS Design (BOX SUP) | 30d | 2006-12-13 | 2007-02-01 | 121221025M | 150d |
| 121221035 |  | Review & Revise PS Re-use Plan & Cost Estimate (BOX SUP) | 20d | 2007-02-02 | 2007-03-02 | 121221030 | 150d |
| 121221040 |  | Prepare & Conduct Preliminary Design & Safety Review (BOX SUP) | 15d | 2007-03-05 | 2007-03-23 | 121221035 | 150d |
| 121221045M |  | Preliminary Design & Safety Review Complete (BOX SUP) | 0d | 2007-03-23 | 2007-03-23 | 121221040 | 150d |
| 121221050 |  | Update Cost and Labor Estimates (BOX SUP) | 20d | 2007-03-26 | 2007-04-20 | 121221045M | 150d |
| 121221055 |  | Update Resource Loaded Schedule (BOX SUP) | 20d | 2007-04-23 | 2007-05-18 | 121221050 | 150d |
| 121221065 |  | Investigate Potential Vendors to Develop Bidders list (BOX SUP) | 20d | 2007-05-21 | 2007-06-18 | 121221055 | 157d |
| 121221070 |  | Write Preliminary PS Design Document (BOX SUP) | 31d | 2007-06-19 | 2007-08-01 | 121221065 | 157d |
| 121221075M |  | Preliminary PS Design Document Complete (BOX SUP) | 0d | 2007-08-01 | 2007-08-01 | 121221070 | 157d |
| 121221085 |  | Develop Dsgn & Specification for 1000 kW Box PS | 60d | 2007-10-01 | 2008-01-03 | 121221075M, 9-080M | 116d |
| 121221090 |  | Develop Dsgn & Specification for 600 kW Box PS | 60d | 2007-10-01 | 2008-01-03 | 9-080M | 116d |
| 121221095 |  | Develop Dsgn & Specification for Low Power (100/30 kW) Box PS | 60d | 2007-10-01 | 2008-01-03 | 9-080M | 116d |
| 121221120 |  | Develop Plan for YA and Shunt PS | 30d | 2008-01-04 | 2008-02-15 | 121221095, 121221085, 121221090 | 116d |
| 121221100 |  | Develop Design Spec for Dummy load | 20d | 2008-02-04 | 2008-03-03 | 9-080M FS+80d | 46d |
| 121221105 |  | Develop Box PS Re-use Plans | 20d | 2008-02-04 | 2008-03-03 | 9-080M FS+80d | 336d |
| 121221125 |  | Create Bill of Materials & Parts List for YA and Shunt PS | 30d | 2008-02-19 | 2008-03-31 | 121221120 | 346d |
| 121221110 |  | Prepare Procurement Plan for Box PS Refurbishment | 30d | 2008-03-04 | 2008-04-14 | 121221105 | 336d |
| 121221135 |  | Pre-Constrctn Final Sys & Safty Review (Box SUPPLIES) | 30d | 2008-03-04 | 2008-04-14 | 121221100 | 46d |
| 121221140 |  | Update Cost & Labor Estimates (Box SUPPLIES) | 30d | 2008-04-15 | 2008-05-27 | 121221135 | 46d |
| 121221145 |  | Update Schedule (Box SUPPLIES) | 30d | 2008-04-15 | 2008-05-27 | 121221135 | 46d |
| 121221150 |  | Prep Final Specification & Prcrmnt Package (Box SUPPLIES)+ | 30d | 2008-07-24 | 2008-09-04 | 121221125, 121221140 FS+40d, 121221110, 121221145 FS+40d | 266d |
| 121221155 |  | Re-Baseline Actuals Adjustment | 1d | 2013-08-30 | 2013-08-30 | 9-130M FS+227d | 20d |
|  | 2 | **1.2.1.2.2.2 SHUNTS - PED** |  |  |  |  |  |
|  | 3 | **1.2.1.2.2.3 TRIMS - PED** |  | 2006-10-02 | 2013-08-30 |  |  |
| 121223000M |  | Start Trim PED (TRIMS) | 0d | 2006-10-02 | 2006-10-02 | 9-070M | 146d |
| 121223005 |  | Update Trim PS Counts and System design- update TDR (TRIMS) | 65d | 2006-10-02 | 2007-01-10 | 121223000M | 170d |
| 121223010 |  | Procure utility chassis sample and Bulk PS sample (TRIMS) | 59d | 2006-10-02 | 2007-01-02 | 121223000M | 146d |
| 121223015M |  | Receive sample hardware (TRIMS) | 0d | 2007-01-02 | 2007-01-02 | 121223010 | 146d |
| 121223020 |  | Install samples into Trim test stand and Test (TRIMS) | 30d | 2007-01-03 | 2007-02-14 | 121223015M | 146d |
| 121223025 |  | Update Trim PS Cost estimate (TRIMS) | 30d | 2007-02-15 | 2007-03-29 | 121223010, 121223020, 121223005 | 146d |
| 121223030 |  | Develop resource loaded schedule (TRIMS) | 40d | 2007-03-30 | 2007-05-24 | 121223025 | 146d |
| 121223030M |  | Start Trim FY08 PED (TRIMS) | 0d | 2007-10-01 | 2007-10-01 | 9-080M | 36d |
| 121223032 |  | Proc Sample Commercial PS (TRIMS) | 60d | 2007-10-01 | 2008-01-03 | 9-080M, 121223030M | 36d |
| 121223035 |  | Test Sample PS (TRIMS) | 10d | 2008-01-04 | 2008-01-17 | 121223032 | 36d |
| 121223040 |  | Develop Specification for 20 amp trim (TRIMS) | 30d | 2008-01-18 | 2008-03-03 | 121223035 | 36d |
| 121223045 |  | Prep Trim Sys Database (TRIMS) | 30d | 2008-03-04 | 2008-04-14 | 121223040 | 36d |
| 121223055 |  | Develop Sys Drawings (TRIMS)++ | 30d | 2008-04-15 | 2008-05-27 | 121223045 | 36d |
| 121223050 |  | Pre-Constrctn Final Sys & Safty Review (TRIMS)++ | 10d | 2008-05-28 | 2008-06-10 | 121223045, 121223055 | 36d |
| 121223060 |  | FY08 Prep Final Specification & Prcrmnt Package (TRIMS) | 78d | 2008-06-11 | 2008-09-30 | 121223055, 9-080M, 121223050 | 196d |
| 121223060a |  | FY09 Prep Final Specification & Prcrmnt Package (TRIMS) | 52d | 2008-10-01 | 2008-12-15 | 121223060 | 196d |
| 121223065 |  | Re-Baseline Actuals Adjustment | 1d | 2013-08-30 | 2013-08-30 | 9-130M FS+227d | 20d |
|  | 4 | **1.2.1.2.2.4 INSTALLATION - PED** |  | 2006-11-01 | 2013-08-30 |  |  |
| 121224022 |  | Preliminary Installation Integration (INSTALL) | 140d | 2006-11-01 | 2007-05-30 | 9-070M FS+22d | 143d |
| 121224000M |  | Start Installation Planning (INSTALL) | 0d | 2007-03-15 | 2007-03-15 | 9-070M FS+108d | 125d |
| 121224005 |  | Update Trim PS Counts (INSTALL) | 10d | 2007-03-15 | 2007-03-28 | 121224000M | 130d |
| 121224010 |  | Update Hall D Equipment Layout (INSTALL) | 15d | 2007-03-15 | 2007-04-04 | 121224000M | 125d |
| 121224015 |  | Develop Trim Installation requirements (INSTALL) | 20d | 2007-04-05 | 2007-05-02 | 121224010, 121224005 | 125d |
| 121224020 |  | Develop Box PS Cable Installation requirements (INSTALL) | 20d | 2007-04-05 | 2007-05-02 | 121224010 | 125d |
| 121224025 |  | Update cost estimate (INSTALL) | 15d | 2007-05-03 | 2007-05-23 | 121224020, 121224015 | 125d |
| 121224030 |  | Create Installation Plan and schedule (INSTALL) | 22d | 2007-05-24 | 2007-06-25 | 121224025 | 125d |
| 121224035 |  | Dsgn & Assemble Proto Box PS Cable Interconnection Sys (Installtn) | 50d | 2007-10-01 | 2007-12-11 | 9-080M | 151d |
| 121224040 |  | Review/Revise Cable Lists- DC Pwr, Interlocks, Controls - Develop Installtn Database (Installtn) | 60d | 2007-10-01 | 2008-01-03 | 9-080M | 41d |
| 121224045 |  | Dsgn Cable Tray Layout, Prep Installtn Drawings (Installtn) | 20d | 2008-01-04 | 2008-02-01 | 121224040 | 41d |
| 121224050 |  | Develop Box Supply Shuffle-Rebuild-Install Plan & S/R Plan (Installtn) | 20d | 2008-02-04 | 2008-03-03 | 121224045 | 41d |
| 121224055 |  | Prep/Dsgn Utility Installtn - LCW & AC Pwr (Installtn) | 30d | 2008-03-04 | 2008-04-14 | 121224050 | 41d |
| 121224060 |  | Prep Bill of Matrl's & Update Matrl's & Labor Cost Estimate (Installtn) | 15d | 2008-04-15 | 2008-05-05 | 121224055 | 41d |
| 121224065 |  | Perform Installtn Hazard Analysis & Revise Schedule (Installtn)++ | 15d | 2008-05-06 | 2008-05-27 | 121224060 | 41d |

| ID | WBS | Task | Duration | Start | Finish | Predecessors | Total float |
| --- | --- | --- | --- | --- | --- | --- | --- |
| 121224999 |  | Pre-Constrctn Final Sys & Safty Review (Installtn)++ | 5d | 2008-05-28 | 2008-06-03 | 121224065, 121224035 | 41d |
| 121224070 |  | Re-Baseline Actuals Adjustment | 1d | 2013-08-30 | 2013-08-30 | 9-130M FS+227d | 20d |
|  | 3 | **1.2.1.3 CRYOGENICS** |  | 2006-10-02 | 2013-08-30 |  |  |
|  | 1 | **1.2.1.3.1 ACCELERATOR** |  | 2006-10-02 | 2013-08-30 |  |  |
| 12131010M |  | Preliminary Engineering Design & Safety Review Completed (ACCEL) | 0d | 2007-01-12 | 2007-01-12 | 12131.04010 | 21d |
|  | 01 | **1.2.1.3.1.01 CHL BUILDING LAYOUT & UTILITIES REQ** |  | 2006-10-02 | 2013-08-30 |  |  |
| 12131.01005 |  | Develop CHL Building Layout and Utility Schedule (CHL BLDG) | 15d | 2006-10-02 | 2006-10-20 | 9-070M | 68d |
| 12131.01010 |  | Re-Baseline Actuals Adjustment | 1d | 2013-08-30 | 2013-08-30 | 9-130M FS+227d | 20d |
|  | 02 | **1.2.1.3.1.02 CHL SYSTEM P&ID DEVELOPMENT** |  |  |  |  |  |
|  | 03 | **1.2.1.3.1.03 CHL WARM HELIUM COMPRESSORS** |  | 2006-10-02 | 2013-08-30 |  |  |
| 12131.03005 |  | Develop Warm Helium Compressor Piping Dsgn, Prelim | 62d | 2006-10-02 | 2007-01-05 | 9-070M | 21d |
| 12131.03010 |  | FY-07 Develop Warm Helium Compressor Piping Design Initial Phase Final Design (CHL WARM HEL COMPR) | 28d | 2007-04-23 | 2007-05-31 | 12131.06010, 12131.05010 FS-21d | 290d |
| 12131.03012 |  | FY-08 Develop Wrm He Cmprssr Piping Dsgn, Initl Phase Final Dsgn | 28d | 2008-10-01 | 2008-11-07 | 12131.03010, 9-090M | 140d |
| 12131.03015 |  | CHL Warm Helium Compressors++ | 75d | 2008-11-10 | 2009-03-06 | 12131.03012, 9-080M | 140d |
| 12131.03020 |  | CHL Warm Helium Compressors Pre-Constrctn Dsgn Review+ | 5d | 2009-03-09 | 2009-03-13 | 12131.03015 | 140d |
| 12131.03025 |  | Re-Baseline Actuals Adjustment | 1d | 2013-08-30 | 2013-08-30 | 9-130M FS+227d | 20d |
|  | 04 | **1.2.1.3.1.04 CHL COLD BOXES** |  | 2006-10-02 | 2013-08-30 |  |  |
| 12131.04005 |  | Develop CHL Cold Box Field Piping Design Preliminary (CHL COLD BOX) | 62d | 2006-10-02 | 2007-01-05 | 9-070M | 21d |
| 12131.04010 |  | Conduct Prelimin Eng Design & Safety Review for WBS 1.2.1.3.1 Elements (CHL COLD BOX) | 5d | 2007-01-08 | 2007-01-12 | 12131.03005, 12131.01005, 12131.05005, 12131.04005, 12131.07005, 12131.10005, 12131.06005, 12131.11005 | 21d |
| 12131.04015 |  | FY-07 Develop CHL Cold Box Field Piping Design Initial Phase Final Design (CHL COLD BOX) | 85d | 2007-01-16 | 2007-05-15 | 12131010M | 146d |
| 12131.04017 |  | FY-08 Develop CHL Cold Box Field Piping Dsgn, Final Phase Final Dsgn | 65d | 2007-10-01 | 2008-01-10 | 9-080M, 12131.04015 | 51d |
| 12131.04020 |  | P-1 CHL Cold Box, Dsgn Installtn+ | 90d | 2008-01-11 | 2008-05-19 | 12131.04017, 9-080M | 51d |
| 12131.04025 |  | P-2 CHL Cold Box, Dsgn Installtn+ | 90d | 2009-01-05 | 2009-05-12 | 1331.02000 FS-188d | 98d |
| 12131.04030 |  | Re-Baseline Actuals Adjustment | 1d | 2013-08-30 | 2013-08-30 | 9-130M FS+227d | 20d |
|  | 05 | **1.2.1.3.1.05 CHL OIL REMOVAL SYSTEMS** |  | 2006-10-02 | 2013-08-30 |  |  |
| 12131.05005 |  | Develop Oil Removal Equipment Fabricaton Drawings Preliminary (CHL OIL REM SYS) | 62d | 2006-10-02 | 2007-01-05 | 9-070M | 21d |
| 12131.05010 |  | Develop Oil Removal Equipment Fabricaton Drawings Initial Phase Final Design (CHL OIL REM SYS) | 28d | 2007-03-23 | 2007-05-01 | 12131.06010 FS-21d | 304d |
| 12131.05020 |  | Re-Baseline Actuals Adjustment | 1d | 2013-08-30 | 2013-08-30 | 9-130M FS+227d | 20d |
|  | 06 | **1.2.1.3.1.06 CHL GAS MANAGEMENT RACK** |  | 2006-10-02 | 2013-08-30 |  |  |
| 12131.06005 |  | Develop Gas Management Rack Assembly and Fabrication Drawings Preliminary (CHL GAS MNGMT RACK) | 62d | 2006-10-02 | 2007-01-05 | 9-070M | 21d |
| 12131.06010 |  | Develop Gas Management Rack Assembly and Fabrication Drawings Initial Phase Final Design (CHL GAS MNGMT RACK) | 28d | 2007-03-14 | 2007-04-20 | 12131010M FS+40d | 290d |
| 12131.06015 |  | Re-Baseline Actuals Adjustment | 1d | 2013-08-30 | 2013-08-30 | 9-130M FS+227d | 20d |
|  | 07 | **1.2.1.3.1.07 CHL SYSTEM INSTRUMENTATION & CONTROLS** |  | 2006-10-02 | 2013-08-30 |  |  |
| 12131.07005 |  | Develop CHL Instrumentation and Controls Assembly Design Preliminary (CHL SYS INSTR & CNTRLS) | 62d | 2006-10-02 | 2007-01-05 | 9-070M | 21d |
| 12131.07010 |  | FY-07 Develop CHL Instrumentation and Controls Assembly Design Initial Phase Final Design (CHL SYS INSTR & CNTRLS) | 180d | 2007-01-16 | 2007-09-28 | 12131010M | 21d |
| 12131.07012 |  | FY-08 Develop CHL Inst & Controls Assy Dsgn, Initl Phase Final Dsgn | 150d | 2007-10-01 | 2008-05-12 | 12131.07010, 9-080M | 21d |
| 12131.07015 |  | PROC Engineer CHL Sys Instrmenttn & Controls+ | 325d | 2008-05-13 | 2009-08-31 | 12131.07012 | 21d |
| 12131.07015a |  | FY08 LAB/EXP Engineer CHL Sys Instrmenttn & Controls+ | 98d | 2008-05-13 | 2008-09-30 | 12131.07012 | 21d |
| 12131.07015b |  | FY09 LAB/EXP Engineer CHL Sys Instrmenttn & Controls+ | 227d | 2008-10-01 | 2009-08-31 | 12131.07015a | 21d |
| 12131.07020 |  | Re-Baseline Actuals Adjustment | 1d | 2013-08-30 | 2013-08-30 | 9-130M FS+227d | 20d |
|  | 08 | **1.2.1.3.1.08 CHL INSTRUMENT AIR SYSTEM** |  | 2009-04-08 | 2013-08-30 |  |  |
| 12131.08000 |  | CHL Instrument Air Sys Engrng+ | 100d | 2009-04-08 | 2009-08-27 | 9-090M FS+125d | 23d |
| 12131.08010 |  | Re-Baseline Actuals Adjustment | 1d | 2013-08-30 | 2013-08-30 | 9-130M FS+227d | 20d |
|  | 09 | **1.2.1.3.1.09 MOTOR CONTROL CENTERS** |  | 2009-04-08 | 2013-08-30 |  |  |
| 12131.09000 |  | Motor Control Center Specification Development+ | 30d | 2009-04-08 | 2009-05-19 | 9-090M FS+125d | 93d |
| 12131.09005 |  | Re-Baseline Actuals Adjustment | 1d | 2013-08-30 | 2013-08-30 | 9-130M FS+227d | 20d |
|  | 10 | **1.2.1.3.1.10 CHL INSTALLATION DESIGN** |  | 2006-10-02 | 2013-08-30 |  |  |
| 12131.10005 |  | Develop Utility Field Piping Installation Design Preliminary (CHL INSTAL DES) | 55d | 2006-10-02 | 2006-12-19 | 9-070M | 28d |
| 12131.10010 |  | Engineer & Dsgn CHL Installtn+ | 180d | 2007-10-01 | 2008-06-24 | 9-080M | 26d |
| 12131.10015 |  | Re-Baseline Actuals Adjustment | 1d | 2013-08-30 | 2013-08-30 | 9-130M FS+227d | 20d |
|  | 11 | **1.2.1.3.1.11 CHL COMMISSIONING PLANNING** |  | 2006-10-02 | 2013-08-30 |  |  |
| 12131.11005 |  | Develop CHL Commissioning Design and Plan Preliminary (CHL COMMIS) | 35d | 2006-10-02 | 2006-11-17 | 9-070M | 48d |
| 12131.11010 |  | Develop CHL Cmmssng Plan++ | 45d | 2008-01-04 | 2008-03-10 | 9-080M FS+60d | 101d |
| 12131.11015 |  | Re-Baseline Actuals Adjustment | 1d | 2013-08-30 | 2013-08-30 | 9-130M FS+227d | 20d |
|  | 12 | **1.2.1.3.1.12 LINAC TRANSFER LINE** |  |  |  |  |  |
|  | 2 | **1.2.1.3.2 HALL D** |  | 2009-01-12 | 2013-08-30 |  |  |
|  | 1 | **1.2.1.3.2.1 CHL-HALL D TRANSFER LINE** |  |  |  |  |  |
|  | 2 | **1.2.1.3.2.2 HALL D COLD BOX** |  | 2009-04-08 | 2013-08-30 |  |  |
| 121322000 |  | Evaluate H-D Refrigerator Cold Box+ | 35d | 2009-04-08 | 2009-05-27 | 9-090M FS+125d | 88d |
| 121322005 |  | Re-Baseline Actuals Adjustment | 1d | 2013-08-30 | 2013-08-30 | 9-130M FS+227d | 20d |
|  | 3 | **1.2.1.3.2.3 HALL D DISTRIBUTION SYSTEM** |  | 2009-01-12 | 2013-08-30 |  |  |
| 121323000 |  | Dsgn H-D Refrigerator Interconnecting Piping+ | 110d | 2009-01-12 | 2009-06-17 | 9-090M FS+65d | 3d |
| 121323005 |  | Re-Baseline Actuals Adjustment | 1d | 2013-08-30 | 2013-08-30 | 9-130M FS+227d | 20d |
|  | 4 | **1.2.1.3.2.4 INSTRUMENTATION & CONTROLS** |  | 2009-06-18 | 2013-08-30 |  |  |
| 121324000 |  | Dsgn H-D Refrgerator Controls+ | 70d | 2009-06-18 | 2009-09-25 | 121323000 | 3d |
| 121324005 |  | Re-Baseline Actuals Adjustment | 1d | 2013-08-30 | 2013-08-30 | 9-130M FS+227d | 20d |
|  | 5 | **1.2.1.3.2.5 U-TUBES** |  | 2009-04-08 | 2013-08-30 |  |  |
| 121325000 |  | Dsgn H-D Refrigerator U-Tubes+ | 25d | 2009-04-08 | 2009-05-12 | 9-090M FS+125d | 98d |
| 121325005 |  | Re-Baseline Actuals Adjustment | 1d | 2013-08-30 | 2013-08-30 | 9-130M FS+227d | 20d |
|  | 6 | **1.2.1.3.2.6 FIELD INSTALLATION** |  |  |  |  |  |

| ID | WBS | Task | Duration | Start | Finish | Predecessors | Total float |
| --- | --- | --- | --- | --- | --- | --- | --- |
|  | 7 | **1.2.1.3.2.7 COMMISSIONING** |  |  |  |  |  |
|  | 4 | **1.2.1.4 BEAM TRANSPORT** |  | 2006-10-02 | 2013-08-30 |  |  |
|  | 1 | **1.2.1.4.1 SPREADERS & RECOMBINERS** |  | 2006-10-02 | 2013-08-30 |  |  |
|  | 1 | **1.2.1.4.1.1 DIPOLES** |  | 2006-10-02 | 2013-08-30 |  |  |
| 121411007LOE |  | FY07 Management of S/R PED Effort (DIPOLES) | 247d | 2006-10-02 | 2007-09-28 | 9-070M | 20d |
| 121411025 |  | Develop Preliminary design of S/R Dipoles and Septa (DIPOLES) | 110d | 2006-10-02 | 2007-03-16 | 9-070M | 404d |
| 121411015 |  | Beam Transport Physics Design & Safety Review (DIPOLES) | 30d | 2006-12-06 | 2007-01-25 | 9-070M FS+45d | 109d |
| 121411015M |  | Beam Transport Physics Design & Safety Review Completed (DIPOLES) | 0d | 2007-01-25 | 2007-01-25 | 121411015 | 109d |
| 121411030 |  | Preliminary Design & Safety Review of S/R Dipoles and Septa (DIPOLES) | 20d | 2007-02-16 | 2007-03-16 | 121411025 FS-20d | 404d |
| 121411030M |  | S/R Dipoles & Septa Preliminary Design & Safety Review Completed (DIPOLES) | 0d | 2007-03-16 | 2007-03-16 | 121411030 | 404d |
| 121411035 |  | FY07 Develop Detailed Design of West curved dipoles (DIPOLES) | 137d | 2007-03-19 | 2007-09-28 | 121411030M | 404d |
| 121411045 |  | FY07 Develop Detailed Design of New 3m Septa (DIPOLES) | 137d | 2007-03-19 | 2007-09-28 | 121411030M | 496d |
| 121411055 |  | Develop Detailed Design of New AG and 2m AH Replacements (DIPOLES) | 110d | 2007-03-19 | 2007-08-21 | 121411030M | 464d |
| 121411020 |  | Installation Cost Schedule and Safety Review (DIPOLES) | 20d | 2007-05-09 | 2007-06-06 | 9-070M FS+147d | 517d |
| 121411020M |  | Installation Cost Schedule and Safety Review Complete (DIPOLES) | 0d | 2007-06-06 | 2007-06-06 | 121411020 | 517d |
| 121411060M |  | Finish All New S/R C Shaped Dipoles (DIPOLES) | 0d | 2007-08-21 | 2007-08-21 | 121411055 | 464d |
| 121411036 |  | Develop Detailed Dsgn of West Curved Dipoles (S/R Dipoles) | 59d | 2007-10-01 | 2008-01-02 | 121411035 | 404d |
| 121411046 |  | Develop Detailed Dsgn of New 3m Septa (S/R Dipoles) | 59d | 2007-10-01 | 2008-01-02 | 121411020M, 121411060M, 9-080M | 437d |
| 121411075 |  | Detailed Dsgn of New 2m Septa (S/R Dipoles) | 130d | 2007-10-01 | 2008-04-14 | 9-080M | 366d |
| 121411080 |  | Detailed Dsgn of New 2m Narrow Pole Septa (S/R Dipoles) | 195d | 2007-10-01 | 2008-07-16 | 9-080M | 301d |
| 121411908LOE |  | FY08 Mngmnt of S/R PED Effort (S/R Dipoles) | 248d | 2007-10-01 | 2008-09-30 | 121411007LOE | 20d |
| 121411065 |  | Detailed Dsgn of East Curved Dipoles (S/R Dipoles) | 130d | 2007-12-03 | 2008-06-13 | 9-080M FS+43d | 323d |
| 121411050M |  | Detailed Dsgn of New 3m Septa Comp (S/R DIPOLES) | 0d | 2008-01-02 | 2008-01-02 | 121411046, 121411045 | 437d |
| 121411090 |  | FY08 Top Assy Dsgns for Modified S/R Dipoles (S/R Dipoles) | 128d | 2008-04-01 | 2008-09-30 | 9-080M FS+120d | 226d |
| 121411090a |  | FY09 Top Assy Dsgns for Modified S/R Dipoles (S/R Dipoles) | 22d | 2008-10-01 | 2008-10-30 | 121411090 | 226d |
| 121411909LOE |  | FY09 Mngmnt of S/R PED Effort (S/R Dipoles) | 248d | 2008-10-01 | 2009-09-30 | 121411908LOE, 121433908LOE | 20d |
| 13411909LOEXD |  | FY09 Mngmnt & Oversight (S/R Dipoles) | 59d | 2008-10-01 | 2008-12-24 | 12155908LOE, 121411908LOE, 9-090M | 20d |
| 121411066 |  | Design Option B of East XM Curved Dipoles (S/R Dipoles) | 29d | 2008-12-01 | 2009-01-16 | 9-090M FS+41d | 178d |
| 121411085 |  | Top Leg Return Dsgns for Trapezoid Dipoles (S/R Dipoles) | 40d | 2009-01-05 | 2009-03-03 | 9-090M FS+60d | 148d |
| 121411038 |  | Design Option B of West XV Curved Dipoles (S/R Dipoles) | 33d | 2009-01-09 | 2009-02-26 | 9-090M FS+64d, 121411036 | 151d |
| 121411081 |  | Design New Dipole for Launch into ARC 10 (S/R Dipoles) | 33d | 2009-01-12 | 2009-02-27 | 9-090M FS+65d | 150d |
| 121411037 |  | Design Option B of West XU Curved Dipoles (S/R Dipoles) | 33d | 2009-01-16 | 2009-03-05 | 9-090M FS+69d | 146d |
| 121411070M |  | Dsgn of East Curved Dipoles Comp (S/R DIPOLES) | 0d | 2009-01-16 | 2009-01-16 | 121411066, 121411065 | 178d |
| 121411040M |  | Dsgn of West Curved Dipoles Comp (S/R DIPOLES) | 0d | 2009-03-05 | 2009-03-05 | 121411036, 121411037, 121411038 | 146d |
| 121411091 |  | East Option B Top Assy Dsgns for Modified S/R Dipoles (S/R Dipoles) | 64d | 2009-04-01 | 2009-06-30 | 9-090M FS+120d | 64d |
| 121411092 |  | West Option B Top Assy Dsgns for Modified S/R Dipoles (S/R Dipoles) | 63d | 2009-05-01 | 2009-07-30 | 9-090M FS+142d | 43d |
| 121411110M |  | All S/R Dipole & Septa Dsgns Comp (S/R DIPOLES)++ | 0d | 2009-07-30 | 2009-07-30 | 121411092, 121411070M, 121411090a, 121411091, 121411040M, 121411080, 121411085, 121411050M, 121411075, 121411081 | 43d |
| 121411120 |  | Re-Baseline Actuals Adjustment | 1d | 2013-08-30 | 2013-08-30 | 9-130M FS+227d | 20d |
|  | 2 | **1.2.1.4.1.2 QUADRUPOLES** |  |  |  |  |  |
|  | 3 | **1.2.1.4.1.3 CORRECTORS** |  |  |  |  |  |
|  | 4 | **1.2.1.4.1.4 STANDS** |  | 2006-11-01 | 2013-08-30 |  |  |
| 121414005 |  | Develop Preliminary S/R Stand and Layout Design (STANDS) | 110d | 2006-11-01 | 2007-04-17 | 9-070M FS+22d | 231d |
| 121414010 |  | Preliminary Design & Safety Review of Stands (STANDS) | 20d | 2007-03-21 | 2007-04-17 | 121414005 FS-20d | 231d |
| 121414010M |  | Preliminary S/R Stand and Layout Design & Safety Review Completed (STANDS) | 0d | 2007-04-17 | 2007-04-17 | 121414010 | 231d |
| 121414015 |  | FY08 Detailed Dsgn of East S/R (S/R Stands) PED++ | 190d | 2008-01-02 | 2008-09-30 | 9-080M FS+58d, 121414010M | 58d |
| 121414020 |  | FY08 Detailed Dsgn of West S/R (S/R Stands)++ | 113d | 2008-04-22 | 2008-09-30 | 9-080M FS+135d | 1d |
| 121414015a |  | FY09 Detailed Dsgn of East S/R (S/R Stands) PED++ | 190d | 2008-10-01 | 2009-07-09 | 121414015 | 58d |
| 121414020a |  | FY09 Detailed Dsgn of West S/R (S/R Stands)++ | 247d | 2008-10-01 | 2009-09-29 | 121414020 | 1d |
| 121414016 |  | Incorporate Changes B to the Modified East S/R (S/R Dipoles) | 118d | 2009-03-02 | 2009-08-14 | 9-090M FS+98d | 32d |
| 121414025 |  | Re-Baseline Actuals Adjustment | 1d | 2013-08-30 | 2013-08-30 | 9-130M FS+227d | 20d |
|  | 5 | **1.2.1.4.1.5 GIRDERS** |  |  |  |  |  |
|  | 6 | **1.2.1.4.1.6 VACUUM** |  | 2008-02-04 | 2013-08-30 |  |  |
| 121416000 |  | FY08 Detailed Dsgn of East S/R Dipole Chambers (S/R Vac)++ | 168d | 2008-02-04 | 2008-09-30 | 9-080M FS+80d | 211d |
| 121416005 |  | FY08 Detailed Dsgn of West S/R Dipole Chambers (S/R Vac)++ | 118d | 2008-04-15 | 2008-09-30 | 121416000a FS-150d | 246d |
| 121416000a |  | FY09 Detailed Dsgn of East S/R Dipole Chambers (S/R Vac)++ | 32d | 2008-10-01 | 2008-11-13 | 121416000 | 211d |
| 121416005a |  | FY09 Detailed Dsgn of West S/R Dipole Chambers (S/R Vac)++ | 2d | 2008-10-01 | 2008-10-02 | 121416005 | 246d |
| 121416010 |  | Pre-Constrctn Dsgn Review for S/R's++ | 5d | 2009-06-04 | 2009-06-10 | 121411110M FS-40d, 121414020a FS-300d, 121414015a FS-300d, 121416000a, 121416005a FS-50d | 78d |
| 121416015 |  | Re-Baseline Actuals Adjustment | 1d | 2013-08-30 | 2013-08-30 | 9-130M FS+227d | 20d |
|  | 7 | **1.2.1.4.1.7 INSTALLATION** |  |  |  |  |  |
|  | 2 | **1.2.1.4.2 EXISTING ARCS (1-9, A, B, & C)** |  | 2006-10-02 | 2013-08-30 |  |  |
|  | 1 | **1.2.1.4.2.1 DIPOLES** |  | 2006-10-02 | 2013-08-30 |  |  |
| 121421005 |  | Develop Partial Design of Arc Dipole H-Iron (DIPOLES) | 80d | 2006-10-02 | 2007-02-01 | 9-070M | 598d |
| 121421010 |  | Preliminary Design & Safety Review of Existing Arcs Dipoles (DIPOLES) | 20d | 2007-01-04 | 2007-02-01 | 121421005 FS-20d | 598d |
| 121421010M |  | Existing Arcs Dipoles Preliminary Design & Safety Review Completed (DIPOLES) | 0d | 2007-02-01 | 2007-02-01 | 121424005, 121421005, 121421010 | 598d |
| 121421908LOE |  | FY08 Mngmnt of Existing Arcs (EXIST ARC Dipoles) | 248d | 2007-10-01 | 2008-09-30 | 9-080M, 121411007LOE | 20d |
| 121421020 |  | Finish Dsgn of Arc Dipole H-Iron (EXIST ARC Dipoles) ++ | 60d | 2008-10-01 | 2009-01-02 | 121421010M, 9-090M | 183d |
| 13421909LOEXD |  | FY09 Mngmnt & Oversight (EXIST ARC Dipoles) | 59d | 2008-10-01 | 2008-12-24 | 121421908LOE | 20d |
| 121421021 |  | Add H Steel to ARC 1 & 2 Design (S/R Dipoles) | 31d | 2009-03-17 | 2009-04-28 | 121421020 FS+49d | 279d |
| 121421022 |  | Synchrotron Radiation Compensation Design (S/R Dipoles) | 19d | 2009-04-28 | 2009-05-22 | 121421021 FS-1d | 281d |
| 121421025 |  | Re-Baseline Actuals Adjustment | 1d | 2013-08-30 | 2013-08-30 | 9-130M FS+227d | 20d |

| ID | WBS | Task | Duration | Start | Finish | Predecessors | Total float |
| --- | --- | --- | --- | --- | --- | --- | --- |
|  | 2 | **1.2.1.4.2.2 QUADRUPOLES** |  | 2008-10-01 | 2013-08-30 |  |  |
| 13422035XD |  | Prcrmnt Prep for Quads (EXIST ARC Q-POLES) | 59d | 2008-10-01 | 2008-12-24 | 9-090M | 1477d |
| 121422000 |  | Re-Baseline Actuals Adjustment | 1d | 2013-08-30 | 2013-08-30 | 9-130M FS+227d | 20d |
|  | 3 | **1.2.1.4.2.3 CORRECTORS** |  |  |  |  |  |
|  | 4 | **1.2.1.4.2.4 STANDS** |  | 2006-10-16 | 2013-08-30 |  |  |
| 121424005 |  | Develop Cartridge Design for Path Length Change (STANDS) | 45d | 2006-10-16 | 2006-12-19 | 9-070M FS+10d | 623d |
| 121425005 |  | Dsgn of Modifed QR & QC/QB Girders (EXIST ARC Girders) | 50d | 2008-01-28 | 2008-04-07 | 9-080M FS+75d | 341d |
| 121425010 |  | Dsgn of simple QR Girder for H-B (EXIST ARC Girders)++ | 25d | 2008-04-08 | 2008-05-12 | 121425005 | 341d |
| 121424010 |  | New Stands for H-B Transport (EXIST ARC Stands)+ | 60d | 2008-12-24 | 2009-03-27 | 9-090M FS+58d | 125d |
| 121425015 |  | Pre-Constrctn Dsgn Review for Existing ARCs++ | 5d | 2009-03-30 | 2009-04-03 | 121424010, 121425010, 121421020 | 125d |
| 121424015 |  | Re-Baseline Actuals Adjustment | 1d | 2013-08-30 | 2013-08-30 | 9-130M FS+227d | 20d |
|  | 5 | **1.2.1.4.2.5 GIRDERS** |  |  |  |  |  |
|  | 6 | **1.2.1.4.2.6 VACUUM** |  |  |  |  |  |
|  | 7 | **1.2.1.4.2.7 INSTALLATION** |  |  |  |  |  |
|  | 3 | **1.2.1.4.3 LINACS** |  | 2007-02-01 | 2013-08-30 |  |  |
|  | 1 | **1.2.1.4.3.1 QUADRUPOLES** |  |  |  |  |  |
|  | 2 | **1.2.1.4.3.2 CORRECTORS** |  | 2008-07-24 | 2013-08-30 |  |  |
| 121432005 |  | Final Dsgn of Linac Correctors & Skew Quads (Linac Correctors)++ | 30d | 2008-07-24 | 2008-09-04 | 9-080M FS+200d | 261d |
| 121432010 |  | Re-Baseline Actuals Adjustment | 1d | 2013-08-30 | 2013-08-30 | 9-130M FS+227d | 20d |
|  | 3 | **1.2.1.4.3.3 STANDS** |  | 2007-02-01 | 2013-08-30 |  |  |
| 121433005 |  | Initial layout of LINAC Stands and Girders (STANDS) | 85d | 2007-02-01 | 2007-06-01 | 9-070M FS+79d | 402d |
| 121433908LOE |  | FY08 Mngmnt of Linac Stands | 248d | 2007-10-01 | 2008-09-30 | 121411007LOE, 9-080M | 20d |
| 121434005 |  | Final Dsgn of Linac Girders (Linac Girders)++ | 40d | 2008-07-24 | 2008-09-18 | 9-080M FS+200d | 251d |
| 121434999 |  | Pre-Constrctn Dsgn Review for Linacs++ | 5d | 2008-09-19 | 2008-09-25 | 121432005, 121434005 | 251d |
| 121433010 |  | Re-Baseline Actuals Adjustment | 1d | 2013-08-30 | 2013-08-30 | 9-130M FS+227d | 20d |
|  | 4 | **1.2.1.4.3.4 GIRDERS** |  |  |  |  |  |
|  | 5 | **1.2.1.4.3.5 VACUUM** |  |  |  |  |  |
|  | 6 | **1.2.1.4.3.6 INSTALLATION** |  |  |  |  |  |
|  | 4 | **1.2.1.4.4 INJECTOR & RE-INJECTION** |  | 2007-02-02 | 2013-08-30 |  |  |
|  | 1 | **1.2.1.4.4.1 DIPOLES** |  | 2007-03-15 | 2013-08-30 |  |  |
| 121441005 |  | Develop Preliminary Design of Re-injection Dipoles (DIPOLES) | 65d | 2007-03-15 | 2007-06-14 | 9-070M FS+108d | 393d |
| 121441010 |  | FY08 Final Dsgn of Re-injection Dipoles (INJ/RE-INJ Dipoles)++ | 48d | 2008-07-24 | 2008-09-30 | 9-080M FS+200d | 234d |
| 121441010a |  | FY09 Final Dsgn of Re-injection Dipoles (INJ/RE-INJ Dipoles)++ | 12d | 2008-10-01 | 2008-10-16 | 121441010 | 234d |
| 121441015 |  | Re-Baseline Actuals Adjustment | 1d | 2013-08-30 | 2013-08-30 | 9-130M FS+227d | 20d |
|  | 2 | **1.2.1.4.4.2 QUADRUPOLES** |  |  |  |  |  |
|  | 3 | **1.2.1.4.4.3 CORRECTORS** |  |  |  |  |  |
|  | 4 | **1.2.1.4.4.4 STANDS** |  | 2007-02-02 | 2013-08-30 |  |  |
| 121444005 |  | Develop Preliminary Layout & Stand Design | 90d | 2007-02-02 | 2007-06-11 | 9-070M FS+80d | 396d |
| 121444010 |  | Preliminary Design & Safety Review of Layout & Stand Design | 20d | 2007-05-14 | 2007-06-11 | 121444005 FS-20d | 396d |
| 121444010M |  | Re-Injection & Linac Preliminary Design & Safety Review Completed | 0d | 2007-06-14 | 2007-06-14 | 121444010, 121433005, 121441005 | 393d |
| 121444015 |  | Detailed Dsgn of Re-Injection Line & Stands (Injector & Re-Injection Stands) ++ | 85d | 2007-10-01 | 2008-02-08 | 9-080M, 121444010M | 319d |
| 121444020 |  | Detailed Dsgn of Spectrometer Move (Injector & Re-Injection Stands)++ | 90d | 2008-02-11 | 2008-06-17 | 121444015 | 319d |
| 13444909LOEXD |  | FY09 Mngmnt/Planning for Reinjection Modifications (INJ/RE-INJ Stands) | 59d | 2008-10-01 | 2008-12-24 | 121411908LOE, 9-090M | 20d |
| 121444025 |  | Re-Baseline Actuals Adjustment | 1d | 2013-08-30 | 2013-08-30 | 9-130M FS+227d | 20d |
|  | 5 | **1.2.1.4.4.5 GIRDERS** |  |  |  |  |  |
|  | 6 | **1.2.1.4.4.6 VACUUM** |  | 2008-07-31 | 2013-08-30 |  |  |
| 121446005 |  | Dsgn New Vac Chambers for Re-Injections (INJ/RE-INJ Vac)++ | 30d | 2008-07-31 | 2008-09-11 | 9-080M FS+205d | 259d |
| 121446999 |  | Pre-Constrctn Dsgn Review for Injector & Re-Injection+ | 2d | 2008-10-17 | 2008-10-20 | 121444015, 121444020, 121446005, 121441010a | 234d |
| 121446010 |  | Re-Baseline Actuals Adjustment | 1d | 2013-08-30 | 2013-08-30 | 9-130M FS+227d | 20d |
|  | 7 | **1.2.1.4.4.7 INSTALLATION** |  |  |  |  |  |
|  | 5 | **1.2.1.4.5 ARC 10 & HALL D BEAMLINE** |  | 2006-10-02 | 2013-08-30 |  |  |
|  | 1 | **1.2.1.4.5.1 DIPOLES** |  | 2006-10-02 | 2013-08-30 |  |  |
| 121451007LOE |  | FY07 Management of ARC 10 and Hall D (DIPOLES) | 247d | 2006-10-02 | 2007-09-28 | 9-070M | 20d |
| 121451020 |  | Develop Design of ARC 10 4m Dipole (DIPOLES) | 90d | 2006-10-02 | 2007-02-15 | 9-070M | 472d |
| 121451025 |  | Preliminary Design & Safety Review of General Dipoles | 20d | 2007-01-19 | 2007-02-15 | 121451020 FS-20d | 472d |
| 121451025M |  | General Dipole Design & Safety Review Completed | 0d | 2007-02-15 | 2007-02-15 | 121451025 | 472d |
| 121451030M |  | Finish Detailed Design of ARC 10 4m Dipole (DIPOLES)+ | 0d | 2007-04-27 | 2007-04-27 | 121451020 FS+50d, 121451025M FS+50d | 472d |
| 121451035 |  | Detailed Dsgn of 2m First bend Dipole (ARC 10/H-D Dipoles)++ | 50d | 2007-10-01 | 2007-12-11 | 9-080M, 121451030M | 401d |
| 121451040 |  | Modify Alignment Fixture (ARC 10/H-D Dipoles) | 20d | 2007-10-01 | 2007-10-26 | 9-080M | 471d |
| 121451908LOE |  | FY08 Mngmnt of ARC 10 & H-D (ARC 10/H-D Dipoles) | 248d | 2007-10-01 | 2008-09-30 | 121451007LOE | 20d |
| 121451909LOE |  | FY09 Mngmnt of ARC 10 & H-D (ARC 10/H-D Dipoles) | 248d | 2008-10-01 | 2009-09-30 | 121451908LOE | 20d |
| 13451055XD |  | Prcrmnt Prep of 4m Dipoles (ARC10/H-D Dipoles) | 59d | 2008-10-01 | 2008-12-24 | 9-090M, 121451030M | 117d |
| 13451909LOEXD |  | FY09 Mngmnt & Oversight (ARC10/H-D Dipoles) | 59d | 2008-10-01 | 2008-12-24 | 121451908LOE | 20d |
| 121451060 |  | Re-Baseline Actuals Adjustment | 1d | 2013-08-30 | 2013-08-30 | 9-130M FS+227d | 20d |
|  | 2 | **1.2.1.4.5.2 QUADRUPOLES** |  | 2006-12-05 | 2013-08-30 |  |  |
| 121452005 |  | Develop Preliminary Design of New Quadrupoles | 110d | 2006-12-05 | 2007-05-17 | 9-070M FS+44d | 343d |
| 121452010 |  | Preliminary Design & Safety Review of Quads | 20d | 2007-04-20 | 2007-05-17 | 121452005 FS-20d | 343d |
| 121452010M |  | Preliminary Quad Design & Safety Review Completed | 0d | 2007-05-17 | 2007-05-17 | 121452010, 121452005 | 343d |
| 121452015 |  | Develop Detailed Design of New Quadrupoles (QUAD POLES) | 90d | 2007-05-18 | 2007-09-25 | 121452010M | 343d |
| 121452020M |  | New Quad Designs Complete (QUAD POLES)++ | 0d | 2007-09-25 | 2007-09-25 | 121452015 | 343d |

| ID | WBS | Task | Duration | Start | Finish | Predecessors | Total float |
| --- | --- | --- | --- | --- | --- | --- | --- |
| 13452025X |  | Prcrmnt Prep for Quads (ARC 10/H-D Q-POLES) | 59d | 2008-10-01 | 2008-12-24 | 9-090M, 121452020M | 92d |
| 121452025 |  | Re-Baseline Actuals Adjustment | 1d | 2013-08-30 | 2013-08-30 | 9-130M FS+227d | 20d |
|  | 3 | **1.2.1.4.5.3 CORRECTORS** |  |  |  |  |  |
|  | 4 | **1.2.1.4.5.4 STANDS** |  | 2006-12-05 | 2013-08-30 |  |  |
| 121454005 |  | Develop Preliminary Design of Arc 10 and Hall D Layout (STANDS) | 110d | 2006-12-05 | 2007-05-17 | 9-070M FS+44d | 401d |
| 121455000M |  | Begin Arc 10 and Hall D Girder Designs (GIRDERS) | 0d | 2007-03-01 | 2007-03-01 | 9-070M FS+98d | 414d |
| 121455005 |  | Preliminary Design Arc 10 & Hall D Quad Girders (GIRDERS) | 43d | 2007-03-01 | 2007-04-30 | 121455000M | 414d |
| 121454010 |  | Preliminary Design & Safety Review of Arc 10 and Hall D Layout (STANDS) | 20d | 2007-04-20 | 2007-05-17 | 121454005 FS-20d | 401d |
| 121454010M |  | Preliminary Design & Safety Review of Arc 10 and Hall D Layout Completed | 0d | 2007-05-17 | 2007-05-17 | 121454005, 121454010, 121455005, 121456005 | 401d |
| 121455006 |  | FY07 Phase of Final Design Arc 10 & Hall D Quad Girders (GIRDERS) | 93d | 2007-05-18 | 2007-09-28 | 121454010M | 401d |
| 121454015 |  | FY08 Detailed Dsgn of ARC 10 Stands++ | 248d | 2007-10-01 | 2008-09-30 | 9-080M | 146d |
| 121455010 |  | Final Dsgn H-D & Arc 10 Quad Girders (IARC 10/H-D Girders) | 90d | 2007-10-01 | 2008-02-15 | 121452020M, 121455006, 9-080M | 401d |
| 121455015M |  | Finish H-D & Arc 10 Girders (IARC 10/H-D GIRDERS)++ | 0d | 2008-02-15 | 2008-02-15 | 121455010 | 401d |
| 121454015a |  | FY09 Detailed Dsgn of ARC 10 Stands++ | 102d | 2008-10-01 | 2009-03-05 | 121454015 | 146d |
| 121454020 |  | Re-Baseline Actuals Adjustment | 1d | 2013-08-30 | 2013-08-30 | 9-130M FS+227d | 20d |
|  | 5 | **1.2.1.4.5.5 GIRDERS** |  |  |  |  |  |
|  | 6 | **1.2.1.4.5.6 VACUUM** |  | 2007-04-02 | 2013-08-30 |  |  |
| 121456005 |  | PreliminaryDesign 4m Dipole Chambers (VACUUM) | 25d | 2007-04-02 | 2007-05-04 | 9-070M FS+120d | 410d |
| 121456010 |  | Detail Design 4m Dipole Chambers (VACUUM) | 46d | 2007-05-18 | 2007-07-24 | 121454010M | 498d |
| 121456015 |  | Dsgn 2m Dipole Chamb for First bend (ARC 10 & H-D Vac)++ | 40d | 2008-07-24 | 2008-09-18 | 9-080M FS+200d, 121451035, 121456010 | 251d |
| 121456999 |  | Pre-Constrctn Dsgn Review (ARC 10 & H-D)++ | 5d | 2008-09-19 | 2008-09-25 | 121454015a FS-200d, 121456015, 121451040, 121455015M, 121451035, 9-080M FS-270d | 251d |
| 121456020 |  | Re-Baseline Actuals Adjustment | 1d | 2013-08-30 | 2013-08-30 | 9-130M FS+227d | 20d |
|  | 7 | **1.2.1.4.5.7 LCW & INSTRUMENT AIR** |  |  |  |  |  |
|  | 8 | **1.2.1.4.5.8 INSTALLATION** |  |  |  |  |  |
|  | 6 | **1.2.1.4.6 INJECTOR RECIRCULATION** |  |  |  |  |  |
|  | 1 | **1.2.1.4.6.1 DIPOLES** |  |  |  |  |  |
|  | 2 | **1.2.1.4.6.2 QUADRUPOLES** |  |  |  |  |  |
|  | 3 | **1.2.1.4.6.3 CORRECTORS** |  |  |  |  |  |
|  | 4 | **1.2.1.4.6.4 STANDS** |  |  |  |  |  |
|  | 5 | **1.2.1.4.6.5 GIRDERS** |  |  |  |  |  |
|  | 6 | **1.2.1.4.6.6 VACUUM** |  |  |  |  |  |
|  | 7 | **1.2.1.4.6.7 INSTALLATION** |  |  |  |  |  |
|  | 5 | **1.2.1.5 EXTRACTION** |  | 2006-10-02 | 2013-08-30 |  |  |
|  | 1 | **1.2.1.5.1 CAVITIES** |  | 2006-10-02 | 2013-08-30 |  |  |
| 12151007LOE |  | FY07 Management of Extraction WBS (CAVITIES) | 247d | 2006-10-02 | 2007-09-28 | 9-070M | 148d |
| 12151009 |  | Develop Design Package for Cavities (CAVITIES) | 25d | 2006-11-01 | 2006-12-07 | 9-070M FS+22d | 673d |
| 12151010 |  | Design & Safety Review for Cavity Package (CAVITIES) | 1d | 2006-12-08 | 2006-12-08 | 12151009 | 673d |
| 12151015 |  | Post-review development of Design Package for Cavities (CAVITIES) | 22d | 2006-12-11 | 2007-01-18 | 12151010 | 673d |
| 12151020M |  | Finish Design of RF Cavities (CAVITIES) | 0d | 2007-01-18 | 2007-01-18 | 12151015 | 673d |
| 12151908LOE |  | FY08 Mngmnt of Extraction WBS | 248d | 2007-10-01 | 2008-09-30 | 12151007LOE | 148d |
| 1351909LOEX |  | FY09 Mngmnt Oversight (Cavities) | 59d | 2008-10-01 | 2008-12-24 | 9-090M | 20d |
| 12151025 |  | Re-Baseline Actuals Adjustment | 1d | 2013-08-30 | 2013-08-30 | 9-130M FS+227d | 20d |
|  | 2 | **1.2.1.5.2 RF COMPONENTS** |  | 2007-02-14 | 2013-08-30 |  |  |
| 12152005 |  | Develop design package for RF Components (RF COMPON) | 30d | 2007-02-14 | 2007-03-28 | 9-070M FS+88d | 573d |
| 12152010 |  | Design & Safety Review for RF Components (RF COMPON) | 1d | 2007-03-29 | 2007-03-29 | 12152005 | 573d |
| 12152015 |  | Post-review development of Design Package for RF Components (RF COMPON) | 16d | 2007-03-30 | 2007-04-20 | 12152010 | 573d |
| 12152025 |  | Continue Dsgn Package for RF Compnts (RF COMPON) | 30d | 2007-10-01 | 2007-11-09 | 12152015, 9-080M | 461d |
| 12152030M |  | Comp Dsgn for RF Components++ | 0d | 2007-11-09 | 2007-11-09 | 12152025 | 461d |
| 12152035 |  | Re-Baseline Actuals Adjustment | 1d | 2013-08-30 | 2013-08-30 | 9-130M FS+227d | 20d |
|  | 3 | **1.2.1.5.3 RESONANCE CONTROL** |  | 2006-10-02 | 2013-08-30 |  |  |
| 12153005 |  | Determine and checkout LCW capacity (RESON CNTRL) | 5d | 2006-10-02 | 2006-10-06 | 9-070M | 727d |
| 12153010 |  | Develop Design Package for Resonance Control (RESON CNTRL) | 30d | 2006-10-02 | 2006-11-10 | 9-070M | 699d |
| 12153015 |  | Design & Safety Review for Resonance Control (RESON CNTRL) | 1d | 2006-11-16 | 2006-11-16 | 12153010 FS+3d, 12153005 | 699d |
| 12153020 |  | Post-review development of Design Package for Resonance Control (RESON CNTRL) | 5d | 2006-11-17 | 2006-11-27 | 12153015 | 699d |
| 12153025M |  | Finish Resonance Control Design (RESON CNTRL) | 0d | 2006-11-27 | 2006-11-27 | 12153020 | 699d |
| 12153025 |  | Re-Baseline Actuals Adjustment | 1d | 2013-08-30 | 2013-08-30 | 9-130M FS+227d | 20d |
|  | 4 | **1.2.1.5.4 LAMBERTSON** |  | 2007-03-15 | 2013-08-30 |  |  |
| 12154005 |  | Develop Design Package for Lambertson (LAMBERTSON) | 50d | 2007-03-15 | 2007-05-23 | 9-070M FS+108d | 564d |
| 12154010 |  | Design & Safety Review for Lambertson (LAMBERTSON) | 1d | 2007-05-24 | 2007-05-24 | 12154005 | 564d |
| 12154015 |  | Post-review development of Design Package for Lambertson (LAMBERTSON) | 15d | 2007-05-25 | 2007-06-15 | 12154010 | 564d |
| 12154020M |  | Finished Lambertson Design (LAMBERTSON) | 0d | 2007-06-15 | 2007-06-15 | 12154015 | 564d |
| 1354909LOEX |  | FY09 Engrng Oversight (LAMBERTSON) | 59d | 2008-10-01 | 2008-12-24 | 12151908LOE | 148d |
| 12154025 |  | Re-Baseline Actuals Adjustment | 1d | 2013-08-30 | 2013-08-30 | 9-130M FS+227d | 20d |
|  | 5 | **1.2.1.5.5 SEPTA & DIPOLES** |  | 2007-02-13 | 2013-08-30 |  |  |
| 12155005 |  | Develop Design Package for Septa and Dipoles (SEPTA/DIPOLES) | 75d | 2007-02-13 | 2007-05-30 | 9-070M FS+87d | 424d |
| 12155006 |  | Preliminary Design & Safety Review for Septa and Dipoles (SEPTA/DIPOLES) | 1d | 2007-05-31 | 2007-05-31 | 12155005 | 424d |
| 12155007 |  | Post-review development of Design Package for Septa and dipoles (SEPTA/DIPOLES) | 10d | 2007-06-01 | 2007-06-14 | 12155006 | 424d |
| 12155035 |  | Dsgn Septa & Dipoles | 90d | 2007-10-01 | 2008-02-15 | 12155007, 9-080M | 350d |
| 12155908LOE |  | FY08 Oversee Dsgn Package for Septa & Dipoles | 248d | 2007-10-01 | 2008-09-30 | 9-080M | 20d |
| 12155040 |  | Prelim Dsgn Review for Septa & Dipoles | 1d | 2008-02-19 | 2008-02-19 | 12155035 | 350d |

| ID | WBS | Task | Duration | Start | Finish | Predecessors | Total float |
| --- | --- | --- | --- | --- | --- | --- | --- |
| 12155045 |  | Post-Review Development of Dsgn Package for Septa & Dipoles | 50d | 2008-02-20 | 2008-04-29 | 12155040 | 350d |
| 12155050M |  | End of Extraction Septa & Dipole PED Effort+ | 0d | 2008-04-29 | 2008-04-29 | 12155045 | 350d |
| 12155055 |  | Re-Baseline Actuals Adjustment | 1d | 2013-08-30 | 2013-08-30 | 9-130M FS+227d | 20d |
|  | 6 | **1.2.1.5.6 STANDS** |  | 2006-11-01 | 2013-08-30 |  |  |
| 12156005 |  | Develop Design Package for Stands (STANDS) | 80d | 2006-11-01 | 2007-03-06 | 9-070M FS+22d | 185d |
| 12156010 |  | Preliminary Design & Safety Review for Stands (STANDS) | 1d | 2007-03-07 | 2007-03-07 | 12156005 | 185d |
| 12156015 |  | Post-review development of Design Package for Stands (STANDS) | 20d | 2007-03-08 | 2007-04-04 | 12156010 | 185d |
| 12156000 |  | FY08 Expenses | 248d | 2007-10-01 | 2008-09-30 | 9-080M | 0d |
| 12156030 |  | FY08 Develop Dsgn Package for Stands | 248d | 2007-10-01 | 2008-09-30 | 12156015, 9-080M | 61d |
| 12156002 |  | FY09 Expenses | 248d | 2008-10-01 | 2009-09-30 | 12156000 | 0d |
| 12156030a |  | FY09 Develop Dsgn Package for Stands | 112d | 2008-10-01 | 2009-03-19 | 12156030 | 61d |
| 12156035 |  | Finalize Dsgn Package for Stands | 75d | 2009-04-08 | 2009-07-23 | 9-090M FS+125d, 12156030a | 48d |
| 12156040M |  | Stands Dsgn Comp++ | 0d | 2009-04-13 | 2009-04-13 | 12156035 FS-72d | 115d |
| 12156045 |  | Pre-Constrctn Dsgn Review for Extraction++ | 5d | 2009-04-13 | 2009-04-17 | 12156040M, 12153025M, 12154020M, 12152030M, 12155050M | 115d |
| 12156050 |  | Re-Baseline Actuals Adjustment | 1d | 2013-08-30 | 2013-08-30 | 9-130M FS+227d | 20d |
|  | 6 | **1.2.1.6 INSTRUMENTATION, CONTROLS, & SAFETY SYSTEMS** |  | 2006-10-02 | 2013-08-30 |  |  |
|  | 1 | **1.2.1.6.1 BEAM DIAGNOSTICS** |  | 2006-10-02 | 2013-08-30 |  |  |
|  | 1 | **1.2.1.6.1.1 BPM's** |  | 2006-10-02 | 2013-08-30 |  |  |
| 121611007LOE |  | FY07 Management Effort (BPMs) | 247d | 2006-10-02 | 2007-09-28 | 9-070M | 111d |
| 121611010 |  | Define & Package System Layout (BPMs) | 22.5d | 2006-12-05 | 2007-01-12 | 9-070M FS+44d | 268d |
| 121611015 |  | Design Top-Level System Layout (BPMs) | 22.5d | 2007-01-12 | 2007-02-14 | 121611010 | 268d |
| 121611020 |  | Evaluate System Interface (BPMs) | 22.5d | 2007-01-12 | 2007-02-14 | 121611010 | 268d |
| 121611030M |  | Ready to Baseline (BPMs) | 0d | 2007-02-14 | 2007-02-14 | 121611020 | 268d |
| 121611025 |  | Preliminary Design & Safety Review (BPMs) | 1d | 2007-02-15 | 2007-02-15 | 121611030M, 121611015, 121611020 | 268d |
| 121611025M |  | Complete Preliminary Design & Safety Review (BPMs) | 0d | 2007-02-15 | 2007-02-15 | 121611025 | 268d |
| 121611040 |  | FY08 Comp BPM Sys Dsgn | 90d | 2007-10-01 | 2008-02-15 | 121611007LOE, 121611025M, 9-080M | 111d |
| 121611908LOE |  | FY08 Mngmnt Effort for BPMs | 248d | 2007-10-01 | 2008-09-30 | 9-080M | 20d |
| 121611041 |  | Pre-Constrctn Final Dsgn Review for BPM's | 5d | 2008-02-19 | 2008-02-25 | 121611040 | 111d |
| 121611045 |  | Compile Mech BPM Prcrmnt Packages | 40d | 2008-07-02 | 2008-08-27 | 121611041 FS+90d | 271d |
| 13611909LOEX |  | FY09 Mngmnt Effort for BPMs | 59d | 2008-10-01 | 2008-12-24 | 121612908LOE, 121611908LOE | 20d |
| 121611050 |  | Compile Elect BPM Prcrmnt Packages | 40d | 2009-04-01 | 2009-05-27 | 9-090M FS+120d, 121611041 | 88d |
| 121611055M |  | BPM PED Comp++ | 0d | 2009-05-27 | 2009-05-27 | 121611045, 121611050 | 88d |
| 121611060 |  | Re-Baseline Actuals Adjustment | 1d | 2013-08-30 | 2013-08-30 | 9-130M FS+227d | 20d |
|  | 2 | **1.2.1.6.1.2 HARPS** |  | 2006-10-02 | 2013-08-30 |  |  |
| 121612007LOE |  | FY07 Management Effort Harps (HARPS) | 247d | 2006-10-02 | 2007-09-28 | 9-070M | 20d |
| 121612010 |  | Design Top-Level System Layout (HARPS) | 22.5d | 2006-10-02 | 2006-11-01 | 9-070M | 327d |
| 121612011 |  | Preliminary Design & Safety Review Harps (HARPS) | 1d | 2007-02-28 | 2007-03-01 | 121612010 FS+75d | 327d |
| 121612015M |  | Complete Preliminary Design & Safety Review Harps (HARPS) | 0d | 2007-03-01 | 2007-03-01 | 121612011 | 327d |
| 121612020M |  | Ready to baseline Harp WBS (HARPS) | 0d | 2007-03-01 | 2007-03-01 | 121612010 FS+76d | 327d |
| 121612021 |  | FY08 Comp Harp Sys Dsgn | 25d | 2007-10-01 | 2007-11-02 | 121612015M, 9-080M, 121612020M | 178.5d |
| 121612908LOE |  | FY08 Mngmnt Effort Harps | 248d | 2007-10-01 | 2008-09-30 | 121612007LOE | 20d |
| 121612022 |  | Pre-Constrctn Final Dsgn Review for Harps | 2.5d | 2007-11-05 | 2007-11-07 | 121612021 | 178.5d |
| 13612909LOEX |  | FY09 Mngmnt Effort for Harps | 59d | 2008-10-01 | 2008-12-24 | 121612908LOE | 20d |
| 121612030 |  | Compile Harp Sys Elect Prcrmnt Packages+ | 21.5d | 2009-04-08 | 2009-05-07 | 121612022, 9-090M FS+125d | 101.5d |
| 121612035 |  | Compile Harp Sys Mech Prcrmnt Packages+ | 21.5d | 2009-04-08 | 2009-05-07 | 121612022, 9-090M FS+125d | 101.5d |
| 121612040 |  | Re-Baseline Actuals Adjustment | 1d | 2013-08-30 | 2013-08-30 | 9-130M FS+227d | 20d |
|  | 3 | **1.2.1.6.1.3 VIEWERS** |  | 2006-10-02 | 2013-08-30 |  |  |
| 121613007LOE |  | FY07 Management Effort for Viewers (VIEWERS) | 247d | 2006-10-02 | 2007-09-28 | 9-070M | 20d |
| 121613010 |  | Design Top-Level System Layout (VIEWERS) | 22.5d | 2006-10-02 | 2006-11-01 | 9-070M | 327d |
| 121613011 |  | Preliminary Design & Safety Review Viewers (VIEWERS) | 1d | 2007-02-28 | 2007-03-01 | 121613010 FS+75d | 327d |
| 121613015M |  | Complete Preliminary Design & Safety Review Viewers (VIEWERS) | 0d | 2007-03-01 | 2007-03-01 | 121613011 | 327d |
| 121613020M |  | Ready to Baseline Viewers (VIEWERS) | 0d | 2007-03-01 | 2007-03-01 | 121613015M, 121613010 FS+76d, 121614015M | 326.5d |
| 121613026 |  | FY08 Comp Viewer Sys Dsgn | 25d | 2007-10-01 | 2007-11-02 | 121613020M, 9-080M | 178.5d |
| 121613908LOE |  | FY08 Mngmnt Effort for Viewers | 248d | 2007-10-01 | 2008-09-30 | 121613007LOE, 9-080M | 20d |
| 121613027 |  | Pre-Constrctn Final Dsgn Review for Viewers | 2.5d | 2007-11-05 | 2007-11-07 | 121613026 | 178.5d |
| 13613909LOEX |  | FY09 Mngmnt Effort for Viewer Syss | 59d | 2008-10-01 | 2008-12-24 | 121613908LOE | 20d |
| 121613030 |  | Compile Viewer Sys Elect Prcrmnt Packages | 50d | 2009-04-01 | 2009-06-10 | 121613027, 9-090M FS+120d | 78d |
| 121613035 |  | Compile Viewer Sys Mech Prcrmnt Packages | 55d | 2009-04-01 | 2009-06-17 | 121613027, 9-090M FS+120d | 73d |
| 121613040M |  | Viewer Sys PED Comp++ | 0d | 2009-06-17 | 2009-06-17 | 121613035, 121613030 | 73d |
| 121613045 |  | Re-Baseline Actuals Adjustment | 1d | 2013-08-30 | 2013-08-30 | 9-130M FS+227d | 20d |
|  | 4 | **1.2.1.6.1.4 BEAM-BASED FEEDBACK SYSTEMS** |  | 2006-10-02 | 2013-08-30 |  |  |
| 121614007LOE |  | FY07 Management Effort for Beam Based Feedback (BEAM-BASED FB SYS) | 247d | 2006-10-02 | 2007-09-28 | 9-070M | 20d |
| 121614010 |  | Define System Requirements & High Level Design (BEAM-BASED FB SYS) | 40d | 2006-10-02 | 2006-11-28 | 9-070M | 324d |
| 121614011 |  | Preliminary Design & Safety Review Beam Based Feedback Systems (BEAM-BASED FB SYS) | 1d | 2007-03-01 | 2007-03-01 | 121614010 FS+58d | 326.5d |
| 121614015M |  | Complete Preliminary Design & Safety Review BBFB (BEAM-BASED FB SYS) | 0d | 2007-03-01 | 2007-03-01 | 121614011 | 326.5d |
| 121614020M |  | Ready to Baseline Beam Based Feedback System (BEAM-BASED FB SYS) | 0d | 2007-03-01 | 2007-03-01 | 121614010 FS+59d | 324d |
| 121614026 |  | FY08 Comp BBFB Sys Dsgn | 25d | 2007-10-01 | 2007-11-02 | 121614020M, 9-080M | 176d |
| 121614908LOE |  | FY08 Mngmnt Effort for Beam Based Feedback 2 | 248d | 2007-10-01 | 2008-09-30 | 121614007LOE | 20d |
| 121614027 |  | Pre-Constrctn Final Dsgn Review for BBFB | 5d | 2007-11-05 | 2007-11-09 | 121614026 | 176d |
| 13614909LOEX |  | FY09 FFB Sys Mangement Effort | 59d | 2008-10-01 | 2008-12-24 | 121614908LOE | 20d |

| ID | WBS | Task | Duration | Start | Finish | Predecessors | Total float |
| --- | --- | --- | --- | --- | --- | --- | --- |
| 121614030 |  | Compile BBFB Hardware Prcrmnt Package (Beam-BASED FB SYS) | 40d | 2009-04-01 | 2009-05-27 | 9-090M FS+120d, 121614027 | 88d |
| 121614035M |  | Beam Based Feedback PED Comp+ | 0d | 2009-05-27 | 2009-05-27 | 121614030 | 88d |
| 121614040 |  | Re-Baseline Actuals Adjustment | 1d | 2013-08-30 | 2013-08-30 | 9-130M FS+227d | 20d |
|  | 2 | **1.2.1.6.2 CONTROL SYSTEM HARDWARE** |  | 2006-10-02 | 2013-08-30 |  |  |
| 12162007LOE |  | FY07 Management Effort for Control System HW (CONT SYS HW) | 247d | 2006-10-02 | 2007-09-28 | 9-070M | 20d |
| 12162010 |  | Define & Package System Layout (CONT SYS HW) | 22.5d | 2006-12-05 | 2007-01-12 | 9-070M FS+44d | 322d |
| 12162015 |  | Design Top-Level System Layout (CONT SYS HW) | 22.5d | 2007-01-12 | 2007-02-14 | 12162010 | 322d |
| 12162016 |  | Preliminary Design & Safety Review Control System Hardware (CONT SYS HW) | 1d | 2007-03-05 | 2007-03-05 | 12162015 FS+11d | 322d |
| 12162020M |  | Complete Preliminary Design & Safety Review Control System HW (CONT SYS HW) | 0d | 2007-03-05 | 2007-03-05 | 12162016 | 322d |
| 12162025M |  | Ready to Baseline Control System Hardware (CONT SYS HW) | 0d | 2007-03-05 | 2007-03-05 | 12162015 FS+12d, 12163020M, 12162020M | 322d |
| 12162026 |  | FY08 Comp CSH Sys Dsgn | 25d | 2007-10-01 | 2007-11-02 | 12162025M, 9-080M | 176d |
| 12162908LOE |  | FY08 Mngmnt Effort for Control Sys HW 2 | 248d | 2007-10-01 | 2008-09-30 | 12162007LOE | 20d |
| 12162027 |  | Pre-Constrctn Final Dsgn Review for CSH | 5d | 2007-11-05 | 2007-11-09 | 12162026 | 176d |
| 12162035 |  | Compile CSH Prcrmnt Packages | 40d | 2008-10-01 | 2008-11-25 | 9-090M, 12162027 | 208d |
| 1362909LOEX |  | FY09 CSH Sys Mngmnt Effort | 59d | 2008-10-01 | 2008-12-24 | 12162908LOE | 20d |
| 12162040M |  | PED for Control Sys Hardware Comp+ | 0d | 2008-11-25 | 2008-11-25 | 12162035 | 208d |
| 12162045 |  | Re-Baseline Actuals Adjustment | 1d | 2013-08-30 | 2013-08-30 | 9-130M FS+227d | 20d |
|  | 3 | **1.2.1.6.3 CONTROL SYSTEM SOFTWARE** |  | 2006-10-02 | 2013-08-30 |  |  |
| 12163007LOE |  | FY07Management Effort for Control System Software (CONT SYS SW) | 247d | 2006-10-02 | 2007-09-28 | 9-070M | 20d |
| 12163010 |  | Identify and document hall dependecies (CONT SYS SW) | 40d | 2006-10-02 | 2006-11-28 | 9-070M | 343d |
| 12163015 |  | Identify and document HLA modifications (CONT SYS SW) | 40d | 2006-10-02 | 2006-11-28 | 9-070M | 183d |
| 12163020 |  | Preliminary Design & Safety Review Control System Software (CONT SYS SW) | 1d | 2007-02-01 | 2007-02-01 | 12163015 FS+39d, 12163010 FS+39d | 343d |
| 12163020M |  | Complete Preliminary Design & Safety Review Control System SW (CONT SYS SW) | 0d | 2007-02-01 | 2007-02-01 | 12163020 | 343d |
| 12163025M |  | Ready to Baseline Control System Software (CONT SYS SW) | 0d | 2007-02-01 | 2007-02-01 | 12163015 FS+40d | 183d |
| 12163035 |  | FY08 Finalize Application Rquirmnts | 140d | 2007-10-01 | 2008-04-28 | 12163025M, 9-080M | 16d |
| 12163908LOE |  | FY08 Mngmnt Effort for Control Sys Software 2 | 248d | 2007-10-01 | 2008-09-30 | 9-080M, 12163007LOE | 20d |
| 12163040 |  | Comp Detailed Application Dsgn (CONT SYS SW) | 130d | 2008-01-18 | 2008-07-23 | 12163035 FS-70d | 16d |
| 12163170 |  | Pre-Constrctn Dsgn Review | 5d | 2008-06-18 | 2008-06-24 | 12163040 FS-25d | 26d |
| 1363909LOEX |  | FY09 CSS Sys Mngmnt Effort | 59d | 2008-10-01 | 2008-12-24 | 12163908LOE | 20d |
| 12163045 |  | Comp Implementn Plan (CONT SYS SW) | 110d | 2009-04-03 | 2009-09-08 | 12163040 FS+170d | 16d |
| 12163050M |  | Control Sys Software PED Comp+ | 0d | 2009-09-08 | 2009-09-08 | 12163045 | 16d |
| 12163175 |  | Re-Baseline Actuals Adjustment | 1d | 2013-08-30 | 2013-08-30 | 9-130M FS+227d | 20d |
|  | 4 | **1.2.1.6.4 SAFETY SYSTEMS** |  | 2006-10-02 | 2013-08-30 |  |  |
|  | 1 | **1.2.1.6.4.1 MACHINE PROTECTION** |  | 2006-10-02 | 2013-08-30 |  |  |
| 121641007LOE |  | FY07 Management effort for Machine Protection Systems (MACHINE PROTECT) | 247d | 2006-10-02 | 2007-09-28 | 9-070M | 20d |
| 121641010 |  | Define MPS System Requirements (MACHINE PROTECT) | 162d | 2006-11-01 | 2007-06-29 | 9-070M FS+22d | 734d |
| 121641025 |  | Design and Test Eng Dev Ion Chamber (MACHINE PROTECT) | 131d | 2006-12-18 | 2007-06-29 | 9-070M FS+53d | 726.5d |
| 121641015 |  | Design System Detail Architecture (MACHINE PROTECT) | 98d | 2007-02-12 | 2007-06-29 | 9-070M FS+86d | 800.5d |
| 121641020 |  | Design FSD Master (MACHINE PROTECT) | 74d | 2007-03-19 | 2007-06-29 | 9-070M FS+110d | 711.5d |
| 121641010A |  | Define MPS System Requirements (MACHINE PROTECT) | 28.5d | 2007-10-01 | 2007-11-08 | 121641010 FS+63d | 734d |
| 121641015A |  | Design System Detail Architecture (MACHINE PROTECT) | 3d | 2007-10-01 | 2007-10-03 | 121641015 FS+63d | 800.5d |
| 121641020A |  | Design FSD Master (MACHINE PROTECT) | 72d | 2007-10-01 | 2008-01-22 | 121641020 FS+63d | 711.5d |
| 121641025A |  | Design and Test Eng Dev Ion Chamber (MACHINE PROTECT) | 56d | 2007-10-01 | 2007-12-19 | 121641025 FS+63d | 726.5d |
| 121641030 |  | Complete Internal Preliminary Design & Safety Review (MACHINE PROTECT) | 5d | 2007-10-24 | 2007-10-30 | 121641015A FS-75d, 121641020A FS-55d, 121641010A FS-34d | 711.5d |
| 121641035 |  | Complete External Preliminary Design & Safety Review (MACHINE PROTECT) | 5d | 2007-11-13 | 2007-11-19 | 121641030 FS+9d, 121641025A FS-40d | 711.5d |
| 121641040M |  | MPS 35% Design Complete (MACHINE PROTECT) | 0d | 2007-12-17 | 2007-12-17 | 121641035 FS+18d | 711.5d |
| 121641045M |  | Start P-#2 of MPS PED - FY08 | 0d | 2007-12-18 | 2007-12-18 | 9-080M, 121641040M | 711.5d |
| 121641050 |  | Detail Dsgn FSD Sys (MACHINE PROTECT) | 45d | 2007-12-18 | 2008-02-29 | 121641045M, 9-080M | 711.5d |
| 121641055 |  | Develop FSD CAD Drawigns to 80% (MACHINE PROTECT) | 30d | 2008-03-03 | 2008-04-11 | 121641050 | 711.5d |
| 121641060 |  | FSD Dsgn & Safty Review (MACHINE PROTECT) | 10d | 2008-06-30 | 2008-07-14 | 121641055 FS+54d | 806.5d |
| 121641065 |  | FSD Mock-up (MACHINE PROTECT) | 30d | 2008-06-30 | 2008-08-11 | 121641055 FS+54d | 711.5d |
| 121641070 |  | FY08 Detail Dsgn BLM Sys (MACHINE PROTECT) | 35d | 2008-08-12 | 2008-09-30 | 121641065 | 711.5d |
| 121641070a |  | FY09 Detail Dsgn BLM Sys (MACHINE PROTECT) | 10d | 2008-10-01 | 2008-10-14 | 121641070 | 711.5d |
| 13641909LOEX |  | FY09 Mngmnt & Elect Dsgn Supprt Effort for MPS | 59d | 2008-10-01 | 2008-12-24 | 9-090M, 121642908LOE | 20d |
| 121641075 |  | Develop BLM CAD Drawigns to 80% (MACHINE PROTECT) | 15d | 2008-10-15 | 2008-11-04 | 121641070a | 711.5d |
| 121641170 |  | Pre-Constrctn Dsgn Review++ | 7.5d | 2008-10-17 | 2008-10-28 | 121641110M FS-110d | 814d |
| 121641080 |  | BLM Dsgn Review (MACHINE PROTECT) | 15d | 2008-11-05 | 2008-11-25 | 121641075 | 711.5d |
| 121641085 |  | BLM Mock-up (MACHINE PROTECT) | 30d | 2008-11-05 | 2008-12-18 | 121641075 | 779d |
| 121641090 |  | Machine Protection Sys Dsgn & Safty Review | 15d | 2008-11-26 | 2008-12-18 | 121641060, 121641080 | 711.5d |
| 121641095 |  | Update MPS Dsgn Based on Desgin Review | 22.5d | 2008-12-19 | 2009-01-29 | 121641090 | 711.5d |
| 121641100 |  | Develop FSD Proc Packages (MACHINE PROTECT) | 45d | 2009-01-29 | 2009-04-03 | 121641095 | 711.5d |
| 121641105 |  | Develop BLM Proc Packages (MACHINE PROTECT) | 45d | 2009-01-29 | 2009-04-03 | 121641095 | 711.5d |
| 121641110M |  | MPS PED Comp++ | 0d | 2009-04-03 | 2009-04-03 | 121641065, 121641100, 121641105, 121641085 | 711.5d |
| 121641175 |  | Re-Baseline Actuals Adjustment | 1d | 2013-08-30 | 2013-08-30 | 9-130M FS+227d | 20d |
|  | 2 | **1.2.1.6.4.2 BELS** |  | 2006-10-02 | 2013-08-30 |  |  |
| 121642007LOE |  | FY07 Management Effort for Beam Envelope Limit System (BELS) | 247d | 2006-10-02 | 2007-09-28 | 9-070M | 20d |
| 121642010 |  | Define BELS System Requirements (BELS) | 89d | 2007-02-26 | 2007-06-29 | 9-070M FS+95d | 378d |
| 121642015 |  | Design and Test Eng Dev BELS - Hall D Interface (BELS) | 34d | 2007-05-14 | 2007-06-29 | 9-070M FS+150d | 101d |
| 121642020M |  | Complete Preliminary Design & Safety Review (BELS) | 0d | 2007-07-18 | 2007-07-18 | 121642015 FS+12d | 101d |
| 121642025M |  | 35% Design Complete (BELS) | 0d | 2007-07-18 | 2007-07-18 | 121642020M | 101d |

| ID | WBS | Task | Duration | Start | Finish | Predecessors | Total float |
| --- | --- | --- | --- | --- | --- | --- | --- |
| 121642010A |  | Define BELS System Requirements (BELS) | 54d | 2007-10-01 | 2007-12-17 | 121642010 FS+63d | 442d |
| 121642015A |  | Design and Test Eng Dev BELS - Hall D Interface (BELS) | 164d | 2007-10-01 | 2008-06-02 | 121642010 FS+17d, 121642015 FS+63d | 332d |
| 121642030M |  | Start P-#2 of BELS PED - FY08 | 0d | 2007-10-01 | 2007-10-01 | 9-080M, 121642025M | 50d |
| 121642035 |  | Develop Detail Dsgn (BELS) | 100d | 2007-10-01 | 2008-03-03 | 121642030M | 50d |
| 121642908LOE |  | FY08 Mngmnt Effort for BELS | 248d | 2007-10-01 | 2008-09-30 | 121642007LOE, 121614007LOE, 121643007LOE, 121641007LOE | 20d |
| 121642040 |  | Develop mock-up (BELS) | 60d | 2008-03-04 | 2008-05-27 | 121642035 | 151d |
| 121642045 |  | Develop CAD Drawings to 80% BELS | 60d | 2008-03-04 | 2008-05-27 | 121642035 | 50d |
| 121642170 |  | Pre-Constrctn Dsgn Review++ | 5d | 2008-05-14 | 2008-05-20 | 121642070M FS-110d | 50d |
| 121642050 |  | Dsgn Review BELS | 10d | 2008-06-26 | 2008-07-10 | 121642045 FS+21d | 50d |
| 121642055 |  | Update Dsgn Based on Dsgn Review BELS | 10d | 2008-07-11 | 2008-07-24 | 121642050 | 50d |
| 121642060 |  | Develop Proc Packages BELS | 60d | 2008-07-25 | 2008-10-17 | 121642055 | 50d |
| 13642909LOEX |  | FY09 Mngmnt & Elect Dsgn Supprt Effort for BELS | 59d | 2008-10-01 | 2008-12-24 | 121642908LOE | 20d |
| 121642070M |  | BELS PED Comp++ | 0d | 2008-10-17 | 2008-10-17 | 121642040, 121642060 | 50d |
| 121642175 |  | Re-Baseline Actuals Adjustment | 1d | 2013-08-30 | 2013-08-30 | 9-130M FS+227d | 20d |
|  | 3 | **1.2.1.6.4.3 PSS** |  | 2006-10-02 | 2013-08-30 |  |  |
| 121643007LOE |  | FY07 Management effort for Personnel Safety Systems (PSS) | 247d | 2006-10-02 | 2007-09-28 | 9-070M | 20d |
| 121643010 |  | Define Programmable Electronics Specification (PSS) | 184d | 2006-10-02 | 2007-06-29 | 9-070M | 324.75d |
| 121643035 |  | Test Safety PLC 1 & PLC 2 (PSS) | 140d | 2006-10-02 | 2007-04-27 | 121643010 FS-220d | 340.75d |
| 121643040 |  | Attend Training for Safety PLC Software (PSS) | 65d | 2006-10-02 | 2007-01-10 | 9-070M | 363.75d |
| 121643015 |  | Write PSS Systems Safety Specificaiton (PSS) | 10d | 2006-11-01 | 2006-11-14 | 9-070M FS+22d | 156.75d |
| 121643045 |  | Design Beam Transport Monitor (PSS) | 162d | 2006-11-01 | 2007-06-29 | 121643015 FS-10d | 411d |
| 121643020 |  | Review PSS Systems Safety Specificaiton (PSS) | 5d | 2006-12-01 | 2006-12-07 | 121643015 FS+10d | 377.75d |
| 121643050 |  | Construct and Test Eng Dev Beam Transport Monitor (PSS) | 136d | 2006-12-11 | 2007-06-29 | 9-070M FS+48d | 231.75d |
| 121643025 |  | Conduct Internal PSS Design & Safety Review (PSS) | 5d | 2006-12-15 | 2006-12-21 | 121643020 FS+5d, 121643015 | 377.75d |
| 121643070 |  | Prepare Baseline Cost Estimate (PSS) | 25d | 2007-03-09 | 2007-04-12 | 121643015, 121643035 FS-52d, 121643040, 121643010 FS-80d | 324.75d |
| 121643055 |  | Develop Cable Plant Design (PSS) | 64d | 2007-04-02 | 2007-06-29 | 121643015 FS+88d | 231.5d |
| 121643060 |  | Develop PSS Insertion Device Design (PSS) | 64d | 2007-04-02 | 2007-06-29 | 121643015 FS+88d | 156.75d |
| 121643065 |  | Define PSS BCM Requirements (PSS) | 64d | 2007-04-02 | 2007-06-29 | 9-070M FS+120d | 284.75d |
| 121643075 |  | Prepare Review Material (PSS) | 15d | 2007-04-09 | 2007-04-27 | 121643070 FS-8d, 121643080 FS-59d | 320.75d |
| 121643080 |  | Develop Software Specification (PSS) | 59d | 2007-04-09 | 2007-06-29 | 9-070M FS+125d | 320.75d |
| 121643085 |  | Complete Design & Safety Review - External Reviewers (PSS) | 5d | 2007-05-14 | 2007-05-18 | 121643065 FS-34d, 121643025, 121643075 FS-26d | 284.75d |
| 121643010A |  | Define Programmable Electronics Specification (PSS) | 30.5d | 2007-10-01 | 2007-11-12 | 9-070M, 121643010 FS+63d | 465.5d |
| 121643045A |  | Design Beam Transport Monitor (PSS) | 85d | 2007-10-01 | 2008-02-08 | 121643045 FS+63d | 411d |
| 121643055A |  | Develop Cable Plant Design (PSS) | 51.75d | 2007-10-01 | 2007-12-13 | 121643055 FS+63d | 231.5d |
| 121643060A |  | Develop PSS Insertion Device Design (PSS) | 75d | 2007-10-01 | 2008-01-25 | 121643060 FS+63d | 156.75d |
| 121643065A |  | Define PSS BCM Requirements (PSS) | 75d | 2007-10-01 | 2008-01-25 | 121643065 FS+63d, 9-070M FS+32d | 421d |
| 121643080A |  | Develop Software Specification (PSS) | 75d | 2007-10-01 | 2008-01-25 | 121643080 FS+63d | 421d |
| 121643090M |  | PSS Design 35% Complete (PSS) | 0d | 2008-01-25 | 2008-01-25 | 121643085 FS+39d, 121643060A, 121643060 | 156.75d |
| 121643050A |  | Construct and Test Eng Dev Beam Transport Monitor (PSS) | 126.5d | 2008-01-28 | 2008-07-25 | 121643090M, 121643050 FS+63d | 156.75d |
| 121643100 |  | FY08 Develop PSS Detail Dsgn | 121.5d | 2008-04-09 | 2008-09-30 | 121643050A FS-75d | 157.75d |
| 121643100a |  | FY09 Develop PSS Detail Dsgn | 5d | 2008-10-01 | 2008-10-07 | 121643100 | 157.75d |
| 13643909LOEX |  | FY09 Mngmnt & Supprt Effort for PSS | 59d | 2008-10-01 | 2008-12-24 | 121642908LOE | 20d |
| 121643095M |  | Start P-#2 of PSS PED - FY08 | 0d | 2008-10-07 | 2008-10-07 | 121643055, 121643055A, 9-080M, 121643050, 121643050A FS-75d, 9-090M FS+4d | 31.25d |
| 121643105 |  | Develop PSS Mock-up & Test-bed | 58.5d | 2008-10-07 | 2009-01-07 | 121643095M | 31.25d |
| 121643115 |  | Develop Logic Specificaiton for Tagger/H-D (PSS) | 24d | 2008-10-07 | 2008-11-07 | 121643095M | 99.25d |
| 121643145 |  | Develop QA Documentation (PSS) | 23d | 2008-10-16 | 2008-11-17 | 121643100a FS+6d | 179.5d |
| 121643110 |  | Develop New Logic Specification for CEBAF Segements (PSS) | 34.5d | 2009-01-07 | 2009-02-26 | 121643095M, 121643105 | 31.25d |
| 121643170 |  | Pre-Constrctn Dsgn Review | 5.75d | 2009-01-22 | 2009-01-29 | 121643135 FS-110d | 135.5d |
| 121643120 |  | Develop Screen Specification (PSS) | 18.5d | 2009-02-26 | 2009-03-24 | 121643115, 121643110 FS-1d | 48.25d |
| 121643125 |  | Develop PSS-EPICS Software Spec (PSS) | 35.5d | 2009-02-26 | 2009-04-16 | 121643110 FS-1d, 121643115 | 31.25d |
| 121643130 |  | Comp Detail Dsgn Review - External Reviewers (PSS) | 27.75d | 2009-04-16 | 2009-05-27 | 121643125, 121643100a, 121643120, 121643110 | 31.25d |
| 121643135 |  | Update Dsgn Based on Review recommendations (PSS) | 23d | 2009-05-27 | 2009-06-29 | 121643130 | 31.25d |
| 121643140 |  | Develop Proc Packages (PSS)++ | 34.5d | 2009-06-29 | 2009-08-17 | 121643170, 121643145, 121643135 | 31.25d |
| 121643175 |  | Re-Baseline Actuals Adjustment | 1d | 2013-08-30 | 2013-08-30 | 9-130M FS+227d | 20d |
|  | 4 | **1.2.1.6.4.4** |  |  |  |  |  |
|  | 5 | **1.2.1.6.5 INSERTABLE DUMP** |  | 2006-10-02 | 2013-08-30 |  |  |
| 12165007LOE |  | FY07 Management Effort for Dump Controls (INSERT DUMP) | 247d | 2006-10-02 | 2007-09-28 | 9-070M | 20d |
| 12165010 |  | Define & Package System Layout (INSERT DUMP) | 30d | 2006-10-02 | 2006-11-10 | 9-070M | 326.5d |
| 12165015 |  | Design Top-Level System Layout (INSERT DUMP) | 30d | 2006-11-29 | 2007-01-18 | 12165010 FS+10d | 326.5d |
| 12165016 |  | Preliminary Design & Safety Review (INSERT DUMP) | 1d | 2007-03-01 | 2007-03-01 | 12165015 FS+28d | 326.5d |
| 12165016M |  | Complete Preliminary Design & Safety Review for Dump Controls (INSERT DUMP) | 0d | 2007-03-01 | 2007-03-01 | 12165016 | 326.5d |
| 12165020M |  | Ready to Baseline Milestone for Dump Controls (INSERT DUMP) | 0d | 2007-03-01 | 2007-03-01 | 12165016M, 12165015 FS+29d | 326.5d |
| 12165026 |  | FY08 Comp Dump Sys Dsgn | 25d | 2007-10-01 | 2007-11-02 | 9-080M, 12165020M | 178.5d |
| 12165908LOE |  | FY08 Mngmnt Effort for Dump Controls | 248d | 2007-10-01 | 2008-09-30 | 12165007LOE, 9-080M | 20d |
| 12165027 |  | Pre-Constrctn Final Dsgn Review for Dump | 2.5d | 2007-11-05 | 2007-11-07 | 12165026 | 178.5d |
| 1365909LOEX |  | FY09 Mngmnt Effort for Dump | 59d | 2008-10-01 | 2008-12-24 | 12165908LOE | 20d |
| 12165030 |  | Compile Dump Sys Elect Prcrmnt Packages++ | 125d | 2009-01-05 | 2009-07-01 | 9-090M FS+60d, 12165027 | 63d |
| 12165035 |  | Compile Dump Systen Mech Prcrmnt Packages++ | 65d | 2009-02-18 | 2009-05-19 | 9-090M FS+90d, 12165027 | 93d |
| 12165040 |  | Re-Baseline Actuals Adjustment | 1d | 2013-08-30 | 2013-08-30 | 9-130M FS+227d | 20d |
|  | 6 | **1.2.1.6.6 VACUUM CONTROLS** |  | 2006-10-02 | 2013-08-30 |  |  |

| ID | WBS | Task | Duration | Start | Finish | Predecessors | Total float |
| --- | --- | --- | --- | --- | --- | --- | --- |
| 12166007LOE |  | FY07 Management Effort for Vacuum (VAC CONT) | 247d | 2006-10-02 | 2007-09-28 | 9-070M | 20d |
| 12166010 |  | Design Top Level System Layout (VAC CONT) | 22.5d | 2006-12-05 | 2007-01-12 | 9-070M FS+44d | 351.5d |
| 12166015 |  | Define Vacuum System Interface Requirements (VAC CONT) | 22.5d | 2006-12-05 | 2007-01-12 | 9-070M FS+44d | 317.5d |
| 12166020 |  | Preliminary Design & Safety Review (VAC CONT) | 1d | 2007-03-02 | 2007-03-05 | 12166015 FS+33d | 317.5d |
| 12166020M |  | Complete Preliminary Design & Safety Review Vauum Controls (VAC CONT) | 0d | 2007-03-05 | 2007-03-05 | 12166010, 12166020 | 317.5d |
| 12166025M |  | Ready to baseline Vauum Controls (VAC CONT) | 0d | 2007-03-05 | 2007-03-05 | 12166015 FS+34d, 12166020M | 317.5d |
| 12166026 |  | FY08 Comp Sys Dsgn (VAC CONT) | 25d | 2007-10-01 | 2007-11-02 | 12166025M, 9-080M | 171d |
| 12166908LOE |  | FY08 Mngmnt Effort for Vac (VAC CONT) | 248d | 2007-10-01 | 2008-09-30 | 12167007LOE, 9-080M, 12166007LOE | 20d |
| 12166027 |  | Pre-Constrctn Final Dsgn Review for Vac Controls | 10d | 2007-11-05 | 2007-11-16 | 12166026 | 171d |
| 1366909LOEX |  | FY09 Mngmnt Effort for SRFand ARC Vac Controls | 59d | 2008-10-01 | 2008-12-24 | 12166908LOE | 20d |
| 12166035 |  | Compile Vac Controls Sys Elect Procurements Packages++ | 130d | 2009-01-05 | 2009-07-09 | 12166027, 9-090M FS+60d | 58d |
| 12166040 |  | Re-Baseline Actuals Adjustment | 1d | 2013-08-30 | 2013-08-30 | 9-130M FS+227d | 20d |
|  | 7 | **1.2.1.6.7 MAGNET INSTRUMENTATION** |  | 2006-10-02 | 2013-08-30 |  |  |
| 12167007LOE |  | FY07 Management Effort for Magnet Controls (MAG INSTR) | 247d | 2006-10-02 | 2007-09-28 | 9-070M | 20d |
| 12167010 |  | Design Top-Level Magnet Control System Layout (MAG INSTR) | 22.5d | 2006-12-05 | 2007-01-12 | 9-070M FS+44d | 344d |
| 12167015 |  | Preliminary Design & Safety Review (MAG INSTR) | 1d | 2007-02-02 | 2007-02-05 | 12167010 FS+14d | 344d |
| 12167015M |  | Complete Preliminary Design & Safety Review Magnet Controls (MAG INSTR) | 0d | 2007-02-05 | 2007-02-05 | 12167015 | 344d |
| 12167020M |  | Ready to Baseline Magnet Controls WBS (MAG INSTR) | 0d | 2007-02-05 | 2007-02-05 | 12167015M, 12167010 FS+15d | 344d |
| 12167026 |  | FY08 Comp Sys Dsgn (MAG INSTR) | 25d | 2007-10-01 | 2007-11-02 | 12167020M, 9-080M | 178.5d |
| 12167027 |  | Pre-Constrctn Final Dsgn Review for Mag Instrmenttn | 2.5d | 2007-11-05 | 2007-11-07 | 12167026 | 178.5d |
| 12167028 |  | Compile Mag Control Sys Elect Prcrmnt Package+ | 21.5d | 2009-01-05 | 2009-02-04 | 9-090M FS+60d, 12167027 | 166.5d |
| 12167030 |  | Re-Baseline Actuals Adjustment | 1d | 2013-08-30 | 2013-08-30 | 9-130M FS+227d | 20d |
|  | 7 | **1.2.1.7** |  |  |  |  |  |
|  | 2 | **1.2.2 UPGRADE HALLS A, B & C** |  | 2006-10-02 | 2013-08-30 |  |  |
| 122030M |  | Monthly Safety Inspection Completed | 0d | 2006-10-31 | 2006-10-31 | 9-070M FS+22d | 475d |
| 122031M |  | Monthly Safety Inspection Completed | 0d | 2006-11-30 | 2006-11-30 | 122030M FS+20d | 475d |
| 122005M |  | Quarterly Safety Meeting Complete | 0d | 2006-12-22 | 2006-12-22 | 9-070M FS+58d | 475d |
| 122032M |  | Monthly Safety Inspection Completed | 0d | 2006-12-22 | 2006-12-22 | 122031M FS+16d | 475d |
| 122033M |  | Monthly Safety Inspection Completed | 0d | 2007-01-31 | 2007-01-31 | 122032M FS+21d | 475d |
| 122034M |  | Monthly Safety Inspection Completed | 0d | 2007-02-28 | 2007-02-28 | 122033M FS+19d | 475d |
| 122010M |  | Quarterly Safety Meeting Complete | 0d | 2007-03-30 | 2007-03-30 | 122005M FS+62d | 475d |
| 122035M |  | Monthly Safety Inspection Completed | 0d | 2007-03-30 | 2007-03-30 | 122034M FS+22d | 475d |
| 122036M |  | Monthly Safety Inspection Completed | 0d | 2007-04-30 | 2007-04-30 | 122035M FS+21d | 475d |
| 122037M |  | Monthly Safety Inspection Completed | 0d | 2007-05-31 | 2007-05-31 | 122036M FS+22d | 475d |
| 122015M |  | Quarterly Safety Meeting Complete | 0d | 2007-06-29 | 2007-06-29 | 122010M FS+64d | 475d |
| 122038M |  | Monthly Safety Inspection Completed | 0d | 2007-06-29 | 2007-06-29 | 122037M FS+21d | 475d |
| 122039M |  | Monthly Safety Inspection Completed | 0d | 2007-07-31 | 2007-07-31 | 122038M FS+21d | 475d |
| 122040M |  | Monthly Safety Inspection Completed | 0d | 2007-08-31 | 2007-08-31 | 122039M FS+23d | 475d |
| 122020M |  | Quarterly Sfty Meet Comp | 0d | 2007-09-28 | 2007-09-28 | 122015M FS+63d | 475d |
| 122041M |  | Monthly Sfty Inspection Comptd | 0d | 2007-09-28 | 2007-09-28 | 122040M FS+19d | 475d |
|  | 1 | **1.2.2.1 HALL A** |  | 2006-10-02 | 2013-08-30 |  |  |
|  | 1 | **1.2.2.1.1 MAGNET** |  |  |  |  |  |
|  | 1 | **1.2.2.1.1.1 COMBINED FUNCTION MAGNET** |  |  |  |  |  |
|  | 2 | **1.2.2.1.1.2 CRYOGENIC SYSTEM** |  |  |  |  |  |
|  | 3 | **1.2.2.1.1.3 POWER SUPPLY** |  |  |  |  |  |
|  | 4 | **1.2.2.1.1.4 SHIELD HOUSE** |  |  |  |  |  |
|  | 5 | **1.2.2.1.1.5 SUPPORT STRUCTURE & MOTION SYSTEM** |  |  |  |  |  |
|  | 6 | **1.2.2.1.1.6 CONTROL SYSTEM** |  |  |  |  |  |
|  | 7 | **1.2.2.1.1.7 SEPTUM** |  |  |  |  |  |
|  | 2 | **1.2.2.1.2 DETECTORS** |  |  |  |  |  |
|  | 1 | **1.2.2.1.2.1 TRIGGER SYSTEM (Scintillators)** |  |  |  |  |  |
|  | 2 | **1.2.2.1.2.2 TRACKING SYSTEM (Drift Chambers)** |  |  |  |  |  |
|  | 3 | **1.2.2.1.2.3 GAS CERENKOV** |  |  |  |  |  |
|  | 4 | **1.2.2.1.2.4 AREOGEL CERENKOV** |  |  |  |  |  |
|  | 5 | **1.2.2.1.2.5 CALORIMETER** |  |  |  |  |  |
|  | 6 | **1.2.2.1.2.6 FOCAL PLANE POLARIMETER** |  |  |  |  |  |
|  | 3 | **1.2.2.1.3 COMPUTING** |  | 2006-10-02 | 2013-08-30 |  |  |
|  | 1 | **1.2.2.1.3.1 DAQ FOR MAD** |  |  |  |  |  |
|  | 2 | **1.2.2.1.3.2 DAQ UPGRADES FOR HRS** |  | 2006-10-02 | 2013-08-30 |  |  |
| 122132005M |  | Start PED DAQ upgrade for one HRS (DAQ UPGRD) | 0d | 2006-10-02 | 2006-10-02 | 9-070M | 637d |
| 122132010 |  | Specify readout modules & busses trigger changes. Design power dist changes. Engineer DAQ driver changes (DAQ UPGRD) | 85d | 2006-10-02 | 2007-02-08 | 122132005M | 637d |
| 122132908LOE |  | FY08 Proj Admin H-A | 248d | 2007-10-01 | 2008-09-30 | 9-080M, 1252007LOE | 20d |
| 122132015 |  | Re-Baseline Actuals Adjustment | 1d | 2013-08-30 | 2013-08-30 | 9-130M FS+227d | 20d |
|  | 4 | **1.2.2.1.4 FAST ELECTRONICS** |  |  |  |  |  |
|  | 5 | **1.2.2.1.5 BEAMLINE** |  | 2006-10-02 | 2013-08-30 |  |  |
|  | 1 | **1.2.2.1.5.1 MOLLER POLARIMETER UPGRADE** |  | 2006-10-02 | 2013-08-30 |  |  |
| 122151005M |  | Start PED Moller (MLLR PLRMTR UPGRD) | 0d | 2006-10-02 | 2006-10-02 | 9-070M | 637d |
| 122151010 |  | Design dipole/detector stands beamline changes dipole insert (MLLR PLRMTR UPGRD) | 85d | 2006-10-02 | 2007-02-08 | 122151005M | 637d |
| 122151015 |  | Re-Baseline Actuals Adjustment | 1d | 2013-08-30 | 2013-08-30 | 9-130M FS+227d | 20d |
|  | 2 | **1.2.2.1.5.2 COMPTON POLARIMETER UPGRADE** |  | 2007-03-01 | 2013-08-30 |  |  |

| ID | WBS | Task | Duration | Start | Finish | Predecessors | Total float |
| --- | --- | --- | --- | --- | --- | --- | --- |
| 122152005M |  | Start FY07 PED Compton - 1st phase | 0d | 2007-03-01 | 2007-03-01 | 9-070M FS+98d | 539d |
| 122152010 |  | FY07 Design magnets / cavity stands. Engineer detector mods (COMPT PLRMTR UPGRD) | 85d | 2007-03-01 | 2007-06-28 | 122152005M | 539d |
| 122152015M |  | Start FY08 Milestone P-#2 (COMPT PLRMTR UPGRD) | 0d | 2008-07-02 | 2008-07-02 | 122041M, 122151010, 9-080M FS+185d, 122132010, 122020M, 122152010 | 290d |
| 122152020 |  | FY08 Dsgn Vac Pipe & Detector motion Sys (COMPT PLRMTR UPGRD)+ | 21d | 2008-07-02 | 2008-07-31 | 122152015M | 290d |
| 122152025 |  | Re-Baseline Actuals Adjustment | 1d | 2013-08-30 | 2013-08-30 | 9-130M FS+227d | 20d |
|  | 3 | **1.2.2.1.5.3 MAPPING-ARC ENERGY MEASUREMENT** |  | 2006-10-02 | 2013-08-30 |  |  |
| 122153000M |  | Start FY07 PED 9th dipole mapper 1ST Phase | 0d | 2006-10-02 | 2006-10-02 | 9-070M | 543d |
| 122153005 |  | FY07 PED Engineer & analysis of mapping coil 1st Phase | 25d | 2006-10-02 | 2006-11-03 | 122153000M | 543d |
| 122153009M |  | Start FY08 PED 9th Dipole Mapper P-#2 | 0d | 2008-10-01 | 2008-10-01 | 122153005, 9-090M | 73d |
| 122153010 |  | PED Mech & Elect Sys Dsgn P-2+ | 70d | 2009-03-11 | 2009-06-17 | 122153009M FS+105d | 73d |
| 122153015 |  | Re-Baseline Actuals Adjustment | 1d | 2013-08-30 | 2013-08-30 | 9-130M FS+227d | 20d |
|  | 6 | **1.2.2.1.6 INFRASTRUCTURE** |  |  |  |  |  |
|  | 1 | **1.2.2.1.6.1 ENGINEERING & DESIGN** |  |  |  |  |  |
|  | 2 | **1.2.2.1.6.2 CABLING** |  |  |  |  |  |
|  | 3 | **1.2.2.1.6.3 INSTALLATION** |  |  |  |  |  |
|  | 2 | **1.2.2.2 HALL B** |  | 2006-10-02 | 2013-08-30 |  |  |
|  | 1 | **1.2.2.2.1 MAGNET** |  | 2006-10-02 | 2013-08-30 |  |  |
| 122211007LOE |  | FY07 Project Management for all Hall B | 247d | 2006-10-02 | 2007-09-28 | 9-070M | 20d |
| 122211015M |  | Torus- Completion of ACD technical review and summary report | 0d | 2007-04-26 | 2007-04-26 | 9-070M FS+139d | 127d |
| 122212015M |  | Sol- Completion of ACD technical review and progress report | 0d | 2007-04-26 | 2007-04-26 | 9-070M FS+139d | 24.08d |
| 122211017 |  | Torus- Initial Payment for the design (TOROIDAL MAG) | 25d | 2007-04-27 | 2007-06-01 | 122211015M | 127d |
| 122212017 |  | Sol- Initial Payment for the design (SACLAY) | 25d | 2007-04-27 | 2007-06-01 | 122212015M | 24.08d |
| 122211020 |  | Torus- First phase of the design (TOROIDAL MAG) | 65d | 2007-06-04 | 2007-09-04 | 122211017, 122211015M | 127d |
| 122212020 |  | Sol- First phase of the design (SOLENOID) | 65d | 2007-06-04 | 2007-09-04 | 122212017 | 24.08d |
| 122211025M |  | Torus- Safety Assessment (TOROIDAL MAG) | 0d | 2007-09-04 | 2007-09-04 | 122211020 | 127d |
| 122212025M |  | Sol- Safety Assessment (SOLENOID) | 0d | 2007-09-04 | 2007-09-04 | 122212020 | 24.08d |
| 122211035 |  | **Torus-FY07-Second phase of the design (1st & part of 2nd prog pymnt) | 40d | 2007-09-05 | 2007-10-30 | 122211025M, 1131005 | 127d |
| 122212035 |  | **Solenoid- FY07 Contract for Design (1st & part of 2nd prog pymnt) | 19d | 2007-09-05 | 2007-10-01 | 122212020, 122212025M | 24.08d |
| 12221050 |  | **Solenoid- FY08 Contract for Design (part of 2nd prog pymnt) | 11.92d | 2007-10-02 | 2007-10-17 | 122212035 | 24.08d |
| 12221050M |  | Solenoid- FY07 Techncl Dsgn Report & Sfty Assessmnt | 0d | 2007-10-17 | 2007-10-17 | 12221050 | 24.08d |
| 12221055 |  | **Solenoid Labor Reference Dsgn | 75d | 2007-10-17 | 2008-02-13 | 12221050M, 122212036M FS-11d | 24.08d |
| 122211035M |  | Torus- FY07 Techncl Dsgn Report & Sfty Assessmnt | 0d | 2007-10-30 | 2007-10-30 | 122211035 | 127d |
| 12221040 |  | **Torus Labor Reference Dsgn | 85d | 2007-10-31 | 2008-03-12 | 122211036M FS-1d | 99d |
| 122211036M |  | Torus- Contract Award | 0d | 2007-11-01 | 2007-11-01 | 9-080M FS+23d | 99d |
| 122211037S |  | **Torus- Contract for Design (balance of 2nd & 3rd progress pymnts) | 56d | 2007-11-01 | 2008-01-31 | 122211036M, 122211035M FS+1d | 127d |
| 122212036M |  | Solenoid- Contract Award | 0d | 2007-11-01 | 2007-11-01 | 9-080M FS+23d | 25d |
| 122212037S |  | **Solenoid- Contract for Design (balance of 2nd & 3rd progress pymnts) | 97d | 2007-11-01 | 2008-03-31 | 122212036M | 86d |
| 122211038M |  | Torus- 1st Progress Payment Completed | 0d | 2007-11-29 | 2007-11-29 | 122211036M FS+19d, 122211035 | 148d |
| 122211039M |  | Torus- 2nd Progress Payment Completed | 0d | 2007-12-21 | 2007-12-21 | 122211038M FS+16d, 122211035 | 148d |
| 122212038M |  | Solenoid- 1st Progress Payment Completed | 0d | 2008-01-04 | 2008-01-04 | 122212035, 122212036M FS+38d | 107d |
| 122211040M |  | Torus- 3rd Progress Payment Completed | 0d | 2008-01-31 | 2008-01-31 | 122211037S, 122211039M | 127d |
| 12221060 |  | Solenoid Labor Procurement Prep | 155d | 2008-02-13 | 2008-09-23 | 12221055 | 24.08d |
| 122212039M |  | Solenoid- 2nd Progress Payment Completed | 0d | 2008-02-29 | 2008-02-29 | 12221050, 122212035, 122212038M FS+38d | 107d |
| 12221045M |  | Torus- Reference Dsgn Comptd++ | 0d | 2008-03-12 | 2008-03-12 | 12221040, 122211040M | 99d |
| 12221045 |  | Torus Labor Procurement Prep | 140d | 2008-03-13 | 2008-09-29 | 12221040 | 831d |
| 12221060M |  | Solenoid- Reference Dsgn Comptd++ | 0d | 2008-03-31 | 2008-03-31 | 122212040M, 12221055 | 86d |
| 122212040M |  | Solenoid- 3rd Progress Payment Completed | 0d | 2008-03-31 | 2008-03-31 | 122212039M, 122212037S | 86d |
| 14211000MX |  | Torus Start 2nd Phase of Proc Prep | 0d | 2008-10-01 | 2008-10-01 | 9-090M, 12221045 | 830d |
| 14211002X |  | Torus Prcrmnt Prep | 59d | 2008-10-01 | 2008-12-24 | 14211000MX | 830d |
| 14211009EX |  | Torus FY09 Travel | 59d | 2008-10-01 | 2008-12-24 | 9-090M | 0d |
| 14212000MX |  | Solenoid Start 2nd Phase of Proc Prep | 0d | 2008-10-01 | 2008-10-01 | 9-090M, 12221060 | 19d |
| 14212002X |  | Solenoid Prcrmnt Prep for Dsgn & Prcrmnt | 59d | 2008-10-01 | 2008-12-24 | 14212000MX, 12221060M | 19d |
| 14212009EX |  | Solenoid FY09 Travel | 59d | 2008-10-01 | 2008-12-24 | 9-090M | 19d |
| 122212050 |  | Re-Baseline Actuals Adjustment | 1d | 2013-08-30 | 2013-08-30 | 9-130M FS+227d | 20d |
|  | 1 | **1.2.2.2.1.1 TOROIDAL MAGNET** |  |  |  |  |  |
|  | 2 | **1.2.2.2.1.2 SOLENOID** |  |  |  |  |  |
|  | 2 | **1.2.2.2.2 DETECTORS** |  | 2006-10-02 | 2013-08-30 |  |  |
| 1222211005 |  | SVT-Design overall layout (SILICON DTCTR) | 150d | 2006-10-02 | 2007-05-11 | 9-070M | 228d |
| 1222211015 |  | SVT- Design of the VME Board (SILICON DTCTR) | 125d | 2006-10-02 | 2007-04-06 | 9-070M | 268d |
| 1222213005 |  | DC- Design of the chamber & Stringing Fixture : Phase 1 (F DRFT CHAMB) | 120d | 2006-10-02 | 2007-03-30 | 9-070M | 251d |
| 1222213010 |  | DC-Design On-chamber Electronics: Phase 1 (F DRFT CHAMB) | 120d | 2006-10-02 | 2007-03-30 | 9-070M | 251d |
| 1222223005 |  | Designing the mounting (FCAL) | 100d | 2006-10-02 | 2007-03-02 | 9-070M | 419d |
| 1222223010 |  | Design Box with end plates (FCAL) | 100d | 2006-10-02 | 2007-03-02 | 9-070M | 419d |
| 1222223025 |  | Design pmt holders fiber routing and light guides (FCAL) | 100d | 2006-10-02 | 2007-03-02 | 9-070M | 454d |
| 1222231005 |  | Design of Light Guides (CTOF) | 120d | 2006-10-02 | 2007-03-30 | 9-070M | 383d |
| 1222232005 |  | Design of the backing structure for scintillators (FTOF) | 125d | 2006-10-02 | 2007-04-06 | 9-070M | 493d |
| 1222232010 |  | Design of the light guides (FTOF) | 125d | 2006-10-02 | 2007-04-06 | 9-070M | 493d |
| 1222223030 |  | Design lifting plan and hardware (FCAL) | 40d | 2006-11-15 | 2007-01-22 | 1222223015 FS-85d | 482d |
| 1222223015 |  | Design scintillator holders (FCAL) | 60d | 2006-12-22 | 2007-03-27 | 1222223010 FS-43d, 1222223005 FS-43d | 419d |
| 1222231010 |  | Design of tools for the LG bending technique (CTOF) | 120d | 2007-01-02 | 2007-06-21 | 9-070M FS+58d | 325d |

| ID | WBS | Task | Duration | Start | Finish | Predecessors | Total float |
| --- | --- | --- | --- | --- | --- | --- | --- |
| 1222232015 |  | Magnetic shielding design (FTOF) | 125d | 2007-01-02 | 2007-06-28 | 9-070M FS+58d | 435d |
| 1222241005 |  | Design of the mirror 6 sectors (HTCC) | 120d | 2007-01-04 | 2007-06-25 | 9-070M FS+60d | 363d |
| 1222242005 |  | Design modification to the mirrors (LTCC) | 110d | 2007-01-04 | 2007-06-11 | 9-070M FS+60d | 411d |
| 1222241010 |  | Design of the Module (HTCC) | 100d | 2007-01-24 | 2007-06-14 | 9-070M FS+73d | 296d |
| 1222231015 |  | Design the support for the triplet with 1 m long bend LG's (CTOF) | 84d | 2007-02-15 | 2007-06-14 | 9-070M FS+89d | 330d |
| 1222232020 |  | PMT housing and grounding design (FTOF) | 158d | 2007-02-15 | 2007-09-28 | 9-070M FS+89d | 371d |
| 1222242010 |  | Design of the support structure (LTCC) | 110d | 2007-03-21 | 2007-08-23 | 1222242005 FS-58d | 411d |
| 1222223020 |  | Design lead sheets (FCAL) | 20d | 2007-03-26 | 2007-04-20 | 1222223015 FS-2d | 419d |
| 1222213015 |  | DC- Design of the chamber & Stringing Fixture : Phase 2 (F DRFT CHAMB) | 127d | 2007-04-02 | 2007-09-28 | 1222213005 | 251d |
| 1222213020 |  | DC-Design On-chamber Electronics: Phase 2 (F DRFT CHAMB) | 127d | 2007-04-02 | 2007-09-28 | 1222213010 | 251d |
| 1222211020 |  | SVT- Design readout software (SILICON DTCTR) | 122d | 2007-04-09 | 2007-09-28 | 1222211015 | 268d |
| 1222232030 |  | FTOF- Comp Dsgn of Light Guides (DETCTR) (FY-07) Notebook | 125d | 2007-04-09 | 2007-10-03 | 1222232010 | 493d |
| 1222223030M |  | EC-FY07 technical design report and safety assessment (FCAL) | 0d | 2007-04-20 | 2007-04-20 | 1222223030, 1222223020, 1222223025 | 419d |
| 1222211010 |  | SVT-Design support structure (SILICON DTCTR) | 137d | 2007-05-14 | 2007-11-27 | 1222211005 | 228d |
| 1222241015 |  | Design of the Mounting Frames (HTCC) | 74d | 2007-06-15 | 2007-09-28 | 1222241010 | 296d |
| 1222231020M |  | CTOF-FY07 Techncl Dsgn Report & Sfty Assessmnt (DETCTR) | 0d | 2007-06-21 | 2007-06-21 | 1222231005, 1222231015, 1222231010 | 325d |
| 12222045 |  | CTOF- Compltn of Light Guides Dsgn (DETCTR) | 120d | 2007-06-22 | 2007-12-12 | 1222231020M | 445d |
| 12222050 |  | CTOF- Compltn of Dsgn LG bending (DETCTR) | 120d | 2007-06-22 | 2007-12-12 | 1222231020M | 325d |
| 1222242015M |  | LTCC- FY07 Techncl Dsgn Report & Sfty Assessmnt (DETCTR) | 0d | 2007-08-23 | 2007-08-23 | 1222242010 | 411d |
| 12222080 |  | LTCC- Dsgn Extended Working Volume (DETCTR) | 110d | 2007-08-24 | 2008-02-08 | 1222242015M | 411d |
| 1222213025M |  | FDC- FY07 Techncl Dsgn Report & Sfty Assessmnt (DETCTR) | 0d | 2007-09-28 | 2007-09-28 | 1222213020, 1222213015 | 251d |
| 1222232020M |  | FTOF- FY07 technical design report and safety assessment | 0d | 2007-09-28 | 2007-09-28 | 1222232010, 1222232015, 1222232020, 1222232005 | 371d |
| 1222241025M |  | FY07 technical design report and safety assessment (HTCC) | 0d | 2007-09-28 | 2007-09-28 | 1222241015, 1222241005 | 296d |
| 12222020M |  | FDC- Resource Loaded Schedule for Fab (DETCTR) | 0d | 2007-10-01 | 2007-10-01 | 1222213025M | 251d |
| 12222025 |  | FDC- Comp Dsgn of Chamb & Stringing Fixture (DETCTR) | 245d | 2007-10-01 | 2008-09-25 | 12222020M | 251d |
| 12222030 |  | FDC- Comp Dsgn of Chambers Electrnc's (DETCTR) | 245d | 2007-10-01 | 2008-09-25 | 12222020M | 251d |
| 12222060 |  | FTOF- Comp Dsgn of Backing Struct for Scintillators (DETCTR) + | 125d | 2007-10-01 | 2008-04-07 | 1222232020M, 1222232005 | 371d |
| 12222065 |  | FTOF- Comp Magnetic Shielding Dsgn (DETCTR) + | 125d | 2007-10-01 | 2008-04-07 | 1222232020M, 1222232015 | 371d |
| 12222070 |  | FTOF- Comp PMT Housing & Grounding Dsgn (DETCTR) + | 125d | 2007-10-01 | 2008-04-07 | 1222232020M, 1222232020 | 371d |
| 12222005 |  | SVT- Dsgn Supprt Struct Optimztn Comptd (DETCTR) | 110d | 2007-11-28 | 2008-05-12 | 1222211020, 9-080M, 1222211010 | 228d |
| 12222010 |  | SVT- Dsgn of VME Board Comptd (DETCTR) | 125d | 2008-03-31 | 2008-09-24 | 12222005 FS-31d | 252d |
| 12222015 |  | FY08 SVT- Dsgn Readout Software Comptd (DETCTR) | 129d | 2008-03-31 | 2008-09-30 | 12222005 FS-31d | 228d |
| 12222000 |  | FY08 SVT- Comp Dsgn Layout (DETCTR)+ | 98d | 2008-05-13 | 2008-09-30 | 1132897 | 236d |
| 12222035M |  | FDC-Compltn of PED (DETCTR)+ | 0d | 2008-09-29 | 2008-09-29 | 1132865M, 12222025, 12222030 | 249d |
| 12222040 |  | FY08 Exp EC- Comp Dsgn of Assy (DETCTR) | 1d | 2008-09-30 | 2008-09-30 | 1132851M, 1222223030M | 60d |
| 12222055 |  | PROC CTOF- Comp Dsgn Supprt for Triplet with 1 m long bend LG's (DETCTR)+ | 120d | 2008-09-30 | 2009-03-30 | 1132890M, 12222050 | 129d |
| 12222055a |  | FY08 Exp CTOF- Comp Dsgn Supprt for Triplet with 1 m long bend LG's (DETCTR)+ | 1d | 2008-09-30 | 2008-09-30 | 1132890M, 12222050 | 129d |
| 12222075 |  | PROC HTCC- Dsgn of Whole Module (DETCTR) | 200d | 2008-09-30 | 2009-07-22 | 1222241025M, 1132831M | 49d |
| 12222075a |  | FY08 Exp HTCC- Dsgn of Whole Module (DETCTR) | 1d | 2008-09-30 | 2008-09-30 | 1132831M, 1222241025M | 49d |
| 12222000a |  | FY09 SVT- Comp Dsgn Layout (DETCTR)+ | 12d | 2008-10-01 | 2008-10-16 | 12222000 | 236d |
| 12222015a |  | FY09 SVT- Dsgn Readout Software Comptd (DETCTR) | 20d | 2008-10-01 | 2008-10-28 | 12222015 | 228d |
| 12222040a |  | FY09 Exp EC- Comp Dsgn of Assy (DETCTR) | 149d | 2008-10-01 | 2009-05-11 | 12222040 | 60d |
| 12222055b |  | FY09 Exp CTOF- Comp Dsgn Supprt for Triplet with 1 m long bend LG's (DETCTR)+ | 119d | 2008-10-01 | 2009-03-30 | 12222055a | 129d |
| 12222075b |  | FY09 Exp HTCC- Dsgn of Whole Module (DETCTR) | 199d | 2008-10-01 | 2009-07-22 | 12222075a | 49d |
| 142213009EX |  | FY09 Travel (FWD Chambers) | 59d | 2008-10-01 | 2008-12-24 | 9-090M | 248d |
| 12222015M |  | SVT- Techncl Dsgn Report & drawings (DETCTR)+ | 0d | 2008-10-28 | 2008-10-28 | 12222015a, 12222010, 1132800M | 228d |
| 1222223040 |  | EC- Dsgn of Lifting & Mounting Hardware (DETCTR)+ | 110d | 2009-01-30 | 2009-07-07 | 12222040a FS-71d | 60d |
| 1222223041M |  | EC- Final Techncl Dsgn Report & Sfty Assessmnt (DETCTR)+ | 0d | 2009-05-11 | 2009-05-11 | 12222040a | 99d |
| 1222241035M |  | HTCC- Techncl Dsgn Report (DETCTR)+ | 0d | 2009-07-22 | 2009-07-22 | 12222075, 12222075b | 49d |
| 1222242020 |  | Re-Baseline Actuals Adjustment | 1d | 2013-08-30 | 2013-08-30 | 9-130M FS+227d | 20d |
|  | 1 | **1.2.2.2.2.1 TRACKING** |  |  |  |  |  |
|  | 1 | **1.2.2.2.2.1.1 SILICON DETECTOR** |  |  |  |  |  |
|  | 2 | **1.2.2.2.2.1.2 CENTRAL TRACKER** |  |  |  |  |  |
|  | 3 | **1.2.2.2.2.1.3 FORWARD DRIFT CHAMBERS** |  |  |  |  |  |
|  | 2 | **1.2.2.2.2.2 CALORIMETRY** |  |  |  |  |  |
|  | 1 | **1.2.2.2.2.2.1 CENTRAL CALORIMETER** |  |  |  |  |  |
|  | 2 | **1.2.2.2.2.2.2 COIL CALORIMETER** |  |  |  |  |  |
|  | 3 | **1.2.2.2.2.2.3 FORWARD CALORIMETER** |  |  |  |  |  |
|  | 3 | **1.2.2.2.2.3 TIME OF FLIGHT** |  |  |  |  |  |
|  | 1 | **1.2.2.2.2.3.1 CENTRAL TOF** |  |  |  |  |  |
|  | 2 | **1.2.2.2.2.3.2 FORWARD TOF** |  |  |  |  |  |
|  | 4 | **1.2.2.2.2.4 CERENKOV** |  |  |  |  |  |
|  | 1 | **1.2.2.2.2.4.1 HIGH THRESHOLD CC** |  |  |  |  |  |
|  | 2 | **1.2.2.2.2.4.2 LOW THRESHOLD CC** |  |  |  |  |  |
|  | 3 | **1.2.2.2.3 COMPUTING** |  | 2006-10-02 | 2013-08-30 |  |  |
| 122231005 |  | Trigger- Level 1 design (TRGR SYS) | 110d | 2006-10-02 | 2007-03-16 | 9-070M | 387d |
| 122231010 |  | Trigger- Level 2 design (TRGR SYS) | 125d | 2006-12-21 | 2007-06-26 | 9-070M FS+56d | 316d |
| 122231015 |  | Trigger- Electronic design (TRGR SYS) | 66d | 2007-06-27 | 2007-09-28 | 122231010, 122231005 | 316d |
| 122231020M |  | Trigger- Design Report (TRGR SYS) | 0d | 2007-09-28 | 2007-09-28 | 122231015 | 316d |
| 12223025 |  | Trigger- Compltn of L-1 Dsgn Scheme (COMPUTNG) | 60d | 2007-10-01 | 2008-01-03 | 122231020M, 122231015 | 316d |

| ID | WBS | Task | Duration | Start | Finish | Predecessors | Total float |
| --- | --- | --- | --- | --- | --- | --- | --- |
| 12223030 |  | Trigger- Compltn of L-2 Dsgn Scheme (COMPUTNG) | 60d | 2008-01-04 | 2008-03-31 | 12223025 | 316d |
| 12223035 |  | Trigger- Compltn of Electronic Dsgn (COMPUTNG) | 60d | 2008-04-01 | 2008-06-24 | 12223030 | 316d |
| 12223040M |  | CLAS12 Trigger Techncl Dsgn Report (COMPUTNG)+ | 0d | 2008-06-24 | 2008-06-24 | 12223035 | 316d |
| 12223045 |  | CLAS12 Slow Control Dsgn Sys (COMPUTNG)++ | 110d | 2009-04-01 | 2009-09-03 | 9-090M FS+120d | 18d |
| 122231025 |  | Re-Baseline Actuals Adjustment | 1d | 2013-08-30 | 2013-08-30 | 9-130M FS+227d | 20d |
|  | 1 | **1.2.2.2.3.1 TRIGGER SYSTEM (Scintillators)** |  |  |  |  |  |
|  | 2 | **1.2.2.2.3.2 DAQ** |  |  |  |  |  |
|  | 3 | **1.2.2.2.3.3 ONLINE COMPUTING** |  |  |  |  |  |
|  | 4 | **1.2.2.2.3.4 OFFLINE COMPUTING** |  |  |  |  |  |
|  | 5 | **1.2.2.2.3.5 SLOW CONTROLS** |  |  |  |  |  |
|  | 4 | **1.2.2.2.4 ELECTRONICS** |  | 2008-01-04 | 2013-08-30 |  |  |
| 12224005 |  | FADC Analysis (ADC) (ELECTRNC'S)++ | 120d | 2008-01-04 | 2008-06-24 | 9-080M FS+60d | 26d |
| 12224010 |  | Re-Baseline Actuals Adjustment | 1d | 2013-08-30 | 2013-08-30 | 9-130M FS+227d | 20d |
|  | 1 | **1.2.2.2.4.1 ADC** |  |  |  |  |  |
|  | 2 | **1.2.2.2.4.2 TDC** |  |  |  |  |  |
|  | 3 | **1.2.2.2.4.3 SCALERS** |  |  |  |  |  |
|  | 4 | **1.2.2.2.4.4 HIGH VOLTAGE** |  |  |  |  |  |
|  | 5 | **1.2.2.2.4.5 PRE-TRIGGER** |  |  |  |  |  |
|  | 6 | **1.2.2.2.4.6 LOGIC** |  |  |  |  |  |
|  | 7 | **1.2.2.2.4.7 CRATES, RACKS** |  |  |  |  |  |
|  | 5 | **1.2.2.2.5 BEAMLINE** |  | 2006-10-02 | 2013-08-30 |  |  |
| 122254005 |  | BL-Shielding design for central detector (BL COMPON) | 110d | 2006-10-02 | 2007-03-16 | 9-070M | 251d |
| 122253000 |  | Target- Design of Longitudinal polarized target (TARGETS) | 150d | 2007-01-04 | 2007-08-07 | 9-070M FS+60d | 288d |
| 122254010 |  | BL-Forward detector shielding (BL COMPON) | 137d | 2007-03-19 | 2007-09-28 | 122254005 | 251d |
| 122253005M |  | Target- Design Report (TARGETS) | 0d | 2007-08-07 | 2007-08-07 | 122253000 | 288d |
| 122254015M |  | BL-Design Report (BL COMPON) | 0d | 2007-09-28 | 2007-09-28 | 122254010, 122253005M | 251d |
| 12225045 |  | BL COMPON- Beam Vac Sys (BL) | 60d | 2008-01-04 | 2008-03-31 | 9-080M FS+60d | 86d |
| 12225050 |  | BL COMPON- Dsgn of BL Shielding (BL)+ | 60d | 2008-06-30 | 2008-09-23 | 12225045, 1135025 | 253d |
| 12225015 |  | Moller Polarimter Optic Dsgn (BL) | 40d | 2008-10-01 | 2008-11-25 | 9-090M | 168d |
| 12225025 |  | Target- Layout (BL) | 55d | 2008-10-06 | 2008-12-23 | 9-090M FS+3d, 122254015M | 0d |
| 12225020 |  | Moller Polarimter Mech Supprt (BL)+ | 40d | 2008-11-26 | 2009-02-02 | 12225015 | 168d |
| 12225030 |  | Target- Vac Sys Dsgn & Mech Supprt (BL) | 95d | 2008-12-24 | 2009-05-15 | 12225025 | 0d |
| 12225035 |  | Target- Dsgn of Cryogenic Sys (BL) | 55d | 2009-05-18 | 2009-08-04 | 12225030 | 0d |
| 12225040 |  | Target- Dsgn Control Sys (BL)+ | 40d | 2009-08-05 | 2009-09-30 | 12225035 | 0d |
| 122254020 |  | Re-Baseline Actuals Adjustment | 1d | 2013-08-30 | 2013-08-30 | 9-130M FS+227d | 20d |
|  | 1 | **1.2.2.2.5.1 FARADAY CUP UPGRADE** |  |  |  |  |  |
|  | 2 | **1.2.2.2.5.2 MOLLER POLARIMETER UPGRADE** |  |  |  |  |  |
|  | 3 | **1.2.2.2.5.3 TARGETS** |  |  |  |  |  |
|  | 4 | **1.2.2.2.5.4 BEAMLINE COMPONENTS** |  |  |  |  |  |
|  | 6 | **1.2.2.2.6 INFRASTRUCTURE** |  | 2008-04-01 | 2013-08-30 |  |  |
| 12226010 |  | FY08 Exp Utilities Dsgn of Connections to Cryogenic systems (Utilities) (INFSTRCTR)+ | 128d | 2008-04-01 | 2008-09-30 | 9-080M FS+120d | 116d |
| 12226015 |  | FY08 Exp Dsgn Mech Supprt Frames for HTCC (INFSTRCTR)+ | 128d | 2008-04-01 | 2008-09-30 | 9-080M FS+120d | 56d |
| 12226020 |  | FY08 Exp Dsgn Mech Supprt Frames for Central Detector (INFSTRCTR)+ | 128d | 2008-04-01 | 2008-09-30 | 9-080M FS+120d | 56d |
| 12226010a |  | FY09 Exp Utilities Dsgn of Connections to Cryogenic systems (Utilities) (INFSTRCTR)+ | 132d | 2008-10-01 | 2009-04-16 | 12226010 | 116d |
| 12226015a |  | FY09 Exp Dsgn Mech Supprt Frames for HTCC (INFSTRCTR)+ | 192d | 2008-10-01 | 2009-07-13 | 12226015 | 56d |
| 12226020a |  | FY09 Exp Dsgn Mech Supprt Frames for Central Detector (INFSTRCTR)+ | 192d | 2008-10-01 | 2009-07-13 | 12226020 | 56d |
| 12226025 |  | Re-Baseline Actuals Adjustment | 1d | 2013-08-30 | 2013-08-30 | 9-130M FS+227d | 20d |
|  | 1 | **1.2.2.2.6.1 UTILITIES** |  |  |  |  |  |
|  | 2 | **1.2.2.2.6.2 MECHANICAL FRAMES** |  |  |  |  |  |
|  | 3 | **1.2.2.2.6.3 ASSEMBLY** |  |  |  |  |  |
|  | 4 | **1.2.2.2.6.4 INSTALLATION** |  |  |  |  |  |
|  | 3 | **1.2.2.3 HALL C** |  | 2006-10-02 | 2013-08-30 |  |  |
|  | 1 | **1.2.2.3.1 MAGNET** |  | 2006-10-02 | 2013-08-30 |  |  |
|  | 1 | **1.2.2.3.1.1 Q-1 QUADRUPOLE** |  | 2006-10-02 | 2013-08-30 |  |  |
| 122311007LOE |  | FY07 Overview entire PED project Q1-QUAD | 247d | 2006-10-02 | 2007-09-28 | 9-070M | 0d |
| 122311010 |  | Perform magnetic analysis and analyze tolerances Q1-QUAD | 130d | 2006-10-02 | 2007-04-13 | 9-070M | 68d |
| 122311020 |  | Design LN2 shield Q1-QUAD | 60d | 2006-10-02 | 2007-01-03 | 9-070M | 17d |
| 122311030 |  | Design control system Q1-QUAD | 40d | 2006-10-02 | 2006-11-28 | 9-070M | 78d |
| 122311035 |  | Trial Winding of Q1 Coil Q1-QUAD | 109d | 2007-01-04 | 2007-06-08 | 122311020 | 17d |
| 122311045 |  | P-1 Prepare reference design Q1-QUAD | 187d | 2007-03-06 | 2007-11-28 | 122311020, 122311035 FS-68d, 122311030, 122311010 FS-80d | 17d |
| 122311047 |  | Dsgn Vac Vessel Q1-QUAD | 65d | 2007-10-01 | 2008-01-10 | 9-080M | 60d |
| 122311908LOE |  | FY08 Overview Entire PED Proj Q1-QUAD | 248d | 2007-10-01 | 2008-09-30 | 122311007LOE, 9-080M | 0d |
| 122311045b |  | P-2 Prep reference Dsgn Q1-QUAD | 122d | 2007-11-29 | 2008-05-30 | 122311045, 9-080M | 17d |
| 122311049 |  | Dsgn Mag SupprtStand Q1-QUAD | 55d | 2008-01-11 | 2008-03-31 | 9-080M, 122311047 | 60d |
| 122311045M |  | Reference Dsgn Comptd Q1-QUAD | 0d | 2008-05-30 | 2008-05-30 | 122311045b | 17d |
| 122311050M |  | Start Bid Process Q1-QUAD | 0d | 2008-06-02 | 2008-06-02 | 122311045M | 17d |
| 122311055 |  | FY08 Exp Bid Process P-#1 Q1-QUAD | 85d | 2008-06-02 | 2008-09-30 | 122311050M, 122311049 | 17d |
| 122311055a |  | FY09 Exp Bid Process P-#1 Q1-QUAD | 41d | 2008-10-01 | 2008-11-26 | 122311055 | 17d |
| 14312909LOEX |  | Q1- FY09 Proj Mngmnt H-C upgrade | 59d | 2008-10-01 | 2008-12-24 | 122311908LOE | 20d |
| 122311056 |  | Determine Best Offer P-#2 Q1-QUAD+ | 50d | 2008-12-01 | 2009-02-18 | 122311055a | 17d |

| ID | WBS | Task | Duration | Start | Finish | Predecessors | Total float |
| --- | --- | --- | --- | --- | --- | --- | --- |
| 122311060 |  | Re-Baseline Actuals Adjustment | 1d | 2013-08-30 | 2013-08-30 | 9-130M FS+227d | 20d |
|  | 2 | **1.2.2.3.1.2 HB/Q2-3/DIPOLE** |  | 2006-10-02 | 2013-08-30 |  |  |
| 122312015 |  | Optimise coil design analyze tolerances HB/Q2-3/Dipole | 120d | 2006-10-02 | 2007-03-30 | 9-070M | 105d |
| 122312050 |  | Prepare reference design Q2-3/Dipole | 206d | 2006-10-02 | 2007-08-01 | 9-070M | 57d |
| 122312060 |  | Optimize Coil Design for HB Magnet (HB) | 84d | 2006-10-02 | 2007-02-07 | 9-070M | 251d |
| 122312035 |  | Design LN2 shield HB/Q2-3/Dipole | 59d | 2007-03-30 | 2007-06-21 | 122312030 FS-40d | 105d |
| 122312030 |  | Design helium vessel (HB/Q2-3/Dipole) | 39d | 2007-04-02 | 2007-05-24 | 122312015 | 105d |
| 122312050M |  | Reference design completed Q2-3/Dipole | 0d | 2007-08-01 | 2007-08-01 | 122312050, 1141015, 1141020 | 57d |
| 122312045 |  | P-1 Dsgn Mag Supprt & Stand Q2-3/Dipole | 29d | 2007-08-02 | 2007-09-12 | 122312035 FS-20d, 122312050M | 57d |
| 122312045b |  | P-2 Dsgn Mag Supprt & Stand Q2-3/Dipole | 43d | 2007-09-13 | 2007-11-12 | 122312045 | 57d |
| 122312062M |  | Start Bid Process Q2-3/Dipole | 0d | 2007-10-01 | 2007-10-01 | 1141010, 1141015, 9-080M, 1141020, 122312060 | 88d |
| 122312074 |  | Dsgn Cryostat for Horiz Bender (HB) | 60d | 2007-10-01 | 2008-01-03 | 9-080M | 366d |
| 122312076 |  | Dsgn quench Detection Sys for Horiz Bender (HB) | 39d | 2007-10-01 | 2007-11-26 | 9-080M | 387d |
| 122312078 |  | Dsgn Supprt & Stand for Horiz Bender (HB) | 60d | 2007-10-01 | 2008-01-03 | 9-080M | 366d |
| 122312079 |  | CR 07-005 Procurements P-1 Dipole | 100d | 2007-10-01 | 2008-03-03 | 9-080M | 276d |
| 122312080 |  | Prepare Preliminary Dsgn for HB | 117d | 2007-10-01 | 2008-03-26 | 9-080M | 89d |
| 122312065 |  | Bid Process P-#1 Q2-3/Dipole | 140d | 2007-11-13 | 2008-06-11 | 122312045b, 122312062M | 57d |
| 122312084 |  | CR 07-005 Procurements P-2 Dipole | 100d | 2008-03-04 | 2008-07-23 | 122312079 | 276d |
| 122312080a |  | Prepare Reference Dsgn for HB | 139d | 2008-05-01 | 2008-11-14 | 9-080M FS+142d | 145d |
| 122312070 |  | Determine Best Offer P-#2 Q2-3/Dipole | 60d | 2008-06-12 | 2008-09-05 | 1141011, 122312065 | 57d |
| 122312080M |  | Reference Dsgn for Horiz Bender Comptd (HB) | 0d | 2008-11-14 | 2008-11-14 | 122312080a, 122312076, 122312080 | 145d |
| 122312090 |  | Bid Process for Horiz Bender P-#1 (HB) | 50d | 2008-11-17 | 2009-02-05 | 122312078, 122312074, 122312080M | 145d |
| 14315050x |  | Design Cryo Reservoirs for All Mag | 80d | 2008-12-01 | 2009-04-01 | 9-090M FS+41d | 346d |
| 14315055x |  | Design Iron Yoke for Q2/3 and Dipole | 60d | 2008-12-01 | 2009-03-04 | 9-090M FS+41d | 692d |
| 122312095 |  | Determine Best Offer for Horiz Bender P-#2 (HB) | 20d | 2009-02-06 | 2009-03-06 | 122312090, 1141012, 122312084 | 145d |
| 122312100 |  | Re-Baseline Actuals Adjustment | 1d | 2013-08-30 | 2013-08-30 | 9-130M FS+227d | 20d |
|  | 2 | **1.2.2.3.2 DETECTOR** |  | 2007-01-04 | 2013-08-30 |  |  |
| 122321005 |  | P-1 Update and rescale existing drawings (WIRE CHAMB) | 187d | 2007-01-04 | 2007-09-28 | 9-070M FS+60d | 248d |
| 122322005 |  | Update drawings for scintillator (HODO) | 130d | 2007-01-04 | 2007-07-10 | 9-070M FS+60d | 333d |
| 122325005 |  | Prepare drawings for final block arrangements (SHWR CNTR) | 60d | 2007-01-04 | 2007-03-30 | 9-070M FS+60d | 603d |
| 122322015 |  | P-1 Prep Drawings for Quartz hosdoscope (HODO) | 57d | 2007-05-14 | 2007-08-02 | 1142025, 9-070M, 122322005 FS-40d | 333d |
| 122323005 |  | P-1 Update existing drawings for Cerenkov (HIPRESS CRNKV) | 73d | 2007-06-18 | 2007-09-28 | 9-070M FS+174d | 275d |
| 12232015 |  | P-2 Update & Rescale Existing Drawings (Wire CHAMB)+ | 228d | 2008-10-01 | 2009-09-01 | 122321005, 9-090M | 0d |
| 122322015b |  | P-2 Prep Drawings for Quartz Hodoscope (HODO)+ | 203d | 2008-10-01 | 2009-07-28 | 9-090M, 122322015 | 45d |
| 122323005b |  | P-2 Update Existing Drawings for Cerenkov (HIPRESS CRNKV) | 11d | 2008-10-01 | 2008-10-15 | 122323005, 9-090M | 27d |
| 122325015 |  | Prep Drawings for PM & Cable Arrangement (SHWR CNTR) | 129d | 2008-10-20 | 2009-04-30 | 9-090M FS+13d | 1d |
| 122324005 |  | P-1 Prepare drawings for heavy gas Cerenkove (LOPRESS CRNKV) | 52d | 2009-01-05 | 2009-03-19 | 1142020, 9-090M FS+60d | 65d |
| 122323015 |  | Update Existing Drawers for Cerenkov (HIPRESS CRNKV)+ | 130d | 2009-02-19 | 2009-08-21 | 122323005b FS+80d | 27d |
| 122324005b |  | P-2 Prep Drawings for Heavy Gas Cerenkove (LOPRESS CRNKV) | 11d | 2009-03-20 | 2009-04-03 | 122324005 | 65d |
| 122324015 |  | Prep Drawings for Heavy Gas Cerenkove (LOPRESS CRNKV)+ | 60d | 2009-04-06 | 2009-06-29 | 122324005b | 65d |
| 122325020 |  | Dsgn Detector Frame (SHWR CNTR)++ | 105d | 2009-05-01 | 2009-09-29 | 122325015 | 1d |
| 12232020 |  | P-3 Update & Rescale Existing Drawings (Wire CHAMB) + | 20d | 2009-09-02 | 2009-09-30 | 122325005, 12232015 | 0d |
| 122325025 |  | Re-Baseline Actuals Adjustment | 1d | 2013-08-30 | 2013-08-30 | 9-130M FS+227d | 20d |
|  | 1 | **1.2.2.3.2.1 WIRE CHAMBERS** |  |  |  |  |  |
|  | 2 | **1.2.2.3.2.2 HODOSCOPES** |  |  |  |  |  |
|  | 3 | **1.2.2.3.2.3 HIGH PRESSURE CERENKOV (Atm.Press.Cerenkov)** |  |  |  |  |  |
|  | 4 | **1.2.2.3.2.4 LOW PRESSURE CERENKOV (Heavy Gas Cerenkov))** |  |  |  |  |  |
|  | 5 | **1.2.2.3.2.5 SHOWER COUNTER** |  |  |  |  |  |
|  | 6 | **1.2.2.3.2.6 AEROGEL CERENKOV** |  |  |  |  |  |
|  | 7 | **1.2.2.3.2.7 TRD** |  |  |  |  |  |
|  | 8 | **1.2.2.3.2.8 DETECTOR FRAME** |  |  |  |  |  |
|  | 3 | **1.2.2.3.3 COMPUTING** |  |  |  |  |  |
|  | 1 | **1.2.2.3.3.1 DAQ** |  |  |  |  |  |
|  | 2 | **1.2.2.3.3.2 SLOW CONTROLS** |  |  |  |  |  |
|  | 4 | **1.2.2.3.4 ELECTRONICS** |  |  |  |  |  |
|  | 1 | **1.2.2.3.4.1 FAST ELECTRONICS** |  |  |  |  |  |
|  | 2 | **1.2.2.3.4.2 POWER SUPPLIES & PROBES** |  |  |  |  |  |
|  | 5 | **1.2.2.3.5 BEAMLINE** |  |  |  |  |  |
|  | 1 | **1.2.2.3.5.1 MOELLER** |  |  |  |  |  |
|  | 2 | **1.2.2.3.5.2 COMPTON** |  |  |  |  |  |
|  | 3 | **1.2.2.3.5.3 MAPPING** |  |  |  |  |  |
|  | 4 | **1.2.2.3.5.4 SCATTERING CHAMBER** |  |  |  |  |  |
|  | 5 | **1.2.2.3.5.5 BEAM PIPE & STANDS** |  |  |  |  |  |
|  | 6 | **1.2.2.3.5.6 MAGNET POWER SUPPLY** |  |  |  |  |  |
|  | 6 | **1.2.2.3.6 INFRASTRUCTURE** |  | 2006-10-02 | 2013-08-30 |  |  |
| 122362010 |  | Hire subcontructor to prepare preliminmary design (SUP STRUCT) | 89d | 2006-10-02 | 2007-02-14 | 9-070M | 154d |
| 122363010 |  | Prepare preliminary drawings (SHLD HOUSE) | 82d | 2006-10-02 | 2007-02-05 | 9-070M | 160d |
| 122363015 |  | Approve preliminary design (SHLD HOUSE) | 5d | 2007-02-06 | 2007-02-12 | 122363010 | 160d |
| 122362015 |  | Approve preliminary design (SUP STRUCT) | 5d | 2007-02-15 | 2007-02-22 | 122362010 | 154d |
| 122361010 |  | P-1 Dsgn Vac Sys (ENG&DES)+ | 117d | 2007-04-16 | 2007-09-28 | 9-070M FS+130d | 386d |

| ID | WBS | Task | Duration | Start | Finish | Predecessors | Total float | Constraint |
| --- | --- | --- | --- | --- | --- | --- | --- | --- |
| 122361015 |  | P-1 Dsgn Cryogenic Sys (ENG&DES)+ | 117d | 2007-04-16 | 2007-09-28 | 9-070M FS+130d | 486d |  |
| 122362020 |  | Produce detailed design and drawings (SUP STRUCT) | 110d | 2007-10-01 | 2008-03-17 | 9-080M, 122362015 | 1d |  |
| 122363020 |  | Prepare detailed design and drawings (SHLD HOUSE) | 120d | 2007-10-01 | 2008-03-31 | 122363015, 9-080M | 0d |  |
| 12236030 |  | PROC Continue Reference Dsgn & Drawings (SUP STRUCT) | 240d | 2008-03-18 | 2009-03-05 | 122362020 | 1d |  |
| 12236030a |  | FY08 Exp Continue Reference Dsgn & Drawings (SUP STRUCT) | 138d | 2008-03-18 | 2008-09-30 | 122362020 | 1d |  |
| 12236045 |  | PROC Continue Reference Dsgn & Drawings (SHLD HOUSE) | 240d | 2008-04-01 | 2009-03-19 | 122363020 | 0d |  |
| 12236045a |  | FY08 Exp Continue Reference Dsgn & Drawings (SHLD HOUSE) | 128d | 2008-04-01 | 2008-09-30 | 122363020 | 0d |  |
| 12236010b |  | P-2 Dsgn Vac Sys (ENG&DES)+ | 10d | 2008-10-01 | 2008-10-14 | 122361010, 9-090M | 138d |  |
| 12236015b |  | P-2 Dsgn Cryogenic Sys (ENG&DES)+ | 10d | 2008-10-01 | 2008-10-14 | 9-090M, 122361015 | 238d |  |
| 12236020 |  | Dsgn Scattering Chamb (ENG&DES)+ | 20d | 2008-10-01 | 2008-10-28 | 9-090M | 128d |  |
| 12236025 |  | Dsgn Beam Pipe & Stands (ENG&DES)+ | 60d | 2008-10-01 | 2009-01-02 | 9-090M | 88d |  |
| 12236030b |  | FY09 Exp Continue Reference Dsgn & Drawings (SUP STRUCT) | 102d | 2008-10-01 | 2009-03-05 | 12236030a | 1d |  |
| 12236045b |  | FY09 Exp Continue Reference Dsgn & Drawings (SHLD HOUSE) | 112d | 2008-10-01 | 2009-03-19 | 12236045a | 0d |  |
| 12236830LOE |  | FY09 Coordinate All SHMS Compnts with Supprt Struct (ENG&DES)+ | 189d | 2008-10-01 | 2009-07-08 | 9-090M | 59d |  |
| 12236035 |  | Prep Bid Packages (SUP STRUCT) | 80d | 2009-03-06 | 2009-06-26 | 12236030b, 12236030 | 1d |  |
| 12236050 |  | Prep Bid Packages (SHLD HOUSE) | 80d | 2009-03-20 | 2009-07-13 | 12236045b, 12236045 | 0d |  |
| 12236035M |  | Start Bid Process (SUP STRUCT) | 0d | 2009-06-29 | 2009-06-29 | 12236035 | 1d |  |
| 12236040 |  | Determine Best Offer (SUP STRUCT)+ | 65d | 2009-06-29 | 2009-09-29 | 12236035M | 1d |  |
| 12236055M |  | Start Bid Process (SHLD HOUSE) | 0d | 2009-07-14 | 2009-07-14 | 12236050 | 0d |  |
| 12236060 |  | Determine Best Offer (SHLD HOUSE)+ | 56d | 2009-07-14 | 2009-09-30 | 12236055M | 0d |  |
| 122363025 |  | Re-Baseline Actuals Adjustment | 1d | 2013-08-30 | 2013-08-30 | 9-130M FS+227d | 20d |  |
|  | 1 | **1.2.2.3.6.1 ENGINEERING & DESIGN** |  |  |  |  |  |  |
|  | 2 | **1.2.2.3.6.2 SUPPORT STRUCTURE** |  |  |  |  |  |  |
|  | 3 | **1.2.2.3.6.3 SHIELD HOUSE** |  |  |  |  |  |  |
|  | 4 | **1.2.2.3.6.4 CRYOGENIC SYSTEM** |  |  |  |  |  |  |
|  | 5 | **1.2.2.3.6.5 VACUUM SYSTEM** |  |  |  |  |  |  |
|  | 6 | **1.2.2.3.6.6 CABLING** |  |  |  |  |  |  |
|  | 7 | **1.2.2.3.6.7 SOS PIVOT MODIFICATION** |  |  |  |  |  |  |
|  | 8 | **1.2.2.3.6.8 INSTALLATION** |  |  |  |  |  |  |
|  | 3 | **1.2.3 HALL D** |  | 2006-10-02 | 2013-08-30 |  |  |  |
|  | 1 | **1.2.3.1 SOLENOID** |  | 2008-10-01 | 2013-08-30 |  |  |  |
| 151009E5 |  | FY09 Travel (SOLENOID) | 59d | 2008-10-01 | 2008-12-24 | 9-090M | 431d |  |
| 1231000 |  | Re-Baseline Actuals Adjustment | 1d | 2013-08-30 | 2013-08-30 | 9-130M FS+227d | 20d |  |
|  | 2 | **1.2.3.2 DETECTORS** |  | 2006-10-02 | 2013-08-30 |  |  |  |
| 123211010 |  | Fall Progress updates including safety assessment at Hall D collaboration meeting | 10d | 2006-11-15 | 2006-11-30 | 9-070M FS+32d | 568d |  |
| 123211010M |  | Fall Design updates based on collaboration assessment | 0d | 2006-12-15 | 2006-12-15 | 123211010 FS+11d | 568d |  |
| 123211020 |  | Spring Progress updates including safety assessment at Hall D collaboration meeting | 10d | 2007-04-30 | 2007-05-11 | 123211010M FS+87d | 568d |  |
| 123211020M |  | Spring Safety Design Report updates based on collaboration assessment | 0d | 2007-05-15 | 2007-05-15 | 123211020 FS+2d | 568d |  |
|  | 1 | **1.2.3.2.1 TRACKING** |  | 2006-10-02 | 2013-08-30 |  |  |  |
| 123211015 |  | Interim Design and Safety Assessment of drift chambers | 10d | 2007-03-15 | 2007-03-28 | 9-070M FS+108d, 1152005 FS-100d | 454d |  |
| 123211015M |  | Interim Drift chamber design requirements updated | 0d | 2007-04-16 | 2007-04-16 | 123211015 FS+13d | 454d |  |
| 12321017 |  | Final Dsgn & Safty Assessmnt of Drift Chambs | 10d | 2008-09-16 | 2008-09-29 | 123211020M, 123213010, 123212035, 123211055 | 236d |  |
| 12321018M |  | Drift Chamb Dsgn Rquirmnts Finalized++ | 0d | 2008-10-16 | 2008-10-16 | 12321017 FS+13d | 236d |  |
|  | 1 | **1.2.3.2.1.1 FORWARD CHAMBERS** |  | 2006-10-02 | 2013-08-30 |  |  |  |
| 123211005 |  | Develop FDC design (FWD CHAMB) | 79d | 2006-10-02 | 2007-02-01 | 9-070M | 339d |  |
| 12321105A |  | Develop FDC design (FWD CHAMB) | 167d | 2007-02-02 | 2007-09-28 | 123211005 | 338d | start on or after 2007-02-02 |
| 123211025 |  | Specify All FDC Chamb Matrl's | 45d | 2007-10-01 | 2007-12-04 | 123211015M, 12321105A | 338d |  |
| 123211030 |  | Detail FDC Final Procedure for Chamb Wire Stringing, Constrctn, & Assy | 45d | 2007-10-01 | 2007-12-04 | 12321105A | 338d |  |
| 123211035 |  | Comp FDC Layout & Dsgn of on-board Electrnc's | 45d | 2007-10-01 | 2007-12-04 | 12321105A | 338d |  |
| 123211040 |  | Dsgn FDC Gas Handling Sys | 45d | 2007-10-01 | 2007-12-04 | 12321105A | 338d |  |
| 123211045 |  | Finalize FDC Cable Spec's, Connectors, Routing, & Packing Decisions | 45d | 2007-10-01 | 2007-12-04 | 12321105A | 338d |  |
| 123211050 |  | Comp Final FDC Drawings | 45d | 2007-12-05 | 2008-02-15 | 123211025, 123211030, 123211040, 123211035, 123211045 | 338d |  |
| 123211055 |  | Detail FDC Final Procedures for Component Quality Control & Acceptance | 45d | 2008-02-19 | 2008-04-21 | 123211050 | 338d |  |
| 15211009EX |  | FY09 Travel (FWD Chambers) | 59d | 2008-10-01 | 2008-12-24 | 9-090M | 64d |  |
| 123211060 |  | Re-Baseline Actuals Adjustment | 1d | 2013-08-30 | 2013-08-30 | 9-130M FS+227d | 20d |  |
|  | 2 | **1.2.3.2.1.2 CENTRAL CHAMBERS** |  | 2006-10-02 | 2013-08-30 |  |  |  |
| 123212005 |  | Develop Preamp design (CENT CHAMB) | 80d | 2006-10-02 | 2007-02-01 | 9-070M | 245d |  |
| 123212005A |  | Develop Preamp design (CENT CHAMB) | 225d | 2007-02-02 | 2007-12-21 | 123212005 | 245d |  |
| 123212008 |  | Preamp Dsgn | 80d | 2008-01-02 | 2008-04-24 | 123212005A | 245d |  |
| 123212010 |  | Specify CDC Chamb Matrl's | 80d | 2008-01-02 | 2008-04-24 | 123212005A | 245d |  |
| 123212015 |  | Detail CDC Final Procedure for Chamb Tube Mounting,/Wire Stringing,/Constrctn/Assy | 80d | 2008-01-02 | 2008-04-24 | 123212005A | 245d |  |
| 123212020 |  | Dsgn CDC Gas Handling Sys | 80d | 2008-01-02 | 2008-04-24 | 123212005A | 245d |  |
| 123212025 |  | Finalize CDC Cable Spec's, Connectors, Routing & Packing | 80d | 2008-01-02 | 2008-04-24 | 123212005A | 245d |  |
| 123212030 |  | Comp CDC Final Drawings | 80d | 2008-05-08 | 2008-08-29 | 123212008, 123212015, 123212020, 1152035 FS-100d, 1152030 FS-100d, 123212010, 123212025 | 236d |  |
| 123212035 |  | Detail CDC Final Procedures for Component Quality Control & Acceptance | 40d | 2008-07-21 | 2008-09-15 | 123212030 FS-30d | 236d |  |
| 15212009EX |  | FY09 Travel (CENT CHAMB) | 59d | 2008-10-01 | 2008-12-24 | 9-090M | 119d |  |
| 123212040 |  | Re-Baseline Actuals Adjustment | 1d | 2013-08-30 | 2013-08-30 | 9-130M FS+227d | 20d |  |
|  | 3 | **1.2.3.2.1.3 START COUNTER** |  | 2006-10-02 | 2013-08-30 |  |  |  |
| 123213005LOE |  | Start counter design (START CNTR) | 247d | 2006-10-02 | 2007-09-28 | 9-070M | 373d |  |
| 123213010 |  | Evaluate H-B Start Counter Use in H-D 08 | 100d | 2007-10-01 | 2008-03-03 | 123213005LOE | 373d |  |

| ID | WBS | Task | Duration | Start | Finish | Predecessors | Total float | Constraint |
| --- | --- | --- | --- | --- | --- | --- | --- | --- |
| 123213015 |  | Re-Baseline Actuals Adjustment | 1d | 2013-08-30 | 2013-08-30 | 9-130M FS+227d | 20d |  |
|  | 2 | **1.2.3.2.2 CALORIMETRY** |  | 2006-10-02 | 2013-08-30 |  |  |  |
| 12322017 |  | Final Dsgn & Safty Assessmnt of Calorimeters | 10d | 2008-08-01 | 2008-08-14 | 123221804bLOE, 123223010, 123223015, 123222025, 123221025, 123223020, 123222020 FS+20d, 123222030 | 267d |  |
| 12322018M |  | Calorimeter Dsgn Rquirmnts Finalized++ | 0d | 2008-09-03 | 2008-09-03 | 12322017 FS+13d | 267d |  |
|  | 1 | **1.2.3.2.2.1 BARREL CALORIMETER** |  | 2006-10-02 | 2013-08-30 |  |  |  |
| 123221002 |  | Develop BCAL design (BCAL) | 80d | 2006-10-02 | 2007-02-01 | 9-070M | 47d |  |
| 123221004LOE |  | FY07 BCAL postdoc for design (BCAL) | 1d | 2006-10-02 | 2006-10-02 | 9-070M | 709d |  |
| 123221007LOE |  | FY07 Hall D project administration (BCAL) | 79d | 2006-10-02 | 2007-02-01 | 9-070M | 59d |  |
| 123221000 |  | Assessment of SiPM progress toward use with BCAL | 20d | 2007-01-02 | 2007-01-30 | 9-070M FS+58d | 494d |  |
| 123221908LOE |  | FY08 H-D Proj Admin (BCAL) | 248d | 2007-02-01 | 2008-02-04 | 123221007LOE | 126d |  |
| 123221002A |  | Develop BCAL design (BCAL) | 167d | 2007-02-02 | 2007-09-28 | 123221002 | 47d |  |
| 123221007ALOE |  | FY07 Hall D project administration (BCAL) | 167d | 2007-02-02 | 2007-09-28 | 123221007LOE | 58d | start on or after 2007-02-02 |
| 123221000M |  | Decision on readout for BCAL | 0d | 2007-03-01 | 2007-03-01 | 123221000 FS+21d | 494d |  |
| 123221004 |  | FY07 BCAL postdoc for design (BCAL) | 117d | 2007-04-16 | 2007-09-28 | 123221000M, 9-070M FS+130d | 463d |  |
| 123221020 |  | Drawings of Supprt in Solenoid (BCAL) | 110d | 2007-10-01 | 2008-03-17 | 123221002A | 47d |  |
| 123221804bLOE |  | FY08 BCAL postdoc for Dsgn (BCAL) | 10d | 2007-10-02 | 2007-10-15 | 1152015LOEA, 9-080M, 123221004LOE, 1152010A, 123221004 | 462d |  |
| 123221025 |  | Assy Drawings (BCAL) | 91d | 2008-03-25 | 2008-07-31 | 1152040, 123221020 | 42d |  |
| 15221009EX |  | FY09 Travel (BarCal) | 59d | 2008-10-01 | 2008-12-24 | 9-090M | 496d |  |
| 123221030 |  | Re-Baseline Actuals Adjustment | 1d | 2013-08-30 | 2013-08-30 | 9-130M FS+227d | 20d |  |
|  | 2 | **1.2.3.2.2.2 FORWARD CALORIMETER** |  | 2006-10-02 | 2013-08-30 |  |  |  |
| 123222005 |  | Develop FCAL modifications for use in Hall D (FCAL) | 247d | 2006-10-02 | 2007-09-28 | 9-070M | 283d |  |
| 123222010 |  | Drawings of Glass Supprt to circular geometry (FCAL) | 60d | 2007-10-01 | 2008-01-03 | 123222005, 1152025A | 353d |  |
| 123222015 |  | Drawings of Cellular Wall (FCAL) | 130d | 2007-10-01 | 2008-04-14 | 123222005 | 283d |  |
| 123222025 |  | Drawings for attaching PMTs to Glass (FCAL) | 75d | 2007-10-01 | 2008-01-25 | 123222005 | 398d |  |
| 123222030 |  | Drawings for Light Guides (FCAL) | 75d | 2007-10-01 | 2008-01-25 | 123222005 | 398d |  |
| 123222020 |  | Assy Plans for stacking Glass (FCAL) | 40d | 2008-04-15 | 2008-06-10 | 123222010, 123222015, 123222005 | 283d |  |
| 15222009EX |  | FY09 Travel (FWD CAL) | 59d | 2008-10-01 | 2008-12-24 | 9-090M | 317d |  |
| 123222035 |  | Re-Baseline Actuals Adjustment | 1d | 2013-08-30 | 2013-08-30 | 9-130M FS+227d | 20d |  |
|  | 3 | **1.2.3.2.2.3 UPSTREAM PHOTON VETO** |  | 2006-10-02 | 2008-07-09 |  |  |  |
| 123223005LOE |  | Develop Upstream Photon Veto Design (CAL TOF) | 80d | 2006-10-02 | 2007-02-01 | 9-070M | 283d |  |
| 123223005ALOE |  | Develop Upstream Photon Veto Design (CAL TOF) | 167d | 2007-02-02 | 2007-09-28 | 123223005LOE | 283d |  |
| 123223010 |  | Drawings for UPV Frame (CAL TOF) | 60d | 2007-10-01 | 2008-01-03 | 123223005ALOE, 1152020 | 353d |  |
| 123223015 |  | Drawings for individual Compnts (CAL TOF) | 130d | 2007-10-01 | 2008-04-14 | 123223005ALOE | 283d |  |
| 123223020 |  | Dsgn Supprt Frame & method for maintenance (CAL TOF) | 60d | 2008-04-15 | 2008-07-09 | 123223010, 123223015 | 283d |  |
|  | 3 | **1.2.3.2.3 PARTICLE ID** |  | 2006-10-02 | 2013-08-30 |  |  |  |
| 12323039 |  | Final Dsgn & Safty Assessmnt of Particle ID | 10d | 2009-06-04 | 2009-06-17 | 123232010, 123231030, 123232035, 123232015, 123232025, 123232030, 123232020 | 73d |  |
| 12323040M |  | Particle ID Dsgn Rquirmnts Finalized++ | 0d | 2009-06-17 | 2009-06-17 | 12323039 | 73d |  |
|  | 1 | **1.2.3.2.3.1 TIME OF FLIGHT** |  | 2006-10-02 | 2008-09-16 |  |  |  |
| 123231005LOE |  | Develop TOF integration (PART ID TOF) | 80d | 2006-10-02 | 2007-02-01 | 9-070M | 248d |  |
| 123231005ALOE |  | Develop TOF integration (PART ID TOF) | 167d | 2007-02-02 | 2007-09-28 | 123231005LOE | 248d |  |
| 123231010 |  | Drawings of Scintillator Counters (PART ID TOF) | 45d | 2007-10-01 | 2007-12-04 | 123231005ALOE | 248d |  |
| 123231015 |  | Drawings of PMT Housing Assy (PART ID TOF) | 45d | 2007-12-05 | 2008-02-15 | 123231010 | 248d |  |
| 123231020 |  | Dsgn Voltage Divider for PMT (PART ID TOF) | 45d | 2008-02-19 | 2008-04-21 | 123231015 | 248d |  |
| 123231025 |  | Dsgn Signal Splitting Between ADC & Discriminator/TDC (PART ID TOF) | 44d | 2008-04-22 | 2008-06-23 | 123231020 | 248d |  |
| 123231030 |  | Dsgn Mounting Frame for Counters (PART ID TOF) | 59d | 2008-06-24 | 2008-09-16 | 123231025 | 248d |  |
|  | 2 | **1.2.3.2.3.2 CERENKOV COUNTER** |  | 2006-10-02 | 2013-08-30 |  |  |  |
| 123232005 |  | Develop CER design (CERENKOV CNTR) | 80d | 2006-10-02 | 2007-02-01 | 9-070M | 261d |  |
| 123232005A |  | Develop CER design (CERENKOV CNTR) | 167d | 2007-02-02 | 2007-09-28 | 123232005 | 261d |  |
| 123232015 |  | Comp Drawings for Mirrors & Fab (CERENKOV CNTR) | 65d | 2009-01-05 | 2009-04-07 | 9-090M FS+60d, 123232005A | 113d |  |
| 123232025 |  | Develop Matrl Spec's for Gas Windows (CERENKOV CNTR) | 20d | 2009-01-05 | 2009-02-02 | 123232005A, 9-090M FS+60d | 158d |  |
| 123232030 |  | Dsgn Supprt Frame for Cerenkov Detector (CERENKOV CNTR) | 65d | 2009-01-05 | 2009-04-07 | 9-090M FS+60d, 123232005A | 113d |  |
| 123232035 |  | Dsgn Alignment Procedure for Mirrors (CERENKOV CNTR) | 65d | 2009-01-05 | 2009-04-07 | 123232005A, 9-090M FS+60d | 113d |  |
| 123232010 |  | Comp Spec's for Mirrors (CERENKOV CNTR) | 45d | 2009-04-01 | 2009-06-03 | 1152025A, 9-090M FS+120d, 123232005A | 73d |  |
| 123232020 |  | Drawings for PMT Assy (CERENKOV CNTR) | 45d | 2009-04-01 | 2009-06-03 | 123232005A FS+180d, 9-090M FS+120d | 73d |  |
| 123232040 |  | Re-Baseline Actuals Adjustment | 1d | 2013-08-30 | 2013-08-30 | 9-130M FS+227d | 20d |  |
|  | 3 | **1.2.3.3 COMPUTING** |  | 2006-10-02 | 2013-08-30 |  |  |  |
| 1233039 |  | Final Dsgn & Safty Assessmnt of Computing | 10d | 2009-03-20 | 2009-04-02 | 12333020, 12332015, 12331010, 12333015a, 12332025a | 126d |  |
| 1233040M |  | Computing Dsgn Rquirmnts Finalized++ | 0d | 2009-04-02 | 2009-04-02 | 1233039 | 126d |  |
|  | 1 | **1.2.3.3.1 DAQ** |  | 2006-10-02 | 2013-08-30 |  |  |  |
| 12331005 |  | Procure architechture and high speed links (DAQ) | 247d | 2006-10-02 | 2007-09-28 | 9-070M | 246d |  |
| 12331010 |  | Proto parallel Event builder (DAQ) (IPL) | 130d | 2008-03-18 | 2008-09-18 | 12331005 FS+110d | 246d |  |
| 12331015 |  | Re-Baseline Actuals Adjustment | 1d | 2013-08-30 | 2013-08-30 | 9-130M FS+227d | 20d |  |
|  | 2 | **1.2.3.3.2 ONLINE COMPUTING** |  | 2006-10-02 | 2013-08-30 |  |  |  |
| 12332005LOE |  | Conduct planning for online system (ONLINE COMP) | 80d | 2006-10-02 | 2007-02-01 | 9-070M | 186d |  |
| 12332005ALOE |  | Conduct planning for online system (ONLINE COMP) | 167d | 2007-02-02 | 2007-09-28 | 12332005LOE | 186d |  |
| 12332020 |  | Dsgn Experiment Controls Sys (ONLINE COMP) | 170d | 2008-01-04 | 2008-09-04 | 9-080M FS+60d, 12332005ALOE | 126d |  |
| 12332010 |  | Dsgn Monitoring Sys (ONLINE COMP) | 65d | 2008-04-01 | 2008-07-01 | 9-080M FS+120d, 12332005ALOE | 251d |  |
| 12332015 |  | Dsgn Alarm Sys (ONLINE COMP) | 50d | 2008-07-02 | 2008-09-11 | 12332010 | 251d |  |
| 12332025 |  | FY08 Exp Dsgn Event Display (ONLINE COMP) | 18d | 2008-09-05 | 2008-09-30 | 12332020 | 126d |  |
| 12332025a |  | FY09 Exp Dsgn Event Display (ONLINE COMP) | 112d | 2008-10-01 | 2009-03-19 | 12332025 | 126d |  |

| ID | WBS | Task | Duration | Start | Finish | Predecessors | Total float | Constraint |
| --- | --- | --- | --- | --- | --- | --- | --- | --- |
| 12332030 |  | Re-Baseline Actuals Adjustment | 1d | 2013-08-30 | 2013-08-30 | 9-130M FS+227d | 20d |  |
|  | 3 | **1.2.3.3.3 OFFLINE COMPUTING** |  | 2006-10-02 | 2013-08-30 |  |  |  |
| 12333005LOE |  | Conduct planning for offline computing (OFFLINE COMP) | 80d | 2006-10-02 | 2007-02-01 | 9-070M | 155d |  |
| 12333005ALOE |  | Conduct planning for offline computing (OFFLINE COMP) | 167d | 2007-02-02 | 2007-09-28 | 12333005LOE | 155d |  |
| 12333010 |  | Dsgn Reconstruction Framework (OFFLINE COMP) | 130d | 2007-10-01 | 2008-04-14 | 12333005ALOE | 155d |  |
| 12333015 |  | FY08 Exp Dsgn Calibration Databases (OFFLINE COMP) | 47d | 2008-07-25 | 2008-09-30 | 12333010 FS+71d | 155d |  |
| 12333020 |  | Dsgn Interface Between Analysis Framework & Simulation (OFFLINE COMP) | 130d | 2008-07-25 | 2009-02-05 | 12333010 FS+71d | 155d |  |
| 12333015a |  | FY09 Exp Dsgn Calibration Databases (OFFLINE COMP) | 83d | 2008-10-01 | 2009-02-05 | 12333015 | 155d |  |
| 12333025 |  | Re-Baseline Actuals Adjustment | 1d | 2013-08-30 | 2013-08-30 | 9-130M FS+227d | 20d |  |
|  | 4 | **1.2.3.4 ELECTRONICS** |  | 2006-10-02 | 2013-08-30 |  |  |  |
| 12341005 |  | Conduct FADC development (FADC) | 79d | 2006-10-02 | 2007-02-01 | 9-070M | 114d |  |
| 12342005 |  | Develop DAQ trigger and electronics integration (TDC) | 79d | 2006-10-02 | 2007-02-01 | 9-070M | 199d |  |
| 12342010 |  | Develop clock distribution and synchronization (TDC) (IPL) | 79d | 2006-10-02 | 2007-02-01 | 9-070M | 114d |  |
| 12343005 |  | Develop plans for trigger integration (TRGR) | 79d | 2006-10-02 | 2007-02-01 | 9-070M | 114d |  |
| 12345005 |  | Integrate electronics subsystems (HV) | 79d | 2006-10-02 | 2007-02-01 | 9-070M | 454d |  |
| 12341005A |  | Conduct FADC development (FADC) | 167d | 2007-02-01 | 2007-09-28 | 12341005 | 114d |  |
| 12342005A |  | Develop DAQ trigger and electronics integration (TDC) | 167d | 2007-02-01 | 2007-09-28 | 12342005 | 199d |  |
| 12342010A |  | Develop clock distribution and synchronization (TDC) | 167d | 2007-02-01 | 2007-09-28 | 12342010 | 114d |  |
| 12343005A |  | Develop plans for trigger integration (TRGR) | 167d | 2007-02-01 | 2007-09-28 | 12343005 | 114d |  |
| 12345005A |  | Integrate electronics subsystems (HV) | 167d | 2007-02-01 | 2007-09-28 | 12345005 | 454d |  |
| 1234050 |  | TDC Version II: Dsgn & Proto (Electrnc's) | 40d | 2007-10-01 | 2007-11-27 | 12342005A FS-85d, 12343005A, 12341005A, 12342010A, 1154005A | 113d |  |
| 1234055 |  | TDC Version II: Test, Evaluate (Electrnc's) | 40d | 2007-11-28 | 2008-02-01 | 1234050 | 113d |  |
| 1234060 |  | Dsgn Clock Distrbtn for TDC Sys (Electrnc's) | 60d | 2008-02-04 | 2008-04-28 | 1234055 | 113d |  |
| 1234065 |  | Dsgn Cabling & Layout for TDC Sys (Electrnc's) (IPL) | 30d | 2008-04-29 | 2008-06-10 | 1234060 | 113d |  |
| 1234070 |  | Dsgn Energy Sum collections into Trigger (Electrnc's) | 30d | 2008-06-11 | 2008-07-23 | 1234065 | 113d |  |
| 1234075 |  | Dsgn Track Count Collection into Trigger (Electrnc's) (IPL) | 30d | 2008-07-24 | 2008-09-04 | 1234070 | 113d |  |
| 1234090 |  | Dsgn Layout of Crates on Detector & Racks (Electrnc's) | 18d | 2008-09-05 | 2008-09-30 | 1234075 | 155d |  |
| 1234080 |  | PROC Dsgn Master Trigger (Electrnc's) | 130d | 2008-09-26 | 2009-04-09 | 1154040, 1234075 | 98d |  |
| 1234080a |  | FY08 Exp Dsgn Master Trigger (Electrnc's) | 3d | 2008-09-26 | 2008-09-30 | 1234075, 1154040 | 98d |  |
| 1234115 |  | FY08 Exp Specify Discriminators & Logic for DAQ/Trigger Integration (Electrnc's) | 3d | 2008-09-26 | 2008-09-30 | 1154060 | 208d |  |
| 1234030 |  | Dsgn Energy Sum Board (Electrnc's) (IPL) | 30d | 2008-10-01 | 2008-11-11 | 1154045, 9-090M | 85d |  |
| 1234080b |  | FY09 Exp Dsgn Master Trigger (Electrnc's) | 127d | 2008-10-01 | 2009-04-09 | 1234080a | 98d |  |
| 1234085 |  | Specification of Crates Backplane, Pwr Supply, remote sensing (Electrnc's) | 20d | 2008-10-01 | 2008-10-28 | 9-090M, 12345005A, 1154010A | 205d |  |
| 1234095 |  | Dsgn Grounding Scheme of Crates & Racks (Electrnc's) | 20d | 2008-10-01 | 2008-10-28 | 1234090 | 155d |  |
| 1234110 |  | Specify HV & Low Voltage Supplies (Electrnc's) | 10d | 2008-10-01 | 2008-10-14 | 9-090M, 1154055 | 215d |  |
| 1234115a |  | FY09 Exp Specify Discriminators & Logic for DAQ/Trigger Integration (Electrnc's) | 17d | 2008-10-01 | 2008-10-23 | 1154060, 1234115 | 208d |  |
| 1545009EX |  | FY09 Travel (LOGIC, HV) | 59d | 2008-10-01 | 2008-12-24 | 9-090M | 310d |  |
| 1234100 |  | Dsgn networking of Crates (Electrnc's) | 20d | 2008-10-29 | 2008-11-25 | 1234095 | 155d |  |
| 1234035 |  | Dsgn Crate Clock Distrbtn for FADCs (Electrnc's) | 40d | 2008-11-12 | 2009-01-16 | 1154050, 1234030 | 85d |  |
| 1234105 |  | Dsgn Global Signal Distrbtn Interface to FADCs & TDCs (Electrnc's) | 30d | 2008-11-26 | 2009-01-16 | 1234100 | 155d |  |
| 1234040 |  | Dsgn Cabling & Layout for FADCs (Electrnc's) | 30d | 2009-01-20 | 2009-03-03 | 1234035 | 85d |  |
| 1234045 |  | Programing of FADCs for Testing (Electrnc's) | 40d | 2009-03-04 | 2009-04-28 | 1234040 | 85d |  |
| 1234159 |  | Final Dsgn & Safty Assessmnt of Electrnc's | 10d | 2009-04-29 | 2009-05-12 | 1234075, 1234040, 1234110, 1234080b, 1234045, 1234105, 1234080, 1234085, 1234115a | 85d |  |
| 1234180M |  | Electrnc's Dsgn Rquirmnts Finalized++ | 0d | 2009-06-01 | 2009-06-01 | 1234159 FS+13d | 85d |  |
| 12345010 |  | Re-Baseline Actuals Adjustment | 1d | 2013-08-30 | 2013-08-30 | 9-130M FS+227d | 20d |  |
|  | 1 | **1.2.3.4.1 FADC** |  |  |  |  |  |  |
|  | 2 | **1.2.3.4.2 TDC** |  |  |  |  |  |  |
|  | 3 | **1.2.3.4.3 TRIGGER** |  |  |  |  |  |  |
|  | 4 | **1.2.3.4.4 CRATES** |  |  |  |  |  |  |
|  | 5 | **1.2.3.4.5 HV** |  |  |  |  |  |  |
|  | 5 | **1.2.3.5 BEAMLINE** |  | 2006-10-02 | 2013-08-30 |  |  |  |
|  | 1 | **1.2.3.5.1 TAGGER** |  | 2006-10-02 | 2013-08-30 |  |  |  |
| 12351054 |  | Final Dsgn & Safty Assessmnt of Tagger | 10d | 2009-03-20 | 2009-04-02 | 123511050, 123512050, 123511045, 123511050b | 113d |  |
| 12351055M |  | Tagger Dsgn Rquirmnts Finalized++ | 0d | 2009-04-21 | 2009-04-21 | 12351054 FS+13d | 113d |  |
|  | 1 | **1.2.3.5.1.1 TAGGING MAGNET** |  | 2006-10-02 | 2013-08-30 |  |  |  |
| 123511005 |  | Develop design and procurement strategies (TAGMAG) | 247d | 2006-10-02 | 2007-09-28 | 9-070M | 188d |  |
| 123511005LOE |  | Develop design and procurement strategies (TAGMAG) | 79d | 2006-10-02 | 2007-02-01 | 9-070M | 189d |  |
| 123511005ALOE |  | Develop design and procurement strategies (TAGMAG) | 167d | 2007-02-02 | 2007-09-28 | 123511005LOE | 188d | start on or after 2007-02-02 |
| 123511010 |  | Top Level Drawings of Quad, Two Dipoles & Vac Sys (TAG MAG) | 45d | 2007-04-11 | 2007-06-13 | 123511005 FS-120d, 123511005ALOE FS-120d | 188d |  |
| 123511015 |  | Vertical Section through a Dipole Showing how Poleshoes & Yoke (TAG MAG) | 45d | 2007-06-14 | 2007-08-16 | 123511010 | 188d |  |
| 123511020 |  | Top view of a Dipole Showing bolt locations (TAG MAG) | 45d | 2007-08-17 | 2007-10-19 | 123511015 | 188d |  |
| 123511025 |  | Individual Drawings for Poleshoes (TAG MAG) | 45d | 2007-10-22 | 2008-01-03 | 123511020 | 188d |  |
| 123511030 |  | Drawings Showing All Different Types of Brackets (TAG MAG) | 45d | 2008-01-04 | 2008-03-10 | 123511025 | 188d |  |
| 123511035 |  | Layout of Vac Chamb (TAG MAG) | 45d | 2008-03-11 | 2008-05-12 | 123511030 | 188d |  |
| 123511040 |  | Drawings of Top & Bottom Lids, & Back-Wall of Vac Chamb (TAG MAG) | 45d | 2008-05-13 | 2008-07-16 | 123511035 | 188d |  |
| 123511045 |  | Drawings Showing Assy & Dis-assy of Mag (TAG MAG) | 45d | 2008-07-17 | 2008-09-18 | 123511040 | 188d |  |
| 123511050 |  | PROC Production of Drawings for Strong Back Supprt for Dipole Magnets. (TAG MAG) | 45d | 2008-09-19 | 2008-11-20 | 123511045 | 188d |  |
| 123511050a |  | FY08 Exp Production of Drawings for Strong Back Supprt for Dipole Magnets. (TAG MAG) | 8d | 2008-09-19 | 2008-09-30 | 123511045 | 188d |  |
| 123511050b |  | FY09 Exp Production of Drawings for Strong Back Supprt for Dipole Magnets. (TAG MAG) | 37d | 2008-10-01 | 2008-11-20 | 123511050a | 188d |  |
| 123511055 |  | Re-Baseline Actuals Adjustment | 1d | 2013-08-30 | 2013-08-30 | 9-130M FS+227d | 20d |  |

| ID | WBS | Task | Duration | Start | Finish | Predecessors | Total float | Constraint |
| --- | --- | --- | --- | --- | --- | --- | --- | --- |
|  | 2 | **1.2.3.5.1.2 HODOSCOPE** |  | 2006-10-02 | 2009-03-19 |  |  |  |
| 123512005 |  | Develop design for the spectrometer hodoscope (HODO) | 80d | 2006-10-02 | 2007-02-01 | 9-070M | 113d |  |
| 123512005A |  | Develop design for the spectrometer hodoscope (HODO) | 167d | 2007-02-02 | 2007-09-28 | 123512005 | 113d |  |
| 123512010 |  | Dsgn Light Guides for Microscope (HODO) | 40d | 2007-10-01 | 2007-11-27 | 123512005A, 1155005A FS-60d | 113d |  |
| 123512015 |  | Dsgn Frame for Microscope (HODO) | 40d | 2007-11-28 | 2008-02-01 | 123512010 | 113d |  |
| 123512020 |  | Dsgn Frame for Fixed Array (HODO) | 40d | 2008-02-04 | 2008-03-31 | 123512015 | 113d |  |
| 123512025 |  | Dsgn Voltage Divider for Fixed Array PMT (HODO) | 40d | 2008-04-01 | 2008-05-27 | 123512020 | 113d |  |
| 123512030 |  | Dsgn Light Guides for Fixed Array (HODO) | 40d | 2008-05-28 | 2008-07-23 | 123512025 | 113d |  |
| 123512035 |  | Determine Assy Procedure for Fixed Array (HODO) | 40d | 2008-07-24 | 2008-09-18 | 123512030 | 113d |  |
| 123512040 |  | Dsgn Alignment for Microscope (HODO) | 40d | 2008-09-19 | 2008-11-13 | 123512035 | 113d |  |
| 123512045 |  | Dsgn Cable Layout for Microscope (HODO) | 40d | 2008-11-14 | 2009-01-21 | 123512040 | 113d |  |
| 123512050 |  | Dsgn Cable Layout for Fixed Array (HODO) | 40d | 2009-01-22 | 2009-03-19 | 123512045 | 113d |  |
|  | 2 | **1.2.3.5.2 TARGET** |  |  |  |  |  |  |
|  | 3 | **1.2.3.5.3 BEAMLINE COMPONENTS** |  | 2006-10-02 | 2013-08-30 |  |  |  |
| 12353005 |  | Develop design for active collimator (BL COMPONENTS) | 79d | 2006-10-02 | 2007-02-01 | 9-070M | 93d |  |
| 12353005A |  | Develop design for active collimator (BL COMPONENTS) | 268d | 2007-02-02 | 2008-03-04 | 12353005 | 92d | start on or after 2007-02-02 |
| 12353010 |  | Dsgn Active Collimator (BL Compnts) | 60d | 2007-09-04 | 2007-11-28 | 1155010A FS-60d, 12353005A FS-120d | 92d |  |
| 12353015 |  | Dsgn Photon Monitor (BL Compnts) | 60d | 2007-11-29 | 2008-03-04 | 12353010 | 92d |  |
| 12353020 |  | Dsgn Feedback Mechanism (BL Compnts) | 110d | 2008-03-05 | 2008-08-07 | 12353015 | 92d |  |
| 12353025 |  | FY08 Exp Dsgn Display of Beam Position (BL Compnts) | 97d | 2008-05-14 | 2008-09-30 | 12353020 FS-60d | 92d |  |
| 12353025a |  | FY09 Exp Dsgn Display of Beam Position (BL Compnts) | 13d | 2008-10-01 | 2008-10-17 | 12353025 | 92d |  |
| 12353030 |  | Dsgn BL Configuration (BL Compnts) | 60d | 2008-10-20 | 2009-01-22 | 12353025a | 92d |  |
| 12353035 |  | Integrate Goniometer into BL (BL Compnts) | 60d | 2009-01-23 | 2009-04-17 | 1155020, 12353030, 1155025 | 92d |  |
| 12353040 |  | Final Dsgn & Safty Assessmnt of Beam Line Compnts | 10d | 2009-04-20 | 2009-05-01 | 12353035 | 92d |  |
| 12353045M |  | Beam Line Components Dsgn Rquirmnts Finalized | 0d | 2009-05-20 | 2009-05-20 | 12353040 FS+13d | 92d |  |
| 12353050 |  | Re-Baseline Actuals Adjustment | 1d | 2013-08-30 | 2013-08-30 | 9-130M FS+227d | 20d |  |
|  | 6 | **1.2.3.6 INFRASTRUCTURE** |  | 2008-10-01 | 2013-08-30 |  |  |  |
|  | 1 | **1.2.3.6.1 ASSEMBLY** |  | 2008-10-01 | 2013-08-30 |  |  |  |
| 12361000M |  | Starting Milestone for FY09 (Assy) | 0d | 2008-10-01 | 2008-10-01 | 9-090M | 58d |  |
| 12361005 |  | Develop Alignment of DCs (Assy)+ | 90d | 2008-10-01 | 2009-02-17 | 12361000M | 158d |  |
| 12361010 |  | Develop Installtn of Bcal (Assy)+ | 90d | 2009-03-04 | 2009-07-09 | 12361000M FS+100d | 58d |  |
| 12361015 |  | Re-Baseline Actuals Adjustment | 1d | 2013-08-30 | 2013-08-30 | 9-130M FS+227d | 20d |  |
|  | 2 | **1.2.3.6.2 INSTALLATION** |  |  |  |  |  |  |
|  | 3 | **1.2.3.6.3 CRYOGENICS** |  |  |  |  |  |  |
|  | 4 | **1.2.4 CONVENTIONAL FACILITIES** |  | 2006-10-02 | 2013-08-30 |  |  |  |
|  | 1 | **1.2.4.1 ACCELERATOR** |  | 2006-10-02 | 2013-08-30 |  |  |  |
| 1241000M |  | Begin Design N&S Access Building Additions | 0d | 2006-10-02 | 2006-10-02 | 9-070M | 140d |  |
| 1241005 |  | Develop N&S Addition Preliminary Design (ACCEL) | 30d | 2006-10-02 | 2006-11-10 | 1241000M | 140d |  |
| 1241010 |  | Conduct N&S Addition Prelim Design & Safety Review | 20d | 2006-11-13 | 2006-12-12 | 1241005 | 140d |  |
| 1241080M |  | Begin Design Beam Switch Yard Addition (ACCEL) | 0d | 2006-11-13 | 2006-11-13 | 1241005 | 155d |  |
| 1241085 |  | Develop BSY Addition 35% Design (ACCEL) | 80d | 2006-11-13 | 2007-03-16 | 1241080M | 155d |  |
| 1241015 |  | Conduct N&S Addition Cost Validation (ACCEL) | 10d | 2006-12-13 | 2007-01-03 | 1241010 | 245d |  |
| 1241040M |  | Begin Design N&S Access Building Utilities (ACCEL) | 0d | 2006-12-13 | 2006-12-13 | 1241010, 1241000M | 140d |  |
| 1241045 |  | Develop N&S Utilities 35% Design (ACCEL) | 40d | 2006-12-13 | 2007-02-15 | 1241040M | 140d |  |
| 1241016M |  | N&S Access Building Preliminary Design Complete | 0d | 2007-01-03 | 2007-01-03 | 1241015 | 245d |  |
| 1241050 |  | Conduct N&S Utilities 35% Design & Safety Review | 40d | 2007-02-16 | 2007-04-13 | 1241045 | 155d |  |
| 1241120M |  | Begin Design Tunnel A/C (ACCEL) | 0d | 2007-02-16 | 2007-02-16 | 1241045 | 140d |  |
| 1241125 |  | Develop Tunnel A/C 35% Design (ACCEL) | 45d | 2007-02-16 | 2007-04-20 | 1241120M | 140d |  |
| 1241160M |  | Begin Design N&S Linac Power (ACCEL) | 0d | 2007-02-16 | 2007-02-16 | 1241045 | 165d |  |
| 1241165 |  | Develop N&S Linac 35% Design (ACCEL) | 30d | 2007-02-16 | 2007-03-30 | 1241160M | 165d |  |
| 1241090 |  | Conduct BSY Addition 35% Design & Safety Review | 20d | 2007-03-19 | 2007-04-13 | 1241085 | 155d |  |
| 1241170 |  | Conduct N&S Linac 35% Design & Safety Review | 10d | 2007-04-02 | 2007-04-13 | 1241165 | 165d |  |
| 1241055 |  | Conduct N&S Utilities Cost Validation (ACCEL) | 20d | 2007-04-16 | 2007-05-11 | 1241050 | 155d |  |
| 1241095 |  | Conduct BSY Addition Cost Validation (ACCEL) | 20d | 2007-04-16 | 2007-05-11 | 1241090 | 155d |  |
| 1241175 |  | Conduct N&S Linac Cost Validation (ACCEL) | 10d | 2007-04-16 | 2007-04-27 | 1241170 | 165d |  |
| 1241130 |  | Conduct Tunnel A/C 35% Design & Safety Review | 20d | 2007-04-23 | 2007-05-18 | 1241125 | 140d |  |
| 1241176M |  | N&S Linac Preliminary Design Complete | 0d | 2007-04-27 | 2007-04-27 | 1241175 | 165d |  |
| 1241056M |  | N&S Utilities Building Preliminary Design Complete | 0d | 2007-05-11 | 2007-05-11 | 1241055 | 155d |  |
| 1241096M |  | BSY Addition Preliminary Design Complete (ACCEL) | 0d | 2007-05-11 | 2007-05-11 | 1241095 | 155d |  |
| 1241135 |  | Conduct Tunnel A/C Cost Validation (ACCEL) | 10d | 2007-05-21 | 2007-06-04 | 1241130 | 140d |  |
| 1241136M |  | Tunnel A/C Preliminary Design Complete (ACCEL) | 0d | 2007-06-04 | 2007-06-04 | 1241135 | 140d |  |
| 1241020 |  | Develop N&S ADDITION 100% Dsgn (ACCEL) | 60d | 2007-10-01 | 2008-01-03 | 9-080M | 26d |  |
| 1241060 |  | Develop N&S UTILITIES 100% Dsgn (ACCEL) | 60d | 2007-10-01 | 2008-01-03 | 9-080M | 16d |  |
| 1241180 |  | Develop N&S LINAC 100% Dsgn (ACCEL) | 60d | 2007-11-28 | 2008-03-03 | 9-080M FS+40d | 26d |  |
| 1241025 |  | Conduct N&S ADDITION 100% Dsgn & Safty Review | 20d | 2008-01-04 | 2008-02-01 | 1241020 | 26d |  |
| 1241065 |  | Conduct N&S UTILITIES100% Dsgn & Safty Review | 20d | 2008-01-04 | 2008-02-01 | 1241060 | 116d |  |
| 1241140 |  | Develop TUNNEL A/C 100% Dsgn (ACCEL) | 60d | 2008-01-04 | 2008-03-31 | 9-080M, 1241060 | 16d |  |
| 1241030 |  | Develop N&S ADDITION Final Dsgn (ACCEL) | 20d | 2008-02-04 | 2008-03-03 | 1241025 | 106d |  |
| 1241070 |  | Develop N&S UTILITIES Final Dsgn (ACCEL) | 10d | 2008-02-04 | 2008-02-15 | 1241065 | 116d |  |
| 1241100 |  | Develop BSY ADDITION 100% Dsgn (ACCEL) | 60d | 2008-02-04 | 2008-04-28 | 1241025, 9-080M | 26d |  |

| ID | WBS | Task | Duration | Start | Finish | Predecessors | Total float |
| --- | --- | --- | --- | --- | --- | --- | --- |
| 1241075M |  | Comp Dsgn N&S UTILITIES (ACCEL)+ | 0d | 2008-02-15 | 2008-02-15 | 1241070 | 158d |
| 1241035M |  | Comp Dsgn N&S Access Bldng ADDITION+ | 0d | 2008-03-03 | 2008-03-03 | 1241030 | 396d |
| 1241185 |  | Conduct N&S LINAC 100% Dsgn & Safty Review | 40d | 2008-03-04 | 2008-04-28 | 1241180 | 26d |
| 1241145 |  | Conduct TUNNEL A/C 100% Dsgn & Safty Review | 40d | 2008-04-01 | 2008-05-27 | 1241140 | 16d |
| 1241105 |  | Conduct BSY ADDITION 100% Dsgn & Safty Review | 20d | 2008-04-29 | 2008-05-27 | 1241100 | 26d |
| 1241190 |  | Develop N&S LINAC Final Dsgn (ACCEL) | 40d | 2008-04-29 | 2008-06-24 | 1241185 | 26d |
| 1241110 |  | Develop BSY ADDITION Final Dsgn (ACCEL) | 20d | 2008-05-28 | 2008-06-24 | 1241105 | 26d |
| 1241150 |  | Develop TUNNEL A/C Final Dsgn (ACCEL) | 30d | 2008-05-28 | 2008-07-09 | 1241145 | 16d |
| 1241115M |  | Comp Dsgn Beam Switch Yard (BSY) ADDITION | 0d | 2008-06-24 | 2008-06-24 | 1241110 | 68d |
| 1241195M |  | Comp Dsgn N&S LINAC Pwr (ACCEL)++ | 0d | 2008-06-24 | 2008-06-24 | 1241190 | 68d |
| 1241155M |  | Comp Dsgn TUNNEL A/C (ACCEL)+ | 0d | 2008-07-09 | 2008-07-09 | 1241150 | 58d |
| 1241200 |  | Re-Baseline Actuals Adjustment | 1d | 2013-08-30 | 2013-08-30 | 9-130M FS+227d | 20d |
|  | 2 | **1.2.4.2 CHL** |  | 2006-10-02 | 2013-08-30 |  |  |
| 1242005M |  | Begin Design CHL Addition (CHL) | 0d | 2006-10-02 | 2006-10-02 | 9-070M | 313d |
| 1242010 |  | Develop CHL 60% Design (CHL) | 40d | 2006-10-02 | 2006-11-28 | 1242005M | 313d |
| 1242015 |  | Conduct CHL 60% Design & Safety Review | 15d | 2006-11-29 | 2006-12-19 | 1242010 | 313d |
| 1242015M |  | 60% Design CHL Complete | 0d | 2006-12-19 | 2006-12-19 | 1242015 | 313d |
| 1242020 |  | Develop CHL 100% Design (CHL) | 45d | 2006-12-20 | 2007-03-02 | 1242015M | 313d |
| 1242025 |  | Conduct CHL 100% Design & Safety Review | 20d | 2007-03-05 | 2007-03-30 | 1242020 | 313d |
| 1242025M |  | 100% Design CHL Complete | 0d | 2007-03-30 | 2007-03-30 | 1242025 | 313d |
| 1242030 |  | Develop CHL Final Design (CHL) | 10d | 2007-04-02 | 2007-04-13 | 1242025M | 313d |
| 1242035 |  | Conduct CHL Final Design & Safety Review | 10d | 2007-04-16 | 2007-04-27 | 1242030 | 313d |
| 1242040M |  | Complete Design CHL Addition (CHL) | 0d | 2007-04-27 | 2007-04-27 | 1242035 | 313d |
| 1621000MX |  | CHL Addition Begin Proc Prep | 0d | 2008-10-01 | 2008-10-01 | 9-090M | 72d |
| 1621005X |  | Prcrmnt Prep for CHL Addition to Award Contract | 59d | 2008-10-01 | 2008-12-24 | 1621000MX | 72d |
| 1242045 |  | Re-Baseline Actuals Adjustment | 1d | 2013-08-30 | 2013-08-30 | 9-130M FS+227d | 20d |
|  | 3 | **1.2.4.3 HALL D** |  | 2006-10-02 | 2013-08-30 |  |  |
| 1243005M |  | Begin Definitive Design Hall D Complex | 0d | 2006-10-02 | 2006-10-02 | 9-070M | 15d |
| 1243010 |  | Develop Hall D 60% Design (HALL D) | 45d | 2006-10-02 | 2006-12-05 | 1243005M | 15d |
| 1243015 |  | Conduct Hall D 60% Design & Safety Review | 25d | 2006-12-06 | 2007-01-18 | 1243010 | 15d |
| 1243015M |  | 60% Design Hall D Complete | 0d | 2007-01-18 | 2007-01-18 | 1243015 | 15d |
| 1243018 |  | Independent Cost Validation | 42d | 2007-04-23 | 2007-06-20 | 1243015M FS+65d | 93d |
| 1243020 |  | Develop Hall D 100% Design (HALL D) | 60d | 2007-05-21 | 2007-08-14 | 1243015M FS+85d | 15d |
| 1243021 |  | Develop Hall D Civil Commissioning Plan | 60d | 2007-05-21 | 2007-08-14 | 1243015M FS+85d | 15d |
| 1243025 |  | Conduct Hall D 100% Design & Safety Review | 40d | 2007-08-15 | 2007-10-10 | 1243021, 1243020 | 15d |
| 1243025M |  | 100% Design Hall D Complete | 0d | 2007-10-10 | 2007-10-10 | 1243018, 1243025 | 15d |
| 1243030 |  | Develop Hall D Final Design (HALL D) | 20d | 2007-10-11 | 2007-11-07 | 1243025M | 15d |
| 1243035 |  | Conduct Hall D Final Design & Safety Review | 15d | 2007-11-08 | 2007-11-30 | 1243030 | 15d |
| 1243040M |  | Complete Design Hall D Complete (HALL D) | 0d | 2007-11-30 | 2007-11-30 | 1243035 | 15d |
| 1243045 |  | Obtain Permit to Dispose of Dewater Effleuent (HALL D)+ | 90d | 2007-12-03 | 2008-04-17 | 1243035 | 256d |
| 1243050 |  | PROC Procurement Prep to Award Hall D Contract | 195d | 2008-01-02 | 2008-10-07 | 1243040M FS+15d | 136d |
| 1243050a |  | FY08 Exp Procurement Prep to Award Hall D Contract | 190d | 2008-01-02 | 2008-09-30 | 1243040M FS+15d | 136d |
| 1243055 |  | Hall D Survey Network | 20d | 2008-08-04 | 2008-08-29 | 1243040M FS+164d | 162d |
| 1243050b |  | FY09 Exp Procurement Prep to Award Hall D Contract | 5d | 2008-10-01 | 2008-10-07 | 1243050a | 136d |
| 1243060 |  | Re-Baseline Actuals Adjustment | 1d | 2013-08-30 | 2013-08-30 | 9-130M FS+227d | 20d |
|  | 5 | **1.2.5 PROJECT MANAGEMENT** |  | 2006-10-02 | 2013-08-30 |  |  |
|  | 1 | **1.2.5.1 PED PROJECT MANAGEMENT PROJECT OFFICE (DIR, PM, APM'S)** |  | 2006-10-02 | 2013-08-30 |  |  |
| 1251006RKC |  | FY06 Obligations RKC | 120d | 2006-10-02 | 2007-03-30 | 9-070M | 333d |
| 1251007LOE |  | FY07 Project Management Project Office | 247d | 2006-10-02 | 2007-09-28 | 9-070M | 1d |
| 1251908LOE |  | FY08 PED Proj Office Proj Mngmnt P-1 | 142d | 2007-10-01 | 2008-04-30 | 1251007LOE | 1d |
| 1251908LOEB |  | FY08 PED Proj Office Proj Mngmnt P-2 | 106d | 2008-05-01 | 2008-09-30 | 1251908LOE | 1d |
| 171909LOEX |  | FY09 Constrctn Proj Office Proj Mngmnt | 59d | 2008-10-01 | 2008-12-24 | 1252908LOEB | 20d |
| 1251910 |  | Re-Baseline Actuals Adjustment | 1d | 2013-08-30 | 2013-08-30 | 9-130M FS+227d | 20d |
|  | 2 | **1.2.5.2 PED PROJECT MANAGEMENT PROJECT OFFICE (OPM STAFF)** |  | 2006-10-02 | 2013-08-30 |  |  |
| 1252007LOE |  | FY07 Project Management Project Office | 247d | 2006-10-02 | 2007-09-28 | 9-070M | 20d |
| 1252010 |  | PREP for OECM EVMS Contractor Certification Review | 40d | 2007-09-17 | 2007-11-09 | 3R-07M | 31d |
| 1252908LOE |  | FY08 PED OPM Proj Mngmnt P-1 | 131d | 2007-10-01 | 2008-04-15 | 122211007LOE, 1252007LOE | 20d |
| 1252015 |  | OECM EVMS Contractor Certification REVIEW | 5d | 2007-12-03 | 2007-12-07 | 1252010 FS+13d | 31d |
| 1252908LOEB |  | FY08 PED OPM Proj Mngmnt P-2 | 117d | 2008-04-16 | 2008-09-30 | 1252908LOE | 20d |
| 1252910 |  | Re-Baseline Actuals Adjustment | 1d | 2013-08-30 | 2013-08-30 | 9-130M FS+227d | 20d |
|  | 6 | **1.2.6 ACCELERATOR SYSTEMS COMMISSIONING PLANNING** |  | 2006-11-01 | 2013-08-30 |  |  |
| 126000M |  | Start Milestone for Commissioning PED (ACC SYS COMMIS PLNNG) | 0d | 2006-11-01 | 2006-11-01 | 9-070M FS+22d | 278d |
| 126005 |  | Develop draft commissioning plan for EIR (ACC SYS COMMIS PLNNG) | 130d | 2006-11-01 | 2007-05-15 | 126000M | 278d |
| 126010 |  | Preliminary Design & Safety Review for Commissioning Plan (ACC SYS COMMIS PLNNG) | 1d | 2007-05-16 | 2007-05-16 | 126005 | 278d |
| 126015 |  | Post-review development of Commissioning Plan (ACC SYS COMMIS PLNNG) | 10d | 2007-05-17 | 2007-05-31 | 126010 | 278d |
| 126020M |  | Draft commissioning plan ready for EIR (ACC SYS COMMIS PLNNG) | 0d | 2007-05-31 | 2007-05-31 | 126015 | 278d |
| 126025M |  | Start of FY08 Commssng Planning (ACC SYS COMMIS PLNNG) | 0d | 2008-03-27 | 2008-03-27 | 126020M, 9-080M FS+117d | 77d |
| 126030 |  | Development of Sys's Cmmssng Milestones (ACC SYS COMMIS PLNNG) | 130d | 2008-03-27 | 2008-09-29 | 126025M | 77d |
| 126035M |  | Comp Draft Sys's Cmmssng Milestones (ACC SYS COMMIS PLNNG) | 0d | 2008-09-29 | 2008-09-29 | 126030 | 77d |
| 126040 |  | Review of Sys Milestones with Sys owners (ACC SYS COMMIS PLNNG) | 1d | 2008-09-30 | 2008-09-30 | 126035M | 77d |

| ID | WBS | Task | Duration | Start | Finish | Predecessors | Total float |
| --- | --- | --- | --- | --- | --- | --- | --- |
| 126045 |  | Incorporate Changes from Review of Sys's Milestones (ACC SYS COMMIS PLNNG) | 20d | 2008-10-01 | 2008-10-28 | 126040 | 77d |
| 126060 |  | Development of Beam-Based Cmmssng Plan (ACC SYS COMMIS PLNNG) | 130d | 2008-10-29 | 2009-05-12 | 126045 | 77d |
| 126065M |  | Comp Draft Beam-Based Commssng Plan (ACC SYS COMMIS PLNNG) | 0d | 2009-05-12 | 2009-05-12 | 126060 | 77d |
| 126070 |  | Review of Beam-Based Cmmssng Plan (ACC SYS COMMIS PLNNG) | 1d | 2009-05-13 | 2009-05-13 | 126065M | 77d |
| 126075 |  | Incorporate Changes from Review of Beam-Based Plan (ACC SYS COMMIS PLNNG) | 20d | 2009-05-14 | 2009-06-11 | 126070 | 77d |
| 126080M |  | Comp Commssng Plan (ACC SYS COMMIS PLNNG) | 0d | 2009-06-11 | 2009-06-11 | 126075 | 77d |
| 126085 |  | Re-Baseline Actuals Adjustment | 1d | 2013-08-30 | 2013-08-30 | 9-130M FS+227d | 20d |
|  | 3 | **1.3 CONSTRUCTION ACCELERATOR SYSTEMS** |  | 2009-01-02 | 2014-10-31 |  |  |
|  | 1 | **1.3.1 CRYOMODULES** |  | 2009-01-02 | 2013-08-30 |  |  |
|  | 1 | **1.3.1.1 PROCUREMENTS** |  | 2009-01-02 | 2013-08-30 |  |  |
|  | 1 | **1.3.1.1.1 CAVITY STRING PROCUREMENTS** |  | 2009-01-05 | 2013-08-30 |  |  |
|  | 1 | **1.3.1.1.1.1 NIOBIUM** |  | 2009-01-05 | 2013-08-30 |  |  |
| 131111010 |  | Proc Niobium | 1d | 2009-01-05 | 2009-01-05 | 9-090M FS+60d | 527d |
| 131111011 |  | Niobium Labor and Expenses Initial | 101d | 2009-01-06 | 2009-05-29 | 131111010 | 527d |
| 131111012 |  | Expenses Niobium Batch 1 | 101d | 2009-01-06 | 2009-05-29 | 131111010 | 713d |
| 131111013 |  | Expenses Niobium Batch 2 | 101d | 2009-01-06 | 2009-05-29 | 131111010 | 713d |
| 131111011LOE |  | Niobium Labor and Expenses Final FY09 | 55d | 2009-07-15 | 2009-09-30 | 131111011 FS+31d | 527d |
| 131111012A |  | Vend Fab - Order Niobium | 19d | 2009-07-15 | 2009-08-10 | 9-090M FS+193d | 663d |
| 131111012B |  | Vend Fab - Niobium Batch 1 | 85d | 2009-07-15 | 2009-11-11 | 9-090M FS+193d | 577d |
| 131111013A |  | Vend Fab - Niobium Batch 2 | 142d | 2009-07-15 | 2010-02-11 | 9-090M FS+193d | 530d |
| 131111011LOEb |  | Niobium Labor and Expenses Final FY10 | 100d | 2009-10-01 | 2010-03-03 | 131111011LOE | 527d |
| 131111015 |  | Receive & Insp Niobium Batch 1 | 20d | 2009-11-12 | 2009-12-11 | 131111012B | 577d |
| 131111020 |  | Receive & Insp Niobium Batch 2 (Original History) | 10d | 2010-02-12 | 2010-02-26 | 131111013A | 530d |
| 131111013B |  | Vend Fab - Niobium Batch 2 Reverse Entry per CR 10-043 | 1d | 2010-03-01 | 2010-03-01 | 9-100M FS+97d | 528d |
| 131111013C |  | Vend Fab - Niobium Batch 2 Revised Delivery per CR 10-043 | 151d | 2010-03-01 | 2010-09-30 | 9-100M FS+97d | 379d |
| 131111020A |  | Receive & Insp Niobium Batch 2 Reverse Entry per CR 10-043 | 1d | 2010-03-02 | 2010-03-02 | 9-100M FS+97d, 131111013B | 528d |
| 131111020B |  | Receive & Insp Niobium Batch 2 Revised Delivery per CR 10-043 | 10d | 2010-09-17 | 2010-09-30 | 131111013C FS-10d | 379d |
| 131111025 |  | Re-Baseline Actuals Adjustment | 1d | 2013-08-30 | 2013-08-30 | 9-130M FS+227d | 20d |
|  | 2 | **1.3.1.1.1.2 CAVITY FABRICATION** |  | 2009-01-05 | 2013-08-30 |  |  |
| 131112000 |  | Re-Baseline Actuals Adjustment | 1d | 2013-08-30 | 2013-08-30 | 9-130M FS+227d | 20d |
|  | 1 | **1.3.1.1.1.2.1 VEND FAB CAVITIES** |  | 2009-01-05 | 2011-09-22 |  |  |
| 1311121010 |  | Proc Cavity Fab | 5d | 2009-01-05 | 2009-01-09 | 9-090M FS+60d, 121113005 | 169d |
| 1311121015 |  | Cavities Labor Initial | 97d | 2009-01-12 | 2009-05-29 | 1311121010 | 169d |
| 1311121015LOE |  | Cavities Labor Final FY09 | 55d | 2009-07-15 | 2009-09-30 | 1311121015 FS+31d | 169d |
| 1311121016 |  | Vend Fab Cavities 1 & 2 | 239d | 2009-07-15 | 2010-06-30 | 9-090M FS+193d | 53d |
| 1311121020 |  | Vend Fab Cavities 3 thru 8 | 260d | 2009-07-15 | 2010-07-30 | 9-090M FS+193d | 40d |
| 1311121025 |  | Vend Fab Cavities 9 thru 14 | 260d | 2009-07-15 | 2010-07-30 | 9-090M FS+193d | 80d |
| 1311121030 |  | Vend Fab Cavities 15 thru 20 | 282d | 2009-07-15 | 2010-08-31 | 9-090M FS+193d | 73d |
| 1311121035 |  | Vend Fab Cavities 21 thru 26 | 303d | 2009-07-15 | 2010-09-30 | 9-090M FS+193d | 138d |
| 1311121040 |  | Vend Fab Cavities 27 thru 32 | 324d | 2009-07-15 | 2010-10-29 | 9-090M FS+193d | 134d |
| 1311121045 |  | Vend Fab Cavities 33 thru 38 | 361d | 2009-07-15 | 2010-12-30 | 9-090M FS+193d | 130d |
| 1311121050 |  | Vend Fab Cavities 39 thru 44 | 381d | 2009-07-15 | 2011-01-31 | 9-090M FS+193d | 129d |
| 1311121055 |  | Vend Fab Cavities 45 thru 50 | 400d | 2009-07-15 | 2011-02-28 | 9-090M FS+193d | 109d |
| 1311121060 |  | Vend Fab Cavities 51 thru 56 | 423d | 2009-07-15 | 2011-03-31 | 9-090M FS+193d | 111d |
| 1311121065 |  | Vend Fab Cavities 57 thru 62 | 444d | 2009-07-15 | 2011-04-29 | 9-090M FS+193d | 110d |
| 1311121070 |  | Vend Fab Cavities 63 thru 68 | 465d | 2009-07-15 | 2011-05-31 | 9-090M FS+193d | 105d |
| 1311121075 |  | Vend Fab Cavities 69 thru 74 | 487d | 2009-07-15 | 2011-06-30 | 9-090M FS+193d | 123d |
| 1311121080 |  | Vend Fab Cavities 75 thru 80 | 507d | 2009-07-15 | 2011-07-29 | 9-090M FS+193d | 119d |
| 1311121085 |  | Vend Fab Cavities 81 thru 86 | 530d | 2009-07-15 | 2011-08-31 | 9-090M FS+193d | 111d |
| 1311121015LOEb |  | Cavities Labor Final FY10 | 248d | 2009-10-01 | 2010-09-30 | 1311121015LOE | 169d |
| 1311121017 |  | Vend Fab Chemistry & Tuning Cavities 1 & 2 | 125d | 2010-01-04 | 2010-06-30 | 9-100M FS+59d | 53d |
| 1311121021 |  | Vend Fab Chemistry & Tuning Cavities 3 thru 8 | 146d | 2010-01-04 | 2010-07-30 | 9-100M FS+59d | 40d |
| 1311121026 |  | Vend Fab Chemistry & Tuning Cavities 9 thru 14 | 146d | 2010-01-04 | 2010-07-30 | 9-100M FS+59d | 80d |
| 1311121031 |  | Vend Fab Chemistry & Tuning Cavities 15 thru 20 | 168d | 2010-01-04 | 2010-08-31 | 9-100M FS+59d | 73d |
| 1311121036 |  | Vend Fab Chemistry & Tuning Cavities 21 thru 26 | 189d | 2010-01-04 | 2010-09-30 | 9-100M FS+59d | 138d |
| 1311121041 |  | Vend Fab Chemistry & Tuning Cavities 27 thru 32 | 210d | 2010-01-04 | 2010-10-29 | 9-100M FS+59d | 134d |
| 1311121046 |  | Vend Fab Chemistry & Tuning Cavities 33 thru 38 | 247d | 2010-01-04 | 2010-12-30 | 9-100M FS+59d | 130d |
| 1311121051 |  | Vend Fab Chemistry & Tuning Cavities 39 thru 44 | 267d | 2010-01-04 | 2011-01-31 | 9-100M FS+59d | 129d |
| 1311121056 |  | Vend Fab Chemistry & Tuning Cavities 45 thru 50 | 286d | 2010-01-04 | 2011-02-28 | 9-100M FS+59d | 109d |
| 1311121061 |  | Vend Fab Chemistry & Tuning Cavities 51 thru 56 | 309d | 2010-01-04 | 2011-03-31 | 9-100M FS+59d | 111d |
| 1311121066 |  | Vend Fab Chemistry & Tuning Cavities 57 thru 62 | 330d | 2010-01-04 | 2011-04-29 | 9-100M FS+59d | 110d |
| 1311121071 |  | Vend Fab Chemistry & Tuning Cavities 63 thru 68 | 351d | 2010-01-04 | 2011-05-31 | 9-100M FS+59d | 105d |
| 1311121076 |  | Vend Fab Chemistry & Tuning Cavities 69 thru 74 | 373d | 2010-01-04 | 2011-06-30 | 9-100M FS+59d | 123d |
| 1311121081 |  | Vend Fab Chemistry & Tuning Cavities 75 thru 80 | 393d | 2010-01-04 | 2011-07-29 | 9-100M FS+59d | 119d |
| 1311121086 |  | Vend Fab Chemistry & Tuning Cavities 81 thru 86 | 416d | 2010-01-04 | 2011-08-31 | 9-100M FS+59d | 111d |
| 1311121091 |  | Cavities Custom Duty Adjustment | 291d | 2010-07-01 | 2011-08-31 | 9-100M FS+184d | 105d |
| 1311121096LOE |  | SOTR Oversight FY10 | 64d | 2010-07-01 | 2010-09-30 | 9-100M FS+184d | 137d |
| 1311121015LOEc |  | Cavities Labor Final FY11 | 210d | 2010-10-01 | 2011-08-08 | 1311121015LOEb | 169d |
| 1311121101LOE |  | SOTR Oversight FY11 | 242d | 2010-10-01 | 2011-09-22 | 1311121096LOE | 137d |
|  | 2 | **1.3.1.1.1.2.2 RECEIVE AND INSPECT CAVITIES** |  | 2010-06-11 | 2011-10-03 |  |  |

| ID | WBS | Task | Duration | Start | Finish | Predecessors | Total float |
| --- | --- | --- | --- | --- | --- | --- | --- |
| 1311122005 |  | Receive and Inspect Cavities 1 & 2 | 10d | 2010-06-11 | 2010-06-24 | 1311121016 FS-14d, 1311121017 FS-14d | 53d |
| 1311122010 |  | Receive and Inspect Cavities 3 Thru 8 | 15d | 2010-07-15 | 2010-08-04 | 1311121021 FS-12d, 1311121020 FS-12d, 1311122005 | 40d |
| 1311122015 |  | Receive and Inspect Cavities 9 Thru 14 | 15d | 2010-09-10 | 2010-09-30 | 1311121025 FS-15d, 1311121026 FS-15d, 1317000, 1311122010 | 37d |
| 1311122020 |  | Receive and Inspect Cavities 15 and 16 | 5d | 2010-10-01 | 2010-10-07 | 1311121030 FS-15d, 1317000, 1311121031 FS-15d, 1311122015 | 37d |
| 1311122022 |  | Receive and Inspect Cavities 17 Thru 20 | 10d | 2010-10-08 | 2010-10-21 | 1317000, 1311122020 | 107d |
| 1311122025 |  | Receive and Inspect Cavities 21 Thru 24 | 10d | 2010-10-22 | 2010-11-04 | 1311121036 FS-16d, 1311122022, 1311121035 FS-16d | 107d |
| 1311122027 |  | Receive and Inspect Cavities 25 and 26 | 5d | 2010-11-05 | 2010-11-11 | 1311122025 | 108d |
| 1311122030 |  | Receive and Inspect Cavities 27 Thru 32 | 15d | 2010-11-12 | 2010-12-06 | 1311121040 FS-17d, 1311122027, 1311121041 FS-17d | 108d |
| 1311122035 |  | Receive and Inspect Cavities 33 Thru 38 | 15d | 2011-01-18 | 2011-02-07 | 1317005, 1311121045 FS-12d, 1311121046 FS-12d, 1311122030 | 108d |
| 1311122065 |  | Receive and Inspect Cavities 39 and 40 | 5d | 2011-02-08 | 2011-02-14 | 1311121050 FS-16d, 1311121051 FS-16d, 1311122035 | 108d |
| 1311122067 |  | Receive and Inspect Cavities 41 Thru 44 | 10d | 2011-02-15 | 2011-03-01 | 1311122065 | 112d |
| 1311122070 |  | Receive and Inspect Cavities 45 Thru 48 | 10d | 2011-03-07 | 2011-03-18 | 1311121055 FS+4d, 1311121056 FS+4d, 1311122067 | 109d |
| 1311122072 |  | Receive and Inspect Cavities 49 and 50 | 5d | 2011-03-21 | 2011-03-25 | 1311122070 | 113d |
| 1311122075 |  | Receive and Inspect Cavities 51 Thru 56 | 15d | 2011-03-30 | 2011-04-19 | 1311121061 FS-2d, 1311122072, 1311121060 FS-2d | 111d |
| 1311122080 |  | Receive and Inspect Cavities 57 Thru 62 | 15d | 2011-04-27 | 2011-05-17 | 1311121066 FS-3d, 1311122075, 1311121065 FS-3d | 110d |
| 1311122085 |  | Receive and Inspect Cavities 63 and 64 | 5d | 2011-05-25 | 2011-06-01 | 1311121070 FS-4d, 1311122080, 1311121071 FS-4d | 105d |
| 1311122087 |  | Receive and Inspect Cavities 65 thru 68 | 10d | 2011-06-02 | 2011-06-15 | 1311122085 | 109d |
| 1311122090 |  | Receive and Inspect Cavities 69 Thru 72 | 10d | 2011-08-01 | 2011-08-12 | 1311122087, 1311121075 FS-5d, 1311121076 FS-5d, 1317010 | 98d |
| 1311122092 |  | Receive and Inspect Cavities 73 and 74 | 5d | 2011-08-15 | 2011-08-19 | 1311122090 | 98d |
| 1311122095 |  | Receive and Inspect Cavities 75 Thru 80 | 15d | 2011-08-22 | 2011-09-12 | 1311121081 FS-6d, 1311121080 FS-6d, 1311122092 | 98d |
| 1311122100 |  | Receive and Inspect Cavities 81 Thru 86 FY11 | 14d | 2011-09-13 | 2011-09-30 | 1311121091, 1311122095, 1311121085 FS-6d, 1311121086 FS-6d | 98d |
| 1311122100a |  | Receive and Inspect Cavities 81 Thru 86 FY12 | 1d | 2011-10-03 | 2011-10-03 | 1311122100 | 98d |
| 1311122105M |  | All Cavities Recieved and Inspected | 0d | 2011-10-03 | 2011-10-03 | 1311122092, 1311122070, 1311122027, 131111020B, 1311121101LOE, 1311122080, 131111012A, 1311122087, 1311122065, 1311122100a, 131111013A, 1311122005, 1311122015, 1311122030, 1311122090, 1311122020, 1311122010, 1311122022, 131111015, 131111020, 131111020A, 1311121015LOEc, 1311122025, 1311122067, 131111013, 131111012, 1311122075, 1311122035, 1311122072, 1311122085, 1311122095, 131111011LOEb | 130d |
|  | 3 | **1.3.1.1.1.2.3 DUMMY** |  |  |  |  |  |
|  | 3 | **1.3.1.1.1.3 WAVEGUIDES** |  | 2009-01-05 | 2013-08-30 |  |  |
| 131113000 |  | Re-Baseline Actuals Adjustment | 1d | 2013-08-30 | 2013-08-30 | 9-130M FS+227d | 20d |
|  | 1 | **1.3.1.1.1.3.1 WAVEGUIDE FABRICATION** |  | 2009-01-05 | 2010-10-01 |  |  |
| 1311131010 |  | Proc Waveguides | 1d | 2009-01-05 | 2009-01-05 | 9-090M FS+60d, 11115005 | 363d |
| 1311131015 |  | Waveguides Labor Initial | 101d | 2009-01-06 | 2009-05-29 | 1311131010 | 379d |
| 1311131015LOE |  | Waveguides Labor Final FY09 | 86d | 2009-06-01 | 2009-09-30 | 1311131015 | 379d |
| 1311131020 |  | Vend Fab Waveguides 1 thru 10 | 138d | 2009-06-01 | 2009-12-15 | 9-090M FS+162d | 234d |
| 1311131025 |  | Vend Fab Waveguides 11 thru 30 | 179d | 2009-06-01 | 2010-02-22 | 9-090M FS+162d | 213d |
| 1311131030 |  | Vend Fab Waveguides 31 thru 40 | 229d | 2009-06-01 | 2010-05-03 | 9-090M FS+162d | 342d |
| 1311131035 |  | Vend Fab Waveguides 41 thru 50 | 249d | 2009-06-01 | 2010-06-01 | 9-090M FS+162d | 368d |
| 1311131040 |  | Vend Fab Waveguides 51 thru 60 | 271d | 2009-06-01 | 2010-07-01 | 9-090M FS+162d | 366d |
| 1311131045 |  | Vend Fab Waveguides 61 thru 70 | 292d | 2009-06-01 | 2010-08-02 | 9-090M FS+162d | 365.5d |
| 1311131050 |  | Vend Fab Waveguides 71 thru 80 | 314d | 2009-06-01 | 2010-09-01 | 9-090M FS+162d | 364d |
| 1311131055 |  | Vend Fab Waveguides 81 thru 88 | 335d | 2009-06-01 | 2010-10-01 | 9-090M FS+162d | 363d |
| 1311131015LOEb |  | Waveguides Labor Final FY10 | 248d | 2009-10-01 | 2010-09-30 | 1311131015LOE | 379d |
| 1311131060 |  | Exchange Rate | 66d | 2010-06-30 | 2010-10-01 | 1311131010 FS+370d | 363d |
|  | 2 | **1.3.1.1.1.3.2 WAVEGUIDES RECEIVE AND INSPECT** |  | 2009-12-16 | 2010-10-22 |  |  |
| 1311132010 |  | Receive & Insp Waveguides 1 thru 8 | 15d | 2009-12-16 | 2010-01-13 | 1311131020 | 234d |
| 1311132015 |  | Receive & Insp Waveguides 9 & 10 | 5d | 2010-01-14 | 2010-01-21 | 1311132010 | 234d |
| 1311132020 |  | Receive & Insp Waveguides 11 thru 16 | 15d | 2010-02-23 | 2010-03-15 | 1311132015, 1311131025 | 213d |
| 1311132025 |  | Receive & Insp Waveguides 17 Thru 20 | 10d | 2010-03-16 | 2010-03-29 | 1311132020 | 342d |
| 1311132030 |  | Receive & Insp Waveguides 21 thru 24 | 10d | 2010-03-30 | 2010-04-12 | 1311132025 | 342d |
| 1311132035 |  | Receive & Insp Waveguides 25 thru 30 | 15d | 2010-04-13 | 2010-05-03 | 1311132030 | 342d |
| 1311132040 |  | Receive & Insp Waveguides 31 and 32 | 5d | 2010-05-04 | 2010-05-10 | 1311132035, 1311131030 | 342d |
| 1311132045 |  | Receive & Insp Waveguides 33 thru 40 | 15d | 2010-05-11 | 2010-06-01 | 1311132040 | 357d |
| 1311132050 |  | Receive & Insp Waveguides 41 thru 48 | 15d | 2010-06-02 | 2010-06-22 | 1311131035, 1311132045 | 368d |
| 1311132055 |  | Receive & Insp Waveguides 49 and 50 | 5d | 2010-06-23 | 2010-06-29 | 1311132050 | 368d |
| 1311132060 |  | Receive & Insp Waveguides 51 thru 56 | 13d | 2010-07-02 | 2010-07-21 | 1311131040, 1311132055 | 366d |
| 1311132065 |  | Receive & Insp Waveguides 57 thru 60 | 7.5d | 2010-07-22 | 2010-08-02 | 1311132060 | 366d |
| 1311132070 |  | Receive & Insp Waveguides 61 thru 64 | 8d | 2010-08-03 | 2010-08-12 | 1311131045, 1311132065 | 365.5d |
| 1311132075 |  | Receive & Insp Waveguides 65 thru 70 | 12.5d | 2010-08-13 | 2010-08-31 | 1311132070 | 365.5d |
| 1311132080 |  | Receive & Insp Waveguides 71 and 72 | 5d | 2010-09-02 | 2010-09-09 | 1311131050, 1311132075 | 364d |
| 1311132085 |  | Receive & Insp Waveguides 73 thru 80 | 15d | 2010-09-10 | 2010-09-30 | 1311132080 | 364d |
| 1311132090 |  | Receive & Insp Waveguides 81 thru 88 | 15d | 2010-10-04 | 2010-10-22 | 1311132085, 1311131060, 1311131055 | 363d |
| 1311132100M |  | All Waveguides Received and Inspected | 0d | 2010-10-22 | 2010-10-22 | 1311132050, 1311132065, 1311132040, 1311132035, 1311132085, 1311131015LOEb, 1311132025, 1311132070, 1311132090, 1311132010, 1311132015, 1311132060, 1311132030, 1311132020, 1311132045, 1311132055, 1311132080, 1311132075 | 363d |
|  | 4 | **1.3.1.1.1.4 HELIUM VESSELS** |  | 2009-03-02 | 2013-08-30 |  |  |
| 131114010 |  | Proc Helium Vessels | 64d | 2009-03-02 | 2009-05-29 | 1211020M FS-42d, 9-090M | 227d |
| 131114015 |  | Helium Vessels Labor Initial | 2d | 2009-05-29 | 2009-06-01 | 131114010 FS-1d | 266d |
| 131114016 |  | Vend Fab - Helium Vessels 1 & 2 | 50d | 2009-06-01 | 2009-08-10 | 131114010 | 286d |
| 131114017 |  | Vend Fab - Helium Vessels 3 Thru 8 | 65d | 2009-06-01 | 2009-08-31 | 131114010 | 281d |
| 131114020 |  | Vend Fab - Helium Vessels 9 Thru 16 | 80d | 2009-06-01 | 2009-09-22 | 131114010 | 291d |
| 131114025 |  | Vend Fab - Helium Vessels 17 Thru 24 | 95d | 2009-06-01 | 2009-10-13 | 131114010 | 366d |
| 131114030 |  | Vend Fab - Helium Vessels 25 Thru 32 | 110d | 2009-06-01 | 2009-11-03 | 131114010 | 389d |
| 131114035 |  | Vend Fab - Helium Vessels 33 Thru 40 | 125d | 2009-06-01 | 2009-11-24 | 131114010 | 400d |
| 131114040 |  | Vend Fab - Helium Vessels 41 Thru 48 | 140d | 2009-06-01 | 2009-12-17 | 131114010 | 409d |
| 131114045 |  | Vend Fab - Helium Vessels 49 Thru 56 | 175d | 2009-06-01 | 2010-02-16 | 131114010 | 398d |

| ID | WBS | Task | Duration | Start | Finish | Predecessors | Total float |
| --- | --- | --- | --- | --- | --- | --- | --- |
| 131114050 |  | Vend Fab - Helium Vessels 57 Thru 64 | 190d | 2009-06-01 | 2010-03-09 | 131114010 | 407d |
| 131114055 |  | Vend Fab - Helium Vessels 65 Thru 72 | 205d | 2009-06-01 | 2010-03-30 | 131114010 | 447d |
| 131114060 |  | Vend Fab - Helium Vessels 73 Thru 80 | 220d | 2009-06-01 | 2010-04-20 | 131114010 | 451d |
| 131114065 |  | Vend Fab - Helium Vessels 81 Thru 90 | 235d | 2009-06-01 | 2010-05-11 | 131114010 | 441d |
| 131114015LOE |  | Helium Vessels Labor Final FY09 | 85d | 2009-06-02 | 2009-09-30 | 131114015 | 266d |
| 131114070 |  | Receive & Insp Helium Vessels 1 & 2 | 10d | 2009-08-11 | 2009-08-24 | 131114016 | 286d |
| 131114075 |  | Receive & Insp Helium Vessels 3 Thru 8 | 5d | 2009-09-01 | 2009-09-08 | 131114070, 131114017 | 281d |
| 131114080 |  | Receive & Insp Helium Vessels 9 Thru 16 | 5d | 2009-09-23 | 2009-09-29 | 131114075, 131114020 | 291d |
| 131114015LOEb |  | Helium Vessels Labor Final FY10 | 213d | 2009-10-01 | 2010-08-11 | 131114015LOE | 266d |
| 131114085 |  | Receive & Insp Helium Vessels 17 thru 24 | 5d | 2009-10-14 | 2009-10-20 | 131114080, 131114025 | 366d |
| 131114090 |  | Receive & Insp Helium Vessels 25 Thru 32 | 5d | 2009-11-04 | 2009-11-10 | 131114085, 131114030 | 389d |
| 131114095 |  | Receive & Insp Helium Vessels 33 Thru 40 | 5d | 2009-11-25 | 2009-12-03 | 131114090, 131114035 | 400d |
| 131114100 |  | Receive & Insp Helium Vessels 41 thru 48 | 5d | 2009-12-18 | 2009-12-31 | 131114040, 131114095 | 409d |
| 131114105 |  | Receive & Insp Helium Vessels 49 Thru 56 | 5d | 2010-02-17 | 2010-02-23 | 131114045, 131114100 | 398d |
| 131114110 |  | Receive & Insp Helium Vessels 57 Thru 64 | 5d | 2010-03-10 | 2010-03-16 | 131114105, 131114050 | 407d |
| 131114115 |  | Receive & Insp Helium Vessels 65 thru 72 | 5d | 2010-03-31 | 2010-04-06 | 131114055, 131114110 | 447d |
| 131114120 |  | Receive & Insp Helium Vessels 73 thru 80 | 5d | 2010-04-21 | 2010-04-27 | 131114060, 131114115 | 451d |
| 131114125 |  | Receive & Insp Helium Vessels 81 Thru 90 | 5d | 2010-05-12 | 2010-05-18 | 131114065, 131114120 | 441d |
| 131114130 |  | Vend Fab 10 CFR 851 Compliance | 184d | 2010-07-01 | 2011-03-31 | 131114010 FS+270d | 227d |
| 131114015LOEc |  | SOTR Oversight FY11 | 116d | 2010-10-01 | 2011-03-25 | 9-110M, 131114015LOEb | 231d |
| 131114130M |  | All Helium Vessels Received and Inspected | 0d | 2011-03-31 | 2011-03-31 | 131114125, 131114015LOEb, 131114085, 131114110, 131114080, 131114120, 131114070, 131114100, 131114105, 131114115, 131114075, 131114130, 131114015LOEc, 131114090, 131114095 | 227d |
| 131114135 |  | Re-Baseline Actuals Adjustment | 1d | 2013-08-30 | 2013-08-30 | 9-130M FS+227d | 20d |
|  | 5 | **1.3.1.1.1.5 HARDWARE** |  | 2009-03-02 | 2013-08-30 |  |  |
| 131115010 |  | Proc Hardware | 45d | 2009-03-02 | 2009-05-01 | 9-090M FS+98d | 356d |
| 131115012 |  | Vend Fab - Hardware (Phase 1) | 30d | 2009-05-01 | 2009-06-12 | 131115010 FS-1d | 356d |
| 131115013 |  | Vend Fab - Hardware (Phase 2) | 31d | 2009-06-15 | 2009-07-28 | 131115012 | 539d |
| 131115015 |  | Receive & Insp Hardware (Phase 1) | 16d | 2009-06-29 | 2009-07-21 | 131115010, 131115012 FS+10d | 356d |
| 131115016 |  | Receive & Insp Hardware (Phase 2) | 16d | 2009-08-12 | 2009-09-02 | 131115013 FS+10d | 539d |
| 131115020 |  | Re-Baseline Actuals Adjustment | 1d | 2013-08-30 | 2013-08-30 | 9-130M FS+227d | 20d |
|  | 6 | **1.3.1.1.1.6 MISC** |  | 2009-03-16 | 2013-08-30 |  |  |
| 131116010 |  | Proc Misc | 55d | 2009-03-16 | 2009-06-01 | 121114010M FS-132d, 9-090M FS+108d | 324d |
| 131116012 |  | Vend Fab - Misc (Phase 1) | 51d | 2009-06-01 | 2009-08-11 | 131116010 FS-1d | 324d |
| 131116013 |  | Vend Fab - Misc (Phase 2) Labor FY09 | 35d | 2009-08-12 | 2009-09-30 | 131116012 | 487d |
| 131116013c |  | Vend Fab - Misc (Phase 2) Procurement | 51d | 2009-08-12 | 2009-10-22 | 131116012 | 487d |
| 131116015 |  | Receive & Insp Misc (Phase 1) | 17d | 2009-08-12 | 2009-09-03 | 131116012, 131116010 | 324d |
| 131116013b |  | Vend Fab - Misc (Phase 2) Labor FY10 | 16d | 2009-10-01 | 2009-10-22 | 131116013 | 487d |
| 131116016 |  | Receive & Insp Misc (Phase 2) | 17d | 2009-10-23 | 2009-11-16 | 131116013b, 131116013c | 487d |
| 131116020 |  | QC Traveler FY10 | 128d | 2010-04-01 | 2010-09-30 | 9-100M FS+120d | 126d |
| 131116025 |  | QC Traveler FY11 | 58d | 2010-10-01 | 2010-12-30 | 131116020 | 126d |
| 131116030 |  | Re-Baseline Actuals Adjustment | 1d | 2013-08-30 | 2013-08-30 | 9-130M FS+227d | 20d |
|  | 2 | **1.3.1.1.2 SPACE FRAME PROCUREMENTS** |  | 2009-02-02 | 2013-08-30 |  |  |
|  | 1 | **1.3.1.1.2.1 SPACE FRAME** |  | 2009-02-02 | 2013-08-30 |  |  |
| 131121010 |  | Proc Space Frames | 128d | 2009-02-02 | 2009-08-03 | 9-090M, 1211020M5 FS-168d | 19d |
| 131121010ALOE |  | Vendor Fab Space Frames Labor FY09 | 24d | 2009-08-27 | 2009-09-30 | 9-090M FS+224d | 476d |
| 131121011 |  | Vend Fab Space Frames 10% of Material Costs | 102d | 2009-08-27 | 2010-01-29 | 9-090M FS+224d, 131121010 FS-45d | 274d |
| 131121015 |  | Vend Fab Space Frames 50% OF Cost (Fab/Ship) 1st Article | 142d | 2009-08-27 | 2010-03-29 | 9-090M FS+224d, 131121010 FS-1d | 234d |
| 131121016 |  | Vend Fab Space Frames 50% OF Cost (Fab/Ship) Upon Receipt of 1st Article | 166d | 2009-08-27 | 2010-04-30 | 9-090M FS+224d | 210d |
| 131121016A |  | Vend Fab Space Frames Production 90% of Material | 144d | 2009-08-27 | 2010-03-31 | 9-090M FS+224d | 345d |
| 131121016B |  | Vend Fab Space Frames Deliver Space Frame #2 | 208d | 2009-08-27 | 2010-06-30 | 9-090M FS+224d | 195.5d |
| 131121016C |  | Vend Fab Space Frames Deliver Space Frame #3 | 229d | 2009-08-27 | 2010-07-30 | 9-090M FS+224d | 260d |
| 131121016D |  | Vend Fab Space Frames Deliver Space Frame #4 | 251d | 2009-08-27 | 2010-08-31 | 9-090M FS+224d | 279d |
| 131121016F |  | Vend Fab Space Frames Deliver Space Frame #5 | 272d | 2009-08-27 | 2010-09-30 | 9-090M FS+224d | 313d |
| 131121016G |  | Vend Fab Space Frames Deliver Space Frame #6 | 293d | 2009-08-27 | 2010-10-29 | 9-090M FS+224d | 345d |
| 131121016H |  | Vend Fab Space Frames Deliver Space Frame #7 | 313d | 2009-08-27 | 2010-11-30 | 9-090M FS+224d | 429d |
| 131121016J |  | Vend Fab Space Frames Deliver Space Frame #8 | 350d | 2009-08-27 | 2011-01-31 | 9-090M FS+224d | 451d |
| 131121016K |  | Vend Fab Space Frames Deliver Space Frame #9 | 350d | 2009-08-27 | 2011-01-31 | 9-090M FS+224d | 496.5d |
| 131121016L |  | Vend Fab Space Frames Deliver Space Frame #10 | 369d | 2009-08-27 | 2011-02-28 | 9-090M FS+224d | 500d |
| 131121010BLOE |  | Vendor Fab Space Frames Labor FY10 | 248d | 2009-10-01 | 2010-09-30 | 131121010ALOE, 9-090M FS+224d | 476d |
| 131121020 |  | Receive & Insp Space Frame First Article (Lab Labor) | 20d | 2010-05-03 | 2010-05-28 | 131121011, 131121015, 131121010, 131121016 | 210d |
| 131121021 |  | Receive & Insp Space Frame #2 | 20d | 2010-07-01 | 2010-07-29 | 131121010, 131121020, 131121016, 131121016B | 195.5d |
| 131121040LOE |  | SOTR Oversight FY10 | 64d | 2010-07-01 | 2010-09-30 | 9-100M FS+184d | 479d |
| 131121022 |  | Receive & Insp Space Frame #3 | 20d | 2010-08-02 | 2010-08-27 | 131121010, 131121016A, 131121021, 131121016C | 260d |
| 131121025 |  | Receive & Insp Space Frame #4 | 20d | 2010-09-01 | 2010-09-29 | 131121016D, 131121022 | 279d |
| 131121010CLOE |  | Vendor Fab Space Frames Labor FY11 | 141d | 2010-10-01 | 2011-04-29 | 9-090M FS+224d, 131121010BLOE | 476d |
| 131121026 |  | Receive & Insp Space Frame #5 | 20d | 2010-10-01 | 2010-10-28 | 131121016F, 131121025 | 313d |
| 131121045LOE |  | SOTR Oversight FY11 | 138d | 2010-10-01 | 2011-04-26 | 131121040LOE | 479d |
| 131121027 |  | Receive & Insp Space Frame #6 | 20d | 2010-11-01 | 2010-11-30 | 131121016G, 131121026 | 345d |
| 131121028 |  | Receive & Insp Space Frame #7 | 20d | 2010-12-01 | 2011-01-05 | 131121016H, 131121027 | 429d |
| 131121029 |  | Receive & Insp Space Frame #8 | 20d | 2011-02-01 | 2011-03-01 | 131121016J, 131121028 | 451d |
| 131121030 |  | Receive & Insp Space Frame #9 | 20d | 2011-03-02 | 2011-03-29 | 131121029, 131121016K | 476.5d |

| ID | WBS | Task | Duration | Start | Finish | Predecessors | Total float |
| --- | --- | --- | --- | --- | --- | --- | --- |
| 131121035 |  | Receive & Insp Space Frame #10 | 20d | 2011-03-30 | 2011-04-26 | 131121030, 131121016L | 479d |
| 131121050 |  | Re-Baseline Actuals Adjustment | 1d | 2013-08-30 | 2013-08-30 | 9-130M FS+227d | 20d |
|  | 2 | **1.3.1.1.2.2 TUNERS** |  | 2009-05-01 | 2013-08-30 |  |  |
| 131122010 |  | Proc Tuners | 86d | 2009-05-01 | 2009-09-01 | 9-090M FS+142d | 274d |
| 131122015 |  | Vend Fab - Cold Tuners Lot #1 (Phase 1) FY09 Original Labor | 21d | 2009-09-01 | 2009-09-30 | 131122010 FS-1d | 318d |
| 131122016A |  | Vend Fab - Cold Tuners - Materials | 16d | 2009-09-09 | 2009-09-30 | 131122010 FS+4d | 274d |
| 131122016B |  | Vend Fab - Cold Tuners - First Article | 38d | 2009-09-09 | 2009-10-30 | 131122016A FS-16d | 274d |
| 131122016C |  | Vend Fab - Cold Tuners - 2 thru 10 | 94d | 2009-09-09 | 2010-01-29 | 131122016B FS-38d | 274d |
| 131122016D |  | Vend Fab - Cold Tuners - 11 thru 20 | 113d | 2009-09-09 | 2010-02-26 | 131122016C FS-94d | 280d |
| 131122016F |  | Vend Fab - Cold Tuners - 21 thru 30 | 136d | 2009-09-09 | 2010-03-31 | 131122016D FS-113d | 345d |
| 131122016G |  | Vend Fab - Cold Tuners - 31 thru 40 | 158d | 2009-09-09 | 2010-04-30 | 131122016F FS-136d | 354d |
| 131122016H |  | Vend Fab - Cold Tuners - 41 thru 50 | 178d | 2009-09-09 | 2010-05-28 | 131122016G FS-158d | 389d |
| 131122016J |  | Vend Fab - Cold Tuners - 51 thru 60 | 200d | 2009-09-09 | 2010-06-30 | 131122016H FS-178d | 425d |
| 131122016K |  | Vend Fab - Cold Tuners - 61 thru 70 | 221d | 2009-09-09 | 2010-07-30 | 131122016J FS-200d | 513d |
| 131122016L |  | Vend Fab - Cold Tuners - 71 thru 80 | 243d | 2009-09-09 | 2010-08-31 | 131122016K FS-221d | 570d |
| 131122016N |  | Vend Fab - Cold Tuners - 81 thru 84 | 264d | 2009-09-09 | 2010-09-30 | 131122016L FS-243d | 572d |
| 131122015A |  | Vend Fab - Cold Tuners Lot #1 (Phase 1) FY10 Original Labor | 79d | 2009-10-01 | 2010-02-01 | 131122015 | 318d |
| 131122065 |  | Vend Fab - Warm Tuners Lot # 1 | 180d | 2009-10-01 | 2010-06-24 | 9-100M | 168d |
| 131122017 |  | Receive & Insp First Article Tuner | 10d | 2009-11-02 | 2009-11-13 | 131122016B, 131122015A FS-64d, 131122015 FS-64d | 335d |
| 131122020 |  | Receive & Insp Tuners Lot #1 2-10 | 15d | 2010-02-01 | 2010-02-22 | 131122016C, 131122015 FS-64d, 131122015A FS-64d | 274d |
| 131122016 |  | Vend Fab - Cold Tuners Lot #2 & 3 (Phase 2) Original Labor | 120d | 2010-02-02 | 2010-07-22 | 131122015, 131122015A | 397d |
| 131122025 |  | Receive & Insp Tuners Lot #2 11-20 | 20d | 2010-03-01 | 2010-03-26 | 131122020 FS-1d, 131122015 FS-20d, 131122016D, 131122017 FS-1d, 131122015A FS-20d | 280d |
| 131122030 |  | Receive & Insp Tuners Lot #3 21-30 | 20d | 2010-04-01 | 2010-04-28 | 131122025, 131122015A, 131122016F, 131122015 | 345d |
| 131122035 |  | Receive & Insp Tuners Lot #4 31-40 | 20d | 2010-05-03 | 2010-05-28 | 131122016G, 131122016 FS-100d, 131122030 | 354d |
| 131122065B |  | Vend Fab - Warm Tuners Peg Point #1 Receipt of Materials | 47d | 2010-05-25 | 2010-07-30 | 9-100M FS+158d | 103d |
| 131122065C |  | Vend Fab - Warm Tuners Peg Point #2 Receipt of Balance of Materials | 69d | 2010-05-25 | 2010-08-31 | 131122065B FS-47d | 103d |
| 131122065D |  | Vend Fab - Warm Tuners Peg Point #3 Receipt of R100 Materials | 69d | 2010-05-25 | 2010-08-31 | 131122065C FS-69d | 103d |
| 131122065F |  | Vend Fab - Warm Tuners Peg Point #4 Receipt of First Article | 90d | 2010-05-25 | 2010-09-30 | 131122065D FS-69d | 103d |
| 131122065G |  | Vend Fab - Warm Tuners Peg Point #5 Receipt of 1st Production Set | 111d | 2010-05-25 | 2010-10-29 | 131122065F FS-90d | 103d |
| 131122065H |  | Vend Fab - Warm Tuners Peg Point #6 Receipt of 2nd Production Set | 131d | 2010-05-25 | 2010-11-30 | 131122065G FS-111d | 113d |
| 131122065J |  | Vend Fab - Warm Tuners Peg Point #7 Receipt of 3rd Production Set | 148d | 2010-05-25 | 2010-12-30 | 131122065H FS-131d | 166d |
| 131122065K |  | Vend Fab - Warm Tuners Peg Point #8 Receipt of 4th Production Set | 187d | 2010-05-25 | 2011-02-28 | 131122065J FS-148d | 166d |
| 131122065L |  | Vend Fab - Warm Tuners Peg Point #9 Receipt of 5th Production Set | 210d | 2010-05-25 | 2011-03-31 | 131122065K FS-187d | 203d |
| 131122065N |  | Vend Fab - Warm Tuners Peg Point #10 Receipt of 6th Production Set | 231d | 2010-05-25 | 2011-04-29 | 131122065L FS-210d | 255d |
| 131122065P |  | Vend Fab - Warm Tuners Peg Point #11 Receipt of 7th Production Set | 274d | 2010-05-25 | 2011-06-30 | 131122065N FS-231d | 310d |
| 131122065Q |  | Vend Fab - Warm Tuners Peg Point #12 Receipt of 8th Production Set | 294d | 2010-05-25 | 2011-07-29 | 131122065P FS-274d | 358d |
| 131122065R |  | Vend Fab - Warm Tuners Peg Point #13 Receipt of R100 Production Set | 317d | 2010-05-25 | 2011-08-31 | 131122065Q FS-294d | 429d |
| 131122040 |  | Receive & Insp Tuners Lot #5 41-50 | 20d | 2010-06-01 | 2010-06-28 | 131122016 FS-80d, 131122035, 131122016H | 389d |
| 131122045 |  | Receive & Insp Tuners Lot #6 51-60 | 20d | 2010-07-01 | 2010-07-29 | 131122016 FS-60d, 131122040, 131122016J | 425d |
| 131122065A |  | Vend Fab - Warm Tuners Lot # 1 Reverse Entry Per CR 10-064 | 1d | 2010-07-01 | 2010-07-01 | 9-100M FS+184d | 217d |
| 131122050 |  | Receive & Insp Tuners Lot #7 61-70 | 20d | 2010-08-02 | 2010-08-27 | 131122016K, 131122045, 131122016 FS-40d | 513d |
| 131122055 |  | Receive & Insp Tuners Lot #8 71-80 | 20d | 2010-09-01 | 2010-09-29 | 131122016L, 131122050, 131122016 FS-20d | 570d |
| 131122060 |  | Receive & Insp Tuners Lot #9 81-84 | 20d | 2010-10-01 | 2010-10-28 | 131122016, 131122055, 131122016N | 572d |
| 131122070 |  | Recieve & Inspect Warm Tuners - First Article | 20d | 2010-10-01 | 2010-10-28 | 131122065F, 131122065 FS+4d | 104d |
| 131122075 |  | Recieve & Inspect Warm Tuners - 1st Production Set | 20d | 2010-11-01 | 2010-11-30 | 131122065G, 131122070 | 103d |
| 131122080 |  | Recieve & Inspect Warm Tuners - 2nd Production Set | 20d | 2010-12-01 | 2011-01-05 | 131122065H, 131122065A | 113d |
| 131122085 |  | Recieve & Inspect Warm Tuners - 3rd Production Set | 20d | 2011-01-06 | 2011-02-03 | 131122080, 131122065J | 186d |
| 131122090 |  | Recieve & Inspect Warm Tuners - 4th Production Set | 20d | 2011-03-01 | 2011-03-28 | 131122065B, 131122065K | 166d |
| 131122095 |  | Recieve & Inspect Warm Tuners - 5th Production Set | 20d | 2011-04-01 | 2011-04-28 | 131122065L, 131122090 | 203d |
| 131122100 |  | Recieve & Inspect Warm Tuners - 6th Production Set | 20d | 2011-05-02 | 2011-05-27 | 131122065N | 255d |
| 131122105 |  | Recieve & Inspect Warm Tuners - 7th Production Set | 20d | 2011-07-01 | 2011-07-29 | 131122065P | 310d |
| 131122110 |  | Recieve & Inspect Warm Tuners - 8th Production Set | 20d | 2011-08-01 | 2011-08-26 | 131122065Q | 358d |
| 131122115 |  | Re-Baseline Actuals Adjustment | 1d | 2013-08-30 | 2013-08-30 | 9-130M FS+227d | 20d |
|  | 3 | **1.3.1.1.2.3 HELIUM HEADERS** |  | 2009-04-01 | 2013-08-30 |  |  |
| 131123010 |  | Proc Helium Headers | 65d | 2009-04-01 | 2009-07-01 | 9-090M FS+120d | 311d |
| 131123015 |  | Vend Fab - Helium Headers Lot #1, 2 & 3 (Phase 1) | 27d | 2009-07-01 | 2009-08-07 | 131123010 FS-1d | 345d |
| 131123016 |  | Vend Fab - Helium Headers Lot #1, 2 & 3 (Phase 2) FY09 Labor | 37d | 2009-08-10 | 2009-09-30 | 131123015 | 458d |
| 131123016c |  | Vend Fab - Helium Headers Lot #1, 2 & 3 (Phase 2) Procurement | 80d | 2009-08-10 | 2009-12-02 | 131123015 | 458d |
| 131123016b |  | Vend Fab - Helium Headers Lot #1, 2 & 3 (Phase 2) FY10 Labor | 43d | 2009-10-01 | 2009-12-02 | 131123016 | 458d |
| 131123020 |  | Receive & Insp Helium Headers Lot #1 1-3 | 20d | 2009-10-05 | 2009-10-30 | 131123010, 131123015 FS+39d | 345d |
| 131123025 |  | Receive & Insp Helium Headers Lot #2 4-7 | 20d | 2009-11-02 | 2009-12-01 | 131123020, 131123015 FS-20d | 474d |
| 131123030 |  | Receive & Insp Helium Headers Lot #3 8-10 | 20d | 2009-12-02 | 2010-01-06 | 131123015, 131123025 | 755d |
| 131123016d |  | Vend Fab 10 CFR 851 Compliance | 5d | 2010-07-02 | 2010-07-09 | 131123010 FS+248d | 311d |
| 131123035 |  | Re-Baseline Actuals Adjustment | 1d | 2013-08-30 | 2013-08-30 | 9-130M FS+227d | 20d |
|  | 3 | **1.3.1.1.3 CRYOMODULE PROCUREMENTS** |  | 2009-01-02 | 2013-08-30 |  |  |
|  | 1 | **1.3.1.1.3.1 MLI** |  | 2009-03-02 | 2013-08-30 |  |  |
| 131131010 |  | Proc MLI | 65d | 2009-03-02 | 2009-06-01 | 9-090M FS+98d | 390d |
| 131131015 |  | Vend Fab - MLI (Phase 1) | 20d | 2009-06-01 | 2009-06-26 | 131131010 FS-1d | 390d |
| 131131016 |  | Vend Fab - MLI (Phase 2) | 56d | 2009-06-29 | 2009-09-16 | 131131015 | 543d |
| 131131020 |  | Receive & Insp MLI (Phase 1) | 28d | 2009-06-29 | 2009-08-06 | 131131015 | 390d |

| ID | WBS | Task | Duration | Start | Finish | Predecessors | Total float |
| --- | --- | --- | --- | --- | --- | --- | --- |
| 131131021 |  | Receive & Insp MLI (Phase 2) FY09 | 10d | 2009-09-17 | 2009-09-30 | 131131016 | 543d |
| 131131021b |  | Receive & Insp MLI (Phase 2) FY10 | 18d | 2009-10-01 | 2009-10-26 | 131131021 | 543d |
| 131131025 |  | Re-Baseline Actuals Adjustment | 1d | 2013-08-30 | 2013-08-30 | 9-130M FS+227d | 20d |
|  | 2 | **1.3.1.1.3.2 THERMAL SHIELD** |  | 2009-02-02 | 2013-08-30 |  |  |
| 131132010 |  | Proc Thermal Shield | 149d | 2009-02-02 | 2009-09-01 | 9-090M FS+79d | 243d |
| 131132015 |  | Vend Fab - Thermal Shield Lot #1 (Phase 1) Labor FY09 | 21d | 2009-09-01 | 2009-09-30 | 131132010 FS-1d | 243d |
| 131132015c |  | Vend Fab - Thermal Shield Lot #1 (Phase 1) Procurement | 120d | 2009-09-01 | 2010-03-02 | 131132010 FS-1d | 243d |
| 131132015b |  | Vend Fab - Thermal Shield Lot #1 (Phase 1) Labor FY10 | 99d | 2009-10-01 | 2010-03-02 | 131132015 | 243d |
| 131132016 |  | Vend Fab - Thermal Shield Lot #2 & 3 (Phase 2) | 120d | 2010-03-03 | 2010-08-19 | 131132015b, 131132015c | 337d |
| 131132020 |  | Receive & Insp Thermal Shield Lot #1 1-3 | 30d | 2010-03-03 | 2010-04-13 | 131132015b, 131132015c | 243d |
| 131132025 |  | Receive & Insp Thermal Shield Lot #2 4-7 | 30d | 2010-05-26 | 2010-07-08 | 131132020, 131132016 FS-60d | 337d |
| 131132030 |  | Receive & Insp Thermal Shield Lot #3 8-10 FY10 | 29d | 2010-08-20 | 2010-09-30 | 131132025, 131132016 | 548d |
| 131132030a |  | Receive & Insp Thermal Shield Lot #3 8-10 FY11 | 1d | 2010-10-01 | 2010-10-01 | 131132030 | 548d |
| 131132035 |  | Re-Baseline Actuals Adjustment | 1d | 2013-08-30 | 2013-08-30 | 9-130M FS+227d | 20d |
|  | 3 | **1.3.1.1.3.3 MAGNETIC SHIELD** |  | 2009-01-02 | 2013-08-30 |  |  |
| 131133010 |  | Prcrmnt Prep for Magnetic Shield | 28d | 2009-01-02 | 2009-02-11 | 131133010XD | 101d |
| 131133015 |  | Vend Fab - Magnetic Shield Lot #1 (Phase 1) | 150d | 2009-02-11 | 2009-09-14 | 131133010 FS-1d | 101d |
| 131133016 |  | Vend Fab - Magnetic Shield Lot #2 & 3 (Phase 2) Labor FY09 | 12d | 2009-09-15 | 2009-09-30 | 131133015 | 242d |
| 131133016b |  | Vend Fab - Magnetic Shield Lot #2 & 3 (Phase 2) Labor FY10 | 108d | 2009-10-01 | 2010-03-15 | 131133016 | 242d |
| 131133020 |  | Receive & Insp Inner Magnetic Shield First Article Set | 20d | 2010-01-12 | 2010-02-09 | 131133016c FS-162d, 131133015 FS+77d, 131133010 | 282d |
| 131133015a |  | Vend Fab - Magnetic Shield Lot #1 (Phase 1) Reverse Entry Per CR10-064 ETC | 1d | 2010-07-01 | 2010-07-01 | 9-100M FS+184d | 182d |
| 131133016c |  | Vend Fab - Inner Magnetic Shield- First Article Set | 43d | 2010-07-01 | 2010-08-31 | 131133015 FS+196d | 119d |
| 131133016c1 |  | Vend Fab - Inner Magnetic Shield Set #2 | 64d | 2010-07-01 | 2010-09-30 | 131133016c FS-43d | 119d |
| 131133017 |  | Vend Fab - Inner Magnetic Shield Set #3 | 105d | 2010-07-01 | 2010-11-30 | 131133016c1 FS-64d | 176d |
| 131133017A |  | Vend Fab - Inner Magnetic Shield Set #4 | 105d | 2010-07-01 | 2010-11-30 | 131133017 FS-105d | 192d |
| 131133017B |  | Vend Fab - Inner Magnetic Shield Set #5 | 122d | 2010-07-01 | 2010-12-30 | 131133017A FS-105d | 235d |
| 131133017C |  | Vend Fab - Inner Magnetic Shield Set #6 | 142d | 2010-07-01 | 2011-01-31 | 131133017B FS-122d | 278d |
| 131133017D |  | Vend Fab - Inner Magnetic Shield Set #7 | 161d | 2010-07-01 | 2011-02-28 | 131133017C FS-142d | 373d |
| 131133017F |  | Vend Fab - Inner Magnetic Shield Set #8 | 184d | 2010-07-01 | 2011-03-31 | 131133017D FS-161d | 409d |
| 131133017G |  | Vend Fab - Inner Magnetic Shield Set #9 | 205d | 2010-07-01 | 2011-04-29 | 131133017F FS-184d | 421d |
| 131133017H |  | Vend Fab - Inner Magnetic Shield Set #10 | 226d | 2010-07-01 | 2011-05-31 | 131133017G FS-205d | 435d |
| 131133018 |  | Vend Fab - Outer Magnetic Shield First Article Set | 85d | 2010-07-01 | 2010-10-29 | 131133015 FS+196d | 101d |
| 131133018A |  | Vend Fab - Outer Magnetic Shield Receipt of Materials | 122d | 2010-07-01 | 2010-12-30 | 131133018 FS-85d | 101d |
| 131133018B |  | Vend Fab - Outer Magnetic Shield Set #2 | 122d | 2010-07-01 | 2010-12-30 | 131133018A FS-122d | 101d |
| 131133018C |  | Vend Fab - Outer Magnetic Shield Set #3 | 161d | 2010-07-01 | 2011-02-28 | 131133018B FS-122d | 143d |
| 131133018D |  | Vend Fab - Outer Magnetic Shield Set #4 | 184d | 2010-07-01 | 2011-03-31 | 131133018C FS-161d | 143d |
| 131133018F |  | Vend Fab - Outer Magnetic Shield Set #5 | 205d | 2010-07-01 | 2011-04-29 | 131133018D FS-184d | 182d |
| 131133018G |  | Vend Fab - Outer Magnetic Shield Set #6 | 226d | 2010-07-01 | 2011-05-31 | 131133018F FS-205d | 234d |
| 131133018H |  | Vend Fab - Outer Magnetic Shield Set #7 | 248d | 2010-07-01 | 2011-06-30 | 131133018G FS-226d | 310d |
| 131133018J |  | Vend Fab - Outer Magnetic Shield Set #8 | 268d | 2010-07-01 | 2011-07-29 | 131133018H FS-248d | 358d |
| 131133018K |  | Vend Fab - Outer Magnetic Shield Set #9 | 291d | 2010-07-01 | 2011-08-31 | 131133018J FS-268d | 379d |
| 131133018L |  | Vend Fab - Outer Magnetic Shield Set #10 | 308d | 2010-07-01 | 2011-09-26 | 131133018K FS-291d | 392d |
| 131133120LOE |  | SOTR Oversight FY10 | 64d | 2010-07-01 | 2010-09-30 | 9-100M FS+184d | 392d |
| 131133025 |  | Receive & Insp Inner Magnetic Shield Set #2 | 20d | 2010-10-01 | 2010-10-28 | 131133016c1, 131133015a, 131133016b FS+17d | 119d |
| 131133125LOE |  | SOTR Oversight FY11 | 248d | 2010-10-01 | 2011-09-30 | 131133120LOE | 392d |
| 131133070 |  | Receive & Insp Outer Magnetic Shield First Article Set | 20d | 2010-11-01 | 2010-11-30 | 131133018 | 103d |
| 131133030 |  | Receive & Insp Inner Magnetic Shield Set #3 | 20d | 2010-12-01 | 2011-01-05 | 131133017, 131133016b FS+77d | 176d |
| 131133035 |  | Receive & Insp Inner Magnetic Shield Set #4 | 20d | 2010-12-01 | 2011-01-05 | 131133017A | 192d |
| 131133075 |  | Receive & Insp Outer Magnetic Shield Set #2 | 20d | 2010-12-17 | 2011-01-24 | 131133018B FS-5d | 101d |
| 131133040 |  | Receive & Insp Inner Magnetic Shield Set #5 | 20d | 2010-12-31 | 2011-01-31 | 131133017B | 235d |
| 131133045 |  | Receive & Insp Inner Magnetic Shield Set #6 | 20d | 2011-02-01 | 2011-03-01 | 131133017C | 278d |
| 131133050 |  | Receive & Insp Inner Magnetic Shield Set #7 | 20d | 2011-03-01 | 2011-03-28 | 131133017D | 373d |
| 131133080 |  | Receive & Insp Outer Magnetic Shield Set #3 | 20d | 2011-03-01 | 2011-03-28 | 131133018C | 150d |
| 131133055 |  | Receive & Insp Inner Magnetic Shield Set #8 | 20d | 2011-04-01 | 2011-04-28 | 131133017F | 409d |
| 131133085 |  | Receive & Insp Outer Magnetic Shield Set #4 | 20d | 2011-04-01 | 2011-04-28 | 131133018D | 143d |
| 131133060 |  | Receive & Insp Inner Magnetic Shield Set #9 | 20d | 2011-05-02 | 2011-05-27 | 131133017G | 421d |
| 131133090 |  | Receive & Insp Outer Magnetic Shield Set #5 | 20d | 2011-05-02 | 2011-05-27 | 131133018F | 182d |
| 131133065 |  | Receive & Insp Inner Magnetic Shield Set #10 | 20d | 2011-06-01 | 2011-06-28 | 131133017H | 435d |
| 131133095 |  | Receive & Insp Outer Magnetic Shield Set #6 | 20d | 2011-06-01 | 2011-06-28 | 131133018G | 234d |
| 131133100 |  | Receive & Insp Outer Magnetic Shield Set #7 | 20d | 2011-07-01 | 2011-07-29 | 131133018H | 310d |
| 131133105 |  | Receive & Insp Outer Magnetic Shield Set #8 | 20d | 2011-08-01 | 2011-08-26 | 131133018J | 358d |
| 131133110 |  | Receive & Insp Outer Magnetic Shield Set #9 | 20d | 2011-09-01 | 2011-09-29 | 131133018K | 379d |
| 131133115 |  | Receive & Insp Outer Magnetic Shield Set #10 FY11 | 4d | 2011-09-27 | 2011-09-30 | 131133018L | 392d |
| 131133115a |  | Receive & Insp Outer Magnetic Shield Set #10 FY12 | 16d | 2011-10-03 | 2011-10-24 | 131133115 | 392d |
| 131133130LOE |  | SOTR Oversight FY12 | 16d | 2011-10-03 | 2011-10-24 | 131133125LOE | 392d |
| 131133135 |  | Re-Baseline Actuals Adjustment | 1d | 2013-08-30 | 2013-08-30 | 9-130M FS+227d | 20d |
|  | 4 | **1.3.1.1.3.4 INSTRUMENTATION** |  | 2009-04-01 | 2013-08-30 |  |  |
| 131134010 |  | Proc Instrmenttn | 65d | 2009-04-01 | 2009-07-01 | 9-090M FS+120d | 276d |
| 131134012 |  | Vend Fab - Instrmenttn (Phase 1) Labor FY09 | 64d | 2009-07-01 | 2009-09-30 | 131134010 FS-1d | 276d |
| 131134012c |  | Vend Fab - Instrmenttn (Phase 1) Procurement | 120d | 2009-07-01 | 2009-12-28 | 131134010 FS-1d | 276d |

| ID | WBS | Task | Duration | Start | Finish | Predecessors | Total float |
| --- | --- | --- | --- | --- | --- | --- | --- |
| 131134012b |  | Vend Fab - Instrmenttn (Phase 1) Labor FY10 | 56d | 2009-10-01 | 2009-12-28 | 131134012 | 276d |
| 131134013 |  | Vend Fab - Instrmenttn (Phase 2) | 120d | 2009-12-29 | 2010-06-18 | 131134012b, 9-100M, 131134012c | 313d |
| 131134015 |  | Receive & Insp Instrmenttn (Phase 1) | 20d | 2009-12-29 | 2010-01-27 | 131134012c, 131134012b, 131134010 | 276d |
| 131134016 |  | Receive & Insp Instrmenttn (Phase 2) | 20d | 2010-06-21 | 2010-07-19 | 131134013 | 313d |
| 131134021LOE |  | SOTR Oversight | 64d | 2010-07-01 | 2010-09-30 | 9-100M FS+184d | 343d |
| 131134018 |  | Receive & Insp Instrmenttn (Phase 2) Additinal Hardware | 52d | 2010-07-20 | 2010-09-30 | 131134016 | 313d |
| 131134025 |  | Re-Baseline Actuals Adjustment | 1d | 2013-08-30 | 2013-08-30 | 9-130M FS+227d | 20d |
|  | 5 | **1.3.1.1.3.5 END CANS** |  | 2009-10-01 | 2013-08-30 |  |  |
| 131135010 |  | Proc End Cans | 80d | 2009-10-01 | 2010-02-02 | 1211020M10, 9-100M | -25d |
| 131135015 |  | Technical Oversight End Cans Procurement FY10 | 189d | 2010-01-04 | 2010-09-30 | 131135010 FS-21d | 515d |
| 131135015B |  | Vend Fab End Cans - Submittal of Project Q.A. Plan | 19d | 2010-01-04 | 2010-01-29 | 131135010 FS-21d | 114d |
| 131135015C |  | Vend Fab End Cans - Material P.O. for End Can sets 1-3 | 83d | 2010-01-04 | 2010-04-30 | 131135015B FS-19d | 114d |
| 131135015D |  | Vend Fab End Cans - Material Receipt for End Can sets 4-6 | 168d | 2010-01-04 | 2010-08-31 | 131135015C FS-83d | 114d |
| 131135015F |  | Vend Fab End Cans - Material P.O. for End Can sets 7-8 | 210d | 2010-01-04 | 2010-10-29 | 131135015D FS-168d | 114d |
| 131135015G |  | Vend Fab End Cans - Material Receipt for End Can sets 9-10 | 247d | 2010-01-04 | 2010-12-30 | 131135015F FS-210d | 114d |
| 131135015H |  | Vend Fab End Cans - Delivery of Set #1 | 146d | 2010-01-04 | 2010-07-30 | 131135015G FS-247d | 114d |
| 131135015J |  | Vend Fab End Cans - Delivery of Set #2 | 189d | 2010-01-04 | 2010-09-30 | 131135015H FS-146d | 114d |
| 131135015K |  | Vend Fab End Cans - Delivery of Set #3 | 189d | 2010-01-04 | 2010-09-30 | 131135015J FS-189d | 182d |
| 131135015N |  | Vend Fab End Cans - Delivery of Set #4 | 230d | 2010-01-04 | 2010-11-30 | 131135015K FS-189d | 182d |
| 131135015O |  | Vend Fab End Cans - Delivery of Set #5 | 230d | 2010-01-04 | 2010-11-30 | 131135015N FS-230d | 242d |
| 131135015P |  | Vend Fab End Cans - Delivery of Set #6 | 248d | 2010-01-04 | 2010-12-31 | 131135015O FS-230d | 297d |
| 131135015Q |  | Vend Fab End Cans - Delivery of Set #7 | 267d | 2010-01-05 | 2011-02-01 | 131135015P FS-247d | 375d |
| 131135015R |  | Vend Fab End Cans - Delivery of Set #8 | 267d | 2010-01-05 | 2011-02-01 | 131135015Q FS-267d | 443d |
| 131135015S |  | Vend Fab End Cans - Delivery of Set #9 | 309d | 2010-01-05 | 2011-04-01 | 131135015R FS-267d | 445d |
| 131135015T |  | Vend Fab End Cans - Delivery of Set #10 | 330d | 2010-01-05 | 2011-05-02 | 131135015S FS-309d | 454d |
| 131135016 |  | Electronic Valve Actuators | 5d | 2010-07-01 | 2010-07-08 | 131135010 FS+104d | 655d |
| 131135017 |  | Additional End Can Hardware | 5d | 2010-07-01 | 2010-07-08 | 131135010 FS+104d | 655d |
| 131135020 |  | Receive & Insp End Cans Set #1 FY10 | 43d | 2010-08-02 | 2010-09-30 | 131135015H | 127d |
| 131135015A |  | Technical Oversight End Cans Procurement FY11 | 141d | 2010-10-01 | 2011-04-29 | 131135015 | 515d |
| 131135020a |  | Receive & Insp End Cans Set #1 FY11 | 17d | 2010-10-01 | 2010-10-25 | 131135020 | 127d |
| 131135025 |  | Receive & Insp End Cans Set #2 | 60d | 2010-10-01 | 2011-01-04 | 131135015J | 114d |
| 131135030 |  | Receive & Insp End Cans Set #3 | 60d | 2010-10-01 | 2011-01-04 | 131135015K | 207d |
| 131135035 |  | Receive & Insp End Cans Set #4 | 60d | 2010-12-01 | 2011-03-04 | 131135015N | 182d |
| 131135040 |  | Receive & Insp End Cans Set #5 | 60d | 2010-12-01 | 2011-03-04 | 131135015O | 242d |
| 131135045 |  | Receive & Insp End Cans Set #6 | 60d | 2011-01-04 | 2011-03-30 | 131135015P | 297d |
| 131135050 |  | Receive & Insp End Cans Set #7 | 60d | 2011-02-02 | 2011-04-27 | 131135015Q | 375d |
| 131135055 |  | Receive & Insp End Cans Set #8 | 60d | 2011-02-02 | 2011-04-27 | 131135015R | 443d |
| 131135060 |  | Receive & Insp End Cans Set #9 | 60d | 2011-04-04 | 2011-06-27 | 131135015S | 445d |
| 131135065 |  | Receive & Insp End Cans Set #10 | 60d | 2011-05-03 | 2011-07-27 | 131135015A FS-60d, 131135016, 131135017, 131135015T | 454d |
| 131135070 |  | Re-Baseline Actuals Adjustment | 1d | 2013-08-30 | 2013-08-30 | 9-130M FS+227d | 20d |
|  | 6 | **1.3.1.1.3.6 VACUUM VESSELS** |  | 2009-11-02 | 2013-08-30 |  |  |
| 131136010 |  | Proc Vac Vessels | 1d | 2009-11-02 | 2009-11-02 | 9-100M FS+22d | 17d |
| 131136016 |  | Vend Fab - Vac Vessels Peg Point #1 Materials | 39d | 2009-11-25 | 2010-01-29 | 9-100M FS+39d | 174d |
| 131136016a |  | Vend Fab - Vac Vessels Peg Point #2 Acceptance of First Article | 103d | 2009-11-25 | 2010-04-30 | 131136016 FS-39d | 174d |
| 131136016b |  | Vend Fab - Vac Vessels Peg Point #4 Completion of Production components prior to Welding | 103d | 2009-11-25 | 2010-04-30 | 131136016a FS-103d | 174d |
| 131136016c |  | Vend Fab - Vac Vessels Peg Point #3 First Article Shipped | 145d | 2009-11-25 | 2010-06-30 | 131136016b FS-103d | 174d |
| 131136016d |  | Vend Fab - Vac Vessels Peg Point #5 Vacuum Vessel Assembly #2 Shipped | 188d | 2009-11-25 | 2010-08-31 | 131136016c FS-145d | 174d |
| 131136016f |  | Vend Fab - Vac Vessels Peg Point #6 Vacuum Vessel Assembly #3 Shipped | 209d | 2009-11-25 | 2010-09-30 | 131136016d FS-188d | 242d |
| 131136016g |  | Vend Fab - Vac Vessels Peg Point #7 Vacuum Vessel Assembly #4 Shipped | 230d | 2009-11-25 | 2010-10-29 | 131136016f FS-209d | 242d |
| 131136016h |  | Vend Fab - Vac Vessels Peg Point #8 Vacuum Vessel Assembly #5 Shipped | 250d | 2009-11-25 | 2010-11-30 | 131136016g FS-230d | 279d |
| 131136016j |  | Vend Fab - Vac Vessels Peg Point #9 Vacuum Vessel Assembly #6 Shipped | 287d | 2009-11-25 | 2011-01-31 | 131136016h FS-250d | 319d |
| 131136016k |  | Vend Fab - Vac Vessels Peg Point #10 Vacuum Vessel Assembly #7 Shipped | 306d | 2009-11-25 | 2011-02-28 | 131136016j FS-287d | 394d |
| 131136016n |  | Vend Fab - Vac Vessels Peg Point #11 Vacuum Vessel Assembly #8 Shipped | 329d | 2009-11-25 | 2011-03-31 | 131136016k FS-306d | 441d |
| 131136016o |  | Vend Fab - Vac Vessels Peg Point #12 Vacuum Vessel Assembly #9 Shipped | 350d | 2009-11-25 | 2011-04-29 | 131136016n FS-329d | 464d |
| 131136016p |  | Vend Fab - Vac Vessels Peg Point #13 Vacuum Vessel Assembly #10 Shipped | 371d | 2009-11-25 | 2011-05-31 | 131136016o FS-350d | 472d |
| 131136015 |  | Vend Fab - Vac Vessels Lot #1 Original Labor FY10 | 146d | 2010-03-08 | 2010-09-30 | 9-100M FS+102d | 197d |
| 131136017 |  | Vend Fab Insulating Vac Components and Hardware | 5d | 2010-07-01 | 2010-07-08 | 131135010 FS+104d | 693d |
| 131136020 |  | Receive & Insp Vac Vessels First Article | 21d | 2010-07-01 | 2010-07-30 | 131136016c, 131136015a FS-69d | 196d |
| 131136025 |  | Receive & Insp Vac Vessel Assembly #2 | 21d | 2010-09-01 | 2010-09-30 | 131136020, 131136016d | 174d |
| 131136015a |  | Vend Fab - Vac Vessels Lot #1 Original Labor FY11 | 4d | 2010-10-01 | 2010-10-06 | 131136015 | 197d |
| 131136030 |  | Receive & Insp Vac Vessels Assembly #3 | 21d | 2010-10-01 | 2010-10-29 | 131136025, 131136016f | 242d |
| 131136035 |  | Receive & Insp Vac Vessels Assembly #4 | 20d | 2010-11-01 | 2010-11-30 | 131136030, 131136016g | 242d |
| 131136040 |  | Receive & Insp Vac Vessels Assembly #5 | 23d | 2010-12-01 | 2011-01-10 | 131136016h, 131136035 | 279d |
| 131136045 |  | Receive & Insp Vac Vessels Assembly #6 | 19d | 2011-02-01 | 2011-02-28 | 131136016j, 131136040 | 319d |
| 131136050 |  | Receive & Insp Vac Vessels Assembly #7 | 23d | 2011-03-01 | 2011-03-31 | 131136016k, 131136045 | 394d |
| 131136055 |  | Receive & Insp Vac Vessels Assembly #8 | 21d | 2011-04-01 | 2011-04-29 | 131136050, 131136016n | 441d |
| 131136060 |  | Receive & Insp Vac Vessels Assembly #9 | 21d | 2011-05-02 | 2011-05-31 | 131136055, 131136016o | 464d |
| 131136065 |  | Receive & Insp Vac Vessels Assembly #10 | 22d | 2011-06-01 | 2011-06-30 | 131136060, 131136016p, 131136017 | 472d |
| 131136070 |  | Re-Baseline Actuals Adjustment | 1d | 2013-08-30 | 2013-08-30 | 9-130M FS+227d | 20d |
|  | 7 | **1.3.1.1.3.7 BEAM PIPES** |  | 2009-09-25 | 2013-08-30 |  |  |

| ID | WBS | Task | Duration | Start | Finish | Predecessors | Total float |
| --- | --- | --- | --- | --- | --- | --- | --- |
| 131137010 |  | Proc Beam Pipes Labor FY09 | 4d | 2009-09-25 | 2009-09-30 | 9-100M FS-4d | 176d |
| 131137012 |  | Vend Fab - Cold Valves 1-4 | 101d | 2009-09-25 | 2010-02-26 | 9-100M FS-4d | 144d |
| 131137013 |  | Vend Fab - Cold Valves 5-8 | 124d | 2009-09-25 | 2010-03-31 | 9-100M FS-4d | 144d |
| 131137014 |  | Vend Fab - Cold Valves 9-12 | 124d | 2009-09-25 | 2010-03-31 | 9-100M FS-4d | 144d |
| 131137015 |  | Vend Fab - Cold Valves 13-16 | 146d | 2009-09-25 | 2010-04-30 | 9-100M FS-4d | 144d |
| 131137016 |  | Vend Fab - Cold Valves 17-20 | 146d | 2009-09-25 | 2010-04-30 | 9-100M FS-4d | 144d |
| 131137017 |  | Vend Fab - Cold Valves 21-22 | 166d | 2009-09-25 | 2010-05-28 | 9-100M FS-4d | 144d |
| 131137010b |  | Proc Beam Pipes Labor FY10 | 97d | 2009-10-01 | 2010-02-26 | 131137010 | 176d |
| 131137011 |  | Vendor Fab Cold Valves - Oversight | 60d | 2009-10-01 | 2010-01-04 | 9-100M, 131137010b FS-101d | 172d |
| 131137025 |  | Vendor Fab Burst Disc | 97d | 2009-10-01 | 2010-02-26 | 9-100M | 272d |
| 131137045 |  | Vendor Fab Warm Valves | 181d | 2009-12-04 | 2010-08-27 | 9-100M FS+44d | 165d |
| 131137034 |  | Vendor Fab Warm to Cold Beam Pipe - Oversight | 165d | 2010-01-05 | 2010-08-27 | 9-100M FS+60d | 165d |
| 131137020 |  | Receive & Inspect Cold Valves | 74d | 2010-02-16 | 2010-05-28 | 131137017 FS-74d, 131137015 FS-54d, 131137011, 131137014 FS-32d, 131137016 FS-54d, 131137012 FS-9d, 131137013 FS-32d | 144d |
| 131137030 |  | Receive & Inspect Burst Disc | 23d | 2010-03-01 | 2010-03-31 | 131137025 | 272d |
| 131137050 |  | Receive & Inspect Warm Valves | 113d | 2010-03-24 | 2010-08-31 | 131137045 FS-111d | 165d |
| 131137040 |  | Receive & Inspect Warm to Cold Beam Pipe | 105d | 2010-04-05 | 2010-08-31 | 131137035 FS-184d, 131137034 FS-103d | 165d |
| 131137035 |  | Vendor Fab Warm to Cold Beam Pipe | 122d | 2010-07-01 | 2010-12-30 | 9-100M FS+184d | 165d |
| 131137055 |  | Re-Baseline Actuals Adjustment | 1d | 2013-08-30 | 2013-08-30 | 9-130M FS+227d | 20d |
|  | 8 | **1.3.1.1.3.8 TOP HATS** |  | 2009-05-13 | 2013-08-30 |  |  |
| 131138010 |  | Proc Top Hats Air Side FPC Components | 60d | 2009-05-13 | 2009-08-06 | 9-090M FS+150d | 135d |
| 131138015 |  | Vend Fab - Warm Windows Labor FY09 | 38d | 2009-08-07 | 2009-09-30 | 131138010 | 287d |
| 131138015c |  | Vend Fab - Warm Windows Lot 1 and 2 | 200d | 2009-08-07 | 2010-05-28 | 131138010 | 223d |
| 131138015b |  | Vend Fab - Warm Windows Labor FY10 Initial | 41d | 2009-10-01 | 2009-11-30 | 131138015 | 287d |
| 131138025 |  | Vendor Fab Vacuum Components Labor Initial | 39d | 2009-10-05 | 2009-11-30 | 131138010 FS+40d | 144d |
| 131138025a5 |  | Vendor Fab Vacuum Components Labor Procurement | 225d | 2009-10-05 | 2010-08-31 | 131138010 FS+40d | 144d |
| 131138035 |  | Support for Diagnostic Components Procurement | 60d | 2009-10-05 | 2010-01-06 | 131138010 FS+40d | 223d |
| 131138015ba |  | Vend Fab - Warm Windows Labor FY10 Final | 207d | 2009-12-01 | 2010-09-30 | 131138015b | 287d |
| 131138025a |  | Vendor Fab Vacuum Components Labor Final | 186d | 2009-12-01 | 2010-08-31 | 131138025 | 144d |
| 131138037 |  | Diagnostic Components Procurement Lots 1 thru 4 | 168d | 2010-01-04 | 2010-08-31 | 131138010 FS+40d, 9-100M FS+59d | 78d |
| 131138030 |  | Receive & Insp Vacuum Components | 166d | 2010-02-05 | 2010-09-30 | 131138025a5 FS-145d, 131138025a FS-145d | 144d |
| 131138020 |  | Receive & Insp Warm Windows Lot 1 | 22d | 2010-06-01 | 2010-06-30 | 131138015ba FS-150d, 131138015c | 223d |
| 131138020a |  | Acceptance Warm Windows Phase 1 | 1d | 2010-06-30 | 2010-06-30 | 131138020 FS-1d | 317d |
| 131138020b |  | Receive & Insp Warm Windows Lot 2 FY10 | 64d | 2010-07-01 | 2010-09-30 | 131138020, 131138015c, 131138020a | 317d |
| 131138060LOE |  | SOTR Oversight FY10 | 64d | 2010-07-01 | 2010-09-30 | 9-100M FS+184d | 435d |
| 131138015d |  | Vend Fab - Warm Windows Lot 3 and 4 | 248d | 2010-07-30 | 2011-07-29 | 9-100M FS+204d | 398d |
| 131138015f |  | Vend Fab - Warm Windows Coatings | 248d | 2010-07-30 | 2011-07-29 | 9-100M FS+204d | 398d |
| 131138040 |  | Receive & Insp Diagnostic Components Lot 1 | 21d | 2010-08-04 | 2010-09-01 | 131138010, 131138037 FS-20d, 131138035 | 78d |
| 131138045 |  | Receive & Insp Diagnostic Components Lot 2 FY10 | 20d | 2010-09-02 | 2010-09-30 | 131138040 | 237d |
| 131138020ba |  | Receive & Insp Warm Windows Lot 2 FY11 | 26d | 2010-10-01 | 2010-11-05 | 131138020b | 317d |
| 131138045a |  | Receive & Insp Diagnostic Components Lot 2 FY11 | 5d | 2010-10-01 | 2010-10-07 | 131138045 | 237d |
| 131138065LOE |  | SOTR Oversight FY11 | 221d | 2010-10-01 | 2011-08-23 | 131138060LOE | 435d |
| 131138050 |  | Receive & Insp Diagnostic Components Lot 3 | 25d | 2010-10-08 | 2010-11-11 | 131138045a | 308d |
| 131138020d |  | Receive & Insp Warm Windows Lot 3 | 90d | 2010-11-08 | 2011-03-25 | 131138015d FS-178d, 131138015f FS-178d | 398d |
| 131138055 |  | Receive & Insp Diagnostic Components Lot 4 | 25d | 2010-11-12 | 2010-12-20 | 131138050 | 334d |
| 131138020g |  | Receive & Insp Warm Windows Lot 4 | 90d | 2011-04-18 | 2011-08-23 | 131138015f FS-73d, 131138015d FS-73d | 405d |
| 131138070 |  | Re-Baseline Actuals Adjustment | 1d | 2013-08-30 | 2013-08-30 | 9-130M FS+227d | 20d |
|  | 9 | **1.3.1.1.3.9 SUPPORTS** |  | 2009-10-01 | 2013-08-30 |  |  |
| 131139010 |  | Proc Supprts | 50d | 2009-10-01 | 2009-12-11 | 9-100M | 261d |
| 131139015 |  | Vend Fab - Supprts | 65d | 2009-12-14 | 2010-03-24 | 131139010 | 261d |
| 131139025 |  | Receive & Insp Supprts | 16d | 2010-03-25 | 2010-04-15 | 131139015, 131139020 FS-80d | 261d |
| 131139020 |  | Additional Support Baseplates | 5d | 2010-07-12 | 2010-07-16 | 131139010 FS+140d | 261d |
| 131139030 |  | Re-Baseline Actuals Adjustment | 1d | 2013-08-30 | 2013-08-30 | 9-130M FS+227d | 20d |
|  | 4 | **1.3.1.1.4 INSTALLATION AND ASSEMBLY TOOLING PROCUREMENTS** |  | 2009-10-01 | 2013-08-30 |  |  |
| 13114010 |  | Vend Fab - Installtn & Assy Tooling | 120d | 2009-10-01 | 2010-03-31 | 9-100M, 1211020M15 | 212d |
| 13114015 |  | Receive & Insp Installtn & Assy Tooling | 20d | 2010-04-01 | 2010-04-28 | 13114010 | 212d |
| 13114012 |  | Vend Fab - Installtn & Assy Tooling Phase 2 | 64d | 2010-07-01 | 2010-09-30 | 9-100M FS+184d | 79d |
| 13114020 |  | Receive & Insp Installtn & Assy Tooling Phase 2 FY10 | 15d | 2010-09-10 | 2010-09-30 | 13114012 FS-15d | 79d |
| 13114020a |  | Receive & Insp Installtn & Assy Tooling Phase 2 FY11 | 25d | 2010-10-01 | 2010-11-04 | 13114020 | 79d |
| 13114025 |  | Re-Baseline Actuals Adjustment | 1d | 2013-08-30 | 2013-08-30 | 9-130M FS+227d | 20d |
|  | 4 | **1.3.1.1.4.4 INSTALLATION AND ASSEMBLY TOOLING** |  |  |  |  |  |
|  | 5 | **1.3.1.1.5 CRYOMODULE TEST INSTRUMENTATION & INTERLOCKS PROCUREMENT** |  | 2009-10-01 | 2010-02-02 |  |  |
| 13115010 |  | Vend Fab - Instrmenttn & Interlocks | 60d | 2009-10-01 | 2010-01-04 | 9-100M | 312d |
| 13115015 |  | Receive & Insp Instrmenttn & Interlocks | 20d | 2010-01-05 | 2010-02-02 | 13115010 | 312d |
|  | 5 | **1.3.1.1.5.5 INSTRUMENTATION & INTERLOCKS** |  |  |  |  |  |
|  | 2 | **1.3.1.2 CAVITY STRING ASSEMBLY** |  | 2010-08-05 | 2013-08-30 |  |  |
| 1312000 |  | Re-Baseline Actuals Adjustment | 1d | 2013-08-30 | 2013-08-30 | 9-130M FS+227d | 20d |
|  | 1 | **1.3.1.2.1 CAVITY PREPARATION** |  | 2010-08-05 | 2011-11-16 |  |  |
|  | 01 | **1.3.1.2.1.01 CAVITY STRING #1 PREPERATION** |  | 2010-08-05 | 2010-11-05 |  |  |
| 1312101005 |  | Cavity String #1 Helium Vessel Welding | 15d | 2010-08-05 | 2010-08-25 | 131114070, 1311122010, 131114075, 1311122005 | 57d |
| 1312101030 |  | Cavity #1 VTA Run | 5d | 2010-09-10 | 2010-09-16 | 1317000, 1312101005 FS-10d | 37d |

| ID | WBS | Task | Duration | Start | Finish | Predecessors | Total float |
| --- | --- | --- | --- | --- | --- | --- | --- |
| 1312101035 |  | Cavity #2 VTA Run | 5d | 2010-09-15 | 2010-09-21 | 1312101030 FS-2d | 37d |
| 1312101040 |  | Cavity #3 VTA Run | 5d | 2010-09-20 | 2010-09-24 | 1312101035 FS-2d | 37d |
| 1312101045 |  | Cavity #4 VTA Run | 5d | 2010-09-23 | 2010-09-29 | 1312101040 FS-2d | 37d |
| 1312101050 |  | Cavity #5 VTA Run FY10 | 3d | 2010-09-28 | 2010-09-30 | 1312101045 FS-2d | 37d |
| 1312101050a |  | Cavity #5 VTA Run FY11 | 2d | 2010-10-01 | 2010-10-04 | 1312101050 | 37d |
| 1312101055 |  | Cavity #6 VTA Run | 5d | 2010-10-01 | 2010-10-07 | 1312101050a FS-2d | 37d |
| 1312101060 |  | Cavity #7 VTA Run | 5d | 2010-10-06 | 2010-10-12 | 1312101055 FS-2d | 37d |
| 1312101065 |  | Cavity #8 VTA Run | 5d | 2010-10-11 | 2010-10-15 | 1312101060 FS-2d | 37d |
| 1312101002 |  | Cavity String #1 Cavity Processing | 5d | 2010-11-01 | 2010-11-05 | 1311122005, 1311122010 FS+61d | 101d |
|  | 02 | **1.3.1.2.1.02 CAVITY STRING #2 PREPARATION** |  | 2010-10-08 | 2010-11-19 |  |  |
| 1312102005 |  | Cavity String #2 Helium Vessel Welding | 15d | 2010-10-08 | 2010-10-28 | 1311122020, 1311122015, 131114080, 1312101005 | 37d |
| 1312102030 |  | Cavity #9 VTA Run | 5d | 2010-10-15 | 2010-10-21 | 1312102005 FS-10d, 1312101065 FS-2d | 37d |
| 1312102035 |  | Cavity #10 VTA Run | 5d | 2010-10-20 | 2010-10-26 | 1312102030 FS-2d | 37d |
| 1312102040 |  | Cavity #11 VTA Run | 5d | 2010-10-25 | 2010-10-29 | 1312102035 FS-2d | 37d |
| 1312102045 |  | Cavity #12 VTA Run | 5d | 2010-10-28 | 2010-11-03 | 1312102040 FS-2d | 37d |
| 1312102050 |  | Cavity #13 VTA Run | 5d | 2010-11-02 | 2010-11-08 | 1312102045 FS-2d | 37d |
| 1312102055 |  | Cavity #14 VTA Run | 5d | 2010-11-05 | 2010-11-11 | 1312102050 FS-2d | 37d |
| 1312102002 |  | Cavity String #2 Cavity Processing | 5d | 2010-11-08 | 2010-11-12 | 1311122020, 1312101002, 1311122015 | 101d |
| 1312102060 |  | Cavity #15 VTA Run | 5d | 2010-11-10 | 2010-11-16 | 1312102055 FS-2d | 37d |
| 1312102065 |  | Cavity #16 VTA Run | 5d | 2010-11-15 | 2010-11-19 | 1312102060 FS-2d | 37d |
|  | 03 | **1.3.1.2.1.03 CAVITY STRING #3 PREPARATION** |  | 2010-11-15 | 2011-02-01 |  |  |
| 1312103005 |  | Cavity String #3 Cavity Process & He Vs Weld | 16d | 2010-11-15 | 2010-12-08 | 1311122022, 1312102002, 1312102005, 1311122025, 131114085 | 101d |
| 1312103030 |  | Cavity #17 VTA Run | 5d | 2010-11-23 | 2010-12-01 | 1312103005 FS-10d, 1312102065 FS-2d | 101d |
| 1312103035 |  | Cavity #18 VTA Run | 5d | 2010-11-30 | 2010-12-06 | 1312103030 FS-2d | 101d |
| 1312103040 |  | Cavity #19 VTA Run | 5d | 2010-12-03 | 2010-12-09 | 1312103035 FS-2d | 101d |
| 1312103045 |  | Cavity #20 VTA Run | 5d | 2010-12-08 | 2010-12-14 | 1312103040 FS-2d | 101d |
| 1312103050 |  | Cavity #21 VTA Run | 5d | 2010-12-13 | 2010-12-17 | 1312103045 FS-2d | 101d |
| 1312103055 |  | Cavity #22 VTA Run | 5d | 2011-01-18 | 2011-01-24 | 1312103050 FS-2d, 1317005 | 99d |
| 1312103060 |  | Cavity #23 VTA Run | 5d | 2011-01-21 | 2011-01-27 | 1312103055 FS-2d | 99d |
| 1312103065 |  | Cavity #24 VTA Run | 5d | 2011-01-26 | 2011-02-01 | 1312103060 FS-2d | 99d |
|  | 04 | **1.3.1.2.1.04 CAVITY STRING #4 PREPARATION** |  | 2010-12-09 | 2011-03-08 |  |  |
| 1312104005 |  | Cavity String #4 Cavity Process & He Vs Weld | 16d | 2010-12-09 | 2011-01-07 | 1311122030, 131114090, 1312103005, 1311122027 | 123d |
| 1312104030 |  | Cavity#25 VTA Run | 5d | 2011-01-31 | 2011-02-04 | 1312103065 FS-2d, 1312104005 FS-10d | 99d |
| 1312104035 |  | Cavity#26 VTA Run | 5d | 2011-02-03 | 2011-02-09 | 1312104030 FS-2d | 99d |
| 1312104040 |  | Cavity#27 VTA Run | 5d | 2011-02-08 | 2011-02-14 | 1312104035 FS-2d | 99d |
| 1312104045 |  | Cavity#28 VTA Run | 5d | 2011-02-11 | 2011-02-17 | 1312104040 FS-2d | 99d |
| 1312104050 |  | Cavity#29 VTA Run | 5d | 2011-02-16 | 2011-02-23 | 1312104045 FS-2d | 99d |
| 1312104055 |  | Cavity#30 VTA Run | 5d | 2011-02-22 | 2011-02-28 | 1312104050 FS-2d | 99d |
| 1312104060 |  | Cavity#31 VTA Run | 5d | 2011-02-25 | 2011-03-03 | 1312104055 FS-2d | 99d |
| 1312104065 |  | Cavity#32 VTA Run | 5d | 2011-03-02 | 2011-03-08 | 1312104060 FS-2d | 99d |
|  | 05 | **1.3.1.2.1.05 CAVITY STRING #5 PREPARATION** |  | 2011-02-15 | 2011-04-13 |  |  |
| 1312105005 |  | Cavity String #5 Cavity Process & He Vs Weld | 16d | 2011-02-15 | 2011-03-09 | 131114095, 1312104005, 1311122065, 1311122035 | 108d |
| 1312105030 |  | Cavity #33 VTA Run | 5d | 2011-03-09 | 2011-03-15 | 1312104065, 1312105005 FS-10d | 99d |
| 1312105035 |  | Cavity #34 VTA Run | 5d | 2011-03-14 | 2011-03-18 | 1312105030 FS-2d | 99d |
| 1312105040 |  | Cavity #35 VTA Run | 5d | 2011-03-17 | 2011-03-23 | 1312105035 FS-2d | 99d |
| 1312105045 |  | Cavity #36 VTA Run | 5d | 2011-03-22 | 2011-03-28 | 1312105040 FS-2d | 99d |
| 1312105050 |  | Cavity #37 VTA Run | 5d | 2011-03-25 | 2011-03-31 | 1312105045 FS-2d | 99d |
| 1312105055 |  | Cavity #38 VTA Run | 5d | 2011-03-30 | 2011-04-05 | 1312105050 FS-2d | 99d |
| 1312105060 |  | Cavity #39 VTA Run | 5d | 2011-04-04 | 2011-04-08 | 1312105055 FS-2d | 99d |
| 1312105065 |  | Cavity #40 VTA Run | 5d | 2011-04-07 | 2011-04-13 | 1312105060 FS-2d | 99d |
|  | 06 | **1.3.1.2.1.06 CAVITY STRING #6 PREPARATION** |  | 2011-03-21 | 2011-05-17 |  |  |
| 1312106005 |  | Cavity String #6 Cavity Process & He Vs Weld | 16d | 2011-03-21 | 2011-04-11 | 131114100, 1311122070, 1311122067, 1312105005 | 109d |
| 1312106030 |  | Cavity #41 VTA Run | 5d | 2011-04-12 | 2011-04-18 | 1312106005 FS-10d, 1312105065 FS-2d | 99d |
| 1312106035 |  | Cavity #42 VTA Run | 5d | 2011-04-15 | 2011-04-21 | 1312106030 FS-2d | 99d |
| 1312106040 |  | Cavity #43 VTA Run | 5d | 2011-04-20 | 2011-04-26 | 1312106035 FS-2d | 99d |
| 1312106045 |  | Cavity #44 VTA Run | 5d | 2011-04-25 | 2011-04-29 | 1312106040 FS-2d | 99d |
| 1312106050 |  | Cavity #45 VTA Run | 5d | 2011-04-28 | 2011-05-04 | 1312106045 FS-2d | 99d |
| 1312106055 |  | Cavity #46 VTA Run | 5d | 2011-05-03 | 2011-05-09 | 1312106050 FS-2d | 99d |
| 1312106060 |  | Cavity #47 VTA Run | 5d | 2011-05-06 | 2011-05-12 | 1312106055 FS-2d | 99d |
| 1312106065 |  | Cavity #48 VTA Run | 5d | 2011-05-11 | 2011-05-17 | 1312106060 FS-2d | 99d |
|  | 07 | **1.3.1.2.1.07 CAVITY STRING #7 PREPARATION** |  | 2011-04-20 | 2011-06-21 |  |  |
| 1312107005 |  | Cavity String #7 Cavity Process & He Vs Weld | 16d | 2011-04-20 | 2011-05-11 | 1312106005, 1311122075, 131114105, 1311122072 | 111d |
| 1312107030 |  | Cavity #49 VTA Run | 5d | 2011-05-16 | 2011-05-20 | 1312107005 FS-10d, 1312106065 FS-2d | 99d |
| 1312107035 |  | Cavity #50 VTA Run | 5d | 2011-05-19 | 2011-05-25 | 1312107030 FS-2d | 99d |
| 1312107040 |  | Cavity #51 VTA Run | 5d | 2011-05-24 | 2011-05-31 | 1312107035 FS-2d | 99d |
| 1312107045 |  | Cavity #52 VTA Run | 5d | 2011-05-27 | 2011-06-03 | 1312107040 FS-2d | 99d |
| 1312107050 |  | Cavity #53 VTA Run | 5d | 2011-06-02 | 2011-06-08 | 1312107045 FS-2d | 99d |
| 1312107055 |  | Cavity #54 VTA Run | 5d | 2011-06-07 | 2011-06-13 | 1312107050 FS-2d | 99d |
| 1312107060 |  | Cavity #55 VTA Run | 5d | 2011-06-10 | 2011-06-16 | 1312107055 FS-2d | 99d |
| 1312107065 |  | Cavity #56 VTA Run | 5d | 2011-06-15 | 2011-06-21 | 1312107060 FS-2d | 99d |

| ID | WBS | Task | Duration | Start | Finish | Predecessors | Total float |
| --- | --- | --- | --- | --- | --- | --- | --- |
|  | 08 | **1.3.1.2.1.08 CAVITY STRING #8 PREPARATION** |  | 2011-06-02 | 2011-08-26 |  |  |
| 1312108005 |  | Cavity String #8 Cavity Process & He Vs Weld | 16d | 2011-06-02 | 2011-06-23 | 1311122080, 1311122085, 1312107005, 131114110 | 105d |
| 1312108030 |  | Cavity #57 VTA Run | 5d | 2011-06-20 | 2011-06-24 | 1312108005 FS-10d, 1312107065 FS-2d | 99d |
| 1312108035 |  | Cavity #58 VTA Run | 5d | 2011-06-23 | 2011-06-29 | 1312108030 FS-2d | 99d |
| 1312108040 |  | Cavity #59 VTA Run | 5d | 2011-08-01 | 2011-08-05 | 1317010, 1312108035 FS-2d | 107d |
| 1312108045 |  | Cavity #60 VTA Run | 5d | 2011-08-04 | 2011-08-10 | 1312108040 FS-2d | 107d |
| 1312108050 |  | Cavity #61 VTA Run | 5d | 2011-08-09 | 2011-08-15 | 1312108045 FS-2d | 107d |
| 1312108055 |  | Cavity #62 VTA Run | 5d | 2011-08-12 | 2011-08-18 | 1312108050 FS-2d | 107d |
| 1312108060 |  | Cavity #63 VTA Run | 5d | 2011-08-17 | 2011-08-23 | 1312108055 FS-2d | 107d |
| 1312108065 |  | Cavity #64 VTA Run | 5d | 2011-08-22 | 2011-08-26 | 1312108060 FS-2d | 107d |
|  | 09 | **1.3.1.2.1.09 CAVITY STRING #9 PREPARATION** |  | 2011-08-15 | 2011-09-30 |  |  |
| 1312109005 |  | Cavity String #9 Cavity Process & He Vs Weld | 16d | 2011-08-15 | 2011-09-06 | 131114115, 1312108005, 1311122087, 1311122090 | 109d |
| 1312109030 |  | Cavity #65 VTA Run | 5d | 2011-08-25 | 2011-08-31 | 1312108065 FS-2d, 1312109005 FS-10d | 107d |
| 1312109035 |  | Cavity #66 VTA Run | 5d | 2011-08-30 | 2011-09-06 | 1312109030 FS-2d | 107d |
| 1312109040 |  | Cavity #67 VTA Run | 5d | 2011-09-02 | 2011-09-09 | 1312109035 FS-2d | 107d |
| 1312109045 |  | Cavity #68 VTA Run | 5d | 2011-09-08 | 2011-09-14 | 1312109040 FS-2d | 107d |
| 1312109050 |  | Cavity #69 VTA Run | 5d | 2011-09-13 | 2011-09-19 | 1312109045 FS-2d | 107d |
| 1312109055 |  | Cavity #70 VTA Run | 5d | 2011-09-16 | 2011-09-22 | 1312109050 FS-2d | 107d |
| 1312109060 |  | Cavity #71 VTA Run | 5d | 2011-09-21 | 2011-09-27 | 1312109055 FS-2d | 107d |
| 1312109065 |  | Cavity #72 VTA Run | 5d | 2011-09-26 | 2011-09-30 | 1312109060 FS-2d | 107d |
|  | 10 | **1.3.1.2.1.10 CAVITY STRING #10 PREPARATION** |  | 2011-10-04 | 2011-11-16 |  |  |
| 1312110005 |  | Cavity String #10 Cavity Process & He Vs Weld | 16d | 2011-10-04 | 2011-10-25 | 1311122092, 1311122095, 131114130M, 131114125, 1312109005, 131114120, 1311122100a | 98d |
| 1312110030 |  | Cavity #73 VTA Run | 5d | 2011-10-12 | 2011-10-18 | 1312110005 FS-10d, 1312109065 FS-2d | 98d |
| 1312110035 |  | Cavity #74 VTA Run | 5d | 2011-10-17 | 2011-10-21 | 1312110030 FS-2d | 98d |
| 1312110040 |  | Cavity #75 VTA Run | 5d | 2011-10-20 | 2011-10-26 | 1312110035 FS-2d | 98d |
| 1312110045 |  | Cavity #76 VTA Run | 5d | 2011-10-25 | 2011-10-31 | 1312110040 FS-2d | 98d |
| 1312110050 |  | Cavity #77 VTA Run | 5d | 2011-10-28 | 2011-11-03 | 1312110045 FS-2d | 98d |
| 1312110055 |  | Cavity #78 VTA Run | 5d | 2011-11-02 | 2011-11-08 | 1312110050 FS-2d | 98d |
| 1312110060 |  | Cavity #79 VTA Run | 5d | 2011-11-07 | 2011-11-11 | 1312110055 FS-2d | 98d |
| 1312110065 |  | Cavity #80 VTA Run | 5d | 2011-11-10 | 2011-11-16 | 1312110060 FS-2d | 98d |
|  | 2 | **1.3.1.2.2 DUMMY** |  |  |  |  |  |
|  | 3 | **1.3.1.2.3 DUMMY** |  |  |  |  |  |
|  | 4 | **1.3.1.2.4 STRING ASSEMBLY** |  | 2010-11-01 | 2012-02-21 |  |  |
|  | 01 | **1.3.1.2.4.01 CAVITY STRING ASSEMBLY #1** |  | 2010-11-01 | 2010-11-15 |  |  |
| 1312401000 |  | Cavity String Assy #1 | 10d | 2010-11-01 | 2010-11-12 | 1312101030, 1312101035, 131116015, 1312101065 FS+10d, 1312101060, 1312101050a, 131115015, 1312101040, 1312101045, 131137020, 32-03M, 1312101055, 131138040, 1311132010 | 37d |
| 1312401010 |  | Transfer to CM #1 Assy | 1d | 2010-11-15 | 2010-11-15 | 1312401000 | 37d |
|  | 02 | **1.3.1.2.4.02 CAVITY STRING ASSEMBLY #2** |  | 2010-11-22 | 2011-03-07 |  |  |
| 1312402000 |  | Cavity String Assy #2 | 10d | 2010-11-22 | 2010-12-07 | 1312102045, 1312102055, 1312102050, 1311132020, 1312102040, 1311132015, 1312102030, 1312102060, 1312102035, 1312102065, 1312401010 FS+4d | 37d |
| 1312402010 |  | Transfer to CM #2 Assy | 1d | 2011-03-07 | 2011-03-07 | 1312402000 FS+55d | 37d |
|  | 03 | **1.3.1.2.4.03 CAVITY STRING ASSEMBLY #3** |  | 2011-03-22 | 2011-04-05 |  |  |
| 1312403000 |  | Cavity String Assy #3 | 10d | 2011-03-22 | 2011-04-04 | 1312103065, 1312103035, 1312402010 FS+4d, 1311132025, 1312103050, 131302001, 1312103060, 1312103040, 1311132030, 1312103030, 1312103055, 1312103045 | 114d |
| 1312403010 |  | Transfer to CM #3 Assy | 1d | 2011-04-05 | 2011-04-05 | 131302001, 1312403000 | 114d |
|  | 04 | **1.3.1.2.4.04 CAVITY STRING ASSEMBLY #4** |  | 2011-05-03 | 2011-05-17 |  |  |
| 1312404000 |  | Cavity String Assy #4 | 10d | 2011-05-03 | 2011-05-16 | 131138045a, 1312104055, 1312104060, 1312104045, 1311132035, 131302002 FS-30d, 1312104065, 1312403010 FS+4d, 1312104040, 1312104030, 1312104035, 1312104050, 1311132040 | 100d |
| 1312404010 |  | Transfer to CM #4 Assy | 1d | 2011-05-17 | 2011-05-17 | 131302002 FS-20d, 1312404000 | 100d |
|  | 05 | **1.3.1.2.4.05 CAVITY STRING ASSEMBLY #5** |  | 2011-05-25 | 2011-06-09 |  |  |
| 1312405000 |  | Cavity String Assy #5 | 10d | 2011-05-25 | 2011-06-08 | 1312105060, 131115016, 131302003 FS-25d, 1312105050, 1312404010 FS-10d, 131116016, 1312105055, 1311132045, 1312105065, 1312105035, 1312105045, 1312105030, 1312105040 | 114d |
| 1312405010 |  | Transfer to CM #5 Assy | 1d | 2011-06-09 | 2011-06-09 | 131302003 FS-15d, 1312405000 | 144d |
|  | 06 | **1.3.1.2.4.06 CAVITY STRING ASSEMBLY #6** |  | 2011-06-17 | 2011-11-21 |  |  |
| 1312406000 |  | Cavity String Assy #6 | 10d | 2011-06-17 | 2011-06-30 | 1312106035, 1312106060, 1312106040, 1312106055, 1312405010 FS+4d, 1312106065, 1312106045, 1311132050, 1312106030, 1312106050, 131302004 FS-105d, 1317010 FS-30d | 149d |
| 1312406010 |  | Transfer to CM #6 Assy | 1d | 2011-11-21 | 2011-11-21 | 131302004 FS+5d, 1312406000, 1317010 | 50d |
|  | 07 | **1.3.1.2.4.07 CAVITY STRING ASSEMBLY #7** |  | 2011-11-30 | 2011-12-14 |  |  |
| 1312407000 |  | Cavity String Assy #7 | 10d | 2011-11-30 | 2011-12-13 | 1312107045, 1312107040, 1312107065, 1312107035, 131138050, 1312406010 FS+4d, 1311132055, 1312107050, 1312107055, 1312107060, 1311132060, 1312107030, 131302005 FS-40d | 50d |
| 1312407010 |  | Transfer to CM #7 Assy | 1d | 2011-12-14 | 2011-12-14 | 1312407000, 131302005 FS-40d | 50d |
|  | 08 | **1.3.1.2.4.08 CAVITY STRING ASSEMBLY #8** |  | 2011-12-21 | 2012-01-12 |  |  |
| 1312408000 |  | Cavity String Assy #8 | 10d | 2011-12-21 | 2012-01-11 | 1312407010 FS+4d, 1311132065, 1312108035, 1312108040, 1312108060, 1312108030, 1312108045, 1312108055, 1312108065, 1312108050, 131302006 FS-65d, 1311132070 | 50d |
| 1312408010 |  | Transfer to CM #8 Assy | 1d | 2012-01-12 | 2012-01-12 | 1312408000, 131302006 FS-65d | 50d |
|  | 09 | **1.3.1.2.4.09 CAVITY STRING ASSEMBLY #9** |  | 2012-01-20 | 2012-02-03 |  |  |
| 1312409000 |  | Cavity String Assy #9 | 10d | 2012-01-20 | 2012-02-02 | 1311132075, 1312109065, 1312109035, 1312109030, 1312109050, 1311132080, 1312109040, 1312109055, 1312109060, 1312408010 FS+4d, 1312109045 | 50d |
| 1312409010 |  | Transfer to CM #9 Assy | 1d | 2012-02-03 | 2012-02-03 | 1312409000 | 50d |
|  | 10 | **1.3.1.2.4.10 CAVITY STRING ASSEMBLY #10** |  | 2012-02-06 | 2012-02-21 |  |  |
| 1312410000 |  | Cavity String Assy #10 | 10d | 2012-02-06 | 2012-02-17 | 1312409010, 1312110055, 1312110030, 1312110065, 1311132085, 1312110060, 1312110040, 1312110050, 1311132100M, 1312110045, 1312110035, 1311122105M, 1311132090 | 50d |
| 1312410010 |  | Transfer to CM #10 Assy | 1d | 2012-02-21 | 2012-02-21 | 1312410000, 131138055 | 50d |
|  | 3 | **1.3.1.3 CRYOMODULE ASSEMBLY** |  | 2010-11-16 | 2013-08-30 |  |  |
|  | 01 | **1.3.1.3.01 SPACE FRAME ASSEMBLY** |  | 2010-11-16 | 2013-08-30 |  |  |
| 131301001 |  | Space Frame Assy #1 | 40d | 2010-11-16 | 2011-01-21 | 1312401010, 131133020 FS-15d, 131134015, 131121020 FS-20d, 131131020, 131123020 FS-15d, 13114020a, 13114015, 131122017 FS-15d, 131132020 FS-20d, 131122020 FS-15d | 72d |
| 131301002 |  | Space Frame Assy #2 | 35d | 2011-03-08 | 2011-04-25 | 131132020 FS-12.5d, 131122020 FS-10d, 131121021 FS-12.5d, 1312402010, 131123020 FS-10d, 131133025, 131122025 FS-10d, 131122017 FS-10d | 37d |
| 131301003 |  | Space Frame Assy #3 | 30d | 2011-04-06 | 2011-05-17 | 131123020, 131122025, 131133030, 131121022, 1312403010, 131132020, 131122030, 131302001 | 114d |
| 131301004 |  | Space Frame Assy #4 | 30d | 2011-06-15 | 2011-07-27 | 1312404010, 131123016c, 131123016d, 131122030 FS-15d, 131123016b, 131122035 FS-15d, 131302002, 131123025 FS-15d, 131132025 FS-25d, 131133035, 131121025 FS-25d | 81d |
| 131301005 |  | Space Frame Assy #5 | 30d | 2011-06-30 | 2011-08-11 | 131132025 FS-20d, 131121026 FS-20d, 131122040 FS-10d, 131302003, 131134016, 131122035 FS-10d, 131133040, 131131021b, 131123025 FS-10d, 1312405010, 131134018 | 130d |

| ID | WBS | Task | Duration | Start | Finish | Predecessors | Total float |
| --- | --- | --- | --- | --- | --- | --- | --- |
| 131301006 |  | Space Frame Assy #6 | 40d | 2011-11-22 | 2012-01-27 | 131123025 FS-5d, 1312406010, 131121027 FS-10d, 131122040 FS-5d, 131132025 FS-10d, 131133045, 131302004, 131122045 FS-5d, 131301005 FS-15d | 92d |
| 131301006a |  | Space Frame Assy #6 Reverse entry | 1d | 2012-02-01 | 2012-02-01 | 9-120M FS+78d | 153d |
| 131301007 |  | Space Frame Assy #7 | 24d | 2012-02-03 | 2012-03-08 | 131133050, 131132025, 131121028, 131122045, 131122050, 131123025, 131302005, 1312407010 | 162d |
| 131301006b |  | Space Frame Assy #6 | 30d | 2012-02-27 | 2012-04-06 | 131122045 FS-5d, 131301006a FS+16d, 131122040 FS-5d, 131123025 FS-5d, 131132025 FS-10d, 131133045, 131301005 FS-15d, 1312406010, 131121027 FS-10d, 131302004 | 153d |
| 131301008 |  | Space Frame Assy #8 | 33d | 2012-05-29 | 2012-07-13 | 131122055 FS-20d, 1312408010, 131123030 FS-20d, 131132030 FS-20d, 131132030a, 131302007, 131122050 FS-20d, 131121029, 1317025, 131133055 | 141d |
| 131301009 |  | Space Frame Assy #9 | 44d | 2012-07-09 | 2012-09-07 | 131121030 FS-12.5d, 1312409010, 131302006b, 131133060, 131122060 FS-10d, 131122055 FS-10d, 131132030 FS-12.5d, 131132030a, 131123030 FS-10d | 146d |
| 131301010 |  | Space Frame Assy #10 FY12 | 19d | 2012-09-04 | 2012-09-28 | 131123030, 131132030a, 131122060, 131132030, 131133065, 131121045LOE, 131302008, 1312410010, 131121010CLOE, 131121035 | 141d |
| 131301010a |  | Space Frame Assy #10 FY13 | 20d | 2012-10-01 | 2012-10-26 | 131301010 | 141d |
| 131301015 |  | Re-Baseline Actuals Adjustment | 1d | 2013-08-30 | 2013-08-30 | 9-130M FS+227d | 20d |
|  | 02 | **1.3.1.3.02 CRYOMODULE ASSEMBLY** |  | 2011-01-24 | 2013-08-30 |  |  |
| 131302001 |  | Cryomodule Assy #1 | 40d | 2011-01-24 | 2011-03-21 | 131137040, 131131020, 131122017 FS-15d, 131136020 FS-15d, 131139025, 131133070, 131123020 FS-15d, 131138020 FS-15d, 131132020 FS-20d, 13114020a, 131137015, 131137030, 131135020a, 13115015, 131138030, 131122075, 131137050, 131138040, 131301001, 13114015, 131134015, 131122020 FS-15d | 72d |
| 131302002 |  | Cryomodule Assy #2 | 35d | 2011-04-26 | 2011-06-14 | 131136025, 131122080, 131132020 FS-12.5d, 131122017 FS-10d, 131302001 FS-15d, 131122025 FS-10d, 131122020 FS-10d, 131133075, 131138020 FS-10d, 131123020 FS-10d, 131301002, 131135025 | 37d |
| 131302003 |  | Cryomodule Assy #3 | 30d | 2011-05-18 | 2011-06-29 | 131138020, 131135030, 131122030, 131136030, 131122085, 131301003, 131133080, 131122025, 131132020, 131123020 | 114d |
| 131302004 |  | Cryomodule Assy #4 | 30d | 2011-10-03 | 2011-11-11 | 131133085, 131123025 FS-15d, 131132025 FS-25d, 131122035 FS-15d, 131122030 FS-15d, 9-120M, 131301004, 131138020, 131122090, 131135035, 131136035 | 35d |
| 131302005 |  | Cryomodule Assy #5 | 20d | 2012-01-05 | 2012-02-02 | 131138020ba, 131135040, 131131021b, 131132025 FS-20d, 131122095, 9-120M FS+60d, 131134018, 131123025 FS-10d, 131301005, 131134016, 131136040, 131134021LOE, 131133090, 131122035 FS-10d, 131122040 FS-10d | 35d |
| 131302006 |  | Cryomodule Assy #6 | 2d | 2012-01-30 | 2012-01-31 | 131136045, 131122045 FS-5d, 131122040 FS-5d, 131138020ba, 131133095, 131123025 FS-5d, 131132025 FS-10d, 131301006, 131122100, 131135045 | 92d |
| 131302006a |  | Cryomodule Assy #6 Reverse Entry | 1d | 2012-02-01 | 2012-02-01 | 9-120M FS+78d | 199d |
| 131302007 |  | Cryomodule Assy #7 | 35d | 2012-03-09 | 2012-04-26 | 131122050, 131301007, 131132025, 131138020d, 131122045, 131122105, 131123025, 131133100, 131135050, 131136050 | 162d |
| 131302006b |  | Cryomodule Assy #6 | 28d | 2012-05-29 | 2012-07-06 | 131302006a, 131132025 FS-10d, 131301006, 131122100, 131135045, 131122045 FS-5d, 131138020ba, 131136045, 131123025 FS-5d, 131301006b, 1317025, 131133095, 131122040 FS-5d | 118d |
| 131302008 |  | Cryomodule Assy #8 | 35d | 2012-07-16 | 2012-08-31 | 131122050 FS-20d, 131138030 FS-20d, 131301008, 131135055, 131122110, 131123030 FS-20d, 131132030a, 131132030 FS-20d, 131138020d, 131136055, 131133105, 131122055 FS-20d | 141d |
| 131302009 |  | Cryomodule Assy #9 FY12 | 15d | 2012-09-10 | 2012-09-28 | 131122055 FS-10d, 131122060 FS-10d, 131123030 FS-10d, 131301009, 131133110, 131138030 FS-10d, 131138020g, 131132030a, 131135060, 131136060, 131132030 FS-12.5d | 146d |
| 131302009a |  | Cryomodule Assy #9 FY13 | 15d | 2012-10-01 | 2012-10-19 | 131302009 | 146d |
| 131302010 |  | Cryomodule Assy #10 | 28d | 2012-10-29 | 2012-12-07 | 131138065LOE, 131138020g, 131135065, 131132030a, 131122060, 131132030, 131123030, 131133130LOE, 131133115a, 131122065R, 131301010a, 131138030, 131136065 | 141d |
| 131302015 |  | Re-Baseline Actuals Adjustment | 1d | 2013-08-30 | 2013-08-30 | 9-130M FS+227d | 20d |
|  | 03 | **1.3.1.3.03 N/A** |  |  |  |  |  |
|  | 04 | **1.3.1.3.04 N/A** |  |  |  |  |  |
|  | 05 | **1.3.1.3.05 N/A** |  |  |  |  |  |
|  | 06 | **1.3.1.3.06 N/A** |  |  |  |  |  |
|  | 07 | **1.3.1.3.07 N/A** |  |  |  |  |  |
|  | 08 | **1.3.1.3.08 N/A** |  |  |  |  |  |
|  | 09 | **1.3.1.3.09 N/A** |  |  |  |  |  |
|  | 10 | **1.3.1.3.10 N/A** |  |  |  |  |  |
|  | 1 | **(New WBS)** |  |  |  |  |  |
|  | 4 | **1.3.1.4 CRYOMODULE ACCEPTANCE TEST** |  | 2011-03-22 | 2013-08-30 |  |  |
| 1314000 |  | Re-Baseline Actuals Adjustment | 1d | 2013-08-30 | 2013-08-30 | 9-130M FS+227d | 20d |
|  | 01 | **1.3.1.4.01 CRYOMODULE ACCEPTANCE TEST #1** |  | 2011-03-22 | 2011-04-25 |  |  |
| 131401000 |  | Acceptance Test Cryomodule #1 | 25d | 2011-03-22 | 2011-04-25 | 131116025, 131302001 | 72d |
|  | 02 | **1.3.1.4.02 CRYOMODULE ACCEPTANCE TEST #2** |  | 2011-06-15 | 2011-07-20 |  |  |
| 131402000 |  | Acceptance Test Cryomodule #2 | 25d | 2011-06-15 | 2011-07-20 | 131302002, 131401000 | 37d |
|  | 03 | **1.3.1.4.03 CRYOMODULE ACCEPTANCE TEST #3** |  | 2011-11-01 | 2011-12-07 |  |  |
| 131403000 |  | Acceptance Test Cryomodule #3 | 25d | 2011-11-01 | 2011-12-07 | 131302003, 9-120M FS+21d, 131402000 | 49d |
|  | 04 | **1.3.1.4.04 CRYOMODULE ACCEPTANCE TEST #4** |  | 2011-12-08 | 2012-03-30 |  |  |
| 131404000 |  | Acceptance Test Cryomodule #4 | 20d | 2011-12-08 | 2012-01-12 | 131403000, 131302004 | 49d |
| 131404005 |  | Acceptance Test Cryomodule #4 Reverse Entry | 1d | 2012-02-01 | 2012-02-01 | 9-120M FS+78d | 51d |
| 131404010 |  | Acceptance Test Cryomodule #4 | 25d | 2012-02-27 | 2012-03-30 | 131405000 FS+1d, 131404005, 131403000, 131302004 FS+65d | 35d |
|  | 05 | **1.3.1.4.05 CRYOMODULE ACCEPTANCE TEST #5** |  | 2012-02-03 | 2012-02-23 |  |  |
| 131405000 |  | Acceptance Test Cryomodule #5 | 14d | 2012-02-03 | 2012-02-23 | 131404000, 131302005 | 35d |
|  | 06 | **1.3.1.4.06 CRYOMODULE ACCEPTANCE TEST #6** |  | 2012-07-16 | 2012-08-31 |  |  |
| 131406000 |  | Acceptance Test Cryomodule #6 | 35d | 2012-07-16 | 2012-08-31 | 131404010, 131302006b, 131302006, 1317035 | 113d |
|  | 07 | **1.3.1.4.07 CRYOMODULE ACCEPTANCE TEST #7** |  | 2012-09-04 | 2012-10-19 |  |  |
| 131407000 |  | Acceptance Test Cryomodule #7 FY12 | 19d | 2012-09-04 | 2012-09-28 | 131406000, 131302007 | 113d |
| 131407000a |  | Acceptance Test Cryomodule #7 FY13 | 15d | 2012-10-01 | 2012-10-19 | 131407000 | 113d |
|  | 08 | **1.3.1.4.08 CRYOMODULE ACCEPTANCE TEST #8** |  | 2012-10-22 | 2012-12-07 |  |  |
| 131408000 |  | Acceptance Test Cryomodule #8 | 33d | 2012-10-22 | 2012-12-07 | 131302008, 131407000a | 113d |
|  | 09 | **1.3.1.4.09 CRYOMODULE ACCEPTANCE TEST #9** |  | 2012-12-10 | 2013-01-25 |  |  |
| 131409000 |  | Acceptance Test Cryomodule #9 | 28d | 2012-12-10 | 2013-01-25 | 131408000, 131302009a | 113d |
|  | 10 | **1.3.1.4.10 CRYOMODULE ACCEPTANCE TEST #10** |  | 2013-01-28 | 2013-03-15 |  |  |
| 131410000 |  | Acceptance Test Cryomodule #10 | 34d | 2013-01-28 | 2013-03-15 | 131302010, 131409000 | 113d |
|  | 5 | **1.3.1.5 CRYOMODULE INSTALLATION AND TEST** |  | 2011-05-23 | 2013-08-30 |  |  |
| 1315000 |  | Re-Baseline Actuals Adjustment | 1d | 2013-08-30 | 2013-08-30 | 9-130M FS+227d | 20d |
|  | 01 | **1.3.1.5.01 CRYOMODULE #1 INSTALLATION AND TEST** |  | 2011-05-23 | 2011-09-07 |  |  |
| 131501000 |  | Installaton Cryomodule #1 | 5d | 2011-05-23 | 2011-05-27 | 3A-20M FS-80d, 131401000, 13436020, 4A-01M | 60d |
| 131501005 |  | In-Tunnel Checkout and Commisioning Cryomodule #1 | 18d | 2011-08-12 | 2011-09-07 | 13213010, 131501000, 13436025, 132121061M, 132112081M | 19d |
|  | 02 | **1.3.1.5.02 CRYOMODULE #2 INSTALLATION AND TEST** |  | 2011-07-21 | 2011-10-05 |  |  |
| 131502000 |  | Installaton Cryomodule #2 | 5d | 2011-07-21 | 2011-07-27 | 131402000, 13436030, 131501000 | 37d |
| 131502005 |  | In-Tunnel Checkout and Commisioning Cryomodule #2 FY11 | 15d | 2011-09-12 | 2011-09-30 | 13436035, 132121062M, 132112082M, 13213010a, 131501005 FS-5d, 131502000 | 12d |
| 131502005a |  | In-Tunnel Checkout and Commisioning Cryomodule #2 FY12 | 3d | 2011-10-03 | 2011-10-05 | 131502005 | 12d |
|  | 03 | **1.3.1.5.03 CRYOMODULE #3 INSTALLATION AND TEST** |  | 2012-12-21 | 2013-01-11 |  |  |
| 131503000 |  | Installaton Cryomodule #3 5th | 10d | 2012-12-21 | 2013-01-11 | 132121065M, 131505000, 131403000, 2-02M, 13436055, 131502005a, 132112085M | 45d |
|  | 04 | **1.3.1.5.04 CRYOMODULE #4 INSTALLATION AND TEST** |  | 2012-05-14 | 2012-07-13 |  |  |

| ID | WBS | Task | Duration | Start | Finish | Predecessors | Total float | Constraint |
| --- | --- | --- | --- | --- | --- | --- | --- | --- |
| 131504000 |  | Installaton Cryomodule #4 3rd | 10d | 2012-05-14 | 2012-05-25 | 131404010 FS+30d, 131404000, 132121063M, 132112083M | 35d |  |
| 131504005 |  | In-Tunnel Checkout and Commisioning Cryomodule #4 3rd | 23d | 2012-06-13 | 2012-07-13 | 13213010b, 131504000 | 312d |  |
|  | 05 | **1.3.1.5.05 CRYOMODULE #5 INSTALLATION AND TEST** |  | 2012-05-29 | 2012-07-27 |  |  |  |
| 131505000 |  | Installaton Cryomodule #5 4th | 8d | 2012-05-29 | 2012-06-08 | 132112084M, 132113115, 131504000, 132121064M, 13436050, 131405000 | 35d |  |
| 131505005 |  | In-Tunnel Checkout and Commisioning Cryomodule #5 4th | 25d | 2012-06-25 | 2012-07-27 | 131505000, 13213010c | 35d |  |
|  | 06 | **1.3.1.5.06 CRYOMODULE #6 INSTALLATION AND TEST** |  | 2013-01-17 | 2013-01-30 |  |  |  |
| 131506000 |  | Installaton Cryomodule #6 | 9d | 2013-01-17 | 2013-01-30 | 132121066M, 131505005, 132112086M, 131406000, 131503000 | 57d |  |
|  | 07 | **1.3.1.5.07 CRYOMODULE #7 INSTALLATION AND TEST** |  | 2013-02-07 | 2013-02-21 |  |  |  |
| 131507000 |  | Installaton Cryomodule #7 | 10d | 2013-02-07 | 2013-02-21 | 132112087M, 131506000, 132121067M, 131407000a | 66d |  |
|  | 08 | **1.3.1.5.08 CRYOMODULE #8 INSTALLATION AND TEST** |  | 2013-02-27 | 2013-03-12 |  |  |  |
| 131508000 |  | Installaton Cryomodule #8 | 10d | 2013-02-27 | 2013-03-12 | 131408000, 132121068M, 132112088M, 131507000 | 78d |  |
|  | 09 | **1.3.1.5.09 CRYOMODULE #9 INSTALLATION AND TEST** |  | 2013-03-18 | 2013-03-29 |  |  |  |
| 131509000 |  | Installaton Cryomodule #9 | 10d | 2013-03-18 | 2013-03-29 | 132112089M, 131508000, 131409000, 132121069M | 89d |  |
|  | 10 | **1.3.1.5.10 CRYOMODULE #10 INSTALLATION AND TEST** |  | 2013-04-04 | 2013-04-17 |  |  |  |
| 131510000 |  | Installaton Cryomodule #10 | 10d | 2013-04-04 | 2013-04-17 | 132122030M, 131509000, 131410000, 132121070M, 132112090M | 100d |  |
|  | 6 | **1.3.1.6 MICROPHONICS** |  | 2011-06-01 | 2013-08-30 |  |  |  |
| 1316005 |  | Initial studies in accelerator tunnel | 22d | 2011-06-01 | 2011-06-30 | 9-110M FS+162d | 22d |  |
| 1316010 |  | Analysis and mitigation development | 47d | 2011-06-24 | 2011-08-30 | 1316005 FS-5d | 22d |  |
| 1316015 |  | Re-Baseline Actuals Adjustment | 1d | 2013-08-30 | 2013-08-30 | 9-130M FS+227d | 20d |  |
|  | 7 | **1.3.1.7 TEDF INTERFACE** |  | 2010-08-10 | 2012-07-13 |  |  |  |
| 1317000 |  | TEDF Summer Down 2010 | 22d | 2010-08-10 | 2010-09-09 | 9-100M FS+211d, 1311122010 | 37d |  |
| 1317005 |  | TEDF Winter Down 2010 | 14d | 2010-12-20 | 2011-01-14 | 1312103050 FS-2d, 1311122030, 9-110M FS+54d | 99d |  |
| 1317010 |  | TEDF Summer Down 2011 | 20d | 2011-07-01 | 2011-07-29 | 1311122087, 9-110M FS+184d, 1312108035, 1312405000 | 98d |  |
| 1317020 |  | Transition - Planning and Coordination | 130d | 2011-10-03 | 2012-04-13 | 9-120M | 0d |  |
| 1317015 |  | TEDF Winter Down 2011 | 18d | 2011-12-19 | 2012-01-20 | 9-120M FS+53d | 79d |  |
| 1317025 |  | Transition - Cryomodule Work Center | 40d | 2012-04-02 | 2012-05-25 | 1317020 FS-10d | 0d | mandatory start 2012-04-02 |
| 1317035 |  | CMTF Down - TL Renovation | 33d | 2012-05-29 | 2012-07-13 | 1317025 | 0d | mandatory finish 2012-07-13 |
|  | 2 | **1.3.2 POWER SYSTEMS** |  | 2009-01-02 | 2014-09-30 |  |  |  |
|  | 1 | **1.3.2.1 RF** |  | 2009-04-21 | 2013-11-06 |  |  |  |
|  | 1 | **1.3.2.1.1 POWER** |  | 2009-04-21 | 2013-09-30 |  |  |  |
|  | 1 | **1.3.2.1.1.1 KLYSTRONS** |  | 2009-04-21 | 2013-09-30 |  |  |  |
| 132111025M |  | Klystron Contract Awarded (KLYSTRONS) | 0d | 2009-04-21 | 2009-04-21 | 1212111120, 9-090M FS+134d | -37d |  |
| 132111030 |  | Vend Dsgn Period (Klystrons) | 77d | 2009-04-21 | 2009-08-07 | 132111025M, 32-01M | 154d |  |
| 132111035 |  | Klystron Dsgn Review & Approval for Production (Klystrons) | 5d | 2009-08-10 | 2009-08-14 | 132111030 | 154d |  |
| 132111040 |  | Vend Manufacture First article Klystron (Order and Recieve Parts) | 69d | 2009-08-17 | 2009-11-20 | 132111035 | 347d |  |
| 132111040A |  | Vend Manufacture First article Klystron (First Article Testing) | 167d | 2009-08-17 | 2010-04-21 | 132111035 | 206d |  |
| 132111040B |  | Vend Manufacture First article Klystron (Delivery of FA Report) | 219d | 2009-08-17 | 2010-07-06 | 132111035 | 154d |  |
| 132111042 |  | Vend Manufacture First article Klystron (Klystrons) LABOR/EXPS FY09 | 32d | 2009-08-17 | 2009-09-30 | 132111035 | 154d |  |
| 132111042b |  | Vend Manufacture First article Klystron (Klystrons) LABOR/EXPS FY10 | 187d | 2009-10-01 | 2010-07-06 | 132111042 | 154d |  |
| 132111911LOE |  | Proj Admin (2011) ongoing (Klystrons) | 248d | 2009-10-01 | 2010-09-30 | 9-100M | 20d |  |
| 132111045 |  | Test First article Klystron (Klystrons) | 10d | 2010-04-21 | 2010-05-04 | 132111040 FS-53d, 132111040A FS-53d, 132111042b FS-53d, 132111040B FS-53d | 197d |  |
| 132111049 |  | Grant Approval for Klystron Production, (Klystrons) | 5d | 2010-07-07 | 2010-07-13 | 132111040A, 132111042b, 9-100M FS+60d, 132111045, 132111040B | 154d |  |
| 132111049M |  | Start of Klystron Production | 0d | 2010-07-14 | 2010-07-14 | 132111049 | 154d |  |
| 132111050 |  | Vend Klystron Production (Klystron 1&2) | 176d | 2010-07-14 | 2011-03-31 | 2-01M, 132111049M | 262d |  |
| 132111050A |  | Vend Klystron Production (Klystrons 3-6) | 197d | 2010-07-14 | 2011-04-29 | 2-01M, 132111049M | 612d |  |
| 132111050B |  | Vend Klystron Production (Klystrons 7-10) | 217d | 2010-07-14 | 2011-05-27 | 2-01M, 132111049M | 592d |  |
| 132111050C |  | Vend Klystron Production (Klystrons 11-14) | 240d | 2010-07-14 | 2011-06-30 | 2-01M, 132111049M | 569d |  |
| 132111050D |  | Vend Klystron Production (Klystrons 15&16) | 260d | 2010-07-14 | 2011-07-29 | 2-01M, 132111049M | 549d |  |
| 132111050F |  | Vend Klystron Production (Klystrons 17-19) | 260d | 2010-07-14 | 2011-07-29 | 2-01M, 132111049M | 549d |  |
| 132111050G |  | Vend Klystron Production (Klystrons 20-24) | 283d | 2010-07-14 | 2011-08-31 | 2-01M, 132111049M | 526d |  |
| 132111050H |  | Vend Klystron Production (Klystrons 25-30) | 304d | 2010-07-14 | 2011-09-30 | 2-01M, 132111049M | 505d |  |
| 132111050J |  | Vend Klystron Production (Klystrons 37-42) | 345d | 2010-07-14 | 2011-11-30 | 132111049M, 2-01M | 154d |  |
| 132111050K |  | Vend Klystron Production (Klystrons 43-48) | 362d | 2010-07-14 | 2011-12-30 | 132111049M, 2-01M | 447d |  |
| 132111050L |  | Vend Klystron Production (Klystrons 49-54) | 382d | 2010-07-14 | 2012-01-31 | 2-01M, 132111049M | 427d |  |
| 132111050N |  | Vend Klystron Production (Klystrons 55-60) | 402d | 2010-07-14 | 2012-02-29 | 2-01M, 132111049M | 407d |  |
| 132111050P |  | Vend Klystron Production (Klystrons 67-72) | 445d | 2010-07-14 | 2012-04-30 | 2-01M, 132111049M | 364d |  |
| 132111050Q |  | Vend Klystron Production (Klystrons 73-78) | 467d | 2010-07-14 | 2012-05-31 | 2-01M, 132111049M | 342d |  |
| 132111050R |  | Vend Klystron Production (Klystrons 79-83) | 487d | 2010-07-14 | 2012-06-29 | 2-01M, 132111049M | 322d |  |
| 132111050i |  | Vend Klystron Production (Klystrons 31-36) | 325d | 2010-07-14 | 2011-10-31 | 2-01M, 132111049M | 484d |  |
| 132111050o |  | Vend Klystron Production (Klystrons 61-66) | 424d | 2010-07-14 | 2012-03-30 | 132111049M, 2-01M | 272d |  |
| 132111052 |  | Vend Klystron Production LABOR/EXP FY10 | 56d | 2010-07-14 | 2010-09-30 | 132111049M | 354d |  |
| 132111052a |  | Vend Klystron Production LABOR/EXP FY11 | 248d | 2010-10-01 | 2011-09-30 | 132111052 | 354d |  |
| 132111912LOE |  | Proj Admin (2012) ongoing (Klystrons) | 248d | 2010-10-01 | 2011-09-30 | 132111911LOE | 20d |  |
| 132111060 |  | Release Prcrmnt Package, Driver Amplifer (Klystrons) | 5d | 2010-12-07 | 2010-12-13 | 9-110M FS+45d, 132111049 | 293d |  |
| 132111065 |  | Receive & Evaluate Driver Amplifer Proposals (Klystrons) | 30d | 2010-12-14 | 2011-02-02 | 132111060 | 293d |  |
| 132111068 |  | Bid Driver Amplifer Prcrmnt (Klystrons) | 10d | 2011-02-03 | 2011-02-16 | 132111065 | 293d |  |
| 132111069M |  | Award Driver Amplifer Prcrmnt (KLYSTRONS) | 0d | 2011-02-17 | 2011-02-17 | 9-110M, 132111068 | 293d |  |
| 132111070 |  | Vend Fab Driver Amplifer 1st Article (Klystrons) | 10d | 2011-02-17 | 2011-03-03 | 132111069M | 293d |  |
| 132111075 |  | Dsgn Review for Driver Amplifer (Klystrons) | 30d | 2011-03-04 | 2011-04-14 | 132111070 | 293d |  |
| 132111055 |  | Receive & Test Production Klystrons FY11 | 128d | 2011-04-01 | 2011-09-30 | 132111050 | 262d |  |

| ID | WBS | Task | Duration | Start | Finish | Predecessors | Total float |
| --- | --- | --- | --- | --- | --- | --- | --- |
| 132111080 |  | Vendor Fab Lot 1 Driver Amplifers (Klystrons) Labor FY11 | 118d | 2011-04-15 | 2011-09-30 | 132111075 | 293d |
| 132111080b |  | Vendor Fab Lot 1 Driver Amplifers (Klystrons) Procurement | 130d | 2011-04-15 | 2011-10-18 | 132111075 | 293d |
| 132111052ab |  | Vend Klystron Production LABOR/EXP FY12 | 151d | 2011-10-03 | 2012-05-14 | 132111052a | 354d |
| 132111055a |  | Receive & Test Production Klystrons FY12 | 243d | 2011-10-03 | 2012-09-24 | 132111055 | 262d |
| 132111080a |  | Vendor Fab Lot 1 Driver Amplifers (Klystrons) Labor FY12 | 12d | 2011-10-03 | 2011-10-18 | 132111080 | 293d |
| 132111913LOE |  | Proj Admin (2013) ongoing (Klystrons) | 247d | 2011-10-03 | 2012-09-28 | 132111912LOE | 20d |
| 132111115 |  | Vendor Fab Lot 2 of Driver Amplifers (Klystrons) | 200d | 2011-10-19 | 2012-08-09 | 132111080b, 132111080a, 9-120M | 293d |
| 132111115M |  | Driver amplfier Prcrmnt Comp (KLYSTRONS) | 0d | 2012-08-09 | 2012-08-09 | 132111115 | 293d |
| 132111057M |  | Production Klystrons Received and Tested | 0d | 2012-09-24 | 2012-09-24 | 132111050, 132111050Q, 132111052ab, 132111050o, 132111055a, 132111050L, 132111050D, 132111050F, 132111050G, 132111050N, 132111050A, 132111050C, 132111050i, 132111050K, 132111050P, 132111050R, 132111050H, 132111050B, 132111050J | 262d |
| 132111914LOE |  | Proj Admin (2014) ongoing (Klystrons) *** Re-Baseline Split | 228d | 2012-10-01 | 2013-08-30 | 132111913LOE | 20d |
| 132111950 |  | Re-Baseline Actuals Adjustment | 1d | 2013-08-30 | 2013-08-30 | 9-130M FS+227d | 20d |
| 232111914LOE |  | Proj Admin ongoing (Klystrons) | 20d | 2013-09-03 | 2013-09-30 | 9-130M FS+228d | 58d |
|  | 2 | **1.3.2.1.1.2 DC POWER** |  | 2009-06-18 | 2013-08-30 |  |  |
| 132112081M |  | First Zone Installed/Tested (DC Power) | 0d | 2011-08-04 | 2011-08-04 | 4A-03M, 1321122100 | 19d |
| 132112082M |  | Second Zone Installed/Tested (DC Power) | 0d | 2011-09-01 | 2011-09-01 | 1321122105 | 12d |
| 132112083M |  | Third Zone Installed/Tested (DC Power) | 0d | 2011-09-30 | 2011-09-30 | 1321122110 | 185d |
| 132112084M |  | Fourth Zone Installed/Tested (DC Power) | 0d | 2011-11-30 | 2011-11-30 | 1321122115a, 132121064M FS+25d, 132111050J, 132112083M | 154d |
| 132112085M |  | Fifth Zones Installed/Tested (DC Power) | 0d | 2012-12-20 | 2012-12-20 | 1321122120a FS+264d | 45d |
| 132112086M |  | Sixth Zone Installed/Tested (DC Power) | 0d | 2013-01-16 | 2013-01-16 | 1321122185, 1321122125 | 51d |
| 132112087M |  | Seventh Zone Installed/Tested (DC Power) | 0d | 2013-02-06 | 2013-02-06 | 132111050o, 1321122190, 1321122130, 132121067M FS+25d, 132112086M | 61d |
| 132112088M |  | Eighth Zone Installed/Tested (DC Power) | 0d | 2013-02-26 | 2013-02-26 | 1321122195, 1321122135 | 73d |
| 132112089M |  | Ninth Zone Installed/Tested (DC Power) | 0d | 2013-03-15 | 2013-03-15 | 1321122200, 1321122140 | 84d |
| 132112090M |  | Tenth Zone Installed/Tested (DC Power) | 0d | 2013-04-03 | 2013-04-03 | 1321122205, 1321122145, 1321122015a, 1321122047LOE, 1321122030a, 1321121035 | 95d |
|  | 1 | **1.3.2.1.1.2.1 High Voltage Power Supply** |  | 2009-06-18 | 2013-08-30 |  |  |
| 1321121000 |  | Bid HVPS | 31d | 2009-06-18 | 2009-07-31 | 9-090M FS+175d | 81d |
| 1321121005 |  | Evaluate HVPS | 33d | 2009-08-03 | 2009-09-17 | 1321121000 | 81d |
| 1321121010 |  | Award HVPS Lot 1 (3) | 5d | 2009-10-01 | 2009-10-07 | 1321121005, 9-100M | 72d |
| 1321121015 |  | Fabricate HVPS Lot 1 (3) Original Expenses | 243d | 2009-10-08 | 2010-09-30 | 1321121010 | 77d |
| 1321121020 |  | Vend Fab HVPS Peg Point #1 Design Review | 61d | 2010-01-04 | 2010-03-31 | 9-100M FS+59d | 12d |
| 1321121025 |  | Vend Fab HVPS Peg Point #2 Special Non Stock parts for 10 Systems | 146d | 2010-01-04 | 2010-07-30 | 1321121020 FS-61d | 12d |
| 1321121030 |  | Vend Fab HVPS Peg Point #3 Test 1st Article | 230d | 2010-01-04 | 2010-11-30 | 1321121025 FS-146d | 12d |
| 1321121035 |  | Vend Fab HVPS Peg Point #4 Ship and Accept 1st Article | 247d | 2010-01-04 | 2010-12-30 | 1321121030 FS-230d | 12d |
| 1321121040 |  | Vend Fab HVPS Peg Point #5 Ship and Accept unit #2 | 286d | 2010-01-04 | 2011-02-28 | 1321121035 FS-247d | 12d |
| 1321121045 |  | Vend Fab HVPS Peg Point #6 Ship and Accept unit #3 | 309d | 2010-01-04 | 2011-03-31 | 1321121040 FS-286d | 45d |
| 1321121050 |  | Vend Fab HVPS Peg Point #7 Ship and Accept unit #4 | 330d | 2010-01-04 | 2011-04-29 | 1321121045 FS-309d | 45d |
| 1321121055 |  | Vend Fab HVPS Peg Point #8 Ship and Accept unit #5 | 351d | 2010-01-04 | 2011-05-31 | 1321121050 FS-330d | 45d |
| 1321121060 |  | Vend Fab HVPS Peg Point #9 Ship and Accept unit #6 | 437d | 2010-01-04 | 2011-09-30 | 1321121055 FS-351d | 270d |
| 1321121065 |  | Vend Fab HVPS Peg Point #10 Ship and Accept unit #7 | 458d | 2010-01-04 | 2011-10-31 | 1321121060 FS-437d | 294d |
| 1321121070 |  | Vend Fab HVPS Peg Point #11 Ship and Accept unit #8 | 478d | 2010-01-04 | 2011-11-30 | 1321121065 FS-458d | 319d |
| 1321121075 |  | Vend Fab HVPS Peg Point #12 Ship and Accept unit #9 | 515d | 2010-01-04 | 2012-01-31 | 1321121070 FS-478d | 337d |
| 1321121080 |  | Vend Fab HVPS Peg Point #13 Ship and Accept unit #10 | 515d | 2010-01-04 | 2012-01-31 | 1321121075 FS-515d | 361d |
| 1321121085 |  | Re-Baseline Actuals Adjustment | 1d | 2013-08-30 | 2013-08-30 | 9-130M FS+227d | 20d |
|  | 2 | **1.3.2.1.1.2.2 High Power Amplifier** |  | 2009-10-01 | 2013-08-30 |  |  |
| 1321122000 |  | Order/Receive Components: Aux PS, Cabling | 84d | 2009-10-01 | 2010-02-08 | 9-100M | 351d |
| 1321122035 |  | Bid HPA Components, Subassemblies | 17d | 2009-10-01 | 2009-10-23 | 9-100M | 86d |
| 1321122035M |  | Award HPA Components | 0d | 2009-12-09 | 2009-12-09 | 1321122035 FS+30d | 86d |
| 1321122020 |  | Bid Solenoid PS (10) | 15d | 2010-01-05 | 2010-01-26 | 9-100M FS+60d | 361d |
| 1321122040 |  | Fabricate HPA Components | 62d | 2010-01-08 | 2010-04-07 | 1321122035M, 9-100M FS+63d | 70d |
| 1321122050 |  | Fabricate HPA #1 | 60d | 2010-01-12 | 2010-04-07 | 1321122040 FS-60d | 70d |
| 1321122020M |  | Award Solenoid PS | 0d | 2010-02-03 | 2010-02-03 | 1321122020 FS+5d | 361d |
| 1321122025 |  | Fabricate, Receive & Test Solenoid PS (Original Labor) | 80d | 2010-02-03 | 2010-05-26 | 1321122020M | 361d |
| 1321122000M |  | Components: Aux PS, Cabling Received | 0d | 2010-02-09 | 2010-02-09 | 1321122000 | 351d |
| 1321122005 |  | Fabricate: Aux PS, Cabling FY10 | 164d | 2010-02-09 | 2010-09-30 | 1321122000M | 351d |
| 1321122045LOE |  | Engineering Oversight FY10 | 128d | 2010-04-01 | 2010-09-30 | 9-100M FS+120d, 1321122000M | 434d |
| 1321122010 |  | Test: Aux PS, Cabling FY10 | 118d | 2010-04-15 | 2010-09-30 | 1321122005a FS-140d | 351d |
| 1321122041 |  | Procure AC Power Materiala (208 VAC) | 40d | 2010-08-02 | 2010-09-27 | 9-100M FS+205d | 419d |
| 1321122055 |  | Fabricate HPA #2 FY10 | 21d | 2010-09-01 | 2010-09-30 | 1321122050 FS+102d | 70d |
| 1321122026 |  | Fabricate Solenoid PS | 202d | 2010-09-07 | 2011-06-30 | 1321122025, 9-100M FS+230d | 291d |
| 1321122042 |  | Install RF Zone 208 VAC FY10 | 3d | 2010-09-28 | 2010-09-30 | 1321122041 | 419d |
| 1321122060 |  | Fabricate HPA #3 FY10 | 1d | 2010-09-30 | 2010-09-30 | 1321122055a FS-40d | 108d |
| 1321122005a |  | Fabricate: Aux PS, Cabling FY11 | 22d | 2010-10-01 | 2010-11-01 | 1321122005 | 351d |
| 1321122010a |  | Test: Aux PS, Cabling FY11 | 60d | 2010-10-01 | 2011-01-04 | 1321122010 | 351d |
| 1321122042a |  | Install RF Zone 208 VAC FY11 | 37d | 2010-10-01 | 2010-11-22 | 1321122042 | 419d |
| 1321122046LOE |  | Engineering Oversight FY11 | 248d | 2010-10-01 | 2011-09-30 | 1321122045LOE | 434d |
| 1321122055a |  | Fabricate HPA #2 FY11 | 39d | 2010-10-01 | 2010-11-24 | 1321122055 | 70d |
| 1321122060a |  | Fabricate HPA #3 FY11 | 59d | 2010-10-01 | 2010-12-31 | 1321122060 | 108d |
| 1321122065 |  | Fabricate HPA #4 | 60d | 2010-10-28 | 2011-02-01 | 1321122060a FS-40d | 108d |
| 1321122070 |  | Fabricate HPA #5 Frozen by CR 12-028 | 60d | 2010-11-29 | 2011-03-02 | 1321122065 FS-40d | 108d |
| 1321122100 |  | Install/Test HPA #1 | 150d | 2010-12-31 | 2011-08-04 | 132127025b FS-280d, 132127025a FS-280d, 1321122050, 1321121015, 1321121035 | 19d |
| 1321122075 |  | Fabricate HPA #6 Frozen by CR 12-028 | 60d | 2011-01-04 | 2011-03-30 | 1321122070 FS-40d | 399d |

| ID | WBS | Task | Duration | Start | Finish | Predecessors | Total float |
| --- | --- | --- | --- | --- | --- | --- | --- |
| 1321122015 |  | Install: Aux PS, Cabling FY11 | 188d | 2011-01-05 | 2011-09-30 | 3A-03M, 1321122010a FS-60d, 9-110M FS+60d | 291d |
| 1321122080 |  | Fabricate HPA #7 Frozen by CR 12-028 | 60d | 2011-02-02 | 2011-04-27 | 1321122075 FS-40d | 424d |
| 1321122105 |  | Install/Test HPA #2 | 131d | 2011-03-01 | 2011-09-01 | 1321122055a, 1321121040 | 12d |
| 1321122085 |  | Fabricate HPA #8 Frozen by CR 12-028 | 60d | 2011-03-03 | 2011-05-25 | 1321122080 FS-40d | 449d |
| 1321122030 |  | Install Solenoid PS FY11 | 144d | 2011-03-10 | 2011-09-30 | 1321122026 FS-80d, 1321122025, 9-110M FS+60d | 291d |
| 1321122090 |  | Fabricate HPA #9 Frozen by CR 12-028 | 60d | 2011-03-31 | 2011-06-23 | 1321122085 FS-40d | 490d |
| 1321122110 |  | Install/Test HPA #3 | 128d | 2011-04-01 | 2011-09-30 | 1321122060a, 1321121045 | 185d |
| 1321122095 |  | Fabricate HPA #10 Frozen by CR 12-028 | 60d | 2011-04-28 | 2011-07-22 | 1321122090 FS-40d | 494d |
| 1321122115 |  | Install/Test HPA #4 FY11 | 107d | 2011-05-02 | 2011-09-30 | 1321121050, 1321122065 | 175d |
| 1321122120 |  | Install/Test HPA #5 FY11 Frozen by CR 12-028 | 86d | 2011-06-01 | 2011-09-30 | 1321121055, 1321122070 | 45d |
| 1321122015a |  | Install: Aux PS, Cabling FY12 | 174d | 2011-10-03 | 2012-06-18 | 1321122015 | 291d |
| 1321122030a |  | Install Solenoid PS FY12 | 174d | 2011-10-03 | 2012-06-18 | 1321122030 | 291d |
| 1321122047LOE |  | Engineering Oversight FY12 | 31d | 2011-10-03 | 2011-11-14 | 1321122046LOE | 434d |
| 1321122115a |  | Install/Test HPA #4 FY12 | 20d | 2011-10-03 | 2011-10-28 | 1321122115 | 175d |
| 1321122120a |  | Install/Test HPA #5 FY12 Frozen by CR 12-028 | 40d | 2011-10-03 | 2011-11-29 | 1321122120 | 45d |
| 1321122125 |  | Install/Test HPA #6 Frozen by CR 12-028 | 98d | 2011-10-03 | 2012-02-29 | 1321122075, 1321121060 | 270d |
| 1321122130 |  | Install/Test HPA #7 Frozen by CR 12-028 | 77d | 2011-11-01 | 2012-02-29 | 1321122080, 1321121065 | 294d |
| 1321122135 |  | Install/Test HPA #8 Frozen by CR 12-028 | 57d | 2011-12-01 | 2012-02-29 | 1321122085, 1321121070 | 319d |
| 1321122140 |  | Install/Test HPA #9 Frozen by CR 12-028 | 20d | 2012-02-01 | 2012-02-29 | 1321122090, 1321121075 | 343d |
| 1321122145 |  | Install/Test HPA #10 Frozen by CR 12-028 | 20d | 2012-02-01 | 2012-02-29 | 1321121080, 1321122095 | 367d |
| 1321122210 |  | Reverse Entry Per CR 12-028 | 15d | 2012-03-05 | 2012-03-23 | 9-120M FS+100d | 132d |
| 1321122150 |  | Fabricate HPA #5 Revised per CR 12-028 | 25d | 2012-10-01 | 2012-11-02 | 1321122065 FS-40d, 132127035 FS-99d, 132127030 FS-91d, 9-130M | 51d |
| 1321122155 |  | Fabricate HPA #6 Revised per CR 12-028 | 25d | 2012-10-22 | 2012-11-27 | 1321122150 FS-10d | 55d |
| 1321122160 |  | Fabricate HPA #7 Revised per CR 12-028 | 25d | 2012-11-12 | 2012-12-18 | 1321122155 FS-10d | 64d |
| 1321122180 |  | Install/Test HPA #5 Revised per CR 12-028 | 26d | 2012-11-13 | 2012-12-20 | 1321122150 FS+6d, 1321121055 | 51d |
| 1321122185 |  | Install/Test HPA #6 Revised per CR 12-028 | 26d | 2012-12-04 | 2013-01-16 | 1321122155, 1321122180 FS-13d, 1321121060 | 51d |
| 1321122165 |  | Fabricate HPA #8 Revised per CR 12-028 | 25d | 2012-12-05 | 2013-01-16 | 1321122160 FS-10d | 74d |
| 1321122170 |  | Fabricate HPA #9 Revised per CR 12-028 | 25d | 2012-12-19 | 2013-01-31 | 1321122165 FS-15d | 88d |
| 1321122190 |  | Install/Test HPA #7 Revised per CR 12-028 | 26d | 2012-12-31 | 2013-02-06 | 1321122185 FS-12d, 1321121065, 1321122160 | 61d |
| 1321122175 |  | Fabricate HPA #10 Revised per CR 12-028 | 25d | 2013-01-10 | 2013-02-14 | 1321122170 FS-15d | 102d |
| 1321122195 |  | Install/Test HPA #8 Revised per CR 12-028 | 26d | 2013-01-18 | 2013-02-26 | 1321121070, 1321122190 FS-13d, 1321122165 | 73d |
| 1321122200 |  | Install/Test HPA #9 Revised per CR 12-028 | 26d | 2013-02-07 | 2013-03-15 | 1321122195 FS-13d, 1321122170, 1321121075 | 84d |
| 1321122205 |  | Install/Test HPA #10 Revised per CR 12-028 | 26d | 2013-02-27 | 2013-04-03 | 1321122200 FS-13d, 1321122175, 1321121080 | 95d |
| 1321122215 |  | Re-Baseline Actuals Adjustment | 1d | 2013-08-30 | 2013-08-30 | 9-130M FS+227d | 20d |
|  | 3 | **1.3.2.1.1.3 WAVEGUIDE COMPONENTS** |  | 2009-08-19 | 2013-09-06 |  |  |
| 132113000 |  | Final Tweaking of Waveguide Layout (Klystron specific) (WVGUIDE COMPON) FY09 | 40d | 2009-08-19 | 2009-10-14 | 1212113090M, 132111035 FS+2d, 1212113170 | 188d |
| 132113005 |  | Release Prcrmnt: Circulators (WVGUIDE COMPON) | 10d | 2009-10-15 | 2009-10-28 | 132113000 | 237d |
| 132113010 |  | Release Prcrmnt: HOM Filter (WVGUIDE COMPON) | 10d | 2009-10-15 | 2009-10-28 | 132113000 | 188d |
| 132113015 |  | Release Prcrmnt: Waveguide Parts (WVGUIDE COMPON) | 10d | 2009-10-15 | 2009-10-28 | 132113000 | 188d |
| 132113020 |  | Release Prcrmnt: Special Waveguide (WVGUIDE COMPON) | 10d | 2009-10-15 | 2009-10-28 | 132113000 | 188d |
| 132113025 |  | Receive Responses, Evaluate, Award: Circulators (WVGUIDE COMPON) | 30d | 2009-10-29 | 2009-12-11 | 132113005 | 237d |
| 132113030 |  | Receive Responses, Evaluate, Award: HOM Filters (WVGUIDE COMPON) | 30d | 2009-10-29 | 2009-12-11 | 132113010 | 188d |
| 132113035 |  | Receive Responses, Evaluate, Award: Special Waveguide (WVGUIDE COMPON) | 30d | 2009-10-29 | 2009-12-11 | 132113015 | 188d |
| 132113040 |  | Receive Responses, Evaluate, Award: Waveguide Parts (WVGUIDE COMPON) | 30d | 2009-10-29 | 2009-12-11 | 132113020 | 188d |
| 132113050 |  | Receive First HOMs (manufacturing delay) (WVGUIDE COMPON) | 60d | 2009-12-14 | 2010-03-17 | 132113030 | 188d |
| 132113055 |  | Receive First Special Waveguide (mfr delay) (WVGUIDE COMPON) | 60d | 2009-12-14 | 2010-03-17 | 132113035 | 188d |
| 132113060 |  | Receive First Waveguide Parts (mfr delay) (WVGUIDE COMPON) | 60d | 2009-12-14 | 2010-03-17 | 132113040 | 188d |
| 132113045 |  | Vend Fab Circulators Peg Point #1 Design Review | 33d | 2010-01-04 | 2010-02-19 | 9-100M FS+59d, 132113025 | 228d |
| 132113045A |  | Vend Fab Circulators Peg Point #2 1st Article Testing | 75d | 2010-01-04 | 2010-04-20 | 132113045 FS-33d | 228d |
| 132113045B |  | Vend Fab Circulators Peg Point #3 1st Article Delivery and Acceptance | 103d | 2010-01-04 | 2010-05-28 | 132113045A FS-75d | 228d |
| 132113045C |  | Vend Fab Circulators Peg Point #4 Units 2-20 Delivery and Acceptance | 125d | 2010-01-04 | 2010-06-30 | 132113045B FS-103d | 228d |
| 132113045D |  | Vend Fab Circulators Peg Point #5 Units 21-40 Delivery and Acceptance | 146d | 2010-01-04 | 2010-07-30 | 132113045C FS-125d | 228d |
| 132113045F |  | Vend Fab Circulators Peg Point #6 Units 41-60 Delivery and Acceptance | 168d | 2010-01-04 | 2010-08-31 | 132113045D FS-146d | 228d |
| 132113045G |  | Vend Fab Circulators Peg Point #7 Units 61-84 Delivery and Acceptance | 189d | 2010-01-04 | 2010-09-30 | 132113045F FS-168d | 228d |
| 132113065 |  | Receive,Test,Install Waveguide Compnts (P-#1, 4 zones) (WVGUIDE COMPON) Labor FY10 | 138d | 2010-03-18 | 2010-09-30 | 132113060, 132113050, 32-03M, 132113055 | 188d |
| 132113065b |  | Receive,Test,Install Waveguide Compnts (P-#1, 4 zones) (WVGUIDE COMPON) Procurement | 178d | 2010-03-18 | 2010-11-29 | 132113060, 132113055, 32-03M, 132113050 | 188d |
| 132113100 |  | Develop and Release Bid Package (40) HOM Filter (WVGUIDE COMPON) | 20d | 2010-05-04 | 2010-06-01 | 9-100M FS+143d | 207d |
| 132113105 |  | Receive Responses, Evaluate, Award: (40) HOM Filters (WVGUIDE COMPON) | 50d | 2010-06-02 | 2010-08-11 | 132113100 | 207d |
| 132113065a |  | Receive,Test,Install Waveguide Compnts (P-#1, 4 zones) (WVGUIDE COMPON) Labor FY11 | 40d | 2010-10-01 | 2010-11-29 | 132113065 | 188d |
| 132113110 |  | Vend Fab (40) HOMs (manufacturing delay) (WVGUIDE COMPON) | 198d | 2010-11-05 | 2011-08-25 | 132113105 FS+60d | 207d |
| 132113070M |  | End P-#1 Waveguide Installtn (WVGUIDE COMPON) | 0d | 2010-11-29 | 2010-11-29 | 132113065a, 132113065b | 188d |
| 132113075 |  | Receive,Test,Install Waveguide Compnts (P-#2, 4 zones) (WVGUIDE COMPON) Labor FY11 | 188d | 2011-01-05 | 2011-09-30 | 132113070M, 9-110M FS+60d, 132113045G | 168d |
| 132113075b |  | Receive,Test,Install Waveguide Compnts (P-#2, 4 zones) (WVGUIDE COMPON) Procurement | 245d | 2011-01-05 | 2011-12-29 | 9-110M FS+60d, 132113045G, 132113070M | 168d |
| 132113115 |  | Receive and Inspect: (40) HOM Filters (WVGUIDE COMPON) | 148d | 2011-02-15 | 2011-09-14 | 132113110 FS-135d | 207d |
| 132113075a |  | Receive,Test,Install Waveguide Compnts (P-#2, 4 zones) (WVGUIDE COMPON) Labor FY12 | 57d | 2011-10-03 | 2011-12-29 | 132113075 | 168d |
| 132113080M |  | End P-#2 Waveguide Installtn (WVGUIDE COMPON) | 0d | 2012-04-24 | 2012-04-24 | 132113075a FS+80d, 132113075b FS+80d | 168d |
| 132113085 |  | Receive,Test,Install Waveguide Compnts (P-#3, 2 zones) (WVGUIDE COMPON) FY12 | 110d | 2012-04-25 | 2012-09-28 | 132113080M | 168d |
| 132113085b |  | Receive,Test,Install Waveguide Compnts (P-#3, 2 zones) (WVGUIDE COMPON) Procurement | 200d | 2012-04-25 | 2013-02-14 | 132113080M | 168d |
| 132113085a |  | Receive,Test,Install Waveguide Compnts (P-#3, 2 zones) (WVGUIDE COMPON) FY13 | 90d | 2012-10-01 | 2013-02-14 | 132113085 | 168d |
| 132113130 |  | Klystron:Modify 20 tubes for body current problems | 13d | 2012-11-05 | 2012-11-21 | 9-130M FS+25d | 52d |

| ID | WBS | Task | Duration | Start | Finish | Predecessors | Total float |
| --- | --- | --- | --- | --- | --- | --- | --- |
| 132113120 |  | Remove SL Circulators for Repair | 58d | 2013-01-14 | 2013-04-05 | 9-130M FS+67d | 73d |
| 132113090M |  | Waveguide Installtn Comp (WVGUIDE COMPON) | 0d | 2013-02-14 | 2013-02-14 | 132113085a, 132113085b | 168d |
| 132113125 |  | Test and Reinstall SL Circulators | 75d | 2013-03-18 | 2013-07-01 | 132113120 FS-15d | 73d |
| 132113135 |  | Klystrons: Retune 20 tubes after Mods | 75d | 2013-03-18 | 2013-07-01 | 132113130 FS+72d | 52d |
| 132113140 |  | Re-Baseline Actuals Adjustment | 1d | 2013-08-30 | 2013-08-30 | 9-130M FS+227d | 20d |
| 232113125 |  | Test and Reinstall SL Circulators | 4d | 2013-09-03 | 2013-09-06 | 9-130M FS+228d | 71d |
|  | 2 | **1.3.2.1.2 CONTROL** |  | 2009-10-01 | 2013-08-30 |  |  |
|  | 1 | **1.3.2.1.2.1 FIELD CONTROL (RF Items - All LLRF Labor)** |  | 2009-10-01 | 2013-08-30 |  |  |
| 132121000 |  | RF & Digital Bd Bid & Award (FIELD Control) | 60d | 2009-10-01 | 2010-01-04 | 1212121170, 9-100M, 1212121145M, 1212121095 | 74d |
| 132121001 |  | RF & Digital Bd Vendor Fab (FIELD Control) | 156d | 2010-01-05 | 2010-08-16 | 9-100M FS+60d, 132121000 | 74d |
| 132121005 |  | First Article (RF and Digital) Inspection and Test (IPL 521215020M) | 40d | 2010-02-01 | 2010-03-29 | 132121001 FS-138d, 1212125025M | 74d |
| 132121020M |  | Comp First Article Board Testing (FIELD CONTROL) | 0d | 2010-03-29 | 2010-03-29 | 132121005 | 74d |
| 132121010 |  | RF Boards Inspection and Testing | 98d | 2010-04-12 | 2010-08-27 | 132121005 FS+9d | 74d |
| 132121025 |  | Digital Boards Inspection and Testing | 98d | 2010-04-12 | 2010-08-27 | 132121005, 132121020M FS+9d | 74d |
| 132121030M |  | 1/2 Production Boards Tested (FIELD CONTROL) | 0d | 2010-06-29 | 2010-06-29 | 132121005, 132121025 FS-43d | 126d |
| 132121040 |  | FC Chassis Procure and Fabricate Labor FY10 | 66d | 2010-06-29 | 2010-09-30 | 132121010 FS-46d, 9-110M FS-66d | 268d |
| 132121040b |  | FC Chassis Procure and Fabricate Procurement | 145d | 2010-06-29 | 2011-02-01 | 132121010 FS-46d, 9-110M FS-66d | 268d |
| 132121045 |  | First FC Chassis Tested (FIELD Control) Labor FY10 | 46d | 2010-07-28 | 2010-09-30 | 132121035M FS-32d, 132121010 FS-23d | 74d |
| 132121045b |  | First FC Chassis Tested (FIELD Control) Procurement | 85d | 2010-07-28 | 2010-11-24 | 132121035M FS-32d, 132121010 FS-23d | 74d |
| 132121035M |  | Comp Production Board Testing (FIELD CONTROL) | 0d | 2010-09-10 | 2010-09-10 | 132121025 FS+9d, 132121030M | 74d |
| 132121040a |  | FC Chassis Procure and Fabricate Labor FY11 | 79d | 2010-10-01 | 2011-02-01 | 132121040 | 268d |
| 132121045a |  | First FC Chassis Tested (FIELD Control) Labor FY11 | 39d | 2010-10-01 | 2010-11-24 | 132121045 | 74d |
| 132121055 |  | FC Chassis Bench Testing (FIELD Control) Labor FY11 | 175d | 2011-01-25 | 2011-09-30 | 3A-02M FS-120d, 132121040b FS-200d, 132125020, 32-03M, 132121040a FS-200d | 74d |
| 132121055b |  | FC Chassis Bench Testing (FIELD Control) Procurement | 289d | 2011-01-25 | 2012-03-22 | 3A-02M FS-120d, 32-03M, 132121040a FS-200d, 132121040b FS-200d, 132125020 | 74d |
| 132121061M |  | First Zone Installed/Tested (FIELD CONTROL) | 0d | 2011-05-02 | 2011-05-02 | 132121060b FS-226d, 132121060a FS-226d | 74d |
| 132121062M |  | Second Zone Installed/Tested (FIELD CONTROL) | 0d | 2011-05-27 | 2011-05-27 | 132121061M FS+20d | 74d |
| 132121060 |  | Zone Test & Check (FIELD Control) Labor FY11 Frozen Per CR12-028 | 81d | 2011-06-08 | 2011-09-30 | 132121045b, 132121055a FS-195d, 132121055b FS-195d, 132121045a | 95d |
| 132121060b |  | Zone Test & Check (FIELD Control) Procurement Frozen Per CR12-028 | 200d | 2011-06-08 | 2012-03-29 | 132121055b FS-195d, 132121045a, 132121055a FS-195d, 132121045b | 74d |
| 132121063M |  | Third Zone Installed/Tested (FIELD CONTROL) | 0d | 2011-06-27 | 2011-06-27 | 132121062M FS+20d | 217d |
| 132121064M |  | Fourth Zone Installed/Tested (FIELD CONTROL) | 0d | 2011-07-26 | 2011-07-26 | 132121063M FS+20d | 217d |
| 132121055a |  | FC Chassis Bench Testing (FIELD Control) Labor FY12 | 114d | 2011-10-03 | 2012-03-22 | 132121055 | 74d |
| 132121060a |  | Zone Test & Check (FIELD Control) Labor FY12 Frozen Per CR12-028 | 98d | 2011-10-03 | 2012-02-29 | 132121060 | 95d |
| 132121060f |  | Reverse Entry Per CR12-028 | 15d | 2012-03-05 | 2012-03-23 | 9-120M FS+100d | 132d |
| 132121050M |  | Comp FC Bench Testing (FIELD CONTROL) | 0d | 2012-04-02 | 2012-04-02 | 132121055a FS+7d, 132121055b FS+7d | 344d |
| 132121060c |  | Zone Test & Check (FIELD Control) Labor Revised Per CR12-028 | 91d | 2012-10-01 | 2013-02-15 | 9-130M | 67d |
| 132121060d |  | Zone Test & Check (FIELD Control) Procurement Revised Per CR12-028 | 99d | 2012-10-01 | 2013-02-28 | 9-130M | 129d |
| 132121065M |  | Fifth Zone Installed/Tested (FIELD CONTROL) | 0d | 2012-10-30 | 2012-10-30 | 132121060c FS-70d, 132121064M FS+20d, 132123020M | 67d |
| 132121066M |  | Sixth Zone Installed/Tested (FIELD CONTROL) | 0d | 2012-11-30 | 2012-11-30 | 132121065M FS+22d | 67d |
| 132121067M |  | Seventh Zone Installed/Tested (FIELD CONTROL) | 0d | 2012-12-14 | 2012-12-14 | 132121066M FS+10d | 67d |
| 132121068M |  | Eighth Zone Installed/Tested (FIELD CONTROL) | 0d | 2013-01-15 | 2013-01-15 | 132121067M FS+16d | 101d |
| 132121069M |  | Ninth Zone Installed/Tested (FIELD CONTROL) | 0d | 2013-02-01 | 2013-02-01 | 132121068M FS+12d | 113d |
| 132121070M |  | Tenth Zone Installed/Tested (FIELD CONTROL) | 0d | 2013-02-15 | 2013-02-15 | 132121050M, 132121060a, 132121069M, 132121060d FS-10d, 132123025M, 132121060c, 132121060b | 127d |
| 132121075 |  | Re-Baseline Actuals Adjustment | 1d | 2013-08-30 | 2013-08-30 | 9-130M FS+227d | 20d |
|  | 2 | **1.3.2.1.2.2 RESONANCE CONTROL & INTERLOCKS (Interlocks,Tuner Controls)** |  | 2010-06-02 | 2013-08-30 |  |  |
| 132122015 |  | Fab & Test Heater & Interlock (RESON CTRL) Labor FY10 | 85d | 2010-06-02 | 2010-09-30 | 9-100M FS+163d | 124d |
| 132122015b |  | Fab & Test Heater & Interlock (RESON CTRL) Procurement | 183d | 2010-06-02 | 2011-03-01 | 9-100M FS+163d | 124d |
| 132122010 |  | Fab & Test PZT Chassis (RESON CTRL) Phase 1 | 1d | 2010-07-01 | 2010-07-01 | 9-100M FS+184d | 154d |
| 132122010a |  | Fab & Test PZT Chassis (RESON CTRL) Phase 2 Labor FY10 | 63d | 2010-07-02 | 2010-09-30 | 132122010 | 154d |
| 132122010c |  | Fab & Test PZT Chassis (RESON CTRL) Phase 2 Procurement | 131d | 2010-07-02 | 2011-01-14 | 132122010 | 154d |
| 132122000 |  | Bid & Award Matrl & Parts (RESON CTRL) FY10 | 19d | 2010-09-03 | 2010-09-30 | 9-110M FS-19d, 1212122170, 1212122110M | 555d |
| 132122000a |  | Bid & Award Matrl & Parts (RESON CTRL) FY11 | 41d | 2010-10-01 | 2010-11-30 | 132122000 | 555d |
| 132122010b |  | Fab & Test PZT Chassis (RESON CTRL) Phase 2 Labor FY11 | 68d | 2010-10-01 | 2011-01-14 | 132122010a | 154d |
| 132122015a |  | Fab & Test Heater & Interlock (RESON CTRL) Labor FY11 | 98d | 2010-10-01 | 2011-03-01 | 132122015 | 124d |
| 132122001 |  | Vend Fab Matrl & Parts (RESON CTRL) | 50d | 2011-01-05 | 2011-03-17 | 132122000a, 9-110M FS+60d | 536d |
| 132122020 |  | Zone Test and Check (Reson Ctrl) Labor FY11 Frozen Per CR12-028 | 140d | 2011-03-16 | 2011-09-30 | 132122015b FS+10d, 132122015a FS+10d | 376d |
| 132122020b |  | Zone Test and Check (Reson Ctrl) Procurement Frozen Per CR12-028 | 251d | 2011-03-16 | 2012-03-19 | 132122015a FS+10d, 132122015b FS+10d | 363d |
| 132122005 |  | Fab & Test Stepper Chassis (RESON CTRL) | 107d | 2011-03-18 | 2011-08-17 | 132122001, 9-120M FS-170d | 536d |
| 132122021M |  | First Zone Installed/Tested (RESON CTRL) | 0d | 2011-06-03 | 2011-06-03 | 132122020a FS-195d, 132122020b FS-195d, 132122010 | 363d |
| 132122022M |  | Second Zone Installed/Tested (RESON CTRL) | 0d | 2011-06-30 | 2011-06-30 | 132122021M FS+20d | 363d |
| 132122023M |  | Third Zone Installed/Tested (RESON CTRL) | 0d | 2011-07-29 | 2011-07-29 | 132122022M FS+20d | 363d |
| 132122024M |  | Fourth Zone Installed/Tested (RESON CTRL) | 0d | 2011-08-26 | 2011-08-26 | 132122023M FS+20d | 363d |
| 132122020a |  | Zone Test and Check (Reson Ctrl) Labor FY12 Frozen Per CR12-028 | 98d | 2011-10-03 | 2012-02-29 | 132122020 | 376d |
| 132122020f |  | Reverse Entry Per CR12-028 | 15d | 2012-03-05 | 2012-03-23 | 9-120M FS+100d | 132d |
| 132122020c |  | Zone Test and Check (Reson Ctrl) Labor Revised Per CR12-028 | 91d | 2012-10-01 | 2013-02-15 | 9-130M | 91d |
| 132122020d |  | Zone Test and Check (Reson Ctrl) Procurement Revised Per CR12-028 | 99d | 2012-10-01 | 2013-02-28 | 9-130M | 133d |
| 132122025M |  | Fifth Zone Installed/Tested (RESON CTRL) | 0d | 2012-10-30 | 2012-10-30 | 132122024M FS+20d, 132122020c FS-70d | 91d |
| 132122026M |  | Sixth Zone Installed/Tested (RESON CTRL) | 0d | 2012-11-30 | 2012-11-30 | 132122025M FS+22d | 142d |
| 132122027M |  | Seventh Zone Installed/Tested (RESON CTRL) | 0d | 2012-12-14 | 2012-12-14 | 132122026M FS+10d | 142d |
| 132122028M |  | Eighth Zone Installed/Tested (RESON CTRL) | 0d | 2013-01-15 | 2013-01-15 | 132122027M FS+16d | 142d |
| 132122029M |  | Ninth Zone Installed/Tested (RESON CTRL) | 0d | 2013-02-01 | 2013-02-01 | 132122028M FS+12d | 142d |

| ID | WBS | Task | Duration | Start | Finish | Predecessors | Total float |
| --- | --- | --- | --- | --- | --- | --- | --- |
| 132122030M |  | Tenth Zone Installed/Tested (RESON CTRL) | 0d | 2013-02-15 | 2013-02-15 | 132122029M, 132122020d FS-9d | 133d |
| 132122035 |  | Re-Baseline Actuals Adjustment | 1d | 2013-08-30 | 2013-08-30 | 9-130M FS+227d | 20d |
|  | 3 | **1.3.2.1.2.3 PACKAGING/INTERFACE (Racks, Crates)** |  | 2010-05-20 | 2013-08-30 |  |  |
| 132123005 |  | Production Pwr Supply Delivered & Tested | 93d | 2010-05-20 | 2010-09-30 | 1212123055M, 9-100M FS+155d | 454d |
| 132123010 |  | Fab Chassis & Cable Harnesses Labor FY10 | 65d | 2010-06-30 | 2010-09-30 | 132123005 FS-65d | 454d |
| 132123010b |  | Fab Chassis & Cable Harnesses Procurement | 162d | 2010-06-30 | 2011-02-28 | 132123005 FS-65d | 454d |
| 132123012 |  | Install Rack Supports & Conduit | 60d | 2010-07-02 | 2010-09-27 | 9-100M FS+185d | 459d |
| 132123000 |  | Bid & Award Racks & Cabling FY10 | 21d | 2010-09-01 | 2010-09-30 | 1212123170, 9-110M FS-21d | 474d |
| 132123000a |  | Bid & Award Racks & Cabling Fy11 | 39d | 2010-10-01 | 2010-11-24 | 132123000 | 474d |
| 132123010a |  | Fab Chassis & Cable Harnesses Labor FY11 | 97d | 2010-10-01 | 2011-02-28 | 132123010 | 454d |
| 132123015 |  | Install Chassis, Racks & Cabling Labor FY11 | 211d | 2010-11-23 | 2011-09-30 | 132123001 FS-117d, 132123012, 132123010a FS-95d, 132123010b FS-95d, 1321122042a | 419d |
| 132123015b |  | Install Chassis, Racks & Cabling Labor Procurement | 212d | 2010-11-23 | 2011-10-03 | 132123012, 1321122042a, 132123010a FS-95d, 132123010b FS-95d, 132123001 FS-117d | 419d |
| 132123001 |  | Vend Fab Racks & Cabling | 60d | 2011-01-05 | 2011-03-31 | 132123000a, 9-110M FS+60d | 453d |
| 132123020M |  | 5 Racks Installed (PACKAGING) | 0d | 2011-06-03 | 2011-06-03 | 132123015a FS-85d, 132123015b FS-85d | 419d |
| 132123015a |  | Install Chassis, Racks & Cabling Labor FY12 | 1d | 2011-10-03 | 2011-10-03 | 132123015 | 419d |
| 132123025M |  | All Racks Installed (PACKAGING) | 0d | 2011-10-03 | 2011-10-03 | 132123015b, 132123015a | 464d |
| 132123030 |  | Re-Baseline Actuals Adjustment | 1d | 2013-08-30 | 2013-08-30 | 9-130M FS+227d | 20d |
|  | 4 | **1.3.2.1.2.4 CPU & SOFTWARE** |  | 2010-05-03 | 2013-08-30 |  |  |
| 132124000 |  | Bid & Award PC104 & Test (CPU) | 60d | 2010-05-03 | 2010-07-27 | 9-100M FS+142d | 126d |
| 132124001 |  | Vend Fab PC104 & Test (CPU) | 86d | 2010-06-02 | 2010-10-01 | 9-100M FS+60d, 132124000 FS-39d | 126d |
| 132124005 |  | EPICS Interface (CPU) | 63d | 2010-10-04 | 2011-01-10 | 132124001 | 283d |
| 132124010 |  | Test Software (CPU) | 75d | 2010-11-01 | 2011-02-25 | 132124005 FS-200d, 132124001 FS+20d | 126d |
| 132124015 |  | Re-Baseline Actuals Adjustment | 1d | 2013-08-30 | 2013-08-30 | 9-130M FS+227d | 20d |
|  | 5 | **1.3.2.1.2.5 TEST STAND** |  | 2009-11-04 | 2013-08-30 |  |  |
| 132125000 |  | Bid & Award Test Equipment (Test STAND) | 60d | 2009-11-04 | 2010-02-08 | 9-100M FS+24d | 74d |
| 132125001 |  | Vend Fab Test Equipment (Test STAND) | 60d | 2010-02-09 | 2010-05-04 | 9-100M FS+60d, 132125000 | 74d |
| 132125010 |  | Automation Software FY10 | 67d | 2010-06-28 | 2010-09-30 | 132125005 FS-65d | 74d |
| 132125005 |  | Assemble Test Stand (Test STAND) | 62d | 2010-07-01 | 2010-09-28 | 132125001 FS+40d | 74d |
| 132125015 |  | Program Cavity Simulator (Test STAND) FY10 | 61d | 2010-07-07 | 2010-09-30 | 132125001 FS+43d | 89d |
| 132125010a |  | Automation Software FY11 | 42d | 2010-10-01 | 2010-12-01 | 132125010 | 74d |
| 132125015a |  | Program Cavity Simulator (Test STAND) FY11 | 2d | 2010-10-01 | 2010-10-04 | 132125015 | 89d |
| 132125020 |  | Test Automation (Test STAND) | 71d | 2010-10-05 | 2011-01-24 | 132125005, 132125015a FS-15d, 132125010a FS-40d | 74d |
| 132125025 |  | Re-Baseline Actuals Adjustment | 1d | 2013-08-30 | 2013-08-30 | 9-130M FS+227d | 20d |
|  | 6 | **1.3.2.1.2.6 MASTER OSCILLATOR** |  |  |  |  |  |
|  | 7 | **1.3.2.1.2.7 HPA CONTROLS** |  | 2010-10-01 | 2013-08-30 |  |  |
| 132127000 |  | Bid & Award HPA Board (HPA CNTLS) | 60d | 2010-10-01 | 2011-01-04 | 9-110M, 1212127065M, 1212127170 | 22d |
| 132127005 |  | First Article Test (HPA CNTLS) | 38d | 2010-12-02 | 2011-02-02 | 9-110M FS+42d | 63d |
| 132127001 |  | Vend Fab HPA Board (HPA CNTLS) | 61d | 2011-01-05 | 2011-04-01 | 9-110M FS+60d, 132127000 | 22d |
| 132127020M |  | Final Bench Test (HPA CNTLS) | 0d | 2011-02-15 | 2011-02-15 | 132127010M FS-40d, 132127015 FS-140d | 22d |
| 132127025 |  | Installtn (HPA CNTLS) Labor FY11 Frozen per CR 12-028 | 160d | 2011-02-15 | 2011-09-30 | 132127020M | 22d |
| 132127025b |  | Installtn (HPA CNTLS) Procurement Frozen per CR 12-028 | 247d | 2011-02-15 | 2012-02-13 | 132127020M | 22d |
| 132127010M |  | Final Board Delivered (HPA CNTLS) | 0d | 2011-04-01 | 2011-04-01 | 132127005, 132127001 | 22d |
| 132127015 |  | Chassis Fab & Test (HPA CNTLS) | 87d | 2011-05-02 | 2011-09-01 | 132127005, 132127010M FS+20d | 22d |
| 132127025a |  | Installtn (HPA CNTLS) Labor FY12 Frozen per CR 12-028 | 87d | 2011-10-03 | 2012-02-13 | 132127025 | 22d |
| 132127040 |  | Reverse Entry per CR12-028 | 15d | 2012-03-05 | 2012-03-23 | 9-120M FS+100d | 132d |
| 132127030 |  | Installtn (HPA CNTLS) Labor Revised per CR12-028 | 91d | 2012-10-01 | 2013-02-15 | 9-130M | 51d |
| 132127035 |  | Installtn (HPA CNTLS) Procurement Revised per CR12-028 | 99d | 2012-10-01 | 2013-02-28 | 9-130M | 51d |
| 132127045 |  | Re-Baseline Actuals Adjustment | 1d | 2013-08-30 | 2013-08-30 | 9-130M FS+227d | 20d |
|  | 3 | **1.3.2.1.3 INSTALLATION & SYSTEM COMMISSIONING (Test Equipment, System Integration Labor)** |  | 2010-10-01 | 2013-11-06 |  |  |
| 13213000 |  | BId & Award Test Equipment (Install & SYS COMMIS) | 60d | 2010-10-01 | 2011-01-04 | 9-110M, 132121045a FS-40d, 132121045b FS-40d | 73d |
| 13213001 |  | Vend Fab Test Equipment (Install & SYS COMMIS) | 60d | 2011-01-05 | 2011-03-31 | 9-110M FS+60d, 13213000 | 73d |
| 13213005 |  | Fab & Program RF Test Stand (Install & SYS COMMIS) | 60d | 2011-03-03 | 2011-05-25 | 13213001 FS-21d, 1212125025M | 73d |
| 13213010 |  | RF Sys Tests #1 (Install & SYS COMMIS) | 10d | 2011-07-29 | 2011-08-11 | 132122010b, 132127020M, 132121061M, 132112081M FS-5d, 132122010c, 13213005 FS-10d, 132122015a, 132122015b, 132124010, 131501000 FS-5d | 19d |
| 13213015 |  | RF Cavity Tests Cryomodule #1 (Install & SYS COMMIS) | 18d | 2011-08-12 | 2011-09-07 | 13213010, 131501005 FS-18d | 522d |
| 13213010a |  | RF Sys Tests #2 (Install & SYS COMMIS) | 10d | 2011-08-26 | 2011-09-09 | 132121062M, 132112082M FS-5d, 131502000 FS-5d | 12d |
| 13213015a |  | RF Cavity Tests Cryomodule #2 (Install & SYS COMMIS) FY11 | 15d | 2011-09-12 | 2011-09-30 | 131502005a FS-18d, 13213010a | 502d |
| 13213015ab |  | RF Cavity Tests Cryomodule #2 (Install & SYS COMMIS) FY12 | 3d | 2011-10-03 | 2011-10-05 | 13213015a | 502d |
| 13213010b |  | RF Sys Tests #3 (Install & SYS COMMIS) | 10d | 2012-05-29 | 2012-06-12 | 132121063M, 131504000, 132112083M FS-5d | 312d |
| 13213010c |  | RF Sys Tests #4 (Install & SYS COMMIS) | 10d | 2012-06-11 | 2012-06-22 | 131505000, 132121064M, 132112084M FS-5d | 35d |
| 13213015c |  | RF Cavity Tests Cryomodule #4 (Install & SYS COMMIS) | 18d | 2012-06-25 | 2012-07-18 | 131504005 FS-18d, 13213010c | 309d |
| 13213015d |  | RF Cavity Tests Cryomodule #5 (Install & SYS COMMIS) | 18d | 2012-07-04 | 2012-07-27 | 13213010b, 131505005 FS-18d | 302d |
| 13213020M |  | Comp Cavity Tests (INSTALL & SYS COMMIS) | 0d | 2013-08-23 | 2013-08-23 | 132113125, 181315025, 181321045, 13213015c, 132122005, 13213015ab, 13213015, 13213015d, 181321055, 181321030, 181321035, 181321050, 181321040 | 35d |
| 13213025 |  | Re-Baseline Actuals Adjustment | 1d | 2013-08-30 | 2013-08-30 | 9-130M FS+227d | 20d |
| 23213020M |  | Comp Cavity Tests (INSTALL & SYS COMMIS) | 0d | 2013-11-06 | 2013-11-06 | 232113125, 281315025, 281321055, 281315025a, 281321050 | 28d |
|  | 4 | **1.3.2.1.4 SYSTEM OPERATION** |  |  |  |  |  |
|  | 2 | **1.3.2.2 MAGNET POWER** |  | 2009-01-02 | 2014-09-30 |  |  |
|  | 1 | **1.3.2.2.1 BOX SUPPLIES** |  | 2009-01-02 | 2014-09-30 |  |  |
| 13221028 |  | Prcrmnt Prep for Box 600/500kW PS - Arc & Septa (Box SUPPLIES) | 60d | 2009-01-02 | 2009-03-30 | 9-090M FS+59d, 121221150 | 971d |
| 13221029M |  | Award Box 600/500 KW PS (BOX SUPPLIES) | 0d | 2010-01-05 | 2010-01-05 | 13221028, 9-100M FS+60d | 782d |
| 13221030 |  | Vend Fab Box 600/500 kW PS - Original Travel Expenses | 37d | 2010-01-05 | 2010-02-26 | 13221029M, 9-100M FS+60d | 878d |

| ID | Task | Duration | Start | Finish | Predecessors | Total float |
| --- | --- | --- | --- | --- | --- | --- |
| 13221035 | Monitor Contract Vend Progress- 600/500kW Box PS Original Labor | 37d | 2010-01-05 | 2010-02-26 | 9-100M FS+60d, 13221029M | 782d |
| 13221010N | Vend Fab Magnet System Box Power Supplies Peg Point #12 Delivery and Accp of Prod PS (QTY 2) (Frozen Per CR11-055) | 365d | 2010-03-18 | 2011-08-31 | 9-100M FS+110d | 1024d |
| 13221010P | Vend Fab Magnet System Box Power Supplies Peg Point #13 Delivery and Accp of Spare Parts (Frozen Per CR11-055) | 365d | 2010-03-18 | 2011-08-31 | 13221010N FS-365d | 1024d |
| 13221005 | Vend Fab Magnet System Box Power Supplies Oversight FY10 | 137d | 2010-03-19 | 2010-09-30 | 13221004M FS-137d, 13221035 | 768d |
| 13221010 | Vend Fab Magnet System Box Power Supplies Peg Point #1 Preliminary Design Report | 51d | 2010-03-19 | 2010-05-28 | 13221004M FS-137d | 542d |
| 13221010A | Vend Fab Magnet System Box Power Supplies Peg Point #2 Design Review and Approval | 73d | 2010-03-19 | 2010-06-30 | 13221010 FS-51d | 542d |
| 13221010B | Vend Fab Magnet System Box Power Supplies Peg Point #3 First Article Testing - First Topology (Frozen Per CR11-055) | 195d | 2010-03-19 | 2010-12-30 | 13221010A FS-73d | 542d |
| 13221010C | Vend Fab Magnet System Box Power Supplies Peg Point #4 First Article Testing - All Topologies (Frozen Per CR11-055) | 234d | 2010-03-19 | 2011-02-28 | 13221010B FS-195d | 542d |
| 13221010D | Vend Fab Magnet System Box Power Supplies Peg Point #5 Delivery and Accp of Prod Power Supplies (Frozen Per CR11-055) | 257d | 2010-03-19 | 2011-03-31 | 13221010C FS-234d | 542d |
| 13221010H | Vend Fab Magnet System Box Power Supplies Peg Point #8 Delivery and Accp of Prod Power Supplies (Frozen Per CR11-055) | 321d | 2010-03-19 | 2011-06-30 | 13221010D FS-257d | 542d |
| 13221077 | Dummy Load Design Re-work / Documentation | 42d | 2010-05-04 | 2010-07-01 | 9-100M FS+143d | 772d |
| 13221095 | Engineering Oversight - Develop/Conduct Procedures, Q.A. and Training FY10 | 98d | 2010-05-13 | 2010-09-30 | 9-100M FS+150d | 227d |
| 13221078 | Order Dummy Load Parts | 21d | 2010-07-02 | 2010-08-02 | 13221077 | 772d |
| 13221003 | Bid/Award Box 1000 kW PS - Arc (Box SUPPLIES) | 60d | 2010-07-08 | 2010-09-30 | 9-110M FS-60d | -129d |
| 13221053 | Bid/Award Box Low Power PS - Transport (Box SUPPLIES) | 60d | 2010-07-08 | 2010-09-30 | 9-110M FS-60d | -129d |
| 13221080 | Dummy Load Procurement | 44d | 2010-08-03 | 2010-10-04 | 13221078 | 772d |
| 13221004M | Award Magnet System Box Power Supplies | 0d | 2010-10-01 | 2010-10-01 | 13221003, 13221054M | -129d |
| 13221005A | Vend Fab Magnet System Box Power Supplies Oversight FY11 | 248d | 2010-10-01 | 2011-09-30 | 13221005 | 768d |
| 13221054M | Award Box Low Power PS (BOX SUPPLIES) | 0d | 2010-10-01 | 2010-10-01 | 9-110M, 13221053 | -129d |
| 13221095LOE | Engineering Oversight - Develop/Conduct Procedures, Q.A. and Training FY11 | 248d | 2010-10-01 | 2011-09-30 | 13221095 | 227d |
| 13221118 | Bid Compnts to Refurb 5 PS (Box SUPPLIES) | 80d | 2010-10-01 | 2011-02-02 | 9-110M | 459d |
| 13221085 | Dummy Load - Fabricate Sub Assemblies | 50d | 2010-10-05 | 2010-12-15 | 13221080 | 772d |
| 13221098 | Procure Extraction YA PS & Shunt Sub assemblies | 50d | 2010-12-07 | 2011-02-24 | 9-110M FS+45d | 300d |
| 13221090 | Dummy Load Assemble Unit #1 | 45d | 2010-12-16 | 2011-02-28 | 13221085 | 772d |
| 13221119M | Award Components to Refurb 6 PS (BOX SUPPLIES) Frozen Per CR 12-028 | 0d | 2011-02-03 | 2011-02-03 | 13221118 | 459d |
| 13221120 | Vend Fab Compnts to Refurb 6 PS (Box SUPPLIES) Frozen Per CR 12-028 | 80d | 2011-02-03 | 2011-05-26 | 13221119M | 459d |
| 13221125 | Monitor Delivery & Receive PS Compnts (Box SUPPLIES) Frozen Per CR 12-028 | 80d | 2011-02-03 | 2011-05-26 | 13221119M | 459d |
| 13221099M | Award H-D & Lambertson (2) PS (BOX SUPPLIES) | 0d | 2011-02-25 | 2011-02-25 | 13221098, 9-100M FS+60d | 300d |
| 13221100 | Assemble YA PS and Shunt subassemblies | 100d | 2011-02-25 | 2011-07-18 | 13221099M | 300d |
| 13221105 | Install and Check-out YA & Shunt hardware | 30d | 2011-02-25 | 2011-04-07 | 13221099M | 370d |
| 13221015 | Receive & Inpect Magnet System Box Power Supplies (Frozen per CR11-055) | 107d | 2011-03-01 | 2011-07-29 | 9-110M FS+97d | 833d |
| 13221092 | Dummy Load Assemble Unit #2 | 45d | 2011-03-01 | 2011-05-02 | 13221090 | 772d |
| 13221093 | Rental for Dummy Load Water Skid FY11 | 118d | 2011-04-15 | 2011-09-30 | 4A-01M FS-20d | 1d |
| 13221020 | Place/Connect/Check-out Magnet System Box Power Supplies (Frozen per CR11-055) | 13d | 2011-07-13 | 2011-07-29 | 9-110M FS+191d | 890d |
| 13221115 | Test Extraction PS Systems | 20d | 2011-07-19 | 2011-08-15 | 13221100, 13221105 | 300d |
| 13221010J | Reverse Entry Per CR 11-055 | 5d | 2011-08-01 | 2011-08-05 | 9-110M FS+204d | 39d |
| 13221010K | Revised Schedule per CR11-055 Vend Fab Magnet Box Power Supplies 1st Article M1 Topology (T&M PS) | 65d | 2011-08-01 | 2011-10-31 | 13221010H FS+20d | 542d |
| 13221010L | Revised Schedule per CR11-055 Vend Fab Magnet Box Power Supplies Delivery of LAM1C | 122d | 2011-08-01 | 2012-01-31 | 13221010K FS-65d | 542d |
| 13221010Na | Revised Schedule per CR11-055 Vend Fab Magnet Box Power Supplies Delivery of LAM3C | 142d | 2011-08-01 | 2012-02-29 | 13221010L FS-122d | 542d |
| 13221010Pa | Revised Schedule per CR11-055 Vend Fab Magnet Box Power Supplies Delivery of XSEP10 | 164d | 2011-08-01 | 2012-03-30 | 13221010Na FS-142d | 542d |
| 13221010Q | Revised Schedule per CR11-055 Vend Fab Magnet Box Power Supplies Delivery of XSEP8 | 164d | 2011-08-01 | 2012-03-30 | 13221010P FS-505d, 13221010Pa FS-164d | 542d |
| 13221010R | Revised Schedule per CR11-055 Vend Fab Magnet Box Power Supplies Delivery of RSEP9A | 164d | 2011-08-01 | 2012-03-30 | 13221010Q FS-164d | 542d |
| 13221010S | Revised Schedule per CR11-055 Vend Fab Magnet Box Power Supplies Delivery of RSEP8A | 164d | 2011-08-01 | 2012-03-30 | 13221010R FS-164d | 542d |
| 13221010T | Revised Schedule per CR11-055 Vend Fab Magnet Box Power Supplies Delivery of ARC2 | 164d | 2011-08-01 | 2012-03-30 | 13221010S FS-164d | 542d |
| 13221010U | Revised Schedule per CR11-055 Vend Fab Magnet Box Power Supplies Delivery of ARC4 | 164d | 2011-08-01 | 2012-03-30 | 13221010T FS-164d | 542d |
| 13221010V | Revised Schedule per CR11-055 Vend Fab Magnet Box Power Supplies Delivery of ARC5 | 164d | 2011-08-01 | 2012-03-30 | 13221010U FS-164d | 542d |
| 13221010W | Revised Schedule per CR11-055 Vend Fab Magnet Box Power Supplies Delivery of ARC7 | 164d | 2011-08-01 | 2012-03-30 | 13221010V FS-164d | 542d |
| 13221010X | Revised Schedule per CR11-055 Vend Fab Magnet Box Power Supplies Delivery of ARC3 | 164d | 2011-08-01 | 2012-03-30 | 13221010W FS-164d | 542d |
| 13221010Y | Revised Schedule per CR11-055 Vend Fab Magnet Box Power Supplies Delivery of ARC6 | 164d | 2011-08-01 | 2012-03-30 | 13221010X FS-164d | 542d |
| 13221010Z | Revised Schedule per CR11-055 Vend Fab Magnet Box Power Supplies Delivery of ARC10 | 164d | 2011-08-01 | 2012-03-30 | 13221010Y FS-164d | 542d |
| 13221010Za | Revised Schedule per CR11-055 Vend Fab Magnet Box Power Supplies Delivery of ARC8 | 164d | 2011-08-01 | 2012-03-30 | 13221010Z FS-164d | 542d |
| 13221010Zb | Revised Schedule per CR11-055 Vend Fab Magnet Box Power Supplies Delivery of ARC9 | 164d | 2011-08-01 | 2012-03-30 | 13221010Za FS-164d | 542d |
| 13221010Zc | Revised Schedule per CR11-055 Vend Fab Magnet Box Power Supplies Delivery of Final Documentation and Spare Parts | 164d | 2011-08-01 | 2012-03-30 | 13221010Zb FS-164d | 542d |
| 13221005B | Vend Fab Magnet System Box Power Supplies Oversight FY12 | 21d | 2011-10-03 | 2011-10-31 | 13221005A | 768d |
| 13221093a | Rental for Dummy Load Water Skid FY12 | 29d | 2011-10-03 | 2011-11-10 | 13221093 | 1d |
| 13221096LOE | Engineering Oversight - Develop/Conduct Procedures, Q.A. and Training FY12 | 247d | 2011-10-03 | 2012-09-28 | 13221095LOE | 227d |
| 13221015a | Receive & Inpect Magnet System Box Power Supplies (Revised by CR11-055) | 23d | 2012-01-27 | 2012-02-29 | 13221010Zc FS-45d, 13221005B FS-172d, 13221010C | 542d |
| 13221020a | Place/Connect/Check-out Magnet System Box Power Supplies (Revised by CR11-055) | 12.42d | 2012-02-29 | 2012-03-16 | 13221015 FS-150d, 13221015a FS-1d, 13224040 | 542d |
| 13221022 | Procurement Prep for Magnet Box Power Supplies Revised per CR12-029 | 58d | 2012-03-01 | 2012-05-21 | 9-120M FS+98d | 20d |
| 13221021 | Reverse Entry Per CR12-029 | 10d | 2012-03-02 | 2012-03-15 | 9-120M FS+99d | 138d |
| 13221025A | Test T&M PS | 64d | 2012-03-05 | 2012-06-01 | 9-120M FS+100d | 512d |
| 13221125A | Reverse Entry Per CR 12-028 | 15d | 2012-03-05 | 2012-03-23 | 9-120M FS+100d | 132d |
| 13221026 | Magnet Box Power Supply Original Vendor Refund | 15d | 2012-04-02 | 2012-04-20 | 9-120M FS+120d | 112d |
| 13221126M | Award Arc 1 and Hall A PS | 0d | 2012-04-02 | 2012-04-02 | 9-120M FS+120d | 162d |
| 13221127 | Production & Delivery of Arc 1 and Hall A PS | 150d | 2012-04-02 | 2012-10-31 | 13221126M | 162d |
| 13221128 | Monitor Production of Arc 1 and Hall A PS FY12 | 127d | 2012-04-02 | 2012-09-28 | 13221126M | 221d |
| 13221021A | Additional Reverse Entry Per CR12-029A | 10d | 2012-04-03 | 2012-04-16 | 9-120M FS+121d | 116d |
| 13221130 | Remove and Shuffle Box PS | 97d | 2012-05-14 | 2012-09-28 | 2-02M, 13221125, 13221127 FS-120d, 13221128a FS-120d, 13221120 | 221d |
| 13221022a | Magnet Box Power Supply Contract Oversight FY12 | 91d | 2012-05-22 | 2012-09-28 | 13221022 | 20d |
| 13221022D | Vend Fab Magnet Box Power Supplies Peg Point #1 - Design Review (Kick-off Meeting) | 105d | 2012-08-24 | 2013-01-31 | 13221022 FS+66d | 20d |

| ID | WBS | Task | Duration | Start | Finish | Predecessors | Total float |
| --- | --- | --- | --- | --- | --- | --- | --- |
| 13221023 |  | Vend Fab Magnet Box Power Supplies Peg Point #1A - Receipt of Materials | 167d | 2012-08-24 | 2013-04-30 | 13221022D FS-105d | 20d |
| 13221023A |  | Vend Fab Magnet Box Power Supplies Peg Point #2 - First Power Supply (ARC 2) Delivered to JLab | 231d | 2012-08-24 | 2013-07-31 | 13221023 FS-167d | 20d |
| 13221023B |  | Vend Fab Magnet Box Power Supplies Peg Point #3 - First Power Supply (ARC 2) Accepted, Tested and Production Start | 253d | 2012-08-24 | 2013-08-30 | 13221023A FS-231d | 20d |
| 13221022b |  | Magnet Box Power Supply Contract Oversight FY13 *** Re-Baseline Split | 228d | 2012-10-01 | 2013-08-30 | 13221022a | 20d |
| 13221097LOE |  | Engineering Oversight - Develop/Conduct Procedures, Q.A. and Training FY13 | 31d | 2012-10-01 | 2012-11-12 | 13221096LOE | 227d |
| 13221128a |  | Monitor Production of Arc 1 and Hall A PS FY13 | 23d | 2012-10-01 | 2012-10-31 | 13221128 | 221d |
| 13221133 |  | Receive, Inspect and Install Arc 1 and Hall A PS | 36d | 2012-11-01 | 2012-12-31 | 13221127 | 162d |
| 13221135 |  | Test Arc 1 and Hall A PS w/ Dummy Load | 21d | 2013-01-02 | 2013-01-31 | 13221130, 13221133 | 162d |
| 13221024 |  | Receive & Inpect Magnet System Box Power Supplies (Revised by CR12-029) *** Re-Baseline Split | 22d | 2013-08-01 | 2013-08-30 | 13221023 FS-320d, 13221023A | 203d |
| 13221024a |  | Place/Connect/Check-out Magnet System Box Power Supplies (Revised by CR12-029) *** Re-Baseline Split | 17d | 2013-08-08 | 2013-08-30 | 13221024 FS-17d | 203d |
| 13221025 |  | Test Magnet System Box Power Supplies w/Dummy Load *** Re-Baseline Split | 12d | 2013-08-15 | 2013-08-30 | 13221092, 13221020a FS+14.58d, 3A-23M, 13221020 FS-180d, 13221024a FS-12d | 203d |
| 13221140 |  | Re-Baseline Actuals Adjustment | 1d | 2013-08-30 | 2013-08-30 | 9-130M FS+227d | 20d |
| 23221022b |  | Magnet Box Power Supply Contract Oversight FY13 | 20d | 2013-09-03 | 2013-09-30 | 9-130M FS+228d | 17d |
| 23221023C |  | Vend Fab Magnet Box Power Supplies Peg Point #4 - ARC 3, 4, 5, 6 and LAM 1 Delivered and accepted at JLab | 62d | 2013-09-03 | 2013-11-27 | 9-130M FS+228d | 154d |
| 23221023D |  | Vend Fab Magnet Box Power Supplies Peg Point #4 *** Delivery Incentive Bonus****** | 62d | 2013-09-03 | 2013-11-27 | 23221023C FS-62d | 154d |
| 23221023F |  | Vend Fab Magnet Box Power Supplies Peg Point #5 - ARC 7, 8, 9, 10, RSEP 8 and XSEP 10 Delivered and accepted at JLab | 161d | 2013-09-03 | 2014-04-30 | 23221023D FS-62d | 154d |
| 23221023G |  | Vend Fab Magnet Box Power Supplies Peg Point #5 *** Delivery Incentive Bonus****** | 161d | 2013-09-03 | 2014-04-30 | 23221023F FS-161d | 154d |
| 23221023H |  | Vend Fab Magnet Box Power Supplies Peg Point #6 - LAM 3, XSEP 8 and RSEP 9 Delivered and accepted at JLab | 182d | 2013-09-03 | 2014-05-30 | 23221023G FS-161d | 154d |
| 23221023J |  | Vend Fab Magnet Box Power Supplies Peg Point #6 *** Delivery Incentive Bonus****** | 182d | 2013-09-03 | 2014-05-30 | 23221023H FS-182d | 154d |
| 23221023K |  | Vend Fab Magnet Box Power Supplies Peg Point #7 Acceptance Test at JLab | 246d | 2013-09-03 | 2014-08-29 | 23221023J FS-182d | 154d |
| 23221023L |  | Vend Fab Magnet Box Power Supplies Peg Point #8 Delivery of Spares | 246d | 2013-09-03 | 2014-08-29 | 23221023K FS-246d | 154d |
| 23221024 |  | Receive & Inpect Magnet System Box Power Supplies Part A FY13 (FY14 @ 23221029) | 20d | 2013-09-03 | 2013-09-30 | 9-130M FS+228d | 0d |
| 23221024b |  | Place/Connect Magnet System Box Power Supplies Part A Procurement | 62d | 2013-09-03 | 2013-11-27 | 23221024a FS-193d | 0d |
| 23221024c |  | Place/Connect Magnet System Box Power Supplies Part A Labor/Expenses FY13 | 20d | 2013-09-03 | 2013-09-30 | 23221024a FS-193d | 0d |
| 23221127 |  | Production & Delivery of Arc 1 and Hall A PS | 34d | 2013-09-03 | 2013-10-18 | 9-130M FS+228d | 62d |
| 23221133 |  | Receive, Inspect and Install Arc 1 and Hall A PS FY13 | 20d | 2013-09-03 | 2013-09-30 | 23221127 FS-34d | 62d |
| 23221022c |  | Magnet Box Power Supply Contract Oversight FY14 | 163d | 2013-10-01 | 2014-06-02 | 23221022b | 17d |
| 23221024d |  | Place/Connect Magnet System Box Power Supplies Part A Labor/Expenses FY14 | 42d | 2013-10-01 | 2013-11-27 | 23221024a FS-193d, 23221024c | 0d |
| 23221029 |  | Receive & Inpect Magnet System Box Power Supplies Part A FY14 (FY13 @ 23221024) | 42d | 2013-10-01 | 2013-11-27 | 9-130M FS+228d, 23221024 | 0d |
| 23221133a |  | Receive, Inspect and Install Arc 1 and Hall A PS FY14 | 39d | 2013-10-01 | 2013-11-22 | 23221127 FS-34d, 23221133 | 62d |
| 23221140LOE |  | Proj Admin ongoing FY14 Part A | 42d | 2013-10-01 | 2013-11-27 | 232111914LOE | 58d |
| 23221023Da |  | DeObligation of Vend Fab Magnet Box Power Supplies Peg Point #4 *** Delivery Incentive Bonus **** | 1d | 2013-11-27 | 2013-11-27 | 23221023D FS-1d | 263d |
| 23221024a |  | Receive & Inpect Magnet System Box Power Supplies Part B | 131d | 2013-12-02 | 2014-06-16 | 23221024, 23221029 | 0d |
| 23221024ba |  | Place/Connect Magnet System Box Power Supplies Part B | 136d | 2013-12-02 | 2014-06-23 | 23221024c, 23221024b, 23221024d | 0d |
| 23221140LOEa |  | Proj Admin ongoing FY14 Part B | 205d | 2013-12-02 | 2014-09-30 | 23221140LOE | 58d |
| 23221023Ga |  | Partial DeObligation of Vend Fab Magnet Box Power Supplies Peg Point #5 *** Delivery Incentive Bonus****** | 1d | 2014-04-30 | 2014-04-30 | 23221023G FS-1d | 164d |
|  | 2 | **1.3.2.2.2 SHUNTS** |  | 2010-05-13 | 2014-02-03 |  |  |
| 13222000M |  | Start Shunt Work | 0d | 2010-05-13 | 2010-05-13 | 9-100M FS+150d | 815d |
| 13222005 |  | Engineering, Drafting and Software - Single Channel Shunt Chassis | 20d | 2010-07-06 | 2010-08-02 | 9-100M FS+186d, 13222000M | 779d |
| 13222020 |  | Procurements Parts and Boards - Single Channel Shunt Chassis | 50d | 2010-07-15 | 2010-09-23 | 13222015 FS-55d | 779d |
| 13222015 |  | Labor and Expenses - Single Channel Shunt Chassis | 52d | 2010-07-20 | 2010-09-30 | 13222005 FS-10d | 779d |
| 13222040 |  | Engineering and Drafting - Shunt Resistor Plates | 8d | 2010-08-02 | 2010-08-11 | 9-100M FS+205d | 806d |
| 13222045 |  | Labor and Expenses - Shunt Resistor Plates FY10 | 35d | 2010-08-12 | 2010-09-30 | 13222040 | 806d |
| 13222050 |  | Procurement (Parts) - Shunt Resistor Plates | 55d | 2010-08-19 | 2010-11-04 | 13222045a FS-55d | 806d |
| 13222025 |  | Assembly and Testing - Single Channel Shunt Chassis FY10 | 5d | 2010-09-24 | 2010-09-30 | 13222020 | 779d |
| 13222025a |  | Assembly and Testing - Single Channel Shunt Chassis FY11 | 65d | 2010-10-01 | 2011-01-11 | 13222025 | 779d |
| 13222045a |  | Labor and Expenses - Shunt Resistor Plates FY11 | 25d | 2010-10-01 | 2010-11-04 | 13222045 | 806d |
| 13222055 |  | Assembly and Testing - Shunt Resistor Plates | 70d | 2010-11-05 | 2011-02-24 | 13222045a, 13222050 | 806d |
| 13222070 |  | Engineering, Drafting and Software - Track Regulator and 30/80 Frozen Per CR 12-028 | 50d | 2011-01-25 | 2011-04-05 | 9-110M FS+73d | 681d |
| 13222075 |  | Oversight (Labor) - Track Regulator and 30/80 Frozen Per CR 12-028 | 40d | 2011-03-23 | 2011-05-17 | 13222070 FS-10d | 681d |
| 13222080 |  | Procurement (Parts) - Track Regulator and 30/80 Frozen Per CR 12-028 | 35d | 2011-03-30 | 2011-05-17 | 13222075 FS-35d | 681d |
| 13222060 |  | Installation - Shunt Resistor Plates Frozen per CR12-028 | 20d | 2011-05-13 | 2011-06-10 | 13222055, 4A-01M | 751d |
| 13222085 |  | Assembly and Testing - Track Regulator and 30/80 Frozen Per CR 12-028 | 68d | 2011-05-18 | 2011-08-23 | 13222080 | 681d |
| 13222145 |  | Engineering (Design) - Shunt Adder System Removal | 3d | 2011-06-06 | 2011-06-08 | 9-110M FS+165d | 725d |
| 13222065 |  | Update Machine Documentation - Shunt Resistor Plates Frozen Per CR 12-028 | 3d | 2011-06-13 | 2011-06-15 | 13222060 | 751d |
| 13222105 |  | Engineering, Drafting and Software - 75 Amp Shunt Upgrade | 5d | 2011-08-23 | 2011-08-29 | 9-110M FS+220d | 604d |
| 13222090 |  | Installation and Testing - Track Regulator and 30/80 Frozen Per CR 12-028 | 20d | 2011-08-24 | 2011-09-21 | 13222085 | 681d |
| 13222110 |  | Oversight (Labor) - 75 Amp Shunt Upgrade | 15d | 2011-08-30 | 2011-09-20 | 13222105 | 604d |
| 13222115 |  | Procurement (Parts) - 75 Amp Shunt Upgrade | 10d | 2011-09-07 | 2011-09-20 | 13222110 FS-10d | 604d |
| 13222120 |  | Modifications and Testing - 75 Amp Shunt Upgrade FY11 | 8d | 2011-09-21 | 2011-09-30 | 13222115 | 604d |
| 13222100 |  | Data Entry/Paperwork - Track Regulator and 30/80 Frozen Per CR 12-028 | 2d | 2011-09-22 | 2011-09-23 | 13222090 | 681d |
| 13222120a |  | Modifications and Testing - 75 Amp Shunt Upgrade FY12 | 13d | 2011-10-03 | 2011-10-19 | 13222120 | 604d |
| 13222125 |  | Installation and Testing - 75 Amp Shunt Upgrade Part A | 10d | 2011-10-20 | 2011-11-02 | 13222120a | 651d |
| 13222140 |  | Update Machine Documentation - 75 Amp Shunt Upgrade Part A | 2d | 2011-11-03 | 2011-11-04 | 13222125 | 651d |
| 13222061 |  | Reverse Entry per CR12-028 | 15d | 2012-03-05 | 2012-03-23 | 9-120M FS+100d | 132d |
| 13222070A |  | Engineering, Drafting and Software - Track Regulator and 30/80 Revised Per CR 12-028 | 147d | 2012-03-05 | 2012-09-28 | 9-120M FS+100d | 259d |
| 13222165 |  | Engineering and Drafting - 12GEV Shunt Shuffle | 40d | 2012-03-12 | 2012-05-04 | 9-120M FS+105d | 385d |
| 13222200 |  | Engineering, Drafting and Software - 25 Amp Shunts | 68d | 2012-03-26 | 2012-06-29 | 9-120M FS+115d | 330d |
| 13222063 |  | Installation - Shunt Resistor Plates Part A | 103d | 2012-05-04 | 2012-09-28 | 9-120M FS+144d | 284d |
| 13222185 |  | New Screens for 12 GEV Shunts | 5d | 2012-05-07 | 2012-05-11 | 13222165 | 478d |

| ID | WBS | Task | Duration | Start | Finish | Predecessors | Total float |
| --- | --- | --- | --- | --- | --- | --- | --- |
| 13222150 |  | Component Removal - Shunt Adder System Removal | 7d | 2012-06-05 | 2012-06-13 | 2-02M FS+14d, 13222145 | 481d |
| 13222170 |  | Pull and Modify - 12GEV Shunt Shuffle | 59d | 2012-06-06 | 2012-08-27 | 13222165 FS+20d | 385d |
| 13222155 |  | Reconfiguration and Testing - Shunt Adder System Removal | 7d | 2012-06-14 | 2012-06-22 | 13222150 | 481d |
| 13222205 |  | Procurement Labor - 25 Amp Shunts FY12 | 64d | 2012-07-02 | 2012-09-28 | 13222200 | 330d |
| 13222210 |  | Procurements - 25 Amp Shunts | 87d | 2012-07-02 | 2012-10-31 | 13222205a FS-87d, 13222200 | 330d |
| 13222160 |  | Update Machine Documentation - Shunt Adder System RemovalNew Activity | 2d | 2012-07-16 | 2012-07-17 | 13222155 FS+15d | 481d |
| 13222175 |  | Clean and Modify Racks - 12GEV Shunts | 9d | 2012-08-28 | 2012-09-10 | 13222170 | 385d |
| 13222180 |  | Reinstall Chassis' in Racks - 12GEV Shunts | 10d | 2012-09-11 | 2012-09-24 | 13222175, 13222170 | 385d |
| 13222030 |  | Installation and Testing - Single Channel Shunt Chassis | 80d | 2012-10-01 | 2013-01-31 | 9-130M, 2-02M, 13222025a | 349d |
| 13222064 |  | Installation - Shunt Resistor Plates Part B | 142d | 2012-10-01 | 2013-04-30 | 13222063 | 284d |
| 13222075A |  | Oversight (Labor) - Track Regulator and 30/80 Revised Per CR 12-028 | 59d | 2012-10-01 | 2012-12-31 | 13222070A | 259d |
| 13222080A |  | Procurement (Parts) - Track Regulator and 30/80 Revised Per CR 12-028 | 59d | 2012-10-01 | 2012-12-31 | 13222075A FS-59d | 259d |
| 13222130 |  | Installation and Testing - 75 Amp Shunt Upgrade Part B | 43d | 2012-10-01 | 2012-11-30 | 13222120a, 9-130M | 370d |
| 13222205a |  | Procurement Labor - 25 Amp Shunts FY13 | 23d | 2012-10-01 | 2012-10-31 | 13222205 | 330d |
| 13222215 |  | Modification - 25 Amp Shunt Upgrade | 25d | 2012-10-25 | 2012-11-30 | 13222210 FS-5d | 330d |
| 13222035 |  | Data Entry / Paperwork - Single Channel Shunt Chassis | 57d | 2012-11-01 | 2013-01-31 | 13222030 FS-57d | 349d |
| 13222142 |  | Update Machine Documentation - 75 Amp Shunt Upgrade Part B | 16d | 2012-12-03 | 2012-12-31 | 13222130 | 370d |
| 13222220 |  | Installation and Testing - 25 Amp Shunt Upgrade | 37d | 2012-12-03 | 2013-01-31 | 13222215 | 330d |
| 13222085A |  | Assembly and Testing - Track Regulator and 30/80 Revised Per CR 12-028 | 68d | 2013-01-02 | 2013-04-09 | 13222080A | 259d |
| 13222230 |  | Drafting (Update Machine Drawings) | 19d | 2013-02-01 | 2013-02-28 | 13222220 | 330d |
| 13222190 |  | Reconfiguration and Testing - 12GEV Shunts | 40d | 2013-02-04 | 2013-04-01 | 13224085C, 13222185, 13222180, 13224087 | 300d |
| 13222195 |  | Update Machine Documentation - 12GEV Shunts | 8d | 2013-04-02 | 2013-04-11 | 13222190 | 300d |
| 13222095 |  | Installation and Testing - Track Regulator and 30/80 Revised Per CR 12-028 | 20d | 2013-04-10 | 2013-05-07 | 13222085A | 259d |
| 13222067 |  | Update Machine Documentation - Shunt Resistor Plates Revised Per CR 12-028 | 3d | 2013-05-01 | 2013-05-03 | 13222064 | 284d |
| 13222100A |  | Data Entry/Paperwork - Track Regulator and 30/80 Revised Per CR 12-028 | 23d | 2013-05-08 | 2013-06-10 | 13222095 | 259d |
| 13222240 |  | Re-Baseline Actuals Adjustment | 1d | 2013-08-30 | 2013-08-30 | 9-130M FS+227d | 20d |
| 23222030 |  | Installation and Testing - Single Channel Shunt Chassis FY13 | 20d | 2013-09-03 | 2013-09-30 | 9-130M FS+228d | 156d |
| 23222035 |  | Data Entry / Paperwork - Single Channel Shunt Chassis FY13 | 20d | 2013-09-03 | 2013-09-30 | 23222030a FS-44d, 23222030 FS-44d | 156d |
| 23222064 |  | Installation - Shunt Resistor Plates Part A FY13 | 20d | 2013-09-03 | 2013-09-30 | 9-130M FS+228d | 102d |
| 23222067 |  | Update Machine Documentation - Shunt Resistor Plates Part A FY13 | 20d | 2013-09-03 | 2013-09-30 | 23222064a FS-98d | 102d |
| 23222070A |  | Engineering, Drafting and Software - Track Regulator and 30/80 Part A FY13 | 20d | 2013-09-03 | 2013-09-30 | 9-130M FS+228d | 101d |
| 23222075A |  | Oversight (Labor) - Track Regulator and 30/80 FY13 | 20d | 2013-09-03 | 2013-09-30 | 23222070Aa FS-99d | 101d |
| 23222080A |  | Procurement (Parts) - Track Regulator and 30/80 Part A Procurement | 62d | 2013-09-03 | 2013-11-27 | 23222075Aa FS-99d | 101d |
| 23222080Ab |  | Procurement (Parts) - Track Regulator and 30/80 Part A Expenses FY13 | 20d | 2013-09-03 | 2013-09-30 | 23222075Aa FS-99d | 101d |
| 23222085A |  | Assembly and Testing - Track Regulator and 30/80 Part A FY13 | 20d | 2013-09-03 | 2013-09-30 | 23222080Aa FS-99d | 101d |
| 23222170 |  | Pull and Modify - 12GEV Shunt Shuffle FY13 | 20d | 2013-09-03 | 2013-09-30 | 9-130M FS+228d | 156d |
| 23222175 |  | Clean and Modify Racks - 12GEV Shunts FY13 | 20d | 2013-09-03 | 2013-09-30 | 23222170 FS-44d, 23222170a FS-44d | 156d |
| 23222180 |  | Reinstall Chassis' in Racks - 12GEV Shunts FY13 | 20d | 2013-09-03 | 2013-09-30 | 23222175a FS-44d, 23222175 FS-44d, 23222170a FS-44d, 23222170 FS-44d | 156d |
| 23222185 |  | New Screens for 12 GEV Shunts FY13 | 20d | 2013-09-03 | 2013-09-30 | 9-130M FS+228d | 156d |
| 23222190 |  | Reconfiguration and Testing - 12GEV Shunts FY13 | 20d | 2013-09-03 | 2013-09-30 | 23222185 FS-44d, 23222180a FS-44d, 23222180 FS-44d, 23222185a FS-44d | 156d |
| 23222195 |  | Update Machine Documentation - 12GEV Shunts FY13 | 20d | 2013-09-03 | 2013-09-30 | 23222190 FS-44d, 23222190a FS-44d | 156d |
| 23222220 |  | Installation and Testing - 25 Amp Shunt Upgrade FY13 | 20d | 2013-09-03 | 2013-09-30 | 9-130M FS+228d | 156d |
| 23222230 |  | Drafting (Update Machine Drawings) FY13 | 20d | 2013-09-03 | 2013-09-30 | 23222220 FS-44d, 23222220a FS-44d | 156d |
| 23222030a |  | Installation and Testing - Single Channel Shunt Chassis FY14 | 24d | 2013-10-01 | 2013-11-01 | 23222030, 9-130M FS+228d | 156d |
| 23222035a |  | Data Entry / Paperwork - Single Channel Shunt Chassis FY14 | 24d | 2013-10-01 | 2013-11-01 | 23222030a FS-44d, 23222035, 23222030 FS-44d | 156d |
| 23222065 |  | Installation - Shunt Resistor Plates Part A FY14 | 42d | 2013-10-01 | 2013-11-27 | 9-130M FS+228d, 23222064 | 102d |
| 23222068 |  | Update Machine Documentation - Shunt Resistor Plates Part A FY14 | 42d | 2013-10-01 | 2013-11-27 | 23222067, 23222064a FS-98d | 102d |
| 23222070Ab |  | Engineering, Drafting and Software - Track Regulator and 30/80 Part A FY14 | 42d | 2013-10-01 | 2013-11-27 | 9-130M FS+228d, 23222070A | 101d |
| 23222075Ab |  | Oversight (Labor) - Track Regulator and 30/80 FY14 | 42d | 2013-10-01 | 2013-11-27 | 23222075A, 23222070Aa FS-99d | 101d |
| 23222080Ac |  | Procurement (Parts) - Track Regulator and 30/80 Part A Expenses FY14 | 42d | 2013-10-01 | 2013-11-27 | 23222080Ab, 23222075Aa FS-99d | 101d |
| 23222085Ab |  | Assembly and Testing - Track Regulator and 30/80 Part A FY14 | 42d | 2013-10-01 | 2013-11-27 | 23222080Aa FS-99d, 23222085A | 101d |
| 23222170a |  | Pull and Modify - 12GEV Shunt Shuffle FY14 | 24d | 2013-10-01 | 2013-11-01 | 9-130M FS+228d, 23222170 | 156d |
| 23222175a |  | Clean and Modify Racks - 12GEV Shunts FY14 | 24d | 2013-10-01 | 2013-11-01 | 23222170 FS-44d, 23222175, 23222170a FS-44d | 156d |
| 23222180a |  | Reinstall Chassis' in Racks - 12GEV Shunts FY14 | 24d | 2013-10-01 | 2013-11-01 | 23222180, 23222170 FS-44d, 23222170a FS-44d, 23222175 FS-44d, 23222175a FS-44d | 156d |
| 23222185a |  | New Screens for 12 GEV Shunts FY14 | 24d | 2013-10-01 | 2013-11-01 | 9-130M FS+228d, 23222185 | 156d |
| 23222190a |  | Reconfiguration and Testing - 12GEV Shunts FY14 | 24d | 2013-10-01 | 2013-11-01 | 23222190, 23222185a FS-44d, 23222180 FS-44d, 23222180a FS-44d, 23222185 FS-44d | 156d |
| 23222195a |  | Update Machine Documentation - 12GEV Shunts FY14 | 24d | 2013-10-01 | 2013-11-01 | 23222190 FS-44d, 23222195, 23222190a FS-44d | 156d |
| 23222220a |  | Installation and Testing - 25 Amp Shunt Upgrade FY14 | 24d | 2013-10-01 | 2013-11-01 | 9-130M FS+228d, 23222220 | 156d |
| 23222230a |  | Drafting (Update Machine Drawings) FY14 | 24d | 2013-10-01 | 2013-11-01 | 23222230, 23222220a FS-44d, 23222220 FS-44d | 156d |
| 23222064a |  | Installation - Shunt Resistor Plates Part B | 36d | 2013-12-02 | 2014-01-31 | 23222064, 23222065 | 102d |
| 23222067a |  | Update Machine Documentation - Shunt Resistor Plates Part B | 36d | 2013-12-02 | 2014-01-31 | 23222067, 23222068 | 102d |
| 23222070Aa |  | Engineering, Drafting and Software - Track Regulator and 30/80 Part B | 37d | 2013-12-02 | 2014-02-03 | 23222070A, 23222070Ab | 101d |
| 23222075Aa |  | Oversight (Labor) - Track Regulator and 30/80 | 37d | 2013-12-02 | 2014-02-03 | 23222075A, 23222075Ab | 101d |
| 23222080Aa |  | Procurement (Parts) - Track Regulator and 30/80 Part B | 37d | 2013-12-02 | 2014-02-03 | 23222080Ab, 23222080A, 23222080Ac | 101d |
| 23222085Aa |  | Assembly and Testing - Track Regulator and 30/80 Part A | 37d | 2013-12-02 | 2014-02-03 | 23222085Ab, 23222085A | 101d |
| 23222095 |  | Installation and Testing - Track Regulator and 30/80 | 37d | 2013-12-02 | 2014-02-03 | 23222085Aa FS-37d | 101d |
| 23222100A |  | Data Entry/Paperwork - Track Regulator and 30/80 | 37d | 2013-12-02 | 2014-02-03 | 23222095 FS-37d | 101d |
| 23222142 |  | Update Machine Documentation - 75 Amp Shunt Upgrade | 37d | 2013-12-02 | 2014-02-03 | 23222100A FS-37d | 101d |
|  | 3 | **1.3.2.2.3 TRIMS** |  | 2010-04-07 | 2014-02-03 |  |  |
| 13223038 |  | Bid 20 amp Trim PS (20 A Trims) | 120d | 2010-04-07 | 2010-09-24 | 9-100M FS+124d, 121223060a | 534d |

| ID | WBS | Task | Duration | Start | Finish | Predecessors | Total float |
| --- | --- | --- | --- | --- | --- | --- | --- |
| 13223030 |  | Proc Rack Hardware for 20 amp Trim PS/Wait for Delivery (20 A TRIMS) | 80d | 2011-01-05 | 2011-04-28 | 121223060a, 9-110M FS+60d | 423d |
| 13223039M |  | Award 20 amp Trim PS (20 A Trims) | 0d | 2011-01-05 | 2011-01-05 | 13223038, 9-110M FS+60d | 470d |
| 13223045 |  | Monitor Design & Development &Test of First Article (20 A Trims) | 80d | 2011-01-05 | 2011-04-28 | 13223039M | 470d |
| 13223035 |  | Assemble Racks for 20 amp Trim PS (20 A TRIMS) Frozen per CR12-028 | 108d | 2011-04-29 | 2011-09-30 | 13223030 | 474d |
| 13223050 |  | Monitor Production and Delvery of PS (20 A Trims) P1(original Labor and Expenses) | 108d | 2011-04-29 | 2011-09-30 | 13223045 | 470d |
| 13223051A |  | Vend Fab 20 Amp Trim Power Supplies - Peg Point #1 NRE | 47d | 2011-06-27 | 2011-08-31 | 9-110M FS+180d | 372d |
| 13223051B |  | Vend Fab 20 Amp Trim Power Supplies - Peg Point #2 Approval of 1st Article Test | 89d | 2011-06-27 | 2011-10-31 | 13223051A FS-47d | 372d |
| 13223051C |  | Vend Fab 20 Amp Trim Power Supplies - Peg Point #3 First Delivery and Acceptance of 30 units | 146d | 2011-06-27 | 2012-01-31 | 13223051B FS-89d | 372d |
| 13223051D |  | Vend Fab 20 Amp Trim Power Supplies - Peg Point #4 Second Delivery and Acceptance of 30 units | 166d | 2011-06-27 | 2012-02-29 | 13223051C FS-146d | 372d |
| 13223051 |  | Monitor Production and Delvery of PS (20 A Trims) P2 (original Labor and Expenses) | 150d | 2011-10-03 | 2012-05-11 | 9-120M, 13223045, 13223050 | 578d |
| 13223052 |  | Receive , Inspect, Test PS (20 A Trims) P1 Frozen Per CR 12-028 | 91d | 2011-11-10 | 2012-03-29 | 13223050 FS-70d, 13223051D FS-70d | 384d |
| 13223051F |  | Vend Fab 20 Amp Trim Power Supplies - Peg Point #5 Third Delivery and Acceptance of 30 units | 62d | 2012-01-03 | 2012-03-30 | 13223051D FS-40d | 381d |
| 13223051G |  | Vend Fab 20 Amp Trim Power Supplies - Peg Point #6 Fourth Delivery and Acceptance of 30 units | 83d | 2012-01-03 | 2012-04-30 | 13223051F FS-62d | 381d |
| 13223051H |  | Vend Fab 20 Amp Trim Power Supplies - Peg Point #7 Fifth Delivery and Acceptance of 30 units | 105d | 2012-01-03 | 2012-05-31 | 13223051G FS-83d | 381d |
| 13223051J |  | Vend Fab 20 Amp Trim Power Supplies - Peg Point #8 Sixth Delivery and Acceptance of 30 units | 125d | 2012-01-03 | 2012-06-29 | 13223051H FS-105d | 381d |
| 13223051K |  | Vend Fab 20 Amp Trim Power Supplies - Peg Point #9 Seventh Delivery and Acceptance of 30 units | 147d | 2012-01-03 | 2012-07-31 | 13223051J FS-125d | 381d |
| 13223051N |  | Vend Fab 20 Amp Trim Power Supplies - Peg Point #10 Eighth Delivery and Acceptance of 30 units | 170d | 2012-01-03 | 2012-08-31 | 13223051K FS-147d | 381d |
| 13223051P |  | Vend Fab 20 Amp Trim Power Supplies - Peg Point #11 Final Delivery and Acceptance of 20 units | 189d | 2012-01-03 | 2012-09-28 | 13223051N FS-170d | 381d |
| 13223051Q |  | ** Option** Vend Fab 20 Amp Trim Power Supplies - Peg Point #12 Delivery and Acceptance of 10 units | 189d | 2012-01-03 | 2012-09-28 | 13223051P FS-189d | 381d |
| 13223035A |  | Reverse Entry Per CR12-028 | 15d | 2012-03-05 | 2012-03-23 | 9-120M FS+100d | 132d |
| 13223036 |  | Assemble Racks for 20 amp Trims Part A | 69d | 2012-04-02 | 2012-07-09 | 9-120M FS+120d, 13223030 | 195d |
| 13223052A |  | Receive , Inspect, Test PS (20 A Trims) P1 Revised Per CR 12-028 | 103d | 2012-05-04 | 2012-09-28 | 9-120M FS+144d, 13223050 FS-70d, 13223051D FS-70d | 256d |
| 13223010 |  | Relocate and Reuse Trim Hardware for Hall D | 60d | 2012-05-14 | 2012-08-07 | 2-02M | 359d |
| 13223110 |  | SRCC 20 Amp PS PS Procurement | 86d | 2012-07-03 | 2012-10-31 | 9-120M FS+184d | 132d |
| 13223055 |  | Install PS in Racks (20 A Trims) Part A | 62d | 2012-07-04 | 2012-09-28 | 13223052A FS-225d, 13223053 FS-125d, 13223052 FS-225d | 256d |
| 13223015 |  | Test Trim Rack Hardware (10 ATRIMS) | 43d | 2012-10-01 | 2012-11-30 | 13223010, 9-130M | 322d |
| 13223020 |  | Reconfigure 10 Amp Trim System (Arc 10 Hall D) (10 A TRIMS) | 143d | 2012-10-01 | 2013-05-01 | 3A-22M, 9-130M | 158d |
| 13223036A |  | Assemble Racks for 20 amp Trims Part B | 90d | 2012-10-01 | 2013-02-14 | 9-130M, 13223036 | 137d |
| 13223053 |  | Receive , Inspect, Test PS (20 A Trims) P2 | 63d | 2012-10-01 | 2013-01-07 | 13223052, 13223051Q FS-125d, 13223052A, 13223051 FS-225d | 256d |
| 13223055A |  | Install PS in Racks (20 A Trims) Part B | 101d | 2012-10-01 | 2013-03-04 | 13223055 | 256d |
| 13223100 |  | SRCC Engineering Design, Planning and Oversight | 43d | 2012-10-01 | 2012-11-30 | 9-130M | 75d |
| 13223112 |  | SRCC Cable & Misc Procurement | 80d | 2012-10-01 | 2013-01-31 | 13223100 FS-43d, 13223105 FS-59d | 75d |
| 13223105 |  | SRCC Drafting | 16d | 2012-12-03 | 2012-12-31 | 13223100 | 75d |
| 13223115 |  | SRCC PS and Rack installation | 20d | 2013-02-01 | 2013-03-01 | 13223112, 13223110 | 75d |
| 13223060 |  | Integration Testing of PS (20 A Trims) | 138d | 2013-02-15 | 2013-08-30 | 13223036, 13223055 FS-130d, 13223036A, 13223055A FS-130d, 2-02M, 13223035 | 137d |
| 13223120 |  | SRCC Cable Installation, Termination and Hook-up | 42d | 2013-03-04 | 2013-04-30 | 13223112, 13223115, 13223110 | 75d |
| 13223125 |  | SRCC System Q.A., Testing and Documentation | 20d | 2013-05-01 | 2013-05-29 | 13223120, 13223115 | 75d |
| 13223025 |  | Assemble & Test 10 amp Trim System (10 A TRIMS) | 64d | 2013-05-02 | 2013-08-01 | 13223020 | 158d |
| 13223130 |  | Re-Baseline Actuals Adjustment | 1d | 2013-08-30 | 2013-08-30 | 9-130M FS+227d | 20d |
| 23223015 |  | Test Trim Rack Hardware (10 ATRIMS) FY13 | 20d | 2013-09-03 | 2013-09-30 | 9-130M FS+228d | 97d |
| 23223025 |  | Assemble & Test 10 amp Trim System (10 A TRIMS) FY13 | 20d | 2013-09-03 | 2013-09-30 | 9-130M FS+228d | 97d |
| 23223051H |  | Vend Fab 20 Amp Trim Power Supplies - Peg Point #7 Fifth Delivery and Acceptance of 30 units | 20d | 2013-09-03 | 2013-09-30 | 9-130M FS+228d | 53d |
| 23223051J |  | Vend Fab 20 Amp Trim Power Supplies - Peg Point #8 Sixth Delivery and Acceptance of 30 units | 43d | 2013-09-03 | 2013-10-31 | 23223051H FS-20d | 53d |
| 23223051K |  | Vend Fab 20 Amp Trim Power Supplies - Peg Point #9 Seventh Delivery and Acceptance of 30 units | 62d | 2013-09-03 | 2013-11-27 | 23223051J FS-43d | 53d |
| 23223051N |  | Vend Fab 20 Amp Trim Power Supplies - Peg Point #10 Eighth Delivery and Acceptance of 30 units | 62d | 2013-09-03 | 2013-11-27 | 23223051K FS-62d | 53d |
| 23223051P |  | Vend Fab 20 Amp Trim Power Supplies - Peg Point #11 Final Delivery and Acceptance of 20 units | 77d | 2013-09-03 | 2013-12-20 | 23223051N FS-62d | 53d |
| 23223051Q |  | ** Option** Vend Fab 20 Amp Trim Power Supplies - Peg Point #12 Delivery and Acceptance of 10 units | 98d | 2013-09-03 | 2014-01-31 | 23223051P FS-77d | 53d |
| 23223052A |  | Receive , Inspect, Test PS (20 A Trims) P1 FY13 | 20d | 2013-09-03 | 2013-09-30 | 9-130M FS+228d | 37d |
| 23223053 |  | Receive , Inspect, Test PS (20 A Trims) P2 Procurement | 62d | 2013-09-03 | 2013-11-27 | 23223052A FS-21d, 23223052Aa FS-21d | 52d |
| 23223054 |  | Receive , Inspect, Test PS (20 A Trims) P2 Labor/Expenses FY13 | 20d | 2013-09-03 | 2013-09-30 | 23223052A FS-21d, 23223052Aa FS-21d | 52d |
| 23223055 |  | Install PS in Racks (20 A Trims) Part A FY13 | 20d | 2013-09-03 | 2013-09-30 | 23223052A FS-21d, 23223052Aa FS-21d, 23223053a FS-101d | 37d |
| 23223110 |  | SRCC 20 Amp PS PS Procurement | 67d | 2013-09-03 | 2013-12-06 | 9-130M FS+228d | 42d |
| 23223125 |  | SRCC System Q.A., Testing and Documentation Part A FY13 | 20d | 2013-09-03 | 2013-09-30 | 23223110 FS-67d | 42d |
| 23223015a |  | Test Trim Rack Hardware (10 ATRIMS) FY14 | 19d | 2013-10-01 | 2013-10-25 | 9-130M FS+228d, 23223015 | 97d |
| 23223025a |  | Assemble & Test 10 amp Trim System (10 A TRIMS) FY14 | 19d | 2013-10-01 | 2013-10-25 | 23223025, 9-130M FS+228d | 97d |
| 23223052Aa |  | Receive , Inspect, Test PS (20 A Trims) P1 FY14 | 1d | 2013-10-01 | 2013-10-01 | 23223052A, 9-130M FS+228d | 37d |
| 23223054a |  | Receive , Inspect, Test PS (20 A Trims) P2 Labor/Expenses FY14 | 42d | 2013-10-01 | 2013-11-27 | 23223052A FS-21d, 23223054, 23223052Aa FS-21d | 52d |
| 23223055b |  | Install PS in Racks (20 A Trims) Part A FY14 | 11d | 2013-10-01 | 2013-10-15 | 23223052A FS-21d, 23223053a FS-101d, 23223055, 23223052Aa FS-21d | 37d |
| 23223125b |  | SRCC System Q.A., Testing and Documentation Part A FY14 | 42d | 2013-10-01 | 2013-11-27 | 23223110 FS-67d, 23223125 | 42d |
| 23223060 |  | Integration Testing of PS (20 A Trims) Part A | 62d | 2013-10-02 | 2014-01-09 | 23223055A FS-130d, 23223055b FS-10d, 23223055 FS-10d | 37d |
| 23223055A |  | Install PS in Racks (20 A Trims) Part B | 36d | 2013-11-20 | 2014-01-23 | 23223055 FS-30d, 23223053a FS-30d, 23223055b FS-30d | 96d |
| 23223053a |  | Receive , Inspect, Test PS (20 A Trims) P3 | 24d | 2013-12-02 | 2014-01-14 | 23223053, 23223054a, 23223054 | 52d |
| 23223125a |  | SRCC System Q.A., Testing and Documentation Part B | 5d | 2013-12-02 | 2013-12-06 | 23223125, 23223125b, 23223110 FS-67d | 42d |
| 23223060a |  | Integration Testing of PS (20 A Trims) Part B | 16d | 2014-01-10 | 2014-02-03 | 23223060 | 37d |
|  | 4 | **1.3.2.2.4 INSTALLATION** |  | 2010-06-11 | 2013-11-06 |  |  |
| 13224000LOE |  | Installation Coordination FY10 | 78d | 2010-06-11 | 2010-09-30 | 9-100M FS+170d | 237d |
| 13224001LOE |  | Installation Coordination FY11 | 248d | 2010-10-01 | 2011-09-30 | 13224000LOE | 237d |
| 13224005 |  | Proc Box PS Load Cable/Hardware (Installtn) | 60d | 2010-10-01 | 2011-01-04 | 9-110M, 121224999 | 434d |
| 13224010 |  | Proc Trim Mag & Shunt Cable (Installtn) | 60d | 2010-10-01 | 2011-01-04 | 121224999, 9-110M | 434d |
| 13224015 |  | Proc Trim Sys AC Pwr, Controls & Interlock Cable (Installtn) | 60d | 2010-10-01 | 2011-01-04 | 9-110M, 121224999 | 434d |

| ID | WBS | Task | Duration | Start | Finish | Predecessors | Total float |
| --- | --- | --- | --- | --- | --- | --- | --- |
| 13224020 |  | Proc Box PS Cable Tray, AC Pwr Matrl's (Installtn) | 60d | 2010-10-01 | 2011-01-04 | 121224999, 9-110M | 434d |
| 13224025 |  | Proc DC Pwr Interconnect Hardware (Installtn) | 60d | 2010-10-01 | 2011-01-04 | 9-110M, 121224999 | 434d |
| 13224030 |  | Proc LCW Manifolds/Hose for Arc & Septa PS (Installtn) | 60d | 2010-10-01 | 2011-01-04 | 9-110M, 121224999 | 434d |
| 13224040 |  | NAB Box Supply Infrastructure Installation Work | 80d | 2011-03-21 | 2011-07-12 | 16111030M | 488d |
| 13224040A |  | SAB Box Supply Infrastructure Installation Work | 80d | 2011-03-21 | 2011-07-12 | 16111030M | 488d |
| 13224045 |  | Pull/Terminate Box PS Load Cable (Installtn) Arc 10/West Arc FY11 (FY12 @ 13224047) | 98d | 2011-05-13 | 2011-09-30 | 4A-01M | 409d |
| 13224085 |  | Pull/Terminate Trim Mag & Shunt Cable (Installtn) | 60d | 2011-05-13 | 2011-08-08 | 4A-01M | 581d |
| 13224002LOE |  | Installation Coordination FY12 | 247d | 2011-10-03 | 2012-09-28 | 13224001LOE | 237d |
| 13224047 |  | Pull/Terminate Box PS Load Cable (Installtn) Arc 10/West Arc FY12 (FY11 @ 13224045) | 22d | 2011-10-03 | 2011-11-01 | 13224045 | 409d |
| 13224050 |  | Pull/Terminate Arc & H-D Klixon Cable (Installtn) Frozen Per CR12-028 | 17d | 2012-02-06 | 2012-02-29 | 9-120M FS+81d, 16332030 FS+40d | 409d |
| 13224053 |  | Reverse Entry Per CR12-028 | 15d | 2012-03-05 | 2012-03-23 | 9-120M FS+100d | 132d |
| 13224044 |  | Label, Disconnect Pull Back SR Cables | 97d | 2012-05-14 | 2012-09-28 | 2-02M | 20d |
| 13224075 |  | Install Trim Racks (Installtn) | 76d | 2012-05-14 | 2012-08-29 | 3A-21M, 3A-22M | 216d |
| 13224080 |  | Install Trim Rack AC Pwr (Installtn) Part A | 97d | 2012-05-14 | 2012-09-28 | 13224075 FS-76d | 216d |
| 13224085B |  | Pull & Terminate Shunt Cable (Remove Old Cable)-Part A | 97d | 2012-05-14 | 2012-09-28 | 2-02M | 300d |
| 13224095 |  | Install Trim Comm/Controls Cable (Installtn) FY12 | 21d | 2012-08-30 | 2012-09-28 | 13224075 | 287d |
| 13224003LOE |  | Installation Coordination FY13 *** Re-Baseline Split | 228d | 2012-10-01 | 2013-08-30 | 13224002LOE | 237d |
| 13224045A |  | Pull/Terminate Box PS Load Cable (Installtn) East Arc, S/R,BSY and Extraction | 164d | 2012-10-01 | 2013-05-31 | 13224044, 2-02M, 9-130M, 13221115 | 20d |
| 13224080A |  | Install Trim Rack AC Pwr (Installtn) Part B | 80d | 2012-10-01 | 2013-01-31 | 13224080 | 216d |
| 13224085A |  | Pull/Terminate Trim Mag (Installtn) East Arc , S/R and BSY | 80d | 2012-10-01 | 2013-01-31 | 2-02M, 9-130M | 216d |
| 13224085C |  | Pull & Terminate Shunt Cable (Remove Old Cable)-Part B | 81d | 2012-10-01 | 2013-02-01 | 2-02M, 13224085B | 300d |
| 13224087 |  | BSY Serv. Bldg Infrastructure Installation- Tray, Power, Water, Controls | 63d | 2012-10-01 | 2013-01-07 | 9-130M | 318d |
| 13224090 |  | Pull/terminate/Connect Trim Mag Load Cable - H-D (Installtn) | 119d | 2012-10-01 | 2013-03-28 | 2-17M, 121224065, 13224052 FS-83d, 121224999, 13224050 FS-83d | 177d |
| 13224095a |  | Install Trim Comm/Controls Cable (Installtn) FY13 | 9d | 2012-10-01 | 2012-10-11 | 13224095 | 287d |
| 13224100 |  | Update/Install/Test Mag Controls Software (Installtn) | 150d | 2012-10-01 | 2013-05-10 | 9-130M, 2-02M | 108d |
| 13224050A |  | Cable Tray Install Hall D Tunnel | 40d | 2012-12-03 | 2013-02-05 | 9-130M FS+43d | 101d |
| 13224052 |  | Pull/Terminate Arc & H-D Klixon Cable (Installtn) Revised Per CR12-028 | 40d | 2012-12-03 | 2013-02-05 | 9-130M FS+43d | 177d |
| 13224110 |  | Intergation , Inspection, Test Trim PS (Installtn) | 69d | 2013-03-29 | 2013-07-05 | 13224095a, 13224080, 13224090, 13224085A, 13224080A, 13224085 | 177d |
| 13224055 |  | Connect Arc & Hall Mag Load & Klixon Cables (Installtn) *** Re-Baseline Split | 64d | 2013-06-03 | 2013-08-30 | 13224050A, 13221135 FS-58d, 13221115, 13224045A, 13224040, 13224047, 13224040A | 20d |
| 13224115 |  | Re-Baseline Actuals Adjustment | 1d | 2013-08-30 | 2013-08-30 | 9-130M FS+227d | 20d |
| 23224003LOE |  | Installation Coordination FY13 | 20d | 2013-09-03 | 2013-09-30 | 9-130M FS+228d | 216d |
| 23224045A |  | Pull/Terminate Box PS Load Cable (Installtn) East Arc, S/R,BSY and Extraction Procurement | 47d | 2013-09-03 | 2013-11-06 | 9-130M FS+228d | 18d |
| 23224045Aa |  | Pull/Terminate Box PS Load Cable (Installtn) East Arc, S/R,BSY and Extraction Labor/Expenses FY13 | 20d | 2013-09-03 | 2013-09-30 | 9-130M FS+228d | 18d |
| 23224055 |  | Connect Arc & Hall Mag Load & Klixon Cables (Installtn) FY13 | 20d | 2013-09-03 | 2013-09-30 | 23224045Ab FS-47d, 2813221005 FS-110d, 23224045A FS-47d, 2813221005a FS-110d, 23224045Aa FS-47d | 18d |
| 23224085A |  | Pull/Terminate Trim Mag (Installtn) East Arc , S/R and BSY FY13 | 20d | 2013-09-03 | 2013-09-30 | 9-130M FS+228d | 36d |
| 23224087 |  | BSY Serv. Bldg Infrastructure Installation- Tray, Power, Water, Controls FY13 | 20d | 2013-09-03 | 2013-09-30 | 9-130M FS+228d | 283d |
| 23224100 |  | Update/Install/Test Mag Controls Software (Installtn) FY13 | 20d | 2013-09-03 | 2013-09-30 | 9-130M FS+228d | 25d |
| 23224045Ab |  | Pull/Terminate Box PS Load Cable (Installtn) East Arc, S/R,BSY and Extraction Labor/Expenses FY14 | 27d | 2013-10-01 | 2013-11-06 | 23224045Aa, 9-130M FS+228d | 18d |
| 23224055a |  | Connect Arc & Hall Mag Load & Klixon Cables (Installtn) FY14 | 27d | 2013-10-01 | 2013-11-06 | 2813221005a FS-110d, 23224045Ab FS-47d, 23224045A FS-47d, 23224045Aa FS-47d, 23224055, 2813221005 FS-110d | 18d |
| 23224085Aa |  | Pull/Terminate Trim Mag (Installtn) East Arc , S/R and BSY FY14 | 22d | 2013-10-01 | 2013-10-30 | 23224085A, 9-130M FS+228d | 36d |
| 23224087a |  | BSY Serv. Bldg Infrastructure Installation- Tray, Power, Water, Controls FY14 | 22d | 2013-10-01 | 2013-10-30 | 9-130M FS+228d, 23224087 | 283d |
| 23224100a |  | Update/Install/Test Mag Controls Software (Installtn) FY14 | 25d | 2013-10-01 | 2013-11-04 | 23224100, 9-130M FS+228d | 25d |
|  | 3 | **1.3.3 CRYOGENICS** |  | 2009-01-05 | 2013-09-30 |  |  |
|  | 1 | **1.3.3.1 ACCELERATOR** |  | 2009-01-05 | 2013-09-30 |  |  |
|  | 01 | **1.3.3.1.01 COMPRESSORS** |  | 2010-01-05 | 2013-08-30 |  |  |
| 1331.01000 |  | Vend Production CHL Helium Compressors (Original Labor) | 37d | 2010-01-05 | 2010-02-26 | 12131.03020, 12131.03015, 1331.02000 FS-125d, 9-100M FS+60d | 109d |
| 1331.01005 |  | Vend Production CHL Helium Compressors Oversight FY10 | 146d | 2010-03-08 | 2010-09-30 | 9-100M FS+102d, 1331.01000 | 104d |
| 1331.01010 |  | Vend Fab CHL Helium Compressors Peg Point #1 Complete Preliminary Design Review | 40d | 2010-03-08 | 2010-04-30 | 9-100M FS+102d | 31d |
| 1331.01015 |  | Vend Fab CHL Helium Compressors Peg Point #2 Placement of Order for Coolers | 40d | 2010-03-08 | 2010-04-30 | 1331.01010 FS-40d | 40d |
| 1331.01020 |  | Vend Fab CHL Helium Compressors Peg Point #3 Placement of Order for Compressors | 40d | 2010-03-08 | 2010-04-30 | 1331.01015 FS-40d | 40d |
| 1331.01025 |  | Vend Fab CHL Helium Compressors Peg Point #4 Placement of Order for Heat Exchangers | 60d | 2010-03-08 | 2010-05-28 | 1331.01020 FS-40d | 40d |
| 1331.01030 |  | Vend Fab CHL Helium Compressors Peg Point #5 Placement of Order for Motors | 60d | 2010-03-08 | 2010-05-28 | 1331.01025 FS-60d | 40d |
| 1331.01035 |  | Vend Fab CHL Helium Compressors Peg Point #6 CDR Complete | 82d | 2010-03-08 | 2010-06-30 | 1331.01030 FS-60d | 40d |
| 1331.01040 |  | Vend Fab CHL Helium Compressors Peg Point #7 Final Drawing Approval | 125d | 2010-03-08 | 2010-08-31 | 1331.01035 FS-82d | 40d |
| 1331.01045 |  | Vend Fab CHL Helium Compressors Peg Point #8 Receipt of Compressors | 146d | 2010-03-08 | 2010-09-30 | 1331.01040 FS-125d | 40d |
| 1331.01050 |  | Vend Fab CHL Helium Compressors Peg Point #9 Receipt of Motors | 167d | 2010-03-08 | 2010-10-29 | 1331.01045 FS-146d | 40d |
| 1331.01055 |  | Vend Fab CHL Helium Compressors Peg Point #10 Receipt of Heat Exchangers | 167d | 2010-03-08 | 2010-10-29 | 1331.01050 FS-167d | 40d |
| 1331.01060 |  | Vend Fab CHL Helium Compressors Peg Point #11 Receipt of Coolers | 204d | 2010-03-08 | 2010-12-30 | 1331.01055 FS-167d | 40d |
| 1331.01065 |  | Vend Fab CHL Helium Compressors Peg Point #12 Complete Installation of Motors | 224d | 2010-03-08 | 2011-01-31 | 1331.01060 FS-204d | 40d |
| 1331.01070 |  | Vend Fab CHL Helium Compressors Peg Point #13 Complete Installation of Compressors | 224d | 2010-03-08 | 2011-01-31 | 1331.01065 FS-224d | 40d |
| 1331.01075 |  | Vend Fab CHL Helium Compressors Peg Point #14 Complete Installation of Coolers | 224d | 2010-03-08 | 2011-01-31 | 1331.01070 FS-224d | 40d |
| 1331.01080 |  | Vend Fab CHL Helium Compressors Peg Point #15 Complete Installation of Heat Exchangers | 243d | 2010-03-08 | 2011-02-28 | 1331.01075 FS-224d | 40d |
| 1331.01085 |  | Vend Fab CHL Helium Compressors Peg Point #16 System Pressure, Leak Test | 243d | 2010-03-08 | 2011-02-28 | 1331.01080 FS-243d | 40d |
| 1331.01090 |  | Vend Fab CHL Helium Compressors Peg Point #17 Installation of Electrical Panels, Instruments and Devices | 243d | 2010-03-08 | 2011-02-28 | 1331.01085 FS-243d | 40d |
| 1331.01095 |  | Vend Fab CHL Helium Compressors Peg Point #18 Spare Parts Received by JLab | 266d | 2010-03-08 | 2011-03-31 | 1331.01090 FS-243d | 40d |
| 1331.01100 |  | Vend Fab CHL Helium Compressors Peg Point #19 Complete User Rediness Review | 350d | 2010-03-08 | 2011-07-29 | 1331.01095 FS-266d | 40d |
| 1331.01105 |  | Vend Fab CHL Helium Compressors Peg Point #20 Completion of Compressor System Commissioning | 350d | 2010-03-08 | 2011-07-29 | 1331.01100 FS-350d | 40d |
| 1331.01110 |  | Vend Fab CHL Helium Compressors Peg Point #21 Completion of System Acceptance Testing and Report | 394d | 2010-03-08 | 2011-09-30 | 1331.01105 FS-350d | 40d |
| 1331.01005A |  | Vend Production CHL Helium Compressors Oversight FY11 | 184d | 2010-10-01 | 2011-06-30 | 1331.01005 | 104d |
| 1331.01115 |  | Re-Baseline Actuals Adjustment | 1d | 2013-08-30 | 2013-08-30 | 9-130M FS+227d | 20d |

| ID | WBS | Task | Duration | Start | Finish | Predecessors | Total float |
| --- | --- | --- | --- | --- | --- | --- | --- |
|  | 02 | **1.3.3.1.02 COLD BOXES** |  | 2009-01-05 | 2013-08-30 |  |  |
| 1331.02000 |  | FY-09 Initial Labor (Planned) Procurement Support | 188d | 2009-01-05 | 2009-09-30 | 12131.04020, 9-090M FS+60d | 0d |
| 1331.02015 |  | Vend Fab- Peg Point 1: Contract Award | 1d | 2009-09-30 | 2009-09-30 | 1331.02000 FS-1d | 0d |
| 1331.02020 |  | Vend Fab- Peg Point 3: Issue PO for Platefin Heat Exchangers& Absorbers | 79d | 2009-09-30 | 2010-01-29 | 1331.02015 FS-1d | 0d |
| 1331.02025 |  | Vend Fab- Peg Point 2: Complete Preliminary Design Review | 79d | 2009-09-30 | 2010-01-29 | 1331.02015 FS-1d, 1331.02020 FS-79d | 0d |
| 1331.02030 |  | Vend Fab- Peg Point 4: Issue PO for Turbines & Cryogenic Valves | 143d | 2009-09-30 | 2010-04-30 | 1331.02025 FS-79d, 1331.02015 FS-1d | 40d |
| 1331.02035 |  | Vend Fab- Peg Point 7: Deliver Platefin Heat Exchangers& Absorbers | 249d | 2009-09-30 | 2010-09-30 | 1331.02030 FS-143d, 1331.02015 FS-1d | 40d |
| 1331.02040 |  | Vend Fab- Peg Point 4: Issue PO for Cold Box Shell | 249d | 2009-09-30 | 2010-09-30 | 1331.02035 FS-249d, 1331.02015 FS-1d | 40d |
| 1331.02045 |  | Vend Fab- Peg Point 8: Deliver Turbine Housing | 290d | 2009-09-30 | 2010-11-30 | 1331.02015 FS-1d, 1331.02040 FS-249d | 40d |
| 1331.02050 |  | Vend Fab- Peg Point 5: Complete Final Design Review | 308d | 2009-09-30 | 2010-12-31 | 1331.02015 FS-1d, 1331.02045 FS-290d | 40d |
| 1331.02055 |  | Vend Fab- Peg Point 10: Complete Internal Piping | 433d | 2009-09-30 | 2011-06-30 | 1331.02050 FS-308d, 1331.02015 FS-1d | 40d |
| 1331.02060 |  | Vend Fab- Peg Point 9: Complete Cold Box Shell | 433d | 2009-09-30 | 2011-06-30 | 1331.02055 FS-433d, 1331.02015 FS-1d | 40d |
| 1331.02065 |  | Vend Fab- Peg Point 11: Ship Cold Box | 476d | 2009-09-30 | 2011-08-31 | 1331.02060 FS-433d, 1331.02090 FS-476d, 1331.02085 FS-108d, 1331.02015 FS-1d | 40d |
| 1331.02070 |  | Vend Fab- Peg Point 12: Complete Installation | 497d | 2009-09-30 | 2011-09-30 | 1331.02065 FS-476d, 1331.02015 FS-1d, 1331.02068 FS-497d | 40d |
| 1331.02075 |  | Vend Fab- Peg Point 14: Deliver Final Operating & Maintenance Manuals | 518d | 2009-09-30 | 2011-10-31 | 1331.02070 FS-497d, 1331.02015 FS-1d | 418d |
| 1331.02080 |  | Vend Fab- Peg Point 13: Acceptance Test Complete & Report Delivered | 617d | 2009-09-30 | 2012-03-30 | 1331.02075 FS-518d, 1331.02015 FS-1d | 418d |
| 1331.02001 |  | FY-10 Labor Procurement Support | 248d | 2009-10-01 | 2010-09-30 | 1331.02000, 9-100M | 113d |
| 1331.02012 |  | He Dewar Procurement | 152d | 2009-10-15 | 2010-05-28 | 9-100M FS+10d | 374d |
| 1331.02085 |  | Additional Funds for Currency Exchange Rate | 10d | 2010-03-01 | 2010-03-12 | 9-100M FS+97d | 40d |
| 1331.02090 |  | Spare Turbine and Seal Kits | 65d | 2010-03-01 | 2010-05-28 | 9-100M FS+97d | 353d |
| 1331.02005 |  | FY-11 Labor Procurement Support | 248d | 2010-10-01 | 2011-09-30 | 9-100M FS+60d, 32-02M, 1331.02000, 1331.02001 | 295d |
| 1331.02052 |  | Vend Fab- Peg Point 15: Venturi Flow Measurement | 38d | 2011-01-04 | 2011-02-28 | 1331.02050 | 40d |
| 1331.02068 |  | Vend Fab- Peg Point 16: Re-rout Transfer Lines | 189d | 2011-01-04 | 2011-09-30 | 1331.02052 FS-38d, 1331.02065 FS-168d | 40d |
| 1331.02010 |  | FY-12 Labor Procurement Support | 120d | 2011-10-03 | 2012-03-30 | 1331.02005, 9-110M FS+60d | 295d |
| 1331.02066 |  | Vend Fab- Peg Point 17: Cold Box Shipping Costs | 37d | 2011-11-01 | 2011-12-30 | 1331.02065 FS+42d | 480d |
| 1331.02100 |  | Re-Baseline Actuals Adjustment | 1d | 2013-08-30 | 2013-08-30 | 9-130M FS+227d | 20d |
|  | 03 | **1.3.3.1.03 OIL REMOVAL SKIDS** |  | 2011-01-05 | 2013-08-30 |  |  |
| 1331.03000 |  | Fab Oil Removl Skids | 115d | 2011-01-05 | 2011-06-17 | 32-03M, 9-110M FS+60d | 113d |
| 1331.03005 |  | Re-Baseline Actuals Adjustment | 1d | 2013-08-30 | 2013-08-30 | 9-130M FS+227d | 20d |
|  | 04 | **1.3.3.1.04 I & C** |  |  |  |  |  |
|  | 05 | **1.3.3.1.05 Not Used** |  |  |  |  |  |
|  | 06 | **1.3.3.1.06 CHL GAS MANAGEMENT RACK** |  | 2011-01-05 | 2013-08-30 |  |  |
| 1331.06000 |  | Fab CHL Gas Mngmnt Rack | 90d | 2011-01-05 | 2011-05-12 | 9-110M FS+60d | 138d |
| 1331.06005 |  | Re-Baseline Actuals Adjustment | 1d | 2013-08-30 | 2013-08-30 | 9-130M FS+227d | 20d |
|  | 07 | **1.3.3.1.07 CHL SYSTEM INSTRUMENTATION & CONTROL** |  | 2010-01-05 | 2013-08-30 |  |  |
| 1331.07000 |  | Fab & Install CHL Instrmenttn & Controls Labor FY10 | 188d | 2010-01-05 | 2010-09-30 | 12131.07015, 9-100M FS+60d, 12131.07015b | 51d |
| 1331.07000b |  | Fab & Install CHL Instrmenttn & Controls Procurement | 425d | 2010-01-05 | 2011-09-15 | 12131.07015, 12131.07015b, 9-100M FS+60d | 51d |
| 1331.07000a |  | Fab & Install CHL Instrmenttn & Controls Labor FY11 | 237d | 2010-10-01 | 2011-09-15 | 1331.07000 | 51d |
| 1331.07005 |  | Re-Baseline Actuals Adjustment | 1d | 2013-08-30 | 2013-08-30 | 9-130M FS+227d | 20d |
|  | 08 | **1.3.3.1.08 INSTRUMENT AIR & SUPPORT EQUIPMENT** |  | 2011-01-05 | 2013-08-30 |  |  |
| 1331.08000 |  | Proc & Install CHL Instrument Air Sys | 175d | 2011-01-05 | 2011-09-13 | 9-110M FS+60d, 12131.08000 | 53d |
| 1331.08005 |  | Re-Baseline Actuals Adjustment | 1d | 2013-08-30 | 2013-08-30 | 9-130M FS+227d | 20d |
|  | 09 | **1.3.3.1.09 MOTOR CONTROL CENTERS** |  | 2010-01-05 | 2013-08-30 |  |  |
| 1331.09000 |  | Proc & Install Motor Control Centers | 150d | 2010-01-05 | 2010-08-06 | 9-100M FS+60d, 12131.09000 | 266d |
| 1331.09005 |  | Re-Baseline Actuals Adjustment | 1d | 2013-08-30 | 2013-08-30 | 9-130M FS+227d | 20d |
|  | 10 | **1.3.3.1.10 CHL INSTALLATION & DESIGN** |  | 2009-12-09 | 2013-09-30 |  |  |
| 1331.10000 |  | Proc & Install CHL Piping & Compnts Labor FY10 | 201d | 2009-12-09 | 2010-09-30 | 12131.04025, 12131.10010, 2-15M FS-60d | 144d |
| 1331.1000b |  | Proc & Install CHL Piping & Compnts Procurement | 345d | 2009-12-09 | 2011-05-04 | 12131.04025, 2-15M FS-60d, 12131.10010 | 144d |
| 1331.1000a |  | Proc & Install CHL Piping & Compnts Labor FY11 | 144d | 2010-10-01 | 2011-05-04 | 1331.10000 | 144d |
| 1331.1005 |  | Install CHL Cold Box Transfer Line to Linac Labor | 78d | 2013-01-07 | 2013-04-26 | 1331.1000a, 9-130M FS+62d | 151d |
| 1331.1010 |  | Re-Baseline Actuals Adjustment | 1d | 2013-08-30 | 2013-08-30 | 9-130M FS+227d | 20d |
| 2331.1005 |  | Install CHL Cold Box Transfer Line to Linac Labor | 20d | 2013-09-03 | 2013-09-30 | 9-130M FS+228d | 43d |
|  | 11 | **1.3.3.1.11 CHL COMMISSIONING** |  | 2011-10-03 | 2013-08-30 |  |  |
| 1331.11000 |  | Cmmssn CHL Helium Plant Original | 141d | 2011-10-03 | 2012-04-30 | 1621025, 3A-04M | 146d |
| 1331.11005 |  | Re-Baseline Actuals Adjustment | 1d | 2013-08-30 | 2013-08-30 | 9-130M FS+227d | 20d |
|  | 12 | **1.3.3.1.12 LINAC TRANSFER LINE** |  | 2011-01-05 | 2013-08-30 |  |  |
| 1331.12000 |  | Fab Cold Box Transfer Line & U-Tubes | 175d | 2011-01-05 | 2011-09-13 | 1331.02010 FS-550d, 1331.02001, 1331.02000, 9-110M FS+60d | 53d |
| 1331.12005 |  | Re-Baseline Actuals Adjustment | 1d | 2013-08-30 | 2013-08-30 | 9-130M FS+227d | 20d |
|  | 2 | **1.3.3.2 HALL D** |  | 2010-01-05 | 2013-08-30 |  |  |
|  | 1 | **1.3.3.2.1 CHL-HALL D TRANSFER LINE AND HEADER** |  | 2011-08-01 | 2013-08-30 |  |  |
| 13321015 |  | Eng Design Cryogenic Transfer Line FY11 | 44d | 2011-08-01 | 2011-09-30 | 1562149, 9-110M FS+204d | 90d |
| 13321055 |  | Design Solenoid Distribution Can (Header) BIA | 111d | 2011-08-01 | 2012-01-13 | 9-110M FS+204d | 50d |
| 13321025 |  | Fabricate Cryogenic Transfer Line Labor FY11 | 15d | 2011-09-12 | 2011-09-30 | 13321020 FS-82d | 90d |
| 13321035 |  | Fabricate Cryogenic Transfer Line Procurement | 135d | 2011-09-12 | 2012-03-30 | 13321030 FS-123d | 90d |
| 13321020 |  | Eng Design Cryogenic Transfer Line FY12 | 67d | 2011-10-03 | 2012-01-13 | 13321015 | 90d |
| 13321030 |  | Fabricate Cryogenic Transfer Line Labor FY12 | 108d | 2011-10-03 | 2012-03-14 | 13321025 | 90d |
| 13321040 |  | Install Cryogenic Transfer Line Labor | 45d | 2012-03-15 | 2012-05-16 | 13321030, 13321035 FS-12d | 104d |
| 13321045 |  | Install Cryogenic Transfer Line Procurement | 55d | 2012-03-15 | 2012-05-31 | 13321030, 13321035 FS-12d | 90d |
| 13321060 |  | Fabricate Solenoid Distribution Can (Header) Labor | 84d | 2012-03-16 | 2012-07-13 | 13321055, 9-120M FS+109d | 8d |
| 13321065 |  | Fabricate Solenoid Distribution Can (Header) Procurement | 96d | 2012-03-16 | 2012-07-31 | 13321060 FS-84d | 8d |

| ID | WBS | Task | Duration | Start | Finish | Predecessors | Total float |
| --- | --- | --- | --- | --- | --- | --- | --- |
| 13321050 |  | Commission Cryogenic Transfer Line | 18d | 2012-06-08 | 2012-07-03 | 13321042 FS-128d, 13321040, 13321045 FS+4d | 90d |
| 13321070 |  | Install Solenoid Distribution Can (Header) | 54d | 2012-07-16 | 2012-09-28 | 151155, 13321065 FS-12d | 8d |
| 13321042 |  | Install Hall D Solenoid External Warm/Vent Piping Labor | 20d | 2012-11-08 | 2012-12-07 | 13321040, 9-130M FS+28d | 90d |
| 13321075 |  | Re-Baseline Actuals Adjustment | 1d | 2013-08-30 | 2013-08-30 | 9-130M FS+227d | 20d |
|  | 2 | **1.3.3.2.2 HALL D COLD BOX** |  | 2010-01-05 | 2013-08-30 |  |  |
| 13322000 |  | Refurblish H-D Cold Box | 25d | 2010-01-05 | 2010-02-09 | 121322000, 9-100M FS+60d | 448d |
| 13322005 |  | Relocation of Helium Refrigerator Labor (Frozen by CR11-036) | 41d | 2011-06-02 | 2011-07-29 | 9-110M FS+163d | 44d |
| 13322006 |  | Reverse entry per CR11-036 | 5d | 2011-08-01 | 2011-08-05 | 9-110M FS+204d | 39d |
| 13322007 |  | Relocation of Helium Refrigerator Labor (Revised by CR11-036) | 79d | 2011-10-03 | 2012-02-01 | 9-120M | 158d |
| 13322010 |  | Relocation of Helium Refrigerator Procurement | 98d | 2011-10-03 | 2012-02-29 | 9-120M | 158d |
| 13322015 |  | Re-Baseline Actuals Adjustment | 1d | 2013-08-30 | 2013-08-30 | 9-130M FS+227d | 20d |
|  | 3 | **1.3.3.2.3 HALL DISTRIBUTION SYSTEM** |  | 2011-03-01 | 2013-08-30 |  |  |
| 13323000 |  | Proc H-D Refrigerator Equip & Piping Proc | 249d | 2011-03-01 | 2012-02-29 | 16332040F, 13322000, 121323000 | 209d |
| 13323005 |  | Proc & Install H-D Refrigerator Equip & Piping (Original labor Frozen per CR 11-036) | 107d | 2011-03-01 | 2011-07-29 | 121323000, 16332040F, 13322000 | 188d |
| 13323010 |  | Reverse Entry per CR 11-036) | 5d | 2011-08-01 | 2011-08-05 | 9-110M FS+204d | 39d |
| 13323015 |  | Install H-D Refrigerator Equip & Piping Labor (Revised per CR 11-036) FY11 | 21d | 2011-09-01 | 2011-09-30 | 9-110M FS+227d | 142d |
| 13323020 |  | Install H-D Refrigerator Equip & Piping Procurement (Revised per CR 11-036) | 119d | 2011-09-01 | 2012-02-29 | 13323015a FS-107d | 142d |
| 13323015a |  | Install H-D Refrigerator Equip & Piping Labor (Revised per CR 11-036) FY12 | 86d | 2011-10-03 | 2012-02-10 | 13323015 | 142d |
| 13323025 |  | Re-Baseline Actuals Adjustment | 1d | 2013-08-30 | 2013-08-30 | 9-130M FS+227d | 20d |
|  | 4 | **1.3.3.2.4 INSTRUMENTATION & CONTROLS** |  | 2011-05-17 | 2013-08-30 |  |  |
| 13324000 |  | Install H-D Refrigerator Instrmenttn & Controls Procurement | 216d | 2011-05-17 | 2012-03-30 | 9-110M FS+60d, 121324000, 13326000 FS-52d | 142d |
| 13324005 |  | Install H-D Refrigerator Instrmenttn & Controls Original Labor Frozen per CR 11-036 | 52d | 2011-05-17 | 2011-07-29 | 121324000, 9-110M FS+60d, 13326000 FS-52d | 306d |
| 13324010 |  | Reverse Entry Per CR 11-036 | 5d | 2011-08-01 | 2011-08-05 | 9-110M FS+204d | 39d |
| 13324015 |  | Install H-D Refrigerator Instrmenttn & Controls FY11 | 21d | 2011-09-01 | 2011-09-30 | 13326010 FS-125d, 121324000, 9-110M FS+227d, 13326015 FS-141d | 158d |
| 13324015a |  | Install H-D Refrigerator Instrmenttn & Controls FY12 | 104d | 2011-10-03 | 2012-03-08 | 13324015 | 158d |
| 13324020 |  | Re-Baseline Actuals Adjustment | 1d | 2013-08-30 | 2013-08-30 | 9-130M FS+227d | 20d |
|  | 5 | **1.3.3.2.5 U-TUBES** |  | 2011-07-07 | 2013-08-30 |  |  |
| 13325000 |  | Fab Cryogenic U-Tubes (Frozen Per CR 11-036) | 17d | 2011-07-07 | 2011-07-29 | 13323005 FS-40d, 121325000, 9-110M FS+125d, 13323015a FS-155d, 13323020 FS-159d | 165d |
| 13325005 |  | Reverse Entry Per CR 11-036 | 5d | 2011-08-01 | 2011-08-05 | 9-110M FS+204d | 39d |
| 13325010 |  | Fab Cryogenic U-Tubes Labor (Revised Per CR 11-036) | 40d | 2011-12-08 | 2012-02-10 | 9-110M FS+125d, 13323005 FS-40d, 13323015a FS-40d, 13323020 FS-52d, 121325000, 13323000 FS-119d | 142d |
| 13325015 |  | Fab Cryogenic U-Tubes Procurment (Revised Per CR 11-036) | 40d | 2011-12-08 | 2012-02-10 | 121325000, 9-110M FS+125d, 13323000 FS-119d, 13323020 FS-52d, 13323015a FS-40d, 13323005 FS-40d | 142d |
| 13325020 |  | Re-Baseline Actuals Adjustment | 1d | 2013-08-30 | 2013-08-30 | 9-130M FS+227d | 20d |
|  | 6 | **1.3.3.2.6 FIELD INSTALLATION** |  | 2011-03-22 | 2013-08-30 |  |  |
| 13326000 |  | Install Field Compnts (Frozen Per CR 11-036) | 92d | 2011-03-22 | 2011-07-29 | 13325015 FS-222d, 13325000 FS-115d, 3C-09M, 9-110M FS+60d, 13325010 FS-222d | 142d |
| 13326005 |  | Reverse Entry Per CR 11-036 | 5d | 2011-08-01 | 2011-08-05 | 9-110M FS+204d | 39d |
| 13326010 |  | Install Field Compnts Labor (Revised Per CR 11-036) | 104d | 2011-10-03 | 2012-03-08 | 13325000 FS-115d, 13322007 FS-79d, 13325010 FS-86d, 13322010 FS-98d, 3C-09M, 9-110M FS+60d, 13325015 FS-86d | 158d |
| 13326015 |  | Install Field Compnts Procurement (Revised Per CR 11-036) | 120d | 2011-10-03 | 2012-03-30 | 13325000 FS-115d, 13325015 FS-86d, 9-110M FS+60d, 3C-09M, 13325010 FS-86d | 158d |
| 13326020 |  | Re-Baseline Actuals Adjustment | 1d | 2013-08-30 | 2013-08-30 | 9-130M FS+227d | 20d |
|  | 7 | **1.3.3.2.7 COMMISSIONING** |  | 2012-04-02 | 2013-08-30 |  |  |
| 13327000 |  | Cmmssn H-D Refrigerator Sys | 23d | 2012-04-02 | 2012-05-02 | 16332010U, 13324000, 13326000, 13326010, 13326015 FS-16d, 13324015a, 16332010, 13324005 | 142d |
| 13327005 |  | Re-Baseline Actuals Adjustment | 1d | 2013-08-30 | 2013-08-30 | 9-130M FS+227d | 20d |
|  | 4 | **1.3.4 BEAM TRANSPORT** |  | 2009-01-02 | 2013-11-18 |  |  |
|  | 1 | **1.3.4.1 SPREADERS & RECOMBINERS** |  | 2009-01-02 | 2013-11-11 |  |  |
|  | 1 | **1.3.4.1.1 DIPOLES** |  | 2009-01-02 | 2013-10-15 |  |  |
| 13411075 |  | Prcrmnt Prep of Septa (S/R Dipoles) | 112d | 2009-01-02 | 2009-06-11 | 9-090M FS+59d | 362d |
| 13411909LOE |  | FY09 Mngmnt & Oversight (S/R Dipoles) | 189d | 2009-01-02 | 2009-09-30 | 13411909LOEXD | 20d |
| 13411095 |  | Prcrmnt Prep of Curved Dipoles (S/R Dipoles) | 117d | 2009-01-12 | 2009-06-26 | 9-090M FS+65d | 111d |
| 13411115 |  | Prcrmnt Prep for C Dipoles & Coils (S/R Dipoles) | 117d | 2009-01-12 | 2009-06-26 | 9-090M FS+65d | 196d |
| 13411080M |  | Award Contract for Septa (S/R DIPOLES) | 0d | 2009-06-12 | 2009-06-12 | 121416010, 13411075, 121411110M FS-34d | 362d |
| 13411085 |  | Vend Fab Septa (S/R Dipoles) LABOR INITIAL FY09 | 35d | 2009-06-12 | 2009-07-31 | 13411080M | 362d |
| 13411100M |  | Award Contract for Curved Dipoles (S/R DIPOLES) | 0d | 2009-06-29 | 2009-06-29 | 13411095, 121411110M FS-24d, 121416010 | 111d |
| 13411105 |  | P-1 Vend Fab Curved Dipoles (S/R Dipoles) Labor FY09 | 66d | 2009-06-29 | 2009-09-30 | 13411100M | 111d |
| 13411120M |  | Award Contract for C Dipoles & Coils (S/R DIPOLES) | 0d | 2009-06-29 | 2009-06-29 | 121416010 FS-20d, 13411115 | 196d |
| 13411125 |  | P-1 Vend Fab C Dipoles & Coils (S/R Dipoles) Labor FY09 | 66d | 2009-06-29 | 2009-09-30 | 13411120M | 196d |
| 13411086 |  | Vend Fab Septa (S/R Dipoles) LABOR FINAL FY09 | 42d | 2009-08-03 | 2009-09-30 | 13411085 | 362d |
| 13411087 |  | Vend Fab Septa (S/R Dipoles) Materials | 36d | 2009-08-26 | 2009-10-15 | 9-090M FS+223d | 764d |
| 13411087A |  | Vend Fab Septa (S/R Dipoles) First Article ZA Magnet | 105d | 2009-08-26 | 2010-02-02 | 9-090M FS+223d | 468d |
| 13411087B |  | Vend Fab Septa (S/R Dipoles) Deliver (4) ZA Magnet Assemblies | 393d | 2009-08-26 | 2011-03-31 | 9-090M FS+223d | 407d |
| 13411087C |  | Vend Fab Septa (S/R Dipoles) Deliver (3) ZA Magnet Assemblies | 477d | 2009-08-26 | 2011-07-29 | 9-090M FS+223d | 323d |
| 13411087D |  | Vend Fab Septa (S/R Dipoles) Deliver ZA Spare Coil Set (Frozen by CR 11-041) | 477d | 2009-08-26 | 2011-07-29 | 9-090M FS+223d | 323d |
| 13411087D10 |  | Vend Fab Septa (S/R Dipoles) Deliver (2) YA Magnet Assemblies (Frozen by CR 11-041) | 562d | 2009-08-26 | 2011-11-30 | 9-090M FS+223d | 238d |
| 13411087D5 |  | Vend Fab Septa (S/R Dipoles) Deliver (2) ZB Coil Sets (Frozen by CR 11-041) | 579d | 2009-08-26 | 2011-12-30 | 9-090M FS+223d | 221d |
| 13411086ALOE |  | Vend Fab Septa (S/R Dipoles) LABOR FY10 | 248d | 2009-10-01 | 2010-09-30 | 13411086 | 362d |
| 13411105b |  | P-1 Vend Fab Curved Dipoles (S/R Dipoles) Labor FY10 | 182d | 2009-10-01 | 2010-06-28 | 13411105 | 111d |
| 13411125b |  | P-1 Vend Fab C Dipoles & Coils (S/R Dipoles) Labor FY10 | 182d | 2009-10-01 | 2010-06-28 | 13411125 | 196d |
| 13411910LOE |  | FY10 Mngmnt & Oversight (S/R Dipoles) | 248d | 2009-10-01 | 2010-09-30 | 121411909LOE, 13411909LOE | 20d |
| 13411055 |  | Prcrmnt Prep for H Steel (S/R Dipoles) | 110d | 2009-10-05 | 2010-03-19 | 9-100M FS+2d | 169d |
| 13411105c |  | Vend Fab Curved Dipoles Peg Point #1 Receipt of Coil Materials and Tooling | 63d | 2009-11-18 | 2010-02-26 | 13411100M, 9-100M FS+34d | 46d |
| 13411105d |  | Vend Fab Curved Dipoles Peg Point #2 Receipt of Core Materials | 63d | 2009-11-18 | 2010-02-26 | 13411105c FS-63d | 46d |
| 13411105f |  | Vend Fab Curved Dipoles Peg Point #3 JLab Approval of First Article XU Coil | 108d | 2009-11-18 | 2010-04-30 | 13411105d FS-63d | 46d |

| ID | Task | Duration | Start | Finish | Predecessors | Total float |
| --- | --- | --- | --- | --- | --- | --- |
| 13411105g | Vend Fab Curved Dipoles Peg Point #4 JLab Approval of First Article XU Core Assembly | 150d | 2009-11-18 | 2010-06-30 | 13411105f FS-108d | 46d |
| 13411105h | Vend Fab Curved Dipoles Peg Point #5 Receipt and Acceptance of XU Coils by JLab | 150d | 2009-11-18 | 2010-06-30 | 13411105g FS-150d | 46d |
| 13411105j | Vend Fab Curved Dipoles Peg Point #6 Receipt and Acceptance of XU Magnet Assemblies by JLab | 235d | 2009-11-18 | 2010-10-29 | 13411105h FS-150d | 46d |
| 13411105k | Vend Fab Curved Dipoles Peg Point #7 Receipt and Acceptance of XM Coils by JLab | 272d | 2009-11-18 | 2010-12-30 | 13411105j FS-235d | 46d |
| 13411105n | Vend Fab Curved Dipoles Peg Point #8 Receipt and Acceptance of XV Coils by JLab | 292d | 2009-11-18 | 2011-01-31 | 13411105k FS-272d | 46d |
| 13411105o | Vend Fab Curved Dipoles Peg Point #9 Receipt and Acceptance of XV Magnet Assemblies by JLab | 292d | 2009-11-18 | 2011-01-31 | 13411105n FS-292d | 46d |
| 13411105p | Vend Fab Curved Dipoles Peg Point #10 Receipt and Acceptance of BP Coils by JLab | 292d | 2009-11-18 | 2011-01-31 | 13411105o FS-292d | 46d |
| 13411105q | Vend Fab Curved Dipoles Peg Point #11 Receipt and Acceptance of JF Coils by JLab | 311d | 2009-11-18 | 2011-02-28 | 13411105p FS-292d | 46d |
| 13411105r | Vend Fab Curved Dipoles Peg Point #12 Receipt and Acceptance of XM Magnet Assemblies by JLab | 311d | 2009-11-18 | 2011-02-28 | 13411105q FS-311d | 46d |
| 13411105s | Vend Fab Curved Dipoles Peg Point #13 Receipt and Acceptance of XX Coils by JLab | 334d | 2009-11-18 | 2011-03-31 | 13411105r FS-311d | 46d |
| 13411105t | Vend Fab Curved Dipoles Peg Point #14 Receipt and Acceptance of JG Magnet Assemblies by JLab | 376d | 2009-11-18 | 2011-05-31 | 13411105s FS-334d | 46d |
| 13411105u | Vend Fab Curved Dipoles Peg Point #15 Receipt and Acceptance of JH Magnet Assemblies by JLab | 441d | 2009-11-18 | 2011-08-31 | 13411105t FS-376d | 46d |
| 13411105v | Vend Fab Curved Dipoles Peg Point #16 Receipt and Acceptance of XX Magnet Assemblies by JLab | 462d | 2009-11-18 | 2011-09-30 | 13411105u FS-441d | 99d |
| 13411135 | Proc & Vend Fab Misc shims & Brackets (S/R Dipoles) Labor FY10 | 188d | 2010-01-05 | 2010-09-30 | 13411909LOE, 9-100M FS+60d | 399d |
| 13411106 | P-2 Vend Fab Curved Dipoles (S/R Dipoles) Original Labor FY10 | 171d | 2010-01-29 | 2010-09-30 | 9-100M FS+60d, 13411105b FS-105d, 13411105c FS-105d | 111d |
| 13411126 | P-2 Vend Fab C Dipoles & Coils (S/R Dipoles) Original Labor FY10 | 171d | 2010-01-29 | 2010-09-30 | 13411125b FS-105d | 196d |
| 13411060M | Award Contract for H Steel (S/R DIPOLES) | 0d | 2010-03-22 | 2010-03-22 | 121416010, 13411055, 121411110M | 169d |
| 13411065 | P-1 Vend Fab H Steel (S/R Dipoles) Labor FY10 | 136d | 2010-03-22 | 2010-09-30 | 13411060M | 169d |
| 13411065b | P-1 Vend Fab H Steel (S/R Dipoles) Procurement | 248d | 2010-03-22 | 2011-03-21 | 13411060M | 169d |
| 13411108M | Deliver First Curved Dipoles (S/R Dipoles) | 0d | 2010-06-30 | 2010-06-30 | 13411105g, 13411100M FS+208d | 252d |
| 13411105w | Vend Fab Curved Dipoles Peg Point #17 Additional Material for XH and XY Magnets | 21d | 2010-07-01 | 2010-07-30 | 9-100M FS+184d | 99d |
| 13411160 | Proc Prep Extra Coils FY10 | 64d | 2010-07-01 | 2010-09-30 | 9-100M FS+184d | 520d |
| 13411200 | Spreader Recombiner Dipole Refurb and Mod Documentation FY10 | 64d | 2010-07-01 | 2010-09-30 | 9-100M FS+184d | 340d |
| 13411136 | Proc Prep BCOMM and Additional Steel FY10 | 63d | 2010-07-02 | 2010-09-30 | 9-100M FS+185d | 285d |
| 13411087F | Vend Fab Septa (S/R Dipoles) Material Annealing | 65d | 2010-07-30 | 2010-10-29 | 9-100M FS+204d | 506d |
| 13411105x | Vend Fab Curved Dipoles Peg Point #18 Receipt and Acceptance XH and XY Magnets | 251d | 2010-09-28 | 2011-09-30 | 13411105w FS+40d | 99d |
| 13411065a | P-1 Vend Fab H Steel (S/R Dipoles) Labor FY11 | 112d | 2010-10-01 | 2011-03-21 | 13411065 | 169d |
| 13411086BLOE | Vend Fab Septa (S/R Dipoles) LABOR FY11 | 165d | 2010-10-01 | 2011-06-03 | 13411086ALOE | 362d |
| 13411106a | P-2 Vend Fab Curved Dipoles (S/R Dipoles) Original Labor FY11 | 77d | 2010-10-01 | 2011-01-28 | 13411106 | 111d |
| 13411126a | P-2 Vend Fab C Dipoles & Coils (S/R Dipoles) Original Labor FY11 | 77d | 2010-10-01 | 2011-01-28 | 13411126 | 196d |
| 13411135a | Proc & Vend Fab Misc shims & Brackets (S/R Dipoles) Labor FY11 | 248d | 2010-10-01 | 2011-09-30 | 13411135 | 399d |
| 13411136a | Proc Prep BCOMM and Additional Steel FY11 | 22d | 2010-10-01 | 2010-11-01 | 13411136 | 285d |
| 13411165 | Proc Prep Extra Coils FY11 | 22d | 2010-10-01 | 2010-11-01 | 13411160 | 520d |
| 13411200a | Spreader Recombiner Dipole Refurb and Mod Documentation FY11 | 58d | 2010-10-01 | 2010-12-30 | 13411200 | 340d |
| 13411911LOE | FY11 Mngmnt & Oversight (S/R Dipoles) | 248d | 2010-10-01 | 2011-09-30 | 13411910LOE | 20d |
| 13411136M | Award Vend Fab BCOMM and Additional Steel | 0d | 2010-11-02 | 2010-11-02 | 13411136a | 285d |
| 13411137 | Vend Fab BCOMM and Additional Steel Oversight | 163d | 2010-11-02 | 2011-07-01 | 13411136M | 520d |
| 13411138 | Vend Fab BCOMM and Additional Steel (Materials) | 226d | 2010-11-02 | 2011-09-30 | 13411136M | 285d |
| 13411170M | Award Vend Fab Extra Coils | 0d | 2010-11-02 | 2010-11-02 | 13411165 | 520d |
| 13411175 | Vend Fab Extra Coils Oversight | 163d | 2010-11-02 | 2011-07-01 | 13411170M | 520d |
| 13411180 | Vend Fab Extra Coils 1st Article | 76d | 2010-11-02 | 2011-03-01 | 13411170M | 520d |
| 13411185 | Vend Fab Extra Coils Production (19) | 163d | 2010-11-02 | 2011-07-01 | 13411180 FS-76d | 520d |
| 13411195 | Magnet End Shim Form Factor Documentation | 97d | 2010-11-03 | 2011-03-31 | 9-110M FS+23d | 585d |
| 13411066 | P-2 Vend Fab H Steel (S/R Dipoles) | 170d | 2011-01-04 | 2011-09-02 | 13411065b FS-53d, 13411065a FS-53d | 169d |
| 13411190 | Receive and Inspect Extra Coils | 107d | 2011-02-01 | 2011-07-01 | 13411185 FS-107d, 13411180 FS-20d | 520d |
| 13411110M | Delivery Complete for Curved Dipoles (S/R DIPOLES) | 0d | 2011-02-28 | 2011-02-28 | 13411106a, 13411105r, 13411108M | 91d |
| 13411087G | Vend Fab Septa (S/R Dipoles) Peg Point #1 Receipt of Material | 110d | 2011-03-29 | 2011-08-31 | 9-110M FS+117d | 181d |
| 13411087H | Vend Fab Septa (S/R Dipoles) Peg Point #2 Acceptance and Shipping of First Article ZA Magnet Assembly | 172d | 2011-03-29 | 2011-11-30 | 13411087G FS-110d | 181d |
| 13411087J | Vend Fab Septa (S/R Dipoles) Peg Point #3 Delivery and Acceptance of Quantity 4 ZA Magnet Assemblies | 188d | 2011-03-29 | 2011-12-29 | 13411087H FS-172d | 181d |
| 13411087K | Vend Fab Septa (S/R Dipoles) Peg Point #4 Delivery and Acceptance of Quantity 3 ZA Magnet Assemblies | 209d | 2011-03-29 | 2012-01-31 | 13411087J FS-188d | 181d |
| 13411087N | Vend Fab Septa (S/R Dipoles) Peg Point #5 Delivery and Acceptance of ZA Spare Coil Set | 209d | 2011-03-29 | 2012-01-31 | 13411087K FS-209d | 181d |
| 13411087P | Vend Fab Septa (S/R Dipoles) Peg Point #6 Delivery and Acceptance of Quantity 2 YA Magnet Assemblies | 229d | 2011-03-29 | 2012-02-29 | 13411087N FS-209d | 181d |
| 13411087Q | Vend Fab Septa (S/R Dipoles) Peg Point #7 Delivery and Acceptance of Quantity 2 ZB Coil Sets | 229d | 2011-03-29 | 2012-02-29 | 13411087P FS-229d | 181d |
| 13411087C5 | Vend Fab Septa (S/R Dipoles) Deliver (3) ZA Magnet Assemblies (WANG Additional Cost to Terminate) | 42d | 2011-06-01 | 2011-07-29 | 9-110M FS+162d | 323d |
| 13411087D05 | Vend Fab Septa (S/R Dipoles) Deliver ZA Spare Coil Set (Reverse Entry per CR 11-041) | 42d | 2011-06-01 | 2011-07-29 | 9-110M FS+162d | 323d |
| 13411087D15 | Vend Fab Septa (S/R Dipoles) Deliver (2) YA Magnet Assemblies (Reverse Entry per CR 11-041) | 127d | 2011-06-01 | 2011-11-30 | 9-110M FS+162d | 238d |
| 13411087D7 | Vend Fab Septa (S/R Dipoles) Deliver (2) ZB Coil Sets (Reverse Entry per CR 11-041) | 144d | 2011-06-01 | 2011-12-30 | 9-110M FS+162d | 221d |
| 13411087F5 | Stangenes Septa Contract Oversight Labor FY11 | 86d | 2011-06-01 | 2011-09-30 | 9-110M FS+162d | 181d |
| 13411087F7 | Completion of Core Macining | 144d | 2011-06-01 | 2011-12-30 | 9-110M FS+162d | 221d |
| 13411140 | Mag Measurment of New C & Curved Dipoles (S/R Dipoles) FY11 | 26d | 2011-08-25 | 2011-09-30 | 13411110M FS+80d, 13411130M FS-5d | 46d |
| 13411130M | Delivery Complete for C Dipoles & Coils (S/R DIPOLES) (IPL 534213060 and 534213120) | 0d | 2011-08-31 | 2011-08-31 | 13411126a, 13411105u | 46d |
| 13411070M | Delivery Complete for H Steel for S/R Dipoles (S/R DIPOLES) | 0d | 2011-09-02 | 2011-09-02 | 13411066 | 169d |
| 13411087F5a | Stangenes Septa Contract Oversight Labor FY12 | 98d | 2011-10-03 | 2012-02-29 | 13411087F5 | 181d |
| 13411135ab | Proc & Vend Fab Misc shims & Brackets (S/R Dipoles) Labor FY12 | 58d | 2011-10-03 | 2011-12-30 | 13411135a | 399d |
| 13411138a | Vend Fab BCOMM and Additional Steel (Machining) | 120d | 2011-10-03 | 2012-03-30 | 9-120M, 13411138 | 285d |
| 13411140a | Mag Measurment of New C & Curved Dipoles (S/R Dipoles) FY12 | 104d | 2011-10-03 | 2012-03-08 | 13411140 | 46d |
| 13411912LOE | FY12 Mngmnt & Oversight (S/R Dipoles) | 247d | 2011-10-03 | 2012-09-28 | 13411911LOE | 20d |
| 13411145 | Mag Measurement of Septa's (S/R Dipoles) | 98d | 2011-11-30 | 2012-04-25 | 13416048M FS-125d, 13411090M FS-227d, 13411087A | 12d |
| 13411088M | First Septa Dipole Delivery | 0d | 2011-11-30 | 2011-11-30 | 13411087A, 13411087H | 238d |
| 13411196 | Procurement of CNC Machining Center | 79d | 2011-12-01 | 2012-03-30 | 9-120M FS+41d | 30d |

| ID | WBS | Task | Duration | Start | Finish | Predecessors | Total float |
| --- | --- | --- | --- | --- | --- | --- | --- |
| 13411135b |  | Proc & Vend Fab Misc shims & Brackets (S/R Dipoles) Procurement | 91d | 2011-12-14 | 2012-04-30 | 13411909LOE, 9-120M FS+50d | 316d |
| 13411139 |  | Receive and Inspect BCOMM and Additional Steel | 107d | 2012-04-02 | 2012-08-30 | 13411138 FS-107d, 13411138a | 285d |
| 13411088 |  | Septa Core Shipping Costs | 20d | 2012-10-01 | 2012-10-26 | 9-130M | 12d |
| 13411150LOE |  | Management Oversight of Septa's (S/R Dipoles) 2012 ETC | 80d | 2012-10-01 | 2013-01-31 | 9-130M | 157d |
| 13411090M |  | Delivery Complete for Septa (S/R DIPOLES) | 0d | 2012-10-26 | 2012-10-26 | 13411087D15, 13411087F, 13411087D10, 13411087F5a, 13411087C, 13411087D7, 13411087D5, 13411087F7, 13411088M, 13411087, 13411087D, 13411087Q, 13411087D05, 13411087A, 13411087C5, 13411086BLOE, 13411087B, 13411088 | 12d |
| 13411950 |  | Re-Baseline Actuals Adjustment | 1d | 2013-08-30 | 2013-08-30 | 9-130M FS+227d | 20d |
| 23411087N |  | Vend Fab Septa (S/R Dipoles) Peg Point #5 Delivery and Acceptance of ZA Spare Coil Set | 31d | 2013-09-03 | 2013-10-15 | 9-130M FS+228d | 3d |
| 23411087Q |  | Vend Fab Septa (S/R Dipoles) Peg Point #7 Delivery and Acceptance of Quantity 2 ZB Coil Sets | 31d | 2013-09-03 | 2013-10-15 | 23411087N FS-31d | 3d |
| 23411145 |  | Mag Measurement of Septa's (S/R Dipoles) FY13 | 9d | 2013-09-18 | 2013-09-30 | 23411090M FS-20d | 3d |
| 23411145a |  | Mag Measurement of Septa's (S/R Dipoles) FY14 | 11d | 2013-10-01 | 2013-10-15 | 23411145, 23411090M FS-20d | 3d |
| 23411090M |  | Delivery Complete for Septa (S/R DIPOLES) | 0d | 2013-10-15 | 2013-10-15 | 23411087Q | 3d |
|  | 2 | **1.3.4.1.2 QUADRUPOLES** |  |  |  |  |  |
|  | 3 | **1.3.4.1.3 CORRECTORS** |  |  |  |  |  |
|  | 4 | **1.3.4.1.4 STANDS** |  | 2010-01-05 | 2013-08-30 |  |  |
| 13414055 |  | Vend Fab S/R Cartridges & Brackets (S/R Stands) (Original) | 37d | 2010-01-05 | 2010-02-26 | 9-100M FS+60d | 549d |
| 13414015 |  | Prcrmnt Prep of New S/R Stands (S/R Stands) Initial | 55d | 2010-03-01 | 2010-05-14 | 9-100M FS+97d, 121414016, 121414015a, 121416010, 121414020a | 298d |
| 13414017 |  | Prcrmnt Prep of New S/R Stands (S/R Stands) Final | 207d | 2010-12-01 | 2011-09-30 | 121414015a, 9-110M FS+41d, 13414015, 121414020a, 121414016, 121416010 | 161d |
| 13414100 |  | Vend Fab New Girders for S/R (S/R Stands) | 83d | 2011-04-01 | 2011-07-28 | 9-110M FS+120d | 502d |
| 13414060 |  | Procurement Prep of S/R Brackets (S/R Stands) | 88d | 2011-05-27 | 2011-09-30 | 9-120M FS-88d | 75d |
| 13414022LOE |  | Vend Fab New S/R Stands (S/R Stands) Oversight | 101d | 2011-12-14 | 2012-05-14 | 13414020M FS-91d | 174d |
| 13414065M |  | Award Contract for Brackets (S/R Stands) | 0d | 2011-12-21 | 2011-12-21 | 9-120M FS+55d, 13414060 | 20d |
| 13414070LOE |  | Vend Fab S/R Brackets (S/R Stands) Oversight | 65d | 2011-12-21 | 2012-03-30 | 13414065M, 13414060 | 129d |
| 13414075 |  | Vend Fab S/R Brackets (S/R Stands) | 192d | 2011-12-21 | 2012-09-28 | 13414065M | 20d |
| 13414090 |  | Receive and Inspect S/R Brackets (S/R Stands) Frozen Per CR 12-035 | 9d | 2012-03-20 | 2012-03-30 | 9-120M FS+111d | 129d |
| 13414027 |  | Receive and Inspect to S/R Stands Frozen Per CR 12-035 | 3d | 2012-03-28 | 2012-03-30 | 9-120M FS+117d | 205d |
| 13414028 |  | Reverse Entry Per CR 12-035 | 15d | 2012-04-02 | 2012-04-20 | 9-120M FS+120d | 112d |
| 13414020M |  | Award Contract for New S/R Stands (S/R STANDS) | 0d | 2012-05-01 | 2012-05-01 | 9-120M FS+141d, 13414017 | 20d |
| 13414025A |  | Vend Fab Stands Peg Point #1 Receipt of Material | 64d | 2012-05-01 | 2012-07-31 | 13414020M | 20d |
| 13414025B |  | Vend Fab Stands Peg Point #2 Receipt and Acceptance of Finished Stands 002-015 (Qty 14) | 87d | 2012-05-01 | 2012-08-31 | 13414025A FS-64d | 20d |
| 13414025C |  | Vend Fab Stands Peg Point #3 Receipt and Acceptance of Finished Stands 016-029 (Qty 14) | 106d | 2012-05-01 | 2012-09-28 | 13414025B FS-87d | 20d |
| 13414025D |  | Vend Fab Stands Peg Point #4 Receipt and Acceptance of Finished Stands 030-040 (Qty 11) | 129d | 2012-05-01 | 2012-10-31 | 13414025C FS-106d | 20d |
| 13414025F |  | Vend Fab Stands Peg Point #5 Receipt and Acceptance of Finished Stands 041-051 (Qty 11) | 149d | 2012-05-01 | 2012-11-30 | 13414025D FS-129d | 20d |
| 13414025G |  | Vend Fab Stands Peg Point #6 Receipt and Acceptance of Finished Stands 052-071 (Qty 20) | 165d | 2012-05-01 | 2012-12-31 | 13414025F FS-149d | 20d |
| 13414092 |  | Receive and Inspect S/R Brackets (S/R Stands) Revised Per CR 12-035 | 36d | 2012-07-16 | 2012-09-04 | 13414075 FS-54d | 20d |
| 13414029 |  | Receive and Inspect to S/R Stands Revised Per CR 12-035 FY12 | 31d | 2012-08-16 | 2012-09-28 | 13414025A, 13414025G FS-90d | 20d |
| 13414095M |  | Delivery Complete for S/R Cartridges & Brackets (S/R Stands) | 0d | 2012-09-04 | 2012-09-04 | 13414092, 13414070LOE, 13414090 | 20d |
| 13414029a |  | Receive and Inspect to S/R Stands Revised Per CR 12-035 FY13 | 58d | 2012-10-01 | 2012-12-21 | 13414029 | 20d |
| 13414030M |  | Delivery Complete for New S/R Stands (S/R STANDS) | 0d | 2012-12-21 | 2012-12-21 | 13414022LOE, 13414025A FS-10d, 13414027, 13414029a | 20d |
| 13414105 |  | Re-Baseline Actuals Adjustment | 1d | 2013-08-30 | 2013-08-30 | 9-130M FS+227d | 20d |
|  | 5 | **1.3.4.1.5 GIRDERS** |  |  |  |  |  |
|  | 6 | **1.3.4.1.6 VACUUM** |  | 2010-01-05 | 2013-08-30 |  |  |
| 13416020 |  | Prcrmnt Prep of S/R Dipole Chambers (S/R Vac) Initial | 60d | 2010-01-05 | 2010-03-31 | 121416010, 9-100M FS+60d, 121416000a, 121416005a | 415d |
| 13416040 |  | Procurement Prep of S/R Septa Chambers (S/R Vac) | 45d | 2010-03-01 | 2010-04-30 | 9-100M FS+97d | 313d |
| 13416042LOE |  | Vend Fab S/R Septa Chambers (S/R Vac) Oversight | 107d | 2010-04-22 | 2010-09-22 | 13416040 FS-7d | 431d |
| 13416045 |  | Vend Fab S/R Septa Chambers- ZAs (S/R Vac) ORG | 49d | 2010-04-22 | 2010-06-30 | 13416040 FS-7d | 313d |
| 13416046 |  | Vend Fab S/R Septa Chambers- YRs (S/R Vac) ORG | 20d | 2010-06-03 | 2010-06-30 | 13416045 FS-20d | 313d |
| 13416045a |  | Vend Fab S/R Septa Chambers- ZAs (S/R Vac) REDESIGN FY10 | 21d | 2010-09-01 | 2010-09-30 | 13416045 FS+43d | 368d |
| 13416025 |  | Prcrmnt Prep of S/R Dipole Chambers (S/R Vac) Final | 110d | 2010-10-01 | 2011-03-17 | 9-110M | 177d |
| 13416045ab |  | Vend Fab S/R Septa Chambers- ZAs (S/R Vac) REDESIGN FY11 | 57d | 2010-10-01 | 2010-12-29 | 13416045a | 368d |
| 13416049A |  | Vend Fab New Bellows (S/R Vac) | 110d | 2010-10-01 | 2011-03-17 | 9-110M | 288d |
| 13416049B |  | Proc Vac Materials Flanges/Gaskets/Hardware (S/R Vac) | 110d | 2010-10-01 | 2011-03-17 | 9-110M | 288d |
| 13416046a |  | Vend Fab S/R Septa Chambers- YRs (S/R Vac) REDESIGN | 91d | 2010-11-01 | 2011-03-21 | 13416046 FS+85d | 313d |
| 13416047 |  | Vend Fab S/R Septa Chambers- YB (S/R Vac) | 91d | 2010-11-01 | 2011-03-21 | 13416046 FS+85d | 313d |
| 13416048M |  | Fabrication Complete S/R Septa Chambers (S/R Vac) | 0d | 2011-03-21 | 2011-03-21 | 13416047, 13416046a, 13416046, 13416045ab, 13416045, 13416042LOE | 313d |
| 13416025M |  | Award Contract for S/R Dipole Chambers (S/R VACUUM) | 0d | 2011-11-14 | 2011-11-14 | 13416020, 9-120M FS+30d, 13416025 | 9d |
| 13416030 |  | Vend Fab S/R Dipole Chambers (S/R Vac) | 111d | 2011-11-14 | 2012-04-30 | 13416025M | 9d |
| 13416049 |  | Vend Fab New Drift Tubes (S/R Vac) | 138d | 2012-02-15 | 2012-08-29 | 9-120M FS+88d | 258d |
| 13416032 |  | Receive and Inspect S/R Dipole Chambers (S/R Vac) | 10d | 2012-04-17 | 2012-04-30 | 13416030 FS-10d | 9d |
| 13416035M |  | Delivery Complete for S/R Dipole Chambers (S/R VACUUM) | 0d | 2012-04-30 | 2012-04-30 | 13416030, 13416032 | 9d |
| 13416050 |  | Re-Baseline Actuals Adjustment | 1d | 2013-08-30 | 2013-08-30 | 9-130M FS+227d | 20d |
|  | 7 | **1.3.4.1.7 INSTALLATION** |  | 2011-11-14 | 2013-11-11 |  |  |
| 13417015 |  | Accelerator Down Planning Activity | 115d | 2011-11-14 | 2012-05-04 | 4A-04M | 5d |
| 13417155 |  | LCW Hoses FY12 | 127d | 2012-04-02 | 2012-09-28 | 9-120M FS+120d | 58d |
| 13417165 |  | Material handling/tooling/transporation FY12 | 127d | 2012-04-02 | 2012-09-28 | 9-120M FS+120d | 9d |
| 13417035 |  | ER - Upstairs | 47d | 2012-06-05 | 2012-08-08 | 13417026M FS-18d | 273d |
| 13417020 |  | Re-survey align network | 10d | 2012-06-18 | 2012-06-29 | 13411137, 13411139 FS-55d, 13414100, 2-02M FS+23d, 13411175, 13411195, 13411135ab, 3A-19M, 13411135b, 13411190 | 284d |
| 13417030 |  | ER - Install stands | 54d | 2012-06-27 | 2012-09-11 | 13417026M FS-2d | 63d |
| 13417026M |  | ER - Removed (BIA Activity Complete) | 0d | 2012-06-28 | 2012-06-28 | 2-02M FS+32d | 63d |
| 13417060 |  | WR - Upstairs FY12 | 64d | 2012-07-02 | 2012-09-28 | 13417050M FS-48d | 140d |
| 13417085 |  | ES - Upstairs FY12 | 49d | 2012-07-23 | 2012-09-28 | 13417075M FS-37d | 75d |

| ID | WBS | Task | Duration | Start | Finish | Predecessors | Total float |
| --- | --- | --- | --- | --- | --- | --- | --- |
| 13417050M |  | WR - Removed (BIA Activity Complete) | 0d | 2012-09-06 | 2012-09-06 | 2-02M FS+81d | 78d |
| 13417075M |  | ES - Removed (BIA Activity Complete) | 0d | 2012-09-12 | 2012-09-12 | 2-02M FS+85d | 75d |
| 13417080 |  | ES - Install stands FY12 | 12d | 2012-09-13 | 2012-09-28 | 13417075M | 163d |
| 13417040 |  | ER - Install magnets and girders FY12 | 9d | 2012-09-18 | 2012-09-28 | 13417030 FS+4d | 63d |
| 13417040a |  | ER - Install magnets and girders FY13 | 67d | 2012-10-01 | 2013-01-11 | 13417040 | 63d |
| 13417060a |  | WR - Upstairs FY13 | 5d | 2012-10-01 | 2012-10-05 | 13417060 | 140d |
| 13417080a |  | ES - Install stands FY13 | 14d | 2012-10-01 | 2012-10-18 | 13417080 | 163d |
| 13417085a |  | ES - Upstairs FY13 | 45d | 2012-10-01 | 2012-12-04 | 13417085 | 75d |
| 13417160 |  | LCW Hoses FY13 | 120d | 2012-10-01 | 2013-03-29 | 13417155 | 58d |
| 13417170 |  | Material handling/tooling/transporation FY13 | 228d | 2012-10-01 | 2013-08-30 | 13417165 | 9d |
| 13417110 |  | WS - Upstairs | 66d | 2012-10-26 | 2013-02-07 | 13417100M FS-14d | 24d |
| 13417100M |  | WS - Removed (BIA Activity Complete) | 0d | 2012-11-14 | 2012-11-14 | 2-02M FS+130d | 24d |
| 13417105 |  | WS - Install stands | 21d | 2012-11-15 | 2012-12-17 | 13417100M | 55d |
| 13417055 |  | WR - Install stands | 31d | 2012-11-20 | 2013-01-11 | 13447035 | 78d |
| 13417065 |  | WR - Install magnets & girders | 65d | 2013-01-14 | 2013-04-16 | 13417060a, 13417055 | 78d |
| 13417115 |  | WS - Install magnets and girders | 86d | 2013-02-08 | 2013-06-11 | 13417110, 13417105 | 24d |
| 13417135 |  | TR - Upstairs | 41d | 2013-02-19 | 2013-04-16 | 13417125M FS-11d | 46d |
| 13417125M |  | TR - Removed (BIA Activity Complete) | 0d | 2013-03-05 | 2013-03-05 | 2-02M FS+199d | 46d |
| 13417090 |  | ES - Install magnets & girders | 50d | 2013-03-06 | 2013-05-14 | 13417080a, 13417085a FS+57d | 75d |
| 13417130 |  | TR - Install stands | 22d | 2013-03-06 | 2013-04-04 | 13417125M | 59d |
| 13417045 |  | ER - Final align | 8d | 2013-04-01 | 2013-04-10 | 13417040a FS+48d, 13417160 | 58d |
| 13417140 |  | TR - Install magnets and girders | 47d | 2013-04-24 | 2013-06-28 | 13417130, 13417135 FS+5d | 46d |
| 13417120 |  | WS - Final align | 5d | 2013-06-12 | 2013-06-18 | 13417115, 13436060 | 24d |
| 13417145 |  | TR - Final align | 4d | 2013-07-01 | 2013-07-05 | 13417140 | 46d |
| 13417070 |  | WR - Final align | 8d | 2013-07-03 | 2013-07-15 | 13417065, 13427062 | 24d |
| 13417095 |  | ES - Final align | 5d | 2013-07-29 | 2013-08-02 | 13436065, 13417090 | 24d |
| 13417150 |  | Alignment complete | 3d | 2013-08-07 | 2013-08-09 | 13427061, 13417145, 13427032 | 24d |
| 13417175 |  | Re-Baseline Actuals Adjustment | 1d | 2013-08-30 | 2013-08-30 | 9-130M FS+227d | 20d |
| 23417065 |  | WR - Install magnets & girders | 20d | 2013-09-03 | 2013-09-30 | 9-130M FS+228d | 4d |
| 23417115 |  | WS - Install magnets and girders | 11d | 2013-09-03 | 2013-09-17 | 9-130M FS+228d | 27d |
| 23417120 |  | WS - Final align | 13d | 2013-09-03 | 2013-09-19 | 23417115 FS-11d | 27d |
| 23417130 |  | TR - Install stands | 16d | 2013-09-03 | 2013-09-24 | 9-130M FS+228d | 4d |
| 23417140 |  | TR - Install magnets and girders FY13 | 20d | 2013-09-03 | 2013-09-30 | 23417130 FS-16d | 4d |
| 23417165 |  | Procure S/R plumbing materials | 20d | 2013-09-03 | 2013-09-30 | 9-130M FS+228d | 4d |
| 23417170 |  | Procure S/R Vacuum materials | 20d | 2013-09-03 | 2013-09-30 | 9-130M FS+228d | 4d |
| 23417145 |  | TR - Final align FY13 | 1d | 2013-09-30 | 2013-09-30 | 23417140 FS-2d, 23417140a FS-2d | 4d |
| 23417140a |  | TR - Install magnets and girders FY14 | 1d | 2013-10-01 | 2013-10-01 | 23417140, 23417130 FS-16d | 4d |
| 23417145a |  | TR - Final align FY14 | 21d | 2013-10-01 | 2013-10-29 | 23417145, 23417140a FS-2d, 23417140 FS-2d | 4d |
| 23417150 |  | Alignment complete | 3d | 2013-11-07 | 2013-11-11 | 23417145a FS+6d, 23417145 FS+6d | 4d |
|  | 2 | **1.3.4.2 EXISTING ARCS (1-9, A, B, & C)** |  | 2009-01-02 | 2013-11-18 |  |  |
|  | 1 | **1.3.4.2.1 DIPOLES** |  | 2009-01-02 | 2013-08-30 |  |  |
| 13421909LOE |  | FY09 Mngmnt & Oversight (EXIST ARC Dipoles) | 189d | 2009-01-02 | 2009-09-30 | 13421909LOEXD | 20d |
| 13421025 |  | Prcrmnt Prep for New Hall A&C Dipoles | 117d | 2009-01-12 | 2009-06-26 | 9-090M FS+65d | 321d |
| 13421046 |  | Fabrication of Existing Arc Dipole Rebuild Parts | 97d | 2009-01-12 | 2009-05-29 | 9-090M FS+65d | 89.54d |
| 13421030 |  | Vendor Fab New Hall A&C Dipoles Original Labor FY10 | 314d | 2009-06-29 | 2010-09-30 | 13421025 | 321d |
| 13421050M |  | Delivery Complete for Magnet Steel & Conductor (EXIST ARC DIPOLES) | 0d | 2009-06-29 | 2009-06-29 | 13422040M FS-25d, 13411100M, 13411080M, 13411120M, 13451060M | 1361d |
| 13421910LOE |  | FY10 Mngmnt & Oversight (EXIST ARC Dipoles) | 248d | 2009-10-01 | 2010-09-30 | 13421909LOE, 13444909LOE | 20d |
| 13421055 |  | Prcrmnt Prep for H Steel (EXIST ARC Dipoles) | 110d | 2009-10-05 | 2010-03-19 | 121425015, 121421021, 121421020, 13411055 FS-110d | 169d |
| 13421060M |  | Award Contract for H Steel (EXIST ARC DIPOLES) | 0d | 2010-03-22 | 2010-03-22 | 13421055 | 169d |
| 13421065 |  | P-1 Vend Fab H Steel (EXIST ARC Dipoles) Labor FY10 | 136d | 2010-03-22 | 2010-09-30 | 13421060M | 169d |
| 13421065b |  | P-1 Vend Fab H Steel (EXIST ARC Dipoles) Procurement | 248d | 2010-03-22 | 2011-03-21 | 13421060M | 169d |
| 13421046a |  | Fabrication of Existing Arc Dipole Rebuild Parts (Labor) FY10 | 105d | 2010-05-03 | 2010-09-30 | 13421046 FS+228.46d | 89.54d |
| 13421046b |  | Fabrication of Existing Arc Dipole Rebuild Parts (proc) | 166d | 2010-05-03 | 2011-01-05 | 13421046 FS+228.46d | 89.54d |
| 13421085 |  | Vendor Fab and Delivery of Magnet Refurbishment Crane | 50d | 2010-09-13 | 2010-11-19 | 9-100M FS+234d | 54d |
| 13421046ab |  | Fabrication of Existing Arc Dipole Rebuild Parts (Labor) FY11 | 61d | 2010-09-30 | 2011-01-05 | 13421046a | 89.54d |
| 13421030a |  | Vendor Fab New Hall A&C Dipoles Original Labor FY11 | 77d | 2010-10-01 | 2011-01-28 | 13421030 | 321d |
| 13421065a |  | P-1 Vend Fab H Steel (EXIST ARC Dipoles) Labor FY11 | 112d | 2010-10-01 | 2011-03-21 | 13421065 | 169d |
| 13421095 |  | Vend Fab Survey Instrument | 40d | 2010-10-01 | 2010-11-29 | 9-110M | 110d |
| 13421911LOE |  | FY11 Mngmnt & Oversight (EXIST ARC Dipoles) | 248d | 2010-10-01 | 2011-09-30 | 13421910LOE | 20d |
| 13421090 |  | Installation of Magnetic Refurbishment Crane | 60d | 2010-11-22 | 2011-02-25 | 13421085 | 54d |
| 13421066 |  | P-2 Vend Fab H Steel (EXIST ARC Dipoles) | 170d | 2011-01-04 | 2011-09-02 | 13421065a FS-53d, 13421065b FS-53d | 169d |
| 13421067M |  | Delivery of First Article H Steel | 0d | 2011-02-22 | 2011-02-22 | 13421060M FS+229d | 305d |
| 13421070M |  | Delivery Complete for H Steel for S/R Dipoles (EXIST ARC DIPOLES) | 0d | 2011-09-02 | 2011-09-02 | 13421065b, 13421067M, 13421066, 13421065a | 169d |
| 13421912LOE |  | FY12 Mngmnt & Oversight (EXIST ARC Dipoles) | 247d | 2011-10-03 | 2012-09-28 | 13421911LOE | 20d |
| 13421950 |  | Re-Baseline Actuals Adjustment | 1d | 2013-08-30 | 2013-08-30 | 9-130M FS+227d | 20d |
|  | 2 | **1.3.4.2.2 QUADRUPOLES** |  | 2009-01-02 | 2013-08-30 |  |  |
| 13422035 |  | Prcrmnt Prep for Quads (EXIST ARC Q-POLES) | 32d | 2009-01-02 | 2009-02-18 | 13422035XD | 1477d |
| 13422045 |  | Vend Fab Quads (EXIST ARC Q-POLES) LABOR Initial | 115d | 2009-02-19 | 2009-07-31 | 9-090M FS+91d | 576d |
| 13432004 |  | Procurement Prep for Linac Correctors FY09 | 63d | 2009-07-02 | 2009-09-30 | 9-090M FS+185d | 302d |
| 13422040M |  | Award Contract for Quadrupoles (EXIST ARC Q-POLES) | 0d | 2009-08-03 | 2009-08-03 | 9-090M FS+206d, 13422035, 1114010 | 1362d |

| ID | WBS | Task | Duration | Start | Finish | Predecessors | Total float |
| --- | --- | --- | --- | --- | --- | --- | --- |
| 13422046 |  | Vend Fab Quads (EXIST ARC Q-POLES) LABOR Final FY09 | 42d | 2009-08-03 | 2009-09-30 | 13422045 | 576d |
| 13422047 |  | Vend Fab Quads (EXIST ARC Q-POLES) Recieve Materials | 45d | 2009-08-03 | 2009-10-05 | 9-090M FS+206d | 839d |
| 13422047A |  | Vend Fab Quads (EXIST ARC Q-POLES) Lamination Stampings | 1d | 2009-08-03 | 2009-08-03 | 9-090M FS+206d | 883d |
| 13422047B |  | Vend Fab Quads (EXIST ARC Q-POLES) First Article QR | 62d | 2009-08-03 | 2009-10-28 | 9-090M FS+206d | 822d |
| 13422047C |  | Vend Fab Quads (EXIST ARC Q-POLES) Deliver 5 QR Magnets | 120d | 2009-08-03 | 2010-01-29 | 9-090M FS+206d | 764d |
| 13422047D |  | Vend Fab Quads (EXIST ARC Q-POLES) Deliver 5 QR Magnets | 139d | 2009-08-03 | 2010-02-26 | 9-090M FS+206d | 745d |
| 13422047F |  | Vend Fab Quads (EXIST ARC Q-POLES) Deliver 5 QR Magnets | 160d | 2009-08-03 | 2010-03-29 | 9-090M FS+206d | 724d |
| 13422047G |  | Vend Fab Quads (EXIST ARC Q-POLES) Deliver 5 QR Magnets | 184d | 2009-08-03 | 2010-04-30 | 9-090M FS+206d | 700d |
| 13422047H |  | Vend Fab Quads (EXIST ARC Q-POLES) Deliver 5 QR Magnets | 204d | 2009-08-03 | 2010-05-28 | 9-090M FS+206d | 680d |
| 13422047J |  | Vend Fab Quads (EXIST ARC Q-POLES) Deliver 5 QR Magnets | 221d | 2009-08-03 | 2010-06-23 | 9-090M FS+206d | 663d |
| 13422047K |  | Vend Fab Quads (EXIST ARC Q-POLES) Deliver 4 QR Magnets | 243d | 2009-08-03 | 2010-07-26 | 9-090M FS+206d | 641d |
| 13422047L |  | Vend Fab Quads (EXIST ARC Q-POLES) Deliver 2 QR Magnets | 308d | 2009-08-03 | 2010-10-26 | 9-090M FS+206d | 576d |
| 13422046b |  | Vend Fab Quads (EXIST ARC Q-POLES) LABOR Final FY10 | 248d | 2009-10-01 | 2010-09-30 | 13422046 | 576d |
| 13432004b |  | Procurement Prep for Linac Correctors FY10 | 53d | 2009-10-01 | 2009-12-16 | 13432004 | 302d |
| 13422100 |  | Prcrmnt Prep for QY Quads FY10a | 64d | 2010-04-01 | 2010-06-30 | 9-100M FS+120d | 528d |
| 13422055 |  | Mag Measurment of New Quads (EXIST ARC Q-POLES) FY10 | 104d | 2010-05-05 | 2010-09-30 | 13422050M FS-122d | 576d |
| 13422102 |  | Prcrmnt Prep for QY Quads FY10b | 64d | 2010-07-01 | 2010-09-30 | 13422100 | 528d |
| 13422046ba |  | Vend Fab Quads (EXIST ARC Q-POLES) LABOR Final FY11 | 18d | 2010-10-01 | 2010-10-26 | 13422046b | 576d |
| 13422055a |  | Mag Measurment of New Quads (EXIST ARC Q-POLES) FY11 | 96d | 2010-10-01 | 2011-02-25 | 13422055 | 576d |
| 13422102a |  | Prcrmnt Prep for QY Quads FY11 | 14d | 2010-10-01 | 2010-10-20 | 13422102 | 528d |
| 13422105M |  | Award Contract for QY Quadrupoles | 0d | 2010-10-21 | 2010-10-21 | 13422102a | 528d |
| 13422110 |  | Vend Fab QY Quads Labor Support FY11 | 170d | 2010-10-21 | 2011-06-30 | 13422105M | 528d |
| 13422115 |  | Vend Fab QY Quads 1st Article | 106d | 2010-10-21 | 2011-03-31 | 13422105M | 528d |
| 13422050M |  | Delivery Complete for Quadrupoles(EXIST ARC Q-POLES) | 0d | 2010-10-26 | 2010-10-26 | 13422047K, 13422047C, 13422047B, 13422047, 13422047D, 13422047F, 13422047A, 13422047J, 13422047L, 13422047H, 13422047G, 13422046ba | 576d |
| 13422122 |  | Receive and Inspect QY Quads | 127d | 2011-01-31 | 2011-07-29 | 13422115 FS-43d | 528d |
| 13422123 |  | Magnetic Measurement QY Quads | 106d | 2011-03-02 | 2011-07-29 | 13422122 FS-500d, 9-110M FS+98d, 13422125M FS-500d | 528d |
| 13422112 |  | Vend Fab QY Quads Labor Support FY12 | 20d | 2011-07-01 | 2011-07-29 | 13422110 | 528d |
| 13422123a |  | Magnetic Measurement QR Quads FY11 | 16d | 2011-09-09 | 2011-09-30 | 13422122 FS-184d, 13422125M FS-184d | 316d |
| 13422065 |  | Measure 69 S/R Quads at Higher Current (EXIST ARC Q-POLES) | 50d | 2011-10-03 | 2011-12-13 | 9-120M | 197d |
| 13422123b |  | Magnetic Measurement QR Quads FY12 | 168d | 2011-10-03 | 2012-06-08 | 13422123a | 316d |
| 13422117 |  | Vend Fab QR Quads Labor Support | 133d | 2011-11-14 | 2012-05-31 | 9-120M FS+30d | 321d |
| 13422120 |  | Vend Fab Additional QR Quads | 133d | 2011-11-14 | 2012-05-31 | 9-120M FS+30d, 13422115 FS-106d | 316d |
| 13422060 |  | Add Klixons to 20 Amp Quads (EXIST ARC Q-POLES) | 60d | 2012-05-07 | 2012-07-31 | 2-02M FS-5d, 13422055a | 279d |
| 13422122a |  | Receive and Inspect QR Quads | 5d | 2012-06-01 | 2012-06-08 | 13422120 | 316d |
| 13422125M |  | Delivery Complete for QR Quadrupoles | 0d | 2012-06-08 | 2012-06-08 | 13422117, 13422112, 13422120, 13422122a, 13422115, 13422122 | 316d |
| 13422130 |  | Re-Baseline Actuals Adjustment | 1d | 2013-08-30 | 2013-08-30 | 9-130M FS+227d | 20d |
|  | 3 | **1.3.4.2.3 CORRECTORS** |  |  |  |  |  |
|  | 4 | **1.3.4.2.4 STANDS** |  | 2009-01-05 | 2013-08-30 |  |  |
| 13425020 |  | Proc Girder Matrl (EXIST ARC Girders) | 102d | 2009-01-05 | 2009-05-29 | 121425010, 9-090M FS+60d | 592d |
| 13425025 |  | Proc Prep of Girders/Stands for QY Quads (EXIST ARC Girders) | 79d | 2011-03-11 | 2011-06-30 | 9-110M FS+105d, 13425020 | 153d |
| 13425030 |  | Vend Fab Girders/Stands for QY Quads (EXIST ARC Girders) | 61d | 2012-02-03 | 2012-04-30 | 13425020, 13425025, 9-120M FS+80d | 9d |
| 13425035 |  | Re-Baseline Actuals Adjustment | 1d | 2013-08-30 | 2013-08-30 | 9-130M FS+227d | 20d |
|  | 5 | **1.3.4.2.5 GIRDERS** |  |  |  |  |  |
|  | 6 | **1.3.4.2.6 VACUUM** |  | 2013-08-30 | 2013-08-30 |  |  |
| 13426000 |  | Re-Baseline Actuals Adjustment | 1d | 2013-08-30 | 2013-08-30 | 9-130M FS+227d | 20d |
|  | 7 | **1.3.4.2.7 INSTALLATION** |  | 2010-07-02 | 2013-11-18 |  |  |
| 13427180 |  | Accelerator Down Planning FY10 | 63d | 2010-07-02 | 2010-09-30 | 9-100M FS+185d | 3d |
| 13427180a |  | Accelerator Down Planning FY11 | 147d | 2010-10-01 | 2011-05-09 | 13427180 | 3d |
| 13427055 |  | Procure new material handling equipment | 107d | 2010-11-05 | 2011-04-18 | 9-110M FS+25d | 18d |
| 13427060 |  | Procure Temporary Space for expanded technician work force | 127d | 2011-03-04 | 2011-08-31 | 9-110M FS+100d | 51d |
| 13427063LOE |  | Tech Training | 40d | 2011-03-04 | 2011-04-28 | 9-110M FS+100d | 10d |
| 13427062LOE |  | Engineering Support 6 Month Down | 80d | 2011-05-13 | 2011-09-06 | 4A-01M | 48d |
| 13427065 |  | AS-FOUND SURVEY (B/L UNDER VACUUM) SOUTH SIDE WEST ARC | 8d | 2011-05-20 | 2011-06-01 | 4A-01M FS+5d | 46d |
| 13427070 |  | BLEED UP VACUUM SOUTH SIDE OF W/ARC | 1d | 2011-06-02 | 2011-06-02 | 13427065 | 46d |
| 13427075 |  | AS-FOUND SURVEY (B/L UNDER VACUUM) NORTH SIDE WEST ARC | 8d | 2011-06-02 | 2011-06-13 | 13427065 | 57d |
| 13427120 |  | REMOVE MAGNETS - QUAD 1 | 5d | 2011-06-03 | 2011-06-09 | 3A-34M, 13427070 | 46d |
| 13427125 |  | REFURB, UPGRADE AND TEST MAGNETS - QUAD 1 | 11d | 2011-06-08 | 2011-06-22 | 13427120 FS-2d | 46d |
| 13427135 |  | REMOVE MAGNETS - QUAD 2 | 4d | 2011-06-08 | 2011-06-13 | 13427120 FS-2d | 52d |
| 13427080 |  | BLEED UP VACUUM NORTH SIDE OF W/ARC | 1d | 2011-06-14 | 2011-06-14 | 13427075 | 57d |
| 13427130 |  | INSTALL MAGNETS AND ARC 10 - QUAD 1 | 19d | 2011-06-15 | 2011-07-12 | 13427125 FS-6d | 72d |
| 13427150 |  | REMOVE MAGNETS - QUAD 3 | 4d | 2011-06-15 | 2011-06-20 | 13427080 | 57d |
| 13427165 |  | REMOVE MAGNETS - QUAD 4 | 6d | 2011-06-20 | 2011-06-27 | 13427150 FS-1d | 61d |
| 13427140 |  | REFURB, UPGRADE AND TEST MAGNETS - QUAD 2 | 10d | 2011-06-22 | 2011-07-06 | 13427135, 13427125 FS-1d | 46d |
| 13427145 |  | INSTALL MAGNETS AND ARC 10 - QUAD 2 | 16d | 2011-06-28 | 2011-07-20 | 13427140 FS-6d | 66d |
| 13427155 |  | REFURB, UPGRADE AND TEST MAGNETS - QUAD 3 | 10d | 2011-07-07 | 2011-07-20 | 13427150, 13427140 | 46d |
| 13427160 |  | INSTALL MAGNETS AND ARC 10 - QUAD 3 | 26d | 2011-07-12 | 2011-08-16 | 13427155 FS-7d | 50d |
| 13427170 |  | REFURB, UPGRADE AND TEST MAGNETS - QUAD 4 | 10d | 2011-07-20 | 2011-08-02 | 13427165, 13427155 FS-1d | 46d |
| 13427085 |  | PUMP OUT SOUTH SIDE WEST ARC | 3d | 2011-07-21 | 2011-07-25 | 13427130, 13427145 | 66d |
| 13427090 |  | QA CHECKS - SOUTH SIDE WEST ARC | 4d | 2011-07-25 | 2011-07-28 | 13427085 FS-1d | 66d |
| 13427175 |  | INSTALL MAGNETS AND ARC 10 - QUAD 4 | 21d | 2011-07-25 | 2011-08-22 | 13427170 FS-7d | 46d |

| ID | WBS | Task | Duration | Start | Finish | Predecessors | Total float |
| --- | --- | --- | --- | --- | --- | --- | --- |
| 13427095 |  | 2B FINAL STACK ALIGNMENT (B/L UNDER VACUUM) - SOUTH SIDE WEST ARC | 9d | 2011-07-29 | 2011-08-10 | 13427090 | 66d |
| 13427100 |  | PUMP OUT NORTH SIDE WEST ARC | 3d | 2011-08-23 | 2011-08-25 | 13427175, 13427160 | 46d |
| 13427105 |  | QA CHECKS - NORTH SIDE WEST ARC | 4d | 2011-08-25 | 2011-08-30 | 13427100 FS-1d | 46d |
| 13427110 |  | 2B FINAL STACK ALIGNMENT (B/L UNDER VACUUM) - NORTH SIDE WEST ARC | 7d | 2011-08-30 | 2011-09-08 | 13427105 FS-1d | 46d |
| 13427115M |  | WEST ARC FINISHED | 0d | 2011-09-08 | 2011-09-08 | 13427110, 13427095 | 46d |
| 13427015LOE |  | Installation Team Engineering Support FY12 (12 Month Down) | 106d | 2012-05-01 | 2012-09-28 | 2-02M FS-9d | 9d |
| 13427022 |  | Rework of arcs 5, 7, and 9 Part B FY12 | 84d | 2012-06-01 | 2012-09-28 | 2-02M FS+13d | 225d |
| 13427023 |  | Rework of arcs 5, 7, and 9 Part C FY12 | 76d | 2012-06-14 | 2012-09-28 | 2-02M FS+21d | 174d |
| 13427024 |  | Rework of arcs 5, 7, and 9 Part D FY12 | 67d | 2012-06-27 | 2012-09-28 | 2-02M FS+30d | 153d |
| 13427020 |  | Arcs 1 & 3 - Remove | 8d | 2012-08-02 | 2012-08-13 | 2-02M FS+56d, 3A-14M | 144d |
| 13427025 |  | Arcs 1 & 3 - Refurb and measure FY12 | 38d | 2012-08-07 | 2012-09-28 | 2-02M FS+13d, 13427020 FS-5d | 144d |
| 13427027 |  | Arcs 1 & 3 - Install FY12 | 38d | 2012-08-07 | 2012-09-28 | 13427025a FS-98d | 144d |
| 13427021 |  | Rework of arcs 5, 7, and 9 Part A FY12 | 33d | 2012-08-14 | 2012-09-28 | 2-02M FS+5d, 3A-36M | 193d |
| 13427016LOE |  | Installation Team Engineering Support FY13 (12 Month Down) *** Re-Baseline Split | 228d | 2012-10-01 | 2013-08-30 | 13427015LOE | 9d |
| 13427021a |  | Rework of arcs 5, 7, and 9 Part A FY13 | 44d | 2012-10-01 | 2012-12-03 | 13427021 | 193d |
| 13427022a |  | Rework of arcs 5, 7, and 9 Part B FY13 | 12d | 2012-10-01 | 2012-10-16 | 13427022 | 225d |
| 13427023a |  | Rework of arcs 5, 7, and 9 Part C FY13 | 63d | 2012-10-01 | 2013-01-07 | 13427023 | 174d |
| 13427024a |  | Rework of arcs 5, 7, and 9 Part D FY13 | 84d | 2012-10-01 | 2013-02-06 | 13427024 | 153d |
| 13427025a |  | Arcs 1 & 3 - Refurb and measure FY13 | 60d | 2012-10-01 | 2013-01-02 | 13427025 | 144d |
| 13427027a |  | Arcs 1 & 3 - Install FY13 | 72d | 2012-10-01 | 2013-01-18 | 13427027 | 144d |
| 13427035 |  | Hall A - Remove | 7d | 2012-10-11 | 2012-10-19 | 9-130M FS+8d | 186d |
| 13427042 |  | Hall B - Remove | 14d | 2012-10-16 | 2012-11-02 | 3A-17M, 13427035 FS-4d | 207d |
| 13427037 |  | Hall A - Upstairs | 22d | 2012-10-22 | 2012-11-20 | 13427035 | 186d |
| 13427050 |  | Hall C - Remove | 14d | 2012-10-23 | 2012-11-09 | 13427042 FS-9d, 3A-18M | 207d |
| 13427045 |  | Hall B - Upstairs | 44d | 2012-11-05 | 2013-01-15 | 13427042 | 293d |
| 13427047 |  | Hall B - Install | 88d | 2012-11-05 | 2013-03-20 | 3A-38M, 13427045 FS-45d | 292d |
| 13427040 |  | Hall A - Install | 89d | 2012-11-12 | 2013-03-28 | 3A-37M, 13427037 FS-7d | 186d |
| 13427052 |  | Hall C - Upstairs | 26d | 2012-11-12 | 2012-12-19 | 13427050 | 328d |
| 13427057 |  | Hall C - Install | 28d | 2012-12-11 | 2013-01-28 | 3A-33M, 13427052 FS-7d | 328d |
| 13427028 |  | West Arc LCW Work | 30d | 2013-01-03 | 2013-02-14 | 9-130M FS+60d | 130d |
| 13427032 |  | Arcs - Final align east end | 18d | 2013-01-22 | 2013-02-14 | 13427027a | 144d |
| 13427030 |  | Arcs - Final align west end | 17d | 2013-02-15 | 2013-03-12 | 9-130M, 13417020, 13427028, 13458010, 13458012, 13458040 | 130d |
| 13427062 |  | SW matching final alignment | 4d | 2013-06-27 | 2013-07-02 | 13463050 | 24d |
| 13427061 |  | NE matching final alignment | 2d | 2013-08-05 | 2013-08-06 | 13417095 | 24d |
| 13427185 |  | Re-Baseline Actuals Adjustment | 1d | 2013-08-30 | 2013-08-30 | 9-130M FS+227d | 20d |
| 23427016LOE |  | Installation Team Engineering Support FY13 (12 Month Down) | 20d | 2013-09-03 | 2013-09-30 | 9-130M FS+228d | 0d |
| 23427040 |  | Hall A - Install FY13 | 20d | 2013-09-03 | 2013-09-30 | 9-130M FS+228d | 48d |
| 23427047 |  | Hall B - Install FY13 | 20d | 2013-09-03 | 2013-09-30 | 9-130M FS+228d | 126d |
| 23427052 |  | Hall C - Upstairs FY13 | 20d | 2013-09-03 | 2013-09-30 | 9-130M FS+228d | 122d |
| 23427062 |  | Material Handling costs (Vehicle) | 54d | 2013-09-03 | 2013-11-15 | 9-130M FS+228d | 81d |
| 23427016LOEa |  | Installation Team Engineering Support FY14 (12 Month Down) | 34d | 2013-10-01 | 2013-11-15 | 9-130M FS+228d, 23427016LOE | 0d |
| 23427040a |  | Hall A - Install FY14 | 9d | 2013-10-01 | 2013-10-11 | 23427040, 9-130M FS+228d | 48d |
| 23427047a |  | Hall B - Install FY14 | 30d | 2013-10-01 | 2013-11-11 | 9-130M FS+228d, 23427047 | 126d |
| 23427052a |  | Hall C - Upstairs FY14 | 7d | 2013-10-01 | 2013-10-09 | 9-130M FS+228d, 23427052 | 122d |
| 23427057 |  | Hall C - Install | 27d | 2013-10-10 | 2013-11-15 | 23427052, 23427052a | 122d |
| 23427067 |  | Material Handling costs DeObligation | 1d | 2013-11-18 | 2013-11-18 | 23427062 | 81d |
|  | 3 | **1.3.4.3 LINACS** |  | 2009-12-17 | 2013-08-30 |  |  |
|  | 1 | **1.3.4.3.1 QUADRUPOLES** |  |  |  |  |  |
|  | 2 | **1.3.4.3.2 CORRECTORS** |  | 2009-12-17 | 2013-08-30 |  |  |
| 13432005 |  | Vend Fab H & V Linac Correctors (Linac Correctors) Labor FY10 | 195d | 2009-12-17 | 2010-09-30 | 121434999, 121432005, 13432004b | 302d |
| 13432005b |  | Vend Fab H & V Linac Correctors (Linac Correctors) Procurement | 261d | 2009-12-17 | 2011-01-12 | 121434999, 13432004b, 121432005 | 302d |
| 13432005a |  | Vend Fab H & V Linac Correctors (Linac Correctors) Labor FY11 | 66d | 2010-10-01 | 2011-01-12 | 13432005 | 302d |
| 13432015 |  | Mag Measurement of Linac Correctors & Skew Quads (Linac Correctors) | 30d | 2011-04-15 | 2011-05-26 | 13432005b, 13432005a, 9-110M FS+130d | 238d |
| 13432020 |  | Re-Baseline Actuals Adjustment | 1d | 2013-08-30 | 2013-08-30 | 9-130M FS+227d | 20d |
|  | 3 | **1.3.4.3.3 STANDS** |  | 2010-08-16 | 2013-08-30 |  |  |
| 13434005 |  | Proc Prep Linac Girders (Linac Girders) FY10 | 33d | 2010-08-16 | 2010-09-30 | 121434005, 9-100M FS+215d, 121434999 | 54d |
| 13433005 |  | Proc Prep Linac Stands (Linac Stands) | 43d | 2010-10-01 | 2010-12-02 | 121434999, 121434005, 9-110M | 55d |
| 13434005a |  | Proc Prep Linac Girders (Linac Girders) FY11 | 26d | 2010-10-01 | 2010-11-05 | 13434005 | 54d |
| 13434006 |  | Vend Fab Linac Girders (Linac Girders) | 70d | 2010-11-08 | 2011-02-25 | 13434005a | 54d |
| 13433010 |  | Vend Fab Linac Stands (Linac Stands) | 52d | 2010-12-03 | 2011-02-24 | 13433005 | 55d |
| 13433015 |  | Receive and Inspect Linac Stands (Linac Stands) | 9d | 2011-02-11 | 2011-02-24 | 13433010 FS-9d | 55d |
| 13434007 |  | Receive and Inspect Linac Girders (Linac Girders) | 9d | 2011-02-14 | 2011-02-25 | 13434006 FS-9d | 54d |
| 13433020 |  | Re-Baseline Actuals Adjustment | 1d | 2013-08-30 | 2013-08-30 | 9-130M FS+227d | 20d |
|  | 4 | **1.3.4.3.4 GIRDERS** |  |  |  |  |  |
|  | 5 | **1.3.4.3.5 VACUUM** |  | 2010-09-17 | 2013-08-30 |  |  |
| 13435010 |  | Proc New DI Ion Pumps (Linac Vac) | 100d | 2010-09-17 | 2011-02-16 | 9-110M FS-10d | 308d |
| 13435015 |  | Rebuild 3 South Linac Girders (Linac Vac) | 6d | 2011-05-23 | 2011-05-31 | 13436020 | 60d |
| 13435020 |  | Re-Baseline Actuals Adjustment | 1d | 2013-08-30 | 2013-08-30 | 9-130M FS+227d | 20d |
|  | 6 | **1.3.4.3.6 INSTALLATION** |  | 2011-05-13 | 2013-08-30 |  |  |
| 13436020 |  | Remove Warm Girder SL22 | 6d | 2011-05-13 | 2011-05-20 | 4A-01M | 60d |

| ID | WBS | Task | Duration | Start | Finish | Predecessors | Total float |
| --- | --- | --- | --- | --- | --- | --- | --- |
| 13436025 |  | Reinstall Warm Girder SL22 | 6d | 2011-06-01 | 2011-06-08 | 131501000 FS+1d, 13435015 | 60d |
| 13436030 |  | Remove Warm Girder SL23 | 6d | 2011-06-09 | 2011-06-16 | 13436025 | 60d |
| 13436035 |  | Reinstall Warm Girder SL23 | 6d | 2011-07-28 | 2011-08-04 | 131502000 | 37d |
| 13436040 |  | SL - remove girders | 10d | 2012-05-21 | 2012-06-05 | 2-02M FS+5d | 38d |
| 13436050 |  | SL - rebuild girders | 1d | 2012-05-22 | 2012-05-22 | 2-02M FS+5d, 13436040 FS-9d | 38d |
| 13436045 |  | NL - remove girders | 19d | 2012-06-06 | 2012-07-02 | 13436040 | 149d |
| 13436055 |  | NL - rebuild girders | 16d | 2012-07-03 | 2012-07-24 | 13436045 | 149d |
| 13436060 |  | SL final alignment | 9d | 2013-04-11 | 2013-04-23 | 13417045 | 58d |
| 13436065 |  | NL final alignment | 9d | 2013-07-16 | 2013-07-26 | 13417070 | 24d |
| 13436070 |  | Re-Baseline Actuals Adjustment | 1d | 2013-08-30 | 2013-08-30 | 9-130M FS+227d | 20d |
|  | 4 | **1.3.4.4 INJECTOR & RE-INJECTION** |  | 2009-01-02 | 2013-09-17 |  |  |
|  | 1 | **1.3.4.4.1 DIPOLES** |  | 2009-07-02 | 2013-08-30 |  |  |
| 13441004 |  | Proc Prep for Chicane Dipoles (INJ/REINJ Dipoles) FY09 | 63d | 2009-07-02 | 2009-09-30 | 9-090M FS+185d | 312d |
| 13441004b |  | Proc Prep for Chicane Dipoles (INJ/REINJ Dipoles) FY10 | 53d | 2009-10-01 | 2009-12-16 | 13441004 | 312d |
| 13441005 |  | Vend Fab New Chicane Dipoles (INJ/REINJ Dipoles) FY10 | 195d | 2009-12-17 | 2010-09-30 | 13441004b, 121441010a | 312d |
| 13441005b |  | Vend Fab New Chicane Dipoles (INJ/REINJ Dipoles) Procurement | 261d | 2009-12-17 | 2011-01-12 | 121441010a, 13441004b | 312d |
| 13441005a |  | Vend Fab New Chicane Dipoles (INJ/REINJ Dipoles) FY11 | 66d | 2010-10-01 | 2011-01-12 | 13441005 | 312d |
| 13441010 |  | Mag Measurement of Chicane Dipoles (INJ/REINJ Dipoles) | 20d | 2011-04-15 | 2011-05-12 | 13441005b, 13441005a, 9-110M FS+130d | 248d |
| 13441015 |  | Re-Baseline Actuals Adjustment | 1d | 2013-08-30 | 2013-08-30 | 9-130M FS+227d | 20d |
|  | 2 | **1.3.4.4.2 QUADRUPOLES** |  |  |  |  |  |
|  | 3 | **1.3.4.4.3 CORRECTORS** |  |  |  |  |  |
|  | 4 | **1.3.4.4.4 STANDS** |  | 2009-01-02 | 2013-08-30 |  |  |
| 13444909LOE |  | FY09 Mngmnt/Planning for Reinjection Modifications (INJ/RE-INJ Stands) | 189d | 2009-01-02 | 2009-09-30 | 13444909LOEXD | 20d |
| 13445005 |  | Proc/Vend Fab New Girder for Chicane (INJ/RE-INJ Girders) | 61d | 2010-08-12 | 2010-11-05 | 9-100M FS+213d | 372d |
| 13444020 |  | Proc Alignment Cartridges (INJ/RE-INJ Stands) | 100d | 2010-12-07 | 2011-05-05 | 121444015, 9-110M FS+45d | 253d |
| 13444025 |  | Procurem/Vend Fab Modifications for Spectrometer (INJ/RE-INJ Stands) | 130d | 2010-12-07 | 2011-06-17 | 9-110M FS+45d, 121444020 | 223d |
| 13444015 |  | Proc Prep New ReInjection Stands (INJ/RE-INJ Stands) | 44d | 2011-06-15 | 2011-08-16 | 9-110M FS+172d, 121444015 | 155d |
| 13444017 |  | Vend Fab New ReInjection Stands (INJ/RE-INJ Stands) | 71d | 2012-01-13 | 2012-04-24 | 13444015, 9-120M FS+66d | 57d |
| 13444018 |  | Receive and Inspect New ReInjection Stands (INJ/RE-INJ Stands) | 10d | 2012-04-11 | 2012-04-24 | 13444017 FS-10d | 57d |
| 13444950 |  | Re-Baseline Actuals Adjustment | 1d | 2013-08-30 | 2013-08-30 | 9-130M FS+227d | 20d |
|  | 5 | **1.3.4.4.5 GIRDERS** |  |  |  |  |  |
|  | 6 | **1.3.4.4.6 VACUUM** |  | 2011-04-08 | 2013-08-30 |  |  |
| 13446010 |  | Proc Prep New Vac Chambers (INJ/RE-INJ Vac) | 44d | 2011-04-08 | 2011-06-09 | 9-110M FS+125d, 121446005, 121446999 | 161d |
| 13446010a |  | Vend Fab New Vac Chambers (INJ/RE-INJ Vac) | 68d | 2011-11-14 | 2012-02-29 | 9-120M FS+30d, 13446010 | 52d |
| 13446010b |  | Receive and Inspect New Vac Chambers (INJ/RE-INJ Vac) | 10d | 2012-02-15 | 2012-02-29 | 13446010a FS-10d | 52d |
| 13446015 |  | Re-Baseline Actuals Adjustment | 1d | 2013-08-30 | 2013-08-30 | 9-130M FS+227d | 20d |
|  | 7 | **1.3.4.4.7 INSTALLATION** |  | 2012-06-05 | 2013-09-17 |  |  |
| 13447005 |  | 45 MeV Dump - Remove | 4d | 2012-06-05 | 2012-06-08 | 13444018, 2-02M FS+14d | 30d |
| 13447015 |  | OL/OR - Remove | 11d | 2012-09-07 | 2012-09-21 | 13417050M | 78d |
| 13447025 |  | OL/OR - Upstairs | 8d | 2012-09-17 | 2012-09-26 | 13447015 FS-5d | 85d |
| 13447020 |  | OL/OR - Install stands FY12 | 5d | 2012-09-24 | 2012-09-28 | 13447015 | 78d |
| 13447020a |  | OL/OR - Install stands FY13 | 5d | 2012-10-01 | 2012-10-05 | 13447020 | 78d |
| 13447030 |  | OL/OR - Install magnets and girders | 21d | 2012-10-08 | 2012-11-05 | 13447025, 13447020a | 78d |
| 13447035 |  | OL/OR - Final align | 10d | 2012-11-06 | 2012-11-19 | 13447030 | 78d |
| 13447010 |  | 45 MeV Dump - Re-install | 6d | 2013-07-25 | 2013-08-01 | 13447005 FS+280d | 30d |
| 13447040 |  | Re-Baseline Actuals Adjustment | 1d | 2013-08-30 | 2013-08-30 | 9-130M FS+227d | 20d |
| 23447010 |  | 45 MeV Dump - Re-install | 11d | 2013-09-03 | 2013-09-17 | 9-130M FS+228d | 3d |
|  | 5 | **1.3.4.5 ARC 10 & HALL D BEAMLINE** |  | 2009-01-02 | 2013-10-23 |  |  |
|  | 1 | **1.3.4.5.1 DIPOLES** |  | 2009-01-02 | 2013-08-30 |  |  |
| 13451055 |  | Prcrmnt Prep of 4m Dipls (ARC10/H-D Dipl) | 7d | 2009-01-02 | 2009-01-12 | 13451055XD | 117d |
| 13451909LOE |  | FY09 Mngmnt & Oversight (ARC10/H-D Dipl) | 189d | 2009-01-02 | 2009-09-30 | 13451909LOEXD | 20d |
| 13451075 |  | Prcrmnt Prep for 2m Pass 6 Dipole (ARC10/H-D Dipl) | 117d | 2009-01-12 | 2009-06-26 | 121451035, 9-090M FS+65d, 121456999 | 270d |
| 13451060M |  | Award Contract for 4m Dipl (ARC10/H-D Dipl) | 0d | 2009-01-12 | 2009-01-12 | 13451055 | 117d |
| 13451065 |  | FY09 LABOR Oversight 4m Dipl Contract (ARC10/H-D Dipl) | 182d | 2009-01-13 | 2009-09-30 | 13451060M | 259d |
| 13451080M |  | Award Contract for 2m Pass 6 Dipole (ARC10/H-D Dipl) | 0d | 2009-06-26 | 2009-06-26 | 13451075 | 270d |
| 13451085 |  | P-1 Vend Fab 2m Pass 6 Dipole (ARC10/H-D Dipl) Labor FY09 | 66d | 2009-06-29 | 2009-09-30 | 13451080M | 270d |
| 13451063a |  | PROC 4m Dpl Cntr PP3a for Coil Material (ARC10/H-D Dipl) | 65d | 2009-06-30 | 2009-09-30 | 13451060M FS+117d | 486d |
| 13451063b |  | PROC 4m Dpl Cntr PP3b for Core Material (ARC10/H-D Dipl) | 44d | 2009-06-30 | 2009-08-31 | 13451060M FS+117d | 507d |
| 13451063c |  | PROC 4m Dipl Cntr PP3c for 1st Article Coil Set (ARC10/H-D Dipl) | 106d | 2009-06-30 | 2009-11-30 | 13451060M FS+117d | 445d |
| 13451063d |  | PROC 4m Dipl Cntr PP3d for 1st Article Core Set (ARC10/H-D Dipl) | 124d | 2009-06-30 | 2009-12-31 | 13451060M FS+117d | 427d |
| 13451063e-1 |  | PROC 4m Dipl Cntr PP3e-1 Deliver 6 Magnets (ARC10/H-D Dipl) | 162d | 2009-06-30 | 2010-02-26 | 13451060M FS+117d | 389d |
| 13451063e-2 |  | PROC 4m Dipl Cntr PP3e-2 Deliver 10 Magnets (ARC10/H-D Dipl) | 207d | 2009-06-30 | 2010-04-30 | 13451060M FS+117d | 344d |
| 13451063e-3 |  | PROC 4m Dipl Cntr PP3e-3 Deliver 10 Magnets (ARC10/H-D Dipl) | 249d | 2009-06-30 | 2010-06-30 | 13451060M FS+117d | 302d |
| 13451063e-4 |  | PROC 4m Dipl Cntr PP3e-4 Deliver 10 Magnets (ARC10/H-D Dipl) | 371d | 2009-06-30 | 2010-12-30 | 13451060M FS+117d | 180d |
| 13451066 |  | FY 10 LABOR Oversight 4m Dipl Contract (ARC10/H-D Dipl) | 227d | 2009-10-01 | 2010-08-31 | 13451065 | 259d |
| 13451085b |  | P-1 Vend Fab 2m Pass 6 Dipole (ARC10/H-D Dipl) Labor FY10 | 182d | 2009-10-01 | 2010-06-28 | 13451085 | 270d |
| 13451910LOE |  | FY10 Mngmnt & Oversight (ARC10/H-D Dipl) | 248d | 2009-10-01 | 2010-09-30 | 13451909LOE, 121451909LOE | 20d |
| 13451068M |  | Deliver 1st Article 4m Dipl (ARC10/H-D Dipl) (IPL 534213030, 534213090 and 534213150) | 0d | 2009-12-31 | 2009-12-31 | 13451063d, 13451063c, 13451063b, 13451063a | 427d |
| 13451086 |  | P-2 Vend Fab 2m Pass 6 Dipole (ARC10/H-D Dipl) Original Labor FY10 | 171d | 2010-01-29 | 2010-09-30 | 13451085b FS-105d | 270d |
| 13451100 |  | Mag Measurement of Arc 10 & H-D Dipl (ARC10/H-D Dipl) (IPL) FY10 | 156d | 2010-02-22 | 2010-09-30 | 121421022, 13451090M FS-404d, 13451070M FS-295d | 99d |

| ID | WBS | Task | Duration | Start | Finish | Predecessors | Total float |
| --- | --- | --- | --- | --- | --- | --- | --- |
| 13451086a |  | P-2 Vend Fab 2m Pass 6 Dipole (ARC10/H-D Dipl) Original Labor FY11 | 77d | 2010-10-01 | 2011-01-28 | 13451086 | 270d |
| 13451100a |  | Mag Measurement of Arc 10 & H-D Dipl (ARC10/H-D Dipl) (IPL) FY11 | 234d | 2010-10-01 | 2011-09-12 | 13451100 | 99d |
| 13451911LOE |  | FY11 Mngmnt & Oversight (ARC10/H-D Dipl) | 248d | 2010-10-01 | 2011-09-30 | 13451910LOE | 20d |
| 13451070M |  | Delivery Complete for all 4m Dipl (ARC10/H-D Dipl) | 0d | 2010-12-30 | 2010-12-30 | 13451063e-4, 13451068M, 13451063e-3, 13451063e-1, 13451063e-2, 13451066 | 180d |
| 13451095 |  | Modify Alignment Fixture for Dipl (ARC10/H-D Dipl) | 66d | 2011-04-01 | 2011-07-05 | 9-110M FS+120d | 212d |
| 13451105 |  | Completion of Mag Measurement of Arc 10 & H-D Dipl (ARC10/H-D Dipl) FY11 | 14d | 2011-09-13 | 2011-09-30 | 13451100a | 99d |
| 13451090M |  | Delivery Complete for 2m Pass 6 Dipole (ARC10/H-D Dipl) | 0d | 2011-09-30 | 2011-09-30 | 13411105v, 13411105x, 13451086a | 99d |
| 13451105a |  | Completion of Mag Measurement of Arc 10 & H-D Dipl (ARC10/H-D Dipl) FY12 | 51d | 2011-10-03 | 2011-12-14 | 13451105 | 99d |
| 13451912LOE |  | FY12 Mngmnt & Oversight (ARC10/H-D Dipl) | 247d | 2011-10-03 | 2012-09-28 | 13451911LOE | 20d |
| 13451950 |  | Re-Baseline Actuals Adjustment | 1d | 2013-08-30 | 2013-08-30 | 9-130M FS+227d | 20d |
|  | 2 | **1.3.4.5.2 QUADRUPOLES** |  | 2009-01-02 | 2013-08-30 |  |  |
| 13452025 |  | Prcrmnt Prep for Quads (ARC 10/H-D Q-POLES) | 32d | 2009-01-02 | 2009-02-18 | 13452025X | 92d |
| 13452035 |  | Vend Fab Quads (ARC 10/H-D Q-POLES) LABOR Initial | 115d | 2009-02-19 | 2009-07-31 | 9-090M FS+91d | 404d |
| 13453010 |  | Prcrmnt Prep for Correctors (ARC10/H-D Correctors) FY09 | 63d | 2009-07-02 | 2009-09-30 | 9-090M FS+185d | 148d |
| 13452030M |  | Award Contract for Quadrupoles (ARC 10/H-D Q-POLES) | 0d | 2009-08-03 | 2009-08-03 | 13452025, 9-090M FS+206d, 1114010 | -23d |
| 13452036 |  | Vend Fab Quads (ARC 10/H-D Q-POLES) LABOR Final FY09 | 42d | 2009-08-03 | 2009-09-30 | 13452035 | 454d |
| 13452037 |  | Vend Fab Quads (ARC 10/H-D Q-POLES) Recieve Materials | 45d | 2009-08-03 | 2009-10-05 | 13452035 | 652d |
| 13452037A |  | Vend Fab Quads (ARC 10/H-D Q-POLES) Lamination Stampings | 1d | 2009-08-03 | 2009-08-03 | 13452035 | 696d |
| 13452037B |  | Vend Fab Quads (ARC 10/H-D Q-POLES) First Article QP | 54d | 2009-08-03 | 2009-10-16 | 13452035 | 404d |
| 13452037C |  | Vend Fab Quads (ARC 10/H-D Q-POLES) Deliver 8 QP Magnets | 101d | 2009-08-03 | 2009-12-31 | 13452035 | 596d |
| 13452037D |  | Vend Fab Quads (ARC 10/H-D Q-POLES) Deliver 8 QP Magnets | 120d | 2009-08-03 | 2010-01-29 | 13452035 | 577d |
| 13452037F |  | Vend Fab Quads (ARC 10/H-D Q-POLES) Deliver 3 QR Magnets | 120d | 2009-08-03 | 2010-01-29 | 13452035 | 577d |
| 13452037G |  | Vend Fab Quads (ARC 10/H-D Q-POLES) Deliver 8 QP Magnets | 139d | 2009-08-03 | 2010-02-26 | 13452035 | 558d |
| 13452037H |  | Vend Fab Quads (ARC 10/H-D Q-POLES) Deliver 3 QR Magnets | 139d | 2009-08-03 | 2010-02-26 | 13452035 | 558d |
| 13452037J |  | Vend Fab Quads (ARC 10/H-D Q-POLES) Deliver 8 QP Magnets | 160d | 2009-08-03 | 2010-03-29 | 13452035 | 537d |
| 13452037K |  | Vend Fab Quads (ARC 10/H-D Q-POLES) Deliver 3 QR Magnets | 160d | 2009-08-03 | 2010-03-29 | 13452035 | 537d |
| 13452037L |  | Vend Fab Quads (ARC 10/H-D Q-POLES) Deliver 8 QP Magnets | 184d | 2009-08-03 | 2010-04-30 | 13452035 | 513d |
| 13452037N |  | Vend Fab Quads (ARC 10/H-D Q-POLES) Deliver 3 QR Magnets | 184d | 2009-08-03 | 2010-04-30 | 13452035 | 513d |
| 13452037P |  | Vend Fab Quads (ARC 10/H-D Q-POLES) Deliver 3 QR Magnets | 204d | 2009-08-03 | 2010-05-28 | 13452035 | 493d |
| 13452037Q |  | Vend Fab Quads (ARC 10/H-D Q-POLES) Deliver 4 QP Magnets | 221d | 2009-08-03 | 2010-06-23 | 13452035 | 476d |
| 13452037R |  | Vend Fab Quads (ARC 10/H-D Q-POLES) Deliver 3 QR Magnets | 221d | 2009-08-03 | 2010-06-23 | 13452035 | 476d |
| 13452037S |  | Vend Fab Quads (ARC 10/H-D Q-POLES) Deliver 2 QR Magnets | 243d | 2009-08-03 | 2010-07-26 | 13452035 | 454d |
| 13452037T |  | Vend Fab Quads (ARC 10/H-D Q-POLES) Deliver 4 QP Magnets | 240d | 2009-08-03 | 2010-07-21 | 13452035 | 457d |
| 13452037o |  | Vend Fab Quads (ARC 10/H-D Q-POLES) Deliver 8 QP Magnets | 204d | 2009-08-03 | 2010-05-28 | 13452035 | 493d |
| 13452036b |  | Vend Fab Quads (ARC 10/H-D Q-POLES) LABOR Final FY10 | 201d | 2009-10-01 | 2010-07-26 | 13452036 | 454d |
| 13453010b |  | Prcrmnt Prep for Correctors (ARC10/H-D Correctors) FY10 | 53d | 2009-10-01 | 2009-12-16 | 13453010 | 148d |
| 13452038M |  | Deliver 1st Article Quadrupoles (ARC 10/H-D Q-POLES) (IPL 534213165) | 0d | 2009-10-16 | 2009-10-16 | 13452037B, 13452030M | 404d |
| 13453015M |  | Award Contract for Correctors (ARC10/H-D CORRECTORS) | 0d | 2009-12-16 | 2009-12-16 | 9-100M, 13453010b | 148d |
| 13453020 |  | Vend Fab Correctors (ARC10/H-D Correctors) Labor FY10 | 195d | 2009-12-17 | 2010-09-30 | 13453015M | 148d |
| 13453020b |  | Vend Fab Correctors (ARC10/H-D Correctors) Procurement | 261d | 2009-12-17 | 2011-01-12 | 13453015M | 148d |
| 13452045 |  | Mag Measurment of New Quads (ARC 10/H-D Q-POLES) Labor FY10 | 117d | 2010-04-16 | 2010-09-30 | 13452040M FS-120d, 13452038M FS+119d | 404d |
| 13452045b |  | Mag Measurment of New Quads (ARC 10/H-D Q-POLES) Procurement | 200d | 2010-04-16 | 2011-02-07 | 13452040M FS-120d, 13452038M FS+119d | 404d |
| 13452050 |  | Completion of Quadrapole Mag Measurement FY10 | 64d | 2010-07-01 | 2010-09-30 | 9-100M FS+184d | 254d |
| 13452040M |  | Delivery Complete for Quadrupoles (ARC 10/H-D Q-POLES) | 0d | 2010-07-26 | 2010-07-26 | 13452037G, 13452037Q, 13452037J, 13452037H, 13452037R, 13452037D, 13452037N, 13452037S, 13452037C, 13452037o, 13452037L, 13452038M, 13452037A, 13452037F, 13452037B, 13452037, 13452037K, 13452037T, 13452036b, 13452037P | 454d |
| 13452045a |  | Mag Measurment of New Quads (ARC 10/H-D Q-POLES) Labor FY11 | 83d | 2010-10-01 | 2011-02-07 | 13452045 | 404d |
| 13452050a |  | Completion of Quadrapole Mag Measurement FY11 | 83d | 2010-10-01 | 2011-02-07 | 9-100M FS+184d, 13452050 | 254d |
| 13453020a |  | Vend Fab Correctors (ARC10/H-D Correctors) Labor FY11 | 66d | 2010-10-01 | 2011-01-12 | 13453020 | 148d |
| 13453025 |  | Delivery Complete for Correctors (ARC10/H-D CORRECTORS) | 0d | 2011-01-12 | 2011-01-12 | 13453020a, 13453020b | 148d |
| 13453030 |  | Mag Measurment of Correctors (ARC10/H-D Correctors) | 123d | 2011-01-13 | 2011-07-08 | 13453015M FS+159d, 13453025 | 148d |
| 13452055 |  | Re-Baseline Actuals Adjustment | 1d | 2013-08-30 | 2013-08-30 | 9-130M FS+227d | 20d |
|  | 3 | **1.3.4.5.3 CORRECTORS** |  |  |  |  |  |
|  | 4 | **1.3.4.5.4 STANDS** |  | 2010-01-05 | 2013-10-23 |  |  |
| 13455015 |  | Proc/Vend Fab Arc 10 Griders (ARC 10/H-D Girders) (Original) | 37d | 2010-01-05 | 2010-02-26 | 121456999, 9-100M FS+60d, 121455015M | 200d |
| 13455020 |  | Proc/Vend Fab H-D Girders (ARC 10/H-D Girders) (Original) | 37d | 2010-01-05 | 2010-02-26 | 121456999, 121455015M, 9-100M FS+60d | 200d |
| 13454020M |  | Award Arc 10 Stands | 0d | 2010-03-15 | 2010-03-15 | 13454015 FS-191d | 716d |
| 13454022LOE |  | Vend Fab Arc 10 Stands Oversight | 75d | 2010-03-15 | 2010-06-28 | 13454020M | 716d |
| 13454025 |  | Vend Fab Arc 10 Stands Phase 1 | 51d | 2010-03-15 | 2010-05-24 | 13454020M | 716d |
| 13454025A |  | Vend Fab Arc 10 Stands Phase 2 | 64d | 2010-03-15 | 2010-06-11 | 13454025 FS-51d | 716d |
| 13454025B |  | Vend Fab Arc 10 Stands Phase 3 | 75d | 2010-03-15 | 2010-06-28 | 13454025A FS-64d | 716d |
| 13454031 |  | Prcrmnt Prep for Hall D Girder Floor Plates | 20d | 2010-04-01 | 2010-04-28 | 9-100M FS+120d | 869d |
| 13455010 |  | Proc Prep For Arc 10 Girders | 73d | 2010-04-05 | 2010-07-16 | 9-100M FS+122d | 12d |
| 13454032 |  | Vend fab Hall D Girder Floor Plates | 39d | 2010-04-29 | 2010-06-23 | 13454031 | 869d |
| 13454026 |  | Receive and Inspect Arc 10 Stands | 24d | 2010-05-25 | 2010-06-28 | 13454025, 13454025B FS-24d | 716d |
| 13455075 |  | Prcrmnt Prep for Hall D Stands Phase 1 | 22d | 2010-06-01 | 2010-06-30 | 9-100M FS+162d | 624d |
| 13455115 |  | Proc Prep Arc 10 Floor to Ceiling Stands | 56d | 2010-06-04 | 2010-08-23 | 9-100M FS+165d | 551d |
| 13454030M |  | Delivery Complete for Arc 10 Stands | 0d | 2010-06-28 | 2010-06-28 | 13454026 | 716d |
| 13455023 |  | Vend Fab Arc 10 Girders Oversight FY10 | 53d | 2010-07-19 | 2010-09-30 | 13455010 | 13d |
| 13455025 |  | Vend Fab Arc 10 Girders Phase 1 | 69d | 2010-07-19 | 2010-10-22 | 13455010 | 12d |
| 13455028 |  | Vend Fab Arc 10 Girders Phase 2 | 100d | 2010-07-19 | 2010-12-08 | 13455025 FS-69d | 12d |
| 13454042 |  | Prcrmnt Prep for Alignment Cartridges (ARC10/H-D Stands) FY10 | 43d | 2010-08-02 | 2010-09-30 | 9-100M FS+205d | 272d |

| ID | WBS | Task | Duration | Start | Finish | Predecessors | Total float |
| --- | --- | --- | --- | --- | --- | --- | --- |
| 13455130 |  | Proc Prep Tagger Dump Enclosure | 39d | 2010-08-02 | 2010-09-24 | 9-100M FS+205d | 1286d |
| 13455140 |  | Proc Prep Hall D Movaable Shield Wall FY10 | 43d | 2010-08-02 | 2010-09-30 | 9-100M FS+205d | 1179d |
| 13455035 |  | Vend Fab Hall D Floor Girders | 77d | 2010-08-09 | 2010-11-24 | 9-100M FS+210d | 10d |
| 13455135 |  | Vend Fab Tagger Dump Enclosure | 39d | 2010-08-20 | 2010-10-14 | 13455130 FS-25d | 1286d |
| 13454015 |  | Prcrmnt Prep for Arc 10 Stands | 50d | 2010-10-01 | 2010-12-13 | 121456999, 9-110M, 121454015a | 716d |
| 13454035 |  | Proc Misc Brackets & Hardware (ARC10/H-D Stands) | 130d | 2010-10-01 | 2011-04-14 | 121456999, 9-110M | 520d |
| 13454042a |  | Prcrmnt Prep for Alignment Cartridges (ARC10/H-D Stands) FY11 | 36d | 2010-10-01 | 2010-11-19 | 13454042 | 272d |
| 13455023a |  | Vend Fab Arc 10 Girders Oversight FY11 | 36d | 2010-10-01 | 2010-11-19 | 13455023 | 13d |
| 13455140a |  | Proc Prep Hall D Movaable Shield Wall FY11 | 7d | 2010-10-01 | 2010-10-11 | 13455140 | 1179d |
| 13455145 |  | Vend Fab Hall D Movaable Shield Wall | 110d | 2010-10-12 | 2011-03-28 | 13455140a | 1179d |
| 13455030 |  | Receive and Inspect Arc 10 Girders | 20d | 2010-11-09 | 2010-12-08 | 13455025, 13455028 FS-20d | 12d |
| 13455120 |  | Vend Fab Arc 10 Floor to Ceiling Stands | 67d | 2010-11-17 | 2011-03-03 | 13455115 FS+60d | 551d |
| 13454045 |  | Vend Fab Alignment Cartridges (ARC10/H-D Stands) | 90d | 2010-11-22 | 2011-04-08 | 13454042a | 272d |
| 13455040 |  | Proc Prep For Hall D Girders | 82d | 2010-12-03 | 2011-04-07 | 9-110M FS+43d | 109d |
| 13454036 |  | Prcrmnt Prep for Insertable Dumps (ARC10/H-D Stands) | 42d | 2011-01-05 | 2011-03-07 | 9-110M FS+60d | 229d |
| 13455125 |  | Receive and Inspect Arc 10 Floor to Ceiling Stands | 10d | 2011-02-17 | 2011-03-03 | 13455120 FS-10d | 551d |
| 13454047 |  | Receive and Inspect Alignment Cartridges (ARC10/H-D Stands) | 10d | 2011-03-28 | 2011-04-08 | 13454045 FS-10d | 272d |
| 13455045 |  | Vend Fab Hall D Girders Oversight | 103d | 2011-04-08 | 2011-09-01 | 13455040 | 109d |
| 13455050 |  | Vend Fab Hall D Girders Part 1 | 78d | 2011-04-08 | 2011-07-28 | 13455040 | 109d |
| 13455055 |  | Vend Fab Hall D Girders Part 2 | 103d | 2011-04-08 | 2011-09-01 | 13455050 FS-78d | 109d |
| 13454050 |  | 100 kW dump Modifications (ARC10/H-D Stands) Original | 37d | 2011-06-08 | 2011-07-29 | 13458030 FS-18d | 549d |
| 13455080 |  | Prcrmnt Prep for Hall D Stands Phase 2 | 80d | 2011-06-09 | 2011-09-30 | 9-120M FS-80d, 13455075 | 392d |
| 13455060 |  | Receive and Inspect Hall D Girders | 25d | 2011-07-29 | 2011-09-01 | 13455055 FS-25d, 13455050 | 109d |
| 13454055 |  | 100 kW dump Modifications (ARC10/H-D Stands) Revised | 76d | 2011-11-02 | 2012-02-29 | 9-120M FS+22d | 407d |
| 13454040 |  | Vend Fab Insertable Dumps (ARC10/H-D Stands) | 117d | 2012-01-13 | 2012-06-29 | 9-120M FS+66d, 13454036 | 17d |
| 13455080M |  | Award Hall D Stands | 0d | 2012-01-17 | 2012-01-17 | 13455080, 9-120M FS+68d | 324d |
| 13455085LOE |  | Vend Fab Hall D Stands Oversight | 73d | 2012-01-18 | 2012-04-30 | 13455080M | 411d |
| 13455105 |  | Receive and Inspect Hall DStands | 39d | 2012-03-07 | 2012-04-30 | 13455090 FS-126d | 416d |
| 13455090 |  | Vend Fab Hall D Stands | 60d | 2012-06-11 | 2012-08-31 | 13455080M FS+100d | 324d |
| 13455110M |  | Delivery Complete for Hall D Stands | 0d | 2012-08-31 | 2012-08-31 | 13455105 FS-5d, 13455090 | 324d |
| 13454060 |  | Re-Baseline Actuals Adjustment | 1d | 2013-08-30 | 2013-08-30 | 9-130M FS+227d | 20d |
| 23454055 |  | 100 kW dump Modifications (ARC10/H-D Stands) Procurement | 37d | 2013-09-03 | 2013-10-23 | 9-130M FS+228d | 13d |
| 23454055a |  | 100 kW dump Modifications (ARC10/H-D Stands) Labor/Expenses FY13 | 20d | 2013-09-03 | 2013-09-30 | 9-130M FS+228d | 13d |
| 23454055b |  | 100 kW dump Modifications (ARC10/H-D Stands) Labor/Expenses FY14 | 17d | 2013-10-01 | 2013-10-23 | 23454055a, 9-130M FS+228d | 13d |
|  | 5 | **1.3.4.5.5 GIRDERS** |  |  |  |  |  |
|  | 6 | **1.3.4.5.6 VACUUM** |  | 2010-04-14 | 2013-08-30 |  |  |
| 13456032 |  | Prcrmnt Prep of Ion Pumps & Vac Valves (ARC 10/H-D Vac) | 44d | 2010-04-14 | 2010-06-15 | 9-100M FS+129d | 254d |
| 13456037 |  | Prcrmnt Prep of Bellows & Drift tubes (ARC 10/H-D Vac) | 58d | 2010-05-11 | 2010-08-02 | 9-100M FS+148d | 9d |
| 13456020M |  | Award Contract for Dipole Chambers (ARC 10/H-D VACUUM) | 0d | 2010-07-30 | 2010-07-30 | 13456015 FS-94d | 232d |
| 13456022LOE |  | Vend Fab Dipole Chambers (ARC 10/H-D Vac) Oversight FY10 | 44d | 2010-07-30 | 2010-09-30 | 13456020M | 292d |
| 13456025 |  | Vend Fab Dipole Chambers (ARC 10/H-D Vac) Phase 1 | 80d | 2010-07-30 | 2010-11-19 | 13456020M | 232d |
| 13456027 |  | Vend Fab Dipole Chambers (ARC 10/H-D Vac) Phase 2 | 112d | 2010-07-30 | 2011-01-14 | 13456025 FS-80d | 292d |
| 13456028 |  | Vend Fab Dipole Chambers (ARC 10/H-D Vac) Phase 3 | 150d | 2010-07-30 | 2011-03-11 | 13456027 FS-112d | 292d |
| 13456035 |  | Prcrmnt of Ion Pumps & Vac Valves (ARC 10/H-D Vac) | 98d | 2010-09-10 | 2011-02-07 | 13456032 FS+60d | 254d |
| 13456040 |  | Prcrmnt of Bellows & Drift tubes (ARC 10/H-D Vac) | 92d | 2010-09-29 | 2011-02-16 | 13456037 FS+40d | 9d |
| 13456015 |  | Prcrmnt Prep for Dipole Chambers (ARC 10/H-D Vac) | 50d | 2010-10-01 | 2010-12-13 | 121456999, 9-110M, 121456015 | 232d |
| 13456022LOEa |  | Vend Fab Dipole Chambers (ARC 10/H-D Vac) Oversight FY11 | 106d | 2010-10-01 | 2011-03-11 | 13456022LOE | 292d |
| 13456030M |  | Delivery Complete for Dipole Chambers (ARC 10/H-D VACUUM) | 0d | 2010-11-19 | 2010-11-19 | 13456025 | 232d |
| 13456029 |  | Receive and Inspect Dipole Chambers (ARC 10/H-D Vac) | 70d | 2010-11-22 | 2011-03-11 | 13456025, 13456028 FS-70d | 292d |
| 13456045 |  | Assemble Quad Girders for Arc10 & Hall D on Floor (ARC 10/H-D Vac) | 101d | 2010-11-30 | 2011-04-29 | 13455030 FS-10d, 13455023a, 13455035, 13456040 FS-50d, 13455015, 13455020 | 9d |
| 13456047 |  | Assemble Quad Girders for Arc10 & Hall D (ARC 10/H-D Vac) | 101d | 2011-10-06 | 2012-03-08 | 9-120M FS+3d, 13455010, 13456035, 13456040 FS-50d, 13452045b FS-150d, 13452050, 13455020, 13453030, 13455015, 13452045a FS-150d, 13455060, 13455045, 13455030, 13452050a, 13455023a | 86d |
| 13456042 |  | Prcrmnt of Hall D Drift tubes (ARC 10/H-D Vac) | 52d | 2012-02-16 | 2012-04-30 | 9-120M FS+89d | 9d |
| 13456050 |  | Re-Baseline Actuals Adjustment | 1d | 2013-08-30 | 2013-08-30 | 9-130M FS+227d | 20d |
|  | 7 | **1.3.4.5.7 LCW & INSTRUMENT AIR** |  |  |  |  |  |
|  | 8 | **1.3.4.5.8 INSTALLATION** |  | 2011-05-13 | 2013-10-23 |  |  |
| 13458030 |  | Remove North Stub dump & Steel (ARC 10/H-D Installtn) | 35d | 2011-05-13 | 2011-07-01 | 4A-01M | 549d |
| 13458012 |  | Install Stands in Arc 10 Phase 2 | 64d | 2011-05-17 | 2011-08-16 | 13454030M, 13454035, 4A-01M FS+2d, 13455125 | 499d |
| 13458010 |  | Install Stands in Arc 10 Phase 1 | 65d | 2011-06-27 | 2011-09-27 | 13454030M, 13454035, 13454022LOE, 4A-01M FS+30d, 9-110M | 470d |
| 13458040 |  | Arc 10 Installation Completion | 90d | 2012-10-01 | 2013-02-14 | 9-130M | 130d |
| 13458050 |  | Hall D - Green door install | 25d | 2012-10-01 | 2012-11-02 | 9-130M | 353d |
| 13458055 |  | Hall D - Install Stands | 22d | 2013-01-30 | 2013-03-01 | 13454032, 13455110M, 3A-12M, 9-130M FS+78d, 13455085LOE | 227d |
| 13458060 |  | Hall D - Install magnets and girders | 46d | 2013-03-04 | 2013-05-06 | 13458055 | 227d |
| 13458045 |  | Hall D - Tagger dump installation | 32d | 2013-04-04 | 2013-05-17 | 2-16M, 16331032, 16331030, 9-130M FS+123d, 2-17M | 82d |
| 13458065 |  | Hall D - Final align | 5d | 2013-05-07 | 2013-05-13 | 13458060 | 227d |
| 13458070 |  | Re-Baseline Actuals Adjustment | 1d | 2013-08-30 | 2013-08-30 | 9-130M FS+227d | 20d |
| 23458040 |  | Arc 10 Installation Completion FY13 | 20d | 2013-09-03 | 2013-09-30 | 9-130M FS+228d | 31d |
| 23458060 |  | Hall D - Install magnets and girders FY13 | 20d | 2013-09-03 | 2013-09-30 | 9-130M FS+228d | 35d |
| 23458045 |  | Hall D - Tagger dump installation FY13 | 4d | 2013-09-25 | 2013-09-30 | 9-130M FS+244d | 90d |
| 23458065 |  | Hall D - Final align FY13 | 4d | 2013-09-25 | 2013-09-30 | 23458060a FS-7d, 23458060 FS-7d | 35d |
| 23458040a |  | Arc 10 Installation Completion FY14 | 10d | 2013-10-01 | 2013-10-14 | 9-130M FS+228d, 23458040 | 31d |

| ID | WBS | Task | Duration | Start | Finish | Predecessors | Total float |
| --- | --- | --- | --- | --- | --- | --- | --- |
| 23458045a |  | Hall D - Tagger dump installation FY14 | 17d | 2013-10-01 | 2013-10-23 | 9-130M FS+244d, 23458045 | 90d |
| 23458060a |  | Hall D - Install magnets and girders FY14 | 3d | 2013-10-01 | 2013-10-03 | 23458060, 9-130M FS+228d | 35d |
| 23458065a |  | Hall D - Final align FY14 | 1d | 2013-10-01 | 2013-10-01 | 23458060a FS-7d, 23458065, 23458060 FS-7d | 35d |
|  | 6 | **1.3.4.6 EXTRACTION** |  | 2011-04-01 | 2013-10-09 |  |  |
|  | 1 | **1.3.4.6.1 LAMBERTSON** |  | 2011-04-01 | 2013-08-30 |  |  |
| 13461050LOE |  | FY11 Engrng Oversight (LAMBERTSON) | 128d | 2011-04-01 | 2011-09-30 | 9-110M FS+120d | 20d |
| 13461015 |  | Machine Lambertson Mag Iron MATL (LAMBERTSON) | 56d | 2011-10-03 | 2011-12-21 | 13461010 FS-70d | 451d |
| 13461000 |  | Proc Coil Packs for Lambertson LABOR (LAMBERTSON) | 64d | 2012-01-05 | 2012-04-05 | 12154020M, 9-120M FS+60d | 383d |
| 13461005 |  | Proc Coil Packs for Lambertson MATL (LAMBERTSON) | 64d | 2012-01-05 | 2012-04-05 | 13461000 FS-64d | 383d |
| 13461010 |  | Machine Lambertson Mag Iron LABOR (LAMBERTSON) | 10d | 2012-01-05 | 2012-01-19 | 9-120M FS+60d | 451d |
| 13461025 |  | Install Lambertson Coil pack (LAMBERTSON) | 5d | 2012-11-08 | 2012-11-14 | 13461005, 2-02M FS+125d, 13461015 | 232d |
| 13461020 |  | Lambertson Mag measurements (LAMBERTSON) | 5d | 2012-11-15 | 2012-11-21 | 9-130M FS+30d, 13461025 | 232d |
| 13461035 |  | Install New Lambertson MATL (LAMBERTSON) | 5d | 2012-11-26 | 2012-11-30 | 13461025, 13461020 | 232d |
| 13461040 |  | Test New Lambertson (LAMBERTSON) | 5d | 2012-12-03 | 2012-12-07 | 13461035 | 232d |
| 13461045M |  | Ready for Beam Commssng (LAMBERTSON) | 0d | 2012-12-07 | 2012-12-07 | 13461040 | 232d |
| 13461055 |  | Re-Baseline Actuals Adjustment | 1d | 2013-08-30 | 2013-08-30 | 9-130M FS+227d | 20d |
|  | 2 | **1.3.4.6.2 CHICANE** |  | 2011-04-01 | 2013-08-30 |  |  |
| 13462000 |  | Fab Dipole Magnets (CHICANE) Original Labor FY11 | 128d | 2011-04-01 | 2011-09-30 | 1355040a | 233d |
| 13462015LOE |  | FY11 Mech Eng/Dsgner Oversight (CHICANE) | 128d | 2011-04-01 | 2011-09-30 | 9-110M FS+120d | 20d |
| 13462000a |  | Fab Dipole Magnets (CHICANE) Original Labor FY12 | 84d | 2011-10-03 | 2012-02-08 | 13462000 | 233d |
| 13462005 |  | Measure Dipole Magnets (CHICANE) (IPL 534213060 and 534213120) | 65d | 2012-02-09 | 2012-05-10 | 13411105u, 13411105t, 13462000a | 233d |
| 13462010M |  | Extraction Dipoles Ready for Installtn (CHICANE) | 0d | 2012-05-10 | 2012-05-10 | 13462005 | 233d |
| 13462020 |  | Re-Baseline Actuals Adjustment | 1d | 2013-08-30 | 2013-08-30 | 9-130M FS+227d | 20d |
|  | 3 | **1.3.4.6.3 STANDS** |  | 2012-01-03 | 2013-10-09 |  |  |
| 13463005 |  | Fab Stands LABOR (Stands) | 86d | 2012-01-03 | 2012-05-03 | 13463000 FS-86d | 173d |
| 13463010 |  | Fab Stands MATL (Stands) Frozen Per CR12-039 | 83d | 2012-01-03 | 2012-04-30 | 13463005 FS-86d | 176d |
| 13463045LOE |  | FY12 Mech Eng/Dsgner Oversight (Stands) | 187d | 2012-01-05 | 2012-09-28 | 9-120M FS+60d | 20d |
| 13463000 |  | Insp Matls (Stands) | 15d | 2012-04-13 | 2012-05-03 | 1356020, 9-120M FS+129d, 1356018 | 173d |
| 13463012 |  | Reverse Entry Per CR12-039 | 3d | 2012-05-01 | 2012-05-03 | 9-120M FS+141d | 103d |
| 13463013 |  | Fab Stands MATL (Stands) Revised Per CR12-039 | 3d | 2012-05-01 | 2012-05-03 | 13463005 FS-3d | 173d |
| 13463015 |  | Extraction - Remove | 32d | 2012-08-15 | 2012-09-28 | 2-02M FS+65d, 13463010, 13463013 | 102d |
| 13463035 |  | Extraction - Upstairs FY12 | 20d | 2012-08-31 | 2012-09-28 | 13463015 FS-20d | 140d |
| 13463035a |  | Extraction - Upstairs FY13 | 17d | 2012-10-01 | 2012-10-23 | 13463035 | 140d |
| 13463020 |  | Install Stands MATL (Stands) | 22d | 2012-11-15 | 2012-12-18 | 13463015 FS+33d | 102d |
| 13463025 |  | Extraction - Install stands | 22d | 2012-11-15 | 2012-12-18 | 13463020 FS-22d, 1355025M, 13463015, 13462010M | 102d |
| 13463030 |  | Install Septa & Dipoles MATL (Stands) | 43d | 2012-12-19 | 2013-02-27 | 13463025 | 102d |
| 13463045 |  | Extraction - Install magnets and girders | 43d | 2012-12-19 | 2013-02-27 | 13463020, 13463035a, 13463025 | 102d |
| 13463050 |  | Extraction - Final align | 6d | 2013-06-19 | 2013-06-26 | 13463030, 13417120, 13463045 | 24d |
| 13463055 |  | Re-Baseline Actuals Adjustment | 1d | 2013-08-30 | 2013-08-30 | 9-130M FS+227d | 20d |
| 23463035a |  | Extraction - Upstairs | 6d | 2013-09-03 | 2013-09-10 | 9-130M FS+228d | 44d |
| 23463045 |  | Extraction - Install magnets and girders | 15d | 2013-09-03 | 2013-09-23 | 9-130M FS+228d, 23463035a FS-48d | 2d |
| 23463050 |  | Extraction - Final align FY13 | 5d | 2013-09-24 | 2013-09-30 | 23463045, 23417120 FS-23d | 2d |
| 23463050a |  | Extraction - Final align FY14 | 7d | 2013-10-01 | 2013-10-09 | 23463050, 23417120 FS-23d, 23463045 | 2d |
|  | 4 | **1.3.4.6.4 NOT USED** |  |  |  |  |  |
|  | 5 | **1.3.4.6.5 NOT USED** |  |  |  |  |  |
|  | 6 | **1.3.4.6.6 NOT USED** |  |  |  |  |  |
|  | 7 | **1.3.4.6.7 NOT USED** |  |  |  |  |  |
|  | 5 | **1.3.5 EXTRACTION** |  | 2009-01-02 | 2013-08-30 |  |  |
|  | 1 | **1.3.5.1 CAVITIES** |  | 2009-01-02 | 2013-08-30 |  |  |
| 1351909LOE |  | FY09 Mngmnt Oversight (Cavities) | 189d | 2009-01-02 | 2009-09-30 | 1351909LOEX | 20d |
| 1351910LOE |  | FY10 Mngmnt Oversight (Cavities) | 248d | 2009-10-01 | 2010-09-30 | 1351909LOE | 20d |
| 1351018 |  | Fab fixturing Assys for Fab (Cavities) | 15d | 2010-10-01 | 2010-10-21 | 9-110M | 588d |
| 1351911LOE |  | FY11 Mngmnt Oversight (Cavities) | 248d | 2010-10-01 | 2011-09-30 | 1351910LOE | 20d |
| 1351016 |  | Proc Separator Cavity Matls & subassemblies LABOR (Cavities) | 59d | 2011-12-01 | 2012-03-02 | 9-120M FS+41d, 12151020M | 230d |
| 1351016a |  | Proc Separator Cavity Matls & subassemblies MATERIALS (Cavities) | 59d | 2011-12-01 | 2012-03-02 | 1351016 FS-59d | 230d |
| 1351040 |  | Assy of Separator Cavities (Cavities) | 50d | 2012-04-09 | 2012-06-19 | 1351018, 1351016a FS+25d | 230d |
| 1351055 |  | Test Separator Cavities | 45d | 2012-06-20 | 2012-08-21 | 1351040 | 230d |
| 1351065 |  | Installtn of Separator Cavities (Cavities) FY12 | 17d | 2012-09-06 | 2012-09-28 | 2-02M, 1351055 FS+10d | 230d |
| 1351065a |  | Installtn of Separator Cavities (Cavities) FY13 | 8d | 2012-10-01 | 2012-10-10 | 1351065 | 230d |
| 1351080 |  | RF Characterization of Installed Separator Cavities (Cavities) | 10d | 2012-10-11 | 2012-10-24 | 1351065a | 230d |
| 1351950 |  | Re-Baseline Actuals Adjustment | 1d | 2013-08-30 | 2013-08-30 | 9-130M FS+227d | 20d |
|  | 2 | **1.3.5.2 RF COMPONENTS** |  | 2012-01-05 | 2013-08-30 |  |  |
| 1352005 |  | Proc RF Components LABOR (RF Compnts) | 82d | 2012-01-05 | 2012-05-01 | 12156045, 9-120M FS+60d, 12152030M | 278d |
| 1352005a |  | Proc RF Components MATERIAL (RF Compnts) | 82d | 2012-01-05 | 2012-05-01 | 1352005 FS-82d | 278d |
| 1352020 |  | Install RF Components (RF Compnts) | 46d | 2012-05-14 | 2012-07-18 | 1352005a, 2-02M | 270d |
| 1352035 |  | Characterize Sys losses (RF Compnts) | 39d | 2012-07-19 | 2012-09-12 | 1352020 | 270d |
| 1352040 |  | Re-Baseline Actuals Adjustment | 1d | 2013-08-30 | 2013-08-30 | 9-130M FS+227d | 20d |
|  | 3 | **1.3.5.3 RESONANCE CONTROL** |  | 2012-01-05 | 2013-08-30 |  |  |
| 1353005 |  | Procure Resonance Control LABOR (RESONANCE Control) | 61d | 2012-01-05 | 2012-04-02 | 9-120M FS+60d, 12153025M | 345d |
| 1353005a |  | Procure Resonance Control MATERIAL (RESONANCE Control) | 61d | 2012-01-05 | 2012-04-02 | 1353005 FS-61d | 345d |

| ID | WBS | Task | Duration | Start | Finish | Predecessors | Total float |
| --- | --- | --- | --- | --- | --- | --- | --- |
| 1353085 |  | Move 5th pass Controls/Rack (RESONANCE Control) | 30d | 2012-01-19 | 2012-03-01 | 4A-01M, 9-120M FS+69d | 396d |
| 1353020 |  | Assemble Heater Units (RESONANCE Control) | 29d | 2012-04-03 | 2012-05-11 | 1353005a | 345d |
| 1353040 |  | Modify Control Chassis (RESONANCE Control) | 29d | 2012-04-03 | 2012-05-11 | 1353005a | 345d |
| 1353070 |  | Install Control Valves (RESONANCE Control) | 21d | 2012-04-03 | 2012-05-01 | 1353005a | 353d |
| 1353095 |  | Sys Testing (RESONANCE Control) | 10d | 2012-10-25 | 2012-11-07 | 1353020, 1353040, 1353070, 1351080, 1353085 | 230d |
| 1353100 |  | Re-Baseline Actuals Adjustment | 1d | 2013-08-30 | 2013-08-30 | 9-130M FS+227d | 20d |
|  | 4 | **1.3.5.4 LAMBERTSON** |  | 2009-01-02 | 2013-08-30 |  |  |
| 1354909LOE |  | FY09 Engrng Oversight (LAMBERTSON) | 189d | 2009-01-02 | 2009-09-30 | 1354909LOEX | 148d |
| 1354910LOE |  | FY10 Engrng Oversight (LAMBERTSON) | 248d | 2009-10-01 | 2010-09-30 | 1354909LOE | 148d |
| 1354911LOE |  | FY11 Engrng Oversight (LAMBERTSON) | 120d | 2010-10-01 | 2011-03-31 | 1354910LOE | 148d |
| 1354950 |  | Re-Baseline Actuals Adjustment | 1d | 2013-08-30 | 2013-08-30 | 9-130M FS+227d | 20d |
|  | 5 | **1.3.5.5 CHICANE** |  | 2009-10-01 | 2013-08-30 |  |  |
| 1355910LOE |  | FY10 Mech Eng/Dsgner Oversight (CHICANE) | 248d | 2009-10-01 | 2010-09-30 | 1354909LOE | 148d |
| 1355016 |  | Proc Septa Mag Iron & Coil Packs (CHICANE) | 65d | 2010-01-05 | 2010-04-07 | 12155050M, 9-100M FS+60d, 12156045 | 743d |
| 1355030 |  | Proc Dipole Mag Iron & Coil Packs (CHICANE) | 65d | 2010-01-05 | 2010-04-07 | 12155050M, 9-100M FS+60d, 12156045 | 233d |
| 1355018 |  | Insp Septa Matls (CHICANE) | 10d | 2010-04-08 | 2010-04-21 | 1355016, 13411087 | 743d |
| 1355035 |  | Insp Dipole Matls (CHICANE) | 10d | 2010-04-08 | 2010-04-21 | 1355030 | 233d |
| 1355040 |  | Fab Dipole Magnets (CHICANE) Original Labor FY10 | 113d | 2010-04-22 | 2010-09-30 | 1355035 | 233d |
| 1355040a |  | Fab Dipole Magnets (CHICANE) Original Labor FY11 | 120d | 2010-10-01 | 2011-03-31 | 1355040 | 233d |
| 1355911LOE |  | FY11 Mech Eng/Dsgner Oversight (CHICANE) | 120d | 2010-10-01 | 2011-03-31 | 1355910LOE | 148d |
| 1355022 |  | Measure Septa Magnets (CHICANE) | 65d | 2011-12-01 | 2012-03-12 | 13411087D10 | 276d |
| 1355025M |  | Extraction Septas Ready for Installtn (CHICANE) | 0d | 2012-03-12 | 2012-03-12 | 1355018, 1355022 | 276d |
| 1355950 |  | Re-Baseline Actuals Adjustment | 1d | 2013-08-30 | 2013-08-30 | 9-130M FS+227d | 20d |
|  | 6 | **1.3.5.6 STANDS** |  | 2009-10-01 | 2013-08-30 |  |  |
| 1356910LOE |  | FY10 Mech Eng/Dsgner Oversight (Stands) | 248d | 2009-10-01 | 2010-09-30 | 1354909LOE | 148d |
| 1356911LOE |  | FY11 Mech Eng/Dsgner Oversight (Stands) | 120d | 2010-10-01 | 2011-03-31 | 1356910LOE | 148d |
| 1356018 |  | Proc Stands Matls (Stands) | 64d | 2010-12-07 | 2011-03-16 | 12156040M, 9-110M FS+45d, 12156045, 12156002 | 430d |
| 1356020 |  | Insp Matls (Stands) | 11d | 2011-03-17 | 2011-03-31 | 1356018 | 430d |
| 1356950 |  | Re-Baseline Actuals Adjustment | 1d | 2013-08-30 | 2013-08-30 | 9-130M FS+227d | 20d |
|  | 6 | **1.3.6 INSTRUMENTATION/CONTROLS/SAFETY SYS** |  | 2009-01-02 | 2014-10-31 |  |  |
|  | 1 | **1.3.6.1 BEAM DIAGNOSTICS** |  | 2009-01-02 | 2014-10-31 |  |  |
|  | 1 | **1.3.6.1.1 BPM'S** |  | 2009-01-02 | 2014-10-31 |  |  |
| 13611909LOE |  | FY09 Mngmnt Effort for BPMs | 189d | 2009-01-02 | 2009-09-30 | 13611909LOEX | 20d |
| 13611910LOE |  | FY10 Mngmnt Effort for BPMs | 248d | 2009-10-01 | 2010-09-30 | 13611909LOE | 20d |
| 13611911LOE |  | FY11 Mngmnt Effort for BPMs | 248d | 2010-10-01 | 2011-09-30 | 13611910LOE | 20d |
| 13611014 |  | Labor - SEE BPMs CANS Accelerator | 40d | 2010-11-05 | 2011-01-11 | 9-110M FS+25d, 121611055M | 557d |
| 13611014A |  | Prcrmnt - SEE BPMs CANS Accelerator | 121d | 2010-12-01 | 2011-05-31 | 9-110M FS+41d, 13611014 FS-30d | 551d |
| 13611014Aa |  | Testing - SEE BPM Compnts CANS Accelerator | 66d | 2011-03-01 | 2011-06-01 | 13611014A FS-65d | 551d |
| 13611014Ab |  | Labor - SEE BPMs CANS Hall D | 10d | 2011-05-02 | 2011-05-13 | 9-110M FS+141d | 465d |
| 13611014Ac |  | Prcrmnt - SEE BPMs CANS Hall D | 107d | 2011-05-02 | 2011-09-30 | 13611014Ab FS-10d | 465d |
| 13611014Ad |  | Testing - SEE BPM Compnts CANS Hall D FY11 | 75d | 2011-06-16 | 2011-09-30 | 13611014Ac FS-75d | 465d |
| 13611014Ada |  | Testing - SEE BPM Compnts CANS Hall D FY12 | 1d | 2011-10-03 | 2011-10-03 | 13611014Ad | 465d |
| 13611912LOE |  | FY12 Mngmnt Effort for BPMs | 247d | 2011-10-03 | 2012-09-28 | 13611911LOE | 20d |
| 13611026 |  | Labor - West ARC Completion BPMs | 140d | 2012-01-05 | 2012-07-24 | 9-120M FS+60d | 279d |
| 13611026a |  | Procurement - West ARC Completion BPMs | 5d | 2012-01-05 | 2012-01-11 | 13611026 FS-140d | 404d |
| 13611014Af |  | RF Receiver - First Article Unit SEE BPM | 49d | 2012-02-01 | 2012-04-10 | 9-120M FS+78d | 172d |
| 13611014Ag |  | Digital IF - First Article Unit SEE BPM | 49d | 2012-02-01 | 2012-04-10 | 9-120M FS+78d | 172d |
| 13611065 |  | System Documentation - BPMs First Article | 80d | 2012-02-01 | 2012-05-23 | 13611014Af FS-49d | 322d |
| 13611014Ah |  | RF Receiver Enclosure - First Article Unit SEE BPM | 68d | 2012-04-11 | 2012-07-17 | 13611014Af, 13611014Ag | 172d |
| 13611025b |  | System Installation Software Support First Article - Electronics SEE BPMs | 40d | 2012-06-06 | 2012-07-31 | 13611014Ah FS-30d | 281d |
| 13611026b |  | Hook-up & Check-out Arc 10 BPMs | 15d | 2012-07-11 | 2012-07-31 | 13611026 FS-10d, 13611026a | 279d |
| 13611913LOE |  | FY13 Mngmnt Effort for BPMs | 228d | 2012-10-01 | 2013-08-30 | 13611912LOE | 20d |
| 13611014B |  | Procurement Labor - SEE BPMs ELECTRONICS | 56d | 2013-02-01 | 2013-04-22 | 9-130M FS+80d | 20d |
| 13611014C |  | Prcrmnt - SEE BPMs ELECTRONICS | 117d | 2013-02-01 | 2013-07-18 | 9-130M FS+80d | 27d |
| 13611036 |  | First Article Cavities - nA BPM Sys | 58d | 2013-02-01 | 2013-04-24 | 9-130M FS+80d | 75d |
| 13611038 |  | First Article Unit RF Receiver - nA BPM Sys | 68d | 2013-02-01 | 2013-05-08 | 9-130M FS+80d | 66d |
| 13611038a |  | First Article Unit Digital IF - nA BPM Sys | 48d | 2013-02-01 | 2013-04-10 | 9-130M FS+80d | 86d |
| 13611039 |  | Procurement Labor Electronics - nA BPM Sys | 38d | 2013-02-01 | 2013-03-27 | 9-130M FS+80d | 33d |
| 13611040 |  | Procurements Electronics - nA BPM Sys | 38d | 2013-02-01 | 2013-03-27 | 13611039 FS-38d, 121611055M | 33d |
| 13611065a |  | System Documentation - BPMs | 145d | 2013-02-01 | 2013-08-27 | 9-130M FS+80d | 33d |
| 13611070 |  | First Article Unit - Power Supply SEE BPMs | 54d | 2013-03-04 | 2013-05-16 | 13611014Ah, 9-130M FS+100d | 20d |
| 13611075 |  | Procurement Labor - Power Supply SEE BPMs | 60d | 2013-03-04 | 2013-05-24 | 13611070 FS-54d | 20d |
| 13611080 |  | Procurement - Power Supply SEE BPMs | 60d | 2013-03-04 | 2013-05-24 | 13611075 FS-60d | 20d |
| 13611045 |  | Assembly Electronics Labor - nA BPM Sys | 83d | 2013-03-27 | 2013-07-23 | 13611040 FS-1d | 33d |
| 13611050 |  | Assembly & Testing Procurement - nA BPM Sys | 83d | 2013-03-27 | 2013-07-23 | 13611040 FS-1d, 13611045 FS-83d | 33d |
| 13611015A |  | Labor - Fab & Assy - SEE BPMs ELECTRONICS | 83d | 2013-04-23 | 2013-08-19 | 13611014B, 13611014C FS-68d | 20d |
| 13611015B |  | Procrmnt - Fab/Assy & Testing - SEE BPMs ELECTRONICS | 83d | 2013-04-23 | 2013-08-19 | 13611015A FS-83d, 13611014C FS-68d, 13611014B | 20d |
| 13611037 |  | Procurement Labor Cavities - nA BPM Sys | 20d | 2013-04-25 | 2013-05-22 | 13611036 | 75d |
| 13611037a |  | Procurement Cavities - nA BPM Sys | 20d | 2013-04-25 | 2013-05-22 | 13611037 FS-20d, 13611036 FS-1d | 75d |
| 13611060 |  | Software support - nA BPMs | 80d | 2013-05-06 | 2013-08-27 | 13611055 FS-80d, 13611050 FS-60d | 33d |

| ID | WBS | Task | Duration | Start | Finish | Predecessors | Total float |
| --- | --- | --- | --- | --- | --- | --- | --- |
| 13611038b |  | First Article Enclosure nA Receiver - nA BPM Sys | 19d | 2013-05-09 | 2013-06-05 | 13611038a, 13611038 | 66d |
| 13611085 |  | Assembly Labor - Power Supply SEE BPMs | 68d | 2013-05-28 | 2013-08-30 | 13611080, 13611075 | 20d |
| 13611025 |  | System Installation - Electronics SEE BPMs | 29d | 2013-07-23 | 2013-08-30 | 13611015B FS-20d, 13611014Aa, 1362025 FS-115d, 13611014Ada | 20d |
| 13611055 |  | System Installation Electronics - nA BPM Sytem (BPM) | 25d | 2013-07-24 | 2013-08-27 | 13611038b, 13611065, 13611050, 13611037a, 1362025 | 33d |
| 13611055a |  | System Installation Electronics Contract Labor - nA BPM Sytem (BPM) | 25d | 2013-07-24 | 2013-08-27 | 13611065, 13611038b, 13611055 FS-25d, 13611037a | 33d |
| 13611025c |  | System Installation Software Support - Electronics SEE BPMs | 9d | 2013-08-20 | 2013-08-30 | 13611014Ag, 13611025b, 13611015B | 20d |
| 13611065M |  | nA BPMs Comp | 0d | 2013-08-27 | 2013-08-27 | 13611065a, 13611055a, 13611060 | 33d |
| 13611950 |  | Re-Baseline Actuals Adjustment | 1d | 2013-08-30 | 2013-08-30 | 9-130M FS+227d | 20d |
| 23611014B |  | Procurement Labor - SPM BPMs ELECTRONICS FY13 | 20d | 2013-09-03 | 2013-09-30 | 9-130M FS+228d | 43.5d |
| 23611014D5 |  | Prcrmnt - SPM BPMs ELECTRONICS (Previously Obligated) | 43d | 2013-09-03 | 2013-10-31 | 9-130M FS+228d | 44d |
| 23611026b |  | Hook-up & Check-out Arc 10 BPMs | 20d | 2013-09-03 | 2013-09-30 | 9-130M FS+228d | 4d |
| 23611065a |  | System Documentation - BPMs FY13 | 20d | 2013-09-03 | 2013-09-30 | 9-130M FS+228d | 262d |
| 23611070 |  | First Article Unit - Power Supplies/PC104/Timing Modules SPM BPMs | 10d | 2013-09-03 | 2013-09-16 | 9-130M FS+228d | 50d |
| 23611075 |  | Procurement Labor - Power Supplies/PC104/Timing Modules SPM BPMs FY13 | 20d | 2013-09-03 | 2013-09-30 | 23611070 FS-10d | 50d |
| 23611913LOE |  | FY13 Mngmnt Effort for BPMs | 20d | 2013-09-03 | 2013-09-30 | 9-130M FS+228d | 67d |
| 23611014Ba |  | Procurement Labor - SPM BPMs ELECTRONICS FY14 | 23.5d | 2013-10-01 | 2013-11-01 | 23611014B, 9-130M FS+228d | 43.5d |
| 23611014D |  | Prcrmnt - SPM BPMs ELECTRONICS | 43d | 2013-10-01 | 2013-12-02 | 9-140M | 24d |
| 23611015A |  | Labor - Fab & Assy - SEE BPMs ELECTRONICS | 77d | 2013-10-01 | 2014-01-30 | 23611014Ba FS-43d, 23611014D FS-43d, 23611014D5 FS-43d, 23611014B FS-43d | 53d |
| 23611065aa |  | System Documentation - BPMs FY14 | 28d | 2013-10-01 | 2013-11-07 | 9-130M FS+228d, 23611065a | 262d |
| 23611075a |  | Procurement Labor - Power Supplies/PC104/Timing Modules SPM BPMs FY14 | 42d | 2013-10-01 | 2013-11-27 | 23611075, 23611070 FS-10d | 50d |
| 23611914LOE |  | FY14 Mngmnt Effort for BPMs Part A | 42d | 2013-10-01 | 2013-11-27 | 23611913LOE | 67d |
| 23611080 |  | Procurement - Power Supplies/PC104/Timing Modules SPM BPMs | 62d | 2013-10-03 | 2014-01-10 | 23611075 FS-40d, 23611075a FS-40d | 50d |
| 23611085 |  | Assembly Labor - Power Supplies/PC104/Timing Modules SPM BPMs Part A | 40d | 2013-10-03 | 2013-11-27 | 23611075 FS-62d, 23611080 FS-62d, 23611075a FS-62d | 50d |
| 23611090 |  | Assembly Procurement - Power Supplies/PC104/Timing Modules SPM BPMs | 77d | 2013-10-03 | 2014-02-03 | 23611075 FS-62d, 23611080 FS-62d, 23611075a FS-62d | 50d |
| 23611095 |  | Installation Labor - Power Supplies/PC104/Timing Modules SPM BPMs Part A | 40d | 2013-10-03 | 2013-11-27 | 23611085a FS-77d, 23611090 FS-77d | 50d |
| 23611100 |  | Installation Procurement - Power Supplies/PC104/Timing Modules SPM BPMs | 77d | 2013-10-03 | 2014-02-03 | 23611095a FS-77d | 50d |
| 23611015B |  | Procrmnt - Fab/Assy & Testing - SPM BPMs ELECTRONICS | 20d | 2013-11-01 | 2013-12-02 | 23611014B FS-20d, 23611014Ba FS-20d, 23611015A FS-83d, 23611014D FS-20d, 23611014D5 FS-20d | 24d |
| 23611025 |  | System Installation - Electronics SPM BPMs Part A | 19d | 2013-11-01 | 2013-11-27 | 23611015B FS-20d | 29d |
| 23611025b |  | System Installation Contract Labor - Electronics SPM BPMs | 20d | 2013-11-01 | 2013-12-02 | 23611015B FS-20d | 86d |
| 23611025c |  | System Installation Software Support - Electronics SPM BPMs Part A | 19d | 2013-11-01 | 2013-11-27 | 23611015B FS-20d | 24d |
| 23611025a |  | System Installation - Electronics SPM BPMs Part B | 58d | 2013-12-02 | 2014-03-04 | 23611025 | 29d |
| 23611025ca |  | System Installation Software Support - Electronics SPM BPMs Part B | 78d | 2013-12-02 | 2014-04-01 | 23611025c | 24d |
| 23611085a |  | Assembly Labor - Power Supplies/PC104/Timing Modules SPM BPMs Part b | 37d | 2013-12-02 | 2014-02-03 | 23611085 | 50d |
| 23611095a |  | Installation Labor - Power Supplies/PC104/Timing Modules SPM BPMs Part B | 37d | 2013-12-02 | 2014-02-03 | 23611095 | 50d |
| 23611914LOEa |  | FY14 Mngmnt Effort for BPMs Part B | 181d | 2013-12-02 | 2014-08-26 | 23611914LOE | 67d |
| 23611036 |  | First Article Cavities - nA BPM Sys | 39d | 2014-01-07 | 2014-03-03 | 9-140M FS+60d | 23d |
| 23611065a5 |  | System Documentation - nA BPMs | 167d | 2014-03-04 | 2014-10-27 | 23611035M FS-21d | 24d |
| 23611027 |  | Hook-up & Check-out H-D B/L BPMs | 15d | 2014-03-12 | 2014-04-01 | 23458065a, 23611025b, 23458065, 23611025a, 23611025ca FS-15d, 23611100 | 24d |
| 23611037 |  | Procurement Labor Cavities - nA BPM Sys | 82d | 2014-03-31 | 2014-07-24 | 23611036 FS+19d | 23d |
| 23611037a |  | Procurement Cavities - nA BPM Sys | 82d | 2014-03-31 | 2014-07-24 | 23611037 FS-82d, 23611036 FS-1d | 23d |
| 23611038 |  | First Article Unit RF Receiver - nA BPM Sys | 49d | 2014-03-31 | 2014-06-06 | 9-140M FS+118d | 86d |
| 23611038a |  | First Article Unit Digital IF - nA BPM Sys | 29d | 2014-03-31 | 2014-05-08 | 9-140M FS+118d | 86d |
| 23611038b |  | First Article Enclosure nA Receiver - nA BPM Sys | 19d | 2014-03-31 | 2014-04-24 | 23611038a FS-29d, 23611038 FS-49d | 86d |
| 23611060 |  | Software support - nA BPMs | 107d | 2014-03-31 | 2014-08-28 | 23611055 FS-160d, 23611050 FS-147d | 65d |
| 23611035M |  | SPM BPMs Comp | 0d | 2014-04-01 | 2014-04-01 | 23611027 | 24d |
| 23611039 |  | Procurement Labor Electronics - nA BPM Sys | 19d | 2014-05-01 | 2014-05-28 | 9-140M FS+141d | 20d |
| 23611040 |  | Procurements Electronics - nA BPM Sys | 19d | 2014-05-01 | 2014-05-28 | 23611039 FS-19d | 20d |
| 23611045 |  | Assembly Electronics Labor - nA BPM Sys | 83d | 2014-06-30 | 2014-10-24 | 23611040 FS+22d | 20d |
| 23611050 |  | Assembly & Testing Procurement - nA BPM Sys | 83d | 2014-06-30 | 2014-10-24 | 23611045 FS-83d, 23611040 FS-1d | 20d |
| 23611055 |  | System Installation Electronics - nA BPM Sytem (BPM) | 67d | 2014-07-30 | 2014-10-31 | 23458065, 23611050 FS-62d, 23611038b, 23458065a, 23611037a | 20d |
| 23611055a |  | System Installation Electronics Contract Labor - nA BPM Sytem (BPM) | 67d | 2014-07-30 | 2014-10-31 | 23611055 FS-67d, 23611038b, 23611037a | 20d |
| 23611065M |  | nA BPMs Comp | 0d | 2014-10-31 | 2014-10-31 | 23611065a5, 23611060, 23611065a, 23611914LOEa, 23611055a, 23611065aa | 20d |
|  | 2 | **1.3.6.1.2 HARPS** |  | 2009-01-02 | 2013-09-30 |  |  |
| 13612909LOE |  | FY09 Mngmnt Effort for Harps | 189d | 2009-01-02 | 2009-09-30 | 13612909LOEX | 20d |
| 13612910LOE |  | FY10 Mngmnt Effort for Harps | 248d | 2009-10-01 | 2010-09-30 | 13612909LOE | 20d |
| 13612911LOE |  | FY11 Mngmnt Effort for Harps | 248d | 2010-10-01 | 2011-09-30 | 13612910LOE | 20d |
| 13612011 |  | LABOR Prep for Harp Sys Procuremnts | 40d | 2011-10-03 | 2011-11-29 | 9-120M, 121612030, 121612035 | 170d |
| 13612014 |  | Vendors Fab Harp Sys Pieces & Components | 95d | 2011-10-03 | 2012-02-24 | 13612011 FS-40d | 170d |
| 13612912LOE |  | FY12 Mngmnt Effort for Harps | 247d | 2011-10-03 | 2012-09-28 | 13612911LOE | 20d |
| 13612015 |  | Harp Sys Fab & Assy | 125d | 2012-02-27 | 2012-08-21 | 13612014 | 170d |
| 13612020 |  | Harp Component Testing FY12 | 27d | 2012-08-22 | 2012-09-28 | 13612015, 9-120M | 170d |
| 13612020b |  | Harp Component Testing Procurement | 35d | 2012-08-22 | 2012-10-10 | 13612015, 9-120M | 170d |
| 13612030 |  | Harp Systems Software Implementn & Cmmssng FY12 | 2d | 2012-09-27 | 2012-09-28 | 13612025 FS-70d | 170d |
| 13612020a |  | Harp Component Testing FY13 | 8d | 2012-10-01 | 2012-10-10 | 13612020 | 170d |
| 13612035 |  | Harp Systems Software Implementn & Cmmssng FY13 | 88d | 2012-10-01 | 2013-02-12 | 13612030 | 170d |
| 13612913LOE |  | FY13 Mngmnt Effort for Harps | 228d | 2012-10-01 | 2013-08-30 | 13612912LOE | 20d |
| 13612025 |  | Harp Sys Implementn | 60d | 2012-10-11 | 2013-01-14 | 1362025, 13612020a, 13612020b, 2-02M | 170d |
| 13612035M |  | Harp Sys Comp | 0d | 2013-02-12 | 2013-02-12 | 13612035 | 170d |
| 13612950 |  | Re-Baseline Actuals Adjustment | 1d | 2013-08-30 | 2013-08-30 | 9-130M FS+227d | 20d |
| 23612030 |  | Harp Sys Implementn Labor | 20d | 2013-09-03 | 2013-09-30 | 9-130M FS+228d, 23458065a FS-26d, 23458065 FS-26d | 30d |

| ID | WBS | Task | Duration | Start | Finish | Predecessors | Total float |
| --- | --- | --- | --- | --- | --- | --- | --- |
| 23612035 |  | Harp Systems Software Implementn & Cmmssng | 20d | 2013-09-03 | 2013-09-30 | 23612030 FS-20d | 30d |
| 23612913LOE |  | FY13 Mngmnt Effort for Harps | 20d | 2013-09-03 | 2013-09-30 | 9-130M FS+228d | 89d |
| 23612035M |  | Harp Sys Comp | 0d | 2013-09-30 | 2013-09-30 | 23612035 | 30d |
|  | 3 | **1.3.6.1.3 VIEWERS** |  | 2009-01-02 | 2013-12-02 |  |  |
| 13613909LOE |  | FY09 Mngmnt Effort for Viewer Syss | 189d | 2009-01-02 | 2009-09-30 | 13613909LOEX | 20d |
| 13613910LOE |  | FY10 Mngmnt Effort for Viewer Syss | 248d | 2009-10-01 | 2010-09-30 | 13613909LOE | 20d |
| 13613911LOE |  | FY11 Mngmnt Effort for Viewer Syss | 248d | 2010-10-01 | 2011-09-30 | 13613910LOE | 20d |
| 13613912LOE |  | FY12 Mngmnt Effort for Viewer Syss | 247d | 2011-10-03 | 2012-09-28 | 13613911LOE | 20d |
| 13613014 |  | Procurements for Viewer Syss | 80d | 2012-02-03 | 2012-05-25 | 121613040M, 9-120M FS+80d | 20d |
| 13613015 |  | Fab & Assy of Viewer Syss FY12 | 87d | 2012-05-29 | 2012-09-28 | 13613014, 9-120M | 20d |
| 13613015b |  | Fab & Assy of Viewer Syss Procurement | 180d | 2012-05-29 | 2013-02-20 | 9-120M, 13613014 | 20d |
| 13613015a |  | Fab & Assy of Viewer Syss FY13 | 93d | 2012-10-01 | 2013-02-20 | 13613015 | 20d |
| 13613913LOE |  | FY13 Mngmnt Effort for Viewer Syss | 228d | 2012-10-01 | 2013-08-30 | 13613912LOE | 20d |
| 13613020 |  | Testing of Viewer Sys Compnts | 125d | 2013-02-21 | 2013-08-16 | 13613015a, 13613015b | 20d |
| 13613030 |  | Software Implementn Viewer Systems | 20d | 2013-08-05 | 2013-08-30 | 13613025 FS-20d, 121613040M | 20d |
| 13613025 |  | Implementn of Viewer Syss | 10d | 2013-08-19 | 2013-08-30 | 13613020, 1362025 | 20d |
| 13613950 |  | Re-Baseline Actuals Adjustment | 1d | 2013-08-30 | 2013-08-30 | 9-130M FS+227d | 20d |
| 23613025a |  | Implementn of Viewer Syss Labor | 20d | 2013-09-03 | 2013-09-30 | 23458065 FS-100d, 23458065a FS-100d, 9-130M FS+228d | 30d |
| 23613030 |  | Software Implementn Viewer Systems | 20d | 2013-09-03 | 2013-09-30 | 23613025a FS-20d | 30d |
| 23613913LOE |  | FY13 Mngmnt Effort for Viewer Syss | 20d | 2013-09-03 | 2013-09-30 | 9-130M FS+228d | 89d |
| 23613035M |  | Viewers Sys Comp | 0d | 2013-09-30 | 2013-09-30 | 23613025a, 23613030 | 30d |
| 23613050 |  | SLM System Controls | 43d | 2013-10-01 | 2013-12-02 | 9-140M | 73d |
|  | 4 | **1.3.6.1.4 BEAM-BASED FEEDBACK SYSTEMS** |  | 2009-01-02 | 2014-09-22 |  |  |
| 13614909LOE |  | FY09 FFB Sys Mangement Effort | 189d | 2009-01-02 | 2009-09-30 | 13614909LOEX | 20d |
| 13614910LOE |  | FY10 FFB Sys Mangement Effort | 248d | 2009-10-01 | 2010-09-30 | 13614909LOE | 20d |
| 13614911LOE |  | FY11 FFB Sys Mangement Effort | 248d | 2010-10-01 | 2011-09-30 | 13614910LOE | 20d |
| 13614014 |  | FFB Sys Prcrmnts | 60d | 2013-02-06 | 2013-05-01 | 121614035M, 2-02M FS+180d | 65d |
| 13614015 |  | FFB Sys Fabriation & Assy | 40d | 2013-05-02 | 2013-06-27 | 13614014 | 65d |
| 13614020 |  | FFB Sys Component & VME Testing | 40d | 2013-05-02 | 2013-06-27 | 13614014 | 65d |
| 13614950 |  | Re-Baseline Actuals Adjustment | 1d | 2013-08-30 | 2013-08-30 | 9-130M FS+227d | 20d |
| 23614014 |  | FFB Sys Prcrmnts | 55d | 2014-03-05 | 2014-05-20 | 9-140M FS+100d | 49d |
| 23614050LOE |  | FY14 Mngmnt Effort for FFB | 140d | 2014-03-05 | 2014-09-19 | 9-140M FS+100d | 50d |
| 23614015 |  | FFB Sys Fabriation & Assy | 43d | 2014-04-23 | 2014-06-23 | 23614014 FS-20d | 49d |
| 23614020 |  | FFB Sys Component & VME Testing | 43d | 2014-04-23 | 2014-06-23 | 23614014 FS-20d | 112d |
| 23614030 |  | FFB Software Implementn | 48d | 2014-05-27 | 2014-08-01 | 23614025 FS-40d | 49d |
| 23614025 |  | FFB Sys Hardware Implementn | 20d | 2014-06-24 | 2014-07-22 | 23614015, 23611035M | 49d |
| 23614035 |  | FFB Slow Lock Implementn | 30d | 2014-08-04 | 2014-09-15 | 23614030 | 49d |
| 23614040 |  | FFB Slow Lock & FFB Cmmssng | 15d | 2014-09-02 | 2014-09-22 | 23614035 FS-10d, 32-05M, 23611035M | 49d |
| 23614045M |  | FFB Sys Comp | 0d | 2014-09-22 | 2014-09-22 | 23614050LOE, 23614025, 23614020, 23614040 | 49d |
|  | 2 | **1.3.6.2 CONTROL SYSTEM HARDWARE** |  | 2009-01-02 | 2013-08-30 |  |  |
| 1362909LOE |  | FY09 CSH Sys Mngmnt Effort | 189d | 2009-01-02 | 2009-09-30 | 1362909LOEX | 20d |
| 1362910LOE |  | FY10 CSH Sys Mngmnt Effort | 248d | 2009-10-01 | 2010-09-30 | 1362909LOE | 20d |
| 1362014 |  | CSH Proc Compnts (multiple reqs) Linacs - Labor | 40d | 2010-04-01 | 2010-05-26 | 9-100M FS+120d, 12162040M | 451d |
| 1362014A |  | CSH Proc Compnts (multiple reqs) Linacs - Procurements | 40d | 2010-04-01 | 2010-05-26 | 9-100M FS+120d | 451d |
| 1362910ALOE |  | FY10 Engineering Oversight | 128d | 2010-04-01 | 2010-09-30 | 9-100M FS+120d | 20d |
| 1362015 |  | CSH Hardware Setup/Configuration Linacs - Labor FY10 | 88d | 2010-05-27 | 2010-09-30 | 1362014, 1362014A | 451d |
| 1362015A |  | CSH Hardware Setup/Configuration Linacs - Procurement | 140d | 2010-05-27 | 2010-12-15 | 1362014A, 1362014 | 451d |
| 1362015ab |  | CSH Hardware Setup/Configuration Linacs - Labor FY11 | 52d | 2010-10-01 | 2010-12-15 | 1362015 | 451d |
| 1362911LOE |  | FY11 CSH Sys Mngmnt Effort (Including Engineering Oversight) | 248d | 2010-10-01 | 2011-09-30 | 1362910ALOE, 1362910LOE | 20d |
| 1362020 |  | CSH Installtn Network/Controls Linacs - Labor | 40d | 2010-12-16 | 2011-02-18 | 1362015ab, 1362015A | 451d |
| 1362020A |  | CSH Installtn Network/Controls Linacs - Procurement | 40d | 2010-12-16 | 2011-02-18 | 1362015ab, 1362015A | 451d |
| 1362025 |  | CSH Commisioning Network/Controls Linacs | 70d | 2011-02-22 | 2011-05-31 | 1362020A, 1362020 | 451d |
| 1362014B |  | CSH Proc Compnts (multiple reqs) Tagger Service Building - Labor | 40d | 2011-10-03 | 2011-11-29 | 9-120M | 105d |
| 1362014C |  | CSH Proc Compnts (multiple reqs) Tagger Service Building - Procurements | 40d | 2011-10-03 | 2011-11-29 | 9-120M | 105d |
| 1362912LOE |  | FY12 CSH Sys Mngmnt Effort (Including Engineering Oversight) | 247d | 2011-10-03 | 2012-09-28 | 1362911LOE | 20d |
| 1362015B |  | CSH Hardware Setup/Configuration Tagger Service Building - Labor | 140d | 2011-11-30 | 2012-06-26 | 1362014B, 1362014C | 105d |
| 1362015C |  | CSH Hardware Setup/Configuration Tagger Service Building - Procurement | 140d | 2011-11-30 | 2012-06-26 | 1362014B, 1362014C | 105d |
| 1362020B |  | CSH Installtn Network/Controls Tagger Service Building - Labor | 40d | 2012-06-27 | 2012-08-21 | 1362015B, 1362015C | 105d |
| 1362020C |  | CSH Installtn Network/Controls Tagger Service Building - Procurement | 40d | 2012-06-27 | 2012-08-21 | 1362015C, 1362015B | 105d |
| 1362025A |  | CSH Commisioning Network/Controls Tagger Service Building FY12 | 27d | 2012-08-22 | 2012-09-28 | 1362020B, 1362020C | 105d |
| 1362025Aa |  | CSH Commisioning Network/Controls Tagger Service Building FY13 | 43d | 2012-10-01 | 2012-11-30 | 1362025A | 105d |
| 1362026 |  | East Arc 12Gev Network Upgrade Procuremnts | 100d | 2012-12-03 | 2013-05-01 | 1362025, 1362025Aa | 105d |
| 1362027 |  | East Arc 12Gev Network Upgrade Installations | 100d | 2012-12-03 | 2013-05-01 | 1362025Aa, 1362025 | 105d |
| 1362028 |  | East Arc 12Gev Network Upgrade Testing | 100d | 2012-12-03 | 2013-05-01 | 1362025Aa, 1362025 | 105d |
| 1362030 |  | CSH Gateway , Data Storage, CPU Capacity | 100d | 2012-12-03 | 2013-05-01 | 1362025Aa, 1362025 | 105d |
| 1362035M |  | CSH Comp Milestone | 0d | 2013-05-01 | 2013-05-01 | 1362026, 1362027, 1362028, 1362030, 1362025 | 105d |
| 1362950 |  | Re-Baseline Actuals Adjustment | 1d | 2013-08-30 | 2013-08-30 | 9-130M FS+227d | 20d |
|  | 3 | **1.3.6.3 CONTROL SYSTEM SOFTWARE** |  | 2009-01-02 | 2013-09-30 |  |  |
| 1363909LOE |  | FY09 CSS Sys Mngmnt Effort | 189d | 2009-01-02 | 2009-09-30 | 1363909LOEX | 20d |
| 1363910LOE |  | FY10 CSS Sys Mngmnt Effort | 248d | 2009-10-01 | 2010-09-30 | 1363909LOE | 20d |

| ID | WBS | Task | Duration | Start | Finish | Predecessors | Total float |
| --- | --- | --- | --- | --- | --- | --- | --- |
| 1363911LOE |  | FY11 CSS Sys Mngmnt Effort | 248d | 2010-10-01 | 2011-09-30 | 1363910LOE | 20d |
| 1363015 |  | Update Hi-Level Applications Labor FY11 | 108d | 2011-04-29 | 2011-09-30 | 9-110M FS+140d | 160d |
| 1363015b |  | Update Hi-Level Applications Procurement | 475d | 2011-04-29 | 2013-03-29 | 9-110M FS+140d | 160d |
| 1363015a |  | Update Hi-Level Applications Labor FY12 | 247d | 2011-10-03 | 2012-09-28 | 1363015 | 160d |
| 1363912LOE |  | FY12 CSS Sys Mngmnt Effort | 247d | 2011-10-03 | 2012-09-28 | 1363911LOE | 20d |
| 1363020 |  | Update Sys Tools (CONT SYS SW) FY12 | 107d | 2012-04-30 | 2012-09-28 | 9-120M FS+140d | 320d |
| 1363020b |  | Update Sys Tools (CONT SYS SW) Procurement | 165d | 2012-04-30 | 2012-12-21 | 9-120M FS+140d | 320d |
| 1363025 |  | Update Low-Level Applications (CONT SYS SW) FY12 | 107d | 2012-04-30 | 2012-09-28 | 9-120M FS+140d | 180d |
| 1363025b |  | Update Low-Level Applications (CONT SYS SW) Procurement | 185d | 2012-04-30 | 2013-01-29 | 9-120M FS+140d | 180d |
| 1363014 |  | Update Synoptic Displays (CONT SYS SW) FY12 | 97d | 2012-05-14 | 2012-09-28 | 2-02M | 205d |
| 1363035 |  | Integration with Sys administration Mngmnt Software (CONT SYS SW) | 20d | 2012-05-14 | 2012-06-12 | 2-02M | 335d |
| 1363030 |  | Update Communication/Coordination Tools (CONT SYS SW) FY12 | 17d | 2012-09-06 | 2012-09-28 | 9-120M FS+230d, 12163050M | 180d |
| 1363014a |  | Update Synoptic Displays (CONT SYS SW) FY13 | 53d | 2012-10-01 | 2012-12-14 | 1363014 | 205d |
| 1363015aa |  | Update Hi-Level Applications Labor FY13 | 120d | 2012-10-01 | 2013-03-29 | 1363015a | 160d |
| 1363020a |  | Update Sys Tools (CONT SYS SW) FY13 | 58d | 2012-10-01 | 2012-12-21 | 1363020 | 320d |
| 1363025a |  | Update Low-Level Applications (CONT SYS SW) FY13 | 78d | 2012-10-01 | 2013-01-29 | 1363025 | 180d |
| 1363030a |  | Update Communication/Coordination Tools (CONT SYS SW) FY13 | 68d | 2012-10-01 | 2013-01-14 | 1363030 | 180d |
| 1363913LOE |  | FY13 CSS Sys Mngmnt Effort | 228d | 2012-10-01 | 2013-08-30 | 1363912LOE | 20d |
| 1363950 |  | Re-Baseline Actuals Adjustment | 1d | 2013-08-30 | 2013-08-30 | 9-130M FS+227d | 20d |
| 2363015aa |  | Update Hi-Level Applications Labor | 20d | 2013-09-03 | 2013-09-30 | 9-130M FS+228d | 32d |
| 2363913LOE |  | FY13 CSS Sys Mngmnt Effort | 20d | 2013-09-03 | 2013-09-30 | 9-130M FS+228d | 89d |
|  | 4 | **1.3.6.4 SAFETY SYSTEMS** |  | 2009-01-02 | 2014-06-02 |  |  |
|  | 1 | **1.3.6.4.1 MACHINE PROTECTION** |  | 2009-01-02 | 2014-06-02 |  |  |
| 13641909LOE |  | FY09 Mngmnt & Elect Dsgn Supprt Effort for MPS | 189d | 2009-01-02 | 2009-09-30 | 13641909LOEX | 20d |
| 13641910LOE |  | FY10 Mngmnt & Elect Dsgn Supprt Effort for MPS | 248d | 2009-10-01 | 2010-09-30 | 13641909LOE | 20d |
| 13641911LOE |  | FY11 Mngmnt & Elect Dsgn Supprt Effort for MPS | 248d | 2010-10-01 | 2011-09-30 | 13641910LOE | 20d |
| 13641014a |  | Proc Wire & Cable for RF Installation (MPS) | 50d | 2011-01-05 | 2011-03-17 | 9-110M FS+60d | 540d |
| 13641015a |  | Proc FSD Hardware for RF Installation (MPS) | 40d | 2011-03-18 | 2011-05-12 | 13641014a | 540d |
| 13641020a |  | Test/QA FSD Hardware for RF Installation (MPS) | 30d | 2011-05-13 | 2011-06-24 | 13641015a | 540d |
| 13641025a |  | Install FSD Wire & Cable for RF Installation (MPS) FY11 | 68d | 2011-06-27 | 2011-09-30 | 13641020a | 540d |
| 13641025ab |  | Install FSD Wire & Cable for RF Installation (MPS) FY12 | 82d | 2011-10-03 | 2012-02-06 | 13641025a | 540d |
| 13641912LOE |  | FY12 Mngmnt & Elect Dsgn Supprt Effort for MPS | 247d | 2011-10-03 | 2012-09-28 | 13641911LOE | 20d |
| 13641014 |  | Proc Wire & Cable (MPS) | 50d | 2012-01-05 | 2012-03-16 | 121641110M, 9-120M FS+60d, 121641170 | 30d |
| 13641050 |  | Proc BLM Hardware (MPS) | 40d | 2012-01-05 | 2012-03-02 | 9-120M FS+60d | 347d |
| 13641085 |  | Proc Tagger/Hall D Beam Loss Monitoring Hardware (MPS) | 50d | 2012-01-05 | 2012-03-16 | 9-120M FS+60d | 480d |
| 13641030a |  | Install/Test FSD Hardwarefor RF Installation(MPS) | 30d | 2012-02-07 | 2012-03-20 | 13641025ab | 540d |
| 13641055 |  | Test/QA BLM Hardware (MPS) | 30d | 2012-03-05 | 2012-04-13 | 13641050 | 459d |
| 13641015 |  | Proc FSD Hardware (MPS) | 40d | 2012-03-19 | 2012-05-11 | 13641014, 121641110M, 121641170 | 347d |
| 13641025 |  | Install FSD Wire & Cable (MPS) FY12 | 137d | 2012-03-19 | 2012-09-28 | 3A-08M, 16332030, 16332010U, 13641014 | 352d |
| 13641090 |  | Test/QA Tagger/Hall D Beam Loss Monitoring Hardware (MPS) | 20d | 2012-03-19 | 2012-04-13 | 13641085 | 480d |
| 13641020 |  | Test/QA FSD Hardware (MPS) FY12 | 21d | 2012-08-30 | 2012-09-28 | 13641015 FS+76d | 347d |
| 13641020b |  | Test/QA FSD Hardware (MPS) FY13 | 21d | 2012-10-01 | 2012-10-29 | 13641020 | 347d |
| 13641025b |  | Install FSD Wire & Cable (MPS) FY13 | 13d | 2012-10-01 | 2012-10-17 | 13641025 | 352d |
| 13641913LOE |  | FY13 Mngmnt & Elect Dsgn Supprt Effort for MPS | 228d | 2012-10-01 | 2013-08-30 | 13641912LOE | 20d |
| 13641035 |  | Develop/Install/Test FSD Firmware (MPS) | 40d | 2012-10-18 | 2012-12-14 | 13641025b, 13641030 FS-45d | 352d |
| 13641014b |  | Proc Remaining Wire & Cable (MPS) | 10d | 2012-11-01 | 2012-11-14 | 9-130M FS+23d | 372d |
| 13641030 |  | Install/Test FSD Hardware (MPS) | 35d | 2012-11-01 | 2012-12-21 | 1362020, 16332030, 13641020b FS+2d | 347d |
| 13641060 |  | Install BLM Wire & Cable (MPS) | 35d | 2012-11-01 | 2012-12-21 | 16333030 FS-125d, 13641050 FS+170d, 16332030, 16332010U | 347d |
| 13641070 |  | Develop/Install/Test BLM Firmware (MPS) | 35d | 2012-11-01 | 2012-12-21 | 13641065 FS-87d | 347d |
| 13641040 |  | Develop/Install/Test FSD Software (MPS) | 22d | 2012-11-20 | 2012-12-21 | 13641030 FS-22d | 347d |
| 13641045M |  | FSD Sys Comp (MPS) | 0d | 2012-12-21 | 2012-12-21 | 13641035, 13641030a, 13641040 | 347d |
| 13641095 |  | Install/Test Tagger/Hall D Beam Loss Monitoring Sys (MPS) | 42d | 2013-01-14 | 2013-03-14 | 16332010U, 16333030, 16332030, 9-130M FS+67d, 13641090 | 296d |
| 13641065 |  | Install BLM Hardware (MPS) | 20d | 2013-02-15 | 2013-03-15 | 1362020, 9-130M FS+90d, 16332030, 13641055 | 252d |
| 13641100M |  | Beam Loss Ion Chamb Sys Comp (MPS) | 0d | 2013-03-14 | 2013-03-14 | 13641095 | 296d |
| 13641075 |  | Develop/Install/Test BLM Software (MPS) | 43d | 2013-03-18 | 2013-05-15 | 13641065 | 252d |
| 13641080M |  | BLM Sys Comp (MPS) | 0d | 2013-05-15 | 2013-05-15 | 13641060, 13641070, 13641075, 13641014b | 252d |
| 13641950 |  | Re-Baseline Actuals Adjustment | 1d | 2013-08-30 | 2013-08-30 | 9-130M FS+227d | 20d |
| 23641020 |  | Test/QA FSD Hardware (MPS) | 9d | 2013-09-03 | 2013-09-13 | 9-130M FS+228d | 119d |
| 23641030 |  | Install/Test FSD Hardware (MPS) FY13 | 20d | 2013-09-03 | 2013-09-30 | 23641020 FS-9d | 119d |
| 23641055 |  | Test/QA BLM Hardware (MPS) FY13 | 20d | 2013-09-03 | 2013-09-30 | 9-130M FS+228d | 134d |
| 23641060 |  | Install BLM Wire & Cable (MPS) FY13 | 20d | 2013-09-03 | 2013-09-30 | 9-130M FS+228d | 99d |
| 23641065 |  | Install BLM Hardware (MPS) FY13 | 20d | 2013-09-03 | 2013-09-30 | 23641055 FS-60d, 23641060 FS-57d, 23641060a FS-57d, 23641055a FS-60d | 99d |
| 23641085 |  | Proc Tagger/Hall D Beam Loss Monitoring Hardware (MPS) | 20d | 2013-09-03 | 2013-09-30 | 9-130M FS+228d | 129d |
| 23641087 |  | Install BLM Wire & Cable (MPS) Tagger Hall D FY13 | 20d | 2013-09-03 | 2013-09-30 | 9-130M FS+228d | 40d |
| 23641090 |  | Test/QA Tagger/Hall D Beam Loss Monitoring Hardware (MPS) FY13 | 20d | 2013-09-03 | 2013-09-30 | 23641087a FS-85d, 23641087 FS-85d | 40d |
| 23641913LOE |  | FY13 Mngmnt & Elect Dsgn Supprt Effort for MPS | 20d | 2013-09-03 | 2013-09-30 | 9-130M FS+228d | 142d |
| 23641030a |  | Install/Test FSD Hardwarefor RF Installation(MPS) FY13 | 11d | 2013-09-16 | 2013-09-30 | 9-130M FS+237d | 133d |
| 23641040 |  | Develop/Install/Test FSD Software (MPS) FY13 | 11d | 2013-09-16 | 2013-09-30 | 9-130M FS+237d | 133d |
| 23641025 |  | Install FSD Wire & Cable (MPS) FY13 | 6d | 2013-09-23 | 2013-09-30 | 9-130M FS+242d | 122d |
| 23641025a |  | Install FSD Wire & Cable (MPS) FY14 | 34d | 2013-10-01 | 2013-11-15 | 9-130M FS+242d, 23641025 | 122d |

| ID | WBS | Task | Duration | Start | Finish | Predecessors | Total float |
| --- | --- | --- | --- | --- | --- | --- | --- |
| 23641030aa |  | Install/Test FSD Hardwarefor RF Installation(MPS) FY14 | 23d | 2013-10-01 | 2013-10-31 | 23641030a, 9-130M FS+237d | 133d |
| 23641030b |  | Install/Test FSD Hardware (MPS) FY14 | 37d | 2013-10-01 | 2013-11-20 | 23641020 FS-9d, 23641030 | 119d |
| 23641040a |  | Develop/Install/Test FSD Software (MPS) FY14 | 23d | 2013-10-01 | 2013-10-31 | 9-130M FS+237d, 23641040 | 133d |
| 23641055a |  | Test/QA BLM Hardware (MPS) FY14 | 5d | 2013-10-01 | 2013-10-07 | 23641055, 9-130M FS+228d | 134d |
| 23641060a |  | Install BLM Wire & Cable (MPS) FY14 | 37d | 2013-10-01 | 2013-11-20 | 9-130M FS+228d, 23641060 | 99d |
| 23641065a |  | Install BLM Hardware (MPS) FY14 | 37d | 2013-10-01 | 2013-11-20 | 23641060 FS-57d, 23641055 FS-60d, 23641060a FS-57d, 23641065, 23641055a FS-60d | 99d |
| 23641087a |  | Install BLM Wire & Cable (MPS) Tagger Hall D FY14 | 65d | 2013-10-01 | 2014-01-13 | 9-130M FS+228d, 23641087 | 40d |
| 23641090a |  | Test/QA Tagger/Hall D Beam Loss Monitoring Hardware (MPS) FY14 | 64d | 2013-10-01 | 2014-01-10 | 23641087a FS-85d, 23641090, 23641087 FS-85d | 40d |
| 23641100 |  | Rework FSD Cards | 35d | 2013-10-01 | 2013-11-18 | 9-140M | 94d |
| 23641914LOE |  | FY14 Mngmnt & Elect Dsgn Supprt Effort for MPS | 163d | 2013-10-01 | 2014-06-02 | 23641913LOE | 142d |
| 23641075 |  | Develop/Install/Test BLM Software (MPS) | 24d | 2013-11-15 | 2013-12-20 | 23641065a FS-4d, 23641065 FS-4d | 99d |
| 23641045M |  | FSD Sys Comp (MPS) | 0d | 2013-11-20 | 2013-11-20 | 23641040, 23641030b, 23641030aa, 23641025, 23641040a, 23641030a, 23641030, 23641025a | 119d |
| 23641080M |  | BLM Sys Comp (MPS) | 0d | 2013-12-20 | 2013-12-20 | 23641060, 23641075, 23641060a | 99d |
| 23641095 |  | Install/Test Tagger/Hall D Beam Loss Monitoring Sys (MPS) | 29d | 2014-01-07 | 2014-02-17 | 23641090 FS-4d, 23641090a FS-4d | 40d |
| 23641100M |  | Beam Loss Ion Chamb Sys Comp (MPS) | 0d | 2014-02-17 | 2014-02-17 | 23641095 | 40d |
|  | 2 | **1.3.6.4.2 BELS** |  | 2009-01-02 | 2014-06-02 |  |  |
| 13642909LOE |  | FY09 Mngmnt & Elect Dsgn Supprt Effort for BELS | 189d | 2009-01-02 | 2009-09-30 | 13642909LOEX | 20d |
| 13642910LOE |  | FY10 Mngmnt & Elect Dsgn Supprt Effort for BELS | 248d | 2009-10-01 | 2010-09-30 | 13642909LOE | 20d |
| 13642911LOE |  | FY11 Mngmnt & Elect Dsgn Supprt Effort for BELS | 248d | 2010-10-01 | 2011-09-30 | 13642910LOE | 20d |
| 13642912LOE |  | FY12 Mngmnt & Elect Dsgn Supprt Effort for BELS | 247d | 2011-10-03 | 2012-09-28 | 13642911LOE | 20d |
| 13642014 |  | Proc BELS Hardware | 75d | 2012-01-05 | 2012-04-20 | 9-120M FS+60d, 121642070M, 121642170 | 295d |
| 13642913LOE |  | FY13 Mngmnt & Elect Dsgn Supprt Effort for BELS | 228d | 2012-10-01 | 2013-08-30 | 13642912LOE | 20d |
| 13642019 |  | Proc Remaining BELS Hardware | 40d | 2013-01-17 | 2013-03-15 | 9-130M FS+70d | 73d |
| 13642015 |  | Test/QA BELS Compnts | 22d | 2013-03-19 | 2013-04-17 | 13642014, 13642019, 9-130M FS+111d | 72d |
| 13642020 |  | Install BELS Hardware | 43d | 2013-04-18 | 2013-06-18 | 13642015, 16332030, 9-130M FS+45d | 72d |
| 13642005 |  | Develop/Install/Test BELS Software | 30d | 2013-05-21 | 2013-07-02 | 13642015, 13642020 FS-20d | 72d |
| 13642030M |  | BELS Sys Comp | 0d | 2013-07-02 | 2013-07-02 | 13642020, 13642005 | 72d |
| 13642950 |  | Re-Baseline Actuals Adjustment | 1d | 2013-08-30 | 2013-08-30 | 9-130M FS+227d | 20d |
| 23642913LOE |  | FY13 Mngmnt & Elect Dsgn Supprt Effort for BELS | 20d | 2013-09-03 | 2013-09-30 | 9-130M FS+228d | 142d |
| 23642014 |  | Proc BELS Hardware | 31d | 2013-10-01 | 2013-11-12 | 9-140M | 21d |
| 23642019 |  | Proc Remaining BELS Hardware | 50d | 2013-10-01 | 2013-12-11 | 9-140M | 21d |
| 23642914LOE |  | FY14 Mngmnt & Elect Dsgn Supprt Effort for BELS | 163d | 2013-10-01 | 2014-06-02 | 23642913LOE | 142d |
| 23642005 |  | Develop/Install/Test BELS Software | 50d | 2013-10-14 | 2014-01-03 | 23642020 FS-120d, 23642015 FS-53d | 70d |
| 23642015 |  | Test/QA BELS Compnts | 42d | 2013-10-29 | 2014-01-08 | 23642014 FS-11d, 23642019 FS-30d | 21d |
| 23642020 |  | Install BELS Hardware | 22d | 2014-02-13 | 2014-03-14 | 23642015 FS+24d, 9-130M FS+228d | 21d |
| 23642030M |  | BELS Sys Comp | 0d | 2014-03-14 | 2014-03-14 | 23642020, 23642005 | 21d |
|  | 3 | **1.3.6.4.3 PSS** |  | 2009-01-02 | 2014-06-02 |  |  |
| 13643909LOE |  | FY09 Mngmnt & Supprt Effort for PSS | 189d | 2009-01-02 | 2009-09-30 | 13643909LOEX | 20d |
| 13643910LOE |  | FY10 Mngmnt & Supprt Effort for PSS | 248d | 2009-10-01 | 2010-09-30 | 13643909LOE | 20d |
| 13643030 |  | Proc Custom Compnts (Run/Safe, Interface Chassis) (PSS) Labor FY11(FY12 @ 13643030b) | 248d | 2010-10-01 | 2011-09-30 | 9-110M, 121643140 | 173d |
| 13643030a |  | Proc Custom Compnts (Run/Safe, Interface Chassis) for RF Installation (PSS) | 72d | 2010-10-01 | 2011-01-21 | 9-110M | 173d |
| 13643030c |  | Proc Custom Compnts (Run/Safe, Interface Chassis) (PSS) Procurement | 490d | 2010-10-01 | 2012-09-21 | 121643140, 9-110M | 173d |
| 13643160 |  | Create & Simulate PSS Logic Programs | 100d | 2010-10-01 | 2011-03-03 | 9-110M | 673d |
| 13643911LOE |  | FY11 Mngmnt & Supprt Effort for PSS | 248d | 2010-10-01 | 2011-09-30 | 13643910LOE | 20d |
| 13643020a |  | Proc PLC Systems for RF Installation (PSS) | 40d | 2010-11-01 | 2011-01-05 | 9-110M FS+21d | 742d |
| 13643035 |  | Test/QA Custom Compnts (PSS) FY11 (FY12 @ 13643035b) | 218d | 2010-11-12 | 2011-09-30 | 13643030c FS-460d, 13643030b FS-460d | 173d |
| 13643040 |  | Proc Local Cable, Conduit, Infrastructure (PSS) Labor FY11 (FY12 @ 13643040b) | 203d | 2010-12-07 | 2011-09-30 | 121643140, 9-110M FS+45d | 35d |
| 13643040a |  | Proc Local Cable, Conduit, Infrastructure for RF Installation (PSS) | 76d | 2010-12-07 | 2011-04-01 | 9-110M FS+45d | 83d |
| 13643040c |  | Proc Local Cable, Conduit, Infrastructure (PSS) Labor Procurement | 245d | 2010-12-07 | 2011-12-01 | 9-110M FS+45d, 121643140 | 35d |
| 13643050 |  | Proc COTS Compnts (Access Control, Video,etc) (PSS) Labor FY11 | 188d | 2011-01-05 | 2011-09-30 | 9-110M FS+60d, 121643140 | 328d |
| 13643050b |  | Proc COTS Compnts (Access Control, Video,etc) (PSS) Procurement | 245d | 2011-01-05 | 2011-12-29 | 9-110M FS+60d, 121643140 | 328d |
| 13643025a |  | Test/QA PLC Systems for RF Installation (PSS) | 30d | 2011-01-06 | 2011-02-17 | 13643020a | 742d |
| 13643035a |  | Test/QA Custom Compnts for RF Installation (PSS) FY11 | 176d | 2011-01-24 | 2011-09-30 | 13643030a | 173d |
| 13643045a |  | Install Linac Cable Conduit, Infrastructure for RF Installation (PSS) | 44d | 2011-05-02 | 2011-07-01 | 13643040a FS+20d | 83d |
| 13643165a |  | Install & Test PSS Logic Programs for Linac RF Upgrade | 6d | 2011-07-25 | 2011-08-01 | 13643045a FS+14d | 83d |
| 13643172M |  | Linac RF PSS Systems Comp | 0d | 2011-08-11 | 2011-08-11 | 13643165a FS+8d | 83d |
| 13643030b |  | Proc Custom Compnts (Run/Safe, Interface Chassis) (PSS) Labor FY12 (FY11 @ 13643030) | 242d | 2011-10-03 | 2012-09-21 | 13643030 | 173d |
| 13643035ab |  | Test/QA Custom Compnts for RF Installation (PSS) FY12 | 247d | 2011-10-03 | 2012-09-28 | 13643035a | 173d |
| 13643035b |  | Test/QA Custom Compnts (PSS) FY12 (FY11 @ 13643035) | 247d | 2011-10-03 | 2012-09-28 | 13643035 | 173d |
| 13643040b |  | Proc Local Cable, Conduit, Infrastructure (PSS) Labor FY12 (FY11 @ 13643040) | 42d | 2011-10-03 | 2011-12-01 | 13643040 | 35d |
| 13643050a |  | Proc COTS Compnts (Access Control, Video,etc) (PSS) Labor FY12 | 57d | 2011-10-03 | 2011-12-29 | 13643050 | 328d |
| 13643125 |  | Proc ODH Monitoring Sys (PSS) | 30d | 2011-10-03 | 2011-11-11 | 9-120M, 121643140 | 415d |
| 13643912LOE |  | FY12 Mngmnt & Supprt Effort for PSS | 247d | 2011-10-03 | 2012-09-28 | 13643911LOE | 20d |
| 13643020 |  | Proc PLC Systems (PSS) | 40d | 2011-11-01 | 2012-01-05 | 9-120M FS+21d, 121643140 | 494d |
| 13643130 |  | Test/QA ODH Monitoring Sys (PSS) | 30d | 2011-11-14 | 2012-01-04 | 13643125 | 415d |
| 13643075 |  | Install RF, Mag Interfaces (PSS) | 30d | 2011-12-01 | 2012-01-20 | 16111025, 16332030, 13224020 | 554d |
| 13643085 |  | Fab & Install Tagger Bldg. Racks (PSS) | 30d | 2011-12-01 | 2012-01-20 | 16332030 | 6d |
| 13643090 |  | Fab & Install H-D Racks PSS | 30d | 2011-12-01 | 2012-01-20 | 16332030 | 6d |
| 13643055 |  | Test/QA COTS Compnts (PSS) | 60d | 2011-12-30 | 2012-03-27 | 13643050a, 13643050b | 328d |
| 13643014 |  | Let Endstation PSS Cable Plant Contract | 40d | 2012-01-05 | 2012-03-02 | 9-120M FS+60d, 16332030 FS-60d | 312d |

| ID | Task | Duration | Start | Finish | Predecessors | Total float |
| --- | --- | --- | --- | --- | --- | --- |
| 13643060 | Proc Beam Transport Monitor Compnts (PSS) | 40d | 2012-01-05 | 2012-03-02 | 9-120M FS+60d, 121643140 | 471d |
| 13643095 | Proc Matrl's for Beam Stoppers & Diffusers (PSS) | 40d | 2012-01-05 | 2012-03-02 | 121643140, 9-120M FS+60d | 453d |
| 13643110 | Proc PSS Beam Current Monitor Compnts | 130d | 2012-01-05 | 2012-07-10 | 9-120M FS+60d, 121643140 | 385d |
| 13643135 | Install & Test ODH Monitoring Sys (PSS) | 30d | 2012-01-05 | 2012-02-16 | 16333030, 13643130, 16332010U | 415d |
| 13643150 | Proc Equipment for H-A, B, C Upgrades (PSS) | 30d | 2012-01-05 | 2012-02-16 | 9-120M FS+60d, 121643140, 2-02M FS-175d | 373d |
| 13643025 | Test/QA PLC Systems (PSS) | 30d | 2012-01-06 | 2012-02-17 | 13643020b FS-232d, 13643020 | 494d |
| 13643045 | Install Linac Cable Conduit, Infrastructure (PSS) FY12 | 176d | 2012-01-23 | 2012-09-28 | 13643040c, 13643040b, 3A-07M, 16332030, 16331030, 16331032 | 174d |
| 13643165 | Install & Test PSS Logic Programs | 100d | 2012-01-23 | 2012-06-13 | 13643085, 13643160, 13643090 | 454d |
| 13643140 | Upgrade MCC Console (PSS) | 5d | 2012-02-17 | 2012-02-24 | 13643135 | 530d |
| 13643015 | PSS Cable Plant Installtn (Contract Oversight) | 20d | 2012-03-05 | 2012-03-30 | 16331032, 16331030, 16332030, 13643014 | 312d |
| 13643065 | Fab & Test Beam Transport Monitor (PSS) | 30d | 2012-03-05 | 2012-04-13 | 13643060, 32-03M | 471d |
| 13643100 | Fab & Test Beam Stoppers & Diffusers (PSS) | 50d | 2012-03-05 | 2012-05-11 | 13643095 | 453d |
| 13643080 | Upgrade Existing PLC Sys in Linacs (PSS) | 40d | 2012-05-14 | 2012-07-10 | 13643025, 13643025a, 2-02M | 435d |
| 13643115 | Test/QA PSS Beam Current Monitor Compnts | 20d | 2012-07-11 | 2012-08-07 | 13643110 | 385d |
| 13643215 | Tagger ODH Management Oversight FY12 | 42d | 2012-08-01 | 2012-09-28 | 9-120M FS+205d | 344d |
| 13643220 | Change Control Process | 8d | 2012-08-01 | 2012-08-10 | 9-120M FS+205d | 412d |
| 13643225 | Design 5C Line ODH Monitoring | 11d | 2012-08-01 | 2012-08-15 | 9-120M FS+205d | 344d |
| 13643230 | Design HD Tagger ODH Monitoring | 11d | 2012-08-01 | 2012-08-15 | 9-120M FS+205d | 344d |
| 13643120 | Install & Test PSS Beam Current Monitor | 30d | 2012-08-08 | 2012-09-19 | 16333030, 13643115 | 385d |
| 13643240 | 5 C Line ODH Procurements | 37d | 2012-08-08 | 2012-09-28 | 13643235 FS-7d | 362d |
| 13643255 | Hall D ODH Procurements | 37d | 2012-08-08 | 2012-09-28 | 13643235 FS-7d | 344d |
| 13643235 | Design Review (Internal) | 1d | 2012-08-16 | 2012-08-16 | 13643230, 13643225 | 344d |
| 13643245 | 5 C Line ODH Installation FY12 | 26d | 2012-08-23 | 2012-09-28 | 13643240 FS-26d | 362d |
| 13643270 | QA Equipment FY12 | 15d | 2012-09-10 | 2012-09-28 | 13643235 FS+15d | 358d |
| 13643275 | Modify PSS Racks FY12 | 6d | 2012-09-21 | 2012-09-28 | 9-120M FS+241d | 372d |
| 13643280 | EPICS Interface Development FY12 | 6d | 2012-09-21 | 2012-09-28 | 9-120M FS+241d | 364d |
| 13643035abb | Test/QA Custom Compnts for RF Installation (PSS) FY13 | 25d | 2012-10-01 | 2012-11-02 | 13643035ab | 173d |
| 13643035ba | Test/QA Custom Compnts (PSS) FY13 | 25d | 2012-10-01 | 2012-11-02 | 13643035b | 173d |
| 13643045b | Install Linac Cable Conduit, Infrastructure (PSS) FY13 | 24d | 2012-10-01 | 2012-11-01 | 13643045 | 174d |
| 13643215a | Tagger ODH Management Oversight FY13 | 35d | 2012-10-01 | 2012-11-16 | 13643215 | 344d |
| 13643245a | 5 C Line ODH Installation FY13 | 16d | 2012-10-01 | 2012-10-22 | 13643245 | 362d |
| 13643260 | Hall D ODH Installation | 23d | 2012-10-01 | 2012-10-31 | 13643255 | 344d |
| 13643270a | QA Equipment FY13 | 20d | 2012-10-01 | 2012-10-26 | 13643270 | 358d |
| 13643275a | Modify PSS Racks FY13 | 6d | 2012-10-01 | 2012-10-08 | 13643275 | 372d |
| 13643280a | EPICS Interface Development FY13 | 14d | 2012-10-01 | 2012-10-18 | 13643280 | 364d |
| 13643913LOE | FY13 Mngmnt & Supprt Effort for PSS | 228d | 2012-10-01 | 2013-08-30 | 13643912LOE | 20d |
| 13643320 | Program Local Electronics | 20d | 2012-10-19 | 2012-11-15 | 13643260 FS-9d | 344d |
| 13643325 | Install Local Alarms | 20d | 2012-10-19 | 2012-11-15 | 13643260 FS-9d | 344d |
| 13643330 | Install Alarm Segment Interface | 15d | 2012-10-26 | 2012-11-15 | 13643325 FS-15d | 344d |
| 13643020b | Proc Remaining Cable and PLC Systems | 23d | 2012-11-01 | 2012-12-05 | 9-130M FS+23d | 494d |
| 13643137 | Complete the Install & Test of ODH Monitoring Sys (PSS) | 25d | 2012-11-01 | 2012-12-07 | 9-130M FS+23d | 210d |
| 13643335 | Software Checkout | 11d | 2012-11-01 | 2012-11-15 | 13643320 FS-11d | 344d |
| 13643350 | PSS PLC Communications - Labor | 171d | 2012-11-01 | 2013-07-15 | 9-130M FS+23d | 95d |
| 13643170M | Linac PSS Systems Comp | 0d | 2012-11-02 | 2012-11-02 | 13643080, 13458050 | 353d |
| 13643340 | Test and Commission | 4d | 2012-11-12 | 2012-11-15 | 13643325 FS-4d | 344d |
| 13643360 | C-100 RF Commissioning PSS Support | 192d | 2012-11-13 | 2013-08-23 | 9-130M FS+31d | 14d |
| 13643345 | 5C Line ODH Extension Complete | 0d | 2012-11-16 | 2012-11-16 | 13643220, 13643340, 13643215a FS-1d, 13643270a, 13643330, 13643275a, 13643235 FS-7d, 13643245a, 13643255, 13643280a, 13643335 | 344d |
| 13643210 | Cable Plant - Field Termination (PSS) | 13d | 2012-11-28 | 2012-12-14 | 13643015, 9-130M FS+40d | 145d |
| 13643145 | Install & Test Access Control Sys (PSS) | 60d | 2012-12-17 | 2013-03-20 | 16331030, 16333030, 16331032, 13643035abb, 13643035ba, 13643055, 13643045b, 13643210, 16332030 | 145d |
| 13643205 | Install Public Address Sys (PSS) | 30d | 2012-12-17 | 2013-02-05 | 16332030, 16331030, 16333030, 16331032, 16332010U, 13643210 | 175d |
| 13643355 | PSS PLC Communications - Procurements | 62d | 2013-02-01 | 2013-04-30 | 13643350 FS-114d | 95d |
| 13643180M | Tagger Bldng PSS Systems Comp | 0d | 2013-03-20 | 2013-03-20 | 13643145, 13643135, 13643137 | 145d |
| 13643185M | H-D PSS Systems Comp | 0d | 2013-03-20 | 2013-03-20 | 13643180M, 16332030, 13643145, 13643205 | 145d |
| 13643105 | Install Beam Stoppers & Diffusers (PSS) | 22d | 2013-05-06 | 2013-06-05 | 13643210, 16333030, 13643100, 9-130M FS+145d | 211d |
| 13643070 | Install Beam Transport Monitor (PSS) | 24d | 2013-05-13 | 2013-06-14 | 9-130M FS+150d, 13643065, 13643210 | 204d |
| 13643155 | Install & Test H-A, B, C Upgrades (PSS) | 42d | 2013-07-01 | 2013-08-28 | 13643150, 2-02M, 9-130M FS+184d | 32d |
| 13643175M | Halls A, B, C PSS Systems Comp | 0d | 2013-08-28 | 2013-08-28 | 13643155 | 32d |
| 13643950 | Re-Baseline Actuals Adjustment | 1d | 2013-08-30 | 2013-08-30 | 9-130M FS+227d | 20d |
| 23643020b | Proc Remaining Cable and PLC Systems | 43d | 2013-09-03 | 2013-10-31 | 9-130M FS+228d | 76d |
| 23643045 | Install Linac Cable Conduit, Infrastructure (PSS) FY13 | 20d | 2013-09-03 | 2013-09-30 | 23643020b FS-43d | 76d |
| 23643100 | Fab & Test Beam Stoppers & Diffusers (PSS) FY13 | 20d | 2013-09-03 | 2013-09-30 | 9-130M FS+228d | 112d |
| 23643117 | Proc BCM Cavity Components- (PSS) Procurement | 43d | 2013-09-03 | 2013-10-31 | 9-130M FS+228d | 106d |
| 23643117a | Proc BCM Cavity Components- (PSS) Expenses FY13 | 20d | 2013-09-03 | 2013-09-30 | 9-130M FS+228d | 105.5d |
| 23643140 | Upgrade MCC Console (PSS) FY13 | 20d | 2013-09-03 | 2013-09-30 | 9-130M FS+228d | 118d |
| 23643360 | C-100 RF Commissioning PSS Support | 20d | 2013-09-03 | 2013-09-30 | 9-130M FS+228d | 30d |
| 23643913LOE | FY13 Mngmnt & Supprt Effort for PSS | 20d | 2013-09-03 | 2013-09-30 | 9-130M FS+228d | 142d |
| 23643105 | Install Beam Stoppers & Diffusers (PSS) FY13 | 11d | 2013-09-16 | 2013-09-30 | 23643100a FS-20d, 23643102 FS-68d, 23643100 FS-20d | 107d |
| 23643145 | Install & Test Tagger Access Control Sys (PSS) FY13 | 11d | 2013-09-16 | 2013-09-30 | 23643045 FS-23d, 23643045a FS-23d | 87d |
| 23643145b | Install & Test Hall D-MCC Access Control Sys (PSS) FY13 | 11d | 2013-09-16 | 2013-09-30 | 23643045 FS-23d, 23643045a FS-23d | 76d |
| 23643350 | PSS PLC Communications - Labor FY13 | 11d | 2013-09-16 | 2013-09-30 | 9-130M FS+237d | 6d |

| ID | WBS | Task | Duration | Start | Finish | Predecessors | Total float |
| --- | --- | --- | --- | --- | --- | --- | --- |
| 23643170M |  | Linac PSS Systems Comp | 0d | 2013-09-30 | 2013-09-30 | 23643360 | 30d |
| 23643045a |  | Install Linac Cable Conduit, Infrastructure (PSS) FY14 | 12d | 2013-10-01 | 2013-10-16 | 23643020b FS-43d, 23643045 | 76d |
| 23643100a |  | Fab & Test Beam Stoppers & Diffusers (PSS) FY14 | 4d | 2013-10-01 | 2013-10-04 | 9-130M FS+228d, 23643100 | 112d |
| 23643105a |  | Install Beam Stoppers & Diffusers (PSS) FY14 | 22d | 2013-10-01 | 2013-10-30 | 23643105, 23643100 FS-20d, 23643102 FS-68d, 23643100a FS-20d | 107d |
| 23643117b |  | Proc BCM Cavity Components- (PSS) Expenses FY14 | 23.5d | 2013-10-01 | 2013-11-01 | 9-130M FS+228d, 23643117a | 105.5d |
| 23643140a |  | Upgrade MCC Console (PSS) FY14 | 11d | 2013-10-01 | 2013-10-15 | 23643140, 9-130M FS+228d | 118d |
| 23643145a |  | Install & Test Tagger Access Control Sys (PSS) FY14 | 42d | 2013-10-01 | 2013-11-27 | 23643045 FS-23d, 23643045a FS-23d, 23643145 | 87d |
| 23643145ba |  | Install & Test Hall D-MCC Access Control Sys (PSS) FY14 | 53d | 2013-10-01 | 2013-12-16 | 23643045a FS-23d, 23643045 FS-23d, 23643145b | 76d |
| 23643350a |  | PSS PLC Communications - Labor FY14 | 42d | 2013-10-01 | 2013-11-27 | 9-130M FS+237d, 23643350 | 6d |
| 23643914LOE |  | FY14 Mngmnt & Supprt Effort for PSS | 163d | 2013-10-01 | 2014-06-02 | 23643913LOE | 142d |
| 23643355 |  | PSS PLC Communications - Procurements | 21d | 2013-10-03 | 2013-10-31 | 23643350a FS-40d, 23643350 FS-40d | 6d |
| 23643065 |  | Fab & Test Beam Transport Monitor (PSS) | 26d | 2013-10-14 | 2013-11-18 | 9-140M FS+9d | 65d |
| 23643120 |  | Install & Test PSS Beam Current Monitor | 47d | 2013-10-15 | 2013-12-20 | 23643115 FS-43d | 72d |
| 23643070 |  | Install Beam Transport Monitor (PSS) | 34d | 2013-11-01 | 2013-12-20 | 23643065 FS-12d | 65d |
| 23643102 |  | Update Stopper/Diffuser Software (PSS) | 34d | 2013-11-01 | 2013-12-20 | 23643100, 23643100a, 9-140M FS+23d | 107d |
| 23643115 |  | Test/QA PSS Beam Current Monitor Compnts | 30d | 2013-11-01 | 2013-12-16 | 9-140M FS+23d | 72d |
| 23643150 |  | Proc Equipment for H-A, B, C Upgrades (PSS) | 74d | 2013-11-04 | 2014-02-28 | 9-140M FS+24d | 18d |
| 23643205 |  | Install Public Address Sys (PSS) | 29d | 2013-11-04 | 2013-12-16 | 9-140M FS+24d | 76d |
| 23643280 |  | EPICS Interface Development | 54d | 2013-11-04 | 2014-01-31 | 9-140M FS+24d | 51d |
| 23643070a |  | Install Beam Transport Monitor - EPICS Interface (PSS) | 22d | 2013-12-02 | 2014-01-10 | 23643065 FS-12d, 23643070 FS-15d | 65d |
| 23643160 |  | Create & Simulate PSS Logic Programs | 24d | 2013-12-03 | 2014-01-15 | 9-140M FS+43d | 62d |
| 23643155 |  | Install & Test H-A, B, C Upgrades (PSS) | 54d | 2013-12-04 | 2014-02-28 | 23643150 FS-54d | 18d |
| 23643180M |  | Tagger Bldng PSS Systems Comp | 0d | 2013-12-16 | 2013-12-16 | 23643145b, 23643145a, 23643145, 23643145ba | 76d |
| 23643165 |  | Install & Test PSS Logic Programs | 10d | 2014-01-02 | 2014-01-15 | 23643160 FS-10d | 62d |
| 23643185M |  | H-D PSS Systems Comp | 0d | 2014-01-10 | 2014-01-10 | 23643205, 23643145ba, 23643070a, 23643070, 23643180M, 23643145, 23643120, 23643145b, 23643145a | 65d |
| 23643175M |  | Halls A, B, C PSS Systems Comp | 0d | 2014-02-28 | 2014-02-28 | 23643155 | 18d |
|  | 5 | **1.3.6.5 DUMPS (HALL D & INSERTABLE)** |  | 2009-01-02 | 2014-01-17 |  |  |
| 1365909LOE |  | FY09 Mngmnt Effort for Dump | 189d | 2009-01-02 | 2009-09-30 | 1365909LOEX | 20d |
| 1365910LOE |  | FY10 Mngmnt Effort for Dump | 248d | 2009-10-01 | 2010-09-30 | 1365909LOE | 20d |
| 1365911LOE |  | FY11 Mngmnt Effort for Dump | 248d | 2010-10-01 | 2011-09-30 | 1365910LOE | 20d |
| 1365014 |  | HD Dump Sys Prcrmnts | 40d | 2011-10-03 | 2011-11-29 | 12165030, 9-120M, 12165035 | 310d |
| 1365912LOE |  | FY12 Mngmnt Effort for Dump | 247d | 2011-10-03 | 2012-09-28 | 1365911LOE | 20d |
| 1365015 |  | HD Dump Sys Fab & Assy | 80d | 2011-11-30 | 2012-03-30 | 1365014 | 310d |
| 1365040 |  | Insertable Dump Sys Prcrmnts | 40d | 2012-01-05 | 2012-03-02 | 9-120M FS+60d, 12165035, 12165030 | 320d |
| 1365020 |  | HD Dump Component Testing | 120d | 2012-10-01 | 2013-03-29 | 1365015, 9-130M | 183d |
| 1365045 |  | Insertable Dump Sys Fab & Assy | 60d | 2012-10-01 | 2013-01-02 | 9-130M, 1365040 | 173d |
| 1365913LOE |  | FY13 Mngmnt Effort for Dump | 228d | 2012-10-01 | 2013-08-30 | 1365912LOE | 20d |
| 1365050 |  | Insertable Dump Component Testing | 35d | 2013-01-03 | 2013-02-22 | 1365045 | 173d |
| 1365060 |  | Insertable Dump Software Implementn & Cmmssng | 120d | 2013-02-08 | 2013-07-30 | 1363035, 1365055 FS-80d | 173d |
| 1365055 |  | Insertable Dump Sys Implementn | 70d | 2013-02-25 | 2013-06-03 | 1365050, 1362025 | 173d |
| 1365025 |  | HD Dump Sys Implementn | 60d | 2013-04-01 | 2013-06-24 | 16331030, 1365020, 16331032 | 183d |
| 1365030 |  | HD Dump Software Implementn & Cmmssng | 55d | 2013-04-29 | 2013-07-16 | 1365025 FS-40d | 183d |
| 1365035M |  | HD Dump Comp | 0d | 2013-07-16 | 2013-07-16 | 1365030 | 183d |
| 1365065M |  | Insertable Dump Comp | 0d | 2013-07-30 | 2013-07-30 | 1365060 | 173d |
| 1365950 |  | Re-Baseline Actuals Adjustment | 1d | 2013-08-30 | 2013-08-30 | 9-130M FS+227d | 20d |
| 2365913LOE |  | FY13 Mngmnt Effort for Dump | 20d | 2013-09-03 | 2013-09-30 | 9-130M FS+228d | 89d |
| 2365014 |  | HD Dump Sys Prcrmnts | 19d | 2013-10-01 | 2013-10-25 | 9-140M | 60d |
| 2365015 |  | HD Dump Sys Fab & Assy | 19d | 2013-10-01 | 2013-10-25 | 2365014 FS-19d | 60d |
| 2365020 |  | HD Dump Component Testing | 19d | 2013-10-01 | 2013-10-25 | 2365015 FS-19d | 60d |
| 2365025 |  | HD Dump Sys Implementn | 54d | 2013-10-01 | 2013-12-17 | 23458045a FS-47d, 23458045 FS-47d, 2365020 FS-19d | 60d |
| 2365045 |  | Insertable Dump Sys Fab & Assy | 19d | 2013-10-01 | 2013-10-25 | 9-140M | 11d |
| 2365050 |  | Insertable Dump Component Testing | 19d | 2013-10-01 | 2013-10-25 | 2365045 FS-19d | 11d |
| 2365055 |  | Insertable Dump Sys Implementn | 19d | 2013-10-01 | 2013-10-25 | 2365050 FS-19d | 11d |
| 2365060 |  | Insertable Dump Software Implementn & Cmmssng | 19d | 2013-10-01 | 2013-10-25 | 23458040 FS-30d, 2365055 FS-19d, 23458040a FS-30d | 11d |
| 2365030 |  | HD Dump Software Implementn & Cmmssng | 55d | 2013-10-21 | 2014-01-17 | 2365025 FS-40d | 60d |
| 2365065M |  | Insertable Dump Comp | 0d | 2013-10-25 | 2013-10-25 | 2365060 | 11d |
| 2365035M |  | HD Dump Comp | 0d | 2014-01-17 | 2014-01-17 | 2365030 | 60d |
|  | 6 | **1.3.6.6 VACUUM CONTROLS** |  | 2009-01-02 | 2013-09-27 |  |  |
| 1366909LOE |  | FY09 Mngmnt Effort for SRFand ARC Vac Controls | 189d | 2009-01-02 | 2009-09-30 | 1366909LOEX | 20d |
| 1366910LOE |  | FY10 Mngmnt Effort for SRFand ARC Vac Controls | 248d | 2009-10-01 | 2010-09-30 | 1366909LOE | 20d |
| 1366014 |  | SRF Vac Controls Sys Prcrmnts | 40d | 2010-05-03 | 2010-06-28 | 12166035, 9-100M FS+142d | 504d |
| 1366015 |  | SRF Vac Controls Hardware Fab/Assy/Configuration | 160d | 2010-10-01 | 2011-05-26 | 1366014, 9-110M | 438d |
| 1366911LOE |  | FY11 Mngmnt Effort for SRFand ARC Vac Controls | 248d | 2010-10-01 | 2011-09-30 | 1366910LOE | 20d |
| 1366020 |  | SRF Vac Controls Sys Installtn Labor FY11 | 88d | 2011-05-27 | 2011-09-30 | 1366015, 1362025 FS-115d | 438d |
| 1366020b |  | SRF Vac Controls Sys Installtn Labor Procurement | 130d | 2011-05-27 | 2011-12-01 | 1362025 FS-115d, 1366015 | 438d |
| 1366025 |  | SRF Vac Controls Software Implementn & Sys Testing FY11 | 83d | 2011-06-06 | 2011-09-30 | 1366020a FS-125d, 1366020b FS-125d | 438d |
| 1366020a |  | SRF Vac Controls Sys Installtn Labor FY12 | 42d | 2011-10-03 | 2011-12-01 | 1366020 | 438d |
| 1366025a |  | SRF Vac Controls Software Implementn & Sys Testing FY12 | 67d | 2011-10-03 | 2012-01-13 | 1366025 | 438d |
| 1366912LOE |  | FY12 Mngmnt Effort for SRFand ARC Vac Controls | 247d | 2011-10-03 | 2012-09-28 | 1366911LOE | 20d |
| 1366030M |  | SRF Vacuum Controls Sys Comp | 0d | 2012-01-13 | 2012-01-13 | 1366025a | 438d |

| ID | WBS | Task | Duration | Start | Finish | Predecessors | Total float |
| --- | --- | --- | --- | --- | --- | --- | --- |
| 1366035 |  | ARC Vac Controls Sys Prcrmnts | 40d | 2012-02-03 | 2012-03-30 | 12166035, 9-120M FS+80d | 355d |
| 1366040 |  | ARC Vac Controls Hardware Fab/Assy/Configuration | 90d | 2012-04-02 | 2012-08-07 | 1366035 | 355d |
| 1366050 |  | ARC Vac Controls Software Implementn & Sys Testing FY12 | 47d | 2012-07-25 | 2012-09-28 | 1366045b FS-55d, 1366047 FS-55d, 1362025, 1366045a FS-55d | 355d |
| 1366045 |  | ARC Vac Controls Sys Installtn FY12 | 37d | 2012-08-08 | 2012-09-28 | 2-02M, 1366040 | 355d |
| 1366045b |  | ARC Vac Controls Sys Installtn Procurement | 45d | 2012-08-08 | 2012-10-10 | 1366040, 2-02M | 355d |
| 1366045a |  | ARC Vac Controls Sys Installtn FY13 | 8d | 2012-10-01 | 2012-10-10 | 1366045 | 355d |
| 1366047 |  | ARC Vac Controls Sys Installtn Additonal effort per 2012 ETC | 8d | 2012-10-01 | 2012-10-10 | 9-130M | 355d |
| 1366050a |  | ARC Vac Controls Software Implementn & Sys Testing FY13 | 23d | 2012-10-01 | 2012-10-31 | 1366050 | 355d |
| 1366055M |  | ARC Vacuum Controls Sys Comp | 0d | 2012-10-31 | 2012-10-31 | 1366050a | 355d |
| 1366950 |  | Re-Baseline Actuals Adjustment | 1d | 2013-08-30 | 2013-08-30 | 9-130M FS+227d | 20d |
| 2366050a |  | ARC Vac Controls Software Implementn | 19d | 2013-09-03 | 2013-09-27 | 9-130M FS+228d | 130d |
| 2366051 |  | ARC Vac Controls Hardware Implementation & Testing | 19d | 2013-09-03 | 2013-09-27 | 2366050a FS-19d | 130d |
| 2366055M |  | ARC Vacuum Controls Sys Comp | 0d | 2013-09-27 | 2013-09-27 | 2366050a, 2366051 | 130d |
|  | 7 | **1.3.6.7 MAGNET INSTRUMENTATION** |  | 2011-10-03 | 2014-02-07 |  |  |
| 1367005 |  | Mag Instrmenttn Prcrmnts | 30d | 2011-10-03 | 2011-11-11 | 9-120M, 12167028 | 185d |
| 1367010 |  | Mag Instrmenttn Fab & Assy | 100d | 2011-11-14 | 2012-04-13 | 1367005 | 185d |
| 1367015 |  | Mag Instrmenttn Testing | 60d | 2012-04-16 | 2012-07-10 | 9-120M, 1367010 | 185d |
| 1367025 |  | Mag Instrmenttn Software Implementn & Cmmssng FY12 | 67d | 2012-06-27 | 2012-09-28 | 1367020b FS-130d, 1362025, 1367020a FS-130d | 185d |
| 1367020 |  | Mag Instrmenttn Implementn FY12 | 57d | 2012-07-11 | 2012-09-28 | 1367015, 1362025 FS-115d | 185d |
| 1367020b |  | Mag Instrmenttn Implementn Procurement | 120d | 2012-07-11 | 2013-01-07 | 1367015, 1362025 FS-115d | 185d |
| 1367020a |  | Mag Instrmenttn Implementn FY13 | 63d | 2012-10-01 | 2013-01-07 | 1367020 | 185d |
| 1367025a |  | Mag Instrmenttn Software Implementn & Cmmssng FY13 | 73d | 2012-10-01 | 2013-01-22 | 1367025 | 185d |
| 1367030 |  | Magnet Communication New I/O IP design - Labor | 60d | 2013-02-01 | 2013-04-26 | 9-130M FS+80d | 33d |
| 1367035 |  | Magnet Communication New I/O IP design - Proc. | 20d | 2013-03-01 | 2013-03-28 | 1367030 FS-41d | 33d |
| 1367040 |  | Magnet Communication New I/O IP Fabrication | 40d | 2013-05-01 | 2013-06-26 | 1367035 FS+23d | 33d |
| 1367045 |  | Magnet Communication New I/O IP Testing | 20d | 2013-06-03 | 2013-06-28 | 1367040 FS-18d | 33d |
| 1367050 |  | Magnet Communication New I/O IP Installation | 20d | 2013-07-01 | 2013-07-29 | 1367045 | 33d |
| 1367055 |  | Magnet Communication New I/O IP Software -Labor | 40d | 2013-07-01 | 2013-08-26 | 1367045 | 34d |
| 1367060 |  | Re-Baseline Actuals Adjustment | 1d | 2013-08-30 | 2013-08-30 | 9-130M FS+227d | 20d |
| 2367025a |  | Mag Instrmenttn Software Implementn & Cmmssng FY13 | 20d | 2013-09-03 | 2013-09-30 | 9-130M FS+228d, 23221024ba FS-198d | 46d |
| 2367030 |  | Magnet Communication New I/O IP design - Labor FY13 | 20d | 2013-09-03 | 2013-09-30 | 9-130M FS+228d | 14d |
| 2367025aa |  | Mag Instrmenttn Software Implementn & Cmmssng FY14 | 83d | 2013-10-01 | 2014-02-07 | 23221024ba FS-198d, 2367025a, 9-130M FS+228d | 46d |
| 2367030a |  | Magnet Communication New I/O IP design - Labor FY14 | 32d | 2013-10-01 | 2013-11-13 | 2367030, 9-130M FS+228d | 14d |
| 2367050 |  | Magnet Communication New I/O IP Installation | 30d | 2013-10-01 | 2013-11-11 | 2367045 FS-31d | 86d |
| 2367055 |  | Magnet Communication New I/O IP Software -Labor | 30d | 2013-10-01 | 2013-11-11 | 2367045 FS-31d | 14d |
| 2367035 |  | Magnet Communication New I/O IP design - Proc. | 31d | 2013-10-02 | 2013-11-13 | 2367030 FS-31d, 2367030a FS-31d | 14d |
| 2367040 |  | Magnet Communication New I/O IP Fabrication | 31d | 2013-10-02 | 2013-11-13 | 2367035 FS-31d | 14d |
| 2367045 |  | Magnet Communication New I/O IP Testing | 30d | 2013-10-02 | 2013-11-12 | 2367040 FS-31d | 14d |
|  | 4 | **1.4 CONSTRUCTION UPGRADE HALLS A, B, & C** |  | 2008-10-01 | 2016-02-03 |  |  |
|  | 1 | **1.4.1 CONSTRUCTION HALL A** |  | 2008-10-01 | 2013-09-30 |  |  |
|  | 1 | **1.4.1.1 MAGNET** |  |  |  |  |  |
|  | 1 | **1.4.1.1.1 COMBINED FUNCTION MAGNET** |  |  |  |  |  |
|  | 2 | **1.4.1.1.2 CRYOGENIC SYSTEM** |  |  |  |  |  |
|  | 3 | **1.4.1.1.3 POWER SUPPLY INFRASTRUCTURE** |  |  |  |  |  |
|  | 4 | **1.4.1.1.4 SHIELD HOUSE** |  |  |  |  |  |
|  | 5 | **1.4.1.1.5 SUPPORT STRUCTURE & MOTION SYSTEM** |  |  |  |  |  |
|  | 6 | **1.4.1.1.6 CONTROL SYSTEM** |  |  |  |  |  |
|  | 7 | **1.4.1.1.7 MAD SEPTUM** |  |  |  |  |  |
|  | 2 | **1.4.1.2 DETECTOR** |  |  |  |  |  |
|  | 1 | **1.4.1.2.1 TRIGGER SYSTEM (Scintillators)** |  |  |  |  |  |
|  | 2 | **1.4.1.2.2 TRACKING SYSTEM (Drift Chambers)** |  |  |  |  |  |
|  | 3 | **1.4.1.2.3 GAS CERENKOV** |  |  |  |  |  |
|  | 4 | **1.4.1.2.4 AEROGEL CERENKOV** |  |  |  |  |  |
|  | 5 | **1.4.1.2.5 CALORIMETER** |  |  |  |  |  |
|  | 6 | **1.4.1.2.6 FOCAL PLANE POLARIMETER** |  |  |  |  |  |
|  | 3 | **1.4.1.3 COMPUTING** |  | 2008-10-01 | 2013-08-30 |  |  |
|  | 1 | **1.4.1.3.1 DAQ FOR MAD** |  |  |  |  |  |
|  | 2 | **1.4.1.3.2 DAQ UPGRADES FOR HRS** |  | 2008-10-01 | 2013-08-30 |  |  |
| 14132909LOE |  | FY09 Proj Admin H-A, All Constrctn (DAQ UPGRADES) | 248d | 2008-10-01 | 2009-09-30 | 122132908LOE | 20d |
| 14132910LOE |  | FY10 Proj Admin H-A, All Constrctn (DAQ UPGRADES) | 248d | 2009-10-01 | 2010-09-30 | 14132909LOE | 20d |
| 14132911LOE |  | FY11 Proj Admin H-A, All Constrctn (DAQ UPGRADES) | 248d | 2010-10-01 | 2011-09-30 | 14132910LOE | 20d |
| 14132018 |  | Proc ADCs, TDCs,¿ (DAQ UPGRADES) | 80d | 2011-01-05 | 2011-04-28 | 9-110M FS+60d | 581d |
| 14132912LOE |  | FY12 Proj Admin H-A, All Constrctn (DAQ UPGRADES) | 247d | 2011-10-03 | 2012-09-28 | 14132911LOE | 20d |
| 14132020 |  | Install Electrnc's (DAQ UPGRADES) | 79d | 2012-01-05 | 2012-04-26 | 14132018, 9-120M FS+60d | 413d |
| 14132913LOE |  | FY13 Proj Admin H-A, All Constrctn (DAQ UPGRADES) | 228d | 2012-10-01 | 2013-08-30 | 14132912LOE | 20d |
|  | 4 | **1.4.1.4 FAST ELECTRONICS** |  |  |  |  |  |
|  | 5 | **1.4.1.5 BEAMLINE** |  | 2011-10-03 | 2013-09-30 |  |  |
|  | 1 | **1.4.1.5.1 MOLLER POLARIMETER** |  | 2011-10-03 | 2013-08-30 |  |  |
| 14151000M |  | Start Moller polarimeter upgrade (MOL POLAR) | 0d | 2011-10-03 | 2011-10-03 | 9-120M | 5d |
| 14151015 |  | Prepare Quadrupole Manufacturing Drawings Package | 15d | 2011-10-03 | 2011-10-21 | 9-120M | 273d |

| ID | WBS | Task | Duration | Start | Finish | Predecessors | Total float |
| --- | --- | --- | --- | --- | --- | --- | --- |
| 14151020 |  | Quadrupole Procurement prep | 56d | 2011-10-24 | 2012-01-20 | 14151015 | 273d |
| 14151005 |  | Proc Compnts - Stands, Magnetic Shield insert,... (MOL POLAR) | 100d | 2011-12-07 | 2012-05-04 | 14151000M FS+45d | 5d |
| 14151025 |  | Quadrupole Contract Support | 157d | 2012-01-23 | 2012-08-31 | 14151020 | 273d |
| 14151030 |  | Vend Fab Quadrupole | 157d | 2012-01-23 | 2012-08-31 | 14151020 | 273d |
| 14151035 |  | Procure/Refurbish Power Supply for Quadrupole | 157d | 2012-01-23 | 2012-08-31 | 14151020 | 273d |
| 14151010 |  | Install Modifications (MOL POLAR) FY12 | 97d | 2012-05-14 | 2012-09-28 | 3P-01M, 2-02M, 14151035 FS-79d, 14151025 FS-79d, 14151030 FS-79d, 14151005 | 272d |
| 14151010a |  | Install Modifications (MOL POLAR) FY13 | 33d | 2012-10-01 | 2012-11-14 | 14151010 | 272d |
| 14151040 |  | Re-Baseline Actuals Adjustment | 1d | 2013-08-30 | 2013-08-30 | 9-130M FS+227d | 20d |
|  | 2 | **1.4.1.5.2 COMPTON POLARIMETER** |  | 2011-10-03 | 2013-09-30 |  |  |
| 14152000M |  | Start Compton upgrade (COMP POLAR) | 0d | 2011-10-03 | 2011-10-03 | 122152020, 9-120M | 90d |
| 14152005 |  | Proc Detector componets (COMP POLAR) | 80d | 2011-10-03 | 2012-02-02 | 14152000M | 272d |
| 14152015 |  | Proc motion sys, Stands & Beam Line (COMP POLAR) | 60d | 2011-10-03 | 2012-01-04 | 14152000M | 90d |
| 14152010 |  | Assemble & Test Detector (COMP POLAR) | 70d | 2012-02-03 | 2012-05-11 | 14152005 | 272d |
| 14152020 |  | Install & Test (COMP POLAR) FY12 | 97d | 2012-05-14 | 2012-09-28 | 14152015, 3P-01M, 2-02M, 14152010 | 272d |
| 14152025 |  | Install & Test (COMP POLAR) FY13 | 33d | 2012-10-01 | 2012-11-14 | 14152020 | 272d |
| 14152030 |  | Re-Baseline Actuals Adjustment | 1d | 2013-08-30 | 2013-08-30 | 9-130M FS+227d | 20d |
| 24152015 |  | Proc motion sys, Stands & Beam Line (COMP POLAR) Re-Baseline Obligation Split | 20d | 2013-09-03 | 2013-09-30 | 9-130M FS+228d | 57d |
| 24152020 |  | Proc motion sys, Stands & Beam Line (COMP POLAR) | 20d | 2013-09-03 | 2013-09-30 | 9-130M FS+228d | 57d |
| 24152025 |  | Install & Test (COMP POLAR) | 20d | 2013-09-03 | 2013-09-30 | 24152020 FS-20d, 24152015 FS-20d | 57d |
|  | 3 | **1.4.1.5.3 MAPPING-ARC ENERGY MEASUREMENT** |  | 2012-05-14 | 2013-09-03 |  |  |
| 14153000M |  | Start Mapper Constr (MAPPER) | 0d | 2012-05-14 | 2012-05-14 | 122153010, 2-02M, 9-110M | 341d |
| 14153010 |  | Calibrate H-A Line Magnets (MAPPER) | 60d | 2012-05-14 | 2012-08-07 | 14153000M, 2-02M | 341d |
| 14153020 |  | Install Mapper & Rebuilt 9th Dipole in Shed (MAPPER) | 1d | 2012-08-08 | 2012-08-08 | 14153010 | 341d |
| 14153025 |  | Re-Baseline Actuals Adjustment | 1d | 2013-08-30 | 2013-08-30 | 9-130M FS+227d | 20d |
| 24153020 |  | Install Rebuilt 9th Dipole in Shed (MAPPER) | 1d | 2013-09-03 | 2013-09-03 | 9-130M FS+228d | 76d |
|  | 6 | **1.4.1.6 INFRASTRUCTURE** |  |  |  |  |  |
|  | 1 | **1.4.1.6.1 ENGINEERING & DESIGN** |  |  |  |  |  |
|  | 2 | **1.4.1.6.2 CABLING** |  |  |  |  |  |
|  | 3 | **1.4.1.6.3 INSTALLATION** |  |  |  |  |  |
|  | 2 | **1.4.2 CONSTRUCTION HALL B** |  | 2008-10-01 | 2016-01-28 |  |  |
|  | 1 | **1.4.2.1 MAGNET** |  | 2009-01-02 | 2013-09-30 |  |  |
|  | 1 | **1.4.2.1.1 TOROIDAL MAGNET** |  | 2009-01-02 | 2013-09-30 |  |  |
| 14211009E |  | Torus FY09 Travel | 189d | 2009-01-02 | 2009-09-30 | 14211009EX | 0d |
| 14211004 |  | Torus Vend Comp Dsgn & Fab FY09 Original Labor Initial | 167d | 2009-01-05 | 2009-08-31 | 14211000MX, 14211002X FS+1d | 830d |
| 14211004A |  | Torus Vend Comp Dsgn & Fab FY09 Original Labor Final | 21d | 2009-09-01 | 2009-09-30 | 9-090M FS+227d | 752d |
| 14211030 |  | Vend Fab Torus - Completion of System Requirements Review (SRR) | 40d | 2009-09-04 | 2009-10-30 | 9-090M FS+230d | 1220d |
| 14211035 |  | Vend Fab Torus - Completion of Preliminary Design Review | 76d | 2009-09-04 | 2009-12-30 | 14211030 FS-40d | 1220d |
| 14211040 |  | Vend Fab Torus - Superconductor Production | 96d | 2009-09-04 | 2010-01-29 | 14211035 FS-76d | 1220d |
| 14211045 |  | Vend Fab Torus - Completion of Preliminary Design Review and Manufacturing Readiness Review | 115d | 2009-09-04 | 2010-02-26 | 14211040B FS-288d, 14211040A FS-116d, 14211040 FS-116d | 1200d |
| 14211004B |  | Torus Vend Comp Dsgn & Fab FY10 Original Labor | 57d | 2009-10-01 | 2009-12-29 | 14211004A | 752d |
| 14211010E |  | Torus FY10 Travel | 248d | 2009-10-01 | 2010-09-30 | 14211009E | 0d |
| 14211040C |  | Vend Fab Torus -Solder Stabilizer Production | 367d | 2009-11-02 | 2011-04-29 | 14211040B FS-247d | 1155d |
| 14211050 |  | Vend Fab Torus -Design and Construction of Prototype Coil (Full Size) | 304d | 2009-11-02 | 2011-01-31 | 14211045 FS-75d, 14211045D FS-340d, 14211045A FS-76d | 1200d |
| 14211050A |  | Vend Fab Torus - Testing of Prototype Coil (Full Size) | 346d | 2009-11-02 | 2011-03-31 | 14211045A FS-76d, 14211045D FS-340d, 14211045 FS-75d | 1200d |
| 14211050Ab |  | Vend Fab Torus - Stability Model Coil test | 367d | 2009-11-02 | 2011-04-29 | 14211050A FS-346d | 1319d |
| 14211050Ac |  | Vend Fab Torus - UG&GUG Duties | 323d | 2009-11-02 | 2011-02-28 | 14211050Ab FS-367d | 1319d |
| 14211050Ad |  | Vend Fab Torus - Coil Case Plates-Mill run Phase 2 Funding | 346d | 2009-11-02 | 2011-03-31 | 14211050Ac FS-323d | 1319d |
| 14211055 |  | Vend Fab Torus -Complete and Warm Test Coil #1 | 532d | 2009-11-02 | 2011-12-30 | 14211050 FS-304d, 14211050A FS-346d | 1200d |
| 14211060 |  | Vend Fab Torus -Complete and Warm Test Coil #2 | 572d | 2009-11-02 | 2012-02-29 | 14211055 FS-532d | 1200d |
| 14211010 |  | Torus Vend Coil Winding Original Labor FY10 | 188d | 2010-01-05 | 2010-09-30 | 14211004, 14211004B, 9-100M FS+60d | 749d |
| 14211015 |  | Torus Vend Compnts Fab Original Labor FY10 | 188d | 2010-01-05 | 2010-09-30 | 14211004, 14211004B, 9-100M FS+60d | 749d |
| 14211040A |  | Vend Fab Torus - Superconductor Production Reverse Entry per CR10-044 | 1d | 2010-03-01 | 2010-03-01 | 9-100M FS+97d | 1200d |
| 14211040B |  | Vend Fab Torus - Superconductor Production Revised Delivery per CR10-044 | 172d | 2010-03-01 | 2010-10-29 | 9-100M FS+97d | 1155d |
| 14211045A |  | Vend Fab Torus - Completion of Preliminary Design Review and Manufacturing Readiness Review Reverse Entry per CR10-044 | 1d | 2010-03-01 | 2010-03-01 | 9-100M FS+97d | 1200d |
| 14211045B |  | Vend Fab Torus - Completion of IDR Revised Delivery per CR10-044 | 172d | 2010-03-01 | 2010-10-29 | 9-100M FS+97d | 1236d |
| 14211045C |  | Vend Fab Torus - Completion of FDR Revised Delivery per CR10-044 | 229d | 2010-03-01 | 2011-01-31 | 9-100M FS+97d, 14211045B FS-172d | 1236d |
| 14211045D |  | Vend Fab Torus - Completion Manufacturing Readiness ReviewRevised Delivery per CR10-044 | 229d | 2010-03-01 | 2011-01-31 | 9-100M FS+97d, 14211045C FS-229d | 1236d |
| 14211010a |  | Torus Vend Coil Winding Original Labor FY11 | 57d | 2010-10-01 | 2010-12-29 | 14211010 | 749d |
| 14211011E |  | Torus FY11 Travel | 248d | 2010-10-01 | 2011-09-30 | 14211010E | 0d |
| 14211015a |  | Torus Vend Compnts Fab Original Labor FY11 | 57d | 2010-10-01 | 2010-12-29 | 14211015 | 749d |
| 14211050AdA |  | Vend Fab Torus - Coil Case Plates-Mill run Phase 3 Funding | 99d | 2010-11-01 | 2011-03-31 | 14211050Ad FS-99d | 1319d |
| 14211051 |  | Vend Fab Torus - Coil Case Plates-CNC machining | 206d | 2010-11-01 | 2011-08-31 | 14211050AdA FS-99d | 1319d |
| 14211051a |  | Vend Fab Torus - He tracing Tube - OFHC | 206d | 2010-11-01 | 2011-08-31 | 14211051 FS-206d | 1319d |
| 14211051b |  | Vend Fab Torus - Torus Vac Vessel Plate-Mill run | 206d | 2010-11-01 | 2011-08-31 | 14211051a FS-206d | 1319d |
| 14211051c |  | Vend Fab Torus - Nitrogen tracing tube | 206d | 2010-11-01 | 2011-08-31 | 14211051b FS-206d | 1319d |
| 14211051d |  | Vend Fab Torus - Torus Vac Vessel Plate-CNC machining | 206d | 2010-11-01 | 2011-08-31 | 14211051c FS-206d | 1319d |
| 14211051f |  | Vend Fab Torus - Torus Coil Hub&Machining | 206d | 2010-11-01 | 2011-08-31 | 14211051d FS-206d | 1319d |
| 14211051g |  | Vend Fab Torus - Cryogenic Control Valves | 206d | 2010-11-01 | 2011-08-31 | 14211051f FS-206d | 1319d |
| 14211051h |  | Vend Fab Torus - Current Leads | 206d | 2010-11-01 | 2011-08-31 | 14211051g FS-206d | 1319d |
| 14211051j |  | Vend Fab Torus - Instrumentation Sensors | 206d | 2010-11-01 | 2011-08-31 | 14211051h FS-206d | 1319d |

| ID | WBS | Task | Duration | Start | Finish | Predecessors | Total float |
| --- | --- | --- | --- | --- | --- | --- | --- |
| 14211051k |  | Vend Fab Torus - Dump Switch | 206d | 2010-11-01 | 2011-08-31 | 14211051j FS-206d | 1319d |
| 14211051n |  | Vend Fab Torus - PLC&Cabinets | 206d | 2010-11-01 | 2011-08-31 | 14211051k FS-206d | 1319d |
| 14211051o |  | Vend Fab Torus - Cold Mass Suspension Materials | 206d | 2010-11-01 | 2011-08-31 | 14211051n FS-206d | 1319d |
| 14211065 |  | Vend Fab Torus -Complete and Warm Test Coil #3 | 325d | 2010-11-01 | 2012-02-29 | 14211060 FS-325d | 1200d |
| 14211070 |  | Vend Fab Torus -Complete and Warm Test Coil #4 | 325d | 2010-11-01 | 2012-02-29 | 14211065 FS-325d | 1200d |
| 14211075 |  | Vend Fab Torus -Complete and Warm Test Coil #5 | 325d | 2010-11-01 | 2012-02-29 | 14211070 FS-325d | 1200d |
| 14211080 |  | Vend Fab Torus -Complete and Warm Test Coil #6 | 325d | 2010-11-01 | 2012-02-29 | 14211075 FS-325d | 1200d |
| 14211020 |  | Torus Vend Contract Support Labor FY11 | 188d | 2011-01-05 | 2011-09-30 | 9-110M FS+60d, 14211010a, 14211015a | 746d |
| 14211012E |  | Torus FY12 Travel | 247d | 2011-10-03 | 2012-09-28 | 14211011E | 0d |
| 14211020a |  | Torus Vend Contract Support Labor FY12 | 57d | 2011-10-03 | 2011-12-29 | 14211020 | 746d |
| 14211025 |  | Torus Delivery Installtn & Check-out Original Labor FY12 | 187d | 2012-01-05 | 2012-09-28 | 14211020a, 9-120M FS+60d | 743d |
| 14211085 |  | Reverse Entry per CR12-024 | 18d | 2012-02-03 | 2012-02-29 | 9-120M FS+80d | 149d |
| 14211025a |  | Torus Delivery Installtn & Check-out Original Labor FY13 | 58d | 2012-10-01 | 2012-12-21 | 14211025 | 743d |
| 14211095 |  | Re-Baseline Actuals Adjustment | 1d | 2013-08-30 | 2013-08-30 | 9-130M FS+227d | 20d |
| 24211090 |  | Wang Torus Settlement | 20d | 2013-09-03 | 2013-09-30 | 9-130M FS+228d | 801d |
| 24211095 |  | Wang Torus Settlement Final | 20d | 2013-09-03 | 2013-09-30 | 9-130M FS+228d | 801d |
|  | 2 | **1.4.2.1.2 SOLENOID** |  | 2009-01-02 | 2013-09-30 |  |  |
| 14212009E |  | Solenoid FY09 Travel | 189d | 2009-01-02 | 2009-09-30 | 14212009EX | 19d |
| 14212005 |  | Solenoid Vend Comp Dsgn Labor FY09 | 188d | 2009-01-05 | 2009-09-30 | 14212002X FS+1d | 19d |
| 14212005b |  | Solenoid Vend Comp Dsgn Labor FY10 | 57d | 2009-10-01 | 2009-12-29 | 14212005 | 19d |
| 14212010E |  | Solenoid FY10 Travel | 248d | 2009-10-01 | 2010-09-30 | 14212009E | 19d |
| 14212005c |  | Vend Fab Solenoid Peg Point #1 Completion of System Requirements Review (SSR) | 22d | 2009-11-20 | 2009-12-30 | 14212002X FS+1d, 9-100M FS+36d | 1200d |
| 14212005d |  | Vend Fab Solenoid Peg Point #2 Completion of Preliminary Design Review | 61d | 2009-11-20 | 2010-02-26 | 14212005c FS-22d | 1200d |
| 14212005f |  | Vend Fab Solenoid Peg Point #3 Design, Construction and Testing of Prototype Testcoil | 253d | 2009-11-20 | 2010-11-30 | 14212005dB FS-193d, 14212005dA FS-62d, 14212005d FS-61d | 1200d |
| 14212005g |  | Vend Fab Solenoid Peg Point #4 Intermediate Design Review | 270d | 2009-11-20 | 2010-12-30 | 14212005f FS-253d | 1200d |
| 14212005h |  | Vend Fab Solenoid Peg Point #5 Final Design Review | 309d | 2009-11-20 | 2011-02-28 | 14212005g FS-270d | 1200d |
| 14212005j |  | Vend Fab Solenoid Peg Point #6A Manufacturing Readiness Review Phase 1 | 373d | 2009-11-20 | 2011-05-27 | 14212005h FS-309d | 1200d |
| 14212005jA |  | Vend Fab Solenoid Peg Point #6B Manufacturing Readiness Review Phase 2 | 416d | 2009-11-20 | 2011-07-29 | 14212005j FS-373d | 1200d |
| 14212005k |  | Vend Fab Solenoid Peg Point #7 Complete Winding & Coil Assembly of First set coils (1 to 6 modules) | 557d | 2009-11-20 | 2012-02-28 | 14212005jA FS-416d | 1200d |
| 14212005kA |  | Vend Fab Solenoid Peg Point #18 Miscellaneous Materials Procurements Phase 1 | 501d | 2009-11-20 | 2011-11-30 | 14212005k FS-557d | 1200d |
| 14212007 |  | Solenoid Vend Comp Dsgn & Prcrmnt Original Labor FY10 | 191d | 2009-12-30 | 2010-09-30 | 14212005b, 9-100M | 19d |
| 14212005dA |  | Vend Fab Solenoid Peg Point #2 Completion of Preliminary Design Review Reverse Entry per CR10-044 | 1d | 2010-03-01 | 2010-03-01 | 9-100M FS+97d | 1200d |
| 14212005dB |  | Vend Fab Solenoid Peg Point #2 Completion of Preliminary Design Review Revised Delivery per CR10-044 | 130d | 2010-03-01 | 2010-08-31 | 9-100M FS+97d | 1202d |
| 14212007a |  | Solenoid Vend Comp Dsgn & Prcrmnt Original Labor FY11 | 57d | 2010-10-01 | 2010-12-29 | 14212007 | 19d |
| 14212011E |  | Solenoid FY11 Travel | 248d | 2010-10-01 | 2011-09-30 | 14212010E | 19d |
| 14212010 |  | Solenoid Vend Coil Winding Original Labor FY11 | 191d | 2010-12-30 | 2011-09-30 | 14212007a | 19d |
| 14212015 |  | Solenoid Vend Compnts Fab Original Labor FY11 | 191d | 2010-12-30 | 2011-09-30 | 14212007a | 19d |
| 14212005kA5 |  | Vend Fab Solenoid Peg Point #18a Miscellaneous Materials Procurements Phase 2 | 211d | 2011-02-01 | 2011-11-30 | 14212005kA FS-211d | 1200d |
| 14212005n |  | Vend Fab Solenoid Peg Point #8 Mid-Term Manufacturing Progress Review | 268d | 2011-02-01 | 2012-02-29 | 14212005kA5 FS-211d | 1200d |
| 14212005o |  | Vend Fab Solenoid Peg Point #9 Complete Winding & Coil Assembly of Second set coils (7 to 12 modules) | 268d | 2011-02-01 | 2012-02-29 | 14212005n FS-268d | 1200d |
| 14212005p |  | Vend Fab Solenoid Peg Point #10 Complete Winding & Coil Assembly of Third set coils (13 to 19 modules) | 268d | 2011-02-01 | 2012-02-29 | 14212005o FS-268d | 1200d |
| 14212005q |  | Vend Fab Solenoid Peg Point #11 Complete Instrumentation and Control | 268d | 2011-02-01 | 2012-02-29 | 14212005p FS-268d | 1200d |
| 14212005r |  | Vend Fab Solenoid Peg Point #12 Complete Subcontractor Acceptance Test Readiness Review | 268d | 2011-02-01 | 2012-02-29 | 14212005q FS-268d | 1200d |
| 14212005s |  | Vend Fab Solenoid Peg Point #13 Complete Cryogenic Reservoir Subassembly Phase 1 | 268d | 2011-02-01 | 2012-02-29 | 14212005r FS-268d | 1200d |
| 14212010a |  | Solenoid Vend Coil Winding Original Labor FY12 | 57d | 2011-10-03 | 2011-12-29 | 14212010 | 19d |
| 14212012E |  | Solenoid FY12 Travel | 228d | 2011-10-03 | 2012-08-31 | 14212011E | 19d |
| 14212015a |  | Solenoid Vend Compnts Fab Original Labor FY12 | 57d | 2011-10-03 | 2011-12-29 | 14212015 | 19d |
| 14212020 |  | Solenoid Vend Assy & Testing Original Labor | 61d | 2011-11-23 | 2012-02-29 | 9-120M FS+22d, 14212015a FS-20d, 14212010a FS-20d | 19d |
| 14212005sA |  | Reverse Entry per CR12-024 | 18d | 2012-02-03 | 2012-02-29 | 9-120M FS+80d | 149d |
| 14212025 |  | Solenoid Delivery & Qualification Check-out Original Labor | 130d | 2012-03-01 | 2012-08-31 | 14212020 | 19d |
| 14212030 |  | Re-Baseline Actuals Adjustment | 1d | 2013-08-30 | 2013-08-30 | 9-130M FS+227d | 20d |
| 24212000 |  | Wang Solenoid Settlement | 20d | 2013-09-03 | 2013-09-30 | 9-130M FS+228d | 801d |
| 24212005 |  | Wang Solenoid Settlement Final | 20d | 2013-09-03 | 2013-09-30 | 9-130M FS+228d | 801d |
|  | 2 | **1.4.2.2 DETECTORS** |  | 2008-10-01 | 2015-08-04 |  |  |
|  | 1 | **1.4.2.2.1 TRACKING** |  | 2008-10-01 | 2015-04-01 |  |  |
|  | 1 | **1.4.2.2.1.1 SILICON DETECTOR** |  | 2009-10-01 | 2014-12-12 |  |  |
| 142211010E |  | SVT-FY10 Travel | 248d | 2009-10-01 | 2010-09-30 | 9-100M | 20d |
| 142211005 |  | SVT-P-#1 Daq Production, Silicon Sensor Assys Labor FY10 | 226d | 2009-11-02 | 2010-09-30 | 12222015M, 9-100M FS+22d, 12222000a | 539d |
| 142211004 |  | SVT Assembly Area & Clean Room | 163d | 2010-08-02 | 2011-03-31 | 9-100M FS+205d | 543d |
| 142211005a |  | SVT-P-#1 Daq Production, Silicon Sensor Assys Labor FY11 | 124d | 2010-10-01 | 2011-04-06 | 12222015M, 12222000a, 9-100M FS+22d, 142211005 | 539d |
| 142211011E |  | SVT-FY11 Travel | 248d | 2010-10-01 | 2011-09-30 | 142211010E | 20d |
| 142211005b |  | Vend Fab SVT Barrel Sensors Layers 1-3 Peg Point #1 NRE for Hybrid Mask | 33d | 2010-12-07 | 2011-01-31 | 12222015M, 9-110M FS+45d, 12222000a | 20d |
| 142211005c |  | Vend Fab SVT Barrel Sensors Layers 1-3 Peg Point #2 NRE for Intermediate Mask | 33d | 2010-12-07 | 2011-01-31 | 142211005b FS-33d | 20d |
| 142211005d |  | Vend Fab SVT Barrel Sensors Layers 1-3 Peg Point #3 NRE for FAR Mask | 33d | 2010-12-07 | 2011-01-31 | 142211005c FS-33d | 20d |
| 142211005f |  | Vend Fab SVT Barrel Sensors Layers 1-3 Peg Point #4 NRE for Mask Redesign | 33d | 2010-12-07 | 2011-01-31 | 142211005d FS-33d | 20d |
| 142211005g |  | Vend Fab SVT Barrel Sensors Layers 1-3 Peg Point #5 Hybrid Wafers Qty 3 | 117d | 2010-12-07 | 2011-05-31 | 142211005f FS-33d | 20d |
| 142211005h |  | Vend Fab SVT Barrel Sensors Layers 1-3 Peg Point #6 Intermediate Wafers Qty 3 | 117d | 2010-12-07 | 2011-05-31 | 142211005g FS-117d | 20d |
| 142211005j |  | Vend Fab SVT Barrel Sensors Layers 1-3 Peg Point #7 FAR Wafers Qty 3 | 117d | 2010-12-07 | 2011-05-31 | 142211005h FS-117d | 20d |
| 142211005k |  | Vend Fab SVT Barrel Sensors Layers 1-3 Peg Point #8 Hybrid Sensors Qty 120 | 431d | 2010-12-07 | 2012-08-31 | 142211005j FS-117d | 20d |
| 142211005n |  | Vend Fab SVT Barrel Sensors Layers 1-3 Peg Point #9 Intermediate Sensors Qty 120 | 431d | 2010-12-07 | 2012-08-31 | 142211005k FS-431d | 187d |

| ID | Task | Duration | Start | Finish | Predecessors | Total float |
| --- | --- | --- | --- | --- | --- | --- |
| 142211005p | Vend Fab SVT Barrel Sensors Layers 1-3 Peg Point #7 FAR Sensors Qty 120 | 431d | 2010-12-07 | 2012-08-31 | 142211005n FS-431d | 187d |
| 142211020 | SVT-Production R1, R2, R3 Stave Barrel & Wedge Assy (Frozen by CR11-005) | 120d | 2011-02-09 | 2011-07-29 | 142211005a FS-40d, 142211005b FS-40d, 9-110M FS+63d, 142211005 FS-40d | 539d |
| 142211004a | Room Preperation and Finishes EEL230 | 23d | 2011-03-01 | 2011-03-31 | 9-110M FS+97d | 148d |
| 142211105 | SVT Clean Room Purchase | 107d | 2011-03-01 | 2011-07-29 | 9-110M FS+97d | 539d |
| 142211105a | SVT Clean Room Electrical | 107d | 2011-03-01 | 2011-07-29 | 142211105 FS-107d | 539d |
| 142211105b | SVT Clean Room Data/Comm | 107d | 2011-03-01 | 2011-07-29 | 142211105a FS-107d | 539d |
| 142211105c | SVT Clean Room Demo/Interior Finishes | 107d | 2011-03-01 | 2011-07-29 | 142211105b FS-107d | 539d |
| 142211105d | SVT Clean Room Mechanicals | 107d | 2011-03-01 | 2011-07-29 | 142211105c FS-107d | 539d |
| 142211105f | SVT Clean Room Sprinklers | 107d | 2011-03-01 | 2011-07-29 | 142211105d FS-107d | 539d |
| 142211105g | SVT Clean Room Moving Expenses | 107d | 2011-03-01 | 2011-07-29 | 142211105f FS-107d | 539d |
| 142211105h | SVT Clean Room Furniture | 107d | 2011-03-01 | 2011-07-29 | 142211105g FS-107d | 539d |
| 142211010 | SVT-P-#2 Daq Production, Silicon Sensor Assys (Frozen by CR11-005) | 80d | 2011-04-07 | 2011-07-29 | 142211005, 142211005a, 142211005b, 142211004 | 539d |
| 142211010a | Reverse Entry per CR11-005 | 5d | 2011-08-01 | 2011-08-05 | 9-110M FS+204d | 39d |
| 142211020a | Reverse Entry per CR11-005 | 5d | 2011-08-01 | 2011-08-05 | 9-110M FS+204d | 39d |
| 142211109M | HBI - 2011 Replan - Milestone | 0d | 2011-08-01 | 2011-08-01 | 9-110M FS+204d | 20d |
| 142211110 | BST R1-R3 Collab-MSU - Contract award for full chain test, 1st article - Proc | 371d | 2011-08-01 | 2013-01-31 | 142211109M | 168d |
| 142211120 | HBI - SVT Engineering and Construction Oversight FY11 | 44d | 2011-08-01 | 2011-09-30 | 142211109M | 20d |
| 142211140 | BST R1-R3 HBI - 1 ASIC: ASIC production: testing, and dicing - Proc | 128d | 2011-08-01 | 2012-02-08 | 142211109M | 197d |
| 142211145 | BST R1-R3 HBI - 2 Sensors: Sensors received and inspected by JLab (1st article and production) - Labor FY11 | 44d | 2011-08-01 | 2011-09-30 | 142211005j FS+42d, 142211005h, 142211005g | 21d |
| 142211155 | BST FNAL - Contract Preparations | 43d | 2011-08-01 | 2011-09-29 | 142211109M | 21d |
| 142211165 | BST R1-R3 HBI - 3: Modules: DAq development front end electronics (1st article) - Labor FY11 | 44d | 2011-08-01 | 2011-09-30 | 142211109M | 20d |
| 142211170 | BST R1-R3 HBI - 4: DAq: 1st article software - Labor FY11 | 44d | 2011-08-01 | 2011-09-30 | 142211109M | 20d |
| 142211185 | BST R1-R3 HBI - 5 Electronics: Pitch Adapter - Proc (Full set for 1st article, R1-R3, R4) | 128d | 2011-08-01 | 2012-02-08 | 142211109M | 411d |
| 142211190 | BST R1-R3 HBI - 5 Electronics: HFCB validation tests (1st article) - Proc | 128d | 2011-08-01 | 2012-02-08 | 142211109M | 197d |
| 142211195 | BST R1-R3 HBI - 6: Cable assemblies: HV, LV, and data (1) specifications and procurement prep - Labor FY11 | 44d | 2011-08-01 | 2011-09-30 | 142211109M | 251d |
| 142211215 | BST R1-R3 HBI - 7 Sloco: HV, LV, PS (1) module components and crates specs and procurement prep - Labor FY11 | 44d | 2011-08-01 | 2011-09-30 | 142211109M | 83d |
| 142211235 | BST R1-R3 HBI - 8 DAq: VME: (1) specification and procurement preparation - Labor | 23d | 2011-08-01 | 2011-08-31 | 142211109M | 297d |
| 142211280 | BST R1-R3 MECH GRP - Modules: 1st article backing structure manufacturing drawing - Labor | 42d | 2011-08-01 | 2011-09-28 | 142211109M | 421d |
| 142211285 | BST R1-R3 MECH GRP - Modules: 1st article cold plate manufacturing drawing - Labor FY11 | 44d | 2011-08-01 | 2011-09-30 | 142211109M | 226d |
| 142211305 | BST R1-R3 MECH GRP - Support structure for cold plate 1st article tests: Manufacturing Drawings - Labor | 30d | 2011-08-01 | 2011-09-12 | 142211109M | 286d |
| 142211150 | BST R1-R3 HBI - 2 Sensors: Sensors shipped to FNAL (1st article) | 21d | 2011-08-05 | 2011-09-02 | 142211145aa FS-310d, 142211005j | 21d |
| 142211115 | HBI - Hardware infrastructure: configuring and installing- Labor FY11 | 23d | 2011-08-30 | 2011-09-30 | 142211109M FS+21d | 411d |
| 142211158M | BST FNAL - 1st article & production SOW Agreement signed (milestone) | 0d | 2011-09-01 | 2011-09-01 | 9-110M FS+227d | 21d |
| 142211160 | FNAL/Jlab/MSU Testing of 1st article sensors | 79d | 2011-09-01 | 2011-12-30 | 142211158M, 142211155 FS-20d | 21d |
| 142211160a | FNAL Module Design Review | 42d | 2011-09-01 | 2011-10-31 | 142211160 FS-79d | 21d |
| 142211160b | FNAL Module Design Report & Recommendations | 42d | 2011-09-01 | 2011-10-31 | 142211160a FS-42d | 21d |
| 142211160c | FNAL/Jlab Develop Module Construction, Assembly, & QA/QC procedures | 62d | 2011-09-01 | 2011-11-30 | 142211160b FS-42d | 21d |
| 142211160d | FNAL Construction & Testing (FNAL/Jlab) of 1st article electrical grade modules | 62d | 2011-09-01 | 2011-11-30 | 142211150 FS-2d, 142211160c FS-62d | 21d |
| 142211160f | FNAL Design of Assembly Fixtures (6.5 months) | 268d | 2011-09-01 | 2012-09-28 | 142211160d FS-62d | 21d |
| 142211160g | FNAL Receive & test (Jlab/FNAL) R1-R3 Production Sensors (4 batches) Part A | 327d | 2011-09-01 | 2012-12-31 | 142211005k FS-250d, 142211160f FS-268d | 31d |
| 142211240 | BST R1-R3 HBI - 8 DAq: VME: (2) crates and cards - Proc | 21d | 2011-09-01 | 2011-09-30 | 142211235 | 297d |
| 142211310 | BST R1-R3 MECH GRP - Support structure for cold plate 1st article tests: procurement prep - Labor FY11 | 14d | 2011-09-13 | 2011-09-30 | 142211305 | 286d |
| 142211012E | SVT-FY12 Travel | 247d | 2011-10-03 | 2012-09-28 | 142211011E, 142211004a | 20d |
| 142211115a | HBI - Hardware infrastructure: configuring and installing- Labor FY12 | 84d | 2011-10-03 | 2012-02-08 | 142211115 | 411d |
| 142211125 | HBI - SVT Engineering and Construction Oversight FY12 | 247d | 2011-10-03 | 2012-09-28 | 142211120 | 20d |
| 142211145a | BST R1-R3 HBI - 2 Sensors: Sensors received and inspected by JLab (1st article and production) - Labor FY12 | 247d | 2011-10-03 | 2012-09-28 | 142211145 | 21d |
| 142211165a | BST R1-R3 HBI - 3: Modules: DAq development front end electronics (1st article) - Labor FY12 | 162d | 2011-10-03 | 2012-05-30 | 142211165 | 20d |
| 142211170a | BST R1-R3 HBI - 4: DAq: 1st article software - Labor FY12 | 160d | 2011-10-03 | 2012-05-25 | 142211170 | 20d |
| 142211195a | BST R1-R3 HBI - 6: Cable assemblies: HV, LV, and data (1) specifications and procurement prep - Labor FY12 | 15d | 2011-10-03 | 2011-10-21 | 142211195 | 251d |
| 142211215a | BST R1-R3 HBI - 7 Sloco: HV, LV, PS (1) module components and crates specs and procurement prep - Labor FY12 | 84d | 2011-10-03 | 2012-02-08 | 142211215 | 83d |
| 142211245 | BST R1-R3 HBI - 8 DAq: VME: (3) 1st article testing - Labor | 86d | 2011-10-03 | 2012-02-10 | 142211240 | 297d |
| 142211260 | BST R1-R3 HBI - 9 DAq-SCM (1) components and PCBs: specification and procurement prep - Labor | 58d | 2011-10-03 | 2011-12-30 | 142211109M, 9-120M | 168d |
| 142211265 | BST R1-R3 HBI - 9 DAq-SCM (2) system for 1st article - Proc | 58d | 2011-10-03 | 2011-12-30 | 142211260 FS-58d | 168d |
| 142211285a | BST R1-R3 MECH GRP - Modules: 1st article cold plate manufacturing drawing - Labor FY12 | 40d | 2011-10-03 | 2011-11-29 | 142211285 | 226d |
| 142211310a | BST R1-R3 MECH GRP - Support structure for cold plate 1st article tests: procurement prep - Labor FY12 | 7d | 2011-10-03 | 2011-10-11 | 142211310 | 286d |
| 142211315 | BST R1-R3 MECH GRP - Support structure to hold 1st article tests for cold plate: (1) procurement - Proc | 44d | 2011-10-12 | 2011-12-14 | 142211310a | 286d |
| 142211200 | BST R1-R3 HBI - 6: Cable assemblies: HV, LV, and data (3) assemble components for fabrication - Labor | 61d | 2011-10-24 | 2012-01-27 | 142211195a | 251d |
| 142211205 | BST R1-R3 HBI - 6: Cable assemblies: HV, LV, and data (4) 1st article - Proc | 61d | 2011-10-24 | 2012-01-27 | 142211200 FS-61d | 251d |
| 142211325 | BST R1-R3 MECH GRP - Modules:for assy 1st article BST, mounting, and alignment fixture -mfg dwgs | 43d | 2011-10-31 | 2012-01-09 | 142211285a FS-20d, 142211280 FS-162d | 237d |
| 142211290 | BST R1-R3 MECH GRP - Cold plate 1st article model: procurement prep - Labor | 21d | 2011-11-30 | 2012-01-05 | 142211285a | 226d |
| 142211320 | BST R1-R3 MECH GRP - Support structure to hold 1st art. tests for cold plate (2) constr/assem (for burn-in tests) - Lab | 46d | 2011-12-15 | 2012-02-28 | 142211315 | 286d |
| 142211405 | BST R1-R3 MECH GRP - Protective enclosure system (1) Manufacturing Drawings - Labor | 32d | 2011-12-16 | 2012-02-08 | 142211109M FS+96d | 371d |
| 142211450 | BST R1-R3 MECH GRP - Cooling system: preparation, manufacturing drawings - Labor | 50d | 2011-12-29 | 2012-03-12 | 142211109M FS+100d | 217d |
| 142211160h | FNAL Receive & test (Jlab/FNAL) R1-R3 Production Sensors (4 batches) Part B | 229d | 2012-01-31 | 2012-12-31 | 142211160g FS-240d, 142211005k FS-151d | 20d |
| 142211160j | FNAL QA/QC and Assembly of Fixtures | 250d | 2012-01-31 | 2013-01-31 | 142211160h FS-229d, 142211255a FS-151d, 142211255 FS-151d | 20d |
| 142211160k | FNAL Construction of 1st article (mechanical grade) modules | 250d | 2012-01-31 | 2013-01-31 | 142211160j FS-250d | 20d |
| 142211160n | FNAL design and construct module shipping containers | 250d | 2012-01-31 | 2013-01-31 | 142211160k FS-250d | 20d |
| 142211160p | FNAL/Jlab/MSU Testing of 1st article (mechanical grade) modules | 250d | 2012-01-31 | 2013-01-31 | 142211180 FS-127d, 142211160n FS-250d, 142211165a FS-85d | 20d |
| 142211160q | FNAL/Jlab review of module testing | 250d | 2012-01-31 | 2013-01-31 | 142211160p FS-250d | 20d |
| 142211160r | FNAL/Jlab revise module construction & assembly & QA/QC procedures | 250d | 2012-01-31 | 2013-01-31 | 142211160q FS-250d | 20d |

| ID | Task | Duration | Start | Finish | Predecessors | Total float |
| --- | --- | --- | --- | --- | --- | --- |
| 142211160s | FNAL QA/QC and assembly of production fixtures | 250d | 2012-01-31 | 2013-01-31 | 142211160r FS-250d | 20d |
| 142211160t | FNAL Construction and test (Jlab/FNAL) of R1-R3 production modules (60 modules) Part A | 398d | 2012-01-31 | 2013-08-30 | 142211160s FS-250d | 20d |
| 142211385 | BST R1-R3 HBI - 7 Sloco: Slow controls and charge calibration system: (1) specification and procurement prep - Labor | 58d | 2012-02-09 | 2012-05-01 | 142211160, 142211190 | 253d |
| 142211410 | BST R1-R3 MECH GRP - Protective enclosure system (1) specifications and procurement prep - Labor | 40d | 2012-02-09 | 2012-04-05 | 142211405 | 371d |
| 142211455 | BST R1-R3 MECH GRP - Cooling system: preparation, procurement prep- Labor | 20d | 2012-03-13 | 2012-04-09 | 142211450 | 217d |
| 142211270 | BST R1-R3 HBI - 9 DAq-SCM (3) custom crate fabrication and 1st article testing - Labor | 40d | 2012-04-03 | 2012-05-29 | 9-120M FS+121d, 142211265 | 105d |
| 142211275 | BST R1-R3 HBI - 9 DAq-SCM (4) develop program and test (1/2) - Labor FY12 | 126d | 2012-04-03 | 2012-09-28 | 142211270 FS-40d | 105d |
| 142211295 | BST R1-R3 MECH GRP - Cold plate 1st article tests: (1) procurement - Proc | 58d | 2012-04-06 | 2012-06-28 | 142211290, 9-120M FS+124d | 163d |
| 142211330 | BST R1-R3 MECH GRP - Modules:for assy 1st article BST, mounting, and alignment fixture - proc prep - Labor | 21d | 2012-04-10 | 2012-05-08 | 142211325, 9-120M FS+126d | 174d |
| 142211460 | BST R1-R3 MECH GRP - Cooling system: procurement - proc | 40d | 2012-04-10 | 2012-06-06 | 142211455 | 217d |
| 142211210 | BST R1-R3 HBI - 6: Cable assemblies: HV, LV, and data (5) 1st article testing - Labor | 64d | 2012-04-30 | 2012-07-30 | 9-120M FS+140d, 142211205 | 187d |
| 142211430 | BST R1-R3 HBI - 7 Sloco-Slow controls charge calibration system: develop slow controls (2/2) - Labor | 100d | 2012-05-02 | 2012-09-21 | 142211385 | 253d |
| 142211220 | BST R1-R3 HBI - 7 Sloco: HV, LV, PS (2) modules 1st article - Proc | 65d | 2012-05-09 | 2012-08-09 | 142211215a, 9-120M FS+147d | 20d |
| 142211335 | BST R1-R3 MECH GRP - Modules: round table, mounting, and alignment fixture (1) procurement - Proc | 100d | 2012-05-09 | 2012-09-28 | 142211330 | 174d |
| 142211175 | BST R1-R3 HBI - 4: DAq: readout card 1st article - Proc | 23d | 2012-05-29 | 2012-06-29 | 142211170a | 20d |
| 142211255 | BST JLab - Tooling Production Part A | 65d | 2012-06-01 | 2012-08-31 | 9-120M FS+163d, 142211160f FS-85d | 20d |
| 142211255a | BST JLab - Tooling Production Part B | 65d | 2012-06-01 | 2012-08-31 | 142211160f FS-85d, 9-120M FS+163d | 20d |
| 142211300 | BST R1-R3 MECH GRP - Cold plate 1st article tests: (2) construct and assemble - Labor | 38d | 2012-06-29 | 2012-08-21 | 142211295 | 163d |
| 142211180 | BST R1-R3 HBI - 4: DAq: readout card R1 R2 R3 - Proc | 21d | 2012-07-02 | 2012-07-30 | 142211175 | 20d |
| 142211340 | BST R1-R3 MECH GRP - 3: Modules: round table, mounting, and alignment fixture (2) construction - Labor | 22d | 2012-07-06 | 2012-08-06 | 9-120M FS+76d, 142211335 FS-60d | 174d |
| 142211390 | BST R1-R3 HBI - 7 Sloco: Slow controls for monitoring and charge calibration system: (2) component procurement - Proc | 136d | 2012-07-12 | 2013-01-31 | 9-120M FS+191d, 142211385 FS-115d | 164d |
| 142211365 | BST R1-R3 HBI - 6: Cable assemblies: HV, LV, and data (6) R1 R2 R3 - Proc Part A | 44d | 2012-07-31 | 2012-10-01 | 142211210 | 187d |
| 142211365a | BST R1-R3 HBI - 6: Cable assemblies: HV, LV, and data (6) R1 R2 R3 - Proc Part B | 44d | 2012-07-31 | 2012-10-01 | 142211210 | 187d |
| 142211225 | BST R1-R3 HBI - 7 Sloco: HV, LV, PS (3) modules components: 1st article testing - Labor | 31d | 2012-08-10 | 2012-09-24 | 142211220 | 20d |
| 142211230 | BST R1-R3 HBI - 7 Sloco: HV, LV, PS (4) crates - Proc (1st Articles and Production) | 31d | 2012-08-10 | 2012-09-24 | 142211220 | 74d |
| 142211400 | BST R1-R3 HBI - 7Sloco:Slow controls for monitor and charge calib system: (4) develop sloco software (1/2) - Labor | 16d | 2012-09-07 | 2012-09-28 | 142211395 FS-121d | 164d |
| 142211375 | BST R1-R3 HBI - 7 Sloco: HV, LV, PS (1) modules R1 R2 R3 - Proc | 58d | 2012-09-25 | 2012-12-17 | 142211230, 142211109M | 74d |
| 142211355M | Start of R1-R3 Production | 0d | 2012-09-26 | 2012-09-26 | 142211350M FS-140d | 37d |
| 142211360 | BST R1-R3 HBI - Electronics 5: HFCB modules R1 R2 R3 - Proc | 58d | 2012-09-26 | 2012-12-18 | 142211140, 142211190, 142211355M | 37d |
| 142211013E | SVT-FY13 Travel | 228d | 2012-10-01 | 2013-08-30 | 142211012E | 20d |
| 142211130 | HBI - SVT Engineering and Construction Oversight FY13 | 228d | 2012-10-01 | 2013-08-30 | 142211125 | 20d |
| 142211145aa | BST R1-R3 HBI - 2 Sensors: Sensors received and inspected by JLab (1st article and production) - Labor FY13 | 23d | 2012-10-01 | 2012-10-31 | 142211145a | 21d |
| 142211275a | BST R1-R3 HBI - 9 DAq-SCM (4) develop program and test (1/2) - Labor FY13 | 43d | 2012-10-01 | 2012-11-30 | 142211275 | 105d |
| 142211400a | BST R1-R3 HBI - 7Sloco:Slow controls for monitor and charge calib system: (4) develop sloco software (1/2) - Labor FY13 | 84d | 2012-10-01 | 2013-02-06 | 142211400 | 164d |
| 142211530 | BST R4 HBI - 6: Cable assemblies: HV, LV, and data (1) R4 - Proc | 80d | 2012-10-01 | 2013-01-31 | 9-130M | 88d |
| 142211540 | BST R4 HBI - 7 Sloco: HV, LV, PS (1) modules R4 - Proc | 80d | 2012-10-01 | 2013-01-31 | 9-130M | 168d |
| 142211550 | BST R4 HBI - 9 DAq- SCM custom crate system components R4 - Proc | 23d | 2012-10-01 | 2012-10-31 | 9-130M | 225d |
| 142211840 | Installation MECH GRP - Installation cart: (1) MFG Drawings - Labor | 120d | 2012-10-01 | 2013-03-29 | 9-130M | 95d |
| 142211860 | Installation MECH GRP - Purging system: (1) procurement prep - Labor | 21d | 2012-10-01 | 2012-10-29 | 9-130M | 184d |
| 142211875 | Installation MECH GRP - Transport box BST: (1) manufacturing drawings - Labor | 60d | 2012-10-01 | 2013-01-02 | 9-130M | 155d |
| 142211370 | BST R1-R3 HBI - 6: Cable assemblies: HV, LV, and data fabrication and testing - Labor | 60d | 2012-10-02 | 2013-01-03 | 142211365a, 142211365 | 187d |
| 142211395 | BST R1-R3 HBI - 7Sloco:Slow controls for monitoring and charge calib system: (3) assemble, test, and debug - Labor | 100d | 2012-10-08 | 2013-03-08 | 142211390 FS-75d | 164d |
| 142211865 | Installation MECH GRP - Purging system: (2) installation - Proc | 22d | 2012-10-30 | 2012-11-30 | 142211860 | 184d |
| 142211160v | FNAL Receive & test (Jlab/FNAL) R4 Production Sensors (3 batches) | 97d | 2012-11-01 | 2013-03-29 | 142211505 FS-40d | 128d |
| 142211880 | Installation MECH GRP - Transport box BST: (2) procurement prep - Labor | 21d | 2012-11-09 | 2012-12-11 | 142211875 FS-31d | 155d |
| 142211500M | Start of BST R4 Production | 0d | 2012-11-27 | 2012-11-27 | 142211005p, 9-130M FS+40d | 128d |
| 142211505 | BST R4 HBI - 2 Sensors: Sensors for R4 - Proc | 23d | 2012-11-28 | 2013-01-07 | 142211500M, 142211005p FS-78d | 128d |
| 142211435 | BST R1-R3 HBI - 9 DAq-SCM (1) custom crate system components R1 R2 R3 - Proc | 59d | 2012-12-03 | 2013-03-05 | 142211275a | 105d |
| 142211445 | BST R1-R3 HBI - 9 DAq-SCM (3) develop program and test (2/2) - Labor | 100d | 2012-12-03 | 2013-05-01 | 142211440 FS-120d | 105d |
| 142211870 | Installation MECH GRP - Purging system: (3) installation - Labor | 21d | 2012-12-03 | 2013-01-08 | 142211865 | 184d |
| 142211885 | Installation MECH GRP - Transport box BST: (3) construct and assemble - Proc | 21d | 2012-12-12 | 2013-01-17 | 142211880 | 155d |
| 142211380 | BST R1-R3 HBI - 7 Sloco: HV, LV, PS (3) distribution system (fabricate) - Labor | 120d | 2012-12-18 | 2013-06-14 | 142211375 | 74d |
| 142211510 | BST R4 HBI - 5 Electronics: HFCB production modules R4 - Proc | 59d | 2012-12-19 | 2013-03-21 | 9-130M, 142211360 | 37d |
| 142211890 | Installation MECH GRP - Transport box BST: (4) construct and assemble - Labor | 22d | 2013-01-18 | 2013-02-20 | 142211885 | 155d |
| 142211535 | BST R4 HBI - 6: Cable assemblies: HV, LV, and data (2) R4 - Labor | 80d | 2013-02-01 | 2013-05-24 | 142211530 | 88d |
| 142211845 | Installation MECH GRP - Installation cart: (2) procurement prep - Labor | 21d | 2013-02-14 | 2013-03-15 | 142211840 FS-31d | 95d |
| 142211440 | BST R1-R3 HBI - 9 DAq-SCM (2) custom crate fabrication and test - Labor | 61d | 2013-03-06 | 2013-05-30 | 142211435 | 105d |
| 142211850 | Installation MECH GRP - Installation cart: (3) construction - Proc | 22d | 2013-03-18 | 2013-04-16 | 142211845 | 95d |
| 142211515 | BST R4 HBI - 5 Electronics: HFCB production modules assembly R4 - Proc | 17d | 2013-03-22 | 2013-04-15 | 142211510 | 37d |
| 142211350 | BST R1-R3 MECH GRP - 3: Modules 1st article stave tests mount & aligning of modules in model of cold plate - Labor | 21d | 2013-03-26 | 2013-04-23 | 142211340, 142211245, 142211230, 142211320, 142211300, 142211225 FS+120d, 142211460 | 20d |
| 142211520 | BST R4 HBI - 5 Electronics: HFCB assemble electronics for modules - Labor | 80d | 2013-04-16 | 2013-08-07 | 142211515 | 37d |
| 142211855 | Installation MECH GRP - Installation cart: (4) construction - Labor | 21d | 2013-04-17 | 2013-05-15 | 142211850 | 95d |
| 142211350M | End of 1st Article Program | 0d | 2013-04-23 | 2013-04-23 | 142211350 | 37d |
| 142211465 | BST R1-R3 MECH GRP - Support, cooling, and alignment (1) of stave: manufacturing Drawings - Labor | 60d | 2013-04-24 | 2013-07-18 | 142211350 | 30d |
| 142211800 | Installation MECH GRP - Support and alignment tube (1) to mount solenoid, MFG Drawings (incl. alignment system) - Labor | 91d | 2013-04-24 | 2013-08-30 | 142211350, 9-130M FS+23d | 20d |
| 142211470 | BST R1-R3 MECH GRP - Support, cooling, and alignment (2) of stave: procurement prep - Labor | 21d | 2013-07-19 | 2013-08-16 | 142211465 | 30d |
| 142211950 | Re-Baseline Actuals Adjustment | 1d | 2013-08-30 | 2013-08-30 | 9-130M FS+227d | 20d |
| 242211013E | SVT-FY13 Travel | 20d | 2013-09-03 | 2013-09-30 | 9-130M FS+228d | 719d |
| 242211130 | HBI - SVT Engineering and Construction Oversight FY13 | 20d | 2013-09-03 | 2013-09-30 | 9-130M FS+228d | 719d |
| 242211160t | FNAL Construction and test (Jlab/FNAL) of R1-R3 production modules (60 modules) Part A | 182d | 2013-09-03 | 2014-05-30 | 242211885 FS-375d, 242211610a FS-114d, 242211890 FS-375d, 9-130M FS+228d, 242211515 FS-325d, 242211610 FS-114d, 242211520 FS-325d | 229d |

| ID | Task | Duration | Start | Finish | Predecessors | Total float |
| --- | --- | --- | --- | --- | --- | --- |
| 242211160u | FNAL Construction and test (Jlab/FNAL) of R1-R3 production modules (60 modules) Part B | 182d | 2013-09-03 | 2014-05-30 | 242211160t FS-182d | 233.75d |
| 242211160w | FNAL Construction and test (Jlab/FNAL) of R4 production modules Phase 1 | 267d | 2013-09-03 | 2014-09-30 | 242211160u FS-182d, 242211515 FS-325d, 242211520 FS-325d | 262d |
| 242211160w5 | FNAL Construction and test (Jlab/FNAL) of R4 production modules Phase 2 | 267d | 2013-09-03 | 2014-09-30 | 242211515 FS-325d, 242211520 FS-325d, 242211160u FS-182d | 262d |
| 242211335 | MECH GRP - Modules: asssembly table, mounting, and alignment fixture procurement - Proc | 9d | 2013-09-03 | 2013-09-13 | 9-130M FS+228d | 255d |
| 242211360 | HBI - Electronics HFCB R1-R4 - Proc | 139d | 2013-09-03 | 2014-03-31 | 9-130M FS+228d | 329d |
| 242211361 | HBI - Electronics HFCB R1-R4 - Proc First Article 6 cables | 14d | 2013-09-03 | 2013-09-20 | 9-130M FS+228d | 527d |
| 242211365a | HBI - Cable assemblies: HV, LV, and data - Proc | 98d | 2013-09-03 | 2014-01-31 | 9-130M FS+228d | 322.75d |
| 242211367 | HBI - Cable assemblies: Pulser | 139d | 2013-09-03 | 2014-03-31 | 9-130M FS+228d | 281.75d |
| 242211370 | HBI - Cable assemblies: HV, LV, and data fabrication and testing R1-R4 - Labor FY13 | 20d | 2013-09-03 | 2013-09-30 | 9-130M FS+228d | 249d |
| 242211405a | Obligated Procured Labor for Activity 242211405 | 99d | 2013-09-03 | 2014-02-03 | 9-130M FS+228d | 299d |
| 242211410 | MECH GRP - Faraday cage protective enclosure system specifications and procurement prep - Labor FY13 | 20d | 2013-09-03 | 2013-09-30 | 242211405a FS-99d, 242211405 FS-99d | 299d |
| 242211465 | MECH GRP - Support, cooling, coldplate, and alignment of stave: manufacturing Drawings - Labor | 14d | 2013-09-03 | 2013-09-20 | 9-130M FS+228d | 255d |
| 242211490 | HBI - Module R1-R4 : quality assurance, test, and burn-in at FNAL - Labor FY13 | 20d | 2013-09-03 | 2013-09-30 | 242211160w FS-300d, 242211160u FS-186.75d, 242211160t FS-182d, 242211160w5 FS-300d | 229d |
| 242211515 | HBI - Electronics: HFCB assembly - Proc Part A | 161d | 2013-09-03 | 2014-04-30 | 242211360 FS-139d | 393d |
| 242211530 | HBI - Compunetics HFCB Bend Test - Proc | 20d | 2013-09-03 | 2013-09-30 | 9-130M FS+228d, 242211361 FS-14d | 527d |
| 242211605 | HBI - Bus cable PCB production - Proc | 62d | 2013-09-03 | 2013-11-27 | 9-130M FS+228d | 266d |
| 242211620 | FNAL Tooling | 20d | 2013-09-03 | 2013-09-30 | 9-130M FS+228d | 551d |
| 242211670 | INFRA STR - Integrated Humidity Reduction System for SVT Control room - Proc | 43d | 2013-09-03 | 2013-10-31 | 9-130M FS+228d | 453d |
| 242211705 | MECH GRP - Tooling for assembly and repairs: manufacturing Drawings - Labor/Expenses FY13 | 20d | 2013-09-03 | 2013-09-30 | 9-130M FS+228d | 256.5d |
| 242211710 | MECH GRP - Tooling for assembly and repairs: procurement prep - Labor FY13 | 20d | 2013-09-03 | 2013-09-30 | 242211705 FS-31d, 242211705a FS-31d | 256.5d |
| 242211755 | HBI - Additional HFCB - Proc | 139d | 2013-09-03 | 2014-03-31 | 9-130M FS+228d | 408d |
| 242211715 | MECH GRP - Tooling for assembly and repairs - Proc | 62d | 2013-09-03 | 2013-12-02 | 242211710 FS-43d, 242211710a FS-43d | 256.5d |
| 242211610 | HBI - Bus cable PCB receive and Test - Labor FY13 | 18d | 2013-09-05 | 2013-09-30 | 242211605 FS-60d | 266d |
| 242211470 | MECH GRP - Support, cooling, coldplate, and alignment of stave: procurement prep - Labor | 6d | 2013-09-23 | 2013-09-30 | 242211465 | 255d |
| 242211014E | SVT-FY14 Travel | 247d | 2013-10-01 | 2014-09-30 | 242211013E | 719d |
| 242211140 | HBI - SVT Engineering and Construction Oversight FY14 | 247d | 2013-10-01 | 2014-09-30 | 242211130 | 719d |
| 242211370a | HBI - Cable assemblies: HV, LV, and data fabrication and testing R1-R4 - Labor FY14 | 162d | 2013-10-01 | 2014-05-30 | 9-130M FS+228d, 242211370 | 249d |
| 242211390 | HBI - Sloco: Slow controls for monitoring and charge calibration system: component procurement - Proc | 57d | 2013-10-01 | 2013-12-20 | 9-140M | 377d |
| 242211405 | MECH GRP - Faraday cage protective enclosure system Manufacturing Drawings - Labor | 79d | 2013-10-01 | 2014-02-03 | 9-140M | 299d |
| 242211410a | MECH GRP - Faraday cage protective enclosure system specifications and procurement prep - Labor FY14 | 87d | 2013-10-01 | 2014-02-13 | 242211405a FS-99d, 242211405 FS-99d, 242211410 | 299d |
| 242211475 | MECH GRP - Support, cooling, coldplate, and alignment of stave - Proc | 23d | 2013-10-01 | 2013-10-31 | 242211470 | 255d |
| 242211490a | HBI - Module R1-R4 : quality assurance, test, and burn-in at FNAL - Labor FY14 | 247d | 2013-10-01 | 2014-09-30 | 242211160w5 FS-300d, 242211490, 242211160w FS-300d, 242211160u FS-186.75d, 242211160t FS-182d | 229d |
| 242211610a | HBI - Bus cable PCB receive and Test - Labor FY14 | 57d | 2013-10-01 | 2013-12-20 | 242211610, 242211605 FS-60d | 266d |
| 242211635 | HBI - LV cards - Proc | 119d | 2013-10-01 | 2014-03-31 | 9-140M | 357d |
| 242211655 | HBI - VXS crate - Proc | 119d | 2013-10-01 | 2014-03-31 | 9-140M | 357d |
| 242211705a | MECH GRP - Tooling for assembly and repairs: manufacturing Drawings - Labor/Expenses FY14 | 11d | 2013-10-01 | 2013-10-15 | 9-130M FS+228d, 242211705 | 256.5d |
| 242211710a | MECH GRP - Tooling for assembly and repairs: procurement prep - Labor FY14 | 23.5d | 2013-10-01 | 2013-11-01 | 242211705 FS-31d, 242211705a FS-31d, 242211710 | 256.5d |
| 242211875 | MECH GRP - Construct silicon module shipping containers -Proc Part A | 98d | 2013-10-01 | 2014-02-28 | 9-140M | 347d |
| 242211885 | MECH GRP - Module inserts Copper/PEEK Part A | 54d | 2013-10-01 | 2013-12-17 | 9-140M | 530d |
| 242211340 | MECH GRP - Modules: assembly table, mounting, and alignment fixture construction - Labor | 20d | 2013-10-04 | 2013-10-31 | 242211335 FS+14d | 255d |
| 242211460 | MECH GRP - Cooling system: procurement - proc | 31d | 2013-10-04 | 2013-11-15 | 9-140M FS+3d | 255d |
| 242211685 | MECH GRP - Region 4 Support, cooling, coldplate, and alignment structure: manufacturing Drawings - Labor | 68d | 2013-10-15 | 2014-01-31 | 9-140M FS+10d | 269d |
| 242211445 | HBI - DAq-VSCM develop program and test - Labor | 98d | 2013-10-17 | 2014-03-18 | 9-140M FS+12d | 249d |
| 242211380 | HBI - Sloco: HV, LV, PS distribution system (fabricate) - Labor | 11d | 2013-11-01 | 2013-11-15 | 9-140M FS+23d | 255d |
| 242211480 | MECH GRP - Support, cooling, coldplate, and alignment of stave Faraday Cage inner: construct and assemble - Labor | 11d | 2013-11-01 | 2013-11-15 | 242211415 FS-120d, 242211475, 242211340 | 255d |
| 242211725 | MECH GRP - Tooling for dissassembly, and repairs : manufacturing Drawings - Labor | 75d | 2013-11-01 | 2014-02-28 | 9-140M FS+23d | 355d |
| 242211485 | MECH GRP - Mounting and aligning on support structure in lab, R1-R3 - Labor | 118d | 2013-11-18 | 2014-05-15 | 242211645 FS-250d, 242211460, 242211480, 242211720 FS-25d, 242211380, 242211415 FS-140d | 255d |
| 242211876 | MECH GRP - Module shipping Charges from FNAL to Jlab - Proc | 216d | 2013-12-02 | 2014-10-15 | 242211875a FS-170d, 9-140M FS+42d, 242211875 FS-170d | 233d |
| 242211720 | MECH GRP - Tooling for assembly and repairs construct and assemble - Labor | 15d | 2013-12-02 | 2014-01-02 | 242211715 | 256.5d |
| 242211520 | HBI - Electronics: HFCB assembly - Proc Part B | 161d | 2013-12-04 | 2014-07-31 | 242211360 FS-75d | 329d |
| 242211645 | HBI - Module Reception tests at JLAB - Labor | 223d | 2013-12-09 | 2014-10-31 | 242211490a FS-200d, 242211490 FS-200d | 269d |
| 242211615 | HBI - Full system R1-R3, test and burn-in in Cleanroom EEL 121 - Labor | 115d | 2013-12-10 | 2014-06-02 | 242211485 FS-110d, 242211370 FS-114d, 242211365a FS-103.75d, 242211445 FS-62d, 242211367 FS-103.75d, 242211370a FS-114d | 249d |
| 242211395 | HBI - Sloco:Slow controls for monitoring and charge calib system: assemble, test, and debug ADC's- Labor | 42d | 2014-01-02 | 2014-03-03 | 242211390 | 377d |
| 242211400a | HBI - Sloco:Slow controls for monitor and charge calib system: develop sloco software (1/2) - Labor | 109d | 2014-01-07 | 2014-06-10 | 9-140M FS+60d | 307d |
| 242211890 | MECH GRP - Module inserts Copper/PEEK Part B | 54d | 2014-01-07 | 2014-03-24 | 9-140M FS+60d | 470d |
| 242211825 | Installation MECH GRP - AC Distribution - proc prep - Labor | 10d | 2014-01-09 | 2014-01-23 | 9-140M FS+62d | 434d |
| 242211830 | Installation MECH GRP - AC Distribution - Proc | 21d | 2014-01-24 | 2014-02-21 | 242211825 | 434d |
| 242211690 | MECH GRP - Region 4 Support, cooling, coldplate, and alignment structure: procurement prep - Labor | 10d | 2014-02-03 | 2014-02-14 | 242211685, 9-140M FS+10d | 269d |
| 242211800 | Installation MECH GRP - Support and alignment tube, MFG Drawings - Labor | 42d | 2014-02-03 | 2014-04-01 | 9-140M FS+78d | 294d |
| 242211745 | MECH GRP - Environmental Control System - Proc | 161d | 2014-02-05 | 2014-09-22 | 9-140M FS+80d | 235d |
| 242211415 | MECH GRP - Faraday cage protective enclosure system - Proc | 12d | 2014-02-14 | 2014-03-03 | 242211410, 242211410a | 299d |
| 242211695 | MECH GRP - Region 4 Support, cooling, coldplate, and alignment structure: - Proc | 31d | 2014-02-17 | 2014-03-31 | 242211690 | 269d |
| 242211730 | MECH GRP - Tooling for disassembly and repairs: procurement prep - Labor | 10d | 2014-03-03 | 2014-03-14 | 242211725 | 355d |
| 242211875a | MECH GRP - Construct silicon module shipping containers -Proc Part B | 98d | 2014-03-05 | 2014-07-22 | 9-140M FS+100d | 247d |
| 242211735 | MECH GRP - Tooling for disassembly, and repairs - Proc | 54d | 2014-03-17 | 2014-05-30 | 242211730 | 355d |
| 242211700 | MECH GRP - Region 4 Support, cooling, coldplate, and alignment structure: construct & assemble - Labor | 14d | 2014-04-01 | 2014-04-18 | 242211695 | 269d |
| 242211660 | INFRA STR - Backup Environmental and power system for SVT Clean Room - Proc | 43d | 2014-04-02 | 2014-06-02 | 9-140M FS+120d | 313d |
| 242211675 | INFRA STR - Integrated Humidity Reduction System for SVT Control room - Proc | 43d | 2014-04-02 | 2014-06-02 | 9-140M FS+120d | 313d |
| 242211805 | Installation MECH GRP - Support & alignment tube - Proc - prep - Labor | 10d | 2014-04-02 | 2014-04-15 | 242211800 | 294d |
| 242211810 | Installation MECH GRP - Support and alignment tube - Proc | 33d | 2014-04-16 | 2014-06-02 | 242211805 | 294d |

| ID | WBS | Task | Duration | Start | Finish | Predecessors | Total float |
| --- | --- | --- | --- | --- | --- | --- | --- |
| 242211740 |  | MECH GRP - Tooling for disassembly and repairs Build - Labor | 30d | 2014-05-02 | 2014-06-13 | 242211735 FS-20d | 355d |
| 242211860 |  | Installation MECH GRP - Purging system: procurement prep - Labor | 10d | 2014-05-14 | 2014-05-28 | 9-140M FS+150d | 275d |
| 242211545 |  | MECH GRP - Mounting and aligning on support structure in lab, R4 - Labor | 54d | 2014-05-19 | 2014-08-04 | 242211700, 242211615 FS-10d | 249d |
| 242211865 |  | Installation MECH GRP - Purging system: installation - Proc | 21d | 2014-05-29 | 2014-06-26 | 242211860 | 275d |
| 242211815 |  | Installation MECH GRP - Support and alignment (construction) - Labor | 19d | 2014-06-03 | 2014-06-27 | 242211810 | 294d |
| 242211600 |  | HBI - Full system R4, test and burn-in in Cleanroom EEL 121 - Labor | 20d | 2014-07-22 | 2014-08-18 | 242211367, 242211545 FS-10d | 259d |
| 242211870 |  | Installation MECH GRP - Purging system: installation in clean room- Labor | 20d | 2014-08-05 | 2014-09-02 | 242211865, 242211545 | 249d |
| 242211495M |  | End of BST R1-R4 Production | 0d | 2014-09-30 | 2014-09-30 | 242211876 FS-15d, 242211490, 242211490a | 229d |
| 242211145 |  | HBI - SVT Engineering and Construction Oversight FY15 | 23d | 2014-10-01 | 2014-10-31 | 242211014E, 242211140 | 719d |
| 242211680 |  | MECH GRP - Full system test Integration of SVT R3/R4 - Labor | 51d | 2014-10-01 | 2014-12-12 | 242211745, 242211395, 242211815, 242211660, 242211635, 242211400a, 242211655, 242211600, 242211495M, 242211870, 242211675, 242211670 | 229d |
| 242211918M |  | SVT Ready for Installation | 0d | 2014-12-12 | 2014-12-12 | 242211530, 242211680, 242211740, 242211145 FS-500d, 242211755, 242211830, 242211361 | 229d |
|  | 2 | **1.4.2.2.1.2 CENTRAL TRACKER** |  |  |  |  |  |
|  | 3 | **1.4.2.2.1.3 FORWARD DRIFT CHAMBERS** |  | 2008-10-01 | 2015-04-01 |  |  |
| 142213000M |  | DC-P-#1 Constrction Start P-#1 (F DRFT CHAM) | 0d | 2008-10-01 | 2008-10-01 | 9-090M, 12222035M | 392d |
| 142213009E |  | FY09 Travel (FWD Chambers) | 189d | 2009-01-02 | 2009-09-30 | 142213009EX | 248d |
| 142213017 |  | P-#1 Proc Endplates & Frames LABOR Initial | 82d | 2009-01-05 | 2009-04-30 | 9-090M FS+60d | 60d |
| 142213017A |  | P-#1 Proc Endplates & Frames LABOR Final FY09 | 106d | 2009-05-01 | 2009-09-30 | 142213017 | 60d |
| 142213020 |  | P-#1 Proc Box Assy. Fixtures LABOR | 60d | 2009-05-06 | 2009-07-30 | 9-090M FS+145d | 196d |
| 142213022 |  | P-#1 Proc Wires, Pins and Feedthroughs LABOR | 103d | 2009-05-06 | 2009-09-30 | 142213000M, 9-090M FS+145d | 247d |
| 142213022P |  | P-#1 Proc Wires, Pins and Feedthroughs | 206d | 2009-05-06 | 2010-03-08 | 9-090M FS+145d | 144d |
| 142213030 |  | P-#1 Proc Circuit Boards LABOR | 88d | 2009-05-06 | 2009-09-09 | 9-090M FS+145d | 262d |
| 142213035 |  | P-#1 Build Stringing Fixtures, Machines and Platforms | 103d | 2009-05-06 | 2009-09-30 | 9-090M FS+145d | 247d |
| 142213017P |  | P-#1 Proc Frames/Endplates | 112d | 2009-05-13 | 2009-10-20 | 9-090M FS+150d | 139d |
| 142213020P |  | P-#1 Proc Box Assy. Fixtures | 60d | 2009-05-20 | 2009-08-13 | 9-090M FS+155d | 186d |
| 142213035P |  | P-#1 Proc Cleanroom Fixtures and Equipment | 30d | 2009-06-11 | 2009-07-23 | 9-090M FS+170d | 295d |
| 142213030P |  | P-#1 Proc Circuit Boards | 90d | 2009-07-31 | 2009-12-08 | 9-090M FS+205d | 200d |
| 142213010E |  | FY10 Travel (FWD Chambers) | 248d | 2009-10-01 | 2010-09-30 | 142213009E | 248d |
| 142213017Ab |  | P-#1 Proc Endplates & Frames LABOR Final FY10 | 20d | 2009-10-01 | 2009-10-28 | 142213017A | 60d |
| 142213100M |  | P-#2 Constrction Start P-#2 | 0d | 2009-10-01 | 2009-10-01 | 9-100M | 184d |
| 142213122 |  | P-#2 Proc Wires, Pins and Feedthroughs LABOR | 120d | 2009-10-01 | 2010-03-31 | 142213100M | 312d |
| 142213135 |  | P-#2 Build Stringing Fixtures, Machines and Platforms | 162d | 2009-10-01 | 2010-05-28 | 142213100M | 270d |
| 142213122P |  | P-#2 Proc Wires, Pins and Feedthroughs | 70d | 2009-10-15 | 2010-02-02 | 142213100M FS+10d | 352d |
| 142213032 |  | P-#1 Build Boxes and Associated Hardware | 94d | 2009-10-21 | 2010-03-15 | 142213020, 142213017P, 142213020P, 9-100M, 142213017Ab FS-20d | 139d |
| 142213117 |  | P-#2 Proc Endplates & Frames LABOR Initial | 161d | 2009-10-29 | 2010-06-25 | 142213017Ab | 60d |
| 142213042M |  | First Wire Strung | 0d | 2009-11-02 | 2009-11-02 | 142213042 FS-140d | 969d |
| 142213117P |  | P-#2 Proc Frames/Endplates | 110d | 2009-11-06 | 2010-04-22 | 142213100M FS+26d | 255d |
| 142213120 |  | P-#2 Proc Box Assy. Fixtures LABOR | 60d | 2009-12-08 | 2010-03-11 | 142213100M FS+46d | 285d |
| 142213135P |  | P-#2 Proc Cleanroom Fixtures and Equipment | 60d | 2009-12-08 | 2010-03-11 | 142213100M FS+46d | 326d |
| 142213120P |  | P-#2 Proc Box Assy. Fixtures | 34d | 2010-01-14 | 2010-03-04 | 142213100M FS+67d | 290d |
| 142213130 |  | P-#2 Proc Circuit Boards LABOR | 148d | 2010-03-04 | 2010-09-30 | 142213100M FS+100d | 184d |
| 142213042 |  | P-#1 String Chambers Initial | 54d | 2010-03-16 | 2010-05-28 | 142213032, 142213035, 9-100M FS+108d, 142213030, 142213035P, 142213022, 142213022P, 142213030P | 139d |
| 142213130P |  | P-#2 Proc Circuit Boards Initial | 69d | 2010-03-25 | 2010-06-30 | 142213100M FS+115d | 184d |
| 142213217P |  | P-#3 Proc Frames/Endplates | 196d | 2010-05-11 | 2011-02-28 | 142213117P FS+12.5d | 460.5d |
| 142213042B |  | P-#1 String Chambers Final FY10 | 86d | 2010-06-01 | 2010-09-30 | 142213042 | 139d |
| 142213045 |  | ODU Contract Preperations | 69d | 2010-06-01 | 2010-09-07 | 9-100M FS+162d | 106d |
| 142213070 |  | ISU Contract Preperations FY10 | 86d | 2010-06-01 | 2010-09-30 | 9-100M FS+162d | 42d |
| 142213117B |  | P-#2 Proc Endplates & Frames LABOR Final FY10 | 67d | 2010-06-28 | 2010-09-30 | 142213117, 142213017Ab | 60d |
| 142213130Pb |  | P-#2 Proc Circuit Boards Final | 64d | 2010-07-01 | 2010-09-30 | 142213130P | 184d |
| 142213011E |  | FY11 Travel (FWD Chambers) | 248d | 2010-10-01 | 2011-09-30 | 142213010E | 248d |
| 142213042Ba |  | P-#1 String Chambers Final FY11 | 45d | 2010-10-01 | 2010-12-06 | 142213042B | 139d |
| 142213070a |  | ISU Contract Preperations FY11 | 2d | 2010-10-01 | 2010-10-04 | 142213070 | 42d |
| 142213117Ba |  | P-#2 Proc Endplates & Frames LABOR Final FY11 | 248d | 2010-10-01 | 2011-09-30 | 142213117B | 60d |
| 142213132 |  | P-#2 Build Boxes and Associated Hardware Part A | 97d | 2010-10-01 | 2011-02-28 | 142213120, 142213117 FS-70d, 142213100M, 142213120P, 9-110M, 142213117P | 143d |
| 142213200M |  | P-#3 Constrction Start P-#3 | 0d | 2010-10-01 | 2010-10-01 | 9-110M | 127d |
| 142213220 |  | P-#3 Proc Box Assy. Fixtures LABOR | 35d | 2010-10-01 | 2010-11-18 | 9-110M | 708d |
| 142213222 |  | P-#3 Proc Wires, Pins and Feedthroughs LABOR | 130d | 2010-10-01 | 2011-04-14 | 9-110M | 398d |
| 142213222P |  | P-#3 Proc Wires, Pins and Feedthroughs | 90d | 2010-10-01 | 2011-02-16 | 9-110M | 438d |
| 142213230 |  | P-#3 Proc Circuit Boards LABOR | 90d | 2010-10-01 | 2011-02-16 | 9-110M, 142213200M | 438d |
| 142213230P |  | P-#3 Proc Circuit Boards | 431d | 2010-10-01 | 2012-06-29 | 9-110M, 142213200M | 127d |
| 142213075 |  | ISU Contract Phase 1a - Hire lead stringer, complete cleanroom, Readiness Review | 95d | 2010-10-05 | 2011-02-28 | 142213070a | 42d |
| 142213220P |  | P-#3 Proc Box Assy. Fixtures | 30d | 2010-11-03 | 2010-12-16 | 9-110M FS+23d | 504d |
| 142213050 |  | ODU Contract Peg Point #1 Boxes Built & Ready to String | 207d | 2010-12-01 | 2011-09-30 | 142213045 FS+58d | 106d |
| 142213055 |  | ODU Contract Peg Point #2 Hire and Train First two Stringers | 121d | 2010-12-01 | 2011-05-31 | 142213050 FS-207d | 106d |
| 142213142 |  | P-#2 String Chambers Part A | 52d | 2010-12-07 | 2011-02-28 | 142213122, 142213130Pb, 142213130, 142213135P, 142213135, 142213042Ba, 142213100M, 142213122P, 142213130P | 139d |
| 142213060 |  | ODU Contract Peg Point #3 Hire and Train Second two Stringers | 191d | 2011-02-01 | 2011-10-31 | 142213055 FS-84d | 106d |
| 142213133 |  | P-#2 Build Boxes and Associated Hardware Part B (Frozen by Administrative CR 11-38) | 44d | 2011-03-01 | 2011-04-29 | 142213132 | 661d |
| 142213144 |  | P-#2 String Chambers Part B FY11 | 151d | 2011-03-01 | 2011-09-30 | 142213142 | 139d |
| 142213235 |  | P-#3 Build Stringing Fixtures, Machines and Platforms FY11 | 148d | 2011-03-04 | 2011-09-30 | 9-110M FS+100d, 142213135 | 429d |
| 142213080 |  | ISU Contract Phase 1b - Hire and train first 2 stringers, install and tension chamber 2 | 143d | 2011-04-11 | 2011-10-31 | 142213075 FS+29d | 42d |
| 142213133a |  | Reverse Entry per Administrative CR 11-38 | 5d | 2011-05-02 | 2011-05-06 | 9-110M FS+141d | 102d |

| ID | WBS | Task | Duration | Start | Finish | Predecessors | Total float |
| --- | --- | --- | --- | --- | --- | --- | --- |
| 142213133b |  | P-#2 Build Boxes and Associated Hardware Part B FY11 (Revised by Administrative CR 11-38) | 107d | 2011-05-02 | 2011-09-30 | 142213132, 9-110M FS+141d | 99d |
| 142213062 |  | ODU Contract Peg Point #4 String and Test all wires on RII chamber #2 | 122d | 2011-07-01 | 2011-12-30 | 142213060 FS-85d | 106d |
| 142213064 |  | ODU Contract Peg Point #5 String and Test all wires on RII chamber #3 | 205d | 2011-07-01 | 2012-04-30 | 142213062 FS-122d | 106d |
| 142213012E |  | FY12 Travel (FWD Chambers) | 247d | 2011-10-03 | 2012-09-28 | 142213011E | 248d |
| 142213085 |  | ISU Contract Phase 1c - Hire and train last 2 stringers, string wires and test chamber 2 | 98d | 2011-10-03 | 2012-02-29 | 142213080 FS-21d | 42d |
| 142213117Bb |  | P-#2 Proc Endplates & Frames LABOR Final FY12 | 206d | 2011-10-03 | 2012-08-01 | 142213117Ba | 60d |
| 142213133C |  | P-#2 Build Boxes and Associated Hardware Part B FY12 (Revised by Administrative CR 11-38) | 247d | 2011-10-03 | 2012-09-28 | 142213133b | 99d |
| 142213144a |  | P-#2 String Chambers Part B FY12 | 141d | 2011-10-03 | 2012-04-30 | 142213144 | 139d |
| 142213232 |  | P-#3 Build Boxes and Associated Hardware FY12 | 247d | 2011-10-03 | 2012-09-28 | 9-120M, 142213217P, 142213220P | 309d |
| 142213235P |  | P-#3 Proc Cleanroom Fixtures and Equipment | 247d | 2011-10-03 | 2012-09-28 | 9-120M | 280d |
| 142213235a |  | P-#3 Build Stringing Fixtures, Machines and Platforms FY12 | 98d | 2011-10-03 | 2012-02-29 | 142213235 | 429d |
| 142213300M |  | P-#4 Constrction Start P-#4 | 0d | 2011-10-03 | 2011-10-03 | 9-120M | 62d |
| 142213317 |  | P-#4 Proc Endplates & Frames LABOR | 161d | 2011-10-03 | 2012-05-29 | 142213300M | 105d |
| 142213320 |  | P-#4 Proc Box Assy. Fixtures LABOR | 121d | 2011-10-03 | 2012-04-02 | 142213300M | 374d |
| 142213320P |  | P-#4 Proc Box Assy. Fixtures | 141d | 2011-10-03 | 2012-04-30 | 142213300M | 354d |
| 142213322 |  | P-#4 Proc Wires, Pins and Feedthroughs LABOR | 130d | 2011-10-03 | 2012-04-13 | 142213300M | 365d |
| 142213322P |  | P-#4 Proc Wires, Pins and Feedthroughs | 90d | 2011-10-03 | 2012-02-16 | 142213300M | 405d |
| 142213330 |  | P-#4 Proc Circuit Boards LABOR | 21d | 2011-10-03 | 2011-10-31 | 142213300M | 288d |
| 142213330P |  | P-#4 Proc Circuit Boards | 205d | 2011-10-03 | 2012-07-31 | 142213300M | 62d |
| 142213335 |  | P-#4 Build Stringing Fixtures, Machines and Platforms | 247d | 2011-10-03 | 2012-09-28 | 142213300M | 309d |
| 142213065 |  | ODU Contract Peg Point #6String and Test all wires on RII chamber #4 | 147d | 2012-01-03 | 2012-07-31 | 142213064 FS-83d | 106d |
| 142213066 |  | ODU Contract Peg Point #7 String and Test all wires on RII chamber #5 | 212d | 2012-01-03 | 2012-10-31 | 142213065 FS-147d | 106d |
| 142213330a |  | P-#4 Proc Circuit Boards LABOR Revised FY12 | 187d | 2012-01-05 | 2012-09-28 | 9-120M FS+60d | 20d |
| 142213087 |  | ISU Contract Phase 2 - Install, tension, string wires and test chamber 3 | 141d | 2012-01-11 | 2012-07-31 | 142213085 FS-34d | 42d |
| 142213089 |  | ISU Contract Phase 3 - Install, tension, string wires and test chamber 4 | 164d | 2012-01-11 | 2012-08-31 | 142213087 FS-141d | 42d |
| 142213335P |  | P-#4 Proc Cleanroom Fixtures and Equipment Part A | 127d | 2012-04-02 | 2012-09-28 | 142213300M FS+120d | 309d |
| 142213242 |  | P-#3 String Chambers FY12 | 94d | 2012-05-17 | 2012-09-28 | 9-120M, 142213144a, 142213230P FS-30d, 142213230, 142213222P, 142213235a FS-247d, 142213232a FS-335d, 142213222, 142213235P FS-247d | 127d |
| 142213067 |  | ODU Contract Peg Point #8 String and Test all wires on RII chamber #6 | 144d | 2012-07-02 | 2013-01-31 | 142213066 FS-87d | 106d |
| 142213068 |  | ODU Contract Peg Point #9 Five RII Chambers fully tested | 184d | 2012-07-02 | 2013-03-29 | 142213067 FS-144d | 106d |
| 142213069 |  | ODU Contract Peg Point #10 Ship Final chamber to JLab | 206d | 2012-07-02 | 2013-04-30 | 142213068 FS-184d | 106d |
| 142213090 |  | ISU Contract Phase 4a - Install and tension chamber 5 | 56d | 2012-07-12 | 2012-09-28 | 142213089 FS-37d | 42d |
| 142213095 |  | ISU Contract Phase 5a - Install and tension chamber 6 | 56d | 2012-07-12 | 2012-09-28 | 142213092 FS-136d | 42d |
| 142213332 |  | P-#4 Build Boxes and Associated Hardware FY12 | 41d | 2012-08-02 | 2012-09-28 | 142213117Bb, 142213317 | 60d |
| 142213092 |  | ISU Contract Phase 4b - String wires and test chamber 5 | 80d | 2012-10-01 | 2013-01-31 | 142213090 | 42d |
| 142213097 |  | ISU Contract Phase 5b - String wires and test chamber 6 | 99d | 2012-10-01 | 2013-02-28 | 142213095 | 42d |
| 142213100 |  | ISU Contract Phase 6 - Ship chambers, fixtures and equipment to JLab | 206d | 2012-10-01 | 2013-07-31 | 142213097 FS-99d | 42d |
| 142213133Ca |  | P-#2 Build Boxes and Associated Hardware Part B FY13 | 208d | 2012-10-01 | 2013-08-02 | 142213133C | 99d |
| 142213232a |  | P-#3 Build Boxes and Associated Hardware FY13 | 59d | 2012-10-01 | 2012-12-31 | 142213232 | 309d |
| 142213242a |  | P-#3 String Chambers FY13 | 121d | 2012-10-01 | 2013-04-01 | 142213242 | 127d |
| 142213330PA |  | P-#5 Proc Circuit Boards | 162d | 2012-10-01 | 2013-05-29 | 9-130M, 142213330P | 20d |
| 142213330b |  | P-#4 Proc Circuit Boards LABOR Revised FY13 | 228d | 2012-10-01 | 2013-08-30 | 142213330a | 20d |
| 142213332a |  | P-#4 Build Boxes and Associated Hardware FY13 | 2d | 2012-10-01 | 2012-10-02 | 142213332 | 60d |
| 142213342 |  | P-#4 String Chambers | 186d | 2012-11-30 | 2013-08-30 | 142213133Ca FS-245d, 142213332a, 142213300M, 142213132, 142213133 FS-245d, 142213330P, 142213335P FS-247d, 142213330, 142213330PA FS-120d, 142213335 FS-247d | 20d |
| 142213360 |  | Re-Baseline Actuals Adjustment | 1d | 2013-08-30 | 2013-08-30 | 9-130M FS+227d | 20d |
| 242213073 |  | ODU Contract Mount Electronics on Chambers | 267d | 2013-09-03 | 2014-09-30 | 9-130M FS+228d | 285d |
| 242213092 |  | ISU Contract Phase 4b - String wires and test chamber 5 | 98d | 2013-09-03 | 2014-01-31 | 9-130M FS+228d | 384d |
| 242213097 |  | ISU Contract Phase 5b - String wires and test chamber 6 | 98d | 2013-09-03 | 2014-01-31 | 242213092 FS-98d | 384d |
| 242213100 |  | ISU Contract Phase 6 - Ship chambers, fixtures and equipment to JLab | 161d | 2013-09-03 | 2014-04-30 | 242213097 FS-98d | 384d |
| 242213133C |  | P-#2 Build Boxes and Associated Hardware FY13 | 20d | 2013-09-03 | 2013-09-30 | 9-130M FS+228d | 337d |
| 242213232 |  | P-#3 Build Boxes and Associated Hardware FY13 | 20d | 2013-09-03 | 2013-09-30 | 9-130M FS+228d | 411d |
| 242213330PA |  | Proc LVHV Distribution Cables and Boxes | 387d | 2013-09-03 | 2015-04-01 | 9-130M FS+228d | 165d |
| 242213331 |  | HV Dist Box Construction and Testing Labor | 387d | 2013-09-03 | 2015-04-01 | 9-130M FS+228d | 165d |
| 242213335Pa |  | P-#4 Proc Cleanroom Fixtures and Equipment Part B | 19d | 2013-09-03 | 2013-09-27 | 9-130M FS+228d | 457d |
| 242213342 |  | P-#4 String Chambers FY13 | 20d | 2013-09-03 | 2013-09-30 | 242213133Ca FS-289d, 9-130M FS+228d, 242213335Pa FS-247d, 242213133C FS-289d | 229d |
| 242213133Ca |  | P-#2 Build Boxes and Associated Hardware FY14 | 161d | 2013-10-01 | 2014-05-29 | 9-130M FS+228d, 242213133C | 337d |
| 242213232a |  | P-#3 Build Boxes and Associated Hardware FY14 | 121d | 2013-10-01 | 2014-04-02 | 242213232, 9-130M FS+228d | 411d |
| 242213342a |  | P-#4 String Chambers FY14 | 61d | 2013-10-01 | 2014-01-07 | 242213133C FS-289d, 242213133Ca FS-289d, 9-130M FS+228d, 242213335Pa FS-247d, 242213342 | 229d |
| 242213078 |  | De-Obligation of ODU Contract | 1d | 2013-10-15 | 2013-10-15 | 9-140M FS+10d | 521d |
| 242213347 |  | P-#5 String Chambers | 242d | 2014-01-08 | 2014-12-19 | 242213342a, 242213342 | 229d |
| 242213355M |  | Chambers Complete | 0d | 2015-04-01 | 2015-04-01 | 242213330PA, 242213073, 242213347, 242213100, 242213078, 242213232a, 242213342a, 242213232, 242213331, 242213342 | 165d |
|  | 2 | **1.4.2.2.2 CALORIMETRY** |  | 2009-10-01 | 2014-11-04 |  |  |
|  | 1 | **1.4.2.2.2.1 CENTRAL CALORIMETER** |  |  |  |  |  |
|  | 2 | **1.4.2.2.2.2 COIL CALORIMETER** |  |  |  |  |  |
|  | 3 | **1.4.2.2.2.3 FORWARD CALORIMETER** |  | 2009-10-01 | 2014-11-04 |  |  |
| 142223000M |  | EC-P-#1 Constr Start (FWD CAL) | 0d | 2009-10-01 | 2009-10-01 | 1222223040, 9-100M, 1222223041M | 621d |
| 142223005 |  | EC-P-#1 Prcrmnt Prep for Assy box (FWD CAL) | 20d | 2009-10-01 | 2009-10-28 | 142223000M | 621d |
| 142223010 |  | EC-P-#1 Prcrmnt Prep for Wave Shifting Fibers (FWD CAL) | 20d | 2009-10-01 | 2009-10-28 | 142223005 FS-20d, 142223000M | 621d |
| 142223015 |  | EC-P-#1 Prcrmnt Prep for PMTs (FWD CAL) | 20d | 2009-10-01 | 2009-10-28 | 142223000M | 846d |
| 142223020 |  | EC-P-#1 Prcrmnt Prep for Light Guides & Accessr's (FWD CAL) | 20d | 2009-10-01 | 2009-10-28 | 142223000M | 891d |
| 142223012 |  | EC-P-#1 Vend Fab of Wave Shifting Fibers (FWD CAL) | 175d | 2010-01-05 | 2010-09-13 | 9-100M FS+60d, 142223010 | 581d |

| ID | Task | Duration | Start | Finish | Predecessors | Total float |
| --- | --- | --- | --- | --- | --- | --- |
| 142223017 | EC-P-#1 Vend Fab of PMTs (FWD CAL) | 125d | 2010-01-05 | 2010-07-01 | 142223015, 9-100M FS+60d | 806d |
| 142223022 | EC-P-#1 Vend Fab of Light Guides & Accessr's (FWD CAL) | 80d | 2010-01-05 | 2010-04-28 | 9-100M FS+60d, 142223020 | 851d |
| 142223100M | PCAL Manufacturing Preparation - Milestone | 0d | 2010-04-01 | 2010-04-01 | 9-100M FS+120d | 560d |
| 142223105 | Scintillator Procurement | 66d | 2010-04-01 | 2010-07-02 | 142223100M, 9-100M FS+120d | 560d |
| 142223185 | Complete Manufacturing Drawings for Box Assy | 33d | 2010-04-15 | 2010-06-01 | 9-100M FS+130d | 190d |
| 142223195 | Prepare workspace | 21d | 2010-05-03 | 2010-06-01 | 9-100M FS+142d | 317d |
| 142223318 | Procurement- PMT Housing Components | 168d | 2010-05-03 | 2011-01-06 | 9-100M FS+142d | 278d |
| 142223110 | W&M - Prepare workspace | 11d | 2010-05-06 | 2010-05-20 | 142223105 FS-41d | 560d |
| 142223193 | Procurement of lead sheets | 404d | 2010-05-14 | 2012-01-03 | 9-100M FS+151d | 248d |
| 142223115 | Scintillator Processing | 89d | 2010-05-21 | 2010-09-27 | 142223110, 142223105 FS-65d | 560d |
| 142223120 | W&M NSF - Fiber procurement | 275d | 2010-06-02 | 2011-07-11 | 142223115 FS-89d, 9-100M FS+163d | 553d |
| 142223186 | Issue PRs and Review Bids | 21d | 2010-06-02 | 2010-06-30 | 142223185 | 190d |
| 142223316 | JMU PMT and Divider assembly and test | 391d | 2010-06-03 | 2012-01-03 | 9-100M FS+164d | 278d |
| 142223320 | Prepare workspace | 31d | 2010-06-30 | 2010-08-12 | 142223195 FS+20d | 317d |
| 142223194 | FCAL Prepare EEL 125 Room & Floors | 64d | 2010-07-01 | 2010-09-30 | 9-100M FS+184d | 190d |
| 142223200 | Prepare Components Module 1 FY10 | 20d | 2010-09-02 | 2010-09-30 | 142223194 FS-20d, 142223193 FS-385d, 142223192 FS-150d, 142223191 FS-150d, 142223190 FS-150d | 190d |
| 142223317 | Fiber Polisher FY10 | 19d | 2010-09-03 | 2010-09-30 | 9-100M FS+229d | 288d |
| 142223190 | Procurement of retainers and PMT supports | 130d | 2010-10-01 | 2011-04-14 | 142223186 FS+64d, 142223185 | 190d |
| 142223191 | Procurement of box sidewalls | 130d | 2010-10-01 | 2011-04-14 | 142223186 FS+64d | 190d |
| 142223192 | Procurement of box windows | 130d | 2010-10-01 | 2011-04-14 | 142223186 FS+64d | 190d |
| 142223200a | Prepare Components Module 1 FY11 | 16d | 2010-10-01 | 2010-10-22 | 142223200 | 190d |
| 142223317a | Fiber Polisher FY11 | 1d | 2010-10-01 | 2010-10-01 | 142223317 | 288d |
| 142223205 | Assembly of box 1 | 10d | 2010-10-25 | 2010-11-05 | 142223200a | 190d |
| 142223210 | Stacking #1 | 46d | 2010-11-08 | 2011-01-21 | 142223205 | 190d |
| 142223037 | EC-P-#2 Vend Fab of Wave Shifting Fibers (FWD CAL) | 175d | 2011-01-05 | 2011-09-13 | 142223012, 9-110M FS+60d | 508d |
| 142223215 | Close Module 1 | 5d | 2011-01-24 | 2011-01-28 | 142223210 | 190d |
| 142223220 | Prepare Components Module 2 | 10d | 2011-01-31 | 2011-02-11 | 142223215 | 190d |
| 142223325 | Setup module1 | 6d | 2011-01-31 | 2011-02-07 | 142223215, 142223320 | 206d |
| 142223330 | Prepare components | 11d | 2011-02-08 | 2011-02-23 | 142223317a, 142223325 | 206d |
| 142223225 | Assembly of box 2 | 10d | 2011-02-14 | 2011-02-28 | 142223220 | 190d |
| 142223335 | Fiber/PMT assembly Module #1 | 31d | 2011-02-24 | 2011-04-07 | 142223330, 142223318 FS-40d, 142223316 FS-285d | 206d |
| 142223230 | Stacking #2 | 46d | 2011-03-01 | 2011-05-03 | 142223225 | 190d |
| 142223340 | Prepare #1 for test | 11d | 2011-04-08 | 2011-04-22 | 142223335, 142223337 FS-196d | 206d |
| 142223345 | Testing #1 | 11d | 2011-04-25 | 2011-05-09 | 142223340 | 206d |
| 142223235 | Close Module 2 | 6d | 2011-05-04 | 2011-05-11 | 142223230, 142223232 FS-163d | 190d |
| 142223535 | Prepare the storage area | 12d | 2011-05-04 | 2011-05-19 | 142223350 FS-10d | 571d |
| 142223350 | Disassemble #1 | 6d | 2011-05-10 | 2011-05-17 | 142223345 | 206d |
| 142223355 | Move #1 to storage | 2d | 2011-05-18 | 2011-05-19 | 142223350 | 206d |
| 142223240 | Prepare Components Module 3 | 10d | 2011-05-19 | 2011-06-02 | 142223235 FS+5d | 190d |
| 142223360 | Setup module2 | 6d | 2011-05-20 | 2011-05-27 | 142223235, 142223355 | 206d |
| 142223540 | Store module #1 | 1d | 2011-05-20 | 2011-05-20 | 142223535, 142223355 | 571d |
| 142223365 | Prepare components | 11d | 2011-05-31 | 2011-06-14 | 142223360 | 206d |
| 142223245 | Assembly of box 3 | 10d | 2011-06-03 | 2011-06-16 | 142223240 | 190d |
| 142223370 | Fiber/PMT assembly Module #2 | 31d | 2011-06-15 | 2011-07-28 | 142223365 | 206d |
| 142223250 | Stacking #3 | 46d | 2011-06-17 | 2011-08-22 | 142223245 | 190d |
| 142223375 | Prepare #2 for test | 11d | 2011-07-29 | 2011-08-12 | 142223370, 142223372 FS-196d | 206d |
| 142223380 | Testing #2 | 11d | 2011-08-15 | 2011-08-29 | 142223375 | 206d |
| 142223255 | Close Module 3 | 6d | 2011-08-23 | 2011-08-30 | 142223252 FS-163d, 142223250 | 190d |
| 142223385 | Disassemble #2 | 6d | 2011-08-30 | 2011-09-07 | 142223380 | 206d |
| 142223260 | Prepare Components Module 4 | 11d | 2011-09-08 | 2011-09-22 | 142223255 FS+5d | 190d |
| 142223390 | Move #2 to storage | 2d | 2011-09-08 | 2011-09-09 | 142223385 | 206d |
| 142223395 | Setup module3 | 6d | 2011-09-12 | 2011-09-19 | 142223255, 142223390 | 206d |
| 142223545 | Store module #2 | 1d | 2011-09-12 | 2011-09-12 | 142223390, 142223540 | 494d |
| 142223400 | Prepare components FY11 | 9d | 2011-09-20 | 2011-09-30 | 142223395 | 206d |
| 142223265 | Assembly of box 4 FY11 | 6d | 2011-09-23 | 2011-09-30 | 142223260 | 190d |
| 142223265a | Assembly of box 4 FY12 | 5d | 2011-10-03 | 2011-10-07 | 142223265 | 190d |
| 142223400a | Prepare components FY12 | 2d | 2011-10-03 | 2011-10-04 | 142223400 | 206d |
| 142223405 | Fiber/PMT assembly Module #3 | 19d | 2011-10-05 | 2011-10-31 | 142223400a | 206d |
| 142223270 | Stacking #4 | 16d | 2011-10-10 | 2011-10-31 | 142223265a | 190d |
| 142223232 | ETC Revision of Stacking #2 | 37d | 2011-11-01 | 2011-12-30 | 9-120M FS+21d | 190d |
| 142223337 | ETC Revision of Fiber/PMT assembly Module #1 | 31d | 2011-12-02 | 2012-01-24 | 9-120M FS+42d | 206d |
| 142223319 | WLS Fibers final set procurement | 81d | 2012-01-05 | 2012-04-30 | 9-120M FS+60d | 354d |
| 142223252 | ETC Revision of Stacking #3 | 46d | 2012-01-09 | 2012-03-14 | 9-120M FS+62d | 217d |
| 142223280 | Prepare Components Module 5 | 11d | 2012-01-09 | 2012-01-24 | 142223275 FS-165d | 20d |
| 142223372 | ETC Revision of Fiber/PMT assembly Module #2 | 31d | 2012-04-02 | 2012-05-14 | 9-120M FS+120d | 206d |
| 142223300 | Prepare Components Module 6 | 11d | 2012-04-24 | 2012-05-08 | 142223295 FS-210d | 64d |
| 142223565 | Procurement of PMT's and Dividers | 130d | 2012-05-01 | 2012-11-01 | 9-120M FS+141d | 189d |
| 142223272 | Stacking #4 Revised | 30d | 2012-07-12 | 2012-08-22 | 9-120M FS+191d, 142223270 | 20d |
| 142223407 | Fiber/PMT assembly Revised Module #3 | 31d | 2012-07-23 | 2012-09-04 | 142223405, 9-120M FS+198d | 29d |
| 142223275 | Close Module 4 | 6d | 2012-08-23 | 2012-08-30 | 142223272, 142223270 | 20d |

| ID | WBS | Task | Duration | Start | Finish | Predecessors | Total float |
| --- | --- | --- | --- | --- | --- | --- | --- |
| 142223410 |  | Prepare #3 for test | 11d | 2012-09-05 | 2012-09-19 | 142223407, 142223405 | 29d |
| 142223415 |  | Testing #3 FY12 | 7d | 2012-09-20 | 2012-09-28 | 142223410 | 29d |
| 142223285 |  | Assembly of box 5 FY12 | 4d | 2012-09-25 | 2012-09-28 | 142223280 FS+170d | 20d |
| 142223285a |  | Assembly of box 5 FY13 | 7d | 2012-10-01 | 2012-10-09 | 142223285 | 20d |
| 142223415a |  | Testing #3 FY13 | 4d | 2012-10-01 | 2012-10-04 | 142223415 | 29d |
| 142223420 |  | Disassemble #3 | 6d | 2012-10-05 | 2012-10-12 | 142223415a | 29d |
| 142223425 |  | Move #3 to storage | 2d | 2012-10-15 | 2012-10-16 | 142223420 | 29d |
| 142223430 |  | Setup module 4 | 6d | 2012-10-17 | 2012-10-24 | 142223275, 142223425 | 29d |
| 142223550 |  | Store module #3 | 1d | 2012-10-17 | 2012-10-17 | 142223545, 142223425 | 221d |
| 142223435 |  | Prepare components | 11d | 2012-10-25 | 2012-11-08 | 142223430 | 29d |
| 142223570 |  | Repair Calorimeter PMT's | 35d | 2012-11-02 | 2012-12-31 | 142223565 | 189d |
| 142223440 |  | Fiber/PMT assembly Module #4 | 31d | 2012-11-09 | 2013-01-02 | 142223435 | 29d |
| 142223290 |  | Stacking #5 | 46d | 2012-12-07 | 2013-02-20 | 142223285a FS+40d | 20d |
| 142223445 |  | Prepare #4 for test | 11d | 2013-01-03 | 2013-01-17 | 142223440 | 29d |
| 142223450 |  | Testing #4 | 11d | 2013-01-18 | 2013-02-04 | 142223445 | 29d |
| 142223455 |  | Disassemble #4 | 6d | 2013-02-05 | 2013-02-12 | 142223450 | 29d |
| 142223460 |  | Move #4 to storage | 2d | 2013-02-13 | 2013-02-14 | 142223455 | 29d |
| 142223555 |  | Store module #4 | 1d | 2013-02-15 | 2013-02-15 | 142223460, 142223550 | 144d |
| 142223295 |  | Close Module 5 | 6d | 2013-02-21 | 2013-02-28 | 142223290 | 20d |
| 142223305 |  | Assembly of box 6 | 11d | 2013-03-01 | 2013-03-15 | 142223295, 142223300 FS+170d | 35d |
| 142223465 |  | Setup module5 | 6d | 2013-03-01 | 2013-03-08 | 142223460, 142223295 | 20d |
| 142223470 |  | Prepare components | 11d | 2013-03-11 | 2013-03-25 | 142223465 | 20d |
| 142223310 |  | Stacking #6 | 46d | 2013-03-18 | 2013-05-20 | 142223305 | 35d |
| 142223475 |  | Fiber/PMT assembly Module #5 | 31d | 2013-03-26 | 2013-05-07 | 142223470 | 20d |
| 142223480 |  | Prepare #5 for test | 11d | 2013-05-08 | 2013-05-22 | 142223475 | 20d |
| 142223315 |  | Close Module 6 | 6d | 2013-05-21 | 2013-05-29 | 142223310 | 35d |
| 142223485 |  | Testing #5 | 11d | 2013-05-23 | 2013-06-07 | 142223480 | 20d |
| 142223490 |  | Disassemble #5 | 6d | 2013-06-10 | 2013-06-17 | 142223485 | 20d |
| 142223495 |  | Move #5 to storage | 2d | 2013-06-18 | 2013-06-19 | 142223490 | 20d |
| 142223500 |  | Setup module 6 | 6d | 2013-06-20 | 2013-06-27 | 142223495, 142223315 | 20d |
| 142223560 |  | Store module #5 | 1d | 2013-06-20 | 2013-06-20 | 142223495, 142223555 | 58d |
| 142223505 |  | Prepare components | 11d | 2013-06-28 | 2013-07-15 | 142223500 | 20d |
| 142223510 |  | Fiber/PMT assembly Module #6 | 31d | 2013-07-16 | 2013-08-27 | 142223505 | 20d |
| 142223515 |  | Prepare #6 for test | 3d | 2013-08-28 | 2013-08-30 | 142223510 | 20d |
| 142223530 |  | Move #6 to storage (Future Activity Complete prior to Rebaseline) | 1d | 2013-08-30 | 2013-08-30 | 9-130M FS+227d | 20d |
| 142223575 |  | Re-Baseline Actuals Adjustment | 1d | 2013-08-30 | 2013-08-30 | 9-130M FS+227d | 20d |
| 242223312 |  | Procured Labor for Modules 5 & 6 | 39d | 2013-09-03 | 2013-10-25 | 9-130M FS+228d | 447d |
| 242223520 |  | Testing #6 FY13 | 20d | 2013-09-03 | 2013-09-30 | 9-130M FS+228d | 447d |
| 242223575 |  | Forklift Rental for ESB | 43d | 2013-09-03 | 2013-10-31 | 9-130M FS+228d | 528d |
| 242223520a |  | Testing #6 FY14 | 10d | 2013-10-01 | 2013-10-14 | 242223520, 9-130M FS+228d | 447d |
| 242223525 |  | Disassemble #6 | 6d | 2013-10-15 | 2013-10-22 | 242223520a, 242223520 | 447d |
| 242223530 |  | Move #6 to storage | 2d | 2013-10-23 | 2013-10-24 | 242223525 | 447d |
| 242223562 |  | Store module #6 | 1d | 2013-10-25 | 2013-10-25 | 242223530 | 447d |
| 242223563M |  | PCAL Complete | 0d | 2013-10-25 | 2013-10-25 | 242223312, 242223562 | 447d |
| 242223570 |  | Repair Calorimeter PMT's | 172d | 2014-03-05 | 2014-11-04 | 9-140M FS+100d | 279d |
|  | 3 | **1.4.2.2.3 TIME OF FLIGHT** |  | 2009-10-01 | 2015-08-04 |  |  |
|  | 1 | **1.4.2.2.3.1 CENTRAL TOF** |  | 2010-07-01 | 2015-08-04 |  |  |
| 142231014 |  | CTOF Prepare Mezzanine workspace | 142d | 2010-07-01 | 2011-01-31 | 9-100M FS+184d | 665d |
| 142231005 |  | CTOF-P-#1 Prcrmnt of PMTs & Hi Voltage Dividers | 20d | 2010-10-01 | 2010-10-28 | 12222055, 9-110M, 12222055b, 12222045 | 723d |
| 142231015 |  | CTOF-P-#1 Prcrmnt of Scintillators & Readout Sys | 20d | 2010-10-01 | 2010-10-28 | 9-110M, 12222055, 12222055b | 723d |
| 142231012E |  | CTOF-FY12 Travel | 247d | 2011-10-03 | 2012-09-28 | 9-120M | 20d |
| 142231018M |  | CTOF Start Milestone | 0d | 2011-11-01 | 2011-11-01 | 9-120M FS+21d | 20d |
| 142231020 |  | Prepare ALL 30 PR-LETTERS/CONTRACTS | 84d | 2011-11-01 | 2012-03-09 | 142231018M | 61d |
| 142231140 |  | Final Drawings of Tooling for wrapping | 75d | 2011-11-01 | 2012-02-27 | 142231018M | 34d |
| 142231150 |  | Purchase Clamps for Storage/Transport Racks | 46d | 2011-11-01 | 2012-01-13 | 142231018M | 94d |
| 142231155 |  | Purchase parts for Storage/Transportation racks | 33d | 2011-11-01 | 2011-12-19 | 142231018M | 107d |
| 142231160 |  | Final Drawings of Storage-Transportation Rack-25 LG | 30d | 2011-11-01 | 2011-12-14 | 142231018M | 110d |
| 142231185 |  | Purchase/Test/Shipping Acr.Rods to Plastic Craft | 33d | 2011-11-01 | 2011-12-19 | 142231018M | 82d |
| 142231430 |  | Purchase incidentals/tools/material FY12 | 226d | 2011-11-01 | 2012-09-28 | 142231018M | 20d |
| 142231105 |  | Specify the Scintillator Quality | 37d | 2011-12-15 | 2012-02-14 | 142231018M FS+30d | 21d |
| 142231190 |  | Purchase/Fabrication./Shipping Bent .LG's | 79d | 2011-12-20 | 2012-04-18 | 142231180 FS-60d, 142231185, 142231018M FS+20d | 125d |
| 142231130 |  | Final Drawings of Precision Gluing Frame-Table | 55d | 2012-01-06 | 2012-03-26 | 142231018M FS+40d | 20d |
| 142231225 |  | Final Drawings of Counter Support Arm Case | 90d | 2012-01-06 | 2012-05-14 | 142231018M FS+40d | 101d |
| 142231235 |  | Final Drawings of Counter Storage-25 Armed Counters | 44d | 2012-01-06 | 2012-03-09 | 142231018M FS+40d | 110d |
| 142231260 |  | Final Drawings of CTOF Support and Solenoid Harness | 112d | 2012-01-06 | 2012-06-15 | 142231018M FS+40d | 20d |
| 142231270 |  | Final Drawings of Counter installation Arm-Cart | 175d | 2012-01-06 | 2012-09-13 | 142231018M FS+40d | 20d |
| 142231280 |  | Final Drawings of Magnetic Shield Compensating Coil | 49d | 2012-01-06 | 2012-03-16 | 142231018M FS+40d | 107d |
| 142231285 |  | Final Drawings of Magnetic Shield Components | 81d | 2012-01-06 | 2012-05-01 | 142231018M FS+40d | 95d |
| 142231375 |  | Purchase/Fabricate/Ship PMT+Inner.Magn. Shield | 185d | 2012-01-09 | 2012-09-28 | 142231018M FS+41d | 97d |
| 142231330 |  | Purchase/Fabricate/Ship External Magnetic Shields FY12 | 183d | 2012-01-11 | 2012-09-28 | 142231018M FS+43d | 225d |

| ID | Task | Duration | Start | Finish | Predecessors | Total float |
| --- | --- | --- | --- | --- | --- | --- |
| 142231330b | Purchase/Fabricate/Ship External Magnetic Shields Procurement | 206d | 2012-01-11 | 2012-10-31 | 142231018M FS+43d | 225d |
| 142231165 | Fabricate Storage-Transportation Rack-25 USLG | 15d | 2012-01-17 | 2012-02-06 | 142231160, 142231155, 142231150 | 94d |
| 142231170 | Fabricate Storage-Transportation Rack-25 DSLG | 15d | 2012-01-17 | 2012-02-06 | 142231160, 142231150, 142231155 | 142d |
| 142231175 | Shipping Racks to Company USLG | 15d | 2012-02-07 | 2012-02-28 | 142231165 | 94d |
| 142231180 | Shipping Racks to Company DSLG | 15d | 2012-02-07 | 2012-02-28 | 142231175 FS-15d, 142231170 | 142d |
| 142231200 | Purchase buffing tools and materials | 29d | 2012-02-14 | 2012-03-26 | 142231018M FS+66d | 20d |
| 142231110 | Purchase/Fabrication./Ship. Scintillators | 159d | 2012-02-15 | 2012-09-28 | 142231020 FS-57d, 142231105 | 21d |
| 142231145 | Fabricate Tooling for Wrapping | 67d | 2012-02-28 | 2012-05-31 | 142231140 | 34d |
| 142231335 | Purchase Cables and Connectors | 101d | 2012-03-09 | 2012-07-31 | 142231018M FS+83d | 94d |
| 142231240 | Fabricate Storage Racks-25 Armed Counters FY12 | 142d | 2012-03-12 | 2012-09-28 | 142231235, 142231155, 142231150 | 110d |
| 142231290 | Purchase Coil components and materials | 39d | 2012-03-19 | 2012-05-10 | 142231280 | 107d |
| 142231345 | Final Drawings of Patch Panels for LV & HV;200 ch | 47d | 2012-03-20 | 2012-05-23 | 142231018M FS+90d | 95d |
| 142231350 | Final Drawings of Splitter to TDC and ADC; 100 ch | 47d | 2012-03-20 | 2012-05-23 | 142231018M FS+90d | 95d |
| 142231135 | Fabricate Precision Gluing-Frame-Table | 122d | 2012-03-27 | 2012-09-17 | 142231130 | 20d |
| 142231195 | Purchase/Fabrication./Shipping Straight .LG's | 67d | 2012-03-27 | 2012-06-29 | 142231018M FS+95d, 142231175, 142231185 | 75d |
| 142231205 | Purchase 900 shts, 12 sqin, VM2002, for wrapping | 46d | 2012-03-27 | 2012-05-30 | 142231018M FS+95d | 21d |
| 142231210 | Purchase TEDLAR for wrapping | 33d | 2012-03-27 | 2012-05-10 | 142231018M FS+95d | 21d |
| 142231215 | Polishing/finishing LG | 122d | 2012-03-27 | 2012-09-17 | 142231200, 142231205 FS-47d, 142231210 FS-34d, 142231185 | 20d |
| 142231415 | Assemble the DAQ system FY12 | 120d | 2012-04-11 | 2012-09-28 | 142231375 FS-120d | 108d |
| 142231115 | Refurbish Laser Calibration System FY12 | 117d | 2012-04-16 | 2012-09-28 | 142231105 FS+42d | 107d |
| 142231300 | Purchase/Fabricate/Ship Middle.Magn. Shield FY12 | 105d | 2012-05-02 | 2012-09-28 | 142231285 | 95d |
| 142231300b | Purchase/Fabricate/Ship Middle.Magn. Shield Procurement | 128d | 2012-05-02 | 2012-10-31 | 142231285 | 95d |
| 142231305 | Purchase/Fabricate/Ship Middle. Magn. Disks FY12 | 105d | 2012-05-02 | 2012-09-28 | 142231285 | 95d |
| 142231305b | Purchase/Fabricate/Ship Middle. Magn. Disks Procurement | 128d | 2012-05-02 | 2012-10-31 | 142231285 | 95d |
| 142231310 | Purchase/Fabricate/Ship Inner. Magn. Disks FY12 | 105d | 2012-05-02 | 2012-09-28 | 142231285 | 95d |
| 142231310b | Purchase/Fabricate/Ship Inner. Magn. Disks Procurement | 128d | 2012-05-02 | 2012-10-31 | 142231285 | 95d |
| 142231295 | Fabricate Compensating Coil FY12 | 98d | 2012-05-11 | 2012-09-28 | 142231280, 142231290 | 107d |
| 142231230 | Fabricate Counter-Support-Arm -Case FY12 | 96d | 2012-05-15 | 2012-09-28 | 142231225 | 101d |
| 142231355 | Fabricate Patch Panels for LV&HV FY12 | 89d | 2012-05-24 | 2012-09-28 | 142231345, 142231350 | 95d |
| 142231360 | Fabricate Splitter Parts FY12 | 89d | 2012-05-24 | 2012-09-28 | 142231345, 142231350 | 95d |
| 142231220 | Wrapping and Transmittance test of LG | 61d | 2012-06-01 | 2012-08-27 | 142231200, 142231205 FS-31d, 142231210 FS-20d, 142231145 | 34d |
| 142231120 | Purchase OMNICURE S2000 UV Curing system | 65d | 2012-06-15 | 2012-09-14 | 142231018M FS+151d | 21d |
| 142231125 | Purchase UV Glue, Tooling and Materials | 65d | 2012-06-15 | 2012-09-14 | 142231018M FS+151d | 21d |
| 142231265 | Fabricate Solenoid Harness FY12 | 74d | 2012-06-18 | 2012-09-28 | 142231260 | 20d |
| 142231380 | Testing the PMT timing performance FY12 | 60d | 2012-07-06 | 2012-09-28 | 142231375 FS-60d | 97d |
| 142231340 | Fabricate Cables LV&HV FY12 | 42d | 2012-08-01 | 2012-09-28 | 142231335 | 94d |
| 142231245 | Two-side glue Counters in Support Arm FY12 | 9d | 2012-09-18 | 2012-09-28 | 142231195, 142231110 FS-10d, 142231220, 142231125, 142231215, 142231135, 142231190, 142231120 | 20d |
| 142231013E | CTOF-FY13 Travel | 228d | 2012-10-01 | 2013-08-30 | 142231012E | 20d |
| 142231115a | Refurbish Laser Calibration System FY13 | 131d | 2012-10-01 | 2013-04-15 | 142231115 | 107d |
| 142231230a | Fabricate Counter-Support-Arm -Case FY13 | 10d | 2012-10-01 | 2012-10-12 | 142231230 | 101d |
| 142231240a | Fabricate Storage Racks-25 Armed Counters FY13 | 1d | 2012-10-01 | 2012-10-01 | 142231240 | 110d |
| 142231245a | Two-side glue Counters in Support Arm FY13 | 102d | 2012-10-01 | 2013-03-05 | 142231190, 142231120, 142231245, 142231110 FS-10d, 142231220, 142231215, 142231125, 142231135, 142231195 | 20d |
| 142231265a | Fabricate Solenoid Harness FY13 | 228d | 2012-10-01 | 2013-08-30 | 142231265 | 20d |
| 142231295a | Fabricate Compensating Coil FY13 | 21d | 2012-10-01 | 2012-10-29 | 142231295 | 107d |
| 142231300a | Purchase/Fabricate/Ship Middle.Magn. Shield FY13 | 23d | 2012-10-01 | 2012-10-31 | 142231300 | 95d |
| 142231305a | Purchase/Fabricate/Ship Middle. Magn. Disks FY13 | 23d | 2012-10-01 | 2012-10-31 | 142231305 | 95d |
| 142231310a | Purchase/Fabricate/Ship Inner. Magn. Disks FY13 | 23d | 2012-10-01 | 2012-10-31 | 142231310 | 95d |
| 142231320 | Purchase DCPS 6030A 200V/17A Ext.Magn. Shield | 110d | 2012-10-01 | 2013-03-15 | 9-130M, 142231018M FS+10d | 25d |
| 142231330a | Purchase/Fabricate/Ship External Magnetic Shields FY13 | 23d | 2012-10-01 | 2012-10-31 | 142231330 | 225d |
| 142231340a | Fabricate Cables LV&HV FY13 | 34d | 2012-10-01 | 2012-11-15 | 142231340 | 94d |
| 142231355a | Fabricate Patch Panels for LV&HV FY13 | 90d | 2012-10-01 | 2013-02-14 | 142231355 | 95d |
| 142231360a | Fabricate Splitter Parts FY13 | 38d | 2012-10-01 | 2012-11-21 | 142231360 | 95d |
| 142231380a | Testing the PMT timing performance FY13 | 25d | 2012-10-01 | 2012-11-02 | 142231375 FS-60d, 142231380 | 97d |
| 142231415a | Assemble the DAQ system FY13 | 130d | 2012-10-01 | 2013-04-12 | 142231415 | 108d |
| 142231430a | Purchase incidentals/tools/material FY13 | 228d | 2012-10-01 | 2013-08-30 | 142231018M, 142231430 | 20d |
| 142231250 | Counter-in-rack storage and wrapping | 98d | 2012-10-15 | 2013-03-13 | 142231135, 142231215, 142231145, 142231125, 142231120, 142231220, 142231240a, 142231190, 142231110 FS-10d, 142231230a, 142231195 | 101d |
| 142231255 | Transmittance test of assembled Counters in Rack | 98d | 2012-10-15 | 2013-03-13 | 142231190, 142231230a, 142231135, 142231215, 142231125, 142231110 FS-10d, 142231240a, 142231195, 142231220, 142231120 | 101d |
| 142231370 | Assembling of the CTOF splitters | 105d | 2012-11-26 | 2013-05-01 | 142231360a | 95d |
| 142231315 | Purchase Magnet for Magnetic Shields Tests | 110d | 2013-01-10 | 2013-06-17 | 142231018M FS+10d, 9-130M FS+65d | 25d |
| 142231365 | Assembling of the CTOF patch panels | 53d | 2013-02-15 | 2013-05-01 | 142231355a | 95d |
| 142231325 | Assemble the Setup for Magnetic Shields Tests | 123d | 2013-03-04 | 2013-08-23 | 142231320 FS-10d, 142231315 FS-75d | 25d |
| 142231390 | Install PMT and check the orientation | 116d | 2013-03-06 | 2013-08-16 | 142231380, 142231245a, 142231380a | 20d |
| 142231395 | Install shield disks onto the Light guides | 108d | 2013-03-06 | 2013-08-06 | 142231300a, 142231305b, 142231305a, 142231310a, 142231310b, 142231245a, 142231300b | 28d |
| 142231400 | Install compensation coils and check polarity | 110d | 2013-03-06 | 2013-08-08 | 142231245a, 142231295a | 26d |
| 142231405 | Install Middle. Mag. Shields onto PMT | 110d | 2013-03-06 | 2013-08-08 | 142231305b, 142231310b, 142231300b, 142231300a, 142231245a, 142231305a, 142231310a | 26d |
| 142231410 | CTOF in Storage Rack cabling | 110d | 2013-03-06 | 2013-08-08 | 142231310b FS+10d, 142231380, 142231300b FS+10d, 142231340a, 142231380a, 142231310a FS+10d, 142231335, 142231300a FS+10d, 142231305a FS+10d, 142231305b FS+10d, 142231245a | 26d |
| 142231275 | Fabricate Counter-Installation-Arm -Cart | 119d | 2013-03-15 | 2013-08-30 | 142231270 FS+120d | 20d |
| 142231420 | Standalone CTOF testing/optimizing | 10d | 2013-08-19 | 2013-08-30 | 142231370, 142231115a, 142231405, 142231410, 142231400, 142231395, 142231245a FS+29d, 142231415a, 142231245 FS+29d, 142231250 FS+29d, 142231255 FS+29d, 142231390, 142231365 | 20d |
| 142231475 | Re-Baseline Actuals Adjustment | 1d | 2013-08-30 | 2013-08-30 | 9-130M FS+227d | 20d |
| 242231013E | CTOF-FY13 Travel | 20d | 2013-09-03 | 2013-09-30 | 9-130M FS+228d | 498d |

| ID | WBS | Task | Duration | Start | Finish | Predecessors | Total float |
| --- | --- | --- | --- | --- | --- | --- | --- |
| 242231120 |  | Refurbish Laser Calibration System FY 13 Obligated Procurement | 20d | 2013-09-03 | 2013-09-30 | 9-130M FS+228d | 499d |
| 242231140 |  | Final Drawings of Tooling for wrapping | 57d | 2013-10-01 | 2013-12-20 | 9-140M | 121d |
| 242231215 |  | Polishing/finishing LG | 58d | 2013-10-01 | 2014-01-02 | 9-140M, 242231200 FS-140d, 242231205 FS-140d | 133d |
| 242231115 |  | Refurbish Laser Calibration System | 225d | 2013-10-03 | 2014-09-02 | 9-140M FS+2d | 272d |
| 242231125 |  | Purchase UV Glue, Tooling and Materials | 203d | 2013-10-03 | 2014-07-31 | 9-140M FS+2d | 174d |
| 242231200 |  | Purchase buffing tools and materials | 77d | 2013-10-03 | 2014-02-03 | 9-140M FS+2d | 194d |
| 242231205 |  | Purchase 900 shts, 12 sqin, VM2002, for wrapping | 77d | 2013-10-03 | 2014-02-03 | 9-140M FS+2d | 183d |
| 242231260 |  | Final Drawings of CTOF Support and Solenoid Harness | 156d | 2013-10-03 | 2014-05-23 | 9-140M FS+2d | 172d |
| 242231220 |  | Wrapping and Transmittance test of LG | 70d | 2013-10-04 | 2014-01-24 | 242231215 FS-55d | 133d |
| 242231270 |  | Final drawings for counter installation arm - cart and transport rack | 233d | 2013-10-28 | 2014-10-07 | 242231260 FS-139d | 172d |
| 242231145 |  | Fabricate Tooling for Wrapping | 55d | 2013-10-29 | 2014-01-28 | 242231140 FS-37d | 121d |
| 242231460 |  | Purchase stabilized dividers for H2431 PMTs | 77d | 2013-11-04 | 2014-03-05 | 9-140M FS+24d | 242.5d |
| 242231285 |  | Final Drawings of Magnetic Shield Components | 58d | 2013-11-21 | 2014-02-25 | 9-140M FS+37d | 192d |
| 242231280 |  | Final Drawings of Magnetic Shield Compensating Coil | 49d | 2013-12-06 | 2014-02-25 | 9-140M FS+46d | 206d |
| 242231287 |  | Magnetic Shield Engineering Analysis | 21d | 2013-12-20 | 2014-01-30 | 242231285 FS-39d | 210d |
| 242231262 |  | CTOF Support and Solenoid Harness Engineer analysis | 117d | 2014-01-10 | 2014-06-25 | 242231260 FS-95d | 188d |
| 242231245 |  | Two-side glue Counters in Support Arm | 133d | 2014-01-27 | 2014-08-01 | 242231220, 242231215 FS-35d | 133d |
| 242231250 |  | Counter-in-rack storage and wrapping | 109d | 2014-01-29 | 2014-07-01 | 242231220 FS-30d, 242231205 FS-66d, 242231145, 242231215, 242231125 FS-183d | 121d |
| 242231465 |  | Soldering the stabilized dividers for H2431 PMTs | 80.5d | 2014-02-21 | 2014-06-16 | 242231460 FS-9d | 242.5d |
| 242231430 |  | Purchase incidentals/tools/material | 67d | 2014-02-25 | 2014-05-29 | 9-140M FS+94d | 337d |
| 242231435 |  | Purchase/Fabricate/Ship Middle Mag. Disks-2 Procurement | 67d | 2014-02-25 | 2014-05-29 | 9-140M FS+94d | 212d |
| 242231440 |  | Purchase/Fabricate/Ship Extern. Mag. Disks-1 Procurement | 67d | 2014-02-25 | 2014-05-29 | 9-140M FS+94d | 212d |
| 242231445 |  | Purchase/Fabricate/Ship Extern. Mag. Disks-2 Procurement | 67d | 2014-02-25 | 2014-05-29 | 9-140M FS+94d | 212d |
| 242231290 |  | Purchase Coil components and materials | 25d | 2014-02-26 | 2014-04-01 | 242231280, 242231285, 9-130M FS+99d | 206d |
| 242231305 |  | Purchase/Fabricate/Ship Inner Mag. Cylinder Procurement | 96d | 2014-03-10 | 2014-07-23 | 242231287 FS+8d, 242231285 FS+8d, 9-130M FS+99d | 192d |
| 242231272 |  | Counter installation arm - cart and transport rack Engineering Analysis | 74d | 2014-03-20 | 2014-07-02 | 9-140M FS+110d, 242231270 FS-141d | 172d |
| 242231295 |  | Fabricate Compensating Coil Machine Shop | 43d | 2014-03-27 | 2014-05-27 | 242231280, 242231290 FS-4d | 268d |
| 242231300 |  | Fabricate Compensating Coil Procurement | 43d | 2014-03-27 | 2014-05-27 | 242231290 FS-4d, 242231280 FS-110d | 206d |
| 242231390 |  | Install PMT and check the orientation | 70d | 2014-04-03 | 2014-07-14 | 242231465 FS-51d | 242.5d |
| 242231450 |  | Purchase/Fabricate/Ship Inner Mag. Cylinder #1 | 35d | 2014-04-10 | 2014-05-29 | 9-140M FS+126d | 212d |
| 242231455 |  | Purchase/Fabricate/Ship Inner Non-mag. Cylinder #2 | 35d | 2014-04-10 | 2014-05-29 | 9-140M FS+126d | 212d |
| 242231255 |  | Transmittance test of assembled Counters in Rack | 120d | 2014-06-04 | 2014-11-20 | 242231250 FS-20d, 242231215, 242231220, 242231125 FS-183d | 121d |
| 242231275 |  | CTOF procure installation tooling and transport rack | 111d | 2014-08-15 | 2015-02-03 | 242231270 FS-38d, 242231272 FS+30d | 172d |
| 242231395 |  | Install shield disks onto the Light guides | 70d | 2014-09-09 | 2014-12-17 | 242231285 FS-110d, 242231440 FS-9d, 242231305 FS-41d, 242231245 FS+25d, 242231435 FS-9d, 242231445 FS-9d, 9-130M FS+99d | 133d |
| 242231400 |  | Install compensation coils and check polarity | 70d | 2014-09-09 | 2014-12-17 | 242231460 FS-9d, 242231300 FS-1d, 242231450 FS-9d, 242231455 FS-9d, 242231295 FS-63d, 242231245 FS+25d | 133d |
| 242231405 |  | Install Middle. Mag. Shields onto PMT | 70d | 2014-09-09 | 2014-12-17 | 242231245 FS+25d, 9-130M FS+99d, 242231285 FS-110d, 242231305 FS-41d | 133d |
| 242231325 |  | Assemble the Setup for Magnetic Shields Tests | 63d | 2014-09-18 | 2014-12-17 | 242231320 FS-68d | 172d |
| 242231320 |  | Purchase DCPS 6030A 200V/17A Ext.Magn. Shield | 67d | 2014-09-19 | 2015-01-05 | 9-140M FS+239d | 172d |
| 242231265 |  | CTOF procure support and solenoid harness and interface rings | 110d | 2014-10-01 | 2015-03-18 | 9-155M, 242231260, 242231262 | 121d |
| 242231335 |  | Purchase Cables and Connectors | 41d | 2014-10-06 | 2014-12-03 | 9-155M FS+3d | 45d |
| 242231345 |  | Final Drawings of Patch Panels for LV & HV;200 ch | 9d | 2014-10-06 | 2014-10-16 | 9-155M FS+3d | 81d |
| 242231350 |  | Final Drawings of Splitter to TDC and ADC; 100 ch | 42d | 2014-10-17 | 2014-12-17 | 242231345 | 81d |
| 242231355 |  | Fabricate Patch Panels for LV&HV | 84d | 2014-10-17 | 2015-02-26 | 242231345 | 81d |
| 242231340 |  | Fabricate Cables LV&HV | 82d | 2014-11-07 | 2015-03-17 | 242231335 FS-17d | 45d |
| 242231360 |  | Fabricate Splitter Parts | 33d | 2014-12-17 | 2015-02-12 | 242231350 FS-1d, 242231345 FS-1d | 81d |
| 242231385 |  | Testing External magnetic shields | 25d | 2014-12-18 | 2015-02-03 | 242231285 FS-120d, 242231325, 9-130M FS+89d | 172d |
| 242231370 |  | Assembling of the CTOF splitters | 40d | 2015-02-13 | 2015-04-09 | 242231360 | 81d |
| 242231365 |  | Assembling of the CTOF patch panels | 30d | 2015-02-27 | 2015-04-09 | 242231355 | 81d |
| 242231410 |  | CTOF in Storage Rack cabling | 33d | 2015-03-18 | 2015-05-01 | 242231285 FS-100d, 9-130M FS+109d, 242231340, 242231335 FS-10d, 242231245, 242231305 FS+10d | 45d |
| 242231415 |  | Assemble the DAQ system | 25d | 2015-03-30 | 2015-05-01 | 242231410 FS-25d | 45d |
| 242231420 |  | Standalone CTOF testing/optimizing | 29d | 2015-05-04 | 2015-06-15 | 242231370 FS-20d, 242231410, 242231415, 242231245 FS+29d, 242231255 FS+29d, 242231405, 242231120 FS-65d, 242231365 FS-20d, 242231395, 242231400, 242231250, 242231115 FS-65d, 242231200, 242231390 | 45d |
| 242231425 |  | Prepare CTOF-in-Storage-Rack for transportation | 35d | 2015-06-16 | 2015-08-04 | 242231265 FS-15d, 242231420, 242231275 FS-35d, 242231385 FS-35d | 45d |
| 242231470M |  | CTOF Ready for Installation | 0d | 2015-08-04 | 2015-08-04 | 242231430, 242231425, 242231013E | 45d |
|  | 2 | **1.4.2.2.3.2 FORWARD TOF** |  | 2009-10-01 | 2014-03-31 |  |  |
| 142232005 |  | FTOF-P-#1 Prcrmnt of Scintillator Matrl & Light Guides | 60d | 2009-10-01 | 2010-01-04 | 12222060, 9-100M, 1222232030, 12222065 | 806d |
| 142232010 |  | FTOF-P-#1 Prcrmnt of PMTs & Hi Voltage Dividers | 60d | 2009-10-01 | 2010-01-04 | 12222070, 9-100M | 931d |
| 142232015 |  | FTOF-P-#1 Vend Fab of Scintillator Matrl & Light Guides Original Labor | 125d | 2010-01-05 | 2010-07-01 | 142232005 | 806d |
| 142232025 |  | FTOF - P#1 QA of Scintillators and PMTs (Original Labor) | 20d | 2010-05-03 | 2010-05-28 | 9-100M FS+142d | 829d |
| 142232160 |  | Final Drawings | 10d | 2010-06-01 | 2010-06-14 | 9-100M FS+162d | 20d |
| 142232165 |  | FTOF Travel FY10 | 86d | 2010-06-01 | 2010-09-30 | 9-100M FS+162d | 20d |
| 142232200M |  | FTOF Construction Milestone | 0d | 2010-06-01 | 2010-06-01 | 142232160 FS-10d, 9-100M FS+162d | 20d |
| 142232205 |  | PMT /Divider Procurement Prep FY10 | 86d | 2010-06-01 | 2010-09-30 | 142232200M | 248d |
| 142232310 |  | Preparation of USC construction contract | 86d | 2010-06-01 | 2010-09-30 | 142232200M | 20d |
| 142232330 |  | Complete design of panel-1b support FY10 | 86d | 2010-06-01 | 2010-09-30 | 142232200M | 722d |
| 142232340 |  | Finalize panel-1b scintillator lengths | 64d | 2010-06-01 | 2010-08-30 | 142232200M | 840d |
| 142232365 |  | PMT Study Procurement | 86d | 2010-06-01 | 2010-09-30 | 142232200M | 685d |
| 142232370 |  | PMT Studies at JLAB FY10 | 86d | 2010-06-01 | 2010-09-30 | 142232365 FS-86d | 685d |
| 142232230 |  | Scintillator Procurement Prep - Labor FY10 | 64d | 2010-07-01 | 2010-09-30 | 142232200M FS+22d | 312d |
| 142232350 |  | Complete panel-1b manufacturing drawings | 32d | 2010-08-02 | 2010-09-15 | 9-100M FS+205d | 207d |
| 142232270 |  | Backing Support Procurement Prep - Labor FY10 | 21d | 2010-09-01 | 2010-09-30 | 142232200M FS+65d | 189d |

| ID | Task | Duration | Start | Finish | Predecessors | Total float |
| --- | --- | --- | --- | --- | --- | --- |
| 142232170 | FTOF Travel FY11 | 248d | 2010-10-01 | 2011-09-30 | 142232165 | 20d |
| 142232205a | PMT /Divider Procurement Prep FY11 | 22d | 2010-10-01 | 2010-11-01 | 142232205 | 248d |
| 142232230a | Scintillator Procurement Prep - Labor FY11 | 22d | 2010-10-01 | 2010-11-01 | 142232230 | 312d |
| 142232270a | Backing Support Procurement Prep - Labor FY11 | 16d | 2010-10-01 | 2010-10-22 | 142232270 | 189d |
| 142232330a | Complete design of panel-1b support FY11 | 21d | 2010-10-01 | 2010-10-29 | 142232330 | 722d |
| 142232370a | PMT Studies at JLAB FY11 | 58d | 2010-10-01 | 2010-12-30 | 142232370 | 685d |
| 142232220 | Vend Fab PMT /Divider Peg Point #1 First Articles (Qty. 6) | 37d | 2010-12-01 | 2011-01-31 | 142232205a FS+19d | 248d |
| 142232221 | Vend Fab PMT /Divider Peg Point #2 Production Delivery #1 (Qty. 133) | 163d | 2010-12-01 | 2011-07-29 | 142232220 FS-37d | 248d |
| 142232222 | Vend Fab PMT /Divider Peg Point #3 Production Delivery #2 (Qty. 133) | 228d | 2010-12-01 | 2011-10-31 | 142232221 FS-163d | 248d |
| 142232223 | Vend Fab PMT /Divider Peg Point #4 Production Delivery #3 (Qty. 134) | 265d | 2010-12-01 | 2011-12-30 | 142232222 FS-228d | 248d |
| 142232355 | Complete Design of Panel-1a Frame Modification Pieces | 103d | 2011-01-04 | 2011-05-31 | 142232200M FS+145d | 39d |
| 142232315M | Award USC Contract | 0d | 2011-04-01 | 2011-04-01 | 142232310 FS+120d | 20d |
| 142232320 | Peg Point #1 - Set up Assembly Space at USC | 21d | 2011-04-01 | 2011-04-29 | 142232315M | 20d |
| 142232320A | Peg Point #2 - Readiness review at USC | 21d | 2011-04-01 | 2011-04-29 | 142232320 FS-21d | 20d |
| 142232320B | Peg Point #3 - PMT/divider testing start | 21d | 2011-04-01 | 2011-04-29 | 142232320A FS-21d | 20d |
| 142232320C | Peg Point #4 - Scintillator testing start | 42d | 2011-04-01 | 2011-05-31 | 142232320B FS-21d | 20d |
| 142232320D | Peg Point #5 - Phase 1 assembly start (first 5units) | 169d | 2011-04-01 | 2011-11-30 | 142232320C FS-42d | 20d |
| 142232320F | Peg Point #6A - Phase 2 assembly start (next 42 units) Part 1 | 206d | 2011-04-01 | 2012-01-31 | 142232320D FS-169d | 20d |
| 142232240 | Phase 1a FRT (BC-404) first article (3 ea) | 33d | 2011-04-14 | 2011-05-31 | 142232340 FS-377d, 142232230a FS+107d | 312d |
| 142232241 | Phase 1b LAL (BC-408) first article (3 ea) | 33d | 2011-04-14 | 2011-05-31 | 142232240 FS-33d | 312d |
| 142232242 | Phase 1c FRT (BC-404) 72 bars | 98d | 2011-04-14 | 2011-08-31 | 142232241 FS-33d | 312d |
| 142232243 | Phase 1d FRT (BC-404) 90 bars | 140d | 2011-04-14 | 2011-10-31 | 142232242 FS-98d | 312d |
| 142232244 | Phase 1e FRT (BC-404) 24 bars | 177d | 2011-04-14 | 2011-12-30 | 142232243 FS-140d | 312d |
| 142232280 | Backing Support Phase 1 Delivery | 290d | 2011-05-02 | 2012-06-29 | 142232270a FS+125d | 189d |
| 142232356 | Final Panel 1-1/1-b manufacturing support FY11 | 101d | 2011-05-10 | 2011-09-30 | 142232355 FS-15d | 39d |
| 142232352 | Panel 1-a/1-b Installation tooling labor | 10d | 2011-06-01 | 2011-06-14 | 142232350 FS+173d | 207d |
| 142232353 | Panel 1-a/1-b Installation tooling Proc | 22d | 2011-06-01 | 2011-06-30 | 142232352 FS-10d | 207d |
| 142232281 | Backing Support 1st Article Test | 5d | 2011-09-15 | 2011-09-21 | 142232280 FS-195d | 264d |
| 142232175 | FTOF Travel FY12 | 247d | 2011-10-03 | 2012-09-28 | 142232170 | 20d |
| 142232245 | Phase 2a LAL (BC-408) 64 bars | 98d | 2011-10-03 | 2012-02-29 | 142232244 FS-58d | 312d |
| 142232246 | Phase 2b LAL (BC-408) 64 bars | 141d | 2011-10-03 | 2012-04-30 | 142232245 FS-98d | 312d |
| 142232247 | Phase 2c LAL (BC-408) 64 bars | 183d | 2011-10-03 | 2012-06-29 | 142232246 FS-141d | 312d |
| 142232356a | Final Panel 1-1/1-b manufacturing support FY12 | 2d | 2011-10-03 | 2011-10-04 | 142232356 | 39d |
| 142232306 | Panel-1b magnetic shields procurement prep. | 37d | 2011-11-01 | 2011-12-30 | 9-120M FS+21d, 142232205a | 20d |
| 142232320G | Peg Point #6B - Phase 2 assembly start (next 42 units) Part 2 | 306d | 2011-11-01 | 2013-01-31 | 142232320F FS-57d | 20d |
| 142232360 | Complete design of panel-2 support | 184d | 2011-11-01 | 2012-07-31 | 9-120M FS+21d, 142232200M | 188d |
| 142232361 | FTOF storage/work shelves final drawings | 57d | 2011-11-01 | 2012-01-31 | 9-120M FS+21d, 142232160 | 25d |
| 142232371 | Panel-1a/2 magnetic shield first article testing | 37d | 2011-11-01 | 2011-12-30 | 9-120M FS+21d, 142232356a | 20d |
| 142232225 | Vend Fab PMT /Divider Peg Point #5 Production Delivery #4 (Qty. 133) | 69d | 2011-12-15 | 2012-03-30 | 142232223 FS-7d | 248d |
| 142232226 | Vend Fab PMT /Divider Peg Point #6 Production Delivery #5 (Qty. 133) | 132d | 2011-12-15 | 2012-06-29 | 142232225 FS-69d | 248d |
| 142232227 | Vend Fab PMT /Divider Peg Point #7 Production Delivery #6 (Qty. 134) | 196d | 2011-12-15 | 2012-09-28 | 142232226 FS-132d | 248d |
| 142232307 | Panel-1b magnetic shields procurement | 232d | 2012-01-03 | 2012-11-30 | 142232306 | 20d |
| 142232372 | Panel-1a/2 magnetic shields procurement prep. | 105d | 2012-01-03 | 2012-05-31 | 142232371 | 20d |
| 142232375M | Panel 1a Preparation | 0d | 2012-01-03 | 2012-01-03 | 142232200M FS+392d | 20d |
| 142232380 | PMT/Divider Procurement Prep - Labor | 23d | 2012-01-03 | 2012-02-03 | 142232375M | 325d |
| 142232390 | Misc. Counter Repair Parts | 113d | 2012-01-03 | 2012-06-13 | 142232375M | 324d |
| 142232395 | Set up FTOF DAQ and Test Station | 127d | 2012-01-03 | 2012-07-03 | 142232375M | 66.88d |
| 142232396 | Calibration test equipment Procurement | 83d | 2012-01-03 | 2012-04-30 | 142232375M | 354d |
| 142232549M | Panel 2 preparation | 0d | 2012-01-03 | 2012-01-03 | 9-120M FS+58d | 312d |
| 142232550 | PMT/Divider Procurement Prep - Labor | 62d | 2012-01-03 | 2012-03-30 | 142232549M, 142232200M FS+392d | 312d |
| 142232362 | FTOF storage/work shelves - procurement prep. | 31d | 2012-01-17 | 2012-02-29 | 142232361 FS-11d | 25d |
| 142232285 | Backing Support Phase 2 Delivery | 238d | 2012-01-18 | 2012-12-31 | 142232281, 142232280 FS-115d | 189d |
| 142232385 | PMT/Divider Procurement | 90d | 2012-02-03 | 2012-06-12 | 142232380 FS-1d | 325d |
| 142232363 | FTOF storage/work shelves - procurement | 65d | 2012-03-01 | 2012-05-31 | 142232362 | 25d |
| 142232354 | Installation tooling load testing | 43d | 2012-04-02 | 2012-05-31 | 142232353, 9-120M FS+120d | 23d |
| 142232373 | Panel-1a/2 magnetic shields procurement | 129d | 2012-05-01 | 2012-10-31 | 142232372 FS-22d | 20d |
| 142232400 | Deinstallation S1 | 2d | 2012-06-07 | 2012-06-08 | 142232375M FS+108d, 142232354 | 20d |
| 142232420 | Deinstallation S2 | 2d | 2012-06-08 | 2012-06-11 | 142232405 FS-3d | 20d |
| 142232425 | Move S2 to storage | 2d | 2012-06-08 | 2012-06-11 | 142232420 FS-2d | 20d |
| 142232405 | Move S1 to storage | 2d | 2012-06-11 | 2012-06-12 | 142232375M FS+108d, 142232363, 142232400 | 20d |
| 142232440 | Deinstallation S3 | 1d | 2012-06-11 | 2012-06-11 | 142232425 FS-1d | 20d |
| 142232445 | Move S3 to storage | 1d | 2012-06-11 | 2012-06-11 | 142232440 FS-1d | 20d |
| 142232460 | Deinstallation S4 | 2d | 2012-06-11 | 2012-06-12 | 142232445 FS-1d | 20d |
| 142232465 | Move S4 to storage | 2d | 2012-06-11 | 2012-06-12 | 142232460 FS-2d | 20d |
| 142232480 | Deinstallation S5 | 1d | 2012-06-12 | 2012-06-12 | 142232465 FS-1d | 20d |
| 142232485 | Move S5 to storage | 1d | 2012-06-12 | 2012-06-12 | 142232480 FS-1d | 20d |
| 142232500 | Deinstallation S6 | 1d | 2012-06-13 | 2012-06-13 | 142232485 | 20d |
| 142232505 | Move S6 to storage | 1d | 2012-06-14 | 2012-06-14 | 142232500 | 20d |
| 142232565 | Deinstallation | 20d | 2012-06-15 | 2012-07-12 | 142232505 | 20d |
| 142232570 | Move Panel 2 to storage | 20d | 2012-06-15 | 2012-07-12 | 142232565 FS-20d | 20d |

| ID | Task | Duration | Start | Finish | Predecessors | Total float |
| --- | --- | --- | --- | --- | --- | --- |
| 142232654 | Support frame procurement prep | 10d | 2012-06-19 | 2012-07-02 | 9-120M FS+174d | 188d |
| 142232410 | S1 Counter QA and baseline measurements | 21d | 2012-07-02 | 2012-07-30 | 142232375M FS+23d, 142232405 FS+13d | 86d |
| 142232655 | Panel 2 Support Frame Procurement | 123d | 2012-07-03 | 2013-01-02 | 142232565 FS-55d, 142232360 FS-21d, 142232654 | 188d |
| 142232580 | Set up FTOF DAQ + Test Station FY12 | 61d | 2012-07-05 | 2012-09-28 | 142232395 FS+1d | 66.88d |
| 142232575 | Extract panel-2 counters from CLAS6 FY12 | 55d | 2012-07-13 | 2012-09-28 | 142232570 | 20d |
| 142232560 | Misc. Repair Parts | 209d | 2012-08-01 | 2013-06-05 | 142232200M FS+539d | 81d |
| 142232180 | FTOF Travel FY13 | 228d | 2012-10-01 | 2013-08-30 | 142232175 | 20d |
| 142232555 | PMT/Divider Procurement | 63d | 2012-10-01 | 2013-01-07 | 142232550, 9-130M | 185d |
| 142232575a | Extract panel-2 counters from CLAS6 FY13 | 19d | 2012-10-01 | 2012-10-25 | 142232575 | 20d |
| 142232580a | Set up FTOF DAQ + Test Station FY13 | 17.12d | 2012-10-01 | 2012-10-24 | 142232580 | 66.88d |
| 142232231 | Forward carriage patch panels procurement prep. | 36d | 2012-11-01 | 2012-12-31 | 9-130M FS+23d, 142232160 | 42d |
| 142232233 | Patch panel to electronics cables procurement prep. | 36d | 2012-11-01 | 2012-12-31 | 9-130M FS+23d, 142232160 | 106d |
| 142232250 | Signal Cable Procurement Prep - Labor | 57d | 2012-11-01 | 2013-01-31 | 142232200M FS+604d | 105d |
| 142232260 | High Voltage Cable Procurement Prep - Labor | 57d | 2012-11-01 | 2013-01-31 | 142232200M FS+604d | 105d |
| 142232290 | Support Frame Procurement Prep - Labor | 57d | 2012-11-01 | 2013-01-31 | 142232200M FS+604d | 84d |
| 142232300 | Divider adaptor Procurement Prep - Labor | 57d | 2012-11-01 | 2013-01-31 | 142232200M FS+604d | 105d |
| 142232320H | Peg Point #6C - Phase 2 assembly start (next 42 units) Part 3 | 57d | 2012-11-01 | 2013-01-31 | 142232320G FS-57d | 20d |
| 142232320J | Peg Point #7 - Phase 3 assembly start (last 17 units) | 161d | 2012-11-01 | 2013-06-28 | 142232320H FS-57d | 20d |
| 142232320K | Peg Point #8 - JLab Acceptance Test preparation start | 161d | 2012-11-01 | 2013-06-28 | 142232307 FS-20d, 142232320J FS-161d | 20d |
| 142232320N | Peg Point #9 - Panel-1b counters delivered to JLab | 161d | 2012-11-01 | 2013-06-28 | 142232320K FS-161d | 20d |
| 142232320P | Peg Point #10 - Sector assembly start | 205d | 2012-11-01 | 2013-08-30 | 142232320N FS-161d | 20d |
| 142232415 | S1 repair | 21d | 2012-11-01 | 2012-12-03 | 142232373, 142232410 | 20d |
| 142232430 | S2 Counter QA and baseline measurements | 20d | 2012-12-04 | 2013-01-08 | 142232425, 142232415 | 20d |
| 142232232 | Forward carriage patch panels procurement | 147d | 2013-01-02 | 2013-07-31 | 142232231 | 42d |
| 142232234 | Patch panel to electronics cables procurement | 83d | 2013-01-02 | 2013-04-30 | 142232233 | 106d |
| 142232520 | Frame Modification Support Piece Procurement | 40d | 2013-01-02 | 2013-02-28 | 142232355, 142232356a, 142232375M FS+248d | 139d |
| 142232435 | S2 repair | 21d | 2013-01-09 | 2013-02-07 | 142232430 | 20d |
| 142232585 | Counter QA and baseline measurements | 52d | 2013-01-09 | 2013-03-25 | 142232580a, 142232575a FS+45d | 20d |
| 142232255 | Signal Cable Procurement | 63d | 2013-02-01 | 2013-05-01 | 142232250 | 105d |
| 142232265 | High Voltage Cable Procurement | 63d | 2013-02-01 | 2013-05-01 | 142232260 | 105d |
| 142232295 | Support Frame Procurement | 84d | 2013-02-01 | 2013-05-31 | 142232290, 142232350 | 84d |
| 142232305 | Divider adaptor procurement | 63d | 2013-02-01 | 2013-05-01 | 142232300 | 105d |
| 142232450 | S3 Counter QA and baseline measurements | 19d | 2013-02-08 | 2013-03-07 | 142232435 | 20d |
| 142232525 | Install Frame Support Pieces | 10d | 2013-03-01 | 2013-03-14 | 142232520 | 139d |
| 142232455 | S3 repair | 20d | 2013-03-08 | 2013-04-04 | 142232450 | 20d |
| 142232590 | Counter repair | 112d | 2013-03-26 | 2013-08-30 | 142232585 | 20d |
| 142232535 | Set up FTOF DAQ + Test Station | 59d | 2013-04-01 | 2013-06-21 | 142232530 FS-63d | 20d |
| 142232470 | S4 Counter QA and baseline measurements | 15d | 2013-04-05 | 2013-04-25 | 142232455 | 20d |
| 142232475 | S4 repair | 20d | 2013-04-26 | 2013-05-23 | 142232470 | 20d |
| 142232530 | Prepare JLAB construction space | 33d | 2013-05-13 | 2013-06-27 | 142232320N FS-34d | 20d |
| 142232490 | S5 Counter QA and baseline measurements | 21d | 2013-05-24 | 2013-06-24 | 142232475 | 20d |
| 142232540 | Unload counters | 4d | 2013-06-24 | 2013-06-27 | 142232535 | 20d |
| 142232495 | S5 repair | 21d | 2013-06-25 | 2013-07-24 | 142232490 | 20d |
| 142232510 | S6 Counter QA and baseline measurements | 21d | 2013-07-25 | 2013-08-22 | 142232495 | 20d |
| 142232545 | Mount counters to support frame | 25d | 2013-07-29 | 2013-08-30 | 142232540 FS+20d | 20d |
| 142232595 | Mount S1 counters to frame | 10d | 2013-07-30 | 2013-08-12 | 142232590 FS-24d | 20d |
| 142232546 | Panel 1-b QA and baseline measurements | 22d | 2013-08-01 | 2013-08-30 | 142232545 FS-22d | 20d |
| 142232600 | S1 panel-2 QA | 5d | 2013-08-13 | 2013-08-19 | 142232595 | 20d |
| 142232605 | Mount S2 counters to frames | 9d | 2013-08-20 | 2013-08-30 | 142232600 | 20d |
| 142232515 | S6 repair | 6d | 2013-08-23 | 2013-08-30 | 142232510 | 20d |
| 142232610 | S2 panel-2 QA (Future Activity Complete prior to Rebaseline) | 1d | 2013-08-30 | 2013-08-30 | 9-130M FS+227d | 20d |
| 142232615 | Mount S3 counters to frames (Future Activity Complete prior to Rebaseline) | 1d | 2013-08-30 | 2013-08-30 | 9-130M FS+227d | 20d |
| 142232620 | S3 panel-2 QA (Future Activity Complete prior to Rebaseline) | 1d | 2013-08-30 | 2013-08-30 | 9-130M FS+227d | 20d |
| 142232625 | Mount S4 counters to frames (Future Activity Complete prior to Rebaseline) | 1d | 2013-08-30 | 2013-08-30 | 9-130M FS+227d | 20d |
| 142232630 | S4 panel-2 QA (Future Activity Complete prior to Rebaseline) | 1d | 2013-08-30 | 2013-08-30 | 9-130M FS+227d | 20d |
| 142232635 | Mount S5 counters to frames (Future Activity Complete prior to Rebaseline) | 1d | 2013-08-30 | 2013-08-30 | 9-130M FS+227d | 20d |
| 142232640 | S5 panel-2 QA (Future Activity Complete prior to Rebaseline) | 1d | 2013-08-30 | 2013-08-30 | 9-130M FS+227d | 20d |
| 142232645 | Mount S6 counters to frames (Future Activity Complete prior to Rebaseline) | 1d | 2013-08-30 | 2013-08-30 | 9-130M FS+227d | 20d |
| 142232650 | S6 panel-2 QA (Future Activity Complete prior to Rebaseline) | 1d | 2013-08-30 | 2013-08-30 | 9-130M FS+227d | 20d |
| 142232660 | Panel 1-a and Panel 2 signal cables and connectors (672) - proc (Future Activity Complete prior to Rebaseline) | 1d | 2013-08-30 | 2013-08-30 | 9-130M FS+227d | 20d |
| 142232665 | Panel 1-a and Panel 2 signal cables and connectors (672) - assy&test (Future Activity Complete prior to Rebaseline) | 1d | 2013-08-30 | 2013-08-30 | 9-130M FS+227d | 20d |
| 142232680 | Panel 1-a and panel 2 HV cable testing (Future Activity Complete prior to Rebaseline) | 1d | 2013-08-30 | 2013-08-30 | 9-130M FS+227d | 20d |
| 142232690 | Re-Baseline Actuals Adjustment | 1d | 2013-08-30 | 2013-08-30 | 9-130M FS+227d | 20d |
| 242232180 | FTOF Travel FY13 | 20d | 2013-09-03 | 2013-09-30 | 9-130M FS+228d | 494d |
| 242232320Q | Peg Point #11 - Counter baseline measurements complete | 77d | 2013-09-03 | 2013-12-20 | 9-130M FS+228d | 456d |
| 242232320R | Peg Point #12 - Panel-1b assembly and testing complete | 77d | 2013-09-03 | 2013-12-20 | 242232320Q FS-77d | 456d |
| 242232546 | Panel 1-b QA and baseline measurements FY13 | 20d | 2013-09-03 | 2013-09-30 | 9-130M FS+228d | 453d |
| 242232655 | Panel 2 Support Frame Procurement | 139d | 2013-09-03 | 2014-03-31 | 9-130M FS+228d | 453d |
| 242232185 | FTOF Travel FY14 | 57d | 2013-10-01 | 2013-12-20 | 242232180 | 494d |
| 242232546a | Panel 1-b QA and baseline measurements FY14 | 98d | 2013-10-01 | 2014-02-28 | 9-130M FS+228d, 242232546 | 453d |

| ID | WBS | Task | Duration | Start | Finish | Predecessors | Total float |
| --- | --- | --- | --- | --- | --- | --- | --- |
| 242232560 |  | Misc. Repair Parts | 77d | 2013-10-23 | 2014-02-21 | 9-140M FS+16d | 458d |
| 242232232 |  | Forward carriage patch panels procurement | 77d | 2013-10-30 | 2014-02-28 | 9-140M FS+21d | 453d |
| 242232265a |  | High Voltage Cable Procurement (Patch Panel Plates/Brackets) | 77d | 2013-10-30 | 2014-02-28 | 9-140M FS+21d | 453d |
| 242232396 |  | Calibration test equipment Procurement | 77d | 2013-10-30 | 2014-02-28 | 9-140M FS+21d | 453d |
| 242232320S |  | De-Obligation of USC Contract | 1d | 2013-12-20 | 2013-12-20 | 242232320R FS-1d | 456d |
| 242232685M |  | FTOF Complete | 0d | 2014-03-03 | 2014-03-03 | 242232655 FS-21d, 242232265a, 242232185, 242232320S, 242232546a, 242232560, 242232396, 242232546, 242232232, 242232320R | 453d |
|  | 4 | **1.4.2.2.4 CERENKOV** |  | 2009-07-23 | 2015-04-17 |  |  |
|  | 1 | **1.4.2.2.4.1 HIGH THRESHOLD CC** |  | 2009-07-23 | 2015-04-17 |  |  |
| 142241000M |  | HTCC-P-#1 Start Constr | 0d | 2009-07-23 | 2009-07-23 | 1222241035M, 9-100M FS-60d | 486d |
| 142241002 |  | HTCC-P-#1 Procumnt Prep for Mirror Compnts & Tooling FY09 | 49d | 2009-07-23 | 2009-09-30 | 142241000M | 486d |
| 142241002b |  | HTCC-P-#1 Procumnt Prep for Mirror Compnts & Tooling FY10 | 11d | 2009-10-01 | 2009-10-15 | 142241002 | 486d |
| 142241026M |  | HTCC-P-#2 Start Constr | 0d | 2009-10-01 | 2009-10-01 | 9-100M | 70d |
| 142241102 |  | HTCC-P-#2 Procumnt Prep for Mirror Compnts & Tooling | 10d | 2009-10-01 | 2009-10-14 | 142241026M | 70d |
| 142241005 |  | HTCC-P-#1 Vend Manufacturing of Mirror Compnts & Tooling | 37d | 2010-01-05 | 2010-02-26 | 142241002b, 9-100M FS+60d | 437d |
| 142241105 |  | HTCC-P-#2 Vend Manufacturing of Mirror Compnts & Tooling | 37d | 2010-01-05 | 2010-02-26 | 9-100M FS+60d, 142241102 | 20d |
| 142241350M |  | Space required for HTCC construction | 0d | 2010-03-01 | 2010-03-01 | 9-100M FS+97d | 137d |
| 142241465 |  | Procurement Prep for magnetic shields - Lab | 26d | 2010-03-31 | 2010-05-05 | 142241210 FS-296d | 521d |
| 142241360 |  | Transport of all necessary equipment from Test area (room 125, EEL) to the HTCC assembly area | 116d | 2010-04-19 | 2010-09-30 | 142241350M FS+35d | 246d |
| 142241365 |  | Installation of all equipment for all the HTCC equipment and safety review | 116d | 2010-04-19 | 2010-09-30 | 142241360 FS-116d | 246d |
| 142241250 |  | Assembly of the mirror #1 substrate - Lab | 58d | 2010-04-23 | 2010-07-15 | 142241105 FS+39d | 20d |
| 142241470 |  | Manufacturing of magnetic shields - Proc | 165d | 2010-05-06 | 2011-01-06 | 142241465 | 521d |
| 142241355 |  | Procurement of Granite Tables - Proc | 94d | 2010-05-28 | 2010-10-11 | 142241350M FS+64d | 137d |
| 142241210 |  | Manufacturing of the 5" PMT ET-9823QB and HV dividers - Proc | 249d | 2010-06-07 | 2011-06-07 | 142241005 FS+69d | 437d |
| 142241354 |  | HTCC Prepare Mezzanine workspace | 142d | 2010-07-01 | 2011-01-31 | 9-100M FS+184d | 238d |
| 142241475 |  | Tests of up to 10% of magnetic shields - Lab FY10 | 58d | 2010-07-12 | 2010-09-30 | 142241470 FS-120d | 521d |
| 142241255 |  | Trimming of the mirror #1 substrate -Expenses | 5d | 2010-07-16 | 2010-07-22 | 142241250 | 792d |
| 142241260 |  | Quality control of the mirror #1 substrate - Lab | 10d | 2010-07-16 | 2010-07-29 | 142241250 | 20d |
| 142241265 |  | Tooling manufacturing for mirror segments construction - Lab | 16d | 2010-07-29 | 2010-08-19 | 142241260 FS-1d | 20d |
| 142241310 |  | Procurement Prep of ROHACELL foam sheets for substrates manufacturing - Lab | 11d | 2010-07-29 | 2010-08-12 | 142241260 FS-1d | 590d |
| 142241320 |  | Procurement Prep of plastic monomers (acrylic and / or epoxy with low vapor pressure) - Lab | 11d | 2010-07-29 | 2010-08-12 | 142241260 FS-1d | 237d |
| 142241330 |  | Procurement prep of plastic films/sheets of optical quality - Lab | 11d | 2010-07-29 | 2010-08-12 | 142241260 FS-1d | 590d |
| 142241270 |  | Manufacturing of tooling for mirror segments construction - Expenses FY10 | 44d | 2010-07-30 | 2010-09-30 | 142241265 FS-15d | 228d |
| 142241275 |  | Quality Control of tooling for mirror segments construction - Lab FY10 | 44d | 2010-07-30 | 2010-09-30 | 142241265 FS-15d | 619.5d |
| 142241430M |  | Start Manufacturing of the Containment Vessel | 0d | 2010-08-02 | 2010-08-02 | 9-100M FS+205d | 259d |
| 142241435 |  | Procurement prep of CV construction parts - Lab FY10 | 43d | 2010-08-02 | 2010-09-30 | 142241430M | 259d |
| 142241495 |  | Procurement prep of cables and gas systems - Lab FY10 | 43d | 2010-08-02 | 2010-09-30 | 9-100M FS+205d | 505d |
| 142241315 |  | Procurement of ROHACELL foam sheets for substrates manufacturing - Proc | 34d | 2010-08-13 | 2010-09-30 | 142241310 | 590d |
| 142241325 |  | Procurement of plastic monomers (acrylic and / or epoxy with low vapor pressure) - Proc | 34d | 2010-08-13 | 2010-09-30 | 142241320 | 237d |
| 142241335 |  | Procurement of plastic films/sheets of optical quality - Proc | 34d | 2010-08-13 | 2010-09-30 | 142241330 | 590d |
| 142241280 |  | Tooling manufacturing for mirror half-sectors assembly - Lab FY10 | 10d | 2010-09-17 | 2010-09-30 | 142241265 FS+19d | 20d |
| 142241340 |  | Manufacturing of foam mirror substrates - Expenses FY10 | 1d | 2010-09-30 | 2010-09-30 | 142241275a FS-51.5d, 142241335 FS-1d, 142241315 FS-1d | 590d |
| 142241345 |  | Quality control of cut mirror substrates - Lab FY10 | 1d | 2010-09-30 | 2010-09-30 | 142241340a FS-154d | 590d |
| 142241270a |  | Manufacturing of tooling for mirror segments construction - Expenses FY11 | 20d | 2010-10-01 | 2010-10-28 | 142241270 | 228d |
| 142241275a |  | Quality Control of tooling for mirror segments construction - Lab FY11 | 21d | 2010-10-01 | 2010-10-29 | 142241275 | 619.5d |
| 142241280a |  | Tooling manufacturing for mirror half-sectors assembly - Lab FY11 | 14d | 2010-10-01 | 2010-10-20 | 142241280 | 20d |
| 142241340a |  | Manufacturing of foam mirror substrates - Expenses FY11 | 153d | 2010-10-01 | 2011-05-17 | 142241340 | 590d |
| 142241345a |  | Quality control of cut mirror substrates - Lab FY11 | 153d | 2010-10-01 | 2011-05-17 | 142241345 | 590d |
| 142241435a |  | Procurement prep of CV construction parts - Lab FY11 | 108d | 2010-10-01 | 2011-03-15 | 142241435 | 259d |
| 142241475a |  | Tests of up to 10% of magnetic shields - Lab FY11 | 83d | 2010-10-01 | 2011-02-07 | 142241475 | 521d |
| 142241495a |  | Procurement prep of cables and gas systems - Lab FY11 | 2d | 2010-10-01 | 2010-10-04 | 142241495 | 505d |
| 142241500 |  | Manufacturing of high voltage (HV) cable RG8X - Proc | 97d | 2010-10-05 | 2011-03-02 | 142241495a | 505d |
| 142241505 |  | Manufacturing of signal cable PE-B319 - Proc | 97d | 2010-10-05 | 2011-03-02 | 142241495a | 505d |
| 142241510 |  | Manufacturing of HV connectors PE-4193 - Proc | 97d | 2010-10-05 | 2011-03-02 | 142241495a | 505d |
| 142241515 |  | Manufacturing of HV connectors PE-4493 - Proc | 97d | 2010-10-05 | 2011-03-02 | 142241495a | 505d |
| 142241520 |  | Manufacturing of BNC connectors PE-4386 - Proc | 97d | 2010-10-05 | 2011-03-02 | 142241495a | 505d |
| 142241525 |  | Manufacturing of BNC connectors PE-4014 - Proc | 97d | 2010-10-05 | 2011-03-02 | 142241495a | 505d |
| 142241530 |  | Manufacturing of Pump EW-07061-42 - Proc | 97d | 2010-10-05 | 2011-03-02 | 142241495a | 644d |
| 142241535 |  | Manufacturing of Power Supply S-240-15 - Proc | 97d | 2010-10-05 | 2011-03-02 | 142241495a | 644d |
| 142241540 |  | Manufacturing of Controller 250E-4-D - Proc | 97d | 2010-10-05 | 2011-03-02 | 142241495a | 644d |
| 142241545 |  | Manufacturing of Transformer FF-108U Proc | 97d | 2010-10-05 | 2011-03-02 | 142241495a | 644d |
| 142241550 |  | Manufacturing of Utility Chasis CHA-5X21 - Proc | 97d | 2010-10-05 | 2011-03-02 | 142241495a | 644d |
| 142241555 |  | Manufacturing of Controller DP25B-EAR - Proc | 97d | 2010-10-05 | 2011-03-02 | 142241495a | 644d |
| 142241560 |  | Manufacturing of Cable 1255/8BK002 - Proc | 97d | 2010-10-05 | 2011-03-02 | 142241495a | 644d |
| 142241565 |  | Procurement of 1/2 Stainless Steel Tubing - Proc | 97d | 2010-10-05 | 2011-03-02 | 142241495a | 644d |
| 142241370 |  | Assembly of 12 indentical sets and QA of 5 substrates (60 substrates total) - Lab FY11 | 239d | 2010-10-14 | 2011-09-30 | 142241354 FS-70d, 142241325 FS+9d, 142241365, 142241270a FS-40d | 237d |
| 142241375 |  | Tests of assembled substrates - Lab FY11 | 239d | 2010-10-14 | 2011-09-30 | 142241270a FS-11d, 142241365 FS-10d | 418d |
| 142241285 |  | Manufacturing of tooling for mirror half sectors assembly - Expenses | 100d | 2010-10-21 | 2011-03-23 | 142241280a | 30d |
| 142241290 |  | Quality Control of tooling for mirror half-sectors assembly - Lab | 110d | 2010-10-21 | 2011-04-06 | 142241280a | 20d |
| 142241380 |  | Precision trimming of 12 identical sets of 5 substrates (60 substrates total) - Expenses FY11 | 222d | 2010-11-08 | 2011-09-30 | 142241365, 142241270a FS+6d | 228d |
| 142241385 |  | Quality control of trimmed substrates before deposition of coating - Labor FY11 | 221d | 2010-11-09 | 2011-09-30 | 142241370a FS-415d, 142241365, 142241270a FS+7d, 142241380a FS-447.5d | 353d |

| ID | Task | Duration | Start | Finish | Predecessors | Total float |
| --- | --- | --- | --- | --- | --- | --- |
| 142241395 | Quality control of 60 coated substrates - Lab FY11 | 217d | 2010-11-15 | 2011-09-30 | 9-110M FS+31d | 353d |
| 142241480 | Procurement Prep of Light Collectors (WC) - Lab | 23d | 2010-11-24 | 2011-01-05 | 9-110M FS+38d | 317d |
| 142241400 | Tests for coated substrates - Lab FY11 | 207d | 2010-12-01 | 2011-09-30 | 142241385a FS-328d | 353d |
| 142241485 | Manufacturing of Light Collectors (WC) - Proc | 204d | 2011-01-06 | 2011-10-25 | 142241480 | 317d |
| 142241490 | Quality control of Light Collectors (WC) - Lab | 194d | 2011-02-23 | 2011-11-28 | 142241487 FS-366d, 142241485 FS-172d | 317d |
| 142241295 | Tooling manufacturing for combined mirror assembly - Lab | 93d | 2011-04-07 | 2011-08-17 | 142241290 | 482d |
| 142241405 | Dry Fit of Preformed Mirror facets into rings - Lab FY11 | 124d | 2011-04-07 | 2011-09-30 | 142241290, 142241355, 142241285 | 20d |
| 142241410 | Quality control of assembled mirror half-sectors - Lab FY11 | 93d | 2011-05-20 | 2011-09-30 | 142241405a FS-114d | 474d |
| 142241415 | Checks of geometry of mirror half-sectors - Lab FY11 | 93d | 2011-05-20 | 2011-09-30 | 142241405a FS-114d | 474d |
| 142241570 | Procurement Prep of the composite exit window - Lab | 45d | 2011-07-01 | 2011-09-02 | 9-110M FS+184d | 106d |
| 142241300 | Manufacturing of tooling for combined mirror assembly - Expenses FY11 | 31d | 2011-08-18 | 2011-09-30 | 142241295 | 500.5d |
| 142241305 | Quality Control of tooling for combined mirror assembly - Lab FY11 | 31d | 2011-08-18 | 2011-09-30 | 142241295, 142241300a FS-61.5d | 482d |
| 142241450 | Assembly of the CV - Lab FY11 | 12d | 2011-09-15 | 2011-09-30 | 142241440a FS-423d, 142241445a FS-423d, 142241440 FS-423d | 316d |
| 142241300a | Manufacturing of tooling for combined mirror assembly - Expenses FY12 | 12d | 2011-10-03 | 2011-10-18 | 142241300 | 500.5d |
| 142241305a | Quality Control of tooling for combined mirror assembly - Lab FY12 | 13d | 2011-10-03 | 2011-10-19 | 142241305 | 482d |
| 142241370a | Assembly of 12 indentical sets and QA of 5 substrates (60 substrates total) - Lab FY12 | 21d | 2011-10-03 | 2011-10-31 | 142241370 | 237d |
| 142241375a | Tests of assembled substrates - Lab FY12 | 77d | 2011-10-03 | 2012-01-30 | 142241375 | 418d |
| 142241380a | Precision trimming of 12 identical sets of 5 substrates (60 substrates total) - Expenses FY12 | 77d | 2011-10-03 | 2012-01-30 | 142241380 | 228d |
| 142241385a | Quality control of trimmed substrates before deposition of coating - Labor FY12 | 121d | 2011-10-03 | 2012-04-02 | 142241385 | 353d |
| 142241395a | Quality control of 60 coated substrates - Lab FY12 | 142d | 2011-10-03 | 2012-05-01 | 142241395 | 353d |
| 142241400a | Tests for coated substrates - Lab FY12 | 142d | 2011-10-03 | 2012-05-01 | 142241400 | 353d |
| 142241405a | Dry Fit of Preformed Mirror facets into rings - Lab FY12 | 21d | 2011-10-03 | 2011-10-31 | 142241405 | 20d |
| 142241410a | Quality control of assembled mirror half-sectors - Lab FY12 | 21d | 2011-10-03 | 2011-10-31 | 142241410 | 474d |
| 142241415a | Checks of geometry of mirror half-sectors - Lab FY12 | 21d | 2011-10-03 | 2011-10-31 | 142241415 | 474d |
| 142241450a | Assembly of the CV - Lab FY12 | 21d | 2011-10-03 | 2011-10-31 | 142241450 | 316d |
| 142241270b | Manufacturing of tooling for mirror segments construction - Expenses FY12 | 110d | 2011-11-01 | 2012-04-16 | 9-120M FS+21d | 234d |
| 142241370b | Assembly of 12 indentical sets and QA of 5 substrates (60 substrates total) - Revised Lab FY12 | 207d | 2011-11-01 | 2012-08-31 | 142241370a | 237d |
| 142241647 | Proc. Prep of components for the HTCC Light Monitoring System | 28d | 2011-11-01 | 2011-12-12 | 9-120M FS+21d | 208d |
| 142241487 | Manufacturing of Additional Light Collectors (WC) - Proc | 161d | 2011-11-02 | 2012-06-29 | 142241485 FS+5d | 345d |
| 142241302 | Procurement of Lab Equipment for Clean Rooms | 61d | 2012-01-05 | 2012-04-02 | 9-120M FS+60d | 374d |
| 142241445 | Manufacturing of Central Dish for the containment vessel FY12 | 176d | 2012-01-23 | 2012-09-28 | 9-120M FS+71d, 142241435a FS+1d | 49d |
| 142241382 | Precision trimming of 12 identical sets of 5 substrates (60 substrates total) - Additional Expenses FY12 | 170d | 2012-01-31 | 2012-09-28 | 142241270b FS-60d, 142241380a, 142241370b FS-160d | 228d |
| 142241300b | Purchase of Pumps and Plumbing for Combined Mirror Assembly | 61d | 2012-02-03 | 2012-04-30 | 9-120M FS+80d | 21d |
| 142241527 | Procurement of components for the HTCC Gas System construction | 395d | 2012-02-03 | 2013-08-30 | 9-120M FS+80d | 20d |
| 142241440 | Manufacturing of parts for the CV construction - Proc Part A | 302d | 2012-03-12 | 2013-05-24 | 9-120M FS+105d, 142241435a | 20d |
| 142241440a | Manufacturing of parts for the CV construction - Proc Part B | 302d | 2012-03-12 | 2013-05-24 | 9-120M FS+105d, 142241435a | 20d |
| 142241575 | Manufacturing of the composite exit window - Proc | 268d | 2012-04-03 | 2013-04-30 | 142241570 FS+140d | 106d |
| 142241405b | Assembly of the mirror with rings - Lab FY12 | 105d | 2012-05-02 | 2012-09-28 | 142241300b, 142241405a FS+121d | 20d |
| 142241382a | Precision trimming of 12 identical sets of 5 substrates (60 substrates total) - Additional Expenses FY13 | 20d | 2012-10-01 | 2012-10-26 | 142241382 | 228d |
| 142241405ba | Assembly of the mirror with rings - Lab FY13 | 228d | 2012-10-01 | 2013-08-30 | 142241405b | 20d |
| 142241445a | Manufacturing of Central Dish for the containment vessel FY13 | 164d | 2012-10-01 | 2013-05-31 | 142241445 | 49d |
| 142241472 | Procurement of PS for Compensation Coils | 164d | 2012-10-01 | 2013-05-31 | 9-130M | 84d |
| 142241647a | Proc of components for the HTCC Light Monitoring System | 104d | 2012-10-01 | 2013-03-07 | 142241647 FS+10d, 9-130M | 20d |
| 142241585 | Assembly of the photo tube housing unit (PMT, HV divider, Winston Cone, Magnetic Shield) - Lab | 63d | 2012-12-21 | 2013-03-29 | 142241525, 142241460 FS-171d, 142241515, 142241520, 142241500, 142241505, 142241210, 142241475a, 142241510, 142241490 | 52d |
| 142241450b | Assembly of the CV - Lab Revised | 137d | 2013-01-17 | 2013-08-01 | 142241440 FS-90d, 142241445a FS-123d, 142241440a FS-90d, 142241450a | 20d |
| 142241647b | Assembly of optical components and reference detectors in the Aluminum box | 122d | 2013-03-12 | 2013-08-30 | 142241647a FS+2d | 20d |
| 142241647c | Tests of optical components and reference detectors in the Aluminum box | 119d | 2013-03-15 | 2013-08-30 | 142241647b FS-119d | 20d |
| 142241455 | Quality control fo the CV construction - Lab | 93d | 2013-04-22 | 2013-08-30 | 142241450b FS-72d | 52d |
| 142241590 | Installation of 48 housing units - Lab | 76d | 2013-05-15 | 2013-08-30 | 142241450b FS-55d, 142241585 | 20d |
| 142241595 | Quality control of the housing unit assembly and installation - Lab | 76d | 2013-05-15 | 2013-08-30 | 142241590 FS-76d, 142241585 | 20d |
| 142241460 | Test of the CV on structural stability - Lab | 20d | 2013-08-05 | 2013-08-30 | 142241455 FS-20d | 52d |
| 142241580 | Procurement of miscellaneous parts - Proc | 1d | 2013-08-30 | 2013-08-30 | 9-130M FS+227d | 20d |
| 142241600 | Assembly of the composite carbon cone - Lab (Future Activity Complete prior to Rebaseline) | 1d | 2013-08-30 | 2013-08-30 | 9-130M FS+227d | 20d |
| 142241655 | Re-Baseline Actuals Adjustment | 1d | 2013-08-30 | 2013-08-30 | 9-130M FS+227d | 20d |
| 242241370 | Assembly, tests and QA of additional substrates (up to 10 substrates total) FY13 | 20d | 2013-09-03 | 2013-09-30 | 9-130M FS+228d | 526.5d |
| 242241372 | Precision trimming of additional substrates (up to 10 substrates total) - Labor/Expenses FY13 | 20d | 2013-09-03 | 2013-09-30 | 9-130M FS+228d | 494d |
| 242241390 | Coating of 60 substrates with Al + MgF2 - Proc | 72d | 2013-09-03 | 2013-12-13 | 9-130M FS+228d | 159d |
| 242241400 | UCONN Quality control of 60 coated substrates - Lab | 234d | 2013-09-03 | 2014-08-13 | 242241390 FS-72d | 159d |
| 242241415 | Checks of geometry of mirror half-sectors - Expenses FY13 | 20d | 2013-09-03 | 2013-09-30 | 9-130M FS+228d | 168d |
| 242241450aa | Manufacturing of top level assembly parts of the CV construction FY13 | 20d | 2013-09-03 | 2013-09-30 | 9-130M FS+228d | 273d |
| 242241450b | Assembly of the CV FY13 | 20d | 2013-09-03 | 2013-09-30 | 242241450aaa FS-70d, 9-130M FS+228d, 242241450aa FS-70d | 257d |
| 242241452 | Vend Fab HTCC Support Cart | 20d | 2013-09-03 | 2013-09-30 | 9-130M FS+228d | 551d |
| 242241457 | HTCC Winston Cone Fabricate finals | 20d | 2013-09-03 | 2013-09-30 | 9-130M FS+228d | 551d |
| 242241462 | HTCC Consumables | 20d | 2013-09-03 | 2013-09-30 | 9-130M FS+228d | 551d |
| 242241580 | Procurement of miscellaneous parts - Proc | 107d | 2013-09-03 | 2014-02-13 | 9-130M FS+228d | 157d |
| 242241580a | Procurement of miscellaneous parts - Expenses FY13 | 20d | 2013-09-03 | 2013-09-30 | 9-130M FS+228d | 157d |
| 242241455 | Quality control fo the CV construction - Lab FY13 | 10d | 2013-09-17 | 2013-09-30 | 242241450b FS-120d, 242241450ba FS-120d | 257d |
| 242241370a | Assembly, tests and QA of additional substrates (up to 10 substrates total) FY14 | 9.5d | 2013-10-01 | 2013-10-14 | 242241370, 9-130M FS+228d | 526.5d |
| 242241372a | Precision trimming of additional substrates (up to 10 substrates total) - Labor/Expenses FY14 | 42d | 2013-10-01 | 2013-11-27 | 242241372, 9-130M FS+228d | 494d |
| 242241415a | Checks of geometry of mirror half-sectors - Expenses FY14 | 183d | 2013-10-01 | 2014-06-30 | 9-130M FS+228d, 242241415 | 168d |

| ID | WBS | Task | Duration | Start | Finish | Predecessors | Total float |
| --- | --- | --- | --- | --- | --- | --- | --- |
| 242241450aaa |  | Manufacturing of top level assembly parts of the CV construction FY14 | 34d | 2013-10-01 | 2013-11-15 | 9-130M FS+228d, 242241450aa | 273d |
| 242241450ba |  | Assembly of the CV FY14 | 110d | 2013-10-01 | 2014-03-18 | 242241450aaa FS-70d, 9-130M FS+228d, 242241450aa FS-70d, 242241450b | 257d |
| 242241455a |  | Quality control fo the CV construction - Lab FY14 | 129d | 2013-10-01 | 2014-04-14 | 242241450ba FS-120d, 242241455, 242241450b FS-120d | 257d |
| 242241580b |  | Procurement of miscellaneous parts - Expenses FY14 | 87d | 2013-10-01 | 2014-02-13 | 242241580a, 9-130M FS+228d | 157d |
| 242241395 |  | Quality control of 60 coated substrates - Proc | 128d | 2013-10-03 | 2014-04-15 | 242241390 FS-50d | 243d |
| 242241395a |  | Quality control of 60 coated substrates - Lab | 212d | 2013-10-03 | 2014-08-13 | 242241390 FS-50d | 159d |
| 242241300 |  | Tooling manufacturing for Quality Control of combined mirror assembly | 85d | 2013-11-01 | 2014-03-14 | 9-140M FS+23d | 265d |
| 242241405 |  | Dry Fit of Preformed Mirror facets into rings - Lab | 157d | 2013-11-01 | 2014-06-25 | 9-140M FS+23d | 159d |
| 242241647a |  | Proc of components for the HTCC Light Monitoring System | 172d | 2013-11-01 | 2014-07-17 | 9-140M FS+23d | 274d |
| 242241405b |  | Assembly of the mirror with rings - Lab | 150d | 2014-02-05 | 2014-09-05 | 242241405 FS-100d | 159d |
| 242241410 |  | Quality control of assembled mirror half-sectors - Lab | 150d | 2014-02-05 | 2014-09-05 | 242241405 FS-100d | 159d |
| 242241430 |  | Procurement of HEPA filters for the HTCC Clean Room | 290d | 2014-02-05 | 2015-04-06 | 9-140M FS+80d | 166d |
| 242241435 |  | Change Out of HEPA filters for the HTCC Clean Room | 291d | 2014-02-05 | 2015-04-07 | 9-140M FS+80d | 165d |
| 242241585 |  | Assembly of the photo tube housing unit (PMT, HV divider, Winston Cone, Magnetic Shield) - Lab | 163d | 2014-02-14 | 2014-10-03 | 242241580a, 242241580, 242241455 FS-260d, 242241455a FS-260d, 242241580b | 157d |
| 242241600 |  | Assembly of the composite carbon cone - Lab | 20d | 2014-02-17 | 2014-03-14 | 242241455a FS-41d, 242241455 FS-41d | 301d |
| 242241528 |  | Assembly of the HTCC Gas System | 65d | 2014-03-04 | 2014-06-03 | 9-140M FS+99d | 372d |
| 242241605 |  | Installation of the assembled carbon cone - Lab | 107d | 2014-04-14 | 2014-09-12 | 242241600 FS+20d | 301d |
| 242241610 |  | Installation of the composite exit window - Lab | 107d | 2014-04-14 | 2014-09-12 | 242241455 FS-1d, 242241455a FS-1d | 301d |
| 242241417 |  | Manufacturing of modified HV-dividers for the 5" PMTs (50 units)-Lab | 62d | 2014-05-05 | 2014-07-31 | 242241415a FS-40d, 242241415 FS-40d | 168d |
| 242241630 |  | Installation of a temporary CO2 gas supply system - Lab | 44d | 2014-06-17 | 2014-08-18 | 9-140M FS+173d | 319d |
| 242241425 |  | Quality control of the final mirror assembly - Lab | 44d | 2014-08-14 | 2014-10-15 | 242241395a, 242241400, 242241405b FS-16d, 242241410 FS-16d, 242241417, 242241300, 242241395 | 159d |
| 242241590 |  | Installation of 48 housing units - Lab | 43d | 2014-10-06 | 2014-12-05 | 242241450b FS-55d, 242241455 FS+21d, 242241585, 242241450ba FS-55d, 242241455a FS+21d | 157d |
| 242241595 |  | Quality control of the housing unit assembly and installation - Lab | 43d | 2014-10-06 | 2014-12-05 | 242241590 FS-43d, 242241585 | 157d |
| 242241647d5 |  | Quality control of the installed items | 106d | 2014-11-06 | 2015-04-17 | 242241647d FS-62d | 157d |
| 242241647d |  | Installation of LMS | 44d | 2014-12-04 | 2015-02-16 | 242241595 FS-2d, 242241647a FS-21d | 157d |
| 242241640 |  | Installation ofthe ellipsoidal mirror - Lab | 40d | 2015-01-20 | 2015-03-16 | 242241425 FS+57d | 159d |
| 242241645 |  | Optical tests of mirror geometry in situ - Lab | 21d | 2015-03-18 | 2015-04-15 | 242241640 FS+1d | 159d |
| 242241650M |  | HTCC Ready for Installation in the Hall | 0d | 2015-04-17 | 2015-04-17 | 242241645, 242241605, 242241595, 242241372a, 242241430, 242241647d5, 242241435, 242241590, 242241370a, 242241370, 242241372, 242241528, 242241610, 242241630 | 157d |
|  | 2 | **1.4.2.2.4.2 LOW THRESHOLD CC** |  | 2011-11-01 | 2015-02-10 |  |  |
| 142242120 |  | Build Scale Model of Box | 80d | 2011-11-01 | 2012-03-05 | 9-120M FS+21d | 126d |
| 142242000M |  | Space Ready | 0d | 2012-01-12 | 2012-01-12 | 9-120M FS+65d | 330d |
| 142242005 |  | Procure Shelving/Desk/Oscilliscope and Computers for LTCC | 36d | 2012-01-12 | 2012-03-05 | 12222080, 142242000M | 380d |
| 142242015 |  | Transport PMTs to new space | 22d | 2012-01-12 | 2012-02-13 | 142242000M | 330d |
| 142242035 |  | Final Manufacturing Drawings of Alignment Tool | 63d | 2012-01-18 | 2012-04-16 | 9-120M FS+68d | 99d |
| 142242130 |  | Gas Window Simulation | 85d | 2012-01-20 | 2012-05-18 | 9-120M FS+70d, 142242120 FS-31d | 236d |
| 142242140 |  | Box Walls Simulation | 85d | 2012-01-20 | 2012-05-18 | 9-120M FS+70d, 142242120 FS-31d | 126d |
| 142242020 |  | Transport HV Electronics from Hall B to new space | 22d | 2012-02-06 | 2012-03-07 | 142242015 FS-6d | 330d |
| 142242010 |  | Prepare electronics for new space | 14d | 2012-03-06 | 2012-03-23 | 142242005, 142242000M | 380d |
| 142242025 |  | Installation of Electronics, Black Box for PMTS Quality Control | 25d | 2012-03-08 | 2012-04-11 | 142242020 | 330d |
| 142242125 |  | Gas Window Test on Scale Model | 45d | 2012-03-12 | 2012-05-11 | 142242120 FS+4d | 345d |
| 142242030 |  | Quality Control of PMTs | 37d | 2012-04-12 | 2012-06-05 | 142242025, 142242015, 142242020 | 330d |
| 142242040 |  | Procurement Prep of Lasers | 21d | 2012-05-07 | 2012-06-06 | 142242035 FS+14d | 99d |
| 142242065M |  | Space Ready For LTCC Refurb | 0d | 2012-06-01 | 2012-06-01 | 9-120M FS+163d | 54d |
| 142242070 |  | Transport 6 CC Sectors to Work Space | 22d | 2012-06-01 | 2012-07-03 | 142242065M | 54d |
| 142242145 |  | Complete Design Box Walls FY12 | 79d | 2012-06-11 | 2012-09-28 | 142242140 FS+13d | 126d |
| 142242165 |  | Procure Cables FY12 | 79d | 2012-06-11 | 2012-09-28 | 9-120M FS+168d | 190d |
| 142242165b |  | Procure Cables Procurement | 137d | 2012-06-11 | 2012-12-21 | 9-120M FS+168d | 190d |
| 142242220 |  | Online Calibration Design FY12 | 79d | 2012-06-11 | 2012-09-28 | 9-120M FS+168d | 20d |
| 142242135 |  | Gas Window Design FY12 | 74d | 2012-06-18 | 2012-09-28 | 142242130 FS+18d | 236d |
| 142242050 |  | Alignment Tool Manufacturing | 69d | 2012-06-25 | 2012-09-28 | 142242040 FS+12d, 142242035 FS+47d | 99d |
| 142242075 |  | Transport Aligment Frame Support to Work Space | 23d | 2012-07-09 | 2012-08-08 | 142242070 FS+3d | 178d |
| 142242085 |  | Quality Control of Elliptical/Hyperbolic mirrors | 22d | 2012-07-09 | 2012-08-07 | 142242070 FS+3d | 99d |
| 142242090 |  | Dimensions check of Elliptical/Hyperbolic mirrors | 25d | 2012-08-01 | 2012-09-05 | 142242085 FS-5d, 142242070 FS+20d | 99d |
| 142242080 |  | Installation and Aligment of Lasers, Tools and Frame Support | 22d | 2012-08-13 | 2012-09-12 | 142242075 FS+2d | 178d |
| 142242180 |  | Gas Line Design FY12 | 19d | 2012-09-04 | 2012-09-28 | 142242070 FS+43d | 54d |
| 142242045 |  | Procurement Lasers | 79d | 2012-10-01 | 2013-01-30 | 142242040 FS+2d, 9-130M | 20d |
| 142242135a |  | Gas Window Design FY13 | 12d | 2012-10-01 | 2012-10-16 | 142242135 | 236d |
| 142242145a |  | Complete Design Box Walls FY13 | 6d | 2012-10-01 | 2012-10-08 | 142242145 | 126d |
| 142242165a |  | Procure Cables FY13 | 58d | 2012-10-01 | 2012-12-21 | 142242165 | 190d |
| 142242170 |  | Procure PMTs | 171d | 2012-10-01 | 2013-06-11 | 9-130M | 53d |
| 142242180a |  | Gas Line Design FY13 | 67d | 2012-10-01 | 2013-01-11 | 142242180 | 54d |
| 142242220a |  | Online Calibration Design FY13 | 125d | 2012-10-01 | 2013-04-05 | 142242220 | 20d |
| 142242210 |  | Transport of FADC, DAQ, Computer, Electronics for 1 Sector | 37d | 2012-11-05 | 2013-01-04 | 9-130M FS+25d | 139d |
| 142242095 |  | Create Manufacturing Drawings | 64d | 2013-01-03 | 2013-04-04 | 9-130M FS+60d, 142242090 FS+7d | 42d |
| 142242100 |  | Removal of mirrors | 82d | 2013-01-03 | 2013-04-30 | 9-130M FS+60d, 142242090 FS-2d | 20d |
| 142242055 |  | Alignment Tool and Lasers Installation | 16d | 2013-01-16 | 2013-02-07 | 142242050 FS-10d, 142242045 FS-10d | 20d |
| 142242185 |  | Procure Gas Line | 92d | 2013-01-22 | 2013-05-31 | 142242180a FS+5d | 54d |
| 142242215 |  | Installation of FADC, DAQ, Computer, Electronics for 1 Sector | 36d | 2013-01-23 | 2013-03-14 | 142242210 FS+11d | 139d |
| 142242060 |  | Alignment Tool and Lasers Quality Control | 23d | 2013-02-14 | 2013-03-19 | 142242055 FS+4d | 136d |
| 142242175 |  | PMTs Quality Control | 99d | 2013-02-26 | 2013-07-16 | 142242170 FS-75d | 53d |

| ID | Task | Duration | Start | Finish | Predecessors | Total float |
| --- | --- | --- | --- | --- | --- | --- |
| 142242150 | PMTs Removal | 77d | 2013-03-04 | 2013-06-19 | 142242145a FS+9d, 9-130M FS+100d | 41d |
| 142242155 | Walls Manufacturing and Installation | 79d | 2013-04-11 | 2013-08-01 | 142242150 FS-49d, 142242145a | 41d |
| 142242200 | Elliptical Mirror Tool/Frame Alignment | 22d | 2013-05-07 | 2013-06-06 | 142242055 FS+61d, 142242080, 142242095 | 20d |
| 142242105 | Al/Mg Deposit Procurement Prep | 43d | 2013-05-10 | 2013-07-11 | 142242100 FS+7d | 20d |
| 142242190 | Install Gas Line | 15d | 2013-05-20 | 2013-06-10 | 142242185 FS-9d | 54d |
| 142242225 | Online Calibration Test | 73d | 2013-05-20 | 2013-08-30 | 142242220a FS+30d | 20d |
| 142242205 | Mirrors Laser Alignments | 57d | 2013-06-12 | 2013-08-30 | 142242200 FS+3d | 20d |
| 142242195 | Gas Line Quality Control | 15d | 2013-06-24 | 2013-07-15 | 142242190 FS+9d | 54d |
| 142242110 | Al/Mg Deposit Procurement | 26d | 2013-07-26 | 2013-08-30 | 142242105 FS+10d | 20d |
| 142242245 | Re-Baseline Actuals Adjustment | 1d | 2013-08-30 | 2013-08-30 | 9-130M FS+227d | 20d |
| 242242036 | Wavelength Shifting tests Labor/Expenses FY13 | 20d | 2013-09-03 | 2013-09-30 | 9-130M FS+228d | 252d |
| 242242045 | Procurement Lasers - Procurement | 95d | 2013-09-03 | 2014-01-28 | 9-130M FS+228d | 216d |
| 242242045a | Procurement Lasers - Labor FY13 | 20d | 2013-09-03 | 2013-09-30 | 9-130M FS+228d | 216d |
| 242242095 | Create Manufacturing Drawings FY13 | 20d | 2013-09-03 | 2013-09-30 | 9-130M FS+228d | 249d |
| 242242105 | Al/Mg Deposit Procurement Prep FY13 | 20d | 2013-09-03 | 2013-09-30 | 9-130M FS+228d | 220d |
| 242242145a | Complete Design Box Walls FY13 | 20d | 2013-09-03 | 2013-09-30 | 9-130M FS+228d | 467d |
| 242242152 | Window Procurement | 139d | 2013-09-03 | 2014-03-31 | 9-130M FS+228d | 185d |
| 242242152a | Window Procurement - Labor FY13 | 20d | 2013-09-03 | 2013-09-30 | 9-130M FS+228d | 185d |
| 242242220a | Online Calibration Design FY13 | 20d | 2013-09-03 | 2013-09-30 | 9-130M FS+228d | 239d |
| 242242222 | Online HV Matching Design FY13 | 20d | 2013-09-03 | 2013-09-30 | 242242220aa FS-202d, 242242220a FS-202d | 239d |
| 242242290 | Cut Line Mark | 20d | 2013-09-03 | 2013-09-30 | 9-130M FS+228d | 382d |
| 242242325 | Spine Refusrbish FY13 | 20d | 2013-09-03 | 2013-09-30 | 242242320 FS-289d, 242242315 FS-289d | 255d |
| 242242031 | Quality Control of Existing PMTs FY13 | 15d | 2013-09-10 | 2013-09-30 | 9-130M FS+233d | 248d |
| 242242107 | Al/Mg Laxon/Acrylic Re-Coating Test Procurement Labor FY13 | 15d | 2013-09-10 | 2013-09-30 | 9-130M FS+233d | 236d |
| 242242280 | Frame Support FY13 | 9d | 2013-09-18 | 2013-09-30 | 9-130M FS+239d | 470d |
| 242242050 | Alignment Tool Manufacturing Labor/Expenses FY13 | 7d | 2013-09-20 | 2013-09-30 | 9-130M FS+241d | 217d |
| 242242295 | Wall Cut-Off FY13 | 1d | 2013-09-30 | 2013-09-30 | 242242290 FS-1d | 382d |
| 242242031a | Quality Control of Existing PMTs FY14 | 169d | 2013-10-01 | 2014-06-10 | 9-130M FS+233d, 242242031 | 248d |
| 242242036a | Wavelength Shifting tests Labor/Expenses FY14 | 11d | 2013-10-01 | 2013-10-15 | 9-130M FS+228d, 242242036 | 252d |
| 242242045b | Procurement Lasers - Labor FY14 | 75d | 2013-10-01 | 2014-01-28 | 9-130M FS+228d, 242242045a | 216d |
| 242242050a | Alignment Tool Manufacturing Labor/Expenses FY14 | 52d | 2013-10-01 | 2013-12-13 | 242242050, 9-130M FS+241d | 217d |
| 242242095a | Create Manufacturing Drawings FY14 | 8d | 2013-10-01 | 2013-10-10 | 242242095, 9-130M FS+228d | 249d |
| 242242105a | Al/Mg Deposit Procurement Prep FY14 | 6d | 2013-10-01 | 2013-10-08 | 242242105, 9-130M FS+228d | 220d |
| 242242107a | Al/Mg Laxon/Acrylic Re-Coating Test Procurement Labor FY14 | 30d | 2013-10-01 | 2013-11-11 | 9-130M FS+233d, 242242107 | 236d |
| 242242145aa | Complete Design Box Walls FY14 | 16d | 2013-10-01 | 2013-10-22 | 242242145a, 9-130M FS+228d | 467d |
| 242242152b | Window Procurement -Labor FY14 | 119d | 2013-10-01 | 2014-03-31 | 9-130M FS+228d, 242242152a | 185d |
| 242242220aa | Online Calibration Design FY14 | 182d | 2013-10-01 | 2014-06-27 | 242242220a, 9-130M FS+228d | 239d |
| 242242222a | Online HV Matching Design FY14 | 182d | 2013-10-01 | 2014-06-27 | 242242220aa FS-202d, 242242222, 242242220a FS-202d | 239d |
| 242242245 | Simulation of Sagging Test | 100d | 2013-10-01 | 2014-03-04 | 9-140M | 383d |
| 242242280a | Frame Support FY14 | 46d | 2013-10-01 | 2013-12-05 | 9-130M FS+239d, 242242280 | 470d |
| 242242295a | Wall Cut-Off FY14 | 134d | 2013-10-01 | 2014-04-21 | 242242295, 242242290 FS-1d | 382d |
| 242242325a | Spine Refusrbish FY14 | 261d | 2013-10-01 | 2014-10-20 | 242242325, 242242320 FS-289d, 242242315 FS-289d | 255d |
| 242242310 | PMTS, Mirrors Holes Drill | 213d | 2013-10-08 | 2014-08-19 | 242242305 FS-200d | 249d |
| 242242030 | Quality Control of PMTs | 162d | 2013-10-10 | 2014-06-10 | 9-140M FS+7d | 347d |
| 242242155 | Walls Manufacturing and Installation | 39d | 2013-10-15 | 2013-12-10 | 242242145a FS-6d, 242242145aa FS-6d | 467d |
| 242242340 | Sector 2 Box Refurbish | 28d | 2013-10-30 | 2013-12-10 | 9-140M FS+21d | 185d |
| 242242085 | Quality Control of Elliptical/Hyperbolic mirrors | 178d | 2013-10-31 | 2014-07-24 | 9-140M FS+22d | 348d |
| 242242055 | Alignment Tool and Lasers Installation | 87d | 2013-11-01 | 2014-03-18 | 242242050a FS-30d, 242242045 FS-52d, 242242050 FS-30d, 242242045a FS-52d, 242242045b FS-52d | 216d |
| 242242335 | Box Refurbish Consumables | 281d | 2013-11-01 | 2014-12-22 | 9-140M FS+23d | 212d |
| 242242300 | Rear Brace Manufacture | 74d | 2013-11-04 | 2014-02-28 | 242242095a FS+16d, 242242095 FS+16d | 249d |
| 242242108 | Lexan/Acrylic/Over- Coating Procurement (all sectors) | 241d | 2013-11-11 | 2014-10-31 | 242242107 FS-1d, 242242107a FS-1d | 246d |
| 242242110 | Al/Mg Deposit Procurement | 259d | 2013-11-11 | 2014-11-26 | 242242105 FS+23d, 242242105a FS+23d | 220d |
| 242242161 | HV Cables Catalog and Tagging | 103d | 2013-11-12 | 2014-04-18 | 9-140M FS+30d | 311.5d |
| 242242162 | Divider Modifications Design and Test | 55d | 2013-11-12 | 2014-02-11 | 9-130M FS+228d, 9-140M FS+30d | 226d |
| 242242165b | Procure Cables Procurement | 149d | 2013-11-12 | 2014-06-24 | 9-140M FS+30d | 337d |
| 242242092 | Al/Mg Deposit Procurement WC | 245d | 2013-11-19 | 2014-11-14 | 242242107a FS+5d, 242242107 FS+5d | 236d |
| 242242137 | Glue Procurement | 74d | 2013-12-05 | 2014-03-31 | 9-140M FS+45d | 397d |
| 242242255 | Procurement Sagging Test Tools | 52d | 2014-01-03 | 2014-03-18 | 242242245 FS-42d | 383d |
| 242242260 | Manufacture Sagging Test Tools | 52d | 2014-01-03 | 2014-03-18 | 242242245 FS-42d | 383d |
| 242242076 | Support Frame Fabrication for 1S in TED | 61d | 2014-01-07 | 2014-04-02 | 9-140M FS+60d | 395d |
| 242242077 | Infrastructure Consumables | 162d | 2014-01-07 | 2014-08-25 | 9-140M FS+60d | 294d |
| 242242090 | Dimensions check of Elliptical/Hyperbolic mirrors | 188d | 2014-01-07 | 2014-10-01 | 242242085 FS-220d, 9-140M FS+60d | 268d |
| 242242040 | Wavelength Shifting Procurement | 203d | 2014-01-08 | 2014-10-23 | 242242036 FS+50d, 242242036a FS+50d | 252d |
| 242242305 | Rear Brace Installation | 137d | 2014-01-17 | 2014-07-31 | 242242300 FS-30d | 249d |
| 242242115 | Installation of Elliptical mirrors | 227d | 2014-01-21 | 2014-12-10 | 242242110 FS-219d | 220d |
| 242242230 | PMT Installation | 219d | 2014-01-21 | 2014-11-26 | 242242031 FS-100d, 242242310 FS-150d, 242242031a FS-100d | 248d |
| 242242320 | Nose Extension Installation | 200d | 2014-01-21 | 2014-10-30 | 9-140M FS+69d | 255d |
| 242242365 | Sector 3 Box Refurbish | 21d | 2014-01-21 | 2014-02-18 | 242242360 FS-163d | 293d |
| 242242205 | Mirrors Laser Alignments | 222d | 2014-02-03 | 2014-12-16 | 242242095, 242242055 FS-32d, 242242095a | 216d |
| 242242315 | Patch Panel Installation | 185d | 2014-02-11 | 2014-10-30 | 242242230 FS-204d | 255d |

| ID | WBS | Task | Duration | Start | Finish | Predecessors | Total float |
| --- | --- | --- | --- | --- | --- | --- | --- |
| 242242169 |  | New Patch Panel Fabrication | 120d | 2014-02-11 | 2014-07-31 | 242242161 FS-48.5d | 311.5d |
| 242242163 |  | Divider Modifications Procurement | 220d | 2014-02-12 | 2014-12-23 | 242242162 | 226d |
| 242242164 |  | Divider Modifications Implementation | 205d | 2014-02-12 | 2014-12-02 | 242242163 FS-220d | 226d |
| 242242330 |  | Gas Line Refurbish | 165d | 2014-02-27 | 2014-10-20 | 242242325 FS-165d, 242242325a FS-165d | 255d |
| 242242390 |  | Sector 4 Box Refurbish | 27d | 2014-03-03 | 2014-04-08 | 242242385 FS-170d | 301d |
| 242242235 |  | Windows Installation 6 sectors | 197d | 2014-03-04 | 2014-12-10 | 242242152 FS-20d, 242242230 FS-252d, 242242152b FS-20d, 242242152a FS-20d | 185d |
| 242242270 |  | Sagging Test | 23d | 2014-03-19 | 2014-04-18 | 242242255, 242242260 | 383d |
| 242242415 |  | Sector 5 Box Refurbish | 22d | 2014-04-14 | 2014-05-13 | 242242410 FS-172d | 302d |
| 242242350 |  | Sector 2 Mirrors Alignment | 50d | 2014-04-15 | 2014-06-24 | 242242340 FS+80d | 185d |
| 242242240 |  | Gas Leak Check 6 sectors | 174d | 2014-05-23 | 2015-02-10 | 242242235 FS-139d | 185d |
| 242242440 |  | Sector 6 Box Refurbish | 16d | 2014-05-27 | 2014-06-17 | 242242435 FS-158d | 300d |
| 242242223 |  | Online HV Matching Test | 110d | 2014-06-09 | 2014-11-11 | 242242220aa FS-15d, 242242222 FS-15d, 242242220a FS-15d, 242242222a FS-15d | 239d |
| 242242355 |  | Sector 2 Windows Installation | 11d | 2014-06-30 | 2014-07-15 | 242242350 FS+3d | 185d |
| 242242375 |  | Sector 3 Mirrors Alignment | 26d | 2014-07-22 | 2014-08-26 | 242242355 FS+4d, 242242365 FS-1d | 185d |
| 242242360 |  | Sector 2 Gas Leaks Checks | 26d | 2014-08-04 | 2014-09-09 | 242242355 FS+13d | 293d |
| 242242380 |  | Sector 3 Windows Installation | 14d | 2014-08-27 | 2014-09-16 | 242242375 | 185d |
| 242242400 |  | Sector 4 Mirrors Alignment | 26d | 2014-09-23 | 2014-10-28 | 242242390, 242242380 FS+4d | 185d |
| 242242385 |  | Sector 3 Gas Leaks Checks | 22d | 2014-09-30 | 2014-10-29 | 242242380 FS+9d | 301d |
| 242242170 |  | Patch Panel Connectors Procurement | 77d | 2014-10-01 | 2015-01-30 | 9-155M | 192d |
| 242242185 |  | Procure Gas Line | 33d | 2014-10-01 | 2014-11-14 | 9-155M | 215d |
| 242242215 |  | Installation of FADC, DAQ, Computer, Electronics for 1 Sector | 42d | 2014-10-01 | 2014-12-01 | 9-155M | 227d |
| 242242225 |  | Online Calibration Test | 24d | 2014-10-09 | 2014-11-11 | 242242222, 242242223 FS-24d, 242242220a, 242242220aa, 242242222a | 239d |
| 242242405 |  | Sector 4 Windows Installation | 15d | 2014-10-29 | 2014-11-18 | 242242400 | 302d |
| 242242425 |  | Sector 5 Mirrors Alignment | 10d | 2014-10-29 | 2014-11-11 | 242242415, 242242400 | 185d |
| 242242190 |  | Install Gas Line (1S) | 10d | 2014-11-25 | 2014-12-10 | 242242185 FS+6d | 215d |
| 242242410 |  | Sector 4 Gas Leaks Checks | 13d | 2014-11-26 | 2014-12-16 | 242242405 FS+5d | 302d |
| 242242430 |  | Sector 5 Windows Installation | 13d | 2014-11-26 | 2014-12-16 | 242242425 FS+10d | 300d |
| 242242450 |  | Sector 6 Mirrors Alignment | 13d | 2014-11-26 | 2014-12-16 | 242242425 FS+10d, 242242440 FS-2d | 185d |
| 242242195 |  | Gas Line Quality Control | 5d | 2014-12-11 | 2014-12-17 | 242242190 | 215d |
| 242242435 |  | Sector 5 Gas Leaks Checks | 16d | 2014-12-17 | 2015-01-20 | 242242430 | 300d |
| 242242455 |  | Sector 6 Windows Installation | 16d | 2014-12-17 | 2015-01-20 | 242242450 | 185d |
| 242242460 |  | Sector 6 Gas Leaks Checks | 16d | 2015-01-20 | 2015-02-10 | 242242455 FS-1d | 185d |
| 242242500M |  | LTCC Complete | 0d | 2015-02-10 | 2015-02-10 | 242242036, 242242215, 242242335, 242242340, 242242460, 242242031, 242242161, 242242280, 242242330, 242242165b, 242242225, 242242169, 242242170, 242242295, 242242195, 242242107a, 242242295a, 242242077, 242242240, 242242030, 242242155, 242242205, 242242095a, 242242280a, 242242040, 242242270, 242242076, 242242090, 242242092, 242242095, 242242115, 242242036a, 242242164, 242242137, 242242107, 242242108, 242242031a | 185d |
|  | 3 | **1.4.2.3 COMPUTING** |  | 2010-10-01 | 2015-08-12 |  |  |
|  | 1 | **1.4.2.3.1 TRIGGER SYSTEM (Scintillators)** |  | 2011-12-01 | 2015-04-28 |  |  |
| 14231015 |  | SSP single board tests | 17d | 2011-12-01 | 2011-12-30 | 9-120M FS+41d | 183d |
| 14231035 |  | GTP single board tests | 17d | 2011-12-01 | 2011-12-30 | 9-120M FS+41d | 209d |
| 14231100 |  | TS single board tests | 17d | 2011-12-01 | 2011-12-30 | 9-120M FS+41d | 306d |
| 14231005 |  | CTP Procurement Prep | 5d | 2012-01-03 | 2012-01-09 | 12223040M, 12223045, 9-120M FS+58d | 204d |
| 14231020 |  | SSP procurement prep | 6d | 2012-02-01 | 2012-02-08 | 14231015 FS+20d | 183d |
| 14231055 |  | SD procurement prep | 6d | 2012-04-02 | 2012-04-09 | 9-120M FS+120d | 20d |
| 14231060 |  | SD procurement (24 boards) | 180d | 2012-04-10 | 2012-12-31 | 14231055 | 20d |
| 14231070 |  | TI procurement prep | 6d | 2012-05-01 | 2012-05-08 | 9-120M FS+141d | 20d |
| 14231075 |  | TI procurement (52 boards) | 159d | 2012-05-09 | 2012-12-31 | 14231070 | 20d |
| 14231085 |  | TD procurement prep | 6d | 2012-06-01 | 2012-06-11 | 9-120M FS+163d | 20d |
| 14231090 |  | TD procurement (10 boards) | 137d | 2012-06-12 | 2012-12-31 | 14231085 | 20d |
| 14231007 |  | CTP procurement (22 boards) | 99d | 2012-10-01 | 2013-02-28 | 14231005, 9-130M | 20d |
| 14231025 |  | SSP procurement (15 boards) | 130d | 2012-10-01 | 2013-04-12 | 14231020, 9-130M | 20d |
| 14231040 |  | GTP procurement prep | 46d | 2012-11-28 | 2013-02-08 | 9-130M FS+40d, 14231035 FS+40d | 20d |
| 14231065 |  | SD testing of 24 boards | 169d | 2013-01-02 | 2013-08-30 | 14231060 | 20d |
| 14231045 |  | GTP procurement (2 boards) | 93d | 2013-02-11 | 2013-06-21 | 9-130M, 14231040 | 20d |
| 14231105 |  | TS procurement prep | 6d | 2013-04-08 | 2013-04-15 | 9-130M FS+125d, 14231100 FS+125d | 117d |
| 14231030 |  | SSP testing of 15 boards (Future Activity Complete prior to Rebaseline) | 1d | 2013-08-30 | 2013-08-30 | 9-130M FS+227d | 20d |
| 14231095 |  | TD testing of 10 boards (Future Activity Complete prior to Rebaseline) | 1d | 2013-08-30 | 2013-08-30 | 9-130M FS+227d | 20d |
| 14231125 |  | Re-Baseline Actuals Adjustment | 1d | 2013-08-30 | 2013-08-30 | 9-130M FS+227d | 20d |
| 24231000 |  | AVAGO QSFP OPTIC TRANS | 43d | 2013-09-03 | 2013-10-31 | 9-130M FS+228d | 528d |
| 24231045 |  | GTP procurement (2 boards) | 78d | 2013-10-01 | 2014-01-31 | 9-140M | 351d |
| 24231005 |  | CTP procurement Prep | 20d | 2014-10-01 | 2014-10-28 | 9-155M | 41d |
| 24231007 |  | CTP procurement (22 boards) | 119d | 2014-10-29 | 2015-04-28 | 24231005 | 41d |
|  | 2 | **1.4.2.3.2 DAQ** |  | 2012-01-03 | 2015-08-12 |  |  |
| 14232010 |  | CLAS12 DAQ/online software updates FY12 | 189d | 2012-01-03 | 2012-09-28 | 9-120M FS+58d | 20d |
| 14232030 |  | Re-Baseline Actuals Adjustment | 1d | 2013-08-30 | 2013-08-30 | 9-130M FS+227d | 20d |
| 24232022 |  | Procure GE VME controllers (53) | 126d | 2014-10-01 | 2015-04-09 | 9-155M | 92d |
| 24232025 |  | Install GE VME controllers (22) | 86d | 2015-04-10 | 2015-08-12 | 24232022 | 92d |
|  | 3 | **1.4.2.3.3 ONLINE COMPUTING** |  | 2011-10-03 | 2015-07-23 |  |  |
| 14233005 |  | ONLINE COMP-P-#1 Contsruction Setup Historical Contributed Labor | 21d | 2011-10-03 | 2011-10-31 | 9-120M | 474d |
| 14233007 |  | CLAS12 Online and Monitoring software updates | 186d | 2012-01-06 | 2012-09-28 | 9-120M FS+61d | 248d |
| 14233075 |  | Re-Baseline Actuals Adjustment | 1d | 2013-08-30 | 2013-08-30 | 9-130M FS+227d | 20d |
| 24233010 |  | Ethernet wiring inside Hall B (10Gbit) | 78d | 2015-01-07 | 2015-04-27 | 9-155M FS+60d | 166d |
| 24233015 |  | Trigger system fibers wiring | 78d | 2015-01-07 | 2015-04-27 | 9-155M FS+60d | 166d |

| ID | WBS | Task | Duration | Start | Finish | Predecessors | Total float |
| --- | --- | --- | --- | --- | --- | --- | --- |
| 24233020 |  | Procure CISCO 2960S switches (24 Cu ports) (15) | 78d | 2015-01-07 | 2015-04-27 | 9-155M FS+60d | 125d |
| 24233030 |  | Procure 4-port 10GBit Blades for BigIron | 78d | 2015-01-07 | 2015-04-27 | 9-155M FS+60d | 146d |
| 24233040 |  | Procure Ethernet fibers/Cu wires | 78d | 2015-01-07 | 2015-04-27 | 9-155M FS+60d | 125d |
| 24233050 |  | Procure Terminal servers (Etherlite32) (10) | 78d | 2015-01-07 | 2015-04-27 | 9-155M FS+60d | 125d |
| 24233060 |  | Procure daq/online computers | 98d | 2015-01-07 | 2015-05-26 | 9-155M FS+60d | 106d |
| 24233025 |  | Install CISCO 2960S switches (24 Cu ports) (15) | 41d | 2015-04-28 | 2015-06-25 | 24233020 | 125d |
| 24233035 |  | Install 4-port 10GBit Blades for BigIron | 20d | 2015-04-28 | 2015-05-26 | 24233030 | 146d |
| 24233045 |  | Install Ethernet fibers/Cu wires | 41d | 2015-04-28 | 2015-06-25 | 24233040 | 125d |
| 24233055 |  | Install Terminal servers (Etherlite32) (10) | 41d | 2015-04-28 | 2015-06-25 | 24233050 | 125d |
| 24233065 |  | Install daq/online computers | 40d | 2015-05-27 | 2015-07-23 | 24233060 | 106d |
| 24233070M |  | Online computing infrastructure complete | 0d | 2015-07-23 | 2015-07-23 | 24233065, 24233025, 24233015, 24233010, 24233035, 24233045, 24233055 | 106d |
|  | 4 | **1.4.2.3.4 OFFLINE COMPUTING** |  | 2011-10-03 | 2013-08-30 |  |  |
| 14234005 |  | OFFLINE COMP- Constrctn Setup (P-#1) Historical | 21d | 2011-10-03 | 2011-10-31 | 9-120M | 1027d |
| 14234020LOE |  | Contributed Labor Effort | 434d | 2011-12-01 | 2013-08-30 | 9-120M FS+41d | 640d |
| 14234025 |  | Re-Baseline Actuals Adjustment | 1d | 2013-08-30 | 2013-08-30 | 9-130M FS+227d | 20d |
|  | 5 | **1.4.2.3.5 SLOW CONTROLS** |  | 2010-10-01 | 2015-03-19 |  |  |
| 14235005 |  | SLOW CNTL- Constrctn Setup (P-#1) | 245d | 2010-10-01 | 2011-09-27 | 12223045, 9-110M | 573d |
| 14235010 |  | SLOW CNTL- Constrctn Setup (P-#2) FY11 | 3d | 2011-09-28 | 2011-09-30 | 14235005 | 573d |
| 14235010a |  | SLOW CNTL- Constrctn Setup (P-#2) FY12 | 247d | 2011-10-03 | 2012-09-28 | 14235005, 14235010 | 573d |
| 14235015 |  | SLOW CNTL- Constrctn Setup (P-#3) | 228d | 2012-10-01 | 2013-08-30 | 14235010, 14235010a | 573d |
| 14235020 |  | Re-Baseline Actuals Adjustment | 1d | 2013-08-30 | 2013-08-30 | 9-130M FS+227d | 20d |
| 24235005 |  | SLOW CNTL (EPICS software development) | 20d | 2013-10-01 | 2013-10-28 | 9-140M | 232d |
| 24235010a |  | SLOW CNTL (EPICS device drivers development) | 189d | 2014-01-06 | 2014-10-01 | 24235005, 9-140M FS+59d | 193d |
| 24235015 |  | SLOW CNTL (EPICS software development) | 110d | 2014-10-02 | 2015-03-19 | 24235010a | 193d |
|  | 4 | **1.4.2.4 ELECTRONICS** |  | 2010-09-30 | 2015-10-01 |  |  |
|  | 1 | **1.4.2.4.1 ADC** |  | 2011-10-03 | 2013-08-30 |  |  |
| 14241005 |  | ADC Prcrmnt | 20d | 2011-10-03 | 2011-10-28 | 9-120M, 12224005 | 699d |
| 14241010 |  | FADC-250 (275) procurement | 231d | 2012-01-04 | 2012-11-30 | 9-120M FS+59d, 14241005 FS+21d | 681d |
| 14241015 |  | UMASS - FADC-250 testing (275) | 98d | 2012-10-31 | 2013-03-29 | 12224005, 14241010 FS-21d | 681d |
| 14241020 |  | Re-Baseline Actuals Adjustment | 1d | 2013-08-30 | 2013-08-30 | 9-130M FS+227d | 20d |
|  | 2 | **1.4.2.4.2 TDC AND DISCRIMINATORS** |  | 2012-01-04 | 2015-10-01 |  |  |
| 14242033 |  | JLab Discriminator First Article and Non-Recurring Engineering | 104d | 2012-01-04 | 2012-05-31 | 9-120M FS+59d | 641d |
| 14242035 |  | JLab Discriminator (275) procurement | 169d | 2012-01-04 | 2012-08-31 | 14242033 FS-104d, 9-120M FS+59d | 641d |
| 14242005 |  | CAEN v1190 TDCs (reuse) (31) installation | 42d | 2012-06-01 | 2012-07-31 | 12224005, 9-120M FS+163d | 843d |
| 14242010 |  | CAEN v1290 TDCs (reuse) (24) installation | 42d | 2012-06-01 | 2012-07-31 | 9-120M FS+163d | 843d |
| 14242015 |  | CAEN v1290N TDCs (reuse) (7) installation | 42d | 2012-06-01 | 2012-07-31 | 9-120M FS+163d | 843d |
| 14242020 |  | JLab TDC Fanout procurement prep | 7d | 2012-10-01 | 2012-10-09 | 9-130M | 615d |
| 14242045 |  | ORTEC 935F discr. procurement prep | 7d | 2012-10-01 | 2012-10-09 | 9-130M | 615d |
| 14242025 |  | JLab TDC Fanout (25) procurement | 120d | 2012-10-10 | 2013-04-09 | 14242020 | 615d |
| 14242050 |  | ORTEC 935F discr. (25) procurement | 120d | 2012-10-10 | 2013-04-09 | 14242045 | 615d |
| 14242040 |  | JLab Discriminator (275) test/install | 59d | 2013-03-05 | 2013-05-24 | 14242035 FS+120d | 641d |
| 14242030 |  | JLab TDC Fanout (25) test/install | 59d | 2013-04-10 | 2013-07-02 | 14242025 | 615d |
| 14242055 |  | ORTEC 935F discr. (25) test/install | 59d | 2013-04-10 | 2013-07-02 | 14242050 | 615d |
| 14242060M |  | TDC and Discriminators Complete | 0d | 2013-07-02 | 2013-07-02 | 14242005, 14242040, 14242055, 14242010, 14242030, 14242015 | 615d |
| 14242065 |  | Re-Baseline Actuals Adjustment | 1d | 2013-08-30 | 2013-08-30 | 9-130M FS+227d | 20d |
| 24242040a |  | JLab Discriminator (12) and Flash FADC (12) test/install (SF) | 128d | 2014-04-01 | 2014-09-30 | 9-140M FS+119d | 304d |
| 24242055 |  | ORTEC 935F Discriminators (24) Test/Install (SF) | 128d | 2014-04-01 | 2014-09-30 | 9-140M FS+119d | 304d |
| 24242005 |  | CAEN v1190 (30) and v1290 (24) TDC's installation (FC) | 119d | 2014-10-01 | 2015-03-31 | 9-155M, 24264278 | 57d |
| 24242010 |  | CAEN v1290 TDC's (1) procurement | 161d | 2014-10-01 | 2015-05-29 | 9-155M | 143d |
| 24242030 |  | JLab TDC Fanout (18) test/install (FC) | 119d | 2014-10-01 | 2015-03-31 | 9-155M | 57d |
| 24242040 |  | JLab Discriminator (240) and Flash FADC (240) test/install (FC) | 77d | 2014-10-01 | 2015-01-30 | 9-130M FS+228d, 9-155M | 227d |
| 24242057 |  | Radial Connectors and Sockets for HV Distribution Boxes | 77d | 2014-10-01 | 2015-01-30 | 9-155M | 167d |
| 24242005a |  | CAEN v1190 (1) and v1290N (7) TDC's installation (SF) | 128d | 2015-04-01 | 2015-10-01 | 24264230, 24242005 | 57d |
| 24242030a |  | JLab TDC Fanout (2) test/install (SF) | 128d | 2015-04-01 | 2015-10-01 | 24242030 | 57d |
| 24242060M |  | TDC and Discriminators Complete | 0d | 2015-10-01 | 2015-10-01 | 24242010, 24242040, 24242030a, 24242055, 24242040a, 24242005a | 57d |
|  | 3 | **1.4.2.4.3 SCALERS** |  | 2012-01-05 | 2015-07-09 |  |  |
| 14243005 |  | SCALERS- Prcrmnt | 20d | 2012-01-05 | 2012-02-02 | 9-120M FS+60d, 12224005 | 415d |
| 14243015 |  | Re-Baseline Actuals Adjustment | 1d | 2013-08-30 | 2013-08-30 | 9-130M FS+227d | 20d |
| 24243010 |  | SCALERS - Procurement/Install (SF) | 128d | 2015-01-07 | 2015-07-09 | 9-155M FS+60d | 116d |
|  | 4 | **1.4.2.4.4 HIGH VOLTAGE** |  | 2012-01-05 | 2014-09-30 |  |  |
| 14244005 |  | Hi Voltage Prcrmnt | 20d | 2012-01-05 | 2012-02-02 | 9-120M FS+60d, 12224005 | 858d |
| 14244010 |  | Vend Fab - Universal Multichannel Power Supply System 750W (QTY 5) | 130d | 2012-01-05 | 2012-07-10 | 14244005 FS-20d | 858d |
| 14244015 |  | Vend Fab - Optional Power Supply 750W (QTY5) | 130d | 2012-01-05 | 2012-07-10 | 14244010 FS-130d | 858d |
| 14244020 |  | Vend Fab - H.V Channels +3.5 KV 3 MA Floating (QTY13) | 130d | 2012-01-05 | 2012-07-10 | 14244015 FS-130d | 858d |
| 14244025 |  | Vend Fab - H.V Channels -3.5 KV 3 MA Floating (QTY87) | 130d | 2012-01-05 | 2012-07-10 | 14244020 FS-130d | 858d |
| 14244040 |  | Re-Baseline Actuals Adjustment | 1d | 2013-08-30 | 2013-08-30 | 9-130M FS+227d | 20d |
| 24244035 |  | HV mainframes SY4525 (5) Procurements | 184d | 2013-10-01 | 2014-07-01 | 9-140M | 367d |
| 24244030 |  | CAEN 1527 HV mainframes install (12) (FC), (2) (SF)installation | 128d | 2014-04-01 | 2014-09-30 | 9-140M FS+119d | 304d |
|  | 5 | **1.4.2.4.5 PRE-TRIGGER** |  |  |  |  |  |
|  | 6 | **1.4.2.4.6 LOGIC** |  |  |  |  |  |

| ID | WBS | Task | Duration | Start | Finish | Predecessors | Total float |
| --- | --- | --- | --- | --- | --- | --- | --- |
|  | 7 | **1.4.2.4.7 CRATES, RACKS** |  | 2010-09-30 | 2014-12-17 |  |  |
| 14247008 |  | Vend Fab Crates and Racks Phase 1 Peg Point #2 VME64 Qty 5 | 98d | 2010-09-30 | 2011-02-28 | 9-110M FS-1d | 1116d |
| 14247009 |  | Vend Fab Crates and Racks Phase 1 Peg Point #4 VXS Qty 5 | 121d | 2010-09-30 | 2011-03-31 | 14247008 FS-98d | 1116d |
| 14247010 |  | Vend Fab Crates and Racks Phase 2 VXS | 60d | 2012-01-05 | 2012-03-30 | 9-120M FS+60d, 14247009 | 928d |
| 14247015 |  | Vend Fab Crates and Racks Phase 2 VME64X | 60d | 2012-01-05 | 2012-03-30 | 9-120M FS+60d, 14247009 | 928d |
| 14247005 |  | Crates & Racks Prcrmnt | 23d | 2012-10-01 | 2012-10-31 | 9-130M, 12224005 | 225d |
| 14247020 |  | NIM crates (10) procurement | 23d | 2012-10-01 | 2012-10-31 | 9-130M | 62d |
| 14247030 |  | Racks FC Level-0 (10) procurement | 23d | 2012-10-01 | 2012-10-31 | 9-130M | 62d |
| 14247006 |  | Wiener VME64x crates install (20) | 20d | 2013-05-31 | 2013-06-27 | 9-130M FS+163d | 65d |
| 14247025 |  | NIM crates (10) install | 20d | 2013-06-05 | 2013-07-02 | 14247020 FS+143d | 62d |
| 14247035 |  | Racks FC Level-0 (10) install | 20d | 2013-06-05 | 2013-07-02 | 14247030 FS+143d | 62d |
| 14247065 |  | Re-Baseline Actuals Adjustment | 1d | 2013-08-30 | 2013-08-30 | 9-130M FS+227d | 20d |
| 24247040 |  | Uninterruptible PowerSupply (16kVA) | 77d | 2013-09-03 | 2013-12-20 | 9-130M FS+228d | 474d |
| 24247045 |  | Re-locate existing UPS to Hall B | 20d | 2014-01-02 | 2014-01-30 | 24247040 | 474d |
| 24247005 |  | Wiener VME64x crates install (20) (FC) | 119d | 2014-01-07 | 2014-06-24 | 9-140M FS+60d | 250d |
| 24247025 |  | NIM crates (10) install (FC) | 127.5d | 2014-01-07 | 2014-07-08 | 9-140M FS+60d | 363.5d |
| 24247030 |  | NIM crates (2) install (SF) | 127.5d | 2014-04-01 | 2014-09-30 | 9-140M FS+119d | 304.5d |
| 24247005a |  | Wiener VME64x crates install (2) (SF) | 122d | 2014-06-25 | 2014-12-17 | 24247005 | 250d |
| 24247060M |  | Crates and Racks Complete | 0d | 2014-12-17 | 2014-12-17 | 24247005a, 24247030, 24247005, 24247025, 24247045 | 250d |
|  | 5 | **1.4.2.5 BEAMLINE** |  | 2011-10-03 | 2015-10-01 |  |  |
|  | 1 | **1.4.2.5.1 FARADAY CUP UPGRADE** |  | 2013-01-03 | 2013-08-30 |  |  |
| 14251005 |  | Refurb CLAS Faraday Cup | 80d | 2013-01-03 | 2013-04-26 | 9-130M FS+60d | 661d |
| 14251010 |  | Re-Baseline Actuals Adjustment | 1d | 2013-08-30 | 2013-08-30 | 9-130M FS+227d | 20d |
|  | 2 | **1.4.2.5.2 MOLLER POLARIMETER UPGRADE** |  | 2013-01-03 | 2013-08-30 |  |  |
| 14252005 |  | Fab a Moller Polarimeter Supprt Struct | 120d | 2013-01-03 | 2013-06-24 | 12225020, 9-130M FS+60d | 573d |
| 14252010 |  | Fab a Moller Polarimeter Supprt Struct | 48d | 2013-06-25 | 2013-08-30 | 9-110M, 14252005 | 573d |
| 14252015 |  | Re-Baseline Actuals Adjustment | 1d | 2013-08-30 | 2013-08-30 | 9-130M FS+227d | 20d |
|  | 3 | **1.4.2.5.3 TARGETS** |  |  |  |  |  |
|  | 4 | **1.4.2.5.4 BEAMLINE COMPONENTS** |  | 2011-10-03 | 2015-10-01 |  |  |
| 14254005 |  | P-#1 Constrctn of Beam Line Monitoring Sys | 120d | 2011-10-03 | 2012-03-30 | 9-120M | 820d |
| 14254007 |  | Beamline Studies and Drawings | 149d | 2012-03-01 | 2012-09-28 | 9-120M FS+98d | 801d |
| 14254008 |  | MOU with FIU on Moller Polarimeter | 149d | 2012-03-01 | 2012-09-28 | 9-120M FS+98d | 801d |
| 14254010 |  | Constrctn of Beam Line Shielding | 120d | 2013-01-03 | 2013-06-24 | 12225050, 9-130M FS+60d | 621d |
| 14254015 |  | Constrctn of Beam Line Vac Sys | 120d | 2013-01-03 | 2013-06-24 | 9-130M FS+60d | 573d |
| 14254020 |  | P-#2 Constrctn of Beam Line Monitoring Sys | 108d | 2013-04-01 | 2013-08-30 | 9-130M FS+120d, 14254005 | 573d |
| 14254025 |  | Constrctn of Beam Line Vac Sys | 48d | 2013-06-25 | 2013-08-30 | 9-110M, 14254015 | 573d |
| 14254030 |  | Re-Baseline Actuals Adjustment | 1d | 2013-08-30 | 2013-08-30 | 9-130M FS+227d | 20d |
| 24254000 |  | Faraday Cup Materials | 57d | 2014-10-01 | 2014-12-22 | 9-155M | 207d |
| 24254040 |  | Moller Shielding Manufacturing Design | 64d | 2014-10-01 | 2015-01-12 | 9-155M | 98d |
| 24254055 |  | Downstream Vacuum System Procurement | 57d | 2014-10-01 | 2014-12-22 | 9-155M | 206d |
| 24254065 |  | Upstream Vacuum System Procurement | 57d | 2014-10-01 | 2014-12-22 | 9-155M | 227d |
| 24254075 |  | Beam Offset Monitor Procurement | 57d | 2014-10-01 | 2014-12-22 | 9-155M | 207d |
| 24254085 |  | 2C24 girder move Procurement | 57d | 2014-10-01 | 2014-12-22 | 9-155M | 238d |
| 24254095 |  | Upstream beam blocker and vacuum box Manufacturing Design | 41d | 2014-10-01 | 2014-11-26 | 9-155M | 79d |
| 24254110 |  | Upstream Shielding Wall Procurement | 146d | 2014-10-01 | 2015-05-07 | 9-155M | 158d |
| 24254120 |  | Procurement of Beamline Devices | 247d | 2014-10-01 | 2015-10-01 | 9-155M | 152d |
| 24254090 |  | 2C24 girder move Labor | 59d | 2014-10-10 | 2015-01-14 | 24254085 FS-50d | 238d |
| 24254010 |  | Downstream Viewer Manufacturing Design | 61d | 2014-11-26 | 2015-03-05 | 9-155M FS+40d | 103d |
| 24254025 |  | Moller polarimeter upgrade Manufacturing Design | 61d | 2014-11-26 | 2015-03-05 | 9-155M FS+40d | 103d |
| 24254100 |  | Upstream beam blocker and vacuum box Procurement | 84d | 2014-12-01 | 2015-04-08 | 24254095 | 79d |
| 24254005 |  | Faraday Cup Labor | 40d | 2014-12-23 | 2015-02-27 | 24254000 | 207d |
| 24254060 |  | Downstream Vacuum System Installation | 41d | 2014-12-23 | 2015-03-02 | 24254055 | 206d |
| 24254070 |  | Upstream Vacuum System Installation | 20d | 2014-12-23 | 2015-01-30 | 24254065 | 227d |
| 24254080 |  | Beam Offset Monitor Installation | 40d | 2014-12-23 | 2015-02-27 | 24254075 | 207d |
| 24254045 |  | Moller Shielding Procurement | 58d | 2015-01-13 | 2015-04-03 | 24254040 | 98d |
| 24254015 |  | Downstream Viewer Procurement | 60d | 2015-03-06 | 2015-05-29 | 24254010 | 103d |
| 24254030 |  | Moller polarimeter upgrade Procurement | 60d | 2015-03-06 | 2015-05-29 | 24254025 | 103d |
| 24254105 |  | Upstream beam blocker and vacuum box Installation | 120d | 2015-03-12 | 2015-08-31 | 24254100 FS-20d | 79d |
| 24254050 |  | Moller Shielding Installation | 84d | 2015-04-06 | 2015-08-04 | 24254045 | 98d |
| 24254115 |  | Upstream Shielding Wall Installation | 20d | 2015-04-10 | 2015-05-07 | 24254110 FS-20d | 158d |
| 24254020 |  | Downstream Viewer Assembly | 57d | 2015-05-06 | 2015-07-28 | 24254015 FS-17d | 103d |
| 24254035 |  | Moller polarimeter upgrade Installation | 57d | 2015-05-06 | 2015-07-28 | 24254030 FS-17d | 103d |
|  | 6 | **1.4.2.6 INFRASTRUCTURE** |  | 2011-07-01 | 2016-01-28 |  |  |
|  | 1 | **1.4.2.6.1 UTILITIES** |  | 2013-08-30 | 2013-08-30 |  |  |
| 14261000 |  | Re-Baseline Actuals Adjustment | 1d | 2013-08-30 | 2013-08-30 | 9-130M FS+227d | 20d |
|  | 2 | **1.4.2.6.2 MECHANICAL FRAMES** |  |  |  |  |  |
|  | 3 | **1.4.2.6.3 ASSEMBLY** |  | 2013-08-30 | 2013-08-30 |  |  |
| 14263000 |  | Re-Baseline Actuals Adjustment | 1d | 2013-08-30 | 2013-08-30 | 9-130M FS+227d | 20d |
|  | 4 | **1.4.2.6.4 INSTALLATION** |  | 2011-07-01 | 2016-01-28 |  |  |
| 14264008a |  | Spaceframe Motion System | 122d | 2011-07-01 | 2011-12-30 | 9-110M FS+184d | 985d |

| ID | Task | Duration | Start | Finish | Predecessors | Total float |
| --- | --- | --- | --- | --- | --- | --- |
| 14264007x | Subway Addition Procurement Prep | 63d | 2011-07-05 | 2011-09-30 | 9-110M FS+185d | 865d |
| 14264009 | Electrical Utilities Mods of Spaceframe | 20d | 2011-08-02 | 2011-08-29 | 9-110M FS+205d | 888d |
| 14264001LOE | Installation Procurement Support FY12 | 247d | 2011-10-03 | 2012-09-28 | 9-120M | 1010d |
| 14264000aLOE | Installation Engineering Oversight A FY12 | 206d | 2011-12-01 | 2012-09-28 | 9-120M FS+41d | 1158d |
| 14264000cLOE | Installation Engineering Oversight B FY12 | 169d | 2012-02-01 | 2012-09-28 | 9-120M FS+78d | 1158d |
| 14264000 | CLAS 6 Removal | 181d | 2012-05-14 | 2013-02-06 | 2-02M | 65d |
| 14264013 | Vend Fab Fwd. carriage Mods and install hangers and mount | 204d | 2012-06-01 | 2013-03-29 | 14264245 FS-165d, 9-120M FS+163d | 69d |
| 14264008 | Vend Fab Subway Addition with rails and Spaceframe Mod | 178d | 2012-09-11 | 2013-05-31 | 9-120M FS+233d, 14264007x, 14264009 | 632d |
| 14264000bLOE | Installation Engineering Oversight A FY13 | 80d | 2012-10-01 | 2013-01-31 | 14264000aLOE | 1158d |
| 14264000dLOE | Installation Engineering Oversight B FY13 | 80d | 2012-10-01 | 2013-01-31 | 14264000cLOE | 1158d |
| 14264002LOE | Installation Procurement Support FY13 | 228d | 2012-10-01 | 2013-08-30 | 14264001LOE | 1010d |
| 14264362 | Vend Fab Fwd. Detector Installation Tooling | 184d | 2012-10-01 | 2013-06-28 | 9-130M | 52d |
| 14264240 | Manufacturing Design of Fwd. Carriage Mods | 12d | 2012-12-03 | 2012-12-18 | 9-130M FS+43d | 70d |
| 14264245 | Procurement Prep of Fwd. Carriage Mods | 25d | 2012-12-19 | 2013-01-31 | 14264240 | 70d |
| 14264269 | Manufacturing Design of Motion System | 55d | 2013-01-03 | 2013-03-22 | 9-130M FS+60d | 20d |
| 14264002M | Hall Cleared and Cleaned for CLAS12 installation | 0d | 2013-02-07 | 2013-02-07 | 2-02M, 2-07M, 14264000 | 65d |
| 14264238M | Start Mods of FWD Carriage | 0d | 2013-02-07 | 2013-02-07 | 14264002M | 702d |
| 14264260 | Reinforce Fwd Carriage, add motion sysytem mounts and detector mounts | 44d | 2013-02-07 | 2013-04-10 | 14264013 FS-40d, 14264002M | 65d |
| 14264882 | Install DC signal cable trays and gas lines | 10d | 2013-02-07 | 2013-02-21 | 14264002M | 129d |
| 14264884 | Route DC Signal Cables | 20d | 2013-02-22 | 2013-03-21 | 14264882 | 129d |
| 14264315M | Start Installation of Hardware for DAQ | 0d | 2013-03-01 | 2013-03-01 | 14264002M FS+15d | 118d |
| 14264316 | Removal of unused cables (DAQ) | 10d | 2013-03-01 | 2013-03-14 | 14264315M | 118d |
| 14264340M | Start Beamline Modifications | 0d | 2013-03-01 | 2013-03-01 | 14264002M FS+15d | 677d |
| 14264350 | Move Moeller Quads and Table | 15d | 2013-03-01 | 2013-03-21 | 14264340M | 677d |
| 14264886 | Install DC HV/LV Racks and cable trays | 6d | 2013-03-21 | 2013-03-28 | 14264884 FS-1d | 129d |
| 14264355 | Move GONI | 7d | 2013-03-22 | 2013-04-01 | 14264350 | 677d |
| 14264271 | Procurement Prep of Motion System | 27d | 2013-03-25 | 2013-04-30 | 14264269 | 20d |
| 14264360 | Align Goni and Moeller Quads | 3d | 2013-04-02 | 2013-04-04 | 14264355 | 677d |
| 14264206M | ToF Panel 1a - First 3 units Ready for Installation | 0d | 2013-04-05 | 2013-04-05 | 142232455 | 666d |
| 14264545 | Install and wire up Torus PS (G0) | 5d | 2013-04-05 | 2013-04-11 | 14264002M FS+40d | 119d |
| 14264265 | Add Hand rails and stairs to FC level 0 | 3d | 2013-04-11 | 2013-04-15 | 14264260 | 65d |
| 14264267 | Add AC power to Level 0 FC | 3d | 2013-04-16 | 2013-04-18 | 14264265 | 652d |
| 14264280 | Modify LTCC gas piping | 15d | 2013-04-19 | 2013-05-09 | 14264267, 14264238M | 652d |
| 14264202M | R2 Drift Chambers Ready for Installation | 0d | 2013-05-01 | 2013-05-01 | 142213069 | 106d |
| 14264273 | Vend Fab Motion System | 34d | 2013-05-01 | 2013-06-18 | 14264271 | 20d |
| 14264228M | Subway Steel Delivered | 0d | 2013-05-31 | 2013-05-31 | 14264008a, 14264008, 14264002M | 632d |
| 14264230 | Subway Level 1 addition wiring Power Dist. | 5d | 2013-06-03 | 2013-06-07 | 14264228M, 14264009 | 632d |
| 14264235 | Hall B Control Survey | 5d | 2013-06-03 | 2013-06-07 | 14264228M, 14264260, 14264009 | 632d |
| 14264345 | Install New Tagger Window | 3d | 2013-06-03 | 2013-06-05 | 14264228M, 14264009 | 634d |
| 14264278 | Install Motion system | 5d | 2013-06-19 | 2013-06-25 | 14264265, 14264273 | 20d |
| 14264220M | PCAL - First 5 units Ready for Installation | 0d | 2013-06-21 | 2013-06-21 | 142223560 | 58d |
| 14264285 | Modify Lead nose | 4d | 2013-06-26 | 2013-07-01 | 14264278 | 20d |
| 14264364M | Start Installation of FWD Detectors | 0d | 2013-07-01 | 2013-07-01 | 14264362, 14264260 | 52d |
| 14264365 | Transport and install first 5 sectors PCAL | 15d | 2013-07-01 | 2013-07-22 | 14264362, 14264220M, 14264364M | 52d |
| 14264290 | Weld PCAL and LTCC brackets | 10d | 2013-07-02 | 2013-07-16 | 14264285 | 20d |
| 14264375 | Cable/test/repair Preshower calorimeters | 9d | 2013-07-05 | 2013-07-17 | 14264365 FS-12d | 52d |
| 14264295 | Install panel 2 TOF brackets | 10d | 2013-07-16 | 2013-07-29 | 14264290 FS-1d | 20d |
| 14264370 | Check PCAL positions | 3d | 2013-07-23 | 2013-07-25 | 14264365 | 588d |
| 14264400 | Transport and Install ToF 1a - First 3 sectors | 6d | 2013-07-26 | 2013-08-02 | 14264370, 14264206M | 588d |
| 14264297M | Start Forward Carriage Precabling | 0d | 2013-07-30 | 2013-07-30 | 14264295 | 20d |
| 14264300 | Install 10 electronics racks level 0 | 3d | 2013-07-30 | 2013-08-01 | 14264297M | 20d |
| 14264204M | R1 Drift Chambers Ready for Installation | 0d | 2013-08-01 | 2013-08-01 | 142213100 | 42d |
| 14264305 | Install 2 electronics racks level 2 | 2d | 2013-08-02 | 2013-08-05 | 14264300 | 20d |
| 14264318 | Relocate PMT signals/HV/network patch panels | 5d | 2013-08-02 | 2013-08-08 | 14264300, 14264316 | 20d |
| 14264405 | Survey (as found location) TOF 1a positions | 1d | 2013-08-05 | 2013-08-05 | 14264400 | 588d |
| 14264308 | Reroute EC, CC, TOF HV/signal cables | 19d | 2013-08-06 | 2013-08-30 | 14264300 FS-1d, 14264305 | 20d |
| 14264410 | Cable/test/repair 1a's TOF's | 4d | 2013-08-06 | 2013-08-09 | 14264400 FS-4d, 14264405 | 588d |
| 14264328 | Relocate electronic crates | 16d | 2013-08-09 | 2013-08-30 | 14264002M, 14264318 | 20d |
| 14264998 | Re-Baseline Actuals Adjustment | 1d | 2013-08-30 | 2013-08-30 | 9-130M FS+227d | 20d |
| 24264002LOE | Installation Procurement Support FY13 | 20d | 2013-09-03 | 2013-09-30 | 9-130M FS+228d | 742d |
| 24264025M | R2 Drift Chambers Ready for Installation | 0d | 2013-09-03 | 2013-09-03 | 9-130M FS+228d | 530d |
| 24264035M | ToF Panel 1a - First 3 units Ready for Installation | 0d | 2013-09-03 | 2013-09-03 | 9-130M FS+228d | 561d |
| 24264045M | ToF Panel 2 Ready for Installation | 0d | 2013-09-03 | 2013-09-03 | 9-130M FS+228d | 556d |
| 24264140 | PCAL - Procure PCAL installation stand | 40d | 2013-09-03 | 2013-10-28 | 9-130M FS+228d | 446d |
| 24264270 | Add AC power to Level 0 FC | 22d | 2013-09-03 | 2013-10-02 | 9-130M FS+228d | 476d |
| 24264278 | Install Fwd Carriage Mods | 20d | 2013-09-03 | 2013-09-30 | 9-130M FS+228d | 304d |
| 24264362 | Vend Fab Fwd. Detector Installation Tooling | 40d | 2013-09-03 | 2013-10-28 | 9-130M FS+228d | 446d |
| 24264517 | Modify Space Frame For Cryo Can | 42d | 2013-09-09 | 2013-11-05 | 9-130M FS+232d | 334d |
| 24264297M | Start Forward Carriage Precabling | 0d | 2013-09-24 | 2013-09-24 | 24264278 FS-5d | 385d |
| 24264300 | Precable forward carriage FY13 | 5d | 2013-09-24 | 2013-09-30 | 24264297M | 385d |

| ID | Task | Duration | Start | Finish | Predecessors | Total float |
| --- | --- | --- | --- | --- | --- | --- |
| 24264003LOE | Installation Enginering Support FY14 | 247d | 2013-10-01 | 2014-09-30 | 24264002LOE | 742d |
| 24264300a | Precable forward carriage FY14 | 81d | 2013-10-01 | 2014-02-05 | 24264297M, 24264300 | 385d |
| 24264515 | Mods to CRYO transfer lines | 40d | 2013-10-01 | 2013-11-25 | 9-140M | 339d |
| 24264935 | Widen the corners of the Hall access walls to allow R3 to pass through horizontal | 83d | 2013-10-01 | 2014-02-07 | 9-140M | 427d |
| 24264364M | Start Installation of FWD Detectors | 0d | 2013-10-29 | 2013-10-29 | 24264278, 24264362, 24264140 | 446d |
| 24264395 | Cable/test/repair EC | 85d | 2013-10-29 | 2014-03-11 | 24264365 FS-142d, 9-140M FS+20d | 446d |
| 24264520 | Modify Space Frame Level 3 deck For Torus Cryo | 20d | 2013-11-06 | 2013-12-05 | 24264517 | 334d |
| 24264280 | Modify LTCC gas piping | 43d | 2013-11-13 | 2014-01-27 | 24264270 FS+29d | 476d |
| 24264890 | DC - design mounts and adjusters for DC to Torus | 82d | 2013-12-05 | 2014-04-10 | 9-140M FS+45d | 226d |
| 24264050M | ToF Panel 1b - First 3 units Ready for Installation | 0d | 2014-01-02 | 2014-01-02 | 242232320R, 242232320S | 456d |
| 24264055M | ToF Panel 1b - Last 3 units Ready for Installation | 0d | 2014-01-02 | 2014-01-02 | 242232320S, 242232320R | 470d |
| 24264888 | Reroute DC gas lines to the distribution pannel | 134d | 2014-01-06 | 2014-07-15 | 9-140M FS+59d | 358d |
| 24264281 | Install new gas lines from gas sched to the hall | 10d | 2014-01-14 | 2014-01-28 | 24264280 FS-9d | 476d |
| 24264895 | DC - mounts and adjusters Engineering Analysis | 37d | 2014-01-16 | 2014-03-10 | 24264890 FS-60d | 249d |
| 24264365 | Transport and install PCAL | 15d | 2014-02-06 | 2014-02-26 | 242223563M, 24264300a, 24264364M, 24264140, 24264362, 24264300 | 385d |
| 24264390 | Cable/test/repair Preshower calorimeters | 20d | 2014-02-10 | 2014-03-07 | 24264365 FS-13d | 448d |
| 24264370 | Check PCAL positions | 2d | 2014-02-27 | 2014-02-28 | 24264365 | 442d |
| 24264400 | Transport and Install ToF 1a | 11d | 2014-03-04 | 2014-03-18 | 24264370 FS+1d, 24264035M | 442d |
| 24264410 | Cable/test/repair 1a's TOF's | 9d | 2014-03-05 | 2014-03-17 | 24264405 FS-13d, 24264400 FS-10d | 442d |
| 24264790 | Solenoid - design adjustment system for solenoid and HTCC rails | 25d | 2014-03-05 | 2014-04-08 | 9-140M FS+100d | 177d |
| 24264405 | Survey (as found location) TOF 1a positions | 2d | 2014-03-20 | 2014-03-21 | 24264400 FS+1d | 442d |
| 24264105 | SVT - Design mounts for SVT to solenoid cart | 39d | 2014-04-02 | 2014-05-27 | 9-140M FS+120d | 252d |
| 24264793 | Solenoid - design motion system | 24d | 2014-04-09 | 2014-05-12 | 24264790 | 213d |
| 24264795 | Solenoid - design cart | 24d | 2014-04-09 | 2014-05-12 | 24264790 | 177d |
| 24264905 | DC - design cable trays and gas system mounts | 127d | 2014-04-11 | 2014-10-09 | 9-140M FS+127d | 49d |
| 24264430 | Transport and install ToF 1b | 12d | 2014-04-14 | 2014-04-29 | 24264050M, 24264365 FS+32d | 385d |
| 24264796 | Solenoid - cart Engineering Analysis | 22d | 2014-04-29 | 2014-05-29 | 24264795 FS-10d | 177d |
| 24264435 | Survey (as found location) TOF 1b's | 2d | 2014-04-30 | 2014-05-01 | 24264430 | 385d |
| 24264440 | Cable/test/repair 1b's TOF's | 10d | 2014-04-30 | 2014-05-13 | 24264430 | 401d |
| 24264030M | R1 Drift Chambers Ready for Installation | 0d | 2014-05-01 | 2014-05-01 | 242213100 | 384d |
| 24264791 | Solenoid - procure rails and adjustment components for solenoid and HTCC rails | 63d | 2014-05-06 | 2014-08-04 | 24264790 FS+19d | 177d |
| 24264794 | Solenoid - procure motion system | 42d | 2014-05-06 | 2014-07-03 | 24264793 FS-5d | 213d |
| 24264545 | Install and wire up Torus PS (G0) | 5d | 2014-05-07 | 2014-05-13 | 9-140M FS+145d | 82d |
| 24264110 | SVT - Design Insertion/service cart and installation arm | 39d | 2014-05-28 | 2014-07-22 | 24264105 | 252d |
| 24264797 | Solenoid - procure cart | 64d | 2014-06-03 | 2014-09-02 | 24264796, 9-140M FS+163d | 175d |
| 24264900 | DC - procure mounts and adjusters for DC to Torus | 84d | 2014-06-03 | 2014-09-30 | 24264895, 9-140M FS+163d, 24264890 | 190d |
| 24264282 | Design modifications to Lead Nose | 15d | 2014-06-05 | 2014-06-25 | 9-140M FS+165d | 330d |
| 24264285 | Modify Lead nose | 13d | 2014-06-26 | 2014-07-15 | 24264278, 24264282 | 330d |
| 24264085M | First Torus Cryostat Ready | 0d | 2014-06-30 | 2014-06-30 | 242743005 | 50d |
| 24264548M | Start Torus Installation | 0d | 2014-06-30 | 2014-06-30 | 24264545, 242751240, 242751415, 242751250, 24264085M | 50d |
| 24264565 | Attach cold hub to Coil D | 7d | 2014-07-09 | 2014-07-17 | 242751290, 242742075, 242751180, 24264548M, 24264085M | 44d |
| 24264570 | Attach Center Base Legs to Coil D | 7d | 2014-07-18 | 2014-07-28 | 24264565 | 44d |
| 24264115 | SVT - Design transportation cart/skid | 52d | 2014-07-23 | 2014-10-03 | 24264110 | 252d |
| 24264575 | Install Temporary Braces to Hall Floor for Coil D and Beam left and right Cold Rings | 10d | 2014-07-29 | 2014-08-11 | 24264570 | 44d |
| 24264910 | DC - cable trays and gas system mounts Engineering Analysis | 23d | 2014-08-01 | 2014-09-03 | 24264905 FS-49d | 74d |
| 24264792 | Solenoid - Install and Align rails and adjustment components for solenoid and HTCC rails | 15d | 2014-08-05 | 2014-08-25 | 24264791 | 177d |
| 24264794a | Solenoid - Install motion system | 5d | 2014-08-26 | 2014-09-02 | 24264792, 24264794 | 177d |
| 24264120 | SVT - Cart/Skid Engineering analysis | 12d | 2014-08-27 | 2014-09-12 | 24264110 FS+25d | 267d |
| 24264525 | Distribution Can - Transport and position distribution box | 2d | 2014-09-02 | 2014-09-03 | 24264515, 242761030, 24264520 FS-1d | 153d |
| 24264550 | Install 3 Torus Base support and adjustment Stands | 5d | 2014-09-02 | 2014-09-08 | 24264548M FS-10d, 242751440, 242751385 | 25d |
| 24264230 | Subway Level 1 addition wiring Power Dist. | 5d | 2014-09-04 | 2014-09-10 | 9-140M FS+228d | 190d |
| 24264527 | Distribution Can - Connect cold piping with fittings and welding | 5d | 2014-09-04 | 2014-09-10 | 24264525 | 153d |
| 24264580 | Install Coil D Assembly | 7d | 2014-09-09 | 2014-09-17 | 24264550, 24264575 | 25d |
| 24264529 | Distribution Can - Connect Instrumentation and valves | 5d | 2014-09-11 | 2014-09-17 | 24264527 | 153d |
| 24264531 | Distribution Can - leak test system | 4d | 2014-09-18 | 2014-09-23 | 24264529 | 153d |
| 24264585 | Install Beam left and right cold ring beams | 10d | 2014-09-18 | 2014-10-01 | 24264580 | 25d |
| 24264533 | Distribution Can - pressure test system | 2d | 2014-09-24 | 2014-09-25 | 24264531 | 153d |
| 24264535 | Distribution Can - final leak test system | 3d | 2014-09-26 | 2014-09-30 | 24264533 | 153d |
| 24264005LOE | Installation Engineering Oversight FY15 | 246d | 2014-09-30 | 2015-09-29 | 242751010LOE FS-16d | 420d |
| 24264090M | Last Torus Cryostat Ready | 0d | 2014-10-01 | 2014-10-01 | 2-34M | 72d |
| 24264145 | HTCC - design transport cart | 56d | 2014-10-01 | 2014-12-19 | 9-155M | 194d |
| 24264345 | Install New Tagger Window | 3d | 2014-10-01 | 2014-10-03 | 9-155M | 301d |
| 24264540 | Distribution Can - purify system | 3d | 2014-10-01 | 2014-10-03 | 24264535 | 153d |
| 24264590 | Align Lower Cold ring beams and lock down | 7d | 2014-10-02 | 2014-10-10 | 24264585 | 25d |
| 24264125 | SVT - Procure SVT mounts and cart | 49d | 2014-10-06 | 2014-12-15 | 24264120, 24264110, 24264115 | 252d |
| 24264915 | DC - procure cable trays and gas system mounts | 52d | 2014-10-09 | 2014-12-23 | 24264910, 24264905 FS-1d | 49d |
| 24264920 | DC - design maintenance platforms | 60d | 2014-10-10 | 2015-01-15 | 9-155M FS+7d | 166d |
| 24264595 | Install Coil E and C Assemblies (mechanical) | 11d | 2014-10-13 | 2014-10-27 | 24264590, 242743015, 242743035 | 25d |
| 24264600 | Install Vertical Cold ring beams and braces | 10d | 2014-10-28 | 2014-11-10 | 24264595 | 25d |
| 24264605 | Install Coil F and B assemblies | 11d | 2014-11-18 | 2014-12-04 | 24264600, 242743055, 242743075 | 20d |

| ID | Task | Duration | Start | Finish | Predecessors | Total float |
| --- | --- | --- | --- | --- | --- | --- |
| 24264925 | DC - maintenance platforms Engineering Analysis | 15d | 2014-12-01 | 2014-12-19 | 24264920 FS-26d | 166d |
| 24264610 | Install Top four Cold Ring beams and temporary braces | 7d | 2014-12-05 | 2014-12-15 | 24264605 | 20d |
| 24264010M | SVT Ready For Installation | 0d | 2014-12-15 | 2014-12-15 | 242211918M | 229d |
| 24264615 | Install Coil A | 6d | 2014-12-19 | 2015-01-07 | 24264090M, 242743095, 24264610 | 17d |
| 24264160 | HTCC - procure transport cart | 41d | 2014-12-22 | 2015-02-27 | 24264145 | 194d |
| 24264930 | DC - procure maintenance platforms | 41d | 2014-12-22 | 2015-02-27 | 24264925, 24264920 FS-20d | 166d |
| 24264095M | Torus Control System Ready for Installation | 0d | 2015-01-07 | 2015-01-07 | 24271740M FS+60d | 137d |
| 24264555 | Install Torus Control System | 20d | 2015-01-07 | 2015-02-04 | 24264095M | 137d |
| 24264620 | Survey all CCM and Cold Hub relative locations adjust as necessary | 3d | 2015-01-08 | 2015-01-12 | 24264615 | 17d |
| 24264625 | Mount the Torus Service Module on Level 3 | 1d | 2015-01-13 | 2015-01-13 | 242751335, 24264620 | 17d |
| 24264798M | Start Installation of Solenoid | 0d | 2015-01-13 | 2015-01-13 | 24272075k FS-10d, 24264794, 242781020, 2-35M FS+23d, 24264515, 24264797, 24264791 | 91d |
| 24264800 | Receive and inspect solenoid magnet from Vendor | 3d | 2015-01-13 | 2015-01-15 | 24264798M | 91d |
| 24264805 | Install Solenoid cart | 1d | 2015-01-13 | 2015-01-13 | 24264800 FS-10d, 24264794a, 24264797, 24264798M | 93d |
| 24264630 | Splice all Coil Leads and Leads to Service Module | 4d | 2015-01-14 | 2015-01-20 | 24264625 | 17d |
| 24264880 | Vend Fab Drift Chambers Installation tooling | 100d | 2015-01-14 | 2015-06-05 | 9-155M FS+65d | 98d |
| 24264810 | Assemble Solenoid and Piping | 30d | 2015-01-16 | 2015-02-27 | 24264805, 24264800 | 91d |
| 24264635 | Weld/Braze all cooling lines (He) | 2d | 2015-01-21 | 2015-01-22 | 24264630 | 17d |
| 24264640 | Pressure and Leak test all 4K cooling lines | 2d | 2015-01-23 | 2015-01-26 | 24264635 | 17d |
| 24264645 | Secure and Heat Station the Splices and coil leads | 3d | 2015-01-27 | 2015-01-29 | 24264640 | 17d |
| 24264650 | Connect all instrumentation including voltage taps | 6d | 2015-01-30 | 2015-02-06 | 24264645 | 17d |
| 24264655 | Insulate all 4K Surfaces | 10d | 2015-02-09 | 2015-02-20 | 242751300, 24264650, 242751260, 242751310 | 17d |
| 24264065M | LTCC - Last 3 units Ready for Installation | 0d | 2015-02-11 | 2015-02-11 | 242242500M | 185d |
| 24264460 | Transport and Install LTCC | 10d | 2015-02-20 | 2015-03-05 | 24264055M FS-4d, 24264065M FS+7d, 24264430 FS-4d, 24264435 FS-4d, 24264285 | 185d |
| 24264660 | Complete Central hub heat shield | 4d | 2015-02-23 | 2015-02-26 | 24264655 | 17d |
| 24264762 | TORUS CRYO WARM PIPING-Design Gas Panel and Piping | 15d | 2015-02-24 | 2015-03-16 | 24264760 FS-70d | 29d |
| 24264665 | Install Cold to warm supports on vertical Cold ring beams | 1d | 2015-02-27 | 2015-02-27 | 24264660 | 17d |
| 24264670 | Install Heat shield on Cold Ring vertical Beams | 4d | 2015-03-02 | 2015-03-05 | 24264665 | 17d |
| 24264465 | Survey (as found location) LTCC positions | 3d | 2015-03-06 | 2015-03-10 | 24264460 | 185d |
| 24264675 | Insulate 80K surfaces on Cold Ring vertical beams | 4d | 2015-03-06 | 2015-03-11 | 24264670 | 17d |
| 24264470 | Cable/test/repair LTCC's | 6d | 2015-03-10 | 2015-03-17 | 24264465 FS-1d | 195d |
| 24264490 | Transport and Install TOF Panel 2 and align relative to panel 1a | 6d | 2015-03-11 | 2015-03-18 | 24264065M, 24264045M, 24264460, 24264465 | 185d |
| 24264680 | Install Outer Legs N & S on Adjusters (includes 1/2 of CS VJ) | 2d | 2015-03-12 | 2015-03-13 | 24264675 | 17d |
| 24264685 | Attach cold to warm support to VJ (2 places) | 1d | 2015-03-16 | 2015-03-16 | 24264680 | 17d |
| 24264690 | Complete Vertical Cold Ring VJ | 4d | 2015-03-17 | 2015-03-20 | 24264685 | 17d |
| 24264762A | TORUS CRYO WARM PIPING-Cut Back Piping | 1d | 2015-03-17 | 2015-03-17 | 24264762 | 29d |
| 24264762B | TORUS CRYO WARM PIPING-Procure valves and fitting | 20d | 2015-03-18 | 2015-04-14 | 24264762A | 29d |
| 24264495 | Final Survey TOF panel 2's Positions | 3d | 2015-03-19 | 2015-03-23 | 24264490 | 185d |
| 24264695 | Transfer load from Temporary legs to Outer Legs and Remove Temp legs | 2d | 2015-03-23 | 2015-03-24 | 24264690 | 17d |
| 24264500 | Cable/test/repair Panel 2 TOFs | 6d | 2015-03-24 | 2015-03-31 | 24264495, 24264490 FS-5d | 185d |
| 24264700 | Install Heat Shield on other 8 Hex Ring beams | 8d | 2015-03-25 | 2015-04-03 | 24264695 | 17d |
| 24264757 | TORUS CRYOTOWER-Transport and position cryotower | 2d | 2015-03-31 | 2015-04-01 | 24264690, 24264525 FS-1d, 24264540, 242762045 | 38d |
| 24264020M | R3 Drift Chambers Ready for Installation | 0d | 2015-04-02 | 2015-04-02 | 242213355M | 165d |
| 24264757A | TORUS CRYOTOWER-Connect cold piping with fittings and welding | 10d | 2015-04-02 | 2015-04-15 | 24264757 | 38d |
| 24264757B | TORUS CRYOTOWER-Connect Instrumentation, valves and current leads | 8d | 2015-04-02 | 2015-04-13 | 24264757A FS-10d | 38d |
| 24264705 | Connect all Heat Shield cooling tubes | 3d | 2015-04-06 | 2015-04-08 | 24264700 | 17d |
| 24264868 | Design and install HTCC gas system | 90d | 2015-04-08 | 2015-08-14 | 9-155M FS+124d | 77d |
| 24264710 | Pressure and Leak test all 80K cooling lines | 2d | 2015-04-09 | 2015-04-10 | 24264705 | 17d |
| 24264340M | Start Beamline Modifications | 0d | 2015-04-13 | 2015-04-13 | 24254120 FS-120d | 152d |
| 24264350 | Move Moeller Quads and Table | 15d | 2015-04-13 | 2015-05-01 | 24264340M | 152d |
| 24264715 | Insulate All 80K Surfaces | 6d | 2015-04-13 | 2015-04-20 | 24264710 | 17d |
| 24264757C | TORUS CRYOTOWER-Leak Test new System | 4d | 2015-04-14 | 2015-04-17 | 24264757B | 38d |
| 24264762C | TORUS CRYO WARM PIPING-Install New Piping | 10d | 2015-04-15 | 2015-04-28 | 24264762B | 29d |
| 24264080M | HTCC Ready for Installation | 0d | 2015-04-20 | 2015-04-20 | 242241650M | 157d |
| 24264757D | TORUS CRYOTOWER-Pressure Test Piping | 2d | 2015-04-20 | 2015-04-21 | 24264757C | 38d |
| 24264720 | Install VJ on other 8 Hex Ring Beams | 8d | 2015-04-21 | 2015-04-30 | 24264715 | 17d |
| 24264757F | TORUS CRYOTOWER-Final Leak Test system | 3d | 2015-04-22 | 2015-04-24 | 24264757D | 38d |
| 24264757G | Purify System | 3d | 2015-04-27 | 2015-04-29 | 24264757F | 38d |
| 24264762D | TORUS CRYO WARM PIPING-Leak Test new Piping | 4d | 2015-04-29 | 2015-05-04 | 24264762C | 29d |
| 24264723 | Install insulation and shield and VJ at central Hub | 4d | 2015-05-01 | 2015-05-06 | 24264720 | 17d |
| 24264355 | Move GONI | 7d | 2015-05-04 | 2015-05-12 | 24264350 | 152d |
| 24264762F | TORUS CRYO WARM PIPING-Pressure Test Piping | 1d | 2015-05-05 | 2015-05-05 | 24264762D | 29d |
| 24264762G | TORUS CRYO WARM PIPING-Final Leak Test system | 4d | 2015-05-06 | 2015-05-11 | 24264762F | 29d |
| 24264725 | Install VJ between Coils at Hub | 6d | 2015-05-07 | 2015-05-14 | 24264723 | 17d |
| 24264762H | TORUS CRYO WARM PIPING-Purify System | 3d | 2015-05-12 | 2015-05-14 | 24264762G | 29d |
| 24264360 | Align Goni and Moeller Quads | 3d | 2015-05-13 | 2015-05-15 | 24264355 | 152d |
| 24264730 | Transfer All Cold Mass Loads to VJ | 2d | 2015-05-15 | 2015-05-18 | 24264725 | 17d |
| 24264735 | Align VJ to Beam Line | 2d | 2015-05-19 | 2015-05-20 | 24264730 | 17d |
| 24264740 | Align Cold Mass to VJ and Beam Line | 2d | 2015-05-21 | 2015-05-22 | 24264735 | 17d |
| 24264755 | Close up all cold mass view ports and temporary CCM support ports | 4d | 2015-05-26 | 2015-05-29 | 24264740 | 17d |
| 24264760 | TORUS CRYO WARM PIPING-Install Vacuum pumping system | 2d | 2015-06-02 | 2015-06-03 | 24264757G, 24264755 | 17d |

| ID | WBS | Task | Duration | Start | Finish | Predecessors | Total float |
| --- | --- | --- | --- | --- | --- | --- | --- |
| 24264765 |  | Pump VJ, leak and pressure test | 10d | 2015-06-04 | 2015-06-17 | 24264760, 24264762H | 17d |
| 24264770 |  | Install mounting adapters for drift chambers | 10d | 2015-06-18 | 2015-07-01 | 24264765, 24264755, 24264900 | 17d |
| 24264775 |  | Connect instrumentation and Leads | 5d | 2015-07-02 | 2015-07-09 | 24264760, 242771035, 24264770 | 17d |
| 24264815 |  | Solenoid instrumentation and current leads | 10d | 2015-07-06 | 2015-07-17 | 24264810 FS-1d, 242710.1030, 242791060 FS-1d | 3d |
| 24264780 |  | Connect Torus cryo lines | 2d | 2015-07-10 | 2015-07-13 | 24264770, 24264775 | 17d |
| 24264886 |  | Install DC HV/LV Racks and cable trays | 22d | 2015-07-16 | 2015-08-14 | 24264884 FS-70d | 49d |
| 24264820 |  | Align Solenoid | 2d | 2015-07-17 | 2015-07-20 | 24264815 FS-1d | 3d |
| 24264825 |  | Connect Solenoid Cryo lines | 20d | 2015-07-21 | 2015-08-17 | 24264820 | 3d |
| 24264015M |  | CTOF Ready for Installation | 0d | 2015-08-05 | 2015-08-05 | 242231470M | 45d |
| 24264882 |  | Install DC signal cable trays and gas lines | 35d | 2015-09-03 | 2015-10-22 | 24264915 FS+169d | 49d |
| 24264884 |  | Route DC Signal Cables | 35d | 2015-09-03 | 2015-10-22 | 24264882 FS-35d | 49d |
| 24264006LOE |  | Installation Engineering Oversight FY16 | 77d | 2015-09-30 | 2016-01-28 | 24264005LOE | 420d |
| 24264788M |  | Torus Assembled and Tested | 0d | 2015-10-01 | 2015-10-01 | 242743120, 28226015, 242743115, 242711.2005, 242743125 | 17d |
| 24264960M |  | Start Installation of Drift Chambers | 0d | 2015-10-01 | 2015-10-01 | 24264765, 3P-26M, 24264025M, 24264880, 24264886, 24264770, 24264890, 24264935, 24264930, 24264900, 24264788M | 17d |
| 24264845 |  | Mount, assemble and cable CTOF system | 25d | 2015-10-05 | 2015-11-06 | 24264805, 28226025, 24264015M | 3d |
| 24264965 |  | Install Region 2 Drift Chamber | 10d | 2015-10-09 | 2015-10-22 | 28226015, 24264025M, 28226010, 24264960M FS+6d | 17d |
| 24264970 |  | Survey/align R2 Drift chambers | 5d | 2015-10-16 | 2015-10-22 | 24264965 FS-5d | 17d |
| 24264975 |  | Install Region 1 Drift Chamber | 10d | 2015-10-22 | 2015-11-04 | 28226015, 24264960M, 24264970 FS-1d, 28226010, 24264030M | 17d |
| 24264980 |  | Survey/align R1 Drift chambers | 5d | 2015-10-27 | 2015-11-02 | 24264975 FS-7d | 17d |
| 24264985 |  | Install Region 3 Drift Chamber | 10d | 2015-11-02 | 2015-11-13 | 28226010, 28226015, 24264980 FS-1d, 24264020M, 24264960M | 17d |
| 24264870 |  | Rig and Transport HTCC to Hall | 2d | 2015-11-03 | 2015-11-04 | 24264080M, 24264980 | 20d |
| 24264872 |  | Install HTCC cart | 4d | 2015-11-05 | 2015-11-10 | 24264160, 24264868, 24264870 | 20d |
| 24264990 |  | Survey/align R3 Drift chambers | 5d | 2015-11-06 | 2015-11-12 | 24264985 FS-6d | 17d |
| 24264850 |  | Align CTOF | 5d | 2015-11-09 | 2015-11-13 | 24264845 | 3d |
| 24264874 |  | Install HTCC | 2d | 2015-11-11 | 2015-11-12 | 28226020 FS-20d, 24264872 | 20d |
| 24264855 |  | Mount, cable and check SVT system | 15d | 2015-11-13 | 2015-12-07 | 24264850 FS-1d, 24264010M | 3d |
| 24264876 |  | HTCC verify mirror alignment and align detector to beam | 3d | 2015-11-13 | 2015-11-17 | 24264874 | 20d |
| 24264995 |  | Connect / Cable Drift Chambers | 10d | 2015-11-13 | 2015-11-30 | 24264990 | 17d |
| 24264878 |  | Cable HTCC | 4d | 2015-11-18 | 2015-11-23 | 24264876 | 20d |
| 24264860 |  | Align SVT | 10d | 2015-12-07 | 2015-12-18 | 24264855 FS-1d | 3d |
| 24264860M |  | Central Detector Ready | 0d | 2015-12-18 | 2015-12-18 | 24264850, 24264125, 24264860 | 3d |
|  | 7 | **1.4.2.7 HALL B MAGNETS** |  | 2011-12-01 | 2015-09-30 |  |  |
|  | 1 | **1.4.2.7.1 TOROIDAL MAGNET NEW VENDOR** |  | 2011-12-01 | 2014-09-30 |  |  |
| 14271000 |  | Procure Replacement Copper | 40d | 2011-12-01 | 2012-02-03 | 9-120M FS+41d | 662d |
| 14271005 |  | JLab Design and Support Labor FY12 | 84d | 2012-06-01 | 2012-09-28 | 9-120M FS+163d | 397d |
| 14271015 |  | FNAL: Kickoff Meeting | 2d | 2012-06-01 | 2012-06-05 | 9-120M FS+163d | 20d |
| 14271020 |  | FNAL: Discussions on Manufacturing possibilities | 11d | 2012-06-01 | 2012-06-18 | 14273003 FS-86d, 14273012 FS-270d, 14273010 FS-86d, 14271015 FS-2d, 14273014B FS-135d, 9-120M FS+77d, 14273010K FS-270d | 20d |
| 14271025 |  | FNAL: Acceptance of Proposal for fabrication | 12d | 2012-06-01 | 2012-06-19 | 14271020 FS-11d | 20d |
| 14271025A |  | FNAL: Overview of Wang NMR CCM Design | 12d | 2012-06-01 | 2012-06-19 | 14271025 FS-12d | 20d |
| 14271025B |  | FNAL: Develop CCM fabrication and QA/QC plans | 33d | 2012-06-01 | 2012-07-18 | 14271025A FS-12d | 20d |
| 14271025C |  | FNAL: Design of CCM Tooling | 65d | 2012-06-01 | 2012-08-31 | 14271025B FS-33d | 20d |
| 14271025D |  | FNAL: Tooling Installation at FNAL | 84d | 2012-06-01 | 2012-09-28 | 14271025C FS-65d, 14271026 FS-90d | 20d |
| 14271025F |  | FNAL: Manufacturing Readiness Review | 84d | 2012-06-01 | 2012-09-28 | 14271025D FS-84d | 20d |
| 14271025G |  | FNAL: Prototype CCM winding and tests | 143d | 2012-06-01 | 2012-12-31 | 14271025F FS-84d | 20d |
| 14271025H |  | FNAL: Update design with lessons learned from prototype | 164d | 2012-06-01 | 2013-01-31 | 14271025G FS-143d | 20d |
| 14271025J |  | FNAL: Production CCM readiness review | 164d | 2012-06-01 | 2013-01-31 | 14271025H FS-164d | 20d |
| 14271025K |  | FNAL: Production final CCM#1 and test | 226d | 2012-06-01 | 2013-04-30 | 14271025J FS-164d | 20d |
| 14271025L |  | FNAL: Production final CCM#2 and test | 248d | 2012-06-01 | 2013-05-31 | 14271025K FS-226d | 20d |
| 14271025N |  | FNAL: Production final CCM#3 and test | 290d | 2012-06-01 | 2013-07-31 | 14271025L FS-248d | 20d |
| 14271025P |  | FNAL: Production final CCM#4 and test | 290d | 2012-06-01 | 2013-07-31 | 14271025N FS-290d | 20d |
| 14271025Q |  | FNAL: Production final CCM#5 and test | 312d | 2012-06-01 | 2013-08-30 | 14271025P FS-290d | 20d |
| 14271027LOE |  | JLab support of FNAL Torus CCM effort FY12 | 84d | 2012-06-01 | 2012-09-28 | 9-120M FS+163d | 573d |
| 14271026 |  | JLab Fabrication of Tooling | 70d | 2012-06-22 | 2012-09-28 | 9-120M FS+177d | 26d |
| 14271010 |  | JLab Design and Support Labor FY13 Original | 59d | 2012-10-01 | 2012-12-31 | 14271005 | 397d |
| 14271028LOE |  | JLab support of FNAL Torus CCM effort FY13 Original | 59d | 2012-10-01 | 2012-12-31 | 14271027LOE | 573d |
| 14271030 |  | Machine Shop Effort FY13 | 228d | 2012-10-01 | 2013-08-30 | 9-130M | 20d |
| 14271012 |  | JLab Design and Support Labor FY13 Revised | 40d | 2013-01-02 | 2013-02-28 | 14271010 | 397d |
| 14271028LOEA |  | JLab support of FNAL Torus CCM effort FY13 Revised | 169d | 2013-01-02 | 2013-08-30 | 14271028LOE | 573d |
| 14271040 |  | Cryostat Factory Phase 1 | 60d | 2013-01-03 | 2013-03-29 | 9-130M FS+60d | 20d |
| 14271045 |  | Cryostat Factory Phase 2 | 108d | 2013-04-01 | 2013-08-30 | 14271040 | 20d |
| 14271085 |  | Re-Baseline Actuals Adjustment | 1d | 2013-08-30 | 2013-08-30 | 9-130M FS+227d | 20d |
| 24271665 |  | FNAL: Tooling Fabrication and Installation at FNAL Part B | 10d | 2013-09-03 | 2013-09-16 | 9-130M FS+228d | 20d |
| 24271680 |  | FNAL: Prototype CCM winding and tests | 35d | 2013-09-03 | 2013-10-21 | 24271665 FS-10d, 242751020 FS-80d | 20d |
| 24271685 |  | FNAL: Update design with lessons learned from prototype | 62d | 2013-09-03 | 2013-11-27 | 24271680 FS-35d | 20d |
| 24271690 |  | FNAL: Production CCM readiness review | 62d | 2013-09-03 | 2013-11-27 | 24271685 FS-62d | 20d |
| 24271695 |  | FNAL: Production final CCM#1 and test | 161d | 2013-09-03 | 2014-04-30 | 24271690 FS-62d, 242751045 FS-139d | 20d |
| 24271725 LOE |  | Consultant Fees WS LQ | 267d | 2013-09-03 | 2014-09-30 | 9-130M FS+228d | 304d |
| 24271730 |  | Existing Coil Case Storage | 267d | 2013-09-03 | 2014-09-30 | 9-130M FS+228d | 304d |
| 24271730LOE |  | JLab support of FNAL Torus CCM effort FY13 | 20d | 2013-09-03 | 2013-09-30 | 9-130M FS+228d | 72d |
| 24271735 |  | Contractor Training TW | 267d | 2013-09-03 | 2014-09-30 | 9-130M FS+228d | 304d |

| ID | WBS | Task | Duration | Start | Finish | Predecessors | Total float |
| --- | --- | --- | --- | --- | --- | --- | --- |
| 24271740 |  | Additional Torus Copper Stabilizer and SSC Cable tests for Coil #7 | 60d | 2013-09-03 | 2013-11-25 | 9-130M FS+228d | 58d |
| 24271700 |  | FNAL: Production final CCM#2 and test | 162d | 2013-10-01 | 2014-05-30 | 24271695 FS-161d, 9-140M | 0d |
| 24271705 |  | FNAL: Production final CCM#3 and test | 183d | 2013-10-01 | 2014-06-30 | 24271700 FS-162d | 0d |
| 24271710 |  | FNAL: Production final CCM#4 and test | 205d | 2013-10-01 | 2014-07-31 | 24271705 FS-183d | 0d |
| 24271715 |  | FNAL: Production final CCM#5 and test | 226d | 2013-10-01 | 2014-08-29 | 24271710 FS-205d | 0d |
| 24271720 |  | FNAL: Production final CCM#6 and test | 247d | 2013-10-01 | 2014-09-30 | 24271715 FS-226d | 0d |
| 24271735LOE |  | JLab support of FNAL Torus CCM effort FY14 | 184d | 2013-10-01 | 2014-07-01 | 24271730LOE | 72d |
| 24271740M |  | FNAL Torus work complete | 0d | 2014-09-30 | 2014-09-30 | 24271720 | 0d |
|  | 2 | **1.4.2.7.2 SOLENOID MAGNET NEW VENDOR** |  | 2012-06-01 | 2015-09-30 |  |  |
| 14271055 |  | JLab Design and Support Labor FY12 | 84d | 2012-06-01 | 2012-09-28 | 9-120M FS+163d | 20d |
| 14271060 |  | JLab Design and Support Labor FY13 | 228d | 2012-10-01 | 2013-08-30 | 14271055 | 20d |
| 14271068M |  | Award Solenoid Contract | 0d | 2012-11-27 | 2012-11-27 | 9-130M FS+39d | 20d |
| 14271070 |  | Vend Fab Solenoid - Peg Point #1 - Preliminary Design Review | 81d | 2012-11-27 | 2013-03-29 | 14271068M | 20d |
| 14271075 |  | Vend Fab Solenoid - Peg Point #2 - Intermediate Design Review | 125d | 2012-11-27 | 2013-05-31 | 14271070 FS-81d | 20d |
| 14271075a |  | Vend Fab Solenoid - Peg Point #3 - Final Design Review | 145d | 2012-11-27 | 2013-06-28 | 14271075 FS-125d | 20d |
| 14271075c |  | Vend Fab Solenoid - Peg Point #4 - Winding and Potting Tooling | 189d | 2012-11-27 | 2013-08-30 | 14271075b FS-145d | 20d |
| 14271075b |  | Vend Fab Solenoid - Final Design Review Incetive Fee | 128d | 2012-12-20 | 2013-06-28 | 14271075a FS-128d | 20d |
| 14271080 |  | Machine Shop Effort | 128d | 2013-03-04 | 2013-08-30 | 9-130M FS+100d | 324d |
| 14271090 |  | Re-Baseline Actuals Adjustment | 1d | 2013-08-30 | 2013-08-30 | 9-130M FS+227d | 20d |
| 24272075 |  | Vend Fab Solenoid - Peg Point #2 - Intermediate Design Review | 43d | 2013-09-03 | 2013-10-31 | 9-130M FS+228d | 17d |
| 24272075a |  | Vend Fab Solenoid - Peg Point #3 - Final Design Review | 77d | 2013-09-03 | 2013-12-20 | 24272075 FS-43d | 17d |
| 24272075b |  | Vend Fab Solenoid - Final Design Review Incetive Fee | 77d | 2013-09-03 | 2013-12-20 | 24272075a FS-77d | 17d |
| 24272075c |  | Vend Fab Solenoid - Peg Point #4 - Winding and Potting Tooling | 118d | 2013-09-03 | 2014-02-28 | 24272075b FS-77d, 24272075ba FS-77d | 17d |
| 24272075d |  | Vend Fab Solenoid - Peg Point #5 - PSMM Fabrication and Testing | 203d | 2013-09-03 | 2014-06-30 | 24272075c FS-118d | 17d |
| 24272075f |  | Vend Fab Solenoid - MRR Incentive Fee | 225d | 2013-09-03 | 2014-07-31 | 24272075d FS-203d | 17d |
| 24272075g |  | Vend Fab Solenoid - Peg Point #6 - Coils Wound | 246d | 2013-09-03 | 2014-08-29 | 24273010R FS-139d, 24273010K FS-139d, 24273010Q FS-250d, 24272075f FS-225d, 24273010P FS-125d | 17d |
| 24272075h |  | Vend Fab Solenoid - Peg Point #7 - Cryostat Materials and Components | 267d | 2013-09-03 | 2014-09-30 | 24272075g FS-246d | 17d |
| 24272075j |  | Vend Fab Solenoid - Peg Point #8 - Cold Mass Materials and Components | 290d | 2013-09-03 | 2014-10-31 | 24272075h FS-267d | 17d |
| 24272075k |  | Vend Fab Solenoid - Peg Point #9 - Assembly and Test | 308d | 2013-09-03 | 2014-11-26 | 24272075j FS-290d | 17d |
| 24272075n |  | Vend Fab Solenoid - Delivery Incentive Fee | 308d | 2013-09-03 | 2014-11-26 | 24272075k FS-308d | 17d |
| 24272075p |  | Vend Fab Solenoid - Peg Point #10 - Commissioning and Acceptance Test | 449d | 2013-09-03 | 2015-06-30 | 24272075n FS-308d | 58d |
| 24272075q |  | Vend Fab Solenoid - Peg Point #11 - Final Report and Closeout | 513d | 2013-09-03 | 2015-09-30 | 24272075p FS-449d | 58d |
| 24272075r |  | Vend Fab Solenoid - Peg Point #12 - Shipping Costs | 513d | 2013-09-03 | 2015-09-30 | 24272075q FS-513d | 58d |
| 24272080 |  | Solenoid Outside Consulting FY13 | 98d | 2013-09-03 | 2014-01-31 | 9-130M FS+228d | 606d |
| 24272405 |  | Solenoid - Cable Testing | 118d | 2013-09-03 | 2014-02-28 | 9-130M FS+228d | 453d |
| 24272410 |  | Consultant Fees WS | 267d | 2013-09-03 | 2014-09-30 | 9-130M FS+228d | 304d |
| 24272075ba |  | De-Obligation of Vend Fab Solenoid - Final Design Review Incetive Fee | 1d | 2013-12-20 | 2013-12-20 | 24272075a FS-1d | 17d |
| 24272085 |  | Solenoid Outside Consulting FY14 | 305d | 2014-02-03 | 2015-04-23 | 24272080 | 606d |
|  | 3 | **1.4.2.7.3 MAGNET INFRASTRUCTURE** |  | 2011-12-01 | 2014-03-31 |  |  |
| 14273000 |  | Set up Solder Production line Labor Original | 37d | 2011-12-01 | 2012-01-31 | 9-120M FS+41d | 22d |
| 14273005 |  | Set up Solder Production line Procurements | 57d | 2011-12-01 | 2012-02-29 | 9-120M FS+41d | 645d |
| 14273003 |  | Set up Solder Production line Labor Revised | 105d | 2012-02-01 | 2012-06-29 | 14273000 | 22d |
| 14273010 |  | Vend Fab Wave Solder of Torus and Solenoid Magnets Peg Point #1A-Soldering Setup Part A | 22d | 2012-07-02 | 2012-07-31 | 9-120M FS+163d, 14273003 | 22d |
| 14273014 |  | Design/Build/Install guides and rollers for inlet/outlet of process | 42d | 2012-08-01 | 2012-09-28 | 9-120M FS+205d | 21d |
| 14273010A |  | Vend Fab Wave Solder of Torus and Solenoid Magnets Peg Point #1-Soldering Setup Part B | 30d | 2012-08-17 | 2012-09-28 | 14273008 FS-125d, 14273010 FS+12d, 14273007 FS-70d | 22d |
| 14273010B |  | Vend Fab Wave Solder of Torus and Solenoid Magnets Peg Point #2-Procurement of Materials and Start of Production | 53d | 2012-08-17 | 2012-10-31 | 14273010A FS-30d | 22d |
| 14273010C |  | Vend Fab Wave Solder of Torus and Solenoid Magnets Peg Point #3-Delivery of Torus Conductor 001 | 73d | 2012-08-17 | 2012-11-30 | 14273010B FS-53d | 22d |
| 14273010D |  | Vend Fab Wave Solder of Torus and Solenoid Magnets Peg Point #4-Delivery of Torus Conductor 002-006 | 110d | 2012-08-17 | 2013-01-31 | 14273010C FS-73d | 22d |
| 14273010G |  | Vend Fab Wave Solder of Torus and Solenoid Magnets Peg Point #5-Delivery of 1st set of Solenoid Conductor Lengths 1-9 | 150d | 2012-08-17 | 2013-03-29 | 14273010D FS-110d | 22d |
| 14273010H |  | Vend Fab Wave Solder of Torus and Solenoid Magnets Peg Point #6-Delivery of 2nd set of Solenoid Conductor Lengths 1-9 | 150d | 2012-08-17 | 2013-03-29 | 14273010G FS-150d | 22d |
| 14273010J |  | Vend Fab Wave Solder of Torus and Solenoid Magnets Peg Point #7-Delivery of 3rd set of Solenoid Conductor Lengths 1-9 | 172d | 2012-08-17 | 2013-04-30 | 14273010H FS-150d | 22d |
| 14273010K |  | Vend Fab Wave Solder of Torus and Solenoid Magnets Peg Point #8-Delivery of 4th set of Solenoid Conductor Lengths 1-9 | 214d | 2012-08-17 | 2013-06-28 | 14273010J FS-172d | 22d |
| 14273011 |  | Wave Solder of Torus and Solenoid Magnets Travel FY12 | 30d | 2012-08-17 | 2012-09-28 | 9-120M FS+217d | 22d |
| 14273012 |  | Wave Solder of Torus and Solenoid Magnets Travel FY13 | 184d | 2012-10-01 | 2013-06-28 | 14273011 | 22d |
| 14273014A |  | Dial in the process settings - spooling and traverse speeds, manual control | 20d | 2012-10-01 | 2012-10-26 | 14273014 | 21d |
| 14273015 |  | Cryostat Factory Setup | 59d | 2012-10-01 | 2012-12-31 | 9-130M | 189d |
| 14273008 |  | Additional Cu Channel and Wagon wheel spools for Torus | 70d | 2012-10-15 | 2013-01-31 | 9-130M FS+10d | 37d |
| 14273007 |  | Shipping of Coductor to AES | 20d | 2012-10-29 | 2012-11-27 | 9-130M FS+20d | 22d |
| 14273014B |  | Unspool/Measure/Respool/Inspect | 30d | 2012-10-29 | 2012-12-11 | 14273014A | 21d |
| 14273020 |  | Re-Baseline Actuals Adjustment | 1d | 2013-08-30 | 2013-08-30 | 9-130M FS+227d | 20d |
| 24273007 |  | Shipping of Coductor to AES | 43d | 2013-09-03 | 2013-10-31 | 9-130M FS+228d | 528d |
| 24273010B |  | Vend Fab Wave Solder of Torus and Solenoid Magnets Peg Point #2-Procurement of Materials and | 43d | 2013-09-03 | 2013-10-31 | 9-130M FS+228d | 17d |
| 24273010H |  | Vend Fab Wave Solder of Torus and Solenoid Magnets Peg Point #6-Delivery of 2nd set of Solenoid Conductor Lengths 1-9 | 98d | 2013-09-03 | 2014-01-31 | 24273010B FS-43d | 17d |
| 24273010J |  | Vend Fab Wave Solder of Torus and Solenoid Magnets Peg Point #7-Delivery of 3rd set of Solenoid Conductor Lengths 1-9 | 118d | 2013-09-03 | 2014-02-28 | 24273010H FS-98d | 17d |
| 24273010K |  | Vend Fab Wave Solder of Torus and Solenoid Magnets Peg Point #8-Delivery of 4th set of Solenoid Conductor Lengths 1-9 | 139d | 2013-09-03 | 2014-03-31 | 24273010J FS-118d | 17d |
| 24273010N |  | Vend Fab Wave Solder of Torus and Solenoid Magnets Peg Point #9-Additional length and splicing required for Solenoid | 129d | 2013-09-03 | 2014-03-17 | 24273010K FS-139d | 17d |
| 24273010P |  | Vend Fab Wave Solder of Torus and Solenoid Magnets Peg Point #10-Additional Reels for Solenoid | 62d | 2013-09-03 | 2013-11-27 | 24273010N FS-129d | 17d |
| 24273010R |  | Vend Fab Wave Solder of Torus and Solenoid Magnets New Scope | 139d | 2013-09-03 | 2014-03-31 | 24273010P FS-62d | 17d |
| 24273012 |  | Wave Solder of Torus and Solenoid Magnets Travel FY13 | 20d | 2013-09-03 | 2013-09-30 | 9-130M FS+228d | 452d |
| 24273017 |  | Twente Cable Testing | 77d | 2013-09-03 | 2013-12-20 | 9-130M FS+228d | 494d |

| ID | WBS | Task | Duration | Start | Finish | Predecessors | Total float |
| --- | --- | --- | --- | --- | --- | --- | --- |
| 24273022 |  | Additional Cu for solenoid conductor - Procurment | 128d | 2013-09-03 | 2014-03-14 | 9-130M FS+228d | 443d |
| 24273027 |  | Consultant Fees WS | 77d | 2013-09-03 | 2013-12-20 | 9-130M FS+228d | 932d |
| 24273012a |  | Wave Solder of Torus and Solenoid Magnets Travel FY14 | 99d | 2013-10-01 | 2014-03-03 | 9-130M FS+228d, 24273012 | 452d |
| 24273010Q |  | Vend Fab Wave Solder of Torus and Solenoid Magnets Peg Point #10-Conductor Cleaning | 23d | 2014-02-13 | 2014-03-17 | 24273010N FS-23d | 138d |
|  | 4 | **1.4.2.7.4 TORUS CRYOSTAT FACTORY** |  | 2013-08-30 | 2015-07-14 |  |  |
|  | 1 | **1.4.2.7.4.1 DESIGN AND PROCEDURES** |  | 2013-08-30 | 2013-11-15 |  |  |
| 142741000 |  | Re-Baseline Actuals Adjustment | 1d | 2013-08-30 | 2013-08-30 | 9-130M FS+227d | 20d |
| 242741010 |  | Cryostat Factory - Design lifting Fixtures and Procurement Prep (Historical) | 3d | 2013-09-03 | 2013-09-05 | 9-130M FS+228d | 199d |
| 242741020 |  | Cryostat Factory - Perform tests for Torus Design - labor | 10d | 2013-09-03 | 2013-09-16 | 9-130M FS+228d | 192d |
| 242741030 |  | Cryostat Factory - Write, review and sign welding Procedures | 10d | 2013-09-03 | 2013-09-16 | 9-130M FS+228d | 192d |
| 242741035 |  | Cryostat Factory - Write, review and sign Incoming material QA Procedures FY13 | 20d | 2013-09-03 | 2013-09-30 | 9-130M FS+228d | 170d |
| 242741040 |  | Cryostat Factory - Write, review and sign material handling Procedures FY13 | 20d | 2013-09-03 | 2013-09-30 | 9-130M FS+228d | 170d |
| 242741045 |  | Cryostat Factory - Write, review and sign MLI application Procedures | 10d | 2013-09-03 | 2013-09-16 | 9-130M FS+228d | 192d |
| 242741050 |  | Cryostat Factory - Write, review and sign OSP FY13 | 20d | 2013-09-03 | 2013-09-30 | 9-130M FS+228d | 148d |
| 242741055 |  | Cryostat Factory - Write, review and sign assembly procedures FY13 | 20d | 2013-09-03 | 2013-09-30 | 9-130M FS+228d | 170d |
| 242741065 |  | Cryostat Factory - Orderfixtures, tables, tools, etc. for assembly Procurement | 32d | 2013-09-03 | 2013-10-16 | 9-130M FS+228d | 166d |
| 242741070 |  | Cryostat Stand and Axle | 42d | 2013-09-03 | 2013-10-30 | 9-130M FS+228d | 156d |
| 242741035a |  | Cryostat Factory - Write, review and sign Incoming material QA Procedures FY14 | 12d | 2013-10-01 | 2013-10-16 | 242741035, 9-130M FS+228d | 170d |
| 242741040a |  | Cryostat Factory - Write, review and sign material handling Procedures FY14 | 12d | 2013-10-01 | 2013-10-16 | 242741040, 9-130M FS+228d | 170d |
| 242741050a |  | Cryostat Factory - Write, review and sign OSP FY14 | 34d | 2013-10-01 | 2013-11-15 | 242741050, 9-130M FS+228d | 148d |
| 242741055a |  | Cryostat Factory - Write, review and sign assembly procedures FY14 | 12d | 2013-10-01 | 2013-10-16 | 242741055, 9-130M FS+228d | 170d |
| 242741070M |  | Cryostat factory fixtures and tooling in-house | 0d | 2013-10-30 | 2013-10-30 | 242741070, 242741065 | 156d |
| 242741075M |  | Torus Cryostat Factory Procedures In-place | 0d | 2013-11-15 | 2013-11-15 | 242741010, 242741030, 242741050, 242741035, 242741040, 242741035a, 242741055, 242741055a, 242741045, 242741020, 242741050a, 242741040a | 148d |
|  | 2 | **1.4.2.7.4.2 PROTOTYPE** |  | 2013-09-03 | 2014-07-08 |  |  |
| 242742000 |  | Cryostat Factory - Test Lifting Fixtures and Procedures with Wang Coil Case FY13 | 20d | 2013-09-03 | 2013-09-30 | 9-130M FS+228d | 132d |
| 242742020 |  | Cryostat Factory - Engineering oversight (Legg) FY13 | 20d | 2013-09-03 | 2013-09-30 | 9-130M FS+228d | 452d |
| 242742030 |  | Cryostat Factory - Pre-assembly of CCM using Wang Coil case FY13 | 20d | 2013-09-03 | 2013-09-30 | 9-130M FS+228d | 528.5d |
| 242742015 |  | Cryostat Factory - Test Lifting Fixtures and Procedures with Wang Coil Case FY14 | 12d | 2013-10-01 | 2013-10-16 | 242742000, 9-130M FS+228d | 132d |
| 242742020a |  | Cryostat Factory - Engineering oversight (Legg) FY14 | 99d | 2013-10-01 | 2014-03-03 | 242742020, 9-130M FS+228d | 452d |
| 242742030a |  | Cryostat Factory - Pre-assembly of CCM using Wang Coil case FY14 | 22.5d | 2013-10-01 | 2013-10-31 | 242742030, 9-130M FS+228d | 528.5d |
| 242742005 |  | Cryostat Factory - Layout Assembly area for equipment and fixtures | 5d | 2013-10-03 | 2013-10-09 | 242741070M FS-20d | 156d |
| 242742010 |  | Cryostat Factory - Install equipment and fixtures in factory area | 24d | 2013-10-03 | 2013-11-05 | 242741070M FS-20d, 242742005 FS-5d | 156d |
| 242742025 |  | Cryostat Factory - Mock-up of one quarter CCM | 66d | 2013-10-04 | 2014-01-17 | 9-140M FS+3d | 482d |
| 242742080 |  | Cryostat Factory - Rewrite procedures and lessons learned from Proto | 88d | 2013-10-17 | 2014-03-04 | 242742000, 242742015 | 132d |
| 242742040 |  | Cryostat Factory - Initial receipt inspection (QA) of Coil case shields | 77d | 2013-11-18 | 2014-03-19 | 242751115 FS-85d | 114d |
| 242742045 |  | Cryostat Factory - Pre-Assemble Seven Coil case shields | 86d | 2013-11-18 | 2014-04-01 | 242742040 FS-77d | 114d |
| 242742050 |  | Cryostat Factory - Initial receipt inspection (QA) of Vacuum Vessel Parts | 80d | 2013-12-18 | 2014-04-21 | 242751090 FS-86d | 44d |
| 242742055 |  | Cryostat Factory - Pre-Assemble Seven Vacuum Jackets | 118d | 2013-12-18 | 2014-06-13 | 242742050 FS-80d | 44d |
| 242742035 |  | Cryostat Factory - Initial reciept inspection of Coil Case MLI | 10d | 2014-02-17 | 2014-02-28 | 242751125 FS-10d | 101d |
| 242742015M |  | Cryostat Factory - Receive parts for proto cryostat | 0d | 2014-03-19 | 2014-03-19 | 242751125, 242751145, 242751090 FS-30d, 242751115 FS-30d | 106d |
| 242742060M |  | Cryostat Factory - Receive 1st Article (CCM #1) coil cold case | 0d | 2014-04-25 | 2014-04-25 | 242711.3035, 24271680 FS-19d | 45d |
| 242742065 |  | Cryostat Factory - Assemble 1st Article (CCM #1) Coil Cryostat with cold mass (Receive, QA and Pre-assembly) | 17d | 2014-04-25 | 2014-05-19 | 242741075M, 242742060M, 242742000, 242742010, 242742015, 242771010 | 45d |
| 242742070 |  | Cryostat Factory - Assemble 1st Article (CCM #1) Coil Cryostat with cold mass (MLI and LN2 shield assembly) | 17d | 2014-05-20 | 2014-06-12 | 242742065, 242742035, 242742045 FS-35d | 45d |
| 242742075 |  | Cryostat Factory - Assemble 1st Article (CCM #1) Coil Cryostat with cold mass (Vac jacket weld up) | 16d | 2014-06-16 | 2014-07-08 | 242742015M, 242742055, 242742070 | 44d |
|  | 3 | **1.4.2.7.4.3 PRODUCTION** |  | 2013-08-30 | 2015-07-14 |  |  |
| 142743000 |  | Re-Baseline Actuals Adjustment | 1d | 2013-08-30 | 2013-08-30 | 9-130M FS+227d | 20d |
| 242743125 |  | Cryostat Factory - Rework | 306d | 2014-02-14 | 2015-05-07 | 242742060M FS-50d | 117d |
| 242743005 |  | Cryostat Factory - Assemble Coil Cryostat #2 with cold mass (Receive, QA and Pre-assembly) | 22d | 2014-05-29 | 2014-06-27 | 242743000M FS-1d, 242742080 FS-35d | 37d |
| 242743000M |  | Cryostat Factory - Receive production coil case #2 | 0d | 2014-05-30 | 2014-05-30 | 242711.3040 | 37d |
| 242743010 |  | Cryostat Factory - Assemble Coil Cryostat #2 with cold mass (MLI and LN2 shield assembly) | 17d | 2014-06-30 | 2014-07-23 | 242743005 | 37d |
| 242743020M |  | Cryostat Factory - Receive production coil case #3 | 0d | 2014-07-03 | 2014-07-03 | 242711.3045 | 35d |
| 242743025 |  | Cryostat Factory - Assemble Coil Cryostat #3 with cold mass (Receive, QA and Pre-assembly) | 17d | 2014-07-03 | 2014-07-28 | 242743005, 242743020M | 35d |
| 242743015 |  | Cryostat Factory - Assemble Coil Cryostat #2 with cold mass (Vac jacket weld up) | 18d | 2014-07-24 | 2014-08-18 | 242743010, 242751375 FS-35d | 37d |
| 242743030 |  | Cryostat Factory - Assemble Coil Cryostat #3 with cold mass (MLI and LN2 shield assembly) | 17d | 2014-07-29 | 2014-08-20 | 242743010, 242743025 | 35d |
| 242743040M |  | Cryostat Factory - Receive production coil case #4 | 0d | 2014-08-11 | 2014-08-11 | 242711.3050 | 30d |
| 242743045 |  | Cryostat Factory - Assemble Coil Cryostat #4 with cold mass (Receive, QA and Pre-assembly) | 15d | 2014-08-11 | 2014-08-29 | 242743040M, 242743025 | 30d |
| 242743035 |  | Cryostat Factory - Assemble Coil Cryostat #3 with cold mass (Vac jacket weld up) | 17d | 2014-08-21 | 2014-09-15 | 242743030, 242743015 | 35d |
| 242743050 |  | Cryostat Factory - Assemble Coil Cryostat #4 with cold mass (MLI and LN2 shield assembly) | 15d | 2014-09-02 | 2014-09-22 | 242743045, 242743030 | 30d |
| 242743060M |  | Cryostat Factory - Receive production coil case #5 | 0d | 2014-09-16 | 2014-09-16 | 242711.3055 | 20d |
| 242743065 |  | Cryostat Factory - Assemble Coil Cryostat #5 with cold mass (Receive, QA and Pre-assembly) | 15d | 2014-09-16 | 2014-10-06 | 242743060M, 242743045 | 20d |
| 242743055 |  | Cryostat Factory - Assemble Coil Cryostat #4 with cold mass (Vac jacket weld up) | 15d | 2014-09-23 | 2014-10-13 | 242743035, 242743050 | 30d |
| 242743070 |  | Cryostat Factory - Assemble Coil Cryostat #5 with cold mass (MLI and LN2 shield assembly) | 15d | 2014-10-07 | 2014-10-27 | 242743065, 242743050 | 20d |
| 242743080M |  | Cryostat Factory - Receive production coil case #6 | 0d | 2014-10-15 | 2014-10-15 | 242711.3060 | 17d |
| 242743085 |  | Cryostat Factory - Assemble Coil Cryostat #6 with cold mass (Receive, QA and Pre-assembly) | 15d | 2014-10-15 | 2014-11-04 | 242743065, 242743080M | 17d |
| 242743075 |  | Cryostat Factory - Assemble Coil Cryostat #5 with cold mass (Vac jacket weld up) | 15d | 2014-10-28 | 2014-11-17 | 242743055, 242743070 | 20d |
| 242743090 |  | Cryostat Factory - Assemble Coil Cryostat #6 with cold mass (MLI and LN2 shield assembly) | 15d | 2014-11-05 | 2014-11-25 | 242743070, 242743085 | 17d |
| 242743095 |  | Cryostat Factory - Assemble Coil Cryostat #6 with cold mass (Vac jacket weld up) | 15d | 2014-11-26 | 2014-12-18 | 242743090, 242743075 | 17d |
| 242743100M |  | Cryostat Factory - Receive production coil case #7 | 0d | 2015-04-10 | 2015-04-10 | 242751010, 242711.5030 | 72d |
| 242743105 |  | Cryostat Factory - Assemble Coil Cryostat #7 with cold mass (Receive, QA and Pre-assembly) | 15d | 2015-04-10 | 2015-04-30 | 242743100M, 242743085 | 72d |
| 242743110 |  | Cryostat Factory - Assemble Coil Cryostat #7 with cold mass (MLI and LN2 shield assembly) | 15d | 2015-05-01 | 2015-05-21 | 242743105, 242743090 | 72d |

| ID | WBS | Task | Duration | Start | Finish | Predecessors | Total float |
| --- | --- | --- | --- | --- | --- | --- | --- |
| 242743120 |  | Cryostat Factory - Clean up And ship to site | 40d | 2015-05-15 | 2015-07-14 | 242743115 FS-20d | 72d |
| 242743115 |  | Cryostat Factory - Assemble Coil Cryostat #7 with cold mass (Vac jacket weld up) | 15d | 2015-05-22 | 2015-06-15 | 242743095, 242743110 | 72d |
|  | 5 | **1.4.2.7.5 TORUS MAGNET DESIGN/PARTS** |  | 2013-08-30 | 2014-10-21 |  |  |
|  | 1 | **1.4.2.7.5.1 TORUS MAGNET DESIGN/PARTS** |  | 2013-08-30 | 2014-10-21 |  |  |
| 142751000 |  | Re-Baseline Actuals Adjustment | 1d | 2013-08-30 | 2013-08-30 | 9-130M FS+227d | 20d |
| 242751000LOE |  | Torus - Engineering Oversight FY13 | 20d | 2013-09-03 | 2013-09-30 | 9-130M FS+228d | 420d |
| 242751010 |  | Vend Fab Additional Coil Case for Coil # 7 | 139d | 2013-09-03 | 2014-03-31 | 9-130M FS+228d | 326d |
| 242751020 |  | Torus - 1st Article Coil Case Procurement | 10d | 2013-09-03 | 2013-09-16 | 9-130M FS+228d | 90d |
| 242751045 |  | Torus - 6 Production Coil Cases Procurement | 139d | 2013-09-03 | 2014-03-31 | 9-130M FS+228d | 20d |
| 242751050 |  | Torus - 4K MLI Modeling and Drafting | 10d | 2013-09-03 | 2013-09-16 | 9-130M FS+228d | 101d |
| 242751080 |  | Torus - Vacuum Vessel Instrumentation Drafting | 20d | 2013-09-03 | 2013-09-30 | 9-130M FS+228d | 44d |
| 242751110 |  | Torus - Coil Case Shields Procurement Prep FY13 | 20d | 2013-09-03 | 2013-09-30 | 9-130M FS+228d | 114d |
| 242751155 |  | Torus - Cold Hub - Hub analysis with off design loads | 10d | 2013-09-03 | 2013-09-16 | 9-130M FS+228d | 59d |
| 242751160 |  | Torus - Cold Hub - Hub Shield Modeling FY13 | 20d | 2013-09-03 | 2013-09-30 | 242751155 FS-10d | 70d |
| 242751165 |  | Torus - Cold Hub - Hub Shield straping for cooling design FY13 | 20d | 2013-09-03 | 2013-09-30 | 242751160 FS-54d, 242751160a FS-54d | 70d |
| 242751185 |  | Torus - Upstream Hex - 4K Beam Stress Analysis | 9d | 2013-09-03 | 2013-09-13 | 242751155 FS-10d | 91d |
| 242751195 |  | Torus - Upstream Hex - Coil to Coil lead force analysis and flexibility analysis | 19d | 2013-09-03 | 2013-09-27 | 242751190a FS-35d, 242751190 FS-35d, 242751185 FS-9d | 91d |
| 242751200 |  | Torus - Upstream Hex - Recooler final design FY13 | 20d | 2013-09-03 | 2013-09-30 | 242751195 FS-19d | 91d |
| 242751205 |  | Torus - Upstream Hex - Recooler Mounting FY13 | 20d | 2013-09-03 | 2013-09-30 | 242751200 FS-44d, 242751200a FS-44d | 91d |
| 242751215 |  | Torus - Upstream Hex - Splice design and tooling design FY13 | 20d | 2013-09-03 | 2013-09-30 | 242751205a FS-44d, 242751205 FS-44d | 91d |
| 242751220 |  | Torus - Upstream Hex - Piping flexibility analysis | 19d | 2013-09-03 | 2013-09-27 | 242751190a FS-35d, 242751190 FS-35d | 59d |
| 242751345 |  | Torus - Main Cold mass support system - Supports Analyses | 20d | 2013-09-03 | 2013-09-30 | 9-130M FS+228d | 25d |
| 242751350 |  | Torus - Main Cold mass support system - Supports Modeling FY13 | 20d | 2013-09-03 | 2013-09-30 | 242751345 FS-20d | 25d |
| 242751355 |  | Torus - Main Cold mass support system - Supports Drafting FY13 | 20d | 2013-09-03 | 2013-09-30 | 242751350 FS-40d, 242751350a FS-40d | 25d |
| 242751425 |  | Torus - LOV analyses - 4K piping analysis FY13 | 20d | 2013-09-03 | 2013-09-30 | 9-130M FS+228d | 521d |
| 242751445 |  | Torus - Engineering Procured Labor Phase 1 | 20d | 2013-09-03 | 2013-09-30 | 9-130M FS+228d | 410d |
| 242751430 |  | Torus - LOV analyses - LN2 Piping FY13 | 15d | 2013-09-10 | 2013-09-30 | 242751425 FS-44d, 242751425a FS-44d | 521d |
| 242751120 |  | Torus - Coil Case MLI Procurement Prep FY13 | 10d | 2013-09-17 | 2013-09-30 | 242751050 | 101d |
| 242751190 |  | Torus - Upstream Hex - Piping mounting design FY13 | 10d | 2013-09-17 | 2013-09-30 | 242751155 | 59d |
| 242751435 |  | Torus - LOV analyses - Service module FY13 | 10d | 2013-09-17 | 2013-09-30 | 242751430a FS-40d, 242751430 FS-40d | 521d |
| 242751005LOE |  | Torus - Engineering Oversight FY14 | 247d | 2013-10-01 | 2014-09-30 | 242751000LOE | 420d |
| 242751110a |  | Torus - Coil Case Shields Procurement Prep FY14 | 24d | 2013-10-01 | 2013-11-01 | 9-130M FS+228d, 242751110 | 114d |
| 242751120a |  | Torus - Coil Case MLI Procurement Prep FY14 | 34d | 2013-10-01 | 2013-11-15 | 242751050, 242751120 | 101d |
| 242751160a |  | Torus - Cold Hub - Hub Shield Modeling FY14 | 34d | 2013-10-01 | 2013-11-15 | 242751160, 242751155 FS-10d | 70d |
| 242751165a |  | Torus - Cold Hub - Hub Shield straping for cooling design FY14 | 42d | 2013-10-01 | 2013-11-27 | 242751160 FS-54d, 242751165, 242751160a FS-54d | 70d |
| 242751190a |  | Torus - Upstream Hex - Piping mounting design FY14 | 15d | 2013-10-01 | 2013-10-21 | 242751190, 242751155 | 59d |
| 242751200a |  | Torus - Upstream Hex - Recooler final design FY14 | 24d | 2013-10-01 | 2013-11-01 | 242751200, 242751195 FS-19d | 91d |
| 242751205a |  | Torus - Upstream Hex - Recooler Mounting FY14 | 24d | 2013-10-01 | 2013-11-01 | 242751200 FS-44d, 242751205, 242751200a FS-44d | 91d |
| 242751215a |  | Torus - Upstream Hex - Splice design and tooling design FY14 | 34d | 2013-10-01 | 2013-11-15 | 242751205a FS-44d, 242751205 FS-44d, 242751215 | 91d |
| 242751350a |  | Torus - Main Cold mass support system - Supports Modeling FY14 | 20d | 2013-10-01 | 2013-10-28 | 242751345 FS-20d, 242751350 | 25d |
| 242751355a |  | Torus - Main Cold mass support system - Supports Drafting FY14 | 20d | 2013-10-01 | 2013-10-28 | 242751350 FS-40d, 242751355, 242751350a FS-40d | 25d |
| 242751425a |  | Torus - LOV analyses - 4K piping analysis FY14 | 29d | 2013-10-01 | 2013-11-08 | 9-130M FS+228d, 242751425 | 521d |
| 242751430a |  | Torus - LOV analyses - LN2 Piping FY14 | 30d | 2013-10-01 | 2013-11-11 | 242751430, 242751425a FS-44d, 242751425 FS-44d | 521d |
| 242751435a |  | Torus - LOV analyses - Service module FY14 | 30d | 2013-10-01 | 2013-11-11 | 242751430a FS-40d, 242751435, 242751430 FS-40d | 521d |
| 242751450 |  | Torus - Engineering Procured Labor Phase 2 | 141d | 2013-10-01 | 2014-04-30 | 242751445 | 410d |
| 242751090 |  | Torus - Vacuum Vessel Assembly Parts Procurement | 139d | 2013-10-02 | 2014-04-29 | 242751080 FS+1d | 44d |
| 242751265 |  | Torus - Downstream Hex - 4K beam Stress Analysis | 10d | 2013-10-14 | 2013-10-25 | 242751215a FS-25d, 242751215 FS-25d | 91d |
| 242751150 |  | Torus - Cold Hub - Magnet construction analysis | 43d | 2013-10-15 | 2013-12-16 | 9-140M FS+10d | 81d |
| 242751145 |  | Torus - Out Of Plane Supports - OOPS Procurement | 87d | 2013-10-16 | 2014-02-28 | 9-140M FS+11d | 118d |
| 242751115 |  | Torus - Coil Case Shields Procurement | 95d | 2013-11-04 | 2014-03-31 | 242751110, 242751110a | 114d |
| 242751210 |  | Torus - Upstream Hex - Recooler Drafting | 18d | 2013-11-04 | 2013-11-27 | 242751200, 242751205a, 242751205, 242751200a | 105d |
| 242751225 |  | Torus - Upstream Hex - Shield final design and Drafting | 18d | 2013-11-04 | 2013-11-27 | 242751220 FS+25d | 59d |
| 242751230 |  | Torus - Upstream Hex - VJ final design and Drafting | 43d | 2013-11-04 | 2014-01-15 | 242751225 FS-18d | 59d |
| 242751275 |  | Torus - Downstream Hex - Shield final design and Drafting | 25d | 2013-11-08 | 2013-12-16 | 242751270 FS-6d | 91d |
| 242751270 |  | Torus - Downstream Hex - 4K piping analysis | 5d | 2013-11-11 | 2013-11-15 | 242751265 FS+10d | 91d |
| 242751125 |  | Torus - Coil Case MLI Procurement | 64d | 2013-11-18 | 2014-02-28 | 242751120, 242751120a | 101d |
| 242751280 |  | Torus - Downstream Hex - VJ final design and Drafting | 13d | 2013-11-25 | 2013-12-13 | 242751275 FS-14d | 91d |
| 242751290 |  | Torus - Downstream Hex Assembly Parts Procurement | 102d | 2013-11-25 | 2014-04-30 | 242751285 FS-32d | 91d |
| 242751170 |  | Torus - Cold Hub - Hub shield final drafting | 22d | 2013-12-02 | 2014-01-10 | 242751165a, 242751165 | 70d |
| 242751235 |  | Torus - Upstream Hex Assembly Parts Procurement Prep | 29d | 2013-12-02 | 2014-01-22 | 242751230 FS-25d | 59d |
| 242751245 |  | Torus - Recooler Procurement Prep | 23d | 2013-12-02 | 2014-01-13 | 242751210 | 105d |
| 242751360 |  | Torus - Main Cold mass support system - Attachment to Floor Engineering | 15d | 2013-12-12 | 2014-01-13 | 242751355a FS+30d, 242751355 FS+30d | 25d |
| 242751285 |  | Torus - Downstream Hex Assembly Parts Procurement Prep | 19d | 2013-12-16 | 2014-01-22 | 242751280 | 91d |
| 242751390 |  | Torus - Installation Design - Develop Installation Tooling Design | 41d | 2014-01-02 | 2014-02-28 | 242751365 FS-22d | 25d |
| 242751175 |  | Torus - Cold Hub Procurement Prep | 34d | 2014-01-13 | 2014-02-28 | 242751170, 242751150 | 70d |
| 242751250 |  | Torus - Recooler Procurement | 62d | 2014-01-14 | 2014-04-10 | 242751245 | 105d |
| 242751365 |  | Torus - Main Cold mass support system - Attachment to Floor Modeling and Drafting | 14d | 2014-01-14 | 2014-02-03 | 242751360 | 25d |
| 242751315 |  | Torus - Supply-Return Header to DS ring - Modeling | 25d | 2014-01-17 | 2014-02-21 | 242751280 FF+16d, 242751280 FS+16d | 145d |
| 242751320 |  | Torus - Supply-Return Header to DS ring - Piping flexibility analysis | 25d | 2014-01-17 | 2014-02-21 | 242751315 FS-25d | 145d |
| 242751240 |  | Torus - Upstream Hex Assembly Parts Procurement | 102d | 2014-01-23 | 2014-06-16 | 242751235 | 59d |

| ID | WBS | Task | Duration | Start | Finish | Predecessors | Total float |
| --- | --- | --- | --- | --- | --- | --- | --- |
| 242751395 |  | Torus - Installation Design - Model Installation Tooling | 20d | 2014-02-03 | 2014-02-28 | 242751390 FS-20d | 25d |
| 242751400 |  | Torus - Installation Design - Analyze Installation Tooling | 30d | 2014-02-03 | 2014-03-14 | 242751395 FS-20d | 25d |
| 242751370 |  | Torus - CM Support Assembly Parts Procurement Prep | 29d | 2014-02-04 | 2014-03-14 | 242751365 | 88d |
| 242751380 |  | Torus - Torus Support to Hall floor Assembly Procurement Prep | 23d | 2014-02-06 | 2014-03-10 | 242751365 FS+2d | 89d |
| 242751255 |  | Torus - Upstream Hex MLI Procurement Prep | 20d | 2014-02-10 | 2014-03-07 | 242751225 FS+41d | 184d |
| 242751295 |  | Torus - Downstream Hex MLI Procurement Prep | 20d | 2014-02-10 | 2014-03-07 | 242751275 FS+30d | 184d |
| 242751305 |  | Torus - Misc Hex MLI Procurement Prep | 20d | 2014-02-10 | 2014-03-07 | 242751275 FS+30d | 184d |
| 242751325 |  | Torus - Supply-Return Header to DS ring - Modeling/Drafting | 15d | 2014-02-24 | 2014-03-14 | 242751320 | 145d |
| 242751180 |  | Torus - Cold Hub Procurement | 64d | 2014-03-03 | 2014-05-30 | 242751175 | 70d |
| 242751415 |  | Torus - Installation Design - Develop procedures and safety documentation | 26d | 2014-03-03 | 2014-04-07 | 242751390 | 108d |
| 242751300 |  | Torus - Downstream Hex MLI Procurement | 60d | 2014-03-07 | 2014-05-30 | 242751295 FS-1d | 184d |
| 242751260 |  | Torus - Upstream Hex MLI Procurement | 59d | 2014-03-10 | 2014-05-30 | 242751255 | 184d |
| 242751310 |  | Torus - Misc Hex MLI Procurement | 59d | 2014-03-10 | 2014-05-30 | 242751305 | 184d |
| 242751385 |  | Torus - Torus Support to Hall floor Assembly Procurement | 58d | 2014-03-11 | 2014-05-30 | 242751380 | 89d |
| 242751330 |  | Torus - Supply-Return Header Procurement Prep | 35d | 2014-03-17 | 2014-05-02 | 242751325 | 145d |
| 242751375 |  | Torus - CM Support Assembly Parts Procurement | 75d | 2014-03-17 | 2014-06-30 | 242751370 | 88d |
| 242751405 |  | Torus - Installation Design - Installation Tooling Drafting | 15d | 2014-03-17 | 2014-04-04 | 242751400 | 25d |
| 242751410 |  | Torus - Installation Design - Develop Scaffolding Design | 10d | 2014-04-07 | 2014-04-18 | 242751405 | 45d |
| 242751420 |  | Torus - Installation Parts Procurement Prep | 26d | 2014-04-07 | 2014-05-12 | 242751405, 242751410 FS-30d | 25d |
| 242751335 |  | Torus - Supply-Return Header Procurement | 40d | 2014-05-05 | 2014-06-30 | 242751330 | 145d |
| 242751440 |  | Torus - Installation Parts Procurement (90K Accounted for Cryo Jumpers) | 77d | 2014-05-13 | 2014-08-29 | 242751420 | 25d |
| 242751010LOE |  | Torus - Engineering Oversight FY15 | 15d | 2014-10-01 | 2014-10-21 | 242751005LOE | 420d |
|  | 6 | **1.4.2.7.6 TORUS CRYOGENICS** |  | 2013-08-30 | 2015-03-30 |  |  |
|  | 1 | **1.4.2.7.6.1 CRYO DISTRIBUTION CAN** |  | 2013-08-30 | 2014-08-29 |  |  |
| 142761000 |  | Re-Baseline Actuals Adjustment | 1d | 2013-08-30 | 2013-08-30 | 9-130M FS+227d | 20d |
| 242761000 |  | Torus - Distribution Can - Drafting Mechanical | 11d | 2013-09-03 | 2013-09-17 | 9-130M FS+228d | 153d |
| 242761005 |  | Torus - Distribution Can - Drafting Structural | 8d | 2013-09-18 | 2013-09-27 | 242761000 | 153d |
| 242761010 |  | Torus - Distribution Can - ProjectMgt FY13 | 1d | 2013-09-30 | 2013-09-30 | 242761005 | 153d |
| 242761010a |  | Torus - Distribution Can - ProjectMgt FY14 | 12d | 2013-10-01 | 2013-10-16 | 242761005, 242761010 | 153d |
| 242761015 |  | Torus - Distribution Can - QA | 13d | 2013-10-17 | 2013-11-04 | 242761010a, 242761010 | 153d |
| 242761020 |  | Torus - Distribution Can - Write Specs | 15d | 2013-11-05 | 2013-11-25 | 242761015 | 153d |
| 242761025 |  | Torus - Distribution Can - Bid and select vendor | 40d | 2013-11-26 | 2014-02-04 | 242761020 | 153d |
| 242761030 |  | Torus - Cryogenic Distribution Can Procurement | 128d | 2014-03-03 | 2014-08-29 | 242761025 FS+18d | 153d |
|  | 2 | **1.4.2.7.6.2 CRYO CONTROL CAN** |  | 2013-08-30 | 2015-03-30 |  |  |
| 142762000 |  | Re-Baseline Actuals Adjustment | 1d | 2013-08-30 | 2013-08-30 | 9-130M FS+227d | 20d |
| 242762000 |  | Torus - Cryogenic Tower - Mechanical Engineering FY13 | 20d | 2013-09-03 | 2013-09-30 | 9-130M FS+228d | 38d |
| 242762000a |  | Torus - Cryogenic Tower - Mechanical Engineering FY14 | 55d | 2013-10-01 | 2013-12-18 | 9-130M FS+228d, 242762000 | 38d |
| 242762005 |  | Torus - Cryogenic Tower - Structural Engineering | 10d | 2013-12-19 | 2014-01-13 | 242762000a, 242762000 | 38d |
| 242762010 |  | Torus - Cryogenic Tower - Electrical/Instrumentation Engineering | 5d | 2014-01-14 | 2014-01-21 | 242762005 | 38d |
| 242762015 |  | Torus - Cryogenic Tower - Drafting Mechanical | 80d | 2014-01-22 | 2014-05-13 | 242762010 | 38d |
| 242762020 |  | Torus - Cryogenic Tower - Drafting Structural | 15d | 2014-05-14 | 2014-06-04 | 242762015 | 38d |
| 242762025 |  | Torus - Cryogenic Tower - ProjectMgt | 10d | 2014-06-05 | 2014-06-18 | 242762020 | 38d |
| 242762030 |  | Torus - Cryogenic Tower - QA | 15d | 2014-06-19 | 2014-07-10 | 242762025 | 38d |
| 242762035 |  | Torus - Cryogenic Tower - Write Specs | 15d | 2014-07-11 | 2014-07-31 | 242762030 | 38d |
| 242762040 |  | Torus - Cryogenic Tower - Bid and select vendor | 40d | 2014-08-01 | 2014-09-26 | 242762035 | 38d |
| 242762045 |  | Torus - Cryogenic Tower Procurement | 120d | 2014-09-29 | 2015-03-30 | 242762040 | 38d |
|  | 7 | **1.4.2.7.7 TORUS INSTUMENTATION AND CONTROL** |  | 2013-08-30 | 2015-05-06 |  |  |
|  | 1 | **1.4.2.7.7.1 TORUS INSTUMENTATION AND CONTROL** |  | 2013-08-30 | 2015-05-06 |  |  |
| 142771000 |  | Re-Baseline Actuals Adjustment | 1d | 2013-08-30 | 2013-08-30 | 9-130M FS+227d | 20d |
| 242771010 |  | Torus - Instrumentation Sensors Procurement | 60d | 2013-09-03 | 2013-11-25 | 9-130M FS+228d | 142d |
| 242771000 |  | Torus - Instrumentation Controls Design | 55d | 2013-10-02 | 2013-12-19 | 9-140M FS+1d | 236d |
| 242771005 |  | Torus - Instrumentation Magnet Protection System Design | 120d | 2013-12-20 | 2014-06-19 | 242771000 | 236d |
| 242771015 |  | Torus - Instrumentation Controls Procurement Prep | 5d | 2014-10-01 | 2014-10-07 | 242771000, 9-155M | 55d |
| 242771025 |  | Torus - Instrumentation Magnet Protection System Procurement Prep | 5d | 2014-10-01 | 2014-10-07 | 9-155M, 242771005 | 165d |
| 242771020 |  | Torus - Instrumentation Controls Procurement | 80d | 2014-10-08 | 2015-02-11 | 242771015 | 55d |
| 242771030 |  | Torus - Instrumentation Magnet Protection System Procurement | 60d | 2014-10-08 | 2015-01-13 | 242771025 | 165d |
| 242771035 |  | Torus - Instrumentation Controls Assembly | 120d | 2014-11-05 | 2015-05-06 | 242771030 FS-150d, 242771020 FS-60d | 55d |
|  | 8 | **1.4.2.7.8 SOLENOID MAGNET DESIGN/PARTS** |  | 2013-08-30 | 2015-01-05 |  |  |
|  | 1 | **1.4.2.7.8.1 SOLENOID MAGNET DESIGN/PARTS** |  | 2013-08-30 | 2015-01-05 |  |  |
| 142781000 |  | Re-Baseline Actuals Adjustment | 1d | 2013-08-30 | 2013-08-30 | 9-130M FS+227d | 20d |
| 242781000LOE |  | Solenoid - Technical Support & Oversite FY13 | 20d | 2013-09-03 | 2013-09-30 | 9-130M FS+228d | 58d |
| 242781005LOE |  | Solenoid - Technical Support & Oversite FY14 | 247d | 2013-10-01 | 2014-09-30 | 242781000LOE | 58d |
| 242781015 |  | Solenoid - Magent Installation Design | 149d | 2013-10-01 | 2014-05-12 | 9-140M | 133d |
| 242781025 |  | Solenoid Commissioning - Design & Documentation | 189d | 2014-03-05 | 2014-12-01 | 9-140M FS+100d | 262d |
| 242781020 |  | Solenoid - Magent Installation Procurements | 120d | 2014-05-13 | 2014-10-30 | 242781015 | 133d |
| 242781010LOE |  | Solenoid - Technical Support & Oversite FY15 | 59d | 2014-10-01 | 2015-01-05 | 242781005LOE | 683d |
|  | 9 | **1.4.2.7.9 SOLENOID CRYOGENICS** |  | 2013-08-30 | 2015-07-06 |  |  |
|  | 1 | **1.4.2.7.9.1 SOLENOID CRYOGENICS** |  | 2013-08-30 | 2015-07-06 |  |  |
| 142791000 |  | Re-Baseline Actuals Adjustment | 1d | 2013-08-30 | 2013-08-30 | 9-130M FS+227d | 20d |
| 242791000 |  | Solenoid - Thermal Analysis FY13 | 20d | 2013-09-03 | 2013-09-30 | 9-130M FS+228d | 3d |

| ID | WBS | Task | Duration | Start | Finish | Predecessors | Total float | Constraint |
| --- | --- | --- | --- | --- | --- | --- | --- | --- |
| 242791000a |  | Solenoid - Thermal Analysis FY14 | 50d | 2013-10-01 | 2013-12-11 | 242791000, 9-130M FS+228d | 3d |  |
| 242791005 |  | Solenoid - Process P&Is | 30d | 2013-11-19 | 2014-01-13 | 242791000a FS-15d, 242791000 FS-15d | 3d |  |
| 242791010 |  | Solenoid - Cryogenic Modes of Operation | 15d | 2014-01-14 | 2014-02-04 | 242791005 | 3d |  |
| 242791020 |  | Solenoid - Evaluation of Process Components | 20d | 2014-02-03 | 2014-02-28 | 242791015 FS-5d | 3d |  |
| 242791015 |  | Solenoid - PDR | 3d | 2014-02-05 | 2014-02-07 | 242791010 | 3d |  |
| 242791025 |  | Solenoid - Current Leads | 23d | 2014-03-03 | 2014-04-02 | 242791020 | 3d |  |
| 242791030 |  | Solenoid - Mechanical Design of the cryogenic can | 120d | 2014-04-03 | 2014-09-22 | 242791025 | 3d |  |
| 242791035 |  | Solenoid - FDR | 1d | 2014-09-23 | 2014-09-23 | 242791030 | 3d |  |
| 242791040 |  | Solenoid Cryogenics - Write Specifications | 15d | 2014-09-24 | 2014-10-14 | 242791035 | 3d |  |
| 242791045 |  | Solenoid Cryogenics - Bid cycle, review and award | 40d | 2014-10-15 | 2014-12-11 | 242791040 | 3d |  |
| 242791050 |  | Solenoid Cryogenics - Procurement | 100d | 2014-12-12 | 2015-05-13 | 242791045 | 3d |  |
| 242791055 |  | Solenoid cryogenics - Installation and Commissioning | 15d | 2015-05-14 | 2015-06-05 | 242791050 | 3d |  |
| 242791060 |  | Solenoid cryogenics - Test of system | 20d | 2015-06-08 | 2015-07-06 | 242791055 | 3d |  |
|  | 10 | **1.4.2.7.10 SOLENOID INSTRUMENTATION AND CONTROLS** |  | 2013-08-30 | 2015-02-17 |  |  |  |
|  | 1 | **1.4.2.7.10.1 SOLENOID INSTRUMENTATION AND CONTROLS** |  | 2013-08-30 | 2015-02-17 |  |  |  |
| 1427.10000 |  | Re-Baseline Actuals Adjustment | 1d | 2013-08-30 | 2013-08-30 | 9-130M FS+227d | 20d |  |
| 242710.1015 |  | Solenoid - Instrumentation Controls Design FY13 | 20d | 2013-09-03 | 2013-09-30 | 9-130M FS+228d | 98d |  |
| 242710.1015a |  | Solenoid - Instrumentation Controls Design FY14 | 52d | 2013-10-01 | 2013-12-13 | 242710.1015, 9-130M FS+228d | 98d |  |
| 242710.1000 |  | Solenoid - Instrumentation Magnet Protection System Design | 120d | 2013-12-16 | 2014-06-13 | 242710.1015, 242710.1015a | 187d |  |
| 242710.1020 |  | Solenoid - Instrumentation Controls Procurement Prep | 5d | 2013-12-16 | 2013-12-20 | 242710.1015, 242710.1015a | 98d |  |
| 242710.1025 |  | Solenoid - Instrumentation Controls Procurement | 79d | 2014-01-02 | 2014-04-23 | 242710.1020 | 98d |  |
| 242710.1005 |  | Solenoid - Instrumentation Magnet Protection System Procurement Prep | 5d | 2014-06-16 | 2014-06-20 | 242710.1000 | 187d |  |
| 242710.1030 |  | Solenoid - Instrumentation Controls Assembly | 160d | 2014-06-20 | 2015-02-17 | 242710.1025 FS+40d, 242710.1010 FS-150d | 98d |  |
| 242710.1010 |  | Solenoid - Instrumentation Magnet Protection System Procurement | 60d | 2014-06-23 | 2014-09-16 | 242710.1005 | 187d |  |
|  | 11 | **1.4.2.7.11 TORUS RISK MITIGATION** |  | 2013-09-03 | 2015-04-09 |  |  |  |
|  | 1 | **1.4.2.7.11.1 ADDITIONAL FNAL COILS FOR TORUS RISK MITIGATION** |  | 2013-10-01 | 2014-11-26 |  |  |  |
| 242711.1005 |  | FNAL - Fabricate Prototype CCM | 119d | 2013-10-01 | 2014-03-31 | 242711.4005a FS-25d, 242711.4005b FS-25d, 242711.4005 FS-25d | 58d |  |
| 242711.1010 |  | FNAL - Fabricate CCM #7 | 288d | 2013-10-01 | 2014-11-26 | 242711.4010 FS-87d, 242711.1000 FS-270d, 242711.1005 FS-119d | 72d |  |
| 242711.1000 |  | Additional FNAL Oversight | 86d | 2014-07-02 | 2014-10-31 | 24271735LOE | 72d |  |
|  | 2 | **1.4.2.7.11.2 ADDITIONAL COIL CASE AND HARDWARE FOR TORUS RISK MITIGATION** |  | 2013-09-03 | 2013-12-20 |  |  |  |
| 242711.2005 |  | Vend Fab 1 Set of Additional Hardware for Cryostat (Cold Mass Shiled, OOPS, Axial Support, MLI, Vacuum Jacket) | 77d | 2013-09-03 | 2013-12-20 | 9-130M FS+228d | 453d |  |
|  | 3 | **1.4.2.7.11.3 COIL LN2 TESTING FOR TORUS RISK MITIGATION** |  | 2013-09-03 | 2014-11-26 |  |  |  |
| 242711.3000 |  | LN2 TEST - Procurements Preperation FY13 | 20d | 2013-09-03 | 2013-09-30 | 9-130M FS+228d | 110.5d |  |
| 242711.3000a |  | LN2 TEST - Procurements Preperation FY14 | 23.5d | 2013-10-01 | 2013-11-01 | 9-130M FS+228d, 242711.3000 | 110.5d |  |
| 242711.3005 |  | LN2 TEST - Preliminary system set up and integration (One coil LN2 Test) Procurements | 40d | 2013-10-01 | 2013-11-26 | 242711.3000 FS-23d, 242711.3000a FS-23d | 121.5d |  |
| 242711.3010 |  | LN2 TEST - Mounting of Q heaters and wiring | 16d | 2013-10-01 | 2013-10-23 | 242711.3000 FS-23d, 242711.3000a FS-23d | 110.5d |  |
| 242711.3015 |  | LN2 TEST - Instrumentation general and wiring layout and cabling | 11d | 2013-10-23 | 2013-11-07 | 242711.3010 | 110.5d |  |
| 242711.3025 |  | LN2 TEST - Preliminary system set up and integration (One coil LN2 Test) Labor | 29d | 2013-10-23 | 2013-12-05 | 242711.3010 | 116.5d |  |
| 242711.3020 |  | LN2 TEST - HV/LV Feedthrough and wirng | 24d | 2013-11-07 | 2013-12-13 | 242711.3015 | 110.5d |  |
| 242711.3030 |  | LN2 TEST - LN2 Testing of Prototype Coil | 10d | 2014-03-11 | 2014-03-24 | 242711.3005, 242711.3020, 242711.1005 FS-15d, 242711.3025 | 58d |  |
| 242711.3035 |  | LN2 TEST - LN2 Testing of CCM #1 | 10d | 2014-04-11 | 2014-04-24 | 242711.3030, 24271695 FS-14d | 45d |  |
| 242711.3040 |  | LN2 TEST - LN2 Testing of CCM #2 | 10d | 2014-05-15 | 2014-05-29 | 24271700 FS-11d, 242711.3035 | 37d |  |
| 242711.3045 |  | LN2 TEST - LN2 Testing of CCM #3 | 10d | 2014-06-19 | 2014-07-02 | 242711.3040, 24271705 FS-8d | 35d |  |
| 242711.3050 |  | LN2 TEST - LN2 Testing of CCM #4 | 10d | 2014-07-28 | 2014-08-08 | 24271710 FS-4d, 242711.3045 | 30d |  |
| 242711.3055 |  | LN2 TEST - LN2 Testing of CCM #5 | 10d | 2014-09-02 | 2014-09-15 | 242711.3050, 24271715 | 20d |  |
| 242711.3060 |  | LN2 TEST - LN2 Testing of CCM #6 | 10d | 2014-10-01 | 2014-10-14 | 24271720, 242711.3055 | 17d |  |
| 242711.3065 |  | LN2 TEST - LN2 Testing of CCM #7 | 10d | 2014-11-13 | 2014-11-26 | 242711.3060, 242711.1010 FS-10d | 72d |  |
|  | 4 | **1.4.2.7.11.4 ADDITIONAL COPPER SSC AND SOLDERING FOR TORUS RISK MITIGATION** |  | 2013-09-03 | 2014-02-06 |  |  |  |
| 242711.4005 |  | Solder condutor for Prototype Coil - Procurement | 45d | 2013-09-03 | 2013-11-04 | 24271740 FS-60d | 58d |  |
| 242711.4005a |  | Solder condutor for Prototype Coil Labor FY13 | 20d | 2013-09-03 | 2013-09-30 | 24271740 FS-60d | 58d |  |
| 242711.4005b |  | Solder condutor for Prototype Coil Labor FY14 | 25d | 2013-10-01 | 2013-11-04 | 242711.4005a, 24271740 FS-60d | 58d |  |
| 242711.4010 |  | Solder condutor for Coil #7 | 57d | 2013-11-05 | 2014-02-06 | 242711.4005b, 242711.4005, 242711.4005a | 77d |  |
|  | 5 | **1.4.2.7.11.5 SECLAY COIL COLD TESTING FOR TORUS RISK MITIGATION** |  | 2013-09-03 | 2015-04-09 |  |  |  |
| 242711.5000 |  | Saclay Cold Tests - Contract Preperation | 9d | 2013-09-03 | 2013-09-13 | 9-130M FS+228d | 229d |  |
| 242711.5010 |  | Saclay Cold Tests - Oversight Expenses and Labor FY13 | 20d | 2013-09-03 | 2013-09-30 | 242711.5000 FS-9d | 229d |  |
| 242711.5010a |  | Saclay Cold Tests - Oversight Expenses and Labor FY14 | 247d | 2013-10-01 | 2014-09-30 | 242711.5000 FS-9d, 242711.5010 | 229d |  |
| 242711.5005 |  | Saclay Cold Tests - Kickoff Meeting | 19d | 2013-11-01 | 2013-11-27 | 9-140M FS+23d | 346d |  |
| 242711.5015 |  | Saclay Cold Tests - Facility Set-up Phase #1 | 118d | 2013-11-01 | 2014-04-30 | 242711.5005 FS-19d, 242711.5000 FS-9d | 346d |  |
| 242711.5020 |  | Saclay Cold Tests - Facility Set-up Phase #2 | 118d | 2013-11-01 | 2014-04-30 | 242711.5005 FS-19d, 242711.5015 FS-118d | 346d |  |
| 242711.5025 |  | Saclay Cold Tests - Cryogenic Tests of Prototype Coil | 85d | 2014-04-02 | 2014-07-31 | 242711.3030, 242711.5020 FS-21d | 346d |  |
| 242711.5010b |  | Saclay Cold Tests - Oversight Expenses and Labor FY15 | 75d | 2014-10-01 | 2015-01-28 | 242711.5000 FS-9d, 242711.5010a | 229d |  |
| 242711.5030 |  | Saclay Cold Tests - Cryogenic Tests of Coil #7 | 85d | 2014-12-01 | 2015-04-09 | 242711.3065 | 72d |  |
|  | 3 | **1.4.3 CONSTRUCTION HALL C** |  | 2009-01-02 | 2016-02-03 |  |  |  |
|  | 1 | **1.4.3.1 MAGNET** |  | 2009-01-02 | 2016-02-03 |  |  |  |
|  | 1 | **1.4.3.1.1 HB MAGNET** |  | 2009-10-14 | 2015-01-05 |  |  |  |
| 14311000M |  | HB- Award Contract for HB Mag | 0d | 2009-10-14 | 2009-10-14 | 9-100M | 0d | mandatory start 2009-10-14 |
| 14311002 |  | HB- Contractor Expenses (FROZEN by CR10-063) | 20d | 2009-10-14 | 2009-11-10 | 14311000M | 195d |  |
| 14311005 |  | HB- Finalise Dsgn for HB Mag (FROZEN by CR10-063) | 130d | 2009-10-14 | 2010-04-27 | 14311000M | 85d |  |
| 143118P1LOE |  | HB Contract Mngmnt for HB Mag | 239d | 2009-10-14 | 2010-09-30 | 14311000M | 20d |  |
| 14311010 |  | HB- Dsgn Review of HB Mag (FROZEN by CR10-063) | 5d | 2010-04-28 | 2010-05-04 | 14311005, 14311002 | 85d |  |

| ID | WBS | Task | Duration | Start | Finish | Predecessors | Total float | Constraint |
| --- | --- | --- | --- | --- | --- | --- | --- | --- |
| 14311015 |  | HB- Insulate Superconductor (FROZEN by CR10-063) | 20d | 2010-05-05 | 2010-06-02 | 14311010 | 85d |  |
| 14311080 |  | Reverse Entry - Change Request 10-063 | 1d | 2010-07-01 | 2010-07-01 | 14311000M FS+175d | 65d |  |
| 14311082 |  | Vend Fab HB Magnet Peg Point #1 Preliminary Design Review | 84d | 2010-07-02 | 2010-10-29 | 14311080 FS-1d, 14311000M FS+176d | 64d |  |
| 14311082a |  | Vend Fab HB Magnet Peg Point #2 HB Analysis Complete | 160d | 2010-07-02 | 2011-02-28 | 14311082 FS-84d | 64d |  |
| 14311082b |  | Vend Fab HB Magnet Peg Point #3 Intermediate Design Review | 247d | 2010-07-02 | 2011-06-30 | 14311082a FS-160d | 64d |  |
| 14311084 |  | Vend Fab HB Magnet Peg Point #4 Final Design Review | 332d | 2010-07-02 | 2011-10-31 | 14311015, 14311082b FS-247d | 64d |  |
| 14311086 |  | Vend Fab HB Magnet Peg Point #5a HB Cold Mass Complete | 409d | 2010-07-02 | 2012-02-29 | 14311073a FS-332d, 14311084 FS-332d | 64d |  |
| 143118P2LOE |  | HB Contract Mngmnt for HB Mag | 248d | 2010-10-01 | 2011-09-30 | 143118P1LOE | 20d |  |
| 14311073 |  | HB Design Reviews FY11 | 104d | 2011-05-05 | 2011-09-30 | 14311082b FS-40d | 64d |  |
| 14311086a |  | Vend Fab HB Magnet Peg Point #5b HB Cold Mass Complete | 162d | 2011-07-01 | 2012-02-29 | 9-110M FS+184d, 14311086 FS-163d | 64d |  |
| 14311086b |  | Vend Fab HB Magnet Peg Point #6 Cryostat and Materials Certifications Complete | 247d | 2011-07-01 | 2012-06-29 | 14311086a FS-162d | 64d |  |
| 14311086c |  | Vend Fab HB Magnet Peg Point #7a HB Magnet Cryostated | 334d | 2011-07-01 | 2012-10-31 | 14311086b FS-247d | 64d |  |
| 14311073a |  | HB Design Reviews FY12 | 21d | 2011-10-03 | 2011-10-31 | 14311073 | 64d |  |
| 143118P3LOE |  | HB Contract Mngmnt for HB Mag | 58d | 2011-10-03 | 2011-12-30 | 143118P2LOE | 20d |  |
| 14311072 |  | HB Site Inspections FY12 | 189d | 2012-01-03 | 2012-09-28 | 14311086 FS-40d | 64d |  |
| 143118P3LOE5 |  | HB Contract Mngmnt for HB Mag | 189d | 2012-01-03 | 2012-09-28 | 143118P3LOE | 20d |  |
| 14311086d |  | Vend Fab HB Magnet Peg Point #7b HB Magnet Cryostated | 150d | 2012-04-02 | 2012-10-31 | 14311086c FS-150d, 9-120M FS+120d | 64d |  |
| 14311086f |  | Vend Fab HB Magnet Peg Point #8 Magnet Complete | 226d | 2012-04-02 | 2013-02-28 | 14311086d FS-150d | 64d |  |
| 14311086g |  | Vend Fab HB Magnet Peg Point #9 HB Tested and Mapped at MSU and delivery to JLab | 311d | 2012-04-02 | 2013-06-28 | 14311086f FS-226d | 64d |  |
| 14311072a |  | HB Site Inspections FY13 | 184d | 2012-10-01 | 2013-06-28 | 14311072 | 64d |  |
| 143118P4LOE |  | HB Contract Mngmnt for HB Mag | 228d | 2012-10-01 | 2013-08-30 | 143118P3LOE5 | 20d |  |
| 14311950 |  | Re-Baseline Actuals Adjustment | 1d | 2013-08-30 | 2013-08-30 | 9-130M FS+227d | 20d |  |
| 24311072 |  | HB Site Inspections FY13 | 20d | 2013-09-03 | 2013-09-30 | 9-130M FS+228d | 368d |  |
| 24311110 |  | Vend Fab HB Magnet Peg Point #10 Weld back He Vessel Plate; Shield Preassembly; Fab Vac Wall Parts | 43d | 2013-09-03 | 2013-10-31 | 9-130M FS+228d | 49d |  |
| 24311115 |  | Vend Fab HB Magnet Peg Point #11 Close He Vessel; Preassemble Cryostat Vac Wall | 62d | 2013-09-03 | 2013-11-27 | 24311110 FS-43d | 49d |  |
| 24311120 |  | Vend Fab HB Magnet Peg Point #12 NDT & Warm Testing; Assemble Shield to He Vessel | 77d | 2013-09-03 | 2013-12-20 | 24311115 FS-62d | 49d |  |
| 24311125 |  | Vend Fab HB Magnet Peg Point #13 Shield Support Assy, Instrumentation & Insulation | 77d | 2013-09-03 | 2013-12-20 | 24311120 FS-77d | 49d |  |
| 24311130 |  | Vend Fab HB Magnet Peg Point #14 Suspend He Vessel/Shield; Complete Vac. Walls 2,3 | 98d | 2013-09-03 | 2014-01-31 | 24311125 FS-77d | 49d |  |
| 24311135 |  | Vend Fab HB Magnet Peg Point #15 Finish Vac Wall & Support Links | 118d | 2013-09-03 | 2014-02-28 | 24311130 FS-98d | 49d |  |
| 24311140 |  | Vend Fab HB Magnet Peg Point #16 Finish & Leak Check Cryo Header | 139d | 2013-09-03 | 2014-03-31 | 24311135 FS-118d | 49d |  |
| 24311145 |  | Vend Fab HB Magnet Peg Point #17 Assemble CCR to Magnet | 161d | 2013-09-03 | 2014-04-30 | 24311140 FS-139d | 49d |  |
| 243118P4LOE |  | HB Contract Mngmnt for HB Mag | 20d | 2013-09-03 | 2013-09-30 | 9-130M FS+228d | 683d |  |
| 24311072a |  | HB Site Inspections FY14 | 183d | 2013-10-01 | 2014-06-30 | 24311072 | 368d |  |
| 243118P5LOE |  | HB Contract Mngmnt for HB Mag | 247d | 2013-10-01 | 2014-09-30 | 243118P4LOE | 683d |  |
| 24311150 |  | Vend Fab HB Magnet Peg Point #18 Connect Leads, Instr. He Vessel, Leak Check Cryo, Finish Shield Conn. | 139d | 2013-11-01 | 2014-05-30 | 24311145 FS-118d | 49d |  |
| 24311155 |  | Vend Fab HB Magnet Peg Point #19 Finish Insul & Vac; Leak Check; Fab shipping structure | 160d | 2013-11-01 | 2014-06-30 | 24311150 FS-139d | 49d |  |
| 24311160 |  | Vend Fab HB Magnet Peg Point #20 Crate & Deliver HB Magnet to JLab | 182d | 2013-11-01 | 2014-07-31 | 24311155 FS-160d | 49d |  |
| 24311165 |  | Vend Fab HB Magnet Peg Point #21 Aceptance, Setup, Testing, and Mapping at JLab | 224d | 2013-11-01 | 2014-09-30 | 24311160 FS-182d | 304d |  |
| 24311168 |  | Vend Fab HB Magnet Contract Closeout | 128d | 2014-04-01 | 2014-09-30 | 24311165 FS-128d | 304d |  |
| 24311170 |  | HB- Factory Mag Test of HB Mag | 41d | 2014-05-02 | 2014-06-30 | 24311120 FS+85d | 368d |  |
| 24311071 |  | HB Drawing Validation | 100d | 2014-08-01 | 2014-12-23 | 24311160 | 246d |  |
| 24311077 |  | Finducialize Magnet CL of SHMS HB Magnet | 1d | 2014-10-01 | 2014-10-01 | 28231000 | 323d |  |
| 243118P6LOE |  | HB Contract Mngmnt for HB Mag | 59d | 2014-10-01 | 2015-01-05 | 243118P5LOE | 683d |  |
|  | 2 | **1.4.3.1.2 Q-1 QUADRUPOLE** |  | 2009-01-02 | 2015-12-22 |  |  |  |
| 14312909LOE |  | Q1- FY09 Proj Mngmnt H-C upgrade | 189d | 2009-01-02 | 2009-09-30 | 14312909LOEX | 20d |  |
| 14312000M |  | Q1- Award Contract for Q1 | 0d | 2009-03-16 | 2009-03-16 | 9-090M, 122311056 | 0d | mandatory start 2009-03-16 |
| 14312002 |  | Q1- Contractor Expenses (Frozen and Reversed by Activity 14312011 per CR 09-041) | 20d | 2009-03-16 | 2009-04-10 | 9-090M FS+108d | 120d |  |
| 14312010 |  | Q1- Finalize Dsgn of Q1 First Phase (Frozen and Reversed by Activity 14312011 per CR 09-041) | 33.25d | 2009-03-16 | 2009-04-30 | 9-090M FS+108d | 106.75d |  |
| 143128P1LOE |  | Q1- P-1 Contract Mngmnt for Q1 | 140d | 2009-03-16 | 2009-09-30 | 14312909LOEX FS+49d | 573d |  |
| 14312010a |  | Q1- Finalize Dsgn of Q1 " Final Phase" (Frozen and Reversed by Activity 14312011 per CR 09-041) | 32d | 2009-06-17 | 2009-07-31 | 9-090M FS+174d | 42d |  |
| 14312011 |  | Reverse Entry for Activities 14312002, 14312010 and 14312010a per CR 09-041 | 1d | 2009-08-03 | 2009-08-03 | 9-090M FS+206d | 41d |  |
| 14312015 |  | Vend Fab Q1 Procure Materials | 10d | 2009-08-03 | 2009-08-14 | 9-090M FS+206d | 1023d |  |
| 14312020 |  | Vend Fab Q1 Completion of Magnetic and Stress Analysis | 130d | 2009-08-03 | 2010-02-12 | 9-090M FS+206d | 903d |  |
| 14312025 |  | Vend Fab Q1 Completion of Trial Wind | 150d | 2009-08-03 | 2010-03-15 | 9-090M FS+206d | 883d |  |
| 14312032 |  | Vend Fab Q1 Completion of Preliminary Design Review | 235d | 2009-08-03 | 2010-07-14 | 9-090M FS+206d | 798d |  |
| 14312036 |  | Vend Fab Q1 Completion of Cold Mass Components (Frozen Per CR12-003) | 431d | 2009-08-03 | 2011-04-29 | 9-090M FS+206d | 602d |  |
| 14312040 |  | Vend Fab Q1 Completion of Cold Mass Assembly (Frozen Per CR12-003) | 494d | 2009-08-03 | 2011-07-29 | 9-090M FS+206d | 500d |  |
| 14312041 |  | Vend Fab Q1 Warm Testing Complete (Frozen Per CR12-003) | 517d | 2009-08-03 | 2011-08-31 | 9-090M FS+206d | 511d |  |
| 14312042 |  | Vend Fab Q1 Completion of Final Design Review | 410d | 2009-08-03 | 2011-03-31 | 9-090M FS+206d | 623d |  |
| 14312045 |  | Vend Fab Q1 Completion of Cryostat Components (Frozen Per CR12-003) | 474d | 2009-08-03 | 2011-06-30 | 9-090M FS+206d | 559d |  |
| 14312046 |  | Vend Fab Q1 Completion of Cryostat Assembly | 884d | 2009-08-03 | 2013-02-28 | 14315031M FS-658d, 14312045a FS-936d, 9-090M FS+206d | 20d |  |
| 14312047 |  | Vend Fab Q1 Completion of Magnet Assembly | 927d | 2009-08-03 | 2013-04-30 | 14312046 FS-884d | 20d |  |
| 14312048 |  | Vend Fab Q1 Completion of Factory Tests by Vendor | 969d | 2009-08-03 | 2013-06-28 | 14312047 FS-927d, 14315038 FS-743d | 20d |  |
| 14312050 |  | Vend Fab Q1 Magnet System Delivery | 991d | 2009-08-03 | 2013-07-31 | 14312048 FS-969d | 20d |  |
| 143128P2LOE |  | Q1- P-2 Contract Mngmnt for Q1 | 248d | 2009-10-01 | 2010-09-30 | 143128P1LOE | 573d |  |
| 14312910LOE |  | Q1- FY10 Proj Mngmnt H-C upgrade | 248d | 2009-10-01 | 2010-09-30 | 14312909LOE | 20d |  |
| 143128P3LOE |  | Q1- P-3 Contract Mngmnt for Q1 | 248d | 2010-10-01 | 2011-09-30 | 143128P2LOE | 573d |  |
| 14312911LOE |  | Q1- FY11 Proj Mngmnt H-C upgrade | 248d | 2010-10-01 | 2011-09-30 | 14312910LOE | 20d |  |
| 14312052M |  | Factory Low Current Mag Test of Q1 Complete | 0d | 2011-08-31 | 2011-08-31 | 14312040, 14312041 | 511d |  |
| 14312005 |  | Q1- Final Dsgn Review | 5d | 2011-09-19 | 2011-09-23 | 14312052M, 14312040 FS+34d | 500d |  |

| ID | WBS | Task | Duration | Start | Finish | Predecessors | Total float | Constraint |
| --- | --- | --- | --- | --- | --- | --- | --- | --- |
| 143128P4LOE |  | Q1- P-4 Contract Mngmnt for Q1 | 247d | 2011-10-03 | 2012-09-28 | 143128P3LOE | 573d |  |
| 14312912LOE |  | Q1- FY12 Proj Mngmnt H-C upgrade | 247d | 2011-10-03 | 2012-09-28 | 14312911LOE | 20d |  |
| 14312034 |  | Reverse Entry for activities 14312036,14312040,14312041 and 14312045 per CR12-003) | 5d | 2011-11-01 | 2011-11-07 | 9-120M FS+21d | 221d |  |
| 14312038 |  | Vend Fab Q1 Completion of Cold Mass Components (Revised Per CR12-003) | 37d | 2011-11-01 | 2011-12-30 | 9-120M FS+21d | 255d |  |
| 14312040a |  | Vend Fab Q1 Completion of Cold Mass Assembly (Revised Per CR12-003) | 142d | 2011-11-01 | 2012-05-31 | 14312038 FS-37d | 255d |  |
| 14312040d |  | Vend Fab Q1 Completion of Cold Mass Testing | 226d | 2011-11-01 | 2012-09-28 | 14312040a FS-142d | 255d |  |
| 14312041a |  | Vend Fab Q1 Warm Testing Complete (Revised Per CR12-003) | 162d | 2011-11-01 | 2012-06-29 | 14312040d FS-226d | 255d |  |
| 14312045a |  | Vend Fab Q1 Completion of Cryostat Components (Revised Per CR12-003) | 142d | 2011-11-01 | 2012-05-31 | 14312041a FS-162d | 255d |  |
| 14312050c |  | Vend Fab Q1 Magnet Acceptance | 422d | 2011-12-19 | 2013-08-30 | 14312050 FS-400d | 20d |  |
| 143128P5LOE |  | Q1- P-5 Contract Mngmnt for Q1 | 228d | 2012-10-01 | 2013-08-30 | 143128P4LOE | 573d |  |
| 14312913LOE |  | Q1- FY13 Proj Mngmnt H-C upgrade | 228d | 2012-10-01 | 2013-08-30 | 14312912LOE | 20d |  |
| 143128P5TLOE |  | Q1- P-5 Extra Travel for Q1 Contract Mgmt | 169d | 2013-01-02 | 2013-08-30 | 143128P5LOE FS-169d | 573d |  |
| 143128PC13LOE |  | Q1- Contract Oversight Consultant FY13 | 169d | 2013-01-02 | 2013-08-30 | 9-130M FS+59d | 573d |  |
| 14312950 |  | Re-Baseline Actuals Adjustment | 1d | 2013-08-30 | 2013-08-30 | 9-130M FS+227d | 20d |  |
| 24312040d |  | Vend Fab Q1 Completion of Cold Mass Testing | 98d | 2013-09-03 | 2014-01-31 | 9-130M FS+228d | 472d |  |
| 24312041a |  | Vend Fab Q1 Warm Testing Complete | 98d | 2013-09-03 | 2014-01-31 | 24312040d FS-98d | 472d |  |
| 24312046 |  | Vend Fab Q1 Completion of Cryostat Assembly | 161d | 2013-09-03 | 2014-04-30 | 9-130M FS+228d | 87d |  |
| 24312047 |  | Vend Fab Q1 Completion of Magnet Assembly | 182d | 2013-09-03 | 2014-05-30 | 24312046 FS-161d | 87d |  |
| 24312048 |  | Vend Fab Q1 Completion of Factory Tests by Vendor | 203d | 2013-09-03 | 2014-06-30 | 24312047 FS-182d | 87d |  |
| 24312050 |  | Vend Fab Q1 Magnet System Delivery | 203d | 2013-09-03 | 2014-06-30 | 24312048 FS-203d | 87d |  |
| 24312050c |  | Vend Fab Q1 Magnet Acceptance | 246d | 2013-09-03 | 2014-08-29 | 24312050 FS-203d | 271d |  |
| 24312060 |  | Q1 Schedule Acceleration Incentives | 203d | 2013-09-03 | 2014-06-30 | 9-130M FS+228d | 367d |  |
| 243128P5LOE |  | Q1- P-5 Contract Mngmnt for Q1 | 20d | 2013-09-03 | 2013-09-30 | 9-130M FS+228d | 249d |  |
| 243128P5TLOE |  | Q1- P-5 Extra Travel for Q1 Contract Mgmt | 20d | 2013-09-03 | 2013-09-30 | 243128P5LOE FS-20d | 249d |  |
| 243128PC13LOE |  | Q1- Contract Oversight Consultant | 98d | 2013-09-03 | 2014-01-31 | 9-130M FS+228d | 784d |  |
| 24312913LOE |  | Q1- FY13 Proj Mngmnt H-C upgrade | 20d | 2013-09-03 | 2013-09-30 | 9-130M FS+228d | 439d |  |
| 243128P6LOE |  | Q1- P-6 Contract Mngmnt for Q1 | 247d | 2013-10-01 | 2014-09-30 | 243128P5TLOE | 249d |  |
| 24312914LOE |  | Q1- FY14 Proj Mngmnt H-C upgrade | 247d | 2013-10-01 | 2014-09-30 | 24312913LOE | 439d |  |
| 243128PC13LOE5 |  | Q1- Contract Oversight Consultant | 127d | 2014-02-03 | 2014-07-31 | 243128PC13LOE, 9-130M FS+228d | 784d |  |
| 24312052M |  | Factory Low Current Mag Test of Q1 Complete | 0d | 2014-06-30 | 2014-06-30 | 24312041a, 24312048 | 367d |  |
| 24312053M |  | Q1 Delivered to JLab | 0d | 2014-06-30 | 2014-06-30 | 24312050, 24312047, 24312048, 24312046 FS-18d | 87d |  |
| 24312050d |  | Q1 Drawing Validation | 100d | 2014-07-01 | 2014-11-19 | 24312050, 24312053M | 268d |  |
| 24312051M |  | Q1 Acceptance Test Complete | 0d | 2014-08-25 | 2014-08-25 | 28231005 | 294d |  |
| 24312055 |  | Pay Profit on Q1 | 1d | 2014-08-26 | 2014-08-26 | 24312060, 24312051M, 24312050, 24312052M | 328d |  |
| 243128P6LOE5 |  | Q1- P-7 Contract Mngmnt for Q1 | 55d | 2014-10-01 | 2014-12-18 | 243128P6LOE, 243128P5TLOE | 249d |  |
| 24312915LOE |  | Q1- FY15 Proj Mngmnt H-C upgrade | 246d | 2014-10-01 | 2015-09-30 | 24312914LOE | 439d |  |
| 24312915LOE5 |  | Q1- FY16 Proj Mngmnt H-C upgrade | 57d | 2015-10-01 | 2015-12-22 | 24312915LOE, 24312914LOE | 439d |  |
|  | 3 | **1.4.3.1.3 Q2-3 QUADRUPOLE** |  | 2009-12-14 | 2016-02-03 |  |  |  |
| 14313P1LOE |  | Q2&3- P-1 Contract Mngmnt for Q2-3 | 198d | 2009-12-14 | 2010-09-30 | 9-100M FS+50d | 20d |  |
| 14313P2LOE |  | Q2&3- P-2 Contract Mngmnt for Q2-3 | 248d | 2010-10-01 | 2011-09-30 | 14313P1LOE | 20d |  |
| 14313000M |  | Q2&3- Award Contract for SHMS Q2/Q3 quadrupoles | 0d | 2010-10-18 | 2010-10-18 | 9-090M FS+60d, 122312070 | 0d | mandatory start 2010-10-18 |
| 14313002 |  | Q2&3- Contractor Expenses | 20d | 2010-10-18 | 2010-11-12 | 14313000M | 433d |  |
| 14313005 |  | Q2&3- Finalize Dsgn for Q2/Q3 Mags Original Expenses | 10d | 2010-11-15 | 2010-11-30 | 14313000M, 14313002, 14313002a FS-40d | 433d |  |
| 14313002a |  | Reverse Entry per CR 11-017 | 5d | 2010-12-01 | 2010-12-07 | 14313000M FS+30d | 458d |  |
| 14313006 |  | Vend Fab Q2&3 Peg Point #1 Intermediate Design Review | 139d | 2010-12-07 | 2011-06-30 | 14313000M FS+34d | 354d |  |
| 14313010 |  | Vend Fab Q2&3 Peg Point #2a Final Design Review | 261d | 2010-12-07 | 2011-12-30 | 14313006 FS-139d, 14313020 FS-139d | 354d |  |
| 14313015 |  | Vend Fab Q2&3 Peg Point #2b Final Design Review | 186d | 2011-04-01 | 2011-12-30 | 14313005, 14313010 FS-186d | 354d |  |
| 14313017 |  | Vend Fab Q2&3 Peg Point #3 Cryostat Component Complete | 269d | 2011-04-01 | 2012-04-30 | 14315029 FS-225d, 14313030 FS-186d, 14313015 FS-186d | 354d |  |
| 14313018 |  | Vend Fab Q2&3 Peg Point #4a Cold Mass Fiducialitzation | 375d | 2011-04-01 | 2012-09-28 | 14315027, 14313017 FS-269d | 518d |  |
| 14313020 |  | PDR/IDR Site Inspection | 20d | 2011-06-03 | 2011-06-30 | 14313006 FS-20d | 354d |  |
| 14313P3LOE |  | Q2&3- P-3 Contract Mngmnt for Q2-3 | 247d | 2011-10-03 | 2012-09-28 | 14313P2LOE | 20d |  |
| 14313030 |  | FDR Site Inspection | 20d | 2011-11-28 | 2011-12-30 | 14313015 FS-20d | 354d |  |
| 14313019 |  | Vend Fab Q2&3 Peg Point #4b Cold Mass Fiducialitzation | 127d | 2012-04-02 | 2012-09-28 | 14313018 FS-127d | 518d |  |
| 14313019a |  | Vend Fab Q2&3 Peg Point #5 Shipment | 333d | 2012-04-02 | 2013-07-31 | 14313019 FS-127d | 518d |  |
| 14313220 |  | Q2 and Q3 Coil Inspection | 20d | 2012-04-03 | 2012-04-30 | 14313017 FS-20d | 354d |  |
| 14313P4LOE |  | Q2&3- P-4 Contract Mngmnt for Q2-3 | 228d | 2012-10-01 | 2013-08-30 | 14313P3LOE | 20d |  |
| 14313280 |  | Re-Baseline Actuals Adjustment | 1d | 2013-08-30 | 2013-08-30 | 9-130M FS+227d | 20d |  |
| 24313015 |  | Vend Fab Q2&3 Peg Point #2 Final Design Review | 43d | 2013-09-03 | 2013-10-31 | 9-130M FS+228d | 1d |  |
| 24313017 |  | Vend Fab Q2&3 Peg Point #3 Cryostat Component Complete | 408d | 2013-09-03 | 2015-04-30 | 24313015 FS-43d, 24313030a FS-186d, 24313030 FS-186d | 1d |  |
| 24313019 |  | Vend Fab Q2&3 Peg Point #4 Cold Mass Fiducialitzation | 449d | 2013-09-03 | 2015-06-30 | 24313017 FS-408d | 6d |  |
| 24313019a |  | Vend Fab Q2&3 Peg Point #5 Shipment | 513d | 2013-09-03 | 2015-09-30 | 24313019 FS-449d | 6d |  |
| 24313019b |  | Vend Fab Q2&3 Peg Point #6 Final Acceptance | 571d | 2013-09-03 | 2015-12-23 | 24313235 FS-679d, 24313019a FS-513d | 64d |  |
| 24313280 |  | Planning Package SigmaPhi Quads (second winding station) | 161d | 2013-09-03 | 2014-04-30 | 9-130M FS+228d | 460d |  |
| 24313P4LOE |  | Q2&3- P-4 Contract Mngmnt for Q2-3 | 20d | 2013-09-03 | 2013-09-30 | 9-130M FS+228d | 354d |  |
| 24313030 |  | FDR Site Inspection FY13 | 17d | 2013-09-06 | 2013-09-30 | 24313015 FS-40d | 164d |  |
| 24313030a |  | FDR Site Inspection FY14 | 3d | 2013-10-01 | 2013-10-03 | 24313015 FS-40d, 24313030 | 164d |  |
| 24313P5LOE |  | Q2&3- P-5 Contract Mngmnt for Q2-3 | 247d | 2013-10-01 | 2014-09-30 | 24313P4LOE | 354d |  |
| 24313P6LOE |  | Q2&3- P-6 Contract Mngmnt for Q2-3 | 247d | 2014-10-01 | 2015-10-01 | 24313P5LOE | 439d |  |
| 24313220 |  | Q2 and Q3 Coil Inspection | 49d | 2014-10-27 | 2015-01-15 | 24313017 FS-123d | 287d |  |
| 24313230 |  | Q2 and Q3- Insp Cold Mass | 6d | 2014-12-22 | 2015-01-08 | 24313019 FS-126d, 2-30M FS-240d | 292d |  |

| ID | WBS | Task | Duration | Start | Finish | Predecessors | Total float | Constraint |
| --- | --- | --- | --- | --- | --- | --- | --- | --- |
| 24313235 |  | Q2 and Q3 witness Pressure Tests | 36d | 2015-05-08 | 2015-06-30 | 24313019a FS-100d, 2-31M FS-100d, 2-30M FS-40d | 294d |  |
| 24313275 |  | Q2&Q3 Drawing Validation | 100d | 2015-09-02 | 2016-02-03 | 24313019a FS-20d, 2-31M FS-20d, 2-30M | 28d |  |
| 24313P6LOE5 |  | Q2&3- P-7 Contract Mngmnt for Q2-3 | 56d | 2015-10-02 | 2015-12-22 | 24313P6LOE, 24313P5LOE | 439d |  |
| 24313270M |  | Q2 and Q3 Contract complete | 0d | 2016-02-03 | 2016-02-03 | 28236010, 24313280, 24313019b FS-14d, 28236020, 24313275, 24313230, 24313220, 24313P5LOE | 28d |  |
|  | 4 | **1.4.3.1.4 DIPOLE** |  | 2009-12-14 | 2015-10-01 |  |  |  |
| 14314P1LOE |  | Dipole- P-1 Contract Mngmnt for Dipole | 198d | 2009-12-14 | 2010-09-30 | 9-100M FS+50d | 573d |  |
| 14314000M5 |  | Dipole- Award Contract for SHMS Dipole Mag | 0d | 2010-08-02 | 2010-08-02 | 9-090M FS+63d, 122312070 | 0d | mandatory start 2010-08-02 |
| 14314002 |  | Dipole- Finalize Dsgn for Dipole Mag (Original Expenses) | 22d | 2010-08-02 | 2010-08-31 | 14314000M5 | 139d |  |
| 14314003 |  | Dipole- Contractor Expenses | 20d | 2010-08-02 | 2010-08-27 | 14314000M5 | 119d |  |
| 14314003a |  | Dipole Contractor Expenses - Reverse Entry | 1d | 2010-09-30 | 2010-09-30 | 14314003 FS+22d | 119d |  |
| 14314004 |  | Vend Fab Dipole Intermediate Design Review Peg Point #1 | 163d | 2010-09-30 | 2011-05-31 | 9-110M FS-1d, 14314003, 14314002, 14314003a FS-1d | 119d |  |
| 14314010 |  | Vend Fab Dipole Coil Tooling Delivered Peg Point #2 | 249d | 2010-09-30 | 2011-09-30 | 14314004 FS-163d, 14314036 FS-163d | 119d |  |
| 14314012 |  | Vend Fab Dipole Final Design Review Peg Point #3 | 269d | 2010-09-30 | 2011-10-28 | 14314010 FS-249d, 14315020 FS-182d | 119d |  |
| 14314015 |  | Vend Fab Dipole Second Coil Wind Peg Point #4a | 369d | 2010-09-30 | 2012-03-30 | 14314045 FS-269d, 14314012 FS-269d | 119d |  |
| 14314P2LOE |  | Dipole- P-2 Contract Mngmnt for Dipole | 248d | 2010-10-01 | 2011-09-30 | 14314P1LOE | 573d |  |
| 14314020 |  | Vend Fab Dipole Second Coil Wind Peg Point #4b | 248d | 2011-04-01 | 2012-03-30 | 9-110M FS+120d, 14314015 FS-248d | 119d |  |
| 14314025 |  | Vend Fab Dipole Outer Vessel Completed Peg Point #5a | 291d | 2011-04-01 | 2012-05-31 | 14314047 FS-487d, 14314020 FS-248d | 119d |  |
| 14314036 |  | Dipole- Intermediate Design Review | 20d | 2011-05-03 | 2011-05-31 | 14314004 FS-20d | 119d |  |
| 14314045 |  | Dipole- Final Design Review | 20d | 2011-10-03 | 2011-10-28 | 14314012 FS-20d | 119d |  |
| 14314P3LOE |  | Dipole- P-3 Contract Mngmnt for Dipole | 247d | 2011-10-03 | 2012-09-28 | 14314P2LOE | 573d |  |
| 14314047 |  | Dipole Inspect Coil | 20d | 2012-03-05 | 2012-03-30 | 14314020 FS-20d | 358d |  |
| 14314027 |  | Vend Fab Dipole Outer Vessel Completed Peg Point #5b | 43d | 2012-04-02 | 2012-05-31 | 14314020 FS-20d, 14314047 FS-245d, 14314025 FS-43d, 9-120M FS+120d | 119d |  |
| 14314030 |  | Vend Fab Dipole Factory Test Completed Peg Point #6 | 226d | 2012-04-02 | 2013-02-28 | 14314027 FS-43d | 119d |  |
| 14314P4LOE |  | Dipole- P-4 Contract Mngmnt for Dipole | 228d | 2012-10-01 | 2013-08-30 | 14314P3LOE | 573d |  |
| 14314100 |  | Planning Package SigmaPhi Phase 1 (Coil Developement) | 61d | 2013-01-02 | 2013-03-29 | 9-130M FS+59d | 128d |  |
| 14314P4TLOE |  | Dipole- P-4 Contract Extra Travel | 169d | 2013-01-02 | 2013-08-30 | 14314P4LOE FS-169d | 573d |  |
| 14314030a |  | Dipole Magnet Shipping | 30d | 2013-03-01 | 2013-04-11 | 14314030 | 119d |  |
| 14314115 |  | Re-Baseline Actuals Adjustment | 1d | 2013-08-30 | 2013-08-30 | 9-130M FS+227d | 20d |  |
| 24314012 |  | Vend Fab Dipole Final Design Review Peg Point #3 | 43d | 2013-09-03 | 2013-10-31 | 9-130M FS+228d | 0d |  |
| 24314020 |  | Vend Fab Dipole Second Coil Wind Peg Point #4 | 139d | 2013-09-03 | 2014-03-31 | 24314012 FS-43d | 0d |  |
| 24314027 |  | Vend Fab Dipole Outer Vessel Completed Peg Point #5 (F-12) | 267d | 2013-09-03 | 2014-09-30 | 24314047 FS-245d, 24314020 FS-139d | 0d |  |
| 24314028 |  | Vend Fab Dipole 4K Testing Peg Point #5a | 77d | 2013-09-03 | 2013-12-20 | 24314027 FS-267d | 0d |  |
| 24314030 |  | Vend Fab Dipole Factory Test Completed Peg Point #6 | 386d | 2013-09-03 | 2015-03-31 | 24314027 FS-267d, 24314028 FS-77d | 0d |  |
| 24314035 |  | Vend Fab Dipole Magnet Accepted Peg Point #7 | 492d | 2013-09-03 | 2015-08-31 | 24314030 FS-386d | 1d |  |
| 24314P4LOE |  | Dipole- P-4 Contract Mngmnt for Dipole | 20d | 2013-09-03 | 2013-09-30 | 9-130M FS+228d | 495d |  |
| 24314P4TLOE |  | Dipole- P-4 Contract Extra Travel | 20d | 2013-09-03 | 2013-09-30 | 24314P4LOE FS-20d | 495d |  |
| 24314110 |  | Planning Package SigmaPhi Phase 2 ( Coil Development, VPI ) | 128d | 2013-10-01 | 2014-04-11 | 9-140M | 861d |  |
| 24314P5LOE |  | Dipole- P-5 Contract Mngmnt for Dipole | 247d | 2013-10-01 | 2014-09-30 | 24314P4TLOE | 495d |  |
| 24314047 |  | Dipole Inspect Coil | 20d | 2014-03-04 | 2014-03-31 | 24314020 FS-20d | 106d |  |
| 24314048 |  | Dipole Inspect Cold Mass | 20d | 2014-09-17 | 2014-10-14 | 24314027 FS-10d, 2-29M FS-290d | 205d |  |
| 24314P6LOE |  | Dipole- P-6 Contract Mngmnt for Dipole | 247d | 2014-10-01 | 2015-10-01 | 24314P5LOE, 24314P4TLOE | 495d |  |
| 24314049 |  | Dipole Witness Final Factory Tests | 40d | 2015-02-04 | 2015-03-31 | 2-29M FS-90d, 24314030 FS-40d | 185d |  |
| 24314030a |  | Dipole Magnet Shipping | 54d | 2015-03-04 | 2015-05-18 | 24314030 FS-20d | 0d |  |
| 24314040 |  | Dipole Drawing Validation | 89d | 2015-05-19 | 2015-09-24 | 24314048, 2-29M | 62d |  |
| 24314050M |  | Dipole Ready for Installation | 0d | 2015-05-19 | 2015-05-19 | 2-29M | 0d |  |
| 24314035a |  | Dipole HC Test | 5d | 2015-08-26 | 2015-09-01 | 28236000, 28236005 FS-5d, 24368305 | 0d |  |
| 24314051M |  | Dipole Contract Complete | 0d | 2015-09-25 | 2015-09-25 | 24314040, 24314049 | 62d |  |
|  | 5 | **1.4.3.1.5 MAGNET COMPONENTS PROCURED BY JLAB** |  | 2009-01-02 | 2014-08-25 |  |  |  |
| 14315010 |  | Design Superconductor for Q2/3 and Dipole | 20d | 2009-01-02 | 2009-01-30 | 9-090M FS+59d | 1093d |  |
| 14315042 |  | Bidding Process Iron Yoke for Q2/3 and Dipole | 80d | 2009-03-05 | 2009-06-25 | 14315055x | 692d |  |
| 14315050LOE |  | Procurement Oversight | 106d | 2009-05-01 | 2009-09-30 | 9-090M FS+142d, 14315010 FS-20d | 1010d |  |
| 14315022 |  | Bidding Process Cryo Reservoirs for All Mag | 50d | 2009-05-26 | 2009-08-04 | 14315050x FS+37d | 346d |  |
| 14315012 |  | Bidding Process Superconductor for Q2/3 and Dipole | 40d | 2009-06-10 | 2009-08-05 | 9-090M FS+169d | 300d |  |
| 14315030 |  | Design Instruments & Controls for All Mag FY09 | 63d | 2009-07-02 | 2009-09-30 | 9-090M FS+185d | 251d |  |
| 14315030b |  | Design Instruments & Controls for All Mag FY10 | 157d | 2009-10-01 | 2010-05-21 | 14315030 | 251d |  |
| 14315050LOEb |  | Procurement Oversight | 248d | 2009-10-01 | 2010-09-30 | 14315050LOE | 1010d |  |
| 14315000 |  | Design DC Pwr Sys for All Mag (IPL) | 20d | 2009-12-15 | 2010-01-20 | 9-100M FS+51d | 101d |  |
| 14315025 |  | Vend Fab Cryo Reservoirs Receipt of Materials less Electric Cylinders and LVDTs | 19d | 2010-01-04 | 2010-01-29 | 9-100M FS+59d, 14315022 | 247d |  |
| 14315026 |  | Vend Fab Cryo Reservoirs Receipt of Electric Cylinders and LVDTs | 61d | 2010-01-04 | 2010-03-31 | 14315025 FS-19d | 247d |  |
| 14315027 |  | Vend Fab Cryo Reservoirs CCR#2 & 3 JT Valves and Bayonets Complete | 168d | 2010-01-04 | 2010-08-31 | 14315055 FS-125d, 14315026 FS-61d | 247d |  |
| 14315027A |  | Vend Fab Cryo Reservoirs CCR#2 & 3 Complete | 247d | 2010-01-04 | 2010-12-30 | 14315027 FS-168d | 247d |  |
| 14315027B |  | Vend Fab Cryo Reservoirs CCR#2 & 3 Approved Acceptance Test/Shipment | 267d | 2010-01-04 | 2011-01-31 | 14315027A FS-247d | 247d |  |
| 14315027C |  | Vend Fab Cryo Reservoirs CCR#1 Test and Fabrication Documentation | 286d | 2010-01-04 | 2011-02-28 | 14315027B FS-267d | 354d |  |
| 14315027D |  | Vend Fab Cryo Reservoirs CCR#4 5 & 6 JT Valves and Bayonets Complete | 168d | 2010-01-04 | 2010-08-31 | 14315027C FS-286d | 354d |  |
| 14315027F |  | Vend Fab Cryo Reservoirs CCR#4 5 & 6 Complete | 458d | 2010-01-04 | 2011-10-31 | 14315027D FS-168d | 354d |  |
| 14315027G |  | Vend Fab Cryo Reservoirs CCR#4 5 & 6 Approved Acceptance Test/Shipment | 494d | 2010-01-04 | 2011-12-29 | 14315027F FS-458d | 354d |  |
| 14315027H |  | Vend Fab Cryo Reservoirs CCR#4 5 & 6 Test and Fabrication Documentation | 515d | 2010-01-04 | 2012-01-31 | 14315027G FS-494d | 354d |  |
| 14315015 |  | Procure and Extrude Copper Stabilizer | 162d | 2010-05-03 | 2010-12-21 | 14314000M5 FS-63d, 14315012 | 119d |  |
| 14315055 |  | Procure Burnout Resistant Current Leads | 20d | 2010-05-03 | 2010-05-28 | 9-100M FS+142d | 269d |  |
| 14315032 |  | Bidding Process Instruments & Controls for All Mag | 5d | 2010-05-24 | 2010-05-28 | 14315030b | 251d |  |

| ID | WBS | Task | Duration | Start | Finish | Predecessors | Total float |
| --- | --- | --- | --- | --- | --- | --- | --- |
| 14315035 |  | Proc Instruments & Controls for HB and Q1 magnets | 130d | 2010-06-01 | 2010-12-03 | 14315032 | 251d |
| 14315015A |  | Solder SC Cable to Extrusion | 113d | 2010-08-06 | 2011-01-25 | 14315015 FS-95d | 129d |
| 14315015B |  | Obtain RRR Measurement of Copper Part A | 113d | 2010-08-06 | 2011-01-25 | 14315015 FS-95d | 119d |
| 14315015Ba |  | Obtain RRR Measurement of Copper Part B | 113d | 2010-08-06 | 2011-01-25 | 14315015 FS-95d | 119d |
| 14315002 |  | Bidding Process DC Pwr Sys for HB & Q1 Mag | 80d | 2010-08-30 | 2010-12-29 | 14315000 FS+154d | 101d |
| 14315003 |  | Bidding Process DC Pwr Sys forQ2/Q3/Dipole Mag | 80d | 2010-08-30 | 2010-12-29 | 14315000 FS+154d | 101d |
| 14315027J |  | Vend Fab Cryo Reservoirs CCR#4 5 & 6 Vendor Change Order | 1d | 2010-09-01 | 2010-09-01 | 14315027D | 700d |
| 14315060 |  | Vend Fab DCPS - Design & Approval | 98d | 2010-09-30 | 2011-02-28 | 14315002 FS-58d, 14315003 FS-58d | 101d |
| 14315065 |  | Vend Fab DCPS - Materials in-house to start prod: Items 1&2 | 142d | 2010-09-30 | 2011-04-29 | 14315060 FS-98d | 101d |
| 14315070 |  | Vend Fab DCPS - Materials in-house to start prod: Items 3,4,&5 | 290d | 2010-09-30 | 2011-11-30 | 14315065 FS-142d | 101d |
| 14315075 |  | Vend Fab DCPS - Shipment of Items 1&2 | 347d | 2010-09-30 | 2012-02-29 | 14315070 FS-290d | 101d |
| 14315080 |  | Vend Fab DCPS - Arrival Test of Items 1&2 | 412d | 2010-09-30 | 2012-05-31 | 14315075 FS-347d | 101d |
| 14315085 |  | Vend Fab DCPS - Shipment of Items 3,4,&5 | 518d | 2010-09-30 | 2012-10-30 | 14315080 FS-412d | 101d |
| 14315090 |  | Vend Fab DCPS - Arrival Test of Items 3,4,&5 | 616d | 2010-09-30 | 2013-03-29 | 14315085 FS-518d | 683d |
| 14315095 |  | Vend Fab DCPS -Delivery of Spare Parts & Maintenance Inventory | 616d | 2010-09-30 | 2013-03-29 | 14315090 FS-616d | 683d |
| 14315050LOEc |  | Procurement Oversight | 247d | 2010-10-01 | 2011-09-29 | 14315050LOEb | 1010d |
| 14315038 |  | Assemble & Test Instruments & Controls Phase 1 (FY10) | 100d | 2010-12-06 | 2011-05-04 | 14315035 | 251d |
| 14315016 |  | Inspect & Ship Superconductor for Q2/3 and Dipole to ReRolling Facility | 30d | 2011-01-26 | 2011-03-09 | 14315015Ba, 14315015B | 119d |
| 14315028 |  | Inspect & Ship Cryo Reservoirs for HB & Q1 magnets | 63d | 2011-02-01 | 2011-04-29 | 14315025, 14315027B | 247d |
| 14315031M |  | Q1 Magnet Vendor Receipt of Cryoresevoir | 0d | 2011-04-29 | 2011-04-29 | 14315028 | 247d |
| 14315015A5 |  | Completion of Solder SC Cable to Extrusion Part A | 10d | 2011-05-02 | 2011-05-13 | 14315015A FS+67d | 129d |
| 14315015A5a |  | Completion of Solder SC Cable to Extrusion Part B | 10d | 2011-05-02 | 2011-05-13 | 14315015A FS+67d | 129d |
| 14315018 |  | ReRoll Superconductor Prototype Run | 20d | 2011-05-02 | 2011-05-27 | 14315016 FS+37d | 119d |
| 14315037a |  | Assemble & Test Instruments & Controls Phase 2 (FY11) | 100d | 2011-05-05 | 2011-09-26 | 14315038 | 251d |
| 14315020 |  | Ship Superconductor for Q2/3 and Dipole to Magnet Vendor | 20d | 2011-05-31 | 2011-06-27 | 14315015A5a, 14315018, 14315019 FS-200d, 14315015A5, 14315019B FS-473d | 119d |
| 14315050LOEd |  | Procurement Oversight FY11 | 1d | 2011-09-30 | 2011-09-30 | 14315050LOEc | 1010d |
| 14315050LOEf |  | Procurement Oversight FY12 | 246d | 2011-10-03 | 2012-09-27 | 14315050LOEd | 1010d |
| 14315029 |  | Inspect & Ship Cryo Reservoirs for Q2/3 & Dipole magnets | 40d | 2011-12-30 | 2012-02-28 | 14315027, 14315027G, 14315027H FS-21d, 14315026, 14315027J FS-21d | 354d |
| 14315019 |  | ReDraw Superconductor Production Run | 30d | 2012-01-04 | 2012-02-15 | 9-120M FS+59d, 14315018 | 143d |
| 14315043 |  | Dipole Top and Bottom Plates | 120d | 2012-01-12 | 2012-07-03 | 9-120M FS+65d | 310d |
| 14315045 |  | Vend Fab Yoke Steel Planning for Dipole, Q2, Q3 Delivered & Accepted | 55d | 2012-01-12 | 2012-03-30 | 9-120M FS+65d, 14315042 | 64d |
| 14315045A |  | Vend Fab Yoke Steel Receipt of Steel Material Inspected | 98d | 2012-01-12 | 2012-05-31 | 14315045 FS-55d | 64d |
| 14315045B |  | Vend Fab Yoke Steel 1st Article: 1st Dipole/Yoke/Casting Inspt/Accept | 118d | 2012-01-12 | 2012-06-29 | 14315045A FS-98d | 64d |
| 14315045C |  | Vend Fab Yoke Steel SHMS Dipole Casting/ Annealing Comp. Casting Delv/Accept | 163d | 2012-01-12 | 2012-08-31 | 14315045B FS-118d | 149d |
| 14315045D |  | Vend Fab Yoke Steel SHMS Q3 Cast/Annel Comp. Cast Deliv.Accept | 205d | 2012-01-12 | 2012-10-31 | 14315045C FS-163d | 149d |
| 14315045F |  | Vend Fab Yoke Steel SHMS Q2 Cast/Annel Comp. Cast Deliv/Accept | 281d | 2012-01-12 | 2013-02-28 | 14315045D FS-205d, 14315044LOE FS-281d, 14315044LOEa FS-281d | 149d |
| 14315044LOE |  | Travel Expenses to Yoke Steel Casting Vendor FY12 | 169d | 2012-02-01 | 2012-09-28 | 14315045 FS-42d | 149d |
| 14315046a |  | Vend Fab Yoke supports and cylinders | 120d | 2012-02-03 | 2012-07-24 | 9-120M FS+80d, 14315042 | 235d |
| 14315036 |  | Proc Instruments & Controls for Q2/3 and Dipole magnets Part A | 130d | 2012-03-05 | 2012-09-05 | 9-120M FS+100d, 14315032 | 117d |
| 14315037 |  | Assemble & Test Instruments & Controls Phase 3 FY12 | 117d | 2012-04-16 | 2012-09-28 | 14315037a, 14315036 FS-100d | 117d |
| 14315046 |  | Large Magnet Yoke Machining | 238d | 2012-07-16 | 2013-06-28 | 14315045B FS+10d, 9-120M FS+45d, 14315042 | 64d |
| 14315046b |  | Procure Yoke Hardware | 60d | 2012-07-25 | 2012-10-17 | 14315046a | 235d |
| 14315037b |  | Assemble & Test Instruments & Controls Phase 3 FY13 | 131d | 2012-10-01 | 2013-04-15 | 14315037 | 117d |
| 14315044LOEa |  | Travel Expenses to Yoke Steel Casting Vendor FY13 | 99d | 2012-10-01 | 2013-02-28 | 14315044LOE, 14315045 FS-42d | 149d |
| 14315019A |  | Dimensional Inspection of Soldered Conductor at Vendor | 80d | 2013-01-02 | 2013-04-25 | 9-130M FS+59d | 119d |
| 14315019B |  | Materials to support Conductor Inspection at Vendor | 80d | 2013-01-02 | 2013-04-25 | 14315019A FS-80d | 119d |
| 14315050LOEg |  | Procurement Oversight FY13 | 169d | 2013-01-02 | 2013-08-30 | 14315050LOEf FS+60d | 1010d |
| 14315100 |  | Install Moeller Quad #2 (6GEV) | 1d | 2013-06-27 | 2013-06-27 | 14351010, 14315020 | 65d |
| 14315105 |  | Re-Baseline Actuals Adjustment | 1d | 2013-08-30 | 2013-08-30 | 9-130M FS+227d | 20d |
| 24315015Ba |  | Obtain Short-Sample SC Measurements | 98d | 2013-09-03 | 2014-01-31 | 9-130M FS+228d | 473d |
| 24315015Bb |  | Obtain RRR Measurement of Copper Part B FY13 | 20d | 2013-09-03 | 2013-09-30 | 9-130M FS+228d | 527d |
| 24315036a5 |  | Proc Instruments & Controls for Q2/3 and Dipole magnets Part B | 98d | 2013-09-03 | 2014-01-31 | 9-130M FS+228d | 287d |
| 24315037b |  | Assemble & Test Instruments & Controls Phase 3 FY13 | 20d | 2013-09-03 | 2013-09-30 | 9-130M FS+228d | 245d |
| 24315050LOEg |  | Procurement Oversight FY13 | 20d | 2013-09-03 | 2013-09-30 | 9-130M FS+228d | 989d |
| 24315080 |  | Vend Fab DCPS - Arrival Test of Items 1&2 | 62d | 2013-09-03 | 2013-11-27 | 9-130M FS+228d | 509d |
| 24315090 |  | Vend Fab DCPS - Arrival Test of Items 3,4,&5 | 62d | 2013-09-03 | 2013-11-27 | 24315080 FS-62d | 509d |
| 24315015Bba |  | Obtain RRR Measurement of Copper Part B FY14 | 24d | 2013-10-01 | 2013-11-01 | 9-130M FS+228d, 24315015Bb | 527d |
| 24315037ba |  | Assemble & Test Instruments & Controls Phase 3 FY14 | 107d | 2013-10-01 | 2014-03-13 | 9-130M FS+228d, 24315037b | 245d |
| 24315007 |  | Test & Integrate DC Pwr Sys for all magnets | 60d | 2014-06-02 | 2014-08-25 | 24368265, 24368135, 9-140M | 331d |
|  | 6 | **1.4.3.1.6 HALL C SPARE COILS** |  | 2014-10-01 | 2015-12-01 |  |  |
|  | 1 | **1.4.3.1.6.1 CONSTRUCTION HALL C SPARE COILS** |  | 2014-10-01 | 2015-12-01 |  |  |
| 243161000 |  | Vendor wind Spare Q2/Q3 Coil | 97d | 2014-10-01 | 2015-02-27 | 24313017 FS-141d, 9-155M | 23d |
| 243161005 |  | Vendor Prepare Tooling to wind Spare Dipole Coil | 15d | 2014-10-01 | 2014-10-21 | 9-155M, 24313017 FS-141d | 1d |
| 243161030LOE |  | Oversight of Spare Coil Winding | 119d | 2014-10-01 | 2015-03-31 | 9-155M | 233d |
| 243161010 |  | Vendor wind Spare Dipole Coil | 104d | 2014-10-22 | 2015-03-31 | 243161005 | 1d |
| 243161015 |  | Vendor storage of Spare Coils | 149d | 2015-04-01 | 2015-10-30 | 243161000, 243161010 | 1d |
| 243161020 |  | Vendor ship spare coils to JLab | 20d | 2015-11-02 | 2015-12-01 | 243161030LOE, 243161015 | 84d |
|  | 2 | **1.4.3.2 DETECTOR** |  | 2009-10-01 | 2014-09-03 |  |  |
|  | 1 | **1.4.3.2.1 WIRE CHAMBERS** |  | 2009-10-01 | 2014-09-03 |  |  |
| 14321000M |  | Award Contract for Wire Chambs | 0d | 2009-10-01 | 2009-10-01 | 12232015, 9-100M | 249d |

| ID | WBS | Task | Duration | Start | Finish | Predecessors | Total float |
| --- | --- | --- | --- | --- | --- | --- | --- |
| 14321005 |  | Fab Wire Chambers at University | 494d | 2009-10-01 | 2011-09-28 | 14321000M | 249d |
| 143218P1LOE |  | P-1 Supervise Fab of Wire Chambs | 248d | 2009-10-01 | 2010-09-30 | 14321000M, 12232020 | 498d |
| 14321007 |  | Procure Connectors and Components | 64d | 2010-07-01 | 2010-09-30 | 9-100M FS+184d | 743d |
| 143218P2LOE |  | P-2 Supervise Fab of Wire Chambs | 245d | 2010-10-01 | 2011-09-27 | 143218P1LOE | 498d |
| 14321900 |  | Proc Prep and Fab of Drift Gas Manifold Parts Original | 2d | 2012-01-30 | 2012-01-31 | 14324001a | 417d |
| 14321900a |  | Reverse Entry per CR12-022 | 2d | 2012-02-03 | 2012-02-06 | 9-120M FS+80d | 165d |
| 14321905 |  | Refurbish LVPS | 120d | 2012-02-03 | 2012-07-24 | 9-120M FS+80d | 295d |
| 14321015M |  | Test Wire Chambers at University | 0d | 2012-09-27 | 2012-09-27 | 14321007, 14321005 FS+248d, 143218P2LOE | 249d |
| 14321900b |  | Proc Prep and Fab of Drift Gas Manifold Parts Revised per CR12-022 | 104d | 2013-01-03 | 2013-05-31 | 9-130M FS+60d, 14324001a | 84d |
| 14321910 |  | Re-Baseline Actuals Adjustment | 1d | 2013-08-30 | 2013-08-30 | 9-130M FS+227d | 20d |
| 24321007 |  | Procure Connectors and Components | 20d | 2013-09-03 | 2013-09-30 | 9-130M FS+228d | 504d |
| 24321015M |  | Test Wire Chambers at University | 0d | 2014-09-03 | 2014-09-03 | 9-140M FS+228d, 24321007 | 276d |
|  | 2 | **1.4.3.2.2 HODOSCOPE (Trigger Hodoscopes)** |  | 2009-10-01 | 2013-08-30 |  |  |
| 14322000M |  | Award Contract for Scintillator Hodoscope Planes | 0d | 2009-10-01 | 2009-10-01 | 9-100M | 495d |
| 14322005M |  | Award Contract for Quartz Hodoscope Planes | 0d | 2009-10-01 | 2009-10-01 | 9-100M | 495d |
| 14322010 |  | Fab 3 Scintillator Planes (incl Supprt) (HODOSCP) | 496d | 2009-10-01 | 2011-09-30 | 14322000M, 122322005 | 495d |
| 14322015 |  | Fab 1 Quartz Hodoscope Plane | 496d | 2009-10-01 | 2011-09-30 | 14322005M, 122322015b | 495d |
| 14322013 |  | Detail Quartz Hodoscope Mounts | 110d | 2011-03-04 | 2011-08-08 | 14322005M, 9-110M FS+100d | 533d |
| 14322020 |  | Re-Baseline Actuals Adjustment | 1d | 2013-08-30 | 2013-08-30 | 9-130M FS+227d | 20d |
|  | 3 | **1.4.3.2.3 NOBLE GAS CERENKOV** |  | 2012-01-05 | 2014-07-31 |  |  |
| 14323000M |  | Award Contract for Noble Gas Cerenkov to University | 0d | 2012-01-05 | 2012-01-05 | 9-120M FS+60d | 45d |
| 14323005 |  | Fab Noble Gas Cerenkov FY12 | 187d | 2012-01-05 | 2012-09-28 | 14323000M | 168d |
| 14323005b |  | Fab Noble Gas Cerenkov Procurement | 267d | 2012-01-05 | 2013-01-31 | 14323000M | 168d |
| 14323010 |  | Design & Build Vacuum Box | 130d | 2012-01-05 | 2012-07-10 | 14323000M | 45d |
| 143238P1LOE |  | P-1 Supervise Constrctn of Noble Gas Cerenkov FY12 | 187d | 2012-01-05 | 2012-09-28 | 122323015, 14323000M | 1010d |
| 14323005a |  | Fab Noble Gas Cerenkov FY13 | 80d | 2012-10-01 | 2013-01-31 | 14323005 | 168d |
| 143238P1LOEa |  | P-1 Supervise Constrctn of Noble Gas Cerenkov FY13 | 80d | 2012-10-01 | 2013-01-31 | 143238P1LOE | 1010d |
| 14323015 |  | Detailing Cerenkov-to-Magnet Interface | 130d | 2013-01-23 | 2013-07-26 | 14323010 FS+130d | 45d |
| 143238P1LOEb |  | P-2 Supervise Constrctn of Noble Gas Cerenkov | 148d | 2013-02-01 | 2013-08-30 | 143238P1LOEa | 1010d |
| 14323020 |  | Re-Baseline Actuals Adjustment | 1d | 2013-08-30 | 2013-08-30 | 9-130M FS+227d | 20d |
| 24323005b |  | Fab Noble Gas Cerenkov Procurement | 225d | 2013-09-03 | 2014-07-31 | 9-130M FS+228d | 264d |
| 24323012 |  | Build Vacuum Box | 62d | 2013-09-03 | 2013-11-27 | 9-130M FS+228d | 462d |
| 243238P1LOEb |  | P-2 Supervise Constrctn of Noble Gas Cerenkov | 20d | 2013-09-03 | 2013-09-30 | 9-130M FS+228d | 551d |
| 24323025 |  | Install NGC Gas Mixer in Gas Shed | 20d | 2013-11-01 | 2013-12-02 | 9-140M FS+23d | 461d |
|  | 4 | **1.4.3.2.4 HEAVY GAS CERENKOV** |  | 2011-06-06 | 2014-07-31 |  |  |
| 14324000 |  | Engineering & Design Oversite FY11 | 83d | 2011-06-06 | 2011-09-30 | 9-110M FS+165d | 1160d |
| 14324001 |  | Engineering & Design - Gas System FY11 | 83d | 2011-06-06 | 2011-09-30 | 9-110M FS+165d | 291d |
| 14324000a |  | Engineering & Design Oversite FY12 | 58d | 2011-10-03 | 2011-12-30 | 14324000 | 1160d |
| 14324001a |  | Engineering & Design - Gas System FY12 | 76d | 2011-10-03 | 2012-01-27 | 14324001 | 291d |
| 14324010 |  | Ship and Aluminize Mirrors | 267d | 2012-01-05 | 2013-01-31 | 9-120M FS+60d | 168d |
| 143248P1LOE |  | P-1 Supervise Constrctn of Heavy Gas Cerenkov FY12 | 187d | 2012-01-05 | 2012-09-28 | 9-120M FS+60d, 14324000a, 122324015 | 1158d |
| 14324003 |  | Fab Gas System Original | 2d | 2012-01-30 | 2012-01-31 | 14324001a | 417d |
| 14324003a |  | Reverse Entry per CR12-022 | 2d | 2012-02-03 | 2012-02-06 | 9-120M FS+80d | 165d |
| 143248P1LOE5 |  | P-1 Supervise Constrctn of Heavy Gas Cerenkov FY13 | 80d | 2012-10-01 | 2013-01-31 | 143248P1LOE | 1158d |
| 14324003b |  | Fab Gas System Revised per CR12-022-- Procurement | 60d | 2013-03-04 | 2013-05-24 | 14324001a, 9-130M FS+100d | 20d |
| 14324005 |  | ASSEMBLE Gas System | 68d | 2013-05-28 | 2013-08-30 | 14324003b | 20d |
| 14324015 |  | Re-Baseline Actuals Adjustment | 1d | 2013-08-30 | 2013-08-30 | 9-130M FS+227d | 20d |
| 24324005 |  | Assemble HGC Gas System & Leak-check tank | 20d | 2014-07-03 | 2014-07-31 | 9-140M FS+185d | 281d |
|  | 5 | **1.4.3.2.5 SHOWER COUNTER** |  | 2011-05-31 | 2013-12-20 |  |  |
| 14325027c |  | Procure SD for Calorimeter Ref. Hall D 1543055 | 66d | 2011-05-31 | 2011-08-31 | 9-110M FS+161d | 516d |
| 14325027a |  | Procure CTP for Calorimeter Ref. Hall D 1543025 | 37d | 2011-07-12 | 2011-08-31 | 9-110M FS+190d | 516d |
| 14325027b |  | Procure TI for Calorimeter Ref. Hall D 1543040 | 28d | 2011-09-08 | 2011-10-17 | 9-110M FS+231d | 484d |
| 14325005 |  | Buy Lead Glass Blocks (SHOWER COUNTER) | 130d | 2011-10-03 | 2012-04-13 | 9-120M, 122325020 | 305d |
| 14325027 |  | Procure F250 ADCs (SHOWER COUNTER) | 231d | 2012-01-04 | 2012-11-30 | 9-120M FS+59d | 128d |
| 14325010 |  | Buy PMTs & Bases (SHOWER COUNTER) | 60d | 2012-04-16 | 2012-07-10 | 14325005 | 305d |
| 14325028 |  | UMASS - Testing of F250 ADCs by University (SHOWER COUNTER) REFERENCE 1541057 | 98d | 2012-10-31 | 2013-03-29 | 14325027 FS-21d | 128d |
| 14325015 |  | Fab Supprt Sys (SHOWER COUNTER) | 10d | 2013-04-01 | 2013-04-12 | 14363030, 14363030a, 14325005 | 118d |
| 14325030 |  | Re-Baseline Actuals Adjustment | 1d | 2013-08-30 | 2013-08-30 | 9-130M FS+227d | 20d |
| 24325027a |  | Procure CTP for Calorimeter Ref. Hall D 1543025 | 20d | 2013-09-03 | 2013-09-30 | 9-130M FS+228d | 401d |
| 24325030 |  | Fiducialize SHMS Shower Counter (Frame) | 57d | 2013-10-01 | 2013-12-20 | 9-140M | 342d |
|  | 6 | **1.4.3.2.6 AEROGEL CERENKOV** |  |  |  |  |  |
|  | 7 | **1.4.3.2.7 TRD** |  |  |  |  |  |
|  | 8 | **1.4.3.2.8 DETECTOR FRAME** |  | 2010-06-01 | 2014-03-31 |  |  |
| 14328015 |  | Procure Support Frame | 86d | 2010-06-01 | 2010-09-30 | 9-100M FS+162d | 743d |
| 14328005 |  | Fab General Struct for Detector Frame FY12 | 225d | 2011-11-02 | 2012-09-28 | 9-120M FS+22d, 122325020 | 228d |
| 14328005b |  | Fab General Struct for Detector Frame Procurement Part A | 245d | 2011-11-02 | 2012-10-26 | 9-120M FS+22d, 122325020 | 228d |
| 14328005ba |  | Fab General Struct for Detector Frame Procurement Part B | 245d | 2011-11-02 | 2012-10-26 | 9-120M FS+22d, 122325020 | 228d |
| 14328010 |  | Fab Supprt for individual Detctr's FY12 | 225d | 2011-11-02 | 2012-09-28 | 9-120M FS+22d, 122325020 | 171d |
| 14328010b |  | Fab Supprt for individual Detctr's Procurement Part A | 302d | 2011-11-02 | 2013-01-28 | 9-120M FS+22d, 122325020 | 171d |
| 14328010ba |  | Fab Supprt for individual Detctr's Procurement Part B | 302d | 2011-11-02 | 2013-01-28 | 9-120M FS+22d, 122325020 | 171d |

| ID | WBS | Task | Duration | Start | Finish | Predecessors | Total float |
| --- | --- | --- | --- | --- | --- | --- | --- |
| 14328005a |  | Fab General Struct for Detector Frame FY13 | 20d | 2012-10-01 | 2012-10-26 | 14328005 | 228d |
| 14328010a |  | Fab Supprt for individual Detctr's FY13 | 77d | 2012-10-01 | 2013-01-28 | 14328010 | 171d |
| 14328020 |  | Re-Baseline Actuals Adjustment | 1d | 2013-08-30 | 2013-08-30 | 9-130M FS+227d | 20d |
| 24328005 |  | Calorimeter Support Frame TBP | 43d | 2013-09-03 | 2013-10-31 | 9-130M FS+228d | 370d |
| 24328010ba |  | Fab Supprt for individual Detctr's Procurement Part B | 119d | 2013-10-01 | 2014-03-31 | 24328005 FS-43d, 9-140M | 350d |
|  | 3 | **1.4.3.3 COMPUTING** |  | 2013-08-30 | 2014-12-02 |  |  |
|  | 1 | **1.4.3.3.1 DAQ** |  | 2013-08-30 | 2014-12-02 |  |  |
| 1433015 |  | Re-Baseline Actuals Adjustment | 1d | 2013-08-30 | 2013-08-30 | 9-130M FS+227d | 20d |
| 2433000 |  | Buy 5 Fast PC's for Data Acq & Processing (COMP) | 40d | 2014-10-06 | 2014-12-02 | 9-140M FS+250d | 186d |
| 2433005 |  | Buy File Servers for Data Acq System (COMP) | 40d | 2014-10-06 | 2014-12-02 | 9-140M FS+250d | 186d |
| 2433010 |  | Buy 8 Workstations/Monitors (COMP) | 40d | 2014-10-06 | 2014-12-02 | 9-140M FS+250d | 186d |
|  | 2 | **1.4.3.3.2 SLOW CONTROLS** |  |  |  |  |  |
|  | 4 | **1.4.3.4 ELECTRONICS** |  | 2010-11-12 | 2014-02-10 |  |  |
|  | 1 | **1.4.3.4.1 FAST ELECTRONICS** |  | 2011-05-13 | 2014-02-10 |  |  |
| 14341007 |  | SOS Signal Cable Prepare for Installation (FAST Electrnc's) | 60d | 2011-05-13 | 2011-08-08 | 4A-01M | 68d |
| 14341015 |  | Proc ADCs for Hodoscopes (FAST Electrnc's) | 231d | 2012-01-04 | 2012-11-30 | 9-120M FS+59d | 205d |
| 14341005 |  | Proc TDCs for Wire Chambers (FAST Electrnc's) | 245d | 2012-01-05 | 2012-12-21 | 9-120M FS+60d | 190d |
| 14341010 |  | Proc Discriminators for Wire Chambers (FAST Electrnc's) | 130d | 2012-01-05 | 2012-07-10 | 9-120M FS+60d | 305d |
| 14341020 |  | Proc ADCs for Calorimeter (FAST Electrnc's) FY12 | 187d | 2012-01-05 | 2012-09-28 | 9-120M FS+60d | 190d |
| 14341025 |  | Proc TDCs for Hodoscopes (FAST Electrnc's) | 245d | 2012-01-05 | 2012-12-21 | 9-120M FS+60d | 190d |
| 14341030 |  | Proc Discriminators for Hodoscopes (FAST Electrnc's) | 245d | 2012-01-05 | 2012-12-21 | 9-120M FS+60d | 190d |
| 14341035 |  | Proc HV for All Detctr's (FAST Electrnc's) | 245d | 2012-01-05 | 2012-12-21 | 9-120M FS+60d | 190d |
| 14341040 |  | Proc CAMAC Controller & Crate (FAST Electrnc's) | 245d | 2012-01-05 | 2012-12-21 | 9-120M FS+60d | 190d |
| 14341045 |  | Proc NIM Crates (FAST Electrnc's) | 245d | 2012-01-05 | 2012-12-21 | 9-120M FS+60d | 190d |
| 14341050 |  | Proc NIM & CAMAC Logic (FAST Electrnc's) | 245d | 2012-01-05 | 2012-12-21 | 9-120M FS+60d | 190d |
| 14341055 |  | Proc scalers (FAST Electrnc's) | 245d | 2012-01-05 | 2012-12-21 | 9-120M FS+60d | 190d |
| 14341060 |  | Proc Cables & Connectors (FAST Electrnc's) | 245d | 2012-01-05 | 2012-12-21 | 9-120M FS+60d | 190d |
| 14341065 |  | Proc VME Crates (FAST Electrnc's) REF. HallD 1544006 | 123d | 2012-01-05 | 2012-06-29 | 9-120M FS+60d | 71.5d |
| 14341070 |  | Proc High-Power 21-slot VME64x/VXS crate for DF2 | 245d | 2012-01-05 | 2012-12-21 | 9-120M FS+60d | 190d |
| 14341075 |  | Proc 2 single-board PC's for DCs, Hodoscopes, Cerenkovs for DF2 | 245d | 2012-01-05 | 2012-12-21 | 9-120M FS+60d | 190d |
| 14341090 |  | Proc SD Module for DF2 | 245d | 2012-01-05 | 2012-12-21 | 9-120M FS+60d | 190d |
| 14341095 |  | Proc 2 TI Modules for DF2 | 245d | 2012-01-05 | 2012-12-21 | 9-120M FS+60d | 190d |
| 14341097 |  | Proc TD Module for DF2 | 245d | 2012-01-05 | 2012-12-21 | 9-120M FS+60d | 190d |
| 14341110 |  | Proc positive high-voltage modules | 245d | 2012-01-05 | 2012-12-21 | 9-120M FS+60d | 190d |
| 14341115 |  | Recondition 1 existing VME64x crate (w/o VXS) FY12 | 187d | 2012-01-05 | 2012-09-28 | 9-120M FS+60d | 190d |
| 14341067 |  | Assemble and Test VME Crates (FAST Electrnc's) REF. HallD 1544025 | 32.5d | 2012-07-02 | 2012-08-15 | 14341065 | 71.5d |
| 14341020a |  | Proc ADCs for Calorimeter (FAST Electrnc's) FY13 | 58d | 2012-10-01 | 2012-12-21 | 14341020 | 190d |
| 14341100 |  | Proc SSP Module for DF2 | 228d | 2012-10-01 | 2013-08-30 | 9-130M | 20d |
| 14341105 |  | Proc 11 TDC modules with CAEN 1190 specs for DC, Cerenkovs, Hodoscopes - for DF2 | 228d | 2012-10-01 | 2013-08-30 | 9-130M | 20d |
| 14341115a |  | Recondition 1 existing VME64x crate (w/o VXS) FY13 | 58d | 2012-10-01 | 2012-12-21 | 14341115 | 190d |
| 14341000 |  | DAQ Trigger Development | 208d | 2012-10-29 | 2013-08-30 | 14341067, 9-130M FS+20d | 20d |
| 14341120 |  | Re-Baseline Actuals Adjustment | 1d | 2013-08-30 | 2013-08-30 | 9-130M FS+227d | 20d |
| 24341000 |  | DAQ Trigger Development FY13 | 20d | 2013-09-03 | 2013-09-30 | 9-130M FS+228d | 317d |
| 24341085 |  | Proc CTP Module for DF2 | 43d | 2013-09-03 | 2013-10-31 | 9-130M FS+228d | 378d |
| 24341000a |  | DAQ Trigger Development FY14 | 84d | 2013-10-01 | 2014-02-10 | 9-130M FS+228d, 24341000 | 317d |
|  | 2 | **1.4.3.4.2 POWER SUPPLIES & PROBES (Power Supply Infrastructure)** |  | 2010-11-12 | 2014-01-02 |  |  |
| 14342005 |  | Proc 4 Pwr Supplies for 480V (PWR SUP) | 1d | 2010-11-12 | 2010-11-12 | 9-110M FS+30d | 707d |
| 14342010 |  | Proc LCW Sys for Pwr Supplies (PWR SUP) | 1d | 2010-11-15 | 2010-11-15 | 14342005 | 707d |
| 14342020 |  | Proc 5000A Rigid Water Cooled Bus (PWR SUP) | 1d | 2010-11-16 | 2010-11-16 | 14342010 | 707d |
| 14342030 |  | Proc 5000A Flexible Lines (PWR SUP) | 1d | 2011-12-02 | 2011-12-02 | 9-120M FS+42d, 14342020 | 450d |
| 14342035 |  | Fab Stand for Pwr Supplies (PWR SUP) | 1d | 2011-12-02 | 2011-12-02 | 9-120M FS+42d, 14342005 | 450d |
| 14342040 |  | Fab Catwalk (PWR SUP) | 1d | 2011-12-05 | 2011-12-05 | 14342030, 14342035 | 450d |
| 14342045 |  | Fab Cable Tray & Bus Supprt (PWR SUP) | 1d | 2011-12-06 | 2011-12-06 | 14342040 | 450d |
| 14342050 |  | Proc 5000A Flexible Lines Revised by 2012 ETC | 120d | 2013-01-03 | 2013-06-24 | 9-130M FS+60d | 68d |
| 14342060 |  | Re-Baseline Actuals Adjustment | 1d | 2013-08-30 | 2013-08-30 | 9-130M FS+227d | 20d |
| 24342055 |  | Fab Cable Tray & Bus Support | 58d | 2013-10-01 | 2014-01-02 | 9-140M | 294d |
|  | 5 | **1.4.3.5 BEAMLINE** |  | 2011-01-05 | 2015-05-01 |  |  |
|  | 1 | **1.4.3.5.1 MOELLER POLARIMETER** |  | 2012-05-14 | 2014-03-31 |  |  |
| 14351005 |  | Proc Pwr Supply for Additional quad for Moeller polarimeter | 130d | 2012-05-14 | 2012-11-14 | 9-100M, 2-02M | 215d |
| 14351010 |  | Proc Cables/Stand for Additional quad for Moeller polarimeter | 40d | 2013-05-01 | 2013-06-26 | 2-02M, 9-100M, 9-130M FS+142d | 65d |
| 14351020 |  | Modify Moeller Collimator- Manufacturing Drawings | 20d | 2013-05-01 | 2013-05-29 | 2-02M, 9-130M FS+142d | 641d |
| 14351025 |  | Re-Baseline Actuals Adjustment | 1d | 2013-08-30 | 2013-08-30 | 9-130M FS+227d | 20d |
| 24351020 |  | Modify Moeller Collimator- Manufacturing Drawings | 65d | 2013-10-18 | 2014-01-31 | 9-140M FS+13d | 468d |
| 24351030 |  | Modify Moeller Collimator - FAB/PROCURE | 41d | 2014-02-03 | 2014-03-31 | 9-140M, 24351020 | 526d |
|  | 2 | **1.4.3.5.2 COMPTON POLARIMETER** |  | 2012-01-20 | 2013-08-30 |  |  |
| 14352005 |  | Procure QR Magnets for Compton | 82d | 2012-01-20 | 2012-05-15 | 9-120M FS+70d | 846d |
| 14352000 |  | Produce Compton Elevation Layout FY12 | 97d | 2012-05-14 | 2012-09-28 | 9-120M FS+150d | 245d |
| 14352000a |  | Produce Compton Elevation Layout FY13 | 3d | 2012-10-01 | 2012-10-03 | 14352000 | 245d |
| 14352010 |  | Re-Baseline Actuals Adjustment | 1d | 2013-08-30 | 2013-08-30 | 9-130M FS+227d | 20d |
|  | 3 | **1.4.3.5.3 MAPPING** |  | 2013-04-01 | 2014-04-30 |  |  |

| ID | WBS | Task | Duration | Start | Finish | Predecessors | Total float |
| --- | --- | --- | --- | --- | --- | --- | --- |
| 14353015 |  | Refurb Existing Harmonic Coil for SHMS Mags | 100d | 2013-04-01 | 2013-08-20 | 9-130M FS+120d | 28d |
| 14353010 |  | Fabricate and Use New ARC Mapper | 48d | 2013-06-25 | 2013-08-30 | 9-130M FS+180d | 573d |
| 14353020 |  | Re-Baseline Actuals Adjustment | 1d | 2013-08-30 | 2013-08-30 | 9-130M FS+227d | 20d |
| 24353010 |  | Fabricate and Use New ARC Mapper FY13 | 20d | 2013-09-03 | 2013-09-30 | 9-130M FS+228d | 494d |
| 24353010a |  | Fabricate and Use New ARC Mapper FY14 | 57d | 2013-10-01 | 2013-12-20 | 9-130M FS+228d, 24353010 | 494d |
| 24353015 |  | Refurb Existing Harmonic Coil for SHMS Mags | 75d | 2014-01-15 | 2014-04-30 | 9-140M FS+66d | 370d |
|  | 4 | **1.4.3.5.4 SCATTERING CHAMBER** |  | 2011-01-05 | 2014-09-05 |  |  |
| 14354005 |  | Modify Existing Chamb Cylinder (SCATTER CHAMB) | 65d | 2011-01-05 | 2011-04-07 | 9-110M FS+60d | 417d |
| 14354010 |  | Proc & Install Chamb Flanges (SCATTER CHAMB) | 80d | 2011-04-08 | 2011-08-01 | 9-110M, 14354005, 14354008 FS-600d | 417d |
| 14354015 |  | Proc & Install HMS & SHMS Window Frames (SCATTER CHAMB) FY11 | 43d | 2011-08-02 | 2011-09-30 | 14354010 | 417d |
| 14354015a |  | Proc & Install HMS & SHMS Window Frames (SCATTER CHAMB) FY12 | 37d | 2011-10-03 | 2011-11-22 | 14354015 | 417d |
| 14354020 |  | Proc & Install HMS & SHMS Blank Covers (SCATTER CHAMB) | 20d | 2011-11-23 | 2011-12-29 | 14354015a | 417d |
| 14354030 |  | Proc & Install Gate Valves,BL adaptors & Vac Gauges (SCATTER CHAMB) Original Labor | 21d | 2011-12-30 | 2012-01-31 | 14354020 | 417d |
| 14354025 |  | Proc Turbo Pump Sys (SCATTER CHAMB) | 130d | 2013-02-01 | 2013-08-06 | 9-130M FS+80d, 14354005 | 38d |
| 14354008 |  | Proc & Fab Chamb Flanges (SCATTER CHAMB) | 80d | 2013-04-15 | 2013-08-06 | 9-130M FS+130d | 437d |
| 14354035 |  | Re-Baseline Actuals Adjustment | 1d | 2013-08-30 | 2013-08-30 | 9-130M FS+227d | 20d |
| 24354008 |  | Proc & Fab Chamb Flanges (SCATTER CHAMB) | 80d | 2014-03-05 | 2014-06-25 | 9-140M FS+100d | 809d |
| 24354010 |  | Procure and Install Chamb Flanges (SCATTER CHAMB) | 130d | 2014-03-05 | 2014-09-05 | 24354008 FS-600d, 9-140M FS+100d | 341d |
| 24354015a |  | Proc & Install HMS & SHMS Window Frames (SCATTER CHAMB) | 130d | 2014-03-05 | 2014-09-05 | 24354010 FS-130d, 9-140M FS+100d | 341d |
| 24354020 |  | Proc & Install HMS & SHMS Blank Covers (SCATTER CHAMB) | 130d | 2014-03-05 | 2014-09-05 | 24354015a FS-130d, 9-140M FS+100d | 341d |
| 24354022 |  | Modify Seal on Scattering Chamber | 120d | 2014-03-05 | 2014-08-21 | 9-140M FS+100d | 321d |
| 24354030 |  | Proc & Install Gate Valves,BL adaptors & Vac Gauges (SCATTER CHAMB) Labor | 75d | 2014-03-05 | 2014-06-18 | 24354020 FS-130d, 9-140M FS+100d | 341d |
| 24354030b |  | Proc & Install Gate Valves,BL adaptors & Vac Gauges (SCATTER CHAMB) Procurement | 75d | 2014-03-05 | 2014-06-18 | 9-140M FS+100d | 341d |
|  | 5 | **1.4.3.5.5 BEAM PIPE & STANDS** |  | 2013-08-28 | 2015-05-01 |  |  |
| 14355010 |  | Proc 2nd Section of Beam Pipe (Beam Pipe) | 3d | 2013-08-28 | 2013-08-30 | 9-130M FS+225d | 20d |
| 14355015 |  | Proc 3rd Section of Beam Pipe (Beam Pipe) | 3d | 2013-08-28 | 2013-08-30 | 9-130M FS+225d | 20d |
| 14355035 |  | Re-Baseline Actuals Adjustment | 1d | 2013-08-30 | 2013-08-30 | 9-130M FS+227d | 20d |
| 24355000 |  | Produce Manufacturing Drawings for Beam Pipe, Stands, Fittings | 65d | 2014-07-01 | 2014-10-01 | 9-140M FS+183d | 270d |
| 24355005 |  | Proc 1st Pipe (Beam Pipe) | 58d | 2014-10-01 | 2014-12-23 | 24355000 FS-75d, 9-155M | 196d |
| 24355010 |  | Proc 2nd Section of Beam Pipe (Beam Pipe) | 55d | 2014-11-03 | 2015-02-02 | 9-155M FS+23d | 112d |
| 24355015 |  | Proc 3rd Section of Beam Pipe (Beam Pipe) | 56d | 2014-12-02 | 2015-03-02 | 9-155M FS+42d | 112d |
| 24355020 |  | Proc Windows & Window Spool (Beam Pipe) | 84d | 2015-01-05 | 2015-05-01 | 24355015 FS-40d, 24355010 FS-20d, 24355005 FS-90d | 117d |
| 24355025 |  | Proc Beam Stands (Beam Pipe) | 84d | 2015-01-05 | 2015-05-01 | 24355005 FS-90d, 24355010 FS-20d, 24355015 FS-40d | 112d |
| 24355030 |  | Proc Vac Fittings (Beam Pipe) | 84d | 2015-01-05 | 2015-05-01 | 24355025 FS-84d | 122d |
|  | 6 | **1.4.3.5.6 MAGNET POWER SUPPLY** |  |  |  |  |  |
|  | 6 | **1.4.3.6 INFRASTUCTURE** |  | 2009-01-05 | 2015-12-23 |  |  |
|  | 1 | **1.4.3.6.1 ENGINEERING & DESIGN** |  |  |  |  |  |
|  | 2 | **1.4.3.6.2 SUPPORT STRUCTURE** |  | 2009-11-02 | 2013-09-30 |  |  |
| 14362000M |  | Award Contract to Dsgn the Supprt Struct | 0d | 2009-11-02 | 2009-11-02 | 12236040, 9-100M FS+22d, 12236830LOE | 296d |
| 14362005 |  | Finalize Dsgn of Supprt Struct | 226d | 2009-11-02 | 2010-09-30 | 14362000M | 296d |
| 14362006 |  | SS/SH Engineering Support FY10 | 21d | 2010-09-01 | 2010-09-30 | 14362005 FS-21d | 296d |
| 14362007 |  | SS/SH Engineering Support FY11 | 248d | 2010-10-01 | 2011-09-30 | 14362006, 9-110M | 296d |
| 14362075 |  | Fab Main Bearing of Supprt Struct Labor FY11 | 248d | 2010-10-01 | 2011-09-30 | 14362005 | 381d |
| 14362075b |  | Fab Main Bearing of Supprt Struct Procurement | 250d | 2010-10-01 | 2011-10-04 | 14362005 | 381d |
| 14362811LOE |  | Overlook Various Subcontracts of Supprt Struct | 248d | 2010-10-01 | 2011-09-30 | 9-110M | 1238d |
| 14362010M |  | Review Final Dsgn of Supprt Struct | 0d | 2010-10-27 | 2010-10-27 | 14362005, 14362006 FS+19d, 14363010 | 306d |
| 14362046a |  | Produce Drawings - Wheels | 23d | 2010-10-28 | 2010-12-01 | 14362010M | 306d |
| 14362012 |  | Produce Drawings - Rails & Base of Supprt Struct | 19d | 2010-12-02 | 2011-01-05 | 14362046a | 306d |
| 14362046 |  | Produce Drawings - Bogies | 23d | 2010-12-02 | 2011-01-11 | 14362046a | 347d |
| 14362047a |  | Procurement Prep - Wheels | 20d | 2010-12-02 | 2011-01-06 | 14362046a, 9-110M | 424d |
| 14362016 |  | Produce Drawings - Pivot Sections of Supprt Struct | 20d | 2011-01-06 | 2011-02-03 | 14362012 | 306d |
| 14362047 |  | Procurement Prep - Bogies | 20d | 2011-01-12 | 2011-02-09 | 14362046, 9-110M | 347d |
| 14362041 |  | Produce Drawings - Access Platforms of Supprt Struct | 21d | 2011-02-04 | 2011-03-07 | 14362016 | 306d |
| 14362013 |  | Procurement Prep - Rails & Base of Supprt Struct | 18d | 2011-02-10 | 2011-03-08 | 14362047, 14362012 | 347d |
| 14362036 |  | Produce Drawings - Mag Mounts of Supprt Struct | 21d | 2011-03-08 | 2011-04-05 | 14362041 | 306d |
| 14362017 |  | Procurement Prep - Pivot Sections of Supprt Struct | 20d | 2011-03-09 | 2011-04-05 | 14362013, 14362016 | 374d |
| 14362026 |  | Produce Drawings - Detector Section of Supprt Struct | 19d | 2011-04-06 | 2011-05-02 | 14362036 | 306d |
| 14362042 |  | Procurement Prep - Access Platforms of Supprt Struct | 20d | 2011-04-06 | 2011-05-03 | 14362041, 14362017 | 374d |
| 14362027 |  | Procurement Prep - Detector Section of Supprt Struct | 19d | 2011-05-03 | 2011-05-27 | 14362026 | 318d |
| 14362051 |  | Produce Drawings - Other Compnts of Supprt Struct | 23d | 2011-05-03 | 2011-06-03 | 14362026 | 306d |
| 14362037 |  | Procurement Prep - Mag Mounts of Supprt Struct | 19d | 2011-05-04 | 2011-05-31 | 14362042, 14362036 | 374d |
| 14362031 |  | Produce Drawings - Wheel Section of Supprt Struct | 24d | 2011-06-06 | 2011-07-08 | 14362051 | 306d |
| 14362052 |  | Procurement Prep - Other Compnts of Supprt Struct | 20d | 2011-06-06 | 2011-07-01 | 14362027, 14362051 | 314d |
| 14362021 |  | Produce Drawings - Mag Section of Supprt Struct | 23d | 2011-07-11 | 2011-08-10 | 14362031 | 306d |
| 14362032 |  | Procurement Prep - Wheel Section of Supprt Struct | 19d | 2011-07-11 | 2011-08-04 | 14362052, 14362031 | 310d |
| 14362022 |  | Procurement Prep - Mag Section of Supprt Struct | 18d | 2011-08-11 | 2011-09-06 | 14362032, 14362021 | 306d |
| 14362011 |  | SS/SH Engineering Support FY12 | 247d | 2011-10-03 | 2012-09-28 | 9-120M, 14362010M, 14362007 | 296d |
| 14362050 |  | PreFab Double Bogies of Supprt Struct | 150d | 2011-10-03 | 2012-05-11 | 14362047, 9-120M | 238d |
| 14362050a |  | PreFab Wheels of Supprt Struct | 150d | 2011-10-03 | 2012-05-11 | 14362047a, 14362010M, 9-120M | 238d |
| 14362075a |  | Fab Main Bearing of Supprt Struct Labor FY12 | 2d | 2011-10-03 | 2011-10-04 | 14362075 | 381d |

| ID | WBS | Task | Duration | Start | Finish | Predecessors | Total float |
| --- | --- | --- | --- | --- | --- | --- | --- |
| 14362812LOE |  | Overlook Various Subcontracts of Supprt Struct | 247d | 2011-10-03 | 2012-09-28 | 14362811LOE | 1238d |
| 14362015 |  | PreFab Rails & Base of Supprt Struct | 100d | 2011-12-07 | 2012-05-04 | 9-120M FS+45d, 14362010M FS-130d, 14362013 | 157d |
| 14362020 |  | PreFab Pivot Sections of Supprt Struct | 130d | 2011-12-07 | 2012-06-19 | 14362010M, 9-120M FS+45d, 14362017 | 213d |
| 14362025 |  | PreFab Mag Section #20 of Supprt Struct | 100d | 2011-12-07 | 2012-05-04 | 14362010M, 14362022, 9-120M FS+45d | 243d |
| 14362035a |  | PreFab #100 section of Support STructure and Inner Race | 120d | 2012-01-04 | 2012-06-25 | 9-120M FS+59d | 209d |
| 14362030 |  | PreFab Detector Section #30 of Supprt Struct | 100d | 2012-01-05 | 2012-05-25 | 9-120M FS+60d, 14362037, 14362027 | 228d |
| 14362035 |  | PreFab Wheel Section of Supprt Struct | 100d | 2012-01-05 | 2012-05-25 | 14362010M, 9-120M FS+60d, 14362032 | 228d |
| 14362065 |  | Electrical System Final Drawings | 120d | 2012-01-05 | 2012-06-26 | 9-120M FS+60d | 315d |
| 14362070 |  | Fire Safety and HVAC Final Drawings | 120d | 2012-01-05 | 2012-06-26 | 9-120M FS+60d | 315d |
| 14362055 |  | PreFab Other Compnts of Supprt Struct | 100d | 2012-01-12 | 2012-06-05 | 14362052, 9-120M FS+65d, 14362010M | 223d |
| 14362060 |  | Proc Drive Motors & Reducers of Supprt Struct | 60d | 2012-01-12 | 2012-04-06 | 9-120M FS+65d, 14362010M | 293d |
| 14362040 |  | PreFab Mag Mounts of Supprt Struct | 100d | 2012-02-03 | 2012-06-26 | 9-120M FS+80d, 14362037 | 208d |
| 14362045 |  | PreFab Access Platforms of Supprt Struct | 100d | 2012-04-02 | 2012-08-21 | 14362042, 9-120M FS+120d | 168d |
| 14362950 |  | Re-Baseline Actuals Adjustment | 1d | 2013-08-30 | 2013-08-30 | 9-130M FS+227d | 20d |
| 24362000 |  | Engineering Consulting | 20d | 2013-09-03 | 2013-09-30 | 9-130M FS+228d | 551d |
|  | 3 | **1.4.3.6.3 SHIELD HOUSE** |  | 2009-11-02 | 2014-01-30 |  |  |
| 14363005M |  | Award Contract for Final Dsgn of Shield House (SHIELD HOUSE) | 0d | 2009-11-02 | 2009-11-02 | 12236060, 9-100M FS+22d | 440d |
| 14363010 |  | Finalize Dsgn of Shield House (SHIELD HOUSE) | 111d | 2010-04-26 | 2010-09-30 | 14363005M, 14362005 FS-111d | 325d |
| 14363021 |  | Produce Drawings - Steel (SHIELD HOUSE) FY11 | 36d | 2011-08-11 | 2011-09-30 | 14362021 | 344d |
| 14363021a |  | Produce Drawings - Steel (SHIELD HOUSE) FY12 | 26d | 2011-10-03 | 2011-11-07 | 14363021 | 344d |
| 14363022 |  | Procurement Prep - Steel (SHIELD HOUSE) | 20d | 2011-11-08 | 2011-12-07 | 14363021a | 349d |
| 14363025 |  | Fab Steel Supprt (SHIELD HOUSE) | 100d | 2011-12-08 | 2012-05-07 | 9-120M, 14362010M, 14363022 | 349d |
| 14363021b |  | Produce Drawings FY13 | 147d | 2013-01-02 | 2013-07-31 | 9-130M FS+59d | 42d |
| 14363030 |  | Proc Boron and Lead Shielding (SHIELD HOUSE) Part A | 60d | 2013-01-03 | 2013-03-29 | 14363021a, 9-130M FS+60d | 63d |
| 14363030a |  | Proc Boron and Lead Shielding (SHIELD HOUSE) Part B | 60d | 2013-01-03 | 2013-03-29 | 9-130M FS+60d, 14363021a | 63d |
| 14363060 |  | Fab Various Small Components (SHIELD HOUSE) | 65d | 2013-04-01 | 2013-07-01 | 14363030, 14363030a | 63d |
| 14363035 |  | Fab Doors and associated hardware for Shield House (SHIELD HOUSE) (Future Activity Complete prior to Rebaseline) | 1d | 2013-08-30 | 2013-08-30 | 9-130M FS+227d | 20d |
| 14363065 |  | Re-Baseline Actuals Adjustment | 1d | 2013-08-30 | 2013-08-30 | 9-130M FS+227d | 20d |
| 24363030aa |  | Assemble Cast Panels and Lead Sheets (SHIELD HOUSE) | 77d | 2013-09-03 | 2013-12-20 | 9-130M FS+228d | 186d |
| 24363035 |  | Fab Doors and associated hardware for Shield House (SHIELD HOUSE) Part A | 77d | 2013-09-03 | 2013-12-20 | 9-130M FS+228d | 209d |
| 24363036 |  | Fab Doors and associated hardware for Shield House (SHIELD HOUSE) Part B | 77d | 2013-09-03 | 2013-12-20 | 9-130M FS+228d | 209d |
| 24363037 |  | Fab Doors and associated hardware for Shield House (SHIELD HOUSE) Part C Procurement | 97d | 2013-09-03 | 2014-01-30 | 9-130M FS+228d | 189d |
| 24363037a |  | Fab Doors and associated hardware for Shield House (SHIELD HOUSE) Part C Labor FY13 | 20d | 2013-09-03 | 2013-09-30 | 9-130M FS+228d | 189d |
| 24363041 |  | Plastic Pellets | 20d | 2013-09-03 | 2013-09-30 | 9-130M FS+228d | 551d |
| 24363046 |  | Rental Containers for Plastic Pellets | 20d | 2013-09-03 | 2013-09-30 | 9-130M FS+228d | 551d |
| 24363037b |  | Fab Doors and associated hardware for Shield House (SHIELD HOUSE) Part C Labor FY14 | 77d | 2013-10-01 | 2014-01-30 | 9-130M FS+228d, 24363037a | 189d |
| 24363060 |  | Fab Various Small Components (SHIELD HOUSE) | 65d | 2013-10-01 | 2014-01-13 | 24363030aa FS-57d | 404d |
|  | 4 | **1.4.3.6.4 CRYOGENIC SYSTEM** |  | 2010-10-01 | 2014-03-20 |  |  |
| 14364005 |  | Update Overall Cryo Flow Sheet (CRYO SYS) | 40d | 2010-10-01 | 2010-11-29 | 12236015b, 9-110M | 393d |
| 14364010 |  | Proc Equipmnt for Mod of G0 Transfer Line (CRYO SYS) | 40d | 2011-10-03 | 2011-11-29 | 9-120M, 14364005 | 185d |
| 14364015 |  | Detail Mods of G0 Transfer Line | 18d | 2011-11-30 | 2011-12-30 | 14364010 | 380d |
| 14364025 |  | Fab SHMS Distrbtn Transfer Line (CRYO SYS) | 60d | 2011-11-30 | 2012-03-02 | 14364010 | 185d |
| 14364020 |  | Proc SHMS Distrbtn Transfer Line and Relief Stacks (CRYO SYS) FY12 | 147d | 2012-03-05 | 2012-09-28 | 14364025 | 185d |
| 14364020b |  | Proc SHMS Distrbtn Transfer Line and Relief Stacks (CRYO SYS) Procurement | 180d | 2012-03-05 | 2012-11-14 | 14364025 | 185d |
| 14364030 |  | Fab SHMS Gas Manifolds (CRYO SYS) | 60d | 2012-03-05 | 2012-05-25 | 14364020a FS-180d, 14364020b FS-180d | 185d |
| 14364035 |  | Fab Jlab U-tubes (CRYO SYS) | 80d | 2012-05-29 | 2012-09-19 | 9-120M, 14364030 | 255d |
| 14364040 |  | Fab Jlab L tubes (CRYO SYS) | 80d | 2012-05-29 | 2012-09-19 | 14364030 | 255d |
| 14364060 |  | Fab Stand & Catwalk (CRYO SYS) | 150d | 2012-05-29 | 2013-01-07 | 14364030 | 185d |
| 14364020a |  | Proc SHMS Distrbtn Transfer Line and Relief Stacks (CRYO SYS) FY13 | 33d | 2012-10-01 | 2012-11-14 | 14364020 | 185d |
| 14364043 |  | Produce Drawings for Cryo System Connections & Controls | 60d | 2013-01-02 | 2013-03-28 | 9-130M FS+59d | 67d |
| 14364045 |  | Proc Valves & Controllers (CRYO SYS) | 40d | 2013-03-29 | 2013-05-23 | 14364030, 14364043, 9-130M FS+80d | 89d |
| 14364050 |  | Proc Boom Supprt (CRYO SYS) | 60d | 2013-03-29 | 2013-06-21 | 14364030, 14364043, 9-130M FS+80d | 67d |
| 14364055 |  | Proc Vac Gauges (CRYO SYS) | 40d | 2013-03-29 | 2013-05-23 | 9-130M FS+80d, 14364030, 14364043 | 89d |
| 14364075 |  | Proc & Fab Various Connections etc (CRYO SYS) | 50d | 2013-03-29 | 2013-06-07 | 14364043, 14364030, 9-130M FS+80d | 79d |
| 14364065 |  | Proc Cables,panels & Pwr Supplies (CRYO SYS) | 40d | 2013-05-03 | 2013-06-28 | 9-130M FS+144d | 64d |
| 14364016 |  | Modify G0 Transfer Line | 57d | 2013-06-12 | 2013-08-30 | 14368175 FS+20d, 14364015 | 20d |
| 14364080 |  | Re-Baseline Actuals Adjustment | 1d | 2013-08-30 | 2013-08-30 | 9-130M FS+227d | 20d |
| 24364030 |  | Fab SHMS Gas Manifolds (CRYO SYS) Part A Procurement | 38d | 2013-09-03 | 2013-10-24 | 9-130M FS+228d | 282d |
| 24364030a |  | Fab SHMS Gas Manifolds (CRYO SYS) Part A Labor FY13 | 20d | 2013-09-03 | 2013-09-30 | 9-130M FS+228d | 282d |
| 24364043 |  | Produce Drawings for Cryo System Connections & Controls FY13 | 20d | 2013-09-03 | 2013-09-30 | 9-130M FS+228d | 287d |
| 24364030b |  | Fab SHMS Gas Manifolds (CRYO SYS) Part A Labor FY14 | 18d | 2013-10-01 | 2013-10-24 | 9-130M FS+228d, 24364030a | 282d |
| 24364043a |  | Produce Drawings for Cryo System Connections & Controls FY14 | 18d | 2013-10-01 | 2013-10-24 | 9-130M FS+228d, 24364043 | 287d |
| 24364065 |  | Proc Cables,panels & Pwr Supplies (CRYO SYS) | 38d | 2013-10-01 | 2013-11-21 | 9-140M | 312d |
| 24364016 |  | Modify G0 Transfer Line | 107d | 2013-10-08 | 2014-03-20 | 24368170 FS+5d | 238d |
| 24364075 |  | Proc & Fab Various Connections etc (CRYO SYS) | 50d | 2013-10-25 | 2014-01-16 | 24364043a FS-5d, 24364030b, 24364030, 24364043 FS-5d, 24364030a | 282d |
|  | 5 | **1.4.3.6.5 VACUUM SYSTEM** |  | 2009-01-05 | 2015-03-31 |  |  |
| 14365005 |  | Finalize Drawing for Comp Vac Sys | 60d | 2009-01-05 | 2009-03-31 | 12236025, 12236010b, 12236020 | 88d |
| 14365023 |  | Manufacturing Drawings for Vacuum System Parts | 120d | 2013-01-02 | 2013-06-21 | 9-130M FS+59d | 69d |
| 14365010 |  | Proc Turbo Pump systems | 40d | 2013-01-03 | 2013-03-01 | 14365005 FS+931d, 2-02M | 88d |
| 14365015 |  | Proc Roots Pump Sys | 40d | 2013-01-03 | 2013-03-01 | 2-02M, 14365005 FS+931d | 88d |

| ID | WBS | Task | Duration | Start | Finish | Predecessors | Total float | Constraint |
| --- | --- | --- | --- | --- | --- | --- | --- | --- |
| 14365035 |  | Proc Windows & Flanges | 130d | 2013-01-03 | 2013-07-09 | 14365005, 9-130M FS+60d | 58d |  |
| 14365040 |  | Proc Shutter Exit Window | 130d | 2013-01-03 | 2013-07-09 | 9-130M FS+60d, 14365005 | 58d |  |
| 14365020 |  | Proc Valves & Plumbing | 60d | 2013-03-04 | 2013-05-24 | 14365010, 14365015 | 88d |  |
| 14365025 |  | Proc Gauges for Vac Sys | 60d | 2013-03-04 | 2013-05-24 | 2-02M, 14365015, 14365010 | 88d |  |
| 14365055 |  | Re-Baseline Actuals Adjustment | 1d | 2013-08-30 | 2013-08-30 | 9-130M FS+227d | 20d |  |
| 24365020 |  | Proc Valves & Plumbing and Reliefs Part A Procurement | 62d | 2013-09-03 | 2013-11-27 | 9-130M FS+228d | 358d |  |
| 24365020a |  | Proc Valves & Plumbing and Reliefs Part A Labor FY13 | 20d | 2013-09-03 | 2013-09-30 | 9-130M FS+228d | 358d |  |
| 24365023 |  | Manufacturing Drawings for Vacuum System Parts FY13 | 20d | 2013-09-03 | 2013-09-30 | 9-130M FS+228d | 150d |  |
| 24365025 |  | Proc Valves & Plumbing and Reliefs Part B | 267d | 2013-09-03 | 2014-09-30 | 9-130M FS+228d | 153d |  |
| 24365030 |  | Proc Spool & Bellows for All Magnets Part A | 203d | 2013-09-03 | 2014-06-30 | 24365023 FS-100d, 9-130M FS+228d, 24365023a FS-100d | 198d |  |
| 24365035 |  | Proc Windows & Flanges Part A | 98d | 2013-09-03 | 2014-01-31 | 9-130M FS+228d | 243d |  |
| 24365045 |  | Proc Sieve Slit Sys Part A | 192d | 2013-09-03 | 2014-06-13 | 24365030 FS-203d, 24365035 FS-98d, 24365040 FS-140d, 24365032 FS-251d | 344d |  |
| 24365020b |  | Proc Valves & Plumbing and Reliefs Part A Labor FY14 | 42d | 2013-10-01 | 2013-11-27 | 9-130M FS+228d, 24365020a | 358d |  |
| 24365023a |  | Manufacturing Drawings for Vacuum System Parts FY14 | 78d | 2013-10-01 | 2014-01-31 | 24365023, 9-130M FS+228d | 150d |  |
| 24365032 |  | Proc Spool & Bellows for All Magnets Part B | 203d | 2013-11-08 | 2014-09-08 | 9-130M FS+228d, 24365023a FS-50d, 24365023 FS-50d | 150d |  |
| 24365040 |  | Proc Windows & Flanges Part B | 75d | 2013-12-04 | 2014-03-31 | 9-140M FS+44d | 202d |  |
| 24365047 |  | Proc Sieve Slit Sys Part B | 192d | 2014-06-13 | 2015-03-26 | 24365035, 24365040, 24365032 FS-60d, 24365030 FS-60d | 153d |  |
| 24365050 |  | Fab Slit Controls | 195d | 2014-06-13 | 2015-03-31 | 24365035, 24365032 FS-60d, 24365030 FS-60d, 24365040 | 150d |  |
|  | 6 | **1.4.3.6.6 CABLING** |  | 2012-01-05 | 2014-07-28 |  |  |  |
| 14366005 |  | Proc HV Cables (CABLING) Original | 18d | 2012-01-05 | 2012-01-31 | 9-120M FS+60d | 417d |  |
| 14366010 |  | Proc LV & Signal Cables (CABLING) Original | 18d | 2012-01-05 | 2012-01-31 | 9-120M FS+60d | 417d |  |
| 14366020 |  | Reverse Entry Per CR12-022 | 130d | 2012-02-03 | 2012-08-07 | 9-120M FS+80d | 285d |  |
| 14366007 |  | Proc HV Cables (CABLING) Revised per CR12-022 | 130d | 2012-10-01 | 2013-04-12 | 9-130M | 118d |  |
| 14366015 |  | Proc LV & Signal Cables (CABLING) Revised per CR12-022 | 130d | 2012-10-01 | 2013-04-12 | 9-130M | 20d |  |
| 14366025 |  | Terminate Cables | 43d | 2013-07-02 | 2013-08-30 | 14366015 FS+55d | 20d |  |
| 14366030 |  | Re-Baseline Actuals Adjustment | 1d | 2013-08-30 | 2013-08-30 | 9-130M FS+227d | 20d |  |
| 24366025 |  | Terminate Cables | 122d | 2014-02-05 | 2014-07-28 | 9-140M FS+80d | 225d |  |
|  | 7 | **1.4.3.6.7 SOS PIVOT MODIFICATION** |  | 2011-11-02 | 2013-08-30 |  |  |  |
| 14367005 |  | Proc Parts for SHMS Pivot Connection (SOS PIVOT MOD) | 130d | 2011-11-02 | 2012-05-15 | 9-120M FS+22d, 2-02M FS-130d | 231d |  |
| 14367010 |  | Re-Baseline Actuals Adjustment | 1d | 2013-08-30 | 2013-08-30 | 9-130M FS+227d | 20d |  |
|  | 8 | **1.4.3.6.8 INSTALLATION** |  | 2011-05-13 | 2015-12-23 |  |  |  |
| 14368170 |  | Remove Remaining HKS/HES Components | 50d | 2011-05-13 | 2011-07-25 | 4A-01M | 78d |  |
| 14368171 |  | Strip Clean The SOS: Hoses, Cable & Shielding | 110d | 2011-05-13 | 2011-10-18 | 4A-01M | 18d |  |
| 14368005 |  | Prep for safety Review for Installtn Plans | 25d | 2011-11-02 | 2011-12-08 | 9-120M FS+22d | 157d |  |
| 14368010M |  | Comp safety Review for Installtn Plans | 0d | 2011-12-08 | 2011-12-08 | 14368005 | 157d |  |
| 14368172 |  | Radiation Cooldown | 20d | 2012-05-14 | 2012-06-12 | 2-02M | 20d |  |
| 14368176 |  | Reroute HMS Cableways to Clear SHMS | 60d | 2012-05-14 | 2012-08-07 | 2-07M, 2-02M | 178d |  |
| 14368180 |  | Restore HaLL C and ESR Cryo To Base Config. | 10d | 2012-05-14 | 2012-05-25 | 2-02M | 275d |  |
| 14368425 |  | Install QR Magnets (Notebook) | 50d | 2012-05-16 | 2012-07-26 | 14352005 | 846d |  |
| 14368172a |  | Qweak Post Run Alignment Survey | 10d | 2012-05-29 | 2012-06-12 | 14368172 FS-10d, 2-02M | 20d |  |
| 14368182M |  | Cryogens Available from ESR or CHL | 0d | 2012-05-29 | 2012-05-29 | 9-120M FS+160d | 275d |  |
| 14368185 |  | Cool Down HMS Dipole | 5d | 2012-05-29 | 2012-06-05 | 14368182M, 14368180 | 275d |  |
| 14368190 |  | Cool Down HMS Q1 | 10d | 2012-06-06 | 2012-06-19 | 14368185 | 275d |  |
| 14368210 |  | Prepare LCW for SHMS DCPS Testing | 10d | 2012-06-06 | 2012-06-19 | 14368185, 14368207 FS-171d | 297d |  |
| 14368215 |  | Prepare AC Power for SHMS DCPS Testing | 10d | 2012-06-06 | 2012-06-19 | 14368185 | 297d |  |
| 14368173 |  | Disconnect & Remove Qweak Girder | 5d | 2012-06-13 | 2012-06-19 | 3P-04M, 14368172 | 208d |  |
| 14368174 |  | Dismantle & Remove Qweak Electronics Bunker | 5d | 2012-06-13 | 2012-06-19 | 14368172a, 14368172 FS-20d | 20d |  |
| 14368174a |  | Install SOS Rails, Move SOS and Remove doors and door frame | 10d | 2012-06-20 | 2012-07-03 | 14368174 | 58d |  |
| 14368174h |  | Remove HKS Dummy weight | 2d | 2012-06-20 | 2012-06-21 | 14368174 | 20d |  |
| 14368195 |  | Cool Down HMS Q2 | 10d | 2012-06-20 | 2012-07-03 | 14368190 | 275d |  |
| 14368220 |  | Connect HMS Q1 to SHMS DCPS #1 | 2d | 2012-06-20 | 2012-06-21 | 14368190, 14315075 | 295d | start on or after 2011-05-26 |
| 14368174j |  | Remove Qweak cableling and trays | 5d | 2012-06-22 | 2012-06-28 | 14368174h | 20d |  |
| 14368225 |  | Test Power Supply DCPS #1 | 3d | 2012-06-22 | 2012-06-26 | 14368220, 14368215, 14368210 | 295d |  |
| 14368230 |  | Connect HMS Q1 to SHMS DCPS #2 | 2d | 2012-06-27 | 2012-06-28 | 14368225 | 295d |  |
| 14368174k |  | Remove Qweak Region 3 Shield Hut | 12d | 2012-06-29 | 2012-07-16 | 14368174j | 20d |  |
| 14368235 |  | Test Power Supply DCPS #2 | 3d | 2012-06-29 | 2012-07-03 | 14368230 | 295d |  |
| 14368174b |  | Remove SOS Hydraulic Cylinders and supports | 10d | 2012-07-04 | 2012-07-17 | 14368174a | 58d |  |
| 14368200 |  | Cool Down HMS Q3 | 10d | 2012-07-04 | 2012-07-17 | 14368195 | 275d |  |
| 14368174n |  | Remove Qweak Region 3 Detectors and support structures | 15d | 2012-07-17 | 2012-08-06 | 14368174k | 20d |  |
| 14368174c |  | Move SOS Back and Saw cut and remove concrete | 15d | 2012-07-18 | 2012-08-07 | 14368174b | 58d |  |
| 14368205 |  | Comission HMS Dipole at 3000 amps | 10d | 2012-07-18 | 2012-07-31 | 14368200 | 275d |  |
| 14368174p |  | Remove QTOR Magnet | 10d | 2012-08-07 | 2012-08-20 | 14368174n | 20d |  |
| 14368174q |  | Remove Qweak shield wall and beam dump sections | 5d | 2012-08-21 | 2012-08-27 | 14368174p | 20d |  |
| 14368174r |  | Remove Qweak regions 1 and 2 | 13d | 2012-08-28 | 2012-09-14 | 14368174q | 20d |  |
| 14368174s |  | Remove Qweak cryo target complete | 5d | 2012-09-17 | 2012-09-21 | 14368174r | 20d |  |
| 14368174d |  | Remove SOS Dipole | 5d | 2012-09-24 | 2012-09-28 | 14368174c, 14368174s | 26d |  |
| 14368174t |  | Remove all remaining 9.5" concrete pads | 10d | 2012-09-24 | 2012-10-05 | 14368174s | 20d |  |
| 14368325 |  | Install Rails of Supprt Struct | 31d | 2012-11-19 | 2013-01-10 | 14368174t FS+30d, 14368322 FS-40d, 14362015 | 20d |  |
| 14368383 |  | Procure SHMS Steel Platforms and Stairs | 99d | 2012-12-03 | 2013-04-30 | 9-130M FS+43d | 106d |  |
| 14368207 |  | Complete Readiness Review for SHMS DCPS Testing | 30d | 2013-01-02 | 2013-02-13 | 9-130M FS+59d | 297d |  |

| ID | Task | Duration | Start | Finish | Predecessors | Total float |
| --- | --- | --- | --- | --- | --- | --- |
| 14368322 | Re-Establish Hall-C Alignment Network Prior to SHMS Assy | 5d | 2013-01-02 | 2013-01-08 | 14368174t FS+54d | 31d |
| 14368174f | Saw cut and remove remaining SOS concrete | 3d | 2013-02-15 | 2013-02-20 | 14368174d FS+90d | 26d |
| 14368174g | Remove SOS Chassis , rails and pivot bearing | 17d | 2013-02-21 | 2013-03-15 | 14368174f | 26d |
| 14368327 | Check Rail Alignment | 1d | 2013-02-21 | 2013-02-21 | 14368325 FS+27d | 707d |
| 14368335M | Central Rails for SHMS Installed (SHIELD HOUSE) | 0d | 2013-02-22 | 2013-02-22 | 14368327, 14368325 | 707d |
| 14368015 | Install Pivot for SHMS | 5d | 2013-03-26 | 2013-04-01 | 14367005, 14368173, 14368174g, 14362075a, 14368325 FS+50d, 14362075b, 3P-07M | 20d |
| 14368020 | Move Pre-Fab Compnts into Hall with road crane | 3d | 2013-04-02 | 2013-04-04 | 14362050, 14368174t, 14362030, 14368176, 14362035, 14362055, 14362035a, 14362020, 14368015, 14362015, 14362040, 14362045, 14362025, 14362050a | 20d |
| 14368175 | Ccan and platform removal | 30d | 2013-04-02 | 2013-05-13 | 14368020 FS-3d | 20d |
| 14368240 | Connect HMS Dipole to SHMS DCPS #3 | 2d | 2013-04-17 | 2013-04-18 | 14315085 FS+110d, 14368235, 14368205 | 101d |
| 14368245 | Test Power Supply DCPS #3 | 3d | 2013-04-19 | 2013-04-23 | 14368240 | 101d |
| 14368250 | Connect HMS Dipole to SHMS DCPS #4 | 2d | 2013-04-24 | 2013-04-25 | 14368245 | 101d |
| 14368255 | Test Power Supply DCPS #4 | 3d | 2013-04-26 | 2013-04-30 | 14368250 | 101d |
| 14368260 | Connect HMS Dipole to SHMS DCPS #5 | 2d | 2013-05-01 | 2013-05-02 | 14368255 | 101d |
| 14368265 | Test Power Supply DCPS #5 | 3d | 2013-05-03 | 2013-05-07 | 14368260 | 101d |
| 14368330 | Assemble Main Carriage of Supprt Struct | 60d | 2013-05-14 | 2013-08-07 | 14362060, 14368175, 14368020, 14362011 FS-125d | 20d |
| 14368115 | Prep for Vac & pressure systems Safety Review | 10d | 2013-06-25 | 2013-07-09 | 9-130M FS+180d | 58d |
| 14368280LOE | Installation Management P1 | 44d | 2013-07-01 | 2013-08-30 | 9-130M FS+184d | 20d |
| 14368120M | Comp safety Review of vacuum & pressure Vessel systems Implementn | 0d | 2013-07-09 | 2013-07-09 | 14368115 | 58d |
| 14368027 | Install Wheels and Bogies | 10d | 2013-08-08 | 2013-08-21 | 14362050, 14368330, 14362050a | 27d |
| 14368028 | Construct REAR Access Platform & Shield Wall | 17d | 2013-08-08 | 2013-08-30 | 14368330 | 20d |
| 14368333 | Install Cryo Boom Support | 2d | 2013-08-08 | 2013-08-09 | 14368330, 14364050 | 35d |
| 14368510 | Re-Baseline Actuals Adjustment | 1d | 2013-08-30 | 2013-08-30 | 9-130M FS+227d | 20d |
| 24368040 | Procure SHMS Steel Platforms and Stairs (Box O Parts) Part A | 77d | 2013-09-03 | 2013-12-20 | 9-130M FS+228d | 285d |
| 24368050 | Install SHMS Steel Procurement | 20d | 2013-09-03 | 2013-09-30 | 9-130M FS+228d | 189d |
| 24368052 | Align Wheels and Bogies on Support Structure | 4d | 2013-09-03 | 2013-09-06 | 24368050 FS-20d | 567d |
| 24368065 | Forming and Pouring Work for Concrete - Procurement | 62d | 2013-09-03 | 2013-11-27 | 9-130M FS+228d, 24368050 FS-20d | 189d |
| 24368065a | Forming and Pouring Work for Concrete - Labor FY13 | 20d | 2013-09-03 | 2013-09-30 | 9-130M FS+228d, 24368050 FS-20d | 189d |
| 24368070 | Procure Concrete for Shield House - Procurement | 62d | 2013-09-03 | 2013-11-27 | 24368065b FS-62d, 24368065a FS-62d, 24368065 FS-62d | 189d |
| 24368070a | Procure Concrete for Shield House - Labor FY13 | 20d | 2013-09-03 | 2013-09-30 | 24368065 FS-62d, 24368065a FS-62d, 24368065b FS-62d | 189d |
| 24368120 | Long-lead procurements for AC Pwr for Support Structure | 20d | 2013-09-03 | 2013-09-30 | 24368070 FS-62d, 9-130M FS+228d, 24368070a FS-62d, 24368070b FS-62d | 355d |
| 24368170 | Remove and Preserve C-Can and Lines | 20d | 2013-09-03 | 2013-09-30 | 9-130M FS+228d | 238d |
| 24368190 | Complete Readiness Review for SHMS DCPS Testing FY13 | 20d | 2013-09-03 | 2013-09-30 | 9-130M FS+228d | 326d |
| 24368575LOE | Installation Management P1 | 20d | 2013-09-03 | 2013-09-30 | 9-130M FS+228d | 439d |
| 24368015M | Cryogens Available from ESR or CHL | 0d | 2013-10-01 | 2013-10-01 | 9-140M | 309d |
| 24368020 | Cool Down HMS Dipole | 5d | 2013-10-01 | 2013-10-07 | 24368015M | 309d |
| 24368045 | Procure SHMS Steel Platforms and Stairs (Box O Parts) Part B | 87d | 2013-10-01 | 2014-02-13 | 9-140M | 255d |
| 24368065b | Forming and Pouring Work for Concrete - Labor FY14 | 42d | 2013-10-01 | 2013-11-27 | 24368065a, 24368050 FS-20d, 9-130M FS+228d | 189d |
| 24368070b | Procure Concrete for Shield House - Labor FY14 | 42d | 2013-10-01 | 2013-11-27 | 24368065 FS-62d, 24368065a FS-62d, 24368065b FS-62d, 24368070a | 189d |
| 24368190a | Complete Readiness Review for SHMS DCPS Testing FY14 | 13d | 2013-10-01 | 2013-10-17 | 24368190, 9-130M FS+228d | 326d |
| 24368580LOE | Installation Management P2 | 247d | 2013-10-01 | 2014-09-30 | 24368575LOE | 439d |
| 24368025 | Cool Down HMS Q1 | 6d | 2013-10-08 | 2013-10-15 | 24368020 | 309d |
| 24368195 | Prepare LCW for SHMS DCPS Testing | 6d | 2013-10-08 | 2013-10-15 | 24368190 FS-13d, 24368020, 24368190a FS-13d | 321d |
| 24368200 | Prepare AC Power for SHMS DCPS Testing | 6d | 2013-10-08 | 2013-10-15 | 24368020 | 321d |
| 24368030 | Cool Down HMS Q2 | 10d | 2013-10-16 | 2013-10-29 | 24368025 | 309d |
| 24368205 | Connect HMS Q1 to SHMS DCPS #1 | 2d | 2013-10-16 | 2013-10-17 | 24368025 | 319d |
| 24368210 | Test Power Supply DCPS #1 | 3d | 2013-10-18 | 2013-10-22 | 24368195, 24368205, 24368200 | 319d |
| 24368215 | Connect HMS Q1 to SHMS DCPS #2 | 2d | 2013-10-23 | 2013-10-24 | 24368210 | 319d |
| 24368220 | Test Power Supply DCPS #2 | 3d | 2013-10-25 | 2013-10-29 | 24368215 | 319d |
| 24368035 | Cool Down HMS Q3 | 10d | 2013-10-30 | 2013-11-12 | 24368030 | 309d |
| 24368060 | Construct REAR Access Platform & Shield Wall | 75d | 2013-11-01 | 2014-02-28 | 9-140M FS+23d | 301d |
| 24368075 | Re-Establish Hall-C Alignment Network After SHMS Assy | 5d | 2013-11-04 | 2013-11-08 | 24368070b FS-18d, 24368070 FS-18d, 24368070a FS-18d | 242d |
| 24368080 | Concrete Hardening Period | 30d | 2013-11-04 | 2013-12-17 | 24368070a FS-18d, 24368070b FS-18d, 24368070 FS-18d | 189d |
| 24368115 | Install LCW for Supprt Struct | 74d | 2013-11-04 | 2014-02-28 | 24368070 FS-18d, 24368070b FS-18d, 24368070a FS-18d | 257d |
| 24368225 | Connect HMS Dipole to SHMS DCPS #3 | 2d | 2013-11-13 | 2013-11-14 | 24368220, 24368035 | 309d |
| 24368230 | Test Power Supply DCPS #3 | 3d | 2013-11-15 | 2013-11-19 | 24368225 | 309d |
| 24368235 | Connect HMS Dipole to SHMS DCPS #4 | 2d | 2013-11-20 | 2013-11-21 | 24368230 | 309d |
| 24368240 | Test Power Supply DCPS #4 | 3d | 2013-11-22 | 2013-11-26 | 24368235 | 309d |
| 24368245 | Connect HMS Dipole to SHMS DCPS #5 | 2d | 2013-11-27 | 2013-12-02 | 24368240 | 309d |
| 24368175 | Install Cryo Boom Support | 27d | 2013-12-02 | 2014-01-17 | 24368170 FS+42d | 281d |
| 24368180 | Pre-Alignment SHMS Cryo Supports | 3d | 2013-12-02 | 2013-12-04 | 24368065b, 24368065, 24368065a | 305d |
| 24368250 | Test Power Supply DCPS #5 | 3d | 2013-12-03 | 2013-12-05 | 24368245 | 309d |
| 24368455 | Install QR Magnets | 19d | 2013-12-17 | 2014-01-23 | 9-140M FS+53d | 479d |
| 24368495 | Adjust Compton Elevation (Notebook) | 19d | 2013-12-17 | 2014-01-23 | 24368485 FS-162d | 474d |
| 24368085M | Shield House Concrete Work Complete | 0d | 2013-12-17 | 2013-12-17 | 24368070a, 24368080, 24368070b, 24368070 | 189d |
| 24368090 | Install Boron & Lead Shielding | 23d | 2014-01-02 | 2014-02-04 | 24368085M, 24363030aa | 186d |
| 24368125 | Install Cable Trays of Supprt Struct | 22d | 2014-01-02 | 2014-02-03 | 9-140M FS+57d, 24368085M | 276d |
| 24368500 | Install Beam Line upstream of Target (6GeV) | 1d | 2014-01-24 | 2014-01-24 | 24368495 | 536d |
| 24368130 | Install Fire Protection & Detection Sys of Supprt Struct | 21d | 2014-02-03 | 2014-03-03 | 24368085M, 9-140M FS+78d | 256d |
| 24368505 | Install, Align, Leak-check Upstream Beam-Pipes & Girders (6GEV) | 5d | 2014-02-03 | 2014-02-07 | 24368495, 24351020 | 468d |
| 24368122 | Install AC Pwr for Supprt Struct | 25d | 2014-02-04 | 2014-03-10 | 9-140M FS+79d, 24368070a FS-18d, 24368070b FS-18d, 24368070 FS-18d | 251d |

| ID | WBS | Task | Duration | Start | Finish | Predecessors | Total float |
| --- | --- | --- | --- | --- | --- | --- | --- |
| 24368095 |  | Install Doors in Shield House | 5d | 2014-02-05 | 2014-02-11 | 24363037, 24363036, 24368090, 24363035, 24363037a, 24363037b | 186d |
| 24368140 |  | Install Cable Tray & Conduits (SHIELD HOUSE) | 25d | 2014-02-05 | 2014-03-11 | 24368090, 24363036, 24363035, 24363037, 24363037a, 24363037b | 196d |
| 24368055 |  | Install SHMS Steel Platforms and Stairs | 15d | 2014-02-12 | 2014-03-04 | 24368040 FS-2d, 24368070b, 24368045 FS-2d, 24368070a, 24368070 | 255d |
| 24368097 |  | Establish Alignment Network inside SHMS Shield House | 5d | 2014-02-12 | 2014-02-18 | 24368075, 24368095 | 186d |
| 24368100 |  | Install and Align Detector Frames for DC and Rear Detectors | 5d | 2014-02-19 | 2014-02-25 | 24368075, 24368097, 24368095 | 186d |
| 24368105 |  | Fab Raised Floor (SHIELD HOUSE) | 20d | 2014-02-26 | 2014-03-25 | 24368100, 24368097, 24368090 | 186d |
| 24368475 |  | Beam-Dump Modifications & Upgrades (6GEV) | 30d | 2014-03-03 | 2014-04-11 | 24368060 | 423d |
| 24368255 |  | Pre-Align Magnet Stand Locations | 2d | 2014-03-05 | 2014-03-06 | 24368055 | 293d |
| 24368400 |  | Stack Calorimeter Blocks (SHOWER COUNTER) | 40d | 2014-03-05 | 2014-04-29 | 24368090, 24368060, 9-140M FS+100d, 24325030 | 299d |
| 24368260 |  | Pre-Align, Install and Assemble Lower Iron Yokes and HB, Q1 Stands | 5d | 2014-03-07 | 2014-03-13 | 24368255 | 293d |
| 24368135 |  | Install Mag Pwr Supplies & Utilities on Platform | 30d | 2014-03-11 | 2014-04-21 | 24368115, 24368122, 24368125, 24368130, 24368120, 24368055, 24368250 | 252d |
| 24368155 |  | Install Cables & Produce Final Drawings (CABLING) | 164d | 2014-03-12 | 2014-10-30 | 24368140, 24366025 FS-122d, 24368085M | 200d |
| 24368265 |  | Connect Mag Pwr Supplies & instrument Controls | 55d | 2014-03-14 | 2014-05-30 | 24342055, 24315036a5 FS-13d, 24315037ba, 24368135 FS-34d, 24315037b | 246d |
| 24368185 |  | Construct & Connect Cryogenic Lines | 80d | 2014-03-21 | 2014-07-14 | 24368180, 24364075, 24368175, 24364065, 24364043, 24368070, 24364043a, 24368070b, 24368070a, 24364016 | 238d |
| 24368150 |  | Install Shield House Electrical Pwr (SHIELD HOUSE) | 80d | 2014-03-26 | 2014-07-17 | 24368105, 24368140 | 186d |
| 24368270 |  | Prep for Review of Hot Check-out & Mag Control systems | 30d | 2014-04-18 | 2014-05-30 | 24368265 FS-30d | 246d |
| 24368405 |  | Connect PMTs & Cables (SHOWER COUNTER) | 40d | 2014-04-30 | 2014-06-25 | 24325027a, 24368400 | 299d |
| 24368460 |  | Install Moeller Quad #2 (6GEV) | 1d | 2014-05-14 | 2014-05-14 | 9-140M FS+150d | 474d |
| 24368275M |  | Comp safety Review of Hot Chkout procedures & Mag control systems | 0d | 2014-05-30 | 2014-05-30 | 24368270 | 246d |
| 24368280 |  | Perform Hot Check-out of Mag Pwr Supplies | 108d | 2014-06-02 | 2014-10-31 | 24368275M | 246d |
| 24368485 |  | Connect Additional Quad for Moeller polarimeter | 44d | 2014-06-13 | 2014-08-14 | 24368460 FS+20d, 24351030 | 474d |
| 24368160 |  | Install Fire Protection and Flamm Gas det. (SHIELD HOUSE) | 20d | 2014-06-19 | 2014-07-17 | 24368165 FS-20d | 186d |
| 24368410 |  | Test Calorimeter (SHOWER COUNTER) | 37d | 2014-06-26 | 2014-08-18 | 24368405 | 299d |
| 24368285M |  | Receive First Mag from vendor | 0d | 2014-07-01 | 2014-07-01 | 2-27M | 217d |
| 24368290 |  | Mount Q1 on Supprt Carriage | 5d | 2014-07-01 | 2014-07-08 | 24315036a5 FS-13d, 24315037ba FS+1d, 24312053M, 24315037b FS+1d | 273d |
| 24368165 |  | Install Shield House HVAC (SHIELD HOUSE) | 5d | 2014-07-11 | 2014-07-17 | 24368150 FS-5d | 186d |
| 24368415 |  | Install and Prep Electronics Room DAQ Racks (SHIELD HOUSE) | 20d | 2014-07-18 | 2014-08-14 | 24368160 | 186d |
| 24368145 |  | Install Drift Gas Manifold | 30d | 2014-08-01 | 2014-09-12 | 24368140, 24324005, 24368090 | 281d |
| 24368420 |  | Install Electrnc's (FAST Electrnc's) | 115d | 2014-08-15 | 2015-02-09 | 24325027a, 2433005 FS-75d, 2433000 FS-75d, 24341000, 24368415, 2433010 FS-75d, 24341000a, 24341085 | 186d |
| 24368570 |  | Install Rotation Controls of Supprt Struct | 20d | 2014-08-15 | 2014-09-12 | 24368415 | 316d |
| 24368295 |  | Mount HB on Supprt Carriage | 5d | 2014-08-26 | 2014-09-02 | 28231005, 24368290 | 269d |
| 24368300 |  | Fiducialize Magnet CL of SHMS Q1 Magnet | 1d | 2014-08-26 | 2014-08-26 | 28231010 FS-5d | 293d |
| 24368550 |  | Prep Procurement of SHMS Angle Scribe Plates | 20d | 2014-10-01 | 2014-10-28 | 9-155M | 135d |
| 24368585LOE |  | Installation Management P3 | 247d | 2014-10-01 | 2015-10-01 | 24368580LOE | 439d |
| 24368470 |  | Install Windows & Flanges | 30d | 2014-10-02 | 2014-11-12 | 24365035, 24311077, 24365040, 28231000 | 323d |
| 24368555 |  | Procure SHMS Angle Scribe Plates | 119d | 2014-10-29 | 2015-04-28 | 24368550 | 135d |
| 24368510 |  | Install Target Scattering Chamber (6GEV) | 5d | 2015-01-08 | 2015-01-14 | 24354022, 24354030b, 9-140M FS+308d | 233d |
| 24368520 |  | Prep for Vac & pressure systems Safety Review | 10d | 2015-01-12 | 2015-01-26 | 9-140M FS+310d | 80d |
| 24368515 |  | Align Target Scattering Chamber (6GEV) | 5d | 2015-01-15 | 2015-01-22 | 24368510 | 233d |
| 24368525M |  | Comp safety Review of vacuum & pressure Vessel systems Implementn | 0d | 2015-01-26 | 2015-01-26 | 24368520 | 80d |
| 24368560 |  | Install & Align SHMS Angle Scribe Plates | 10d | 2015-04-29 | 2015-05-12 | 24368070, 24368070b, 24368555, 24368070a | 135d |
| 24368465 |  | Install Beam Stands (Beam Pipe) | 5d | 2015-05-04 | 2015-05-08 | 24368055, 24368085M, 24355025, 24355005, 24355010, 24355015 | 112d |
| 24368480 |  | Install Beam Pipe and Vac Fittings | 5d | 2015-05-11 | 2015-05-15 | 24355020, 24355030 FS-5d, 24368465 | 112d |
| 24368565 |  | Install SHMS Position Readback System | 20d | 2015-05-13 | 2015-06-11 | 24368560, 24368415 | 135d |
| 24368490 |  | Leak Test Beam Pipe Vac Sys | 5d | 2015-05-18 | 2015-05-22 | 24368480 | 112d |
| 24368305 |  | Final Assemble & Mount Dipole on Supprt Carriage | 20d | 2015-05-19 | 2015-06-17 | 24368070b, 24368260, 24368070a, 24368097, 24368255, 24314050M, 24368070, 24368100, 24368285M | 0d |
| 24368310 |  | Install & Connect Magnet Insulating Vac system | 30d | 2015-05-19 | 2015-07-01 | 24365020b, 24365025, 24365020, 24368525M, 24365020a, 24368305 FS-20d | 0d |
| 24368315 |  | Inspect & Assemble Upper Iron Yoke & Stands for Dipole magnet | 3d | 2015-06-18 | 2015-06-22 | 24368305 | 7d |
| 24368425 |  | Fiducialize SHMS Aerogel Cerenkov Counter (6GEV) | 1d | 2015-06-18 | 2015-06-18 | 24368305 | 48d |
| 24368430 |  | Fiducialize SHMS Drift Ch's, Hodoscopes, Cerenkovs, Preshower | 5d | 2015-06-18 | 2015-06-24 | 24368305 | 44d |
| 24368435 |  | Install Detctr's in Shield House REAR | 65d | 2015-06-25 | 2015-09-25 | 24328010ba, 24368095, 24368155, 24368090, 24323005b, 24368400, 24368425, 24368430, 24363060 | 44d |
| 24368325 |  | Assemble Upper Iron Yoke & Stands for Q2 magnet | 3d | 2015-07-16 | 2015-07-20 | 24368340 FS-27d, 24368350 FS-34d, 28236005 FS-34d | 2d |
| 24368340 |  | Mount Q2 on Supprt Carriage | 5d | 2015-07-16 | 2015-07-22 | 24314035a FS-34d, 24315037ba FS+1d, 24368350 FS-34d, 24314035 FS-34d, 2-30M, 28236005 FS-34d, 24315037b FS+1d | 0d |
| 24368335M |  | First New SC Mag Cooled Down in place | 0d | 2015-08-07 | 2015-08-07 | 28236000, 24368185 | 61d |
| 24368350 |  | Fiducialize Magnet CL of SHMS Dipole Magnet | 3d | 2015-08-26 | 2015-08-28 | 24314035a FS-5d | 2d |
| 24368360 |  | Assemble Upper Iron Yoke & Stands for Q3 magnet | 3d | 2015-09-02 | 2015-09-04 | 28236005, 24314035a, 24368370 FS-7d, 24368350 | 3d |
| 24368365 |  | Finucialize Magnet CL of SHMS Q2 Magnet | 1d | 2015-09-02 | 2015-09-02 | 28236015 FS-1d | 42d |
| 24368440 |  | Install Shutter Exit Window | 5d | 2015-09-02 | 2015-09-09 | 28236005 | 26d |
| 24368370 |  | Mount Q3 on Supprt Carriage | 5d | 2015-09-03 | 2015-09-10 | 28236010, 2-31M, 24315037ba FS+1d, 24315037b FS+1d, 24368340 | 0d |
| 24368445 |  | Install Detctr's in Shield House FWD | 30d | 2015-09-10 | 2015-10-21 | 24363060, 24328010ba, 24368095, 24368440, 24368155, 24323012, 24323025, 24368090, 24368430, 24321015M, 24323005b | 26d |
| 24368450 |  | Hot Check-out of Detctr's in Shield House | 40d | 2015-09-28 | 2015-11-20 | 24368445 FS-18d, 24368410, 24368145, 24368435 FS-18d, 24368420 | 26d |
| 24368590LOE |  | Installation Management P4 | 56d | 2015-10-02 | 2015-12-22 | 24368585LOE | 439d |
| 24368110 |  | Install Roof Beams and Wall Blocks in Shield House | 1d | 2015-10-22 | 2015-10-22 | 24368435, 24368445 | 42d |
| 24368390 |  | Finucialize Magnet CL of SHMS Q3 Magnet | 1d | 2015-11-02 | 2015-11-02 | 28236025 FS-1d | 0d |
| 24368530 |  | Install & Connect Spectrometer Vac system | 25d | 2015-11-03 | 2015-12-09 | 28236025, 24365050, 24365045, 24368525M, 24368490, 24354030, 24365047, 24368390, 28231000, 24354030b | 0d |
| 24368535 |  | Install Spool & Bellows for All Magnets | 25d | 2015-11-03 | 2015-12-09 | 28231000, 28236025, 24368390, 24365032, 24365030 | 0d |
| 24368540 |  | Install Slit Controls | 10d | 2015-12-10 | 2015-12-23 | 24368530, 24368440 FS-60d, 24365050, 24368470 FS-60d, 24368535 | 0d |
| 24368545 |  | Install Sieve Slit Sys | 10d | 2015-12-10 | 2015-12-23 | 24368470 FS-60d, 24368535, 24365045, 24365047, 24368530 | 0d |
|  | 5 | **1.5 CONSTRUCTION HALL D** |  | 2008-10-01 | 2015-04-01 |  |  |
|  | 1 | **1.5.1 SOLENOID** |  | 2008-10-01 | 2013-09-30 |  |  |

| ID | Task | Duration | Start | Finish | Predecessors | Total float |
| --- | --- | --- | --- | --- | --- | --- |
| 151000 | Ship Iron to contractor (SOLENOID) | 10d | 2008-10-01 | 2008-10-14 | 9-090M | 925d |
| 151001 | Modify Iron Pole (SOLENOID) | 40d | 2008-10-15 | 2008-12-11 | 151000 | 925d |
| 151002 | Ship Iron to Jlab (SOLENOID) | 10d | 2008-12-12 | 2009-01-02 | 151001 | 925d |
| 151009E | FY09 Travel (SOLENOID) | 189d | 2009-01-02 | 2009-09-30 | 151009E5 | 431d |
| 151000a | Labr/Exp to Proc/Assy/Test Rack for Coil Control + 1 Module (SOLENOIID) FY09 | 86d | 2009-06-01 | 2009-09-30 | 9-090M FS+162d | 383d |
| 151000c | Design Test Platform (SOLENOID) | 66d | 2009-06-01 | 2009-09-01 | 9-090M FS+162d | 402d |
| 151000e | Write Controls for Solenoid (SOLENOID) | 85d | 2009-06-01 | 2009-09-29 | 9-090M FS+162d | 383d |
| 151000d | Design Yoke Baffles (SOLENOID) | 64d | 2009-07-01 | 2009-09-30 | 9-090M FS+184d | 382d |
| 151000b | Procure Rack for Coil Control + 1 Module Set for 1 Coil (SOLENOIID) | 60d | 2009-07-14 | 2009-10-06 | 151000aB FS-110d | 383d |
| 151000aB | Labr/Exp to Proc/Assy/Test Rack for Coil Control + 1 Module (SOLENOIID) FY10 | 54d | 2009-10-01 | 2009-12-17 | 151000a | 383d |
| 151000f | Prepare Procurements/Fabrication Packages 2010 (SOLENOID) | 60d | 2009-10-01 | 2010-01-04 | 9-100M, 151000b FS-5d, 151000d, 151000e, 151000c | 382d |
| 151010E | FY10 Travel (SOLENOID) | 248d | 2009-10-01 | 2010-09-30 | 151009E | 431d |
| 151020 | Control Cabling fab (SOLENOID) | 60d | 2009-10-01 | 2010-01-04 | 9-100M | 517d |
| 151015 | Dsgn Ring Girders (SOLENOID) | 40d | 2010-01-05 | 2010-03-03 | 9-100M FS+60d | 637d |
| 151023 | Design Iron Spacers (SOLENOID) | 40d | 2010-01-05 | 2010-03-03 | 151020 | 517d |
| 151030 | Dsgn Missing Mounts (SOLENOID) | 20d | 2010-01-05 | 2010-02-02 | 9-100M FS+60d | 537d |
| 151040 | Fab Stands (SOLENOID) | 80d | 2010-01-05 | 2010-04-28 | 9-100M FS+60d | 597d |
| 151000g | Evaluate Procurements 2010 (SOLENOID) | 43d | 2010-02-02 | 2010-04-02 | 151000f FS+19d | 382d |
| 151033 | Fabricate Missing Mounts (SOLENOID) | 40d | 2010-02-03 | 2010-03-31 | 151030 | 537d |
| 151025 | Fab Iron Spacers (SOLENOID) | 120d | 2010-03-04 | 2010-08-20 | 151023, 9-100M FS+60d | 517d |
| 151035 | Fab Ring Girders (SOLENOID) | 80d | 2010-04-01 | 2010-07-23 | 151033, 151000g FS-5d, 9-100M FS+60d | 537d |
| 151000h | Track Fabrication 2010 (SOLENOID) | 66d | 2010-05-03 | 2010-08-04 | 151000g FS+20d | 382d |
| 151000i | Acceptance Checks/Documentation 2010 (SOLENOID) | 64d | 2010-05-28 | 2010-08-27 | 151000h FS-47d | 382d |
| 151011E | FY11 Travel (SOLENOID) | 248d | 2010-10-01 | 2011-09-30 | 151010E | 431d |
| 151000j | Labor for Procurmnt Prep of 3 Module Sets for 3 Coils (SOLENOID) | 10d | 2010-12-14 | 2011-01-04 | 9-110M FS+50d, 151000i | 309d |
| 151171 | Prpare Procurement Packages for Cladding | 62d | 2011-01-04 | 2011-04-01 | 9-110M FS+59d | 208d |
| 151000k | Procurmnt of 3 Module Sets for 3 Coils (SOLENOID) Part A | 65d | 2011-01-05 | 2011-04-07 | 151000j | 309d |
| 151000ka | Procurmnt of 3 Module Sets for 3 Coils (SOLENOID) Part B | 65d | 2011-01-05 | 2011-04-07 | 151000j | 309d |
| 151045 | Set Up Solenoid Test Area (SOLENOID) (IPL 551400LOE) | 22d | 2011-08-30 | 2011-09-29 | 9-110M FS+225d, 2-16M, 2-10M FS+12d | 112d |
| 151050 | Move Solenoid to H-D (SOLENOID) (IPL 551360) | 15d | 2011-10-03 | 2011-10-21 | 151030, 151015, 16331032, 151025, 3P-23M, 16331030, 151035, 151020, 151040, 151002, 151045 FS+1d | 241d |
| 151060 | Install Solenoid Stands (SOLENOID) | 15d | 2011-10-03 | 2011-10-21 | 151045 FS+1d | 148d |
| 151085 | Install Yoke mounts (SOLENOID) | 15d | 2011-10-03 | 2011-10-21 | 151045 FS+1d | 148d |
| 151147 | Safety Review (SOLENOID) | 36d | 2011-10-03 | 2011-11-21 | 151045 FS+1d | 149d |
| 151160 | Install US Pole (SOLENOID) | 3d | 2011-10-12 | 2011-10-14 | 151060 FS-8d, 151085 FS-8d | 148d |
| 151090 | Install Yoke 1 (SOLENOID) | 5d | 2011-10-17 | 2011-10-21 | 151160 | 148d |
| 151095 | Install Coil 1 (SOLENOID) | 3d | 2011-10-24 | 2011-10-26 | 151090 | 148d |
| 151100 | Install Iron Spacer/Ring Girder 1 (SOLENOID) | 2d | 2011-10-27 | 2011-10-28 | 151095 | 148d |
| 151105 | Install Yoke 2 (SOLENOID) | 2d | 2011-10-31 | 2011-11-01 | 151100 | 148d |
| 151171a | Procure Cladding | 99d | 2011-11-01 | 2012-03-30 | 151171, 9-120M FS+21d | 60d |
| 151110 | Install Coil 2 (SOLENOID) | 1d | 2011-11-02 | 2011-11-02 | 151105 | 148d |
| 151115 | Install Iron Spacer/Ring Girder 2 (SOLENOID) | 2d | 2011-11-03 | 2011-11-04 | 151110 | 148d |
| 151120 | Install Yoke 3 (SOLENOID) | 2d | 2011-11-07 | 2011-11-08 | 151115 | 148d |
| 151125 | Install Coil 3 (SOLENOID) | 1d | 2011-11-09 | 2011-11-09 | 151120 | 148d |
| 151130 | Install Iron Spacer/Ring Girder 3 (SOLENOID) | 2d | 2011-11-10 | 2011-11-11 | 151125 | 148d |
| 151135 | Install Yoke 4 (SOLENOID) | 2d | 2011-11-14 | 2011-11-15 | 151130 | 148d |
| 151140 | Install Coil 4 (SOLENOID) | 3d | 2011-11-16 | 2011-11-18 | 151135 | 148d |
| 151145 | Install Iron Spacer/Ring Girder 4 (SOLENOID) | 2d | 2011-11-21 | 2011-11-22 | 151140 | 148d |
| 151170 | Install DS Pole (SOLENOID) (IPL) | 1d | 2011-11-23 | 2011-11-23 | 151147, 151145 | 148d |
| 151150 | Elect Test Coils (SOLENOID) | 5d | 2011-11-28 | 2011-12-02 | 151000ka, 151000k, 151170, 151147 | 148d |
| 151155 | Leak Test Coils (SOLENOID) | 10d | 2011-12-05 | 2011-12-16 | 151150 | 148d |
| 151055 | Install DC Sys (SOLENOID) | 34d | 2012-01-13 | 2012-03-02 | 151045 FS+67d | 112d |
| 151065 | Install Solenoid Controls (SOLENOID) (IPL) | 34d | 2012-01-13 | 2012-03-02 | 151045 FS+67d | 112d |
| 151173 | Develop cryo/magnet elect/pipe interface | 44d | 2012-02-03 | 2012-04-05 | 9-120M FS+80d | 190d |
| 151173a | Procure elec/piping interface hardware Part A | 103d | 2012-02-03 | 2012-06-29 | 151173 FS-44d | 190d |
| 151173aa | Procure elec/piping interface hardware Part B | 103d | 2012-02-03 | 2012-06-29 | 151173 FS-44d | 190d |
| 151173j | Develop shims and baffle support | 56d | 2012-02-03 | 2012-04-23 | 9-120M FS+80d | 277d |
| 151173c | Develop solenoid vacuum manifold | 63d | 2012-02-06 | 2012-05-03 | 9-120M FS+81d | 217d |
| 151173g | FMEA for solenoid | 12d | 2012-02-06 | 2012-02-22 | 9-120M FS+81d | 338d |
| 151173d | Procure solenoid vacuum manifold Part A | 83d | 2012-03-05 | 2012-06-29 | 151173c FS-44d | 217d |
| 151173d5 | Procure solenoid vacuum manifold Part B | 83d | 2012-03-05 | 2012-06-29 | 151173c FS-44d | 217d |
| 151173k | Procure shims and baffle support | 62d | 2012-03-06 | 2012-05-31 | 151173j FS-35d | 277d |
| 151172 | Install Cladding (SOLENOID) | 24d | 2012-04-10 | 2012-05-11 | 151171a FS+6d, 151170 | 60d |
| 151173n | Install shims and baffle support | 46d | 2012-04-19 | 2012-06-25 | 151173k FS-30d | 277d |
| 151070 | Install DC Buswork (SOLENOID) | 20d | 2012-05-04 | 2012-06-01 | 151055 FS+44d, 151050, 151065 FS+44d | 112d |
| 151075 | Test DC Sys (SOLENOID) | 20d | 2012-05-04 | 2012-06-01 | 151070 FS-20d | 112d |
| 151080 | Install Controls Cabling (SOLENOID) | 20d | 2012-05-04 | 2012-06-01 | 151075 FS-20d | 112d |
| 151173f | Install solenoid vacuum manifold | 51d | 2012-06-01 | 2012-08-13 | 151173d5 FS-20d, 151173d FS-20d | 217d |
| 151175 | Connect Coils (SOLENOID) (IPL) | 45d | 2012-07-27 | 2012-09-28 | 151172, 13321070 FS-45d, 151170 | 8d |
| 151185 | Elect Test Solenoid (SOLENOID) | 10d | 2012-09-17 | 2012-09-28 | 151175 FS-10d | 8d |
| 151250M | Installtn of Solenoid Comptd (SOLENOID) | 0d | 2013-02-20 | 2013-02-20 | 151173f, 151173g, 151011E, 18241040, 18241000, 18241005 | 91d |

| ID | WBS | Task | Duration | Start | Finish | Predecessors | Total float |
| --- | --- | --- | --- | --- | --- | --- | --- |
| 151255 |  | Re-Baseline Actuals Adjustment | 1d | 2013-08-30 | 2013-08-30 | 9-130M FS+227d | 20d |
| 251173f |  | Install solenoid vacuum manifold | 10d | 2013-09-03 | 2013-09-16 | 9-130M FS+228d | 64d |
| 251195 |  | Repair Solenoid Vac Leaks | 4d | 2013-09-03 | 2013-09-06 | 9-130M FS+228d | 0d |
| 251666 |  | Consultant Fee (Quench Study WS) | 20d | 2013-09-03 | 2013-09-30 | 9-130M FS+228d | 247d |
| 251250M |  | Installtn of Solenoid Comptd (SOLENOID) | 0d | 2013-09-16 | 2013-09-16 | 251173f | 64d |
|  | 2 | **1.5.2 DETECTORS** |  | 2008-12-01 | 2014-04-21 |  |  |
|  | 1 | **1.5.2.1 TRACKING** |  | 2009-01-02 | 2014-04-21 |  |  |
|  | 1 | **1.5.2.1.1 FORWARD CHAMBERS** |  | 2009-01-02 | 2014-03-31 |  |  |
| 15211009E |  | FY09 Travel (FWD Chambers) | 189d | 2009-01-02 | 2009-09-30 | 15211009EX | 64d |
| 15211000a |  | Procurement for Testing the Assembly Proceedure (FWD Chambers) | 65d | 2009-06-01 | 2009-08-31 | 9-090M FS+162d | 850d |
| 15211000b |  | Testing the Assembly Procedure (FWD Chambers) | 86d | 2009-06-01 | 2009-09-30 | 15211000a FS-106d, 9-090M FS+162d | 809d |
| 15211001a |  | Prepare Procurements/Fabrication Packages 2010 (FWD Chambers) | 86d | 2009-06-01 | 2009-09-30 | 9-090M FS+162d | 755d |
| 15211010E |  | FY10 Travel (FWD Chambers) | 248d | 2009-10-01 | 2010-09-30 | 15211009E | 146d |
| 15211001b |  | Evaluate Procurements 2010 (FWD Chambers) | 6d | 2009-12-18 | 2010-01-04 | 15211000b, 15211001a FS+54d | 755d |
| 15211001c |  | Track Fabrication 2010 (FWD Chambers) | 130d | 2010-01-05 | 2010-07-09 | 9-100M FS+60d | 745d |
| 15211002a |  | Engineering Support for Assembly FY10 (FWD Chambers) | 188d | 2010-01-05 | 2010-09-30 | 15211009E FS+60d | 64d |
| 15211020 |  | ProcFirst Article PC Boards Cathode Kapton Foil (FWD Chambers) | 102d | 2010-01-05 | 2010-05-28 | 12321018M, 9-100M FS+60d | 63d |
| 15211022 |  | Procuremnt of Rigid Flex Assemblies (FWD Chambers) | 80d | 2010-01-05 | 2010-04-28 | 9-100M FS+60d, 12321018M | 300d |
| 15211025 |  | Proc Wire (Field, sense) (FWD Chambers) | 130d | 2010-01-05 | 2010-07-09 | 9-100M FS+60d, 12321018M | 176d |
| 15211030 |  | Proc First Article On-Chamb Electrnc's (capacitors, resistors) (FWD Chambers) | 102d | 2010-01-05 | 2010-05-28 | 9-100M FS+60d | 159d |
| 15211100 |  | Fab Setup (FWD Chambers) | 110d | 2010-01-05 | 2010-06-10 | 9-100M FS+60d, 15211002a FS-190d | 225.5d |
| 15211005 |  | Proc Chamb Frames (G10) (FWD Chambers) | 135d | 2010-05-14 | 2010-11-23 | 9-100M FS+151d, 12321018M | 109.5d |
| 15211015 |  | Proc PC Boards (G10) (FWD Chambers) | 89d | 2010-05-14 | 2010-09-20 | 12321018M, 9-100M FS+151d | 163.5d |
| 15211020a |  | Proc Production PC Boards Cathode Kapton Foil (FWD Chambers) | 130d | 2010-05-14 | 2010-11-16 | 15211020 FS-11d | 63d |
| 15211030a |  | Proc Production On-Chamb Electrnc's (capacitors, resistors) (FWD Chambers) | 130d | 2010-05-14 | 2010-11-16 | 15211030 FS-11d | 159d |
| 15211035 |  | Proc Chamb Preamps (ASIC Dsgn) (FWD Chambers) Labor FY10 | 68d | 2010-06-25 | 2010-09-30 | 9-100M FS+180d | 221d |
| 15211001d |  | Acceptance Checks/Documentation 2010 (FWD Chambers) | 44d | 2010-07-01 | 2010-09-01 | 9-100M FS+184d | 709d |
| 15211090 |  | Test Wire (Field, sense) (FWD Chambers) FY10 | 57.5d | 2010-07-12 | 2010-09-30 | 15211025 | 176d |
| 15211080 |  | Test PC Boards (G10) (FWD Chambers) FY10 | 7.5d | 2010-09-21 | 2010-09-30 | 15211015 | 163.5d |
| 15211080a |  | Test PC Boards (G10) (FWD Chambers) FY11 | 29d | 2010-09-30 | 2010-11-10 | 15211080 | 163.5d |
| 15211090a |  | Test Wire (Field, sense) (FWD Chambers) FY11 | 16.5d | 2010-09-30 | 2010-10-22 | 15211090 | 176d |
| 15211002b |  | Engineering Support for Assembly FY11 (FWD Chambers) | 248d | 2010-10-01 | 2011-09-30 | 15211002a | 64d |
| 15211011E |  | FY11 Travel (FWD Chambers) | 248d | 2010-10-01 | 2011-09-30 | 15211010E | 146d |
| 15211035a |  | Proc Chamb Preamps (ASIC Dsgn) (FWD Chambers) Labor FY11 | 62d | 2010-10-01 | 2011-01-06 | 15211035 | 221d |
| 15211140 |  | G10 PC Board Prep (FWD Chambers) | 36.5d | 2010-11-10 | 2011-01-11 | 15211080a | 202d |
| 15211085 |  | Test PC Boards (Flex) (FWD Chambers) | 73.5d | 2010-11-17 | 2011-03-14 | 15211020, 15211020a | 63d |
| 15211155 |  | Mount on-Chamb Electrnc's (FWD Chambers) | 26d | 2010-11-17 | 2010-12-31 | 9-110M FS+33d | 430d |
| 15211105 |  | Wire Chamb Frames Prep (FWD Chambers) | 36.5d | 2010-11-24 | 2011-01-26 | 15211100, 15211002a FS-55d, 15211005, 197111030M | 109.5d |
| 15211102 |  | Set-up Clean Room for Production | 34d | 2011-01-04 | 2011-02-22 | 9-110M FS+59d | 91d |
| 15211145 |  | Procurement of Consumables for Fab (2011) (FWD Chambers) | 189d | 2011-01-04 | 2011-09-30 | 15211140 FS-10d, 9-110M FS+59d | 198d |
| 15211050 |  | Proc Cables,Connectors (HV, LV, Signal, Gas) (FWD Chambers) | 130d | 2011-01-05 | 2011-07-11 | 9-110M FS+60d | 172d |
| 15211070 |  | Proc Gas Connections (FWD Chambers) | 130d | 2011-01-05 | 2011-07-11 | 9-110M FS+60d | 236d |
| 15211035b |  | ASIC Fabrication (FDC&CDC) | 60d | 2011-03-07 | 2011-05-27 | 1546005, 9-100M FS+180d | 77d |
| 15211163 |  | Manufacture All Cables & QA (FWD Chambers) | 110d | 2011-03-14 | 2011-08-16 | 15211050 FS-84d | 172d |
| 15211120 |  | Cathode Frame Inspection (FWD Chambers) | 22d | 2011-03-15 | 2011-04-13 | 15211002b FS-233d, 15211100, 15211085 FS+0.5d | 63d |
| 15211125 |  | Cell #1Assy. (FWD Chambers) | 22d | 2011-04-01 | 2011-05-02 | 15211100, 15211105, 15211002b FS-128d, 15211102 | 64d |
| 15211126 |  | Package #1 Fabrication (FWD Chambers) | 119d | 2011-04-14 | 2011-09-30 | 15211120, 15211080a, 15211090a, 15211022, 15211125 FS-14d, 15211002b FS-245d, 15211030a | 63d |
| 15211163a |  | Support for procurement of parts for gas system (FWD Chambers) | 66d | 2011-06-01 | 2011-09-01 | 9-110M FS+162d | 198d |
| 15211002c |  | Additional Engineering Support for Assembly FY12 (FWD Chambers) | 84d | 2011-06-03 | 2011-09-30 | 15211002b FS-84d | 628d |
| 15211060 |  | Proc Cooling Sys (FWD Chambers) Part A | 64d | 2011-07-01 | 2011-09-30 | 9-110M FS+184d | 346d |
| 15211060a |  | Proc Cooling Sys (FWD Chambers) Part B | 64d | 2011-07-01 | 2011-09-30 | 9-110M FS+184d | 346d |
| 15211130 |  | Package #2 Fabrication (FWD Chambers) FY11 | 9d | 2011-09-20 | 2011-09-30 | 15211126 FS-9d | 63d |
| 15211012E |  | FY12 Travel (FWD Chambers) | 247d | 2011-10-03 | 2012-09-28 | 15211011E | 146d |
| 15211075 |  | Proc Supprt Frame (FWD Chambers) Part A | 87d | 2011-10-03 | 2012-02-13 | 15211001b FS-60d, 15211001c FS-180d, 15211001d FS-182d, 9-120M | 259d |
| 15211075a |  | Proc Supprt Frame (FWD Chambers) Part B | 87d | 2011-10-03 | 2012-02-13 | 15211001c FS-180d, 15211001b FS-60d, 9-120M, 15211001d FS-182d | 259d |
| 15211094 |  | Acceptance Preamp Daughter Board (FWD Chambers) | 178d | 2011-10-03 | 2012-06-22 | 15211035b, 15211035a, 9-120M | 35d |
| 15211130a |  | Package #2 Fabrication (FWD Chambers) FY12 | 100.5d | 2011-10-03 | 2012-03-05 | 15211130 | 63d |
| 15211190 |  | Procurement of Consumables for Fab (2012) (FWD Chambers) | 247d | 2011-10-03 | 2012-09-28 | 9-120M | 71d |
| 15211135 |  | Package #3 Fabrication (FWD Chambers) | 116d | 2012-02-21 | 2012-08-03 | 15211130a FS-9d | 63d |
| 15211249 |  | Construct/Install/Test HV Sys (FWD Chambers) | 68d | 2012-03-12 | 2012-06-15 | 9-120M FS+105d, 15211163 | 35d |
| 15211250 |  | Construct/Install/Test LV Sys ((FWD Chambers) | 68d | 2012-03-12 | 2012-06-15 | 9-120M FS+105d | 35d |
| 15211095 |  | Test Electrnc's (FWD Chambers) | 127d | 2012-03-26 | 2012-09-21 | 9-120M FS+115d | 36d |
| 15211164 |  | Construct/ Test Gas System (FWD Chambers) | 43d | 2012-05-01 | 2012-07-02 | 9-120M FS+141d, 15211070, 15211163a, 15211002b FS-245d | 37d |
| 15211150 |  | Package #1 Final Assy. and Testing (FWD Chambers) | 43d | 2012-06-25 | 2012-08-22 | 1546090, 15211249 FS-10d, 15211164 FS-23d, 15211095 FS-80d, 15211145, 15211094 FS-15d, 15211250 FS-10d | 20d |
| 15211141 |  | Package #4 Fabrication (FWD Chambers) FY12 | 55.5d | 2012-07-12 | 2012-09-28 | 15211135 FS-16d | 63d |
| 15211195 |  | Cell #25 Assy. (FWD Chambers) | 22d | 2012-08-03 | 2012-09-05 | 15211135 | 468.5d |
| 15211155a |  | Package #2 Final Assy. and Testing (FWD Chambers) FY12 | 26d | 2012-08-23 | 2012-09-28 | 15211150, 15211155 | 20d |
| 15211200 |  | Cell #26 Assy. (FWD Chambers) | 20d | 2012-08-24 | 2012-09-24 | 15211195 FS-7d | 468.5d |
| 15211141a |  | Package #4 Fabrication (FWD Chambers) FY13 | 2d | 2012-10-01 | 2012-10-02 | 15211141 | 63d |
| 15211155aa |  | Package #2 Final Assy. and Testing (FWD Chambers) FY13 | 15d | 2012-10-01 | 2012-10-19 | 15211155a | 20d |

| ID | WBS | Task | Duration | Start | Finish | Predecessors | Total float |
| --- | --- | --- | --- | --- | --- | --- | --- |
| 15211160 |  | 3rd Package Final Assy. and Testing (FWD Chambers) | 45d | 2012-10-01 | 2012-12-04 | 15211155aa FS-15d, 15211155 | 20d |
| 15211191 |  | Procurement of Consumables for Fab (2013) (FWD Chambers) | 100d | 2012-10-01 | 2013-03-01 | 15211190 | 71d |
| 15211165 |  | 4th Package Final Assy. and Testing (FWD Chambers) | 71d | 2012-12-05 | 2013-03-25 | 15211141a, 15211160 | 20d |
| 15211175 |  | Complete Package Assy (FWD Chambers) | 47d | 2013-01-31 | 2013-04-08 | 15211165 FS-37d, 15211075a, 15211160, 15211075, 15211060, 15211150, 15211060a, 15211135, 15211145 | 20d |
| 15211220 |  | Final Testing (FWD Chambers) | 40d | 2013-02-04 | 2013-04-01 | 15211145, 15211175 FS-45d | 25d |
| 15211230 |  | Alignment Procedures (FWD Chambers) | 10d | 2013-03-08 | 2013-03-21 | 15211175 FS-22d, 15211002c FS-245d | 32d |
| 15211205 |  | Cell #27 Assy. (FWD Chambers) | 19.5d | 2013-04-01 | 2013-04-26 | 15211200 FS-7d, 9-130M FS+120d | 337d |
| 15211185 |  | Fiducialize complete package (FWD Chambers) | 5d | 2013-04-02 | 2013-04-08 | 15211175 FS-5d | 20d |
| 15211210 |  | Cell #28 Assy. (FWD Chambers) | 24.5d | 2013-04-19 | 2013-05-23 | 15211205 FS-5d | 337d |
| 15211255 |  | Re-Baseline Actuals Adjustment | 1d | 2013-08-30 | 2013-08-30 | 9-130M FS+227d | 20d |
| 25211172 |  | Resolution_studies_(FWD_Chambers) FY13 | 20d | 2013-09-03 | 2013-09-30 | 9-130M FS+228d | 0d |
| 25211175 |  | Complete Package Mechanical Assy (FWD Chambers) FY13 | 20d | 2013-09-03 | 2013-09-30 | 9-130M FS+228d | 56d |
| 25211191 |  | Procurement of Consumables for Fab (2013) (FWD Chambers) | 20d | 2013-09-03 | 2013-09-30 | 9-130M FS+228d | 42d |
| 25211208 |  | Assemble and Electrical Test of Package R (FDC) | 20d | 2013-09-03 | 2013-09-30 | 9-130M FS+228d | 1d |
| 25211217 |  | Cooling system assembly FY13 | 20d | 2013-09-03 | 2013-09-30 | 9-130M FS+228d | 204d |
| 25211220 |  | Final Testing (FWD Chambers) | 20d | 2013-09-03 | 2013-09-30 | 25211175 FS-30d, 25211175a FS-30d | 56d |
| 25211250 |  | Disassembly of the construction equipment and site - labor and forklift lease | 20d | 2013-09-03 | 2013-09-30 | 25211208 FS-20d | 247d |
| 25211255LOE |  | Pick-up Truck Lease | 139d | 2013-09-03 | 2014-03-31 | 25211208 FS-20d | 128d |
| 25211255LOE5 |  | Blue Crab Cleaning (Previously Obligated) | 20d | 2013-09-03 | 2013-09-30 | 25211208 FS-20d | 247d |
| 25211260 |  | Develop algorithm for fADC125 readout FY13 | 20d | 2013-09-03 | 2013-09-30 | 9-130M FS+228d | 178d |
| 25211172a |  | Resolution_studies_(FWD_Chambers) FY14 | 10d | 2013-10-01 | 2013-10-14 | 25211172, 9-130M FS+228d | 0d |
| 25211175a |  | Complete Package Mechanical Assy (FWD Chambers) FY14 | 10d | 2013-10-01 | 2013-10-14 | 25211175, 9-130M FS+228d | 56d |
| 25211217a |  | Cooling system assembly FY14 | 43d | 2013-10-01 | 2013-12-02 | 9-130M FS+228d, 25211217 | 204d |
| 25211260a |  | Develop algorithm for fADC125 readout FY14 | 69d | 2013-10-01 | 2014-01-17 | 9-130M FS+228d, 25211260 | 178d |
|  | 2 | **1.5.2.1.2 CENTRAL CHAMBERS** |  | 2009-01-02 | 2014-04-21 |  |  |
| 15212009E |  | FY09 Travel (CENT CHAMB) | 189d | 2009-01-02 | 2009-09-30 | 15212009EX | 119d |
| 15212005 |  | Proc Straws (CENT CHAMB) | 65d | 2009-01-05 | 2009-04-07 | 12321018M, 9-090M FS+60d | 783d |
| 15212010 |  | Proc Wire (CENT CHAMB) | 130d | 2009-01-05 | 2009-07-09 | 9-090M FS+60d, 12321018M | 707d |
| 15212070 |  | Proc Epoxy (CENT CHAMB) (Frozen by CR10-007) | 130d | 2009-01-05 | 2009-07-09 | 9-090M FS+60d, 12321018M | 306d |
| 15212090 |  | Test Straws (CENT CHAMB) | 11d | 2009-04-08 | 2009-04-22 | 15212005 | 783d |
| 15212000a |  | Prepare Procurements/Fabrication Packages 2009 (CENT CHAMB) | 86d | 2009-06-01 | 2009-09-30 | 9-090M FS+162d | 582d |
| 15212015 |  | Proc Feedthroughs (CENT CHAMB) | 130d | 2009-06-01 | 2009-12-03 | 9-090M FS+60d, 12321018M, 15212000a FS-86d | 605d |
| 15212020 |  | Proc Crimp pins (CENT CHAMB) | 130d | 2009-06-01 | 2009-12-03 | 12321018M, 9-090M FS+60d, 15212000a FS-86d | 617d |
| 15212040 |  | Proc endplates (CENT CHAMB) | 155d | 2009-06-01 | 2010-01-15 | 9-090M FS+60d, 12321018M, 15212000a FS-86d, 15212000c FS-245d, 15212000d FS-245d | 582d |
| 15212050 |  | Proc Stand-offs (CENT CHAMB) | 85d | 2009-06-01 | 2009-09-29 | 15212000a FS-86d, 9-090M FS+60d, 12321018M | 672d |
| 15212095 |  | Check Wire Quality (CENT CHAMB) | 22d | 2009-07-10 | 2009-08-10 | 15212010 | 707d |
| 15212000c |  | Support Parts Fabrication 2010 (CENT CHAMB) | 69d | 2009-10-01 | 2010-01-15 | 9-100M | 672d |
| 15212010E |  | FY10 Travel (CENT CHAMB) | 248d | 2009-10-01 | 2010-09-30 | 15212009E | 119d |
| 15212075 |  | Reverse Entry per CR10-007 | 1d | 2009-12-01 | 2009-12-01 | 9-100M FS+41d | 206d |
| 15212100 |  | Check Feedthroughs (CENT CHAMB) | 22d | 2009-12-04 | 2010-01-12 | 15212015 | 605d |
| 15212105 |  | Check Crimp pins (CENT CHAMB) | 11d | 2009-12-04 | 2009-12-18 | 15212020 | 617d |
| 15212025 |  | Proc HV Cables (CENT CHAMB) | 130d | 2010-01-05 | 2010-07-09 | 9-100M FS+60d | 482d |
| 15212035 |  | Proc Gas Connectors (CENT CHAMB) | 65d | 2010-01-05 | 2010-04-07 | 9-100M FS+60d | 546d |
| 15212080 |  | Proc First Article Preamps (CENT CHAMB) | 102d | 2010-01-05 | 2010-05-28 | 9-100M FS+60d | 272d |
| 15212000d |  | Acceptance Checks/Documentation 2010 (CENT CHAMB) | 20d | 2010-01-19 | 2010-02-16 | 9-100M FS+69d | 652d |
| 15212110 |  | Check endplates (CENT CHAMB) | 10d | 2010-01-19 | 2010-02-01 | 15212040 | 582d |
| 15212001 |  | FY10 Engineering Support for Assembly Prep (CENT CHAMB) | 113d | 2010-02-02 | 2010-07-13 | 9-100M FS+79d | 349d |
| 15212120 |  | Clean endplates & Compnts (CENT CHAMB) | 10d | 2010-02-02 | 2010-02-16 | 15212001 FS-113d, 15212110 | 582d |
| 15212030 |  | Proc Signal Cables (CENT CHAMB) | 130d | 2010-05-14 | 2010-11-16 | 9-100M FS+151d | 391d |
| 15212002 |  | FY10 Engineering Support for Straw Tube Install (CENT CHAMB) FY10 | 56d | 2010-07-14 | 2010-09-30 | 15212001 | 349d |
| 15212002a |  | FY10 Engineering Support for Straw Tube Install (CENT CHAMB) FY11 | 74d | 2010-10-01 | 2011-01-25 | 15212002 | 349d |
| 15212003 |  | FY11 Engineering Support for Assembly Initial (CENT CHAMB) | 59d | 2010-10-01 | 2010-12-31 | 9-110M | 279d |
| 15212011E |  | FY11 Travel (CENT CHAMB) | 248d | 2010-10-01 | 2011-09-30 | 15212010E | 119d |
| 15212003a |  | FY11 Engineering Support for Assembly Final (CENT CHAMB) | 189d | 2011-01-04 | 2011-09-30 | 15212003 | 279d |
| 15212060 |  | Proc Fiber Glass shell (inner surface) (CENT CHAMB) | 130d | 2011-01-05 | 2011-07-11 | 9-110M FS+60d | 254d |
| 15212065 |  | Proc Lucite and hardware (Gas plenum) (CENT CHAMB) | 108d | 2011-03-01 | 2011-08-01 | 9-110M FS+97d | 391d |
| 15212088 |  | Proc Rail Bearings (CENT CHAMB) | 66d | 2011-03-01 | 2011-06-01 | 9-110M FS+97d | 386d |
| 15212055 |  | Proc Aluminum shell (Outer surface) (CENT CHAMB) | 86d | 2011-06-01 | 2011-09-30 | 9-110M FS+162d | 196d |
| 15212045 |  | Prepare Procurement Packages for Supprt Frame (CENT CHAMB) | 44d | 2011-08-01 | 2011-09-30 | 12321018M, 15212000a FS-86d, 9-120M FS-44d | 303d |
| 15212004 |  | FY12 Engineering Support for Assembly (CENT CHAMB) | 247d | 2011-10-03 | 2012-09-28 | 9-120M | 85d |
| 15212012E |  | FY12 Travel (CENT CHAMB) | 247d | 2011-10-03 | 2012-09-28 | 15212011E | 119d |
| 15212047 |  | Proc Supprt Frame (CENT CHAMB) Part A | 87d | 2011-10-03 | 2012-02-13 | 15212045 | 303d |
| 15212047a |  | Proc Supprt Frame (CENT CHAMB) Part B | 87d | 2011-10-03 | 2012-02-13 | 15212045 | 303d |
| 15212115 |  | Test On-Chamb Electrnc's (CENT CHAMB) | 45d | 2012-01-30 | 2012-04-02 | 1546180, 15212080 FS+193d | 55d |
| 15212145 |  | Gas Sys Installtn (CENT CHAMB) | 1d | 2012-04-03 | 2012-04-03 | 9-120M FS+121d, 15212095, 15212100, 15212050, 15212003a FS-104d, 15212035, 15212002a, 15212120, 15212090 | 54d |
| 15212155 |  | Mount Signal Connectors (CENT CHAMB) | 20d | 2012-04-04 | 2012-05-01 | 15212105, 15212030, 15212004a FS-299d, 15212115, 15212025, 15212145 | 54d |
| 15212160 |  | Attach shell (CENT CHAMB) | 10d | 2012-05-02 | 2012-05-15 | 15212055, 15212004a FS-390d, 15212155, 15212060 | 54d |
| 15212087 |  | Alignment CC (CENT CHAMB) | 20d | 2012-06-21 | 2012-07-18 | 9-120M FS+176d, 15212088, 15212160, 15212065 | 172d |
| 15212004a |  | FY13 Engineering Support for Assembly (CENT CHAMB) | 143d | 2012-10-01 | 2013-05-01 | 15212004 | 85d |
| 15212013E |  | FY13 Travel (CENT CHAMB) | 59d | 2012-10-01 | 2012-12-31 | 15212012E | 119d |

| ID | WBS | Task | Duration | Start | Finish | Predecessors | Total float |
| --- | --- | --- | --- | --- | --- | --- | --- |
| 15212185 |  | Resolution Studies (CENT CHAMB) | 45d | 2012-10-01 | 2012-12-04 | 15212160 FS+95d, 15212088 | 54d |
| 15212190 |  | Cross talk Studies (CENT CHAMB) | 22d | 2012-12-05 | 2013-01-11 | 15212185 | 54d |
| 15212195 |  | Magnetic Field Tests (CENT CHAMB) | 22d | 2013-01-14 | 2013-02-13 | 15212087, 15212190 | 54d |
| 15212200 |  | Shipping (CENT CHAMB) | 35d | 2013-02-14 | 2013-04-04 | 15212047, 15212047a, 15212195 | 54d |
| 15212205 |  | Re-Baseline Actuals Adjustment | 1d | 2013-08-30 | 2013-08-30 | 9-130M FS+227d | 20d |
| 25212185 |  | Resolution Studies (CENT CHAMB) FY13 | 20d | 2013-09-03 | 2013-09-30 | 9-130M FS+228d | 216d |
| 25212185a |  | Resolution Studies (CENT CHAMB) FY14 | 134d | 2013-10-01 | 2014-04-21 | 9-130M FS+228d, 25212185 | 216d |
| 25212010 |  | Prepare as built drawings for CDC (CENT CHAMB) | 33d | 2013-10-31 | 2013-12-18 | 2561110 FS-20d | 192d |
|  | 3 | **1.5.2.1.3 START COUNTERS** |  | 2011-12-01 | 2014-02-27 |  |  |
| 15213000 |  | Prepare Fabrication Packages (START COUNTERS) | 80d | 2011-12-01 | 2012-04-02 | 9-120M FS+41d | 189d |
| 15213001 |  | FY12 Engineering Support for Assembly (START COUNTERS) FY12 | 126d | 2012-04-03 | 2012-09-28 | 15213000, 9-120M | 189d |
| 15213001a |  | FY12 Engineering Support for Assembly (START COUNTERS) FY13 | 59d | 2012-10-01 | 2012-12-31 | 15213001 | 189d |
| 15213010 |  | Procure Sipms Part A | 184d | 2012-10-01 | 2013-06-28 | 9-130M | 64d |
| 15213010a |  | Procure Sipms Part B | 184d | 2012-10-01 | 2013-06-28 | 9-130M | 64d |
| 15213005 |  | Fabricate Start Counter (START COUNTERS) | 65d | 2013-05-31 | 2013-08-30 | 9-130M FS+163d, 15213000 | 20d |
| 15213015 |  | Re-Baseline Actuals Adjustment | 1d | 2013-08-30 | 2013-08-30 | 9-130M FS+227d | 20d |
| 25213005 |  | Fabricate (FIU) Start Counter (START COUNTERS) | 117d | 2013-09-03 | 2014-02-27 | 9-130M FS+228d | 131d |
| 25213015 |  | All Manufacturing Drawings for start counter FY13 | 20d | 2013-09-03 | 2013-09-30 | 9-130M FS+228d | 154d |
| 25213015a |  | All Manufacturing Drawings for start counter FY14 | 16d | 2013-10-01 | 2013-10-22 | 9-130M FS+228d, 25213015 | 154d |
| 25213020 |  | Procure start counter support frame parts | 67d | 2013-10-23 | 2014-02-07 | 25213015, 25213015a | 154d |
| 25213025 |  | Assemble start counter support frame | 25d | 2014-01-03 | 2014-02-07 | 25213020 FS-25d | 154d |
|  | 2 | **1.5.2.2 CALORIMETRY** |  | 2008-12-01 | 2014-01-16 |  |  |
|  | 1 | **1.5.2.2.1 BARREL CALORIMETER** |  | 2008-12-01 | 2013-11-27 |  |  |
| 15221010 |  | Proc SciFi Mods 01-06 (BarCal) P-1 | 121d | 2008-12-01 | 2009-05-29 | 9-090M FS+41d, 123221025, 12322018M, 1-6M | 220d |
| 15221009E |  | FY09 Travel (BarCal) | 189d | 2009-01-02 | 2009-09-30 | 15221009EX | 496d |
| 15221060 |  | Proc Lead Sheets 1-6 (BarCal) | 60d | 2009-01-05 | 2009-03-31 | 9-090M FS+60d, 12322018M | 424d |
| 15221035 |  | Proc Clean Room (BarCal) | 60d | 2009-04-01 | 2009-06-24 | 9-090M FS+120d | 741d |
| 15221040 |  | Proc Fiber Handling & Sorting table (BarCal) | 60d | 2009-04-01 | 2009-06-24 | 9-090M FS+120d | 741d |
| 15221045 |  | Proc 2nd Swaging machine (BarCal) | 60d | 2009-04-01 | 2009-06-24 | 9-090M FS+120d | 695d |
| 15221070 |  | Proc Lead Sheets 25-30 (BarCal) | 60d | 2009-04-01 | 2009-06-24 | 15221060 | 424d |
| 15221190 |  | Lead Cutting & Swaging Mods 1-6 (BarCal) (FROZEN and Reversed BY CR09-043 Activity 15221191) | 60d | 2009-04-01 | 2009-06-24 | 9-090M FS+120d | 68d |
| 15221192LOE |  | Bcal Module Construction Manager Initial Prototype | 106d | 2009-04-01 | 2009-08-28 | 9-090M FS+120d | 84d |
| 15221012 |  | Proc SciFi Mods 25-30 (BarCal) P-2 | 86d | 2009-06-01 | 2009-09-30 | 9-090M, 15221010 | 220d |
| 15221001 |  | Prepare Fabrication Packages 2009 (BarCal) | 45d | 2009-06-02 | 2009-08-04 | 9-090M FS+163d | 695d |
| 15221080 |  | Proc Lead Sheets 7-12 (BarCal) | 60d | 2009-06-25 | 2009-09-18 | 15221070 | 424d |
| 15221185 |  | Scifi Sorting & Bundling Mods 1-6 (BarCal) (FROZEN and Reversed BY CR09-043 Activity 15221191) | 26d | 2009-06-25 | 2009-07-31 | 9-090M FS+180d | 42d |
| 15221310 |  | Lead Cutting & Swaging Mods 25-30 (BarCal) (FROZEN and Reversed BY CR09-043 Activity 15221191) | 26d | 2009-06-25 | 2009-07-31 | 9-090M FS+180d | 42d |
| 15221002 |  | Evaluate Procurements 2009 (BarCal) | 65d | 2009-06-30 | 2009-09-30 | 15221001 FS-25d | 695d |
| 15221191 |  | Reverse Entry for Frozen Activities 15221185, 15221190 and 15221310 Per CR09-043 | 1d | 2009-08-05 | 2009-08-05 | 9-090M FS+208d | 39d |
| 15221050 |  | Proc 2nd press/Frame (BarCal) | 120d | 2009-08-31 | 2010-03-01 | 9-090M FS+226d | 595d |
| 15221195 |  | Bcal Module Construction Manager Phase 1 (LOE) | 120d | 2009-08-31 | 2010-03-01 | 15221192LOE | 84d |
| 15221200 |  | Module #1 Matrix Fabrication | 64d | 2009-08-31 | 2009-12-01 | 15221002 FS-22d, 15221035, 15221040, 9-090M FS+226d | 695d |
| 15221205 |  | Module #1 Machining and Shipping | 108d | 2009-08-31 | 2010-02-10 | 9-090M FS+226d | 646d |
| 15221210 |  | Module #2 Matrix Fabrication | 64d | 2009-08-31 | 2009-12-01 | 9-090M FS+226d | 695d |
| 15221215 |  | Module #2 Machining and Shipping | 108d | 2009-08-31 | 2010-02-10 | 9-090M FS+226d | 646d |
| 15221220 |  | Module #3 Matrix Fabrication | 85d | 2009-08-31 | 2010-01-07 | 9-090M FS+226d | 674d |
| 15221225 |  | Module #3 Machining and Shipping | 108d | 2009-08-31 | 2010-02-10 | 9-090M FS+226d | 646d |
| 15221230 |  | Module #4 Matrix Fabrication | 85d | 2009-08-31 | 2010-01-07 | 9-090M FS+226d | 674d |
| 15221235 |  | Module #4 Machining and Shipping | 108d | 2009-08-31 | 2010-02-10 | 9-090M FS+226d | 646d |
| 15221240 |  | Module #5 Matrix Fabrication | 110d | 2009-08-31 | 2010-02-12 | 9-090M FS+226d, 15221045 | 649d |
| 15221245 |  | Module #5 Machining and Shipping | 161d | 2009-08-31 | 2010-04-27 | 9-090M FS+226d | 593d |
| 15221250 |  | Module #6 Matrix Fabrication | 110d | 2009-08-31 | 2010-02-12 | 9-090M FS+226d | 649d |
| 15221255 |  | Module #6 Machining and Shipping | 161d | 2009-08-31 | 2010-04-27 | 9-090M FS+226d | 593d |
| 15221260 |  | Module #7 Matrix Fabrication | 137d | 2009-08-31 | 2010-03-24 | 9-090M FS+226d | 622d |
| 15221265 |  | Module #7 Machining and Shipping | 161d | 2009-08-31 | 2010-04-27 | 9-090M FS+226d | 593d |
| 15221270 |  | Module #8 Matrix Fabrication | 137d | 2009-08-31 | 2010-03-24 | 9-090M FS+226d | 622d |
| 15221275 |  | Module #8 Machining and Shipping | 161d | 2009-08-31 | 2010-04-27 | 9-090M FS+226d | 593d |
| 15221014 |  | Proc SciFi Mods P-2 FY10 October Delivery | 38d | 2009-09-09 | 2009-10-30 | 9-090M FS+232d, 15221012 FS-16d | 220d |
| 15221016 |  | Proc SciFi Mods P-2 FY10 November Delivery | 57d | 2009-09-09 | 2009-11-30 | 15221014 FS-38d | 220d |
| 15221018 |  | Proc SciFi Mods P-2 FY10 December Delivery | 74d | 2009-09-09 | 2009-12-30 | 15221016 FS-57d | 220d |
| 15221018A |  | Proc SciFi Mods P-2 FY10 January Delivery | 94d | 2009-09-09 | 2010-01-29 | 15221018 FS-74d | 220d |
| 15221018B |  | Proc SciFi Mods P-2 FY10 February Delivery | 113d | 2009-09-09 | 2010-02-26 | 15221018A FS-94d | 220d |
| 15221018C |  | Proc SciFi Mods P-2 FY10 March Delivery | 136d | 2009-09-09 | 2010-03-31 | 15221018B FS-113d | 220d |
| 15221018D |  | Proc SciFi Mods P-2 FY10 April Delivery | 158d | 2009-09-09 | 2010-04-30 | 15221018C FS-136d | 220d |
| 15221018F |  | Proc SciFi Mods P-2 FY10 May Delivery | 178d | 2009-09-09 | 2010-05-28 | 15221018D FS-158d | 220d |
| 15221018G |  | Proc SciFi Mods P-2 FY10 June Delivery | 200d | 2009-09-09 | 2010-06-30 | 15221018F FS-178d | 220d |
| 15221018H |  | Proc SciFi Mods P-2 FY10 July Delivery | 221d | 2009-09-09 | 2010-07-30 | 15221018G FS-200d | 220d |
| 15221018J |  | Proc SciFi Mods P-2 FY10 August Delivery | 243d | 2009-09-09 | 2010-08-31 | 15221018H FS-221d | 220d |
| 15221018K |  | Proc SciFi Mods P-2 FY10 September Delivery | 264d | 2009-09-09 | 2010-09-30 | 15221018J FS-243d | 220d |
| 15221012A |  | Proc SciFi Mods P-1 Correction to Match award per CR09-052 | 1d | 2009-09-17 | 2009-09-17 | 9-090M FS+238d | 9d |

| ID | Task | Duration | Start | Finish | Predecessors | Total float |
| --- | --- | --- | --- | --- | --- | --- |
| 15221090 | Proc Lead Sheets 31-36 (BarCal) | 60d | 2009-09-21 | 2009-12-15 | 15221080 | 424d |
| 15221005 | FY10 Engineering Support for Procurements (BarCal) | 248d | 2009-10-01 | 2010-09-30 | 9-100M | 399d |
| 15221010E | FY10 Travel (BarCal) | 248d | 2009-10-01 | 2010-09-30 | 15221009E | 496d |
| 15221100 | Proc Lead Sheets 13-18 (BarCal) | 60d | 2009-12-16 | 2010-03-19 | 15221090, 9-100M | 424d |
| 15221165 | Proc PMT's & Dividers (BarCal) | 120d | 2010-01-05 | 2010-06-24 | 9-100M FS+60d | 557d |
| 15221115 | Proc Lead Sheets 37-42 (BarCal) | 60d | 2010-03-22 | 2010-06-14 | 15221100 | 424d |
| 15221003 | Prep Procur Packages for Si PM's/Winston Cones 2010 (BarCal) | 60d | 2010-04-01 | 2010-06-24 | 9-100M FS+120d | 278d |
| 15221130 | Proc Lead Sheets 19-24 (BarCal) | 60d | 2010-06-15 | 2010-09-08 | 15221115 | 424d |
| 15221004 | Prep Light Guide Procurement Package (BarCal) | 59d | 2010-06-25 | 2010-09-17 | 15221003 | 278d |
| 15221160a | SiPM Elec Preamp/Sum, Temp stab, Mech cooling FY10 | 68d | 2010-06-25 | 2010-09-30 | 15221003 FS-120d, 9-100M FS+180d | 437d |
| 15221160b | Mechanical Drawings Including Temperature Stability (BarCal) (IPL 55221010 and 55221010c) FY10 | 68d | 2010-06-25 | 2010-09-30 | 9-100M FS+180d, 15221003 FS-120d | 489d |
| 15221145 | Proc Lead Sheets 43-48 (BarCal) | 60d | 2010-09-09 | 2010-12-03 | 15221130 | 424d |
| 15221173 | Proc Light Guides (BarCal) | 220d | 2010-09-20 | 2011-08-09 | 15221004, 15221005 FS-130d, 12322018M, 9-100M FS+120d | 278d |
| 15221008 | Prep Procur Packages Shipping Fixture/Support Frame 2011 (BarCal) | 60d | 2010-10-01 | 2011-01-04 | 9-110M | 539d |
| 15221011E | FY11 Travel (BarCal) | 248d | 2010-10-01 | 2011-09-30 | 15221010E | 496d |
| 15221018N | Proc SciFi Mods P-3 FY11 December Delivery | 58d | 2010-10-01 | 2010-12-30 | 195221001 FS-41d | 220d |
| 15221018P | Proc SciFi Mods P-3 FY11 January Delivery | 78d | 2010-10-01 | 2011-01-31 | 15221018N FS-58d | 220d |
| 15221018Q | Proc SciFi Mods P-3 FY11 February Delivery | 97d | 2010-10-01 | 2011-02-28 | 15221018P FS-78d | 220d |
| 15221018R | Proc SciFi Mods P-3 FY11 March Delivery | 120d | 2010-10-01 | 2011-03-31 | 15221018Q FS-97d | 220d |
| 15221018S | Proc SciFi Mods P-3 FY11 April Delivery | 141d | 2010-10-01 | 2011-04-29 | 15221018R FS-120d | 220d |
| 15221018T | Proc SciFi Mods P-3 FY11 May Delivery | 162d | 2010-10-01 | 2011-05-31 | 15221018S FS-141d | 220d |
| 15221018U | Proc SciFi Mods P-3 FY11 June Delivery | 184d | 2010-10-01 | 2011-06-30 | 15221018T FS-162d | 220d |
| 15221018V | Proc SciFi Mods P-3 FY11 July Delivery | 204d | 2010-10-01 | 2011-07-29 | 15221018U FS-184d | 220d |
| 15221018W | Proc SciFi Mods P-3 FY11 August Delivery | 227d | 2010-10-01 | 2011-08-31 | 15221018V FS-204d | 220d |
| 15221018X | Proc SciFi Mods P-3 FY11 September Delivery | 248d | 2010-10-01 | 2011-09-30 | 15221018W FS-227d | 220d |
| 15221160ab | SiPM Elec Preamp/Sum, Temp stab, Mech cooling FY11 Part A | 52d | 2010-10-01 | 2010-12-15 | 15221160a | 437d |
| 15221160aba | SiPM Elec Preamp/Sum, Temp stab, Mech cooling FY11 Part B | 52d | 2010-10-01 | 2010-12-15 | 15221160a | 437d |
| 15221157M | SiPM Contract Award (APP) | 0d | 2010-11-30 | 2010-11-30 | 9-110M FS+40d | 312d |
| 15221158 | Vend Fab SiPMs Peg Point #1 - First Article | 56d | 2010-12-01 | 2011-02-28 | 9-110M FS+41d, 15221157M | 334d |
| 15221159 | Vend Fab SiPMs Peg Point #2 - Production Delivery #1 Qty 500 | 163d | 2010-12-01 | 2011-07-29 | 15221158M FS-101d | 312d |
| 15221159a | Vend Fab SiPMs Peg Point #3 - Production Delivery #2 Qty 500 | 186d | 2010-12-01 | 2011-08-31 | 15221159 FS-163d | 495d |
| 15221159b | Vend Fab SiPMs Peg Point #4 - Production Delivery #3 Qty 120 | 207d | 2010-12-01 | 2011-09-30 | 15221159a FS-186d | 495d |
| 15221158a | SiPM First Article Testing | 83d | 2011-01-04 | 2011-05-02 | 15221157M FS+19d | 312d |
| 15221006 | FY11 Engineering Support for fabrication (BarCal) | 188d | 2011-01-05 | 2011-09-30 | 9-110M FS+60d | 115d |
| 15221147 | Drawings Winston Cones (BarCal) | 103d | 2011-01-05 | 2011-06-01 | 9-110M FS+60d | 20d |
| 15221158b | SiPM First Article Test set up | 19d | 2011-02-02 | 2011-03-01 | 15221157M FS+39d | 356d |
| 15221055 | Fabricate BCAL Calibration System (BarCal) Labor FY11 | 107d | 2011-05-02 | 2011-09-30 | 1152055, 9-110M FS+141d | 100d |
| 15221055b | Fabricate BCAL Calibration System (BarCal) Procurement | 248d | 2011-05-02 | 2012-04-30 | 1152055, 9-110M FS+141d | 100d |
| 15221158M | SiPM Notice To Begin Production | 0d | 2011-05-03 | 2011-05-03 | 15221158b, 15221158 FS+23d, 15221158a | 312d |
| 15221020 | Completion of BCAL assembly work in factory, exchange rate coverage | 207d | 2011-08-01 | 2012-05-31 | 9-110M FS+204d | 78d |
| 15221025 | Fabrication of matrix #49 | 207d | 2011-08-01 | 2012-05-31 | 9-110M FS+204d | 58d |
| 15221030 | Machining and shipping of matrix #49 | 227d | 2011-08-01 | 2012-06-29 | 15221025 FS-207d | 58d |
| 15221150 | Proc Winston Cones First Article (Per CR12-017 This is Part of Peg Point #1) | 44d | 2011-08-01 | 2011-09-30 | 15221003, 15221147 FS+41d | 20d |
| 15221160ba | SiPM production testing FY11 | 44d | 2011-08-01 | 2011-09-30 | 15221159 | 312d |
| 15221160bb | SiPM production testing set up (materials) | 227d | 2011-08-01 | 2012-06-29 | 15221159 | 312d |
| 15221007 | Prepare procurement packages for assembly tooling | 78d | 2011-10-03 | 2012-01-31 | 9-120M | 273d |
| 15221012E | FY12 Travel (BarCal) | 247d | 2011-10-03 | 2012-09-28 | 15221011E | 496d |
| 15221055a | Fabricate BCAL Calibration System (BarCal) Labor FY12 | 141d | 2011-10-03 | 2012-04-30 | 15221055 | 100d |
| 15221160baa | SiPM production testing FY12 | 183d | 2011-10-03 | 2012-06-29 | 15221160ba | 312d |
| 15221155 | Vend Fab Light Guides (WC) Peg Point # 1 - Materials | 58d | 2011-10-31 | 2012-01-31 | 9-110M FS+60d, 15221003, 15221150 FS+20d | 20d |
| 15221156 | Vend Fab Light Guides (WC) Peg Point # 2 - First Article Delivery | 58d | 2011-10-31 | 2012-01-31 | 15221155 FS-58d | 20d |
| 15221156a | Vend Fab Light Guides (WC) Peg Point # 3 - 1st Production Delivery | 100d | 2011-10-31 | 2012-03-30 | 15221156 FS-58d | 20d |
| 15221156b | Vend Fab Light Guides (WC) Peg Point # 4 -2nd Production Delivery | 121d | 2011-10-31 | 2012-04-30 | 15221156a FS-100d | 20d |
| 15221156c | Vend Fab Light Guides (WC) Peg Point # 5 - 3rd Production Delivery | 143d | 2011-10-31 | 2012-05-31 | 15221156b FS-121d | 20d |
| 15221156d | Vend Fab Light Guides (WC) Peg Point # 6 - 4th Production Delivery | 163d | 2011-10-31 | 2012-06-29 | 15221156c FS-143d | 20d |
| 15221156f | Vend Fab Light Guides (WC) Peg Point # 7 - 5th Production Delivery | 163d | 2011-10-31 | 2012-06-29 | 15221156d FS-163d | 20d |
| 15221156g | Vend Fab Light Guides (WC) Peg Point # 8 - 6th Production Delivery | 185d | 2011-10-31 | 2012-07-31 | 15221156f FS-163d | 20d |
| 15221156h | Vend Fab Light Guides (WC) Peg Point # 9 - 7th Production Delivery | 185d | 2011-10-31 | 2012-07-31 | 15221156g FS-185d | 20d |
| 15221156j | Vend Fab Light Guides (WC) Peg Point # 10 - 8th Production Delivery | 208d | 2011-10-31 | 2012-08-31 | 15221156h FS-185d | 20d |
| 15221156k | Vend Fab Light Guides (WC) Peg Point # 11 - 9th Production Delivery | 208d | 2011-10-31 | 2012-08-31 | 15221156j FS-208d | 20d |
| 15221156n | Vend Fab Light Guides (WC) Peg Point # 12 - 10th Production Delivery | 227d | 2011-10-31 | 2012-09-28 | 15221156k FS-208d | 20d |
| 15221161 | SiPM cool Procurement labor FY12 (FY13 @ 15221161s) | 183d | 2012-01-11 | 2012-09-28 | 15221160aba, 15221160ab, 9-120M FS+64d | 548d |
| 15221155a | Mechanical Support (BarCal) | 84d | 2012-02-01 | 2012-05-30 | 15221003, 9-120M FS+78d | 294d |
| 15221155b | Light Tight Boxes (BarCal) | 84d | 2012-02-01 | 2012-05-30 | 9-120M FS+78d, 15221003 | 294d |
| 15221180 | Proc Supprt Struct and assy tooling (BarCal) Part A | 105d | 2012-02-01 | 2012-06-29 | 15221008, 15221007, 9-120M | 273d |
| 15221180a | Proc Supprt Struct and assy tooling (BarCal) Part B | 105d | 2012-02-01 | 2012-06-29 | 9-120M, 15221007, 15221008 | 273d |
| 15221009 | FY12 Engineering Support for Fabrication (BarCal) | 126d | 2012-02-23 | 2012-08-20 | 9-120M FS+93d, 15221006 | 22d |
| 15221057 | Installation BCAL Calibration System (BarCal) FY12 | 40d | 2012-08-03 | 2012-09-28 | 9-120M FS+207d, 15221055b FS+60d, 15221055a FS+60d | 203d |
| 15221057b | Installation BCAL Calibration System (BarCal) Procurements | 85d | 2012-08-03 | 2012-12-04 | 15221055b FS+60d, 9-120M FS+207d, 15221055a FS+60d | 203d |
| 15221057a | Installation BCAL Calibration System (BarCal) FY13 | 45d | 2012-10-01 | 2012-12-04 | 15221057 | 203d |

| ID | WBS | Task | Duration | Start | Finish | Predecessors | Total float |
| --- | --- | --- | --- | --- | --- | --- | --- |
| 15221161a |  | SiPM cool light guide grating | 165d | 2012-10-01 | 2013-06-03 | 9-130M, 15221160aba, 15221160ab | 213d |
| 15221161b |  | SiPM cool SiPM mount | 165d | 2012-10-01 | 2013-06-03 | 9-130M, 15221160aba, 15221160ab | 406d |
| 15221161c |  | SiPM cool Cooling plate | 165d | 2012-10-01 | 2013-06-03 | 15221160aba, 9-130M, 15221160ab | 406d |
| 15221161f |  | SiPM cool Electronic heat removal | 162d | 2012-10-01 | 2013-05-29 | 9-130M, 15221160aba, 15221160ab | 409d |
| 15221161h |  | SiPM cool light covers | 165d | 2012-10-01 | 2013-06-03 | 15221160aba, 15221160ab, 9-130M | 406d |
| 15221161j |  | SiPM cool cable supports/layout | 165d | 2012-10-01 | 2013-06-03 | 15221160aba, 9-130M, 15221160ab | 406d |
| 15221161k |  | SiPM cool cooling tubes support/layout | 165d | 2012-10-01 | 2013-06-03 | 15221160ab, 15221160aba, 9-130M | 406d |
| 15221161n |  | SiPM cool mechanical support | 165d | 2012-10-01 | 2013-06-03 | 9-130M, 15221160ab, 15221160aba | 406d |
| 15221161s |  | SiPM cool Procurement labor FY13 (FY12 @ 15221161) | 23d | 2012-10-01 | 2012-10-31 | 15221161 | 548d |
| 15221182 |  | Procure BCAL SiPm chillers | 80d | 2013-01-03 | 2013-04-26 | 9-130M FS+60d | 108d |
| 15221315 |  | Re-Baseline Actuals Adjustment | 1d | 2013-08-30 | 2013-08-30 | 9-130M FS+227d | 20d |
| 25221000 |  | Regina contract Decommissioning | 43d | 2013-09-03 | 2013-10-31 | 9-130M FS+228d | 224d |
| 25221005 |  | Procured Labor (Designer) | 20d | 2013-09-03 | 2013-09-30 | 9-130M FS+228d | 247d |
| 25221010 |  | Athens contract Completion | 43d | 2013-09-03 | 2013-10-31 | 9-130M FS+228d | 224d |
| 25221010LOE |  | Forklift Rental (ESB) | 43d | 2013-09-03 | 2013-10-31 | 9-130M FS+228d | 224d |
| 25221057b |  | Construction BCAL Pulsing System (BarCal) Labor FY13 | 20d | 2013-09-03 | 2013-09-30 | 9-130M FS+228d | 194d |
| 25221057c |  | Construction BCAL Pulsing System (BarCal) Expenses FY13 | 20d | 2013-09-03 | 2013-09-30 | 9-130M FS+228d | 194d |
| 25221060 |  | Setup and Testing of BCAL Pulsing System FY13 | 20d | 2013-09-03 | 2013-09-30 | 9-130M FS+228d | 54d |
| 25221320 |  | Procure BCAL cooling manifold | 23d | 2013-09-03 | 2013-10-03 | 9-130M FS+228d | 29d |
| 25221057ba |  | Construction BCAL Pulsing System (BarCal) Labor FY14 | 42d | 2013-10-01 | 2013-11-27 | 9-130M FS+228d, 25221057b | 194d |
| 25221057ca |  | Construction BCAL Pulsing System (BarCal) Expenses FY14 | 42d | 2013-10-01 | 2013-11-27 | 9-130M FS+228d, 25221057c | 194d |
| 25221060a |  | Setup and Testing of BCAL Pulsing System FY14 | 42d | 2013-10-01 | 2013-11-27 | 25221060, 9-130M FS+228d | 54d |
|  | 2 | **1.5.2.2.2 FORWARD CALORIMETER** |  | 2009-01-02 | 2014-01-16 |  |  |
| 15222009E |  | FY09 Travel (FWD CAL) | 189d | 2009-01-02 | 2009-09-30 | 15222009EX | 317d |
| 15222001 |  | Prepare Procurements/Fabrication Packages 2009 (FWD CAL) | 64d | 2009-07-01 | 2009-09-30 | 9-090M FS+184d | 802d |
| 15222015 |  | Proc Replacement PMTs (FWD CAL) | 130d | 2009-07-01 | 2010-01-12 | 9-090M FS+184d, 12322018M | 761d |
| 15222003 |  | FY10 Engineering Support for Fabrication (FWD CAL) | 131d | 2009-10-01 | 2010-04-15 | 9-100M | 726d |
| 15222010E |  | FY10 Travel (FWD CAL) | 248d | 2009-10-01 | 2010-09-30 | 15222009E | 317d |
| 15222025 |  | Setup Divider Constrctn (FWD CAL) (Frozen by CR10-007) | 41d | 2009-10-01 | 2009-11-30 | 9-100M | 207d |
| 15222050 |  | Proc Magnetic Shields (FWD CAL) (Frozen by CR10-007) | 25d | 2009-10-01 | 2009-11-04 | 15222001, 9-100M, 12322018M | 802d |
| 15222045 |  | Setup Procedure & Glue LG to PMT's (FWD CAL) (Frozen by CR10-007) | 10d | 2009-11-12 | 2009-11-25 | 9-100M FS+30d | 787d |
| 15222110 |  | Reverse Entry Per CR10-007 | 1d | 2009-12-07 | 2009-12-07 | 9-100M FS+45d | 202d |
| 15222002 |  | Prepare Procurements/Fabrication Packages 2010 (FWD CAL) | 64d | 2010-07-01 | 2010-09-30 | 9-100M FS+184d | 609d |
| 15222011E |  | FY11 Travel (FWD CAL) | 248d | 2010-10-01 | 2011-09-30 | 15222010E | 317d |
| 15222007 |  | FY11 Engineering Support for Fabrication (FWD CAL) | 188d | 2011-01-05 | 2011-09-30 | 9-110M FS+60d | 150d |
| 15222055 |  | Proc Pb Glass Insert PR | 64d | 2011-02-01 | 2011-05-02 | 9-110M FS+78d | 55d |
| 15222060 |  | Proc Pb Glass Insert | 269d | 2011-05-03 | 2012-05-31 | 15222055 | 55d |
| 15222004 |  | Prep Support Struc Procurement Package 2011(FWD CAL) | 65d | 2011-06-30 | 2011-09-30 | 15222003, 9-110M FS+183d, 15222002 | 426d |
| 15222012E |  | FY12 Travel (FWD CAL) | 58d | 2011-10-03 | 2011-12-30 | 15222011E | 317d |
| 15222080 |  | Fabricate FCAL Monitoring System (FWD CAL) | 64d | 2012-01-05 | 2012-04-05 | 9-120M FS+60d, 1152055 | 48d |
| 15222005 |  | FY12 Engineering Support for Fabrication (FWD CAL) | 117d | 2012-04-16 | 2012-09-28 | 9-120M FS+130d, 15222007 | 20d |
| 15222100 |  | Stacking of Blocks (FWD CAL) FY12 | 49d | 2012-07-23 | 2012-09-28 | 15222060, 15222006 FS-253d | 20d |
| 15222006 |  | FY13 Engineering Support for Fabrication (FWD CAL) | 204d | 2012-10-01 | 2013-07-29 | 15222005 | 20d |
| 15222100a |  | Stacking of Blocks (FWD CAL) FY13 | 204d | 2012-10-01 | 2013-07-29 | 15222100 | 20d |
| 15222105 |  | Assy of Single Channel FCal Detector (FWD CAL) | 65d | 2013-01-03 | 2013-04-05 | 15222050, 195222285, 15222045, 9-130M FS+60d, 15222015, 15222080 FS+159d | 24d |
| 15222115 |  | Re-Baseline Actuals Adjustment | 1d | 2013-08-30 | 2013-08-30 | 9-130M FS+227d | 20d |
| 25222085 |  | Fabricate and Install Monitoring Panes (FCAL) FY13 | 20d | 2013-09-03 | 2013-09-30 | 9-130M FS+228d | 79d |
| 25222090 |  | Fabricate and Install Monitoring Panes (FCAL) (Previously Obligated) | 88d | 2013-09-03 | 2014-01-16 | 9-130M FS+228d | 79d |
| 25222085a |  | Fabricate and Install Monitoring Panes (FCAL) FY14 | 68d | 2013-10-01 | 2014-01-16 | 25222085, 9-130M FS+228d | 79d |
|  | 3 | **1.5.2.2.3 UPSTREAM PHOTON VETO** |  |  |  |  |  |
|  | 3 | **1.5.2.3 PARTICLE ID** |  | 2010-08-02 | 2014-01-31 |  |  |
|  | 1 | **1.5.2.3.1 TIME OF FLIGHT** |  | 2010-08-02 | 2014-01-31 |  |  |
| 15231019 |  | Proc First Article PMTs (TOF) | 43d | 2010-08-02 | 2010-09-30 | 9-100M FS+205d | 743d |
| 15231011E |  | FY11 Travel (TOF) | 248d | 2010-10-01 | 2011-09-30 | 9-110M | 128d |
| 15231001 |  | Prepare Procurements/Fabrication Packages 2011 (TOF) | 86d | 2011-06-01 | 2011-09-30 | 9-110M FS+162d | 288d |
| 15231001a |  | Prepare Procurements/Fabrication Packages 2012 (TOF) | 127d | 2011-10-03 | 2012-04-10 | 15231001 | 288d |
| 15231012E |  | FY12 Travel (TOF) | 247d | 2011-10-03 | 2012-09-28 | 15231011E | 128d |
| 15231015 |  | FSU - Proc Supplies (TOF) Part A | 20d | 2011-11-02 | 2011-12-01 | 9-120M FS+22d, 12323040M | 453d |
| 15231020 |  | Proc PMTs (TOF) | 124d | 2012-04-05 | 2012-09-28 | 9-120M FS+123d, 12323040M, 15231019 FF | 248d |
| 15231025 |  | Proc Dividers (TOF) | 124d | 2012-04-05 | 2012-09-28 | 9-120M FS+123d, 12323040M | 248d |
| 15231002 |  | Engineering Support for Testing 2012 | 65d | 2012-05-29 | 2012-08-28 | 9-120M FS+160d | 270d |
| 15231070 |  | FSU - Scintillator Procurement Part D | 38d | 2012-07-11 | 2012-08-31 | 9-120M FS+190d | 267d |
| 15231060 |  | FSU - Scintillator Procurement Part B | 31d | 2012-07-20 | 2012-08-31 | 9-120M FS+197d | 267d |
| 15231065 |  | FSU - Scintillator Procurement Part C | 26d | 2012-07-27 | 2012-08-31 | 9-120M FS+202d | 267d |
| 15231055 |  | FSU - Scintillator Procurement Part A | 1d | 2012-08-31 | 2012-08-31 | 9-120M FS+227d | 267d |
| 15231075 |  | FSU - Scintillator Procurement Part E | 225d | 2012-09-04 | 2013-07-31 | 1152055, 9-120M FS+228d | 20d |
| 15231080 |  | FSU - Light Guide Material Procurement | 225d | 2012-09-04 | 2013-07-31 | 15231075 FS-225d | 20d |
| 15231090 |  | FSU - Proc Supplies (TOF) Part B | 225d | 2012-09-04 | 2013-07-31 | 15231080 FS-225d | 20d |
| 15231093 |  | FSU - Jig Construction | 62d | 2012-09-04 | 2012-11-30 | 15231090 FS-225d | 20d |
| 15231095 |  | FSU - Polishing and Gluing of First 30 Units | 183d | 2012-09-04 | 2013-05-31 | 15231093 FS-62d | 20d |

| ID | WBS | Task | Duration | Start | Finish | Predecessors | Total float |
| --- | --- | --- | --- | --- | --- | --- | --- |
| 15231100 |  | FSU - Wrapping of First 30 Units | 183d | 2012-09-04 | 2013-05-31 | 15231095 FS-183d | 20d |
| 15231105 |  | FSU - Mount PMT and Testing of First 30 Units | 183d | 2012-09-04 | 2013-05-31 | 15231100 FS-183d | 20d |
| 15231110 |  | FSU - Polishing and Gluing of Second 30 Units | 247d | 2012-09-04 | 2013-08-30 | 15231105 FS-183d | 20d |
| 15231115 |  | FSU - Wrapping of Second 30 Units | 247d | 2012-09-04 | 2013-08-30 | 15231110 FS-247d | 20d |
| 15231120 |  | FSU - Mount PMT and Testing of Second 30 Units | 247d | 2012-09-04 | 2013-08-30 | 15231115 FS-247d | 20d |
| 15231013E |  | FY13 Travel (TOF) | 120d | 2012-10-01 | 2013-03-29 | 15222012E, 15231012E | 128d |
| 15231030 |  | Proc Magnetic Shields (TOF) | 80d | 2013-01-03 | 2013-04-26 | 9-130M FS+60d, 15231001a, 12323040M | 108d |
| 15231045 |  | Proc Supprt Struct (TOF) | 40d | 2013-02-01 | 2013-03-29 | 9-130M FS+80d, 9-120M FS+22d, 15231001a, 12323040M | 128d |
| 15231150 |  | Re-Baseline Actuals Adjustment | 1d | 2013-08-30 | 2013-08-30 | 9-130M FS+227d | 20d |
| 25231010 |  | FSU contract support and supervision FY13 | 20d | 2013-09-03 | 2013-09-30 | 9-130M FS+228d | 269d |
| 25231085 |  | FSU - Initial wrapping and fitup | 20d | 2013-09-03 | 2013-09-30 | 9-130M FS+228d | 111d |
| 25231090 |  | FSU - Proc Supplies (TOF) | 20d | 2013-09-03 | 2013-09-30 | 9-130M FS+228d | 111d |
| 25231105 |  | FSU - Mount PMT and Testing of First 30 Units | 20d | 2013-09-03 | 2013-09-30 | 9-130M FS+228d | 69d |
| 25231115 |  | FSU - Wrapping of Second 30 Units | 20d | 2013-09-03 | 2013-09-30 | 25231105 FS-20d | 69d |
| 25231120 |  | FSU - Mount PMT and Testing of Second 30 Units | 20d | 2013-09-03 | 2013-09-30 | 25231115 FS-20d | 69d |
| 25231125 |  | FSU - Polishing and Gluing of Third 30 Units | 43d | 2013-09-03 | 2013-10-31 | 25231120 FS-20d | 69d |
| 25231130 |  | FSU - Wrapping of Third 30 Units | 43d | 2013-09-03 | 2013-10-31 | 25231125 FS-43d | 69d |
| 25231135 |  | FSU - Mount PMT and Testing of Third 30 Units | 43d | 2013-09-03 | 2013-10-31 | 25231130 FS-43d | 69d |
| 25231140 |  | FSU - Construction Manager | 62d | 2013-09-03 | 2013-11-27 | 25231135 FS-43d | 69d |
| 25231145 |  | FSU - Shipping of TOF | 77d | 2013-09-03 | 2013-12-20 | 25231140 FS-62d | 69d |
| 25231010a |  | FSU contract support and supervision FY14 | 42d | 2013-10-01 | 2013-11-27 | 25231010, 9-130M FS+228d | 269d |
| 25231030 |  | Proc Magnetic Shields (TOF) | 34d | 2013-11-01 | 2013-12-20 | 9-140M FS+23d | 84d |
| 25231045 |  | Proc Supprt Struct (TOF) | 47d | 2013-11-13 | 2014-01-31 | 9-140M FS+31d, 9-130M FS+228d | 63d |
|  | 2 | **1.5.2.3.2 CERENKOV COUNTER** |  |  |  |  |  |
|  | 3 | **1.5.3 COMPUTING** |  | 2010-10-01 | 2014-12-11 |  |  |
|  | 1 | **1.5.3.1 DAQ** |  | 2010-10-01 | 2014-12-11 |  |  |
| 15311011E |  | FY11 Travel (DAQ) | 248d | 2010-10-01 | 2011-09-30 | 9-110M | 189d |
| 1531170 |  | Software Licenses and Fees FY11 | 189d | 2011-01-04 | 2011-09-30 | 9-110M FS+59d | 251d |
| 1531200 |  | Proc PLC comm Modules PR | 22d | 2011-02-01 | 2011-03-03 | 9-110M FS+78d | 303d |
| 1531230 |  | Proc PLC Controller PR | 22d | 2011-02-01 | 2011-03-03 | 9-110M FS+78d | 231d |
| 1531205 |  | Proc PLC comm Modules | 63d | 2011-03-04 | 2011-06-01 | 1531200 | 303d |
| 1531235 |  | Proc PLC Controller | 42d | 2011-03-04 | 2011-05-02 | 1531230 | 231d |
| 1531005 |  | Proc Single Board Computing PR (DAQ) | 43d | 2011-04-01 | 2011-06-01 | 1233040M, 9-110M FS+120d | 314d |
| 1531180 |  | Proc embedded computers for controls PR | 22d | 2011-04-01 | 2011-05-02 | 9-110M FS+120d | 241d |
| 1531185 |  | Proc embedded computers for controls | 83d | 2011-05-03 | 2011-08-29 | 1531180 | 241d |
| 1531240 |  | Install PLC Controller | 43d | 2011-05-03 | 2011-07-01 | 1531235 | 231d |
| 1531005a |  | Proc Single Board Computing First items (DAQ) | 65d | 2011-06-02 | 2011-09-01 | 1531005 | 314d |
| 1531080 |  | Proc Racks (DAQ) PR | 44d | 2011-08-01 | 2011-09-30 | 9-110M FS+204d | 377d |
| 1531005b |  | Proc Single Board Computing Test First items (DAQ) FY11 | 20d | 2011-09-02 | 2011-09-30 | 1531005a | 314d |
| 1531005ba |  | Proc Single Board Computing Test First items (DAQ) FY12 | 97d | 2011-10-03 | 2012-02-28 | 1531005b | 314d |
| 1531020 |  | Proc EB nodes (DAQ) PR | 41d | 2011-10-03 | 2011-11-30 | 9-120M | 354d |
| 1531065 |  | Proc Cables (DAQ) PR | 42d | 2011-10-03 | 2011-12-01 | 9-120M | 291d |
| 1531082 |  | Proc Racks (DAQ) | 78d | 2011-10-03 | 2012-01-31 | 1531080 | 377d |
| 1531090 |  | Proc Test Setup Equipmnt (DAQ) PR | 77d | 2011-10-03 | 2012-01-30 | 1233040M, 9-120M | 230d |
| 15311012E |  | FY12 Travel (DAQ) | 247d | 2011-10-03 | 2012-09-28 | 15311011E | 189d |
| 1531155 |  | Proc VME based electronic for Controls/Monitoring PR | 41d | 2011-10-03 | 2011-11-30 | 9-120M | 142d |
| 1531175 |  | Software Licenses and Fees FY12 | 244d | 2011-10-03 | 2012-09-25 | 1531170, 9-120M | 251d |
| 1531210 |  | Proc PLC Point I/O Chassis PR | 21d | 2011-10-03 | 2011-10-31 | 9-120M | 105d |
| 1531093 |  | Plan Installation in Counting House | 77d | 2011-10-31 | 2012-02-28 | 9-120M FS+20d | 230d |
| 1531215 |  | Proc PLC Point I/O Chassis | 56d | 2011-11-01 | 2012-01-30 | 1531210 | 105d |
| 1531015 |  | Proc Small Network Switch (DAQ) PR | 41d | 2012-01-03 | 2012-03-01 | 9-120M FS+58d | 188d |
| 1531075 |  | Proc Consoles (DAQ) PR | 41d | 2012-01-03 | 2012-03-01 | 9-120M FS+58d | 227d |
| 1531085 |  | Proc funiture (DAQ) PR | 41d | 2012-01-03 | 2012-03-01 | 9-120M FS+58d | 235d |
| 1531190 |  | Test embedded computers for controls | 118d | 2012-01-31 | 2012-07-17 | 1531215, 1531205, 1531185 | 141d |
| 1531220 |  | Proc PLC Point I/O Modules PR | 42d | 2012-01-31 | 2012-03-29 | 1531215 | 105d |
| 1531005c |  | Proc Single Board Computing Second items (DAQ) Part A | 84d | 2012-02-29 | 2012-06-27 | 1531005ba | 314d |
| 1531005ca |  | Proc Single Board Computing Second items (DAQ) Part B | 84d | 2012-02-29 | 2012-06-27 | 1531005ba | 314d |
| 1531032 |  | Proc Online Computers (DAQ) Phase 1 Part A | 172d | 2012-03-01 | 2012-10-31 | 1531030 FS-65d | 161d |
| 1531032a |  | Proc Online Computers (DAQ) Phase 1 Part B | 172d | 2012-03-01 | 2012-10-31 | 1531030 FS-65d | 161d |
| 1531017 |  | Proc Small Network Switch (DAQ) Phase 1 | 84d | 2012-03-02 | 2012-06-29 | 1531015 | 188d |
| 1531030 |  | Proc Online Computers (DAQ) PR | 43d | 2012-04-02 | 2012-05-31 | 9-120M FS+120d | 161d |
| 1531060 |  | Proc Wireless (DAQ) PR | 33d | 2012-04-02 | 2012-05-16 | 9-120M FS+120d | 219d |
| 1531050 |  | Proc terminal servers (DAQ) PR | 43d | 2012-05-01 | 2012-07-02 | 9-120M FS+141d | 186d |
| 1531055 |  | Proc UPS (DAQ) PR | 42d | 2012-05-01 | 2012-06-29 | 9-120M FS+141d | 187d |
| 1531092 |  | Proc Test Setup Equipmnt (DAQ) Part A | 129d | 2012-05-01 | 2012-10-31 | 9-120M FS+141d, 1531090 | 166d |
| 1531092a |  | Proc Test Setup Equipmnt (DAQ) Part B | 129d | 2012-05-01 | 2012-10-31 | 9-120M FS+141d, 1531090 | 166d |
| 1531062 |  | Proc Wireless (DAQ) | 83d | 2012-05-17 | 2012-09-13 | 1531060 | 219d |
| 1531010 |  | Proc Large Network Switch (DAQ) PR | 42d | 2012-06-01 | 2012-07-31 | 9-120M FS+163d | 167d |
| 1531160 |  | Proc VME based electronic for Controls/Monitoring | 65d | 2012-06-01 | 2012-08-31 | 9-120M FS+163d, 1531155 | 20d |
| 1531145 |  | Proc Net Switches for Controls PR FY12 | 67d | 2012-06-27 | 2012-09-28 | 9-120M FS+180d | 65d |

| ID | Task | Duration | Start | Finish | Predecessors | Total float |
| --- | --- | --- | --- | --- | --- | --- |
| 1531018 | Proc Small Network Switch (DAQ) Phase 2 | 84d | 2012-07-02 | 2012-10-26 | 1531017 | 188d |
| 1531057 | Proc UPS (DAQ) | 85d | 2012-07-02 | 2012-10-29 | 1531055 | 187d |
| 1531052 | Proc terminal servers (DAQ) | 85d | 2012-07-03 | 2012-10-30 | 1531050 | 186d |
| 1531045 | Proc Telecom Installation (DAQ) PR | 43d | 2012-07-04 | 2012-08-31 | 9-120M FS+185d | 69d |
| 1531225 | Proc PLC Point I/O Modules Phase 1 | 67d | 2012-07-30 | 2012-10-31 | 1531220, 9-120M FS+203d, 1531215 FS+20d | 21d |
| 1531012 | Proc Large Network Switch (DAQ) | 83d | 2012-08-01 | 2012-11-28 | 1531010 | 167d |
| 1531135 | Proc infiniband Switch PR | 42d | 2012-08-01 | 2012-09-28 | 9-120M FS+205d | 149d |
| 1531048 | Proc Fibers Installation from Rack Room to Telecom Room (DAQ) | 127d | 2012-10-01 | 2013-04-09 | 9-130M | 81d |
| 15311013E | FY13 Travel (DAQ) | 59d | 2012-10-01 | 2012-12-31 | 15311012E | 189d |
| 1531145a | Proc Net Switches for Controls PR FY13 | 33d | 2012-10-01 | 2012-11-14 | 1531145 | 65d |
| 1531165 | Install VME based electronic for Controls/Monitoring | 120d | 2012-10-02 | 2013-04-01 | 1531160 FS+20d | 20d |
| 1531140 | Proc infiniband Switch | 78d | 2012-10-30 | 2013-02-28 | 1531135 FS+21d | 149d |
| 1531150 | Proc Net Switches for Controls | 63d | 2012-11-15 | 2013-02-25 | 1531145a | 65d |
| 1531040 | Proc file servers (DAQ) PR | 42d | 2012-11-28 | 2013-02-04 | 9-130M FS+40d | 24d |
| 1531070 | Proc Fiber Cables for Counting House to Hall (DAQ) | 122d | 2012-11-28 | 2013-05-29 | 9-130M FS+40d, 1531065 | 46d |
| 1531227 | Proc PLC Point I/O Modules Phase 2 Part A | 79d | 2012-11-29 | 2013-03-29 | 1531225 FS+18d | 21d |
| 1531227a | Proc PLC Point I/O Modules Phase 2 Part B | 79d | 2012-11-29 | 2013-03-29 | 1531225 FS+18d | 21d |
| 1531087 | Proc furniture (DAQ) | 121d | 2012-12-03 | 2013-05-31 | 1531085, 9-130M FS+43d | 44d |
| 1531077 | Proc Consoles (DAQ) | 129d | 2012-12-19 | 2013-06-28 | 1531075, 9-130M FS+55d | 24d |
| 1531025 | Proc RAID disks (DAQ) PR | 40d | 2013-01-03 | 2013-03-01 | 9-130M FS+60d | 64d |
| 1531095 | Install Crates (DAQ) | 55d | 2013-01-03 | 2013-03-22 | 9-130M FS+60d, 1531093, 1562195 FS-20d, 1544005d | 20d |
| 1531195 | Proc remaining embedded computers for controls | 32d | 2013-01-03 | 2013-02-19 | 9-130M FS+60d, 1531190 FS+20d | 49d |
| 1531047 | Proc Telecom Installation (DAQ) | 78d | 2013-01-04 | 2013-04-25 | 1531045 FS+80d | 69d |
| 1531022 | Proc EB nodes (DAQ) Phase 1 | 60d | 2013-02-01 | 2013-04-26 | 9-130M FS+80d, 1531020 | 68d |
| 1531042 | Proc file servers (DAQ) | 102d | 2013-02-05 | 2013-06-28 | 1531040 | 24d |
| 1531027 | Proc RAID disks (DAQ) | 84d | 2013-03-04 | 2013-06-28 | 1531025 | 64d |
| 1531033 | Proc Online Computers (DAQ) Phase 2 | 64d | 2013-03-04 | 2013-05-31 | 9-130M FS+100d, 1531032a, 1531032 | 84d |
| 1531105 | Install Trigger Electrnc's (DAQ) Phase 1 | 59d | 2013-03-25 | 2013-06-14 | 1531092a, 1531092, 1532007a, 1532007, 1531095, 1532005 | 74d |
| 1531110 | Install DAQ Electrnc's (DAQ) | 41d | 2013-03-25 | 2013-05-20 | 1531095 | 20d |
| 1531100 | Install Cabling (DAQ) | 64d | 2013-06-03 | 2013-08-30 | 1531095, 1531110 FS+8d | 20d |
| 1531035 | Proc large displays (DAQ) PR | 44d | 2013-07-01 | 2013-08-30 | 9-130M FS+184d | 20d |
| 1531037 | Proc large displays (DAQ) (Future Activity Complete prior to Rebaseline) | 1d | 2013-08-30 | 2013-08-30 | 9-130M FS+227d | 20d |
| 1531245 | Re-Baseline Actuals Adjustment | 1d | 2013-08-30 | 2013-08-30 | 9-130M FS+227d | 20d |
| 2531005f | Proc Single Board Computing Remaining items (DAQ) | 84d | 2013-09-03 | 2014-01-10 | 9-130M FS+228d | 122d |
| 2531022 | Proc EB nodes (DAQ) | 62d | 2013-09-03 | 2013-11-27 | 9-130M FS+228d | 165d |
| 2531027 | Proc RAID disks (DAQ) | 62d | 2013-09-03 | 2013-11-27 | 9-130M FS+228d | 165d |
| 2531047 | Proc Telecom Installation (DAQ) | 43d | 2013-09-03 | 2013-10-31 | 9-130M FS+228d | 31d |
| 2531065 | Proc Fibers for Counting House to Hall (DAQ) PR FY13 | 20d | 2013-09-03 | 2013-09-30 | 9-130M FS+228d | 17d |
| 2531077 | Proc Consoles (DAQ) | 20d | 2013-09-03 | 2013-09-30 | 9-130M FS+228d | 54d |
| 2531105 | Install Trigger Electrnc's (DAQ) FY13 | 20d | 2013-09-03 | 2013-09-30 | 9-130M FS+228d | 19d |
| 2531115 | Install VME CPUs FY13 | 20d | 2013-09-03 | 2013-09-30 | 9-130M FS+228d | 17d |
| 2531140 | Proc infiniband Hardware | 31d | 2013-09-03 | 2013-10-15 | 9-130M FS+228d | 164d |
| 2531165 | Install VME based electronic for Controls/Monitoring FY13 | 20d | 2013-09-03 | 2013-09-30 | 9-130M FS+228d | 43d |
| 2531227aa | Proc IO Modules (DAQ) Batch 2 (Previously Obligated) | 42d | 2013-09-03 | 2013-10-30 | 9-130M FS+228d | 225d |
| 2531227aa5 | Proc IO Modules (DAQ) Batch 2 | 42d | 2013-09-03 | 2013-10-30 | 9-130M FS+228d | 225d |
| 2531315 | Install Computing Infrastructure (DAQ) FY13 | 20d | 2013-09-03 | 2013-09-30 | 9-130M FS+228d | 500d |
| 2531335 | Proc Accessories for Computing Cluster (DAQ) PR FY13 | 20d | 2013-09-03 | 2013-09-30 | 9-130M FS+228d | 95d |
| 2531350 | Proc Hardware for Microscope Voltage Control (DAQ) | 77d | 2013-09-03 | 2013-12-20 | 9-130M FS+228d | 128d |
| 2531390 | Installation Coordination | 20d | 2013-09-03 | 2013-09-30 | 9-130M FS+228d | 216d |
| 2531065a | Proc Fibers for Counting House to Hall (DAQ) PR FY14 | 9d | 2013-10-01 | 2013-10-11 | 9-130M FS+228d, 2531065 | 17d |
| 2531105a | Install Trigger Electrnc's (DAQ) FY14 | 146d | 2013-10-01 | 2014-05-07 | 9-130M FS+228d, 2531105 | 19d |
| 2531115a | Install VME CPUs FY14 | 90d | 2013-10-01 | 2014-02-18 | 9-130M FS+228d, 2531115 | 17d |
| 2531165a | Install VME based electronic for Controls/Monitoring FY14 | 77d | 2013-10-01 | 2014-01-30 | 2531165, 9-130M FS+228d | 43d |
| 2531178 | Software Licenses and Fees | 246d | 2013-10-01 | 2014-09-29 | 9-140M | 101d |
| 2531315a | Install Computing Infrastructure (DAQ) FY14 | 53d | 2013-10-01 | 2013-12-16 | 9-130M FS+228d, 2531315 | 500d |
| 2531335a | Proc Accessories for Computing Cluster (DAQ) PR FY14 | 11d | 2013-10-01 | 2013-10-15 | 2531335, 9-130M FS+228d | 95d |
| 2531070 | Proc Fibers for Counting House to Hall (DAQ) | 29d | 2013-10-14 | 2013-11-21 | 2531065, 2531065a | 17d |
| 2531375 | Check-out Counting House (DAQ) | 31d | 2013-10-15 | 2013-11-26 | 2531390, 9-140M FS+10d, 2531077 | 206d |
| 2531097 | Install infiniband network (DAQ) | 42d | 2013-10-16 | 2013-12-16 | 2531140 | 164d |
| 2531005fa | Proc Single Board Computing Remaining items (DAQ) Phase 2 | 55d | 2013-11-01 | 2014-01-31 | 9-140M FS+23d | 108d |
| 2531089 | Procure Conference Equipment (DAQ) | 75d | 2013-11-01 | 2014-02-28 | 9-140M FS+23d | 149d |
| 2531310 | Install DAQ Equipment in Hall (DAQ) | 84d | 2013-11-01 | 2014-03-13 | 2562405 FS-32d | 0d |
| 2531330 | Proc L3 Farm Infrastucture (DAQ) | 30d | 2013-11-01 | 2013-12-16 | 9-140M FS+23d | 154d |
| 2531395 | Procure Small UPSs for Tagger Hall and Hall D (DAQ) | 77d | 2013-11-01 | 2014-03-04 | 9-140M FS+23d | 147d |
| 2531340 | Proc Accessories for Computing Cluster (DAQ) | 82d | 2013-11-12 | 2014-03-20 | 2531335 FS+19d, 2531335a FS+19d | 95d |
| 2531360 | Patch Panels and Cu Cables to CH (DAQ) | 84d | 2013-11-27 | 2014-04-08 | 2562645 FS+5d, 9-140M FS+41d, 2562645a FS+5d | 122d |
| 2531088 | Procure and Install cameras in the hall (DAQ) | 49d | 2013-12-02 | 2014-02-19 | 9-140M FS+42d | 156d |
| 2531100 | Install DAQ fibers to switches (DAQ) | 68d | 2013-12-02 | 2014-03-18 | 9-140M FS+42d | 107d |
| 2531400 | Procure and Install Voltage Chassis Remote Reset | 59d | 2013-12-05 | 2014-03-10 | 9-140M FS+45d | 143d |
| 2531365 | Sys Admin Support (DAQ) | 188d | 2014-01-06 | 2014-09-30 | 2531315 FS+6d, 2531315a FS+6d | 500d |

| ID | WBS | Task | Duration | Start | Finish | Predecessors | Total float |
| --- | --- | --- | --- | --- | --- | --- | --- |
| 2531380 |  | Check-out Cabling (DAQ) | 30d | 2014-03-19 | 2014-04-29 | 2531100, 2531097 | 107d |
| 2531370 |  | Check-out Online Computers (DAQ) | 40d | 2014-03-21 | 2014-05-15 | 2531027, 2531005f FS+21d, 2531330, 2531340, 2531022, 2531005fa FS+21d | 95d |
| 2531385 |  | Check-out DAQ Hardware (DAQ) | 110d | 2014-04-25 | 2014-09-30 | 2531115a FS+30d, 2531115 FS+30d, 2531310 FS+30d | 0d |
| 2531125 |  | Check-out Trigger Electrnc's (DAQ) | 63d | 2014-05-08 | 2014-08-06 | 2531105, 2531105a | 19d |
| 2531033 |  | Proc Servers for EPICS Archiving (DAQ) | 50d | 2014-10-01 | 2014-12-11 | 9-155M | 447d |
|  | 2 | **1.5.3.2 ONLINE COMPUTING** |  | 2011-04-01 | 2014-09-30 |  |  |
| 1532060 |  | Plan Experiment Controls Framework FY11 (FY12 @ 1532060p) | 128d | 2011-04-01 | 2011-09-30 | 9-110M FS+120d | 48d |
| 1532060a |  | Plan Experiment Controls Display management FY11 | 128d | 2011-04-01 | 2011-09-30 | 9-110M FS+120d | 157d |
| 1532060b |  | Plan Experiment Controls Backup/Restore FY11 | 128d | 2011-04-01 | 2011-09-30 | 9-110M FS+120d | 247d |
| 1532060c |  | Plan Experiment Controls Magnet PS FY11 | 128d | 2011-04-01 | 2011-09-30 | 9-110M FS+120d | 247d |
| 1532060d |  | Plan Experiment Controls HV FY11 | 128d | 2011-04-01 | 2011-09-30 | 9-110M FS+120d | 20d |
| 1532060f |  | Plan Experiment Controls LV FY11 | 128d | 2011-04-01 | 2011-09-30 | 9-110M FS+120d | 20d |
| 1532060g |  | Plan Experiment Controls Motors FY11 | 128d | 2011-04-01 | 2011-09-30 | 9-110M FS+120d | 20d |
| 1532060h |  | Plan Experiment Controls Gas Systems FY11 | 128d | 2011-04-01 | 2011-09-30 | 9-110M FS+120d | 247d |
| 1532060j |  | Plan Experiment Controls Temperature FY11 | 128d | 2011-04-01 | 2011-09-30 | 9-110M FS+120d | 247d |
| 1532060k |  | Plan Experiment Controls Target FY11 | 128d | 2011-04-01 | 2011-09-30 | 9-110M FS+120d | 227d |
| 1532060n |  | Plan Experiment Controls Interface with DAQ FY11 | 128d | 2011-04-01 | 2011-09-30 | 9-110M FS+120d | 20d |
| 1532035 |  | Plan Monitoring Framework FY11(FY12 @ 1532035h) | 86d | 2011-06-01 | 2011-09-30 | 9-110M FS+162d | 180d |
| 1532035a |  | Plan Monitoring Scalers FY11 | 86d | 2011-06-01 | 2011-09-30 | 9-110M FS+162d | 379d |
| 1532035b |  | Plan Monitoring Histograms FY11 | 86d | 2011-06-01 | 2011-09-30 | 9-110M FS+162d | 290d |
| 1532035c |  | Plan Monitoring Remote FY11 | 86d | 2011-06-01 | 2011-09-30 | 9-110M FS+162d | 284d |
| 1532035d |  | Plan Monitoring Hardware Status FY11 | 86d | 2011-06-01 | 2011-09-30 | 9-110M FS+162d | 290d |
| 1532035f |  | Plan Monitoring Process Status FY11 | 86d | 2011-06-01 | 2011-09-30 | 9-110M FS+162d | 379d |
| 1532035g |  | Plan Monitoring Trigger FY11 | 86d | 2011-06-01 | 2011-09-30 | 9-110M FS+162d | 183d |
| 1532011E |  | FY11 Travel (ONLINE COMP) | 64d | 2011-07-01 | 2011-09-30 | 9-110M FS+184d | 20d |
| 1532050 |  | Plan Event Display FY11 | 64d | 2011-07-01 | 2011-09-30 | 9-110M FS+184d | 20d |
| 1532065 |  | Trigger Board Initialization FY11 | 64d | 2011-07-01 | 2011-09-30 | 9-110M FS+184d | 20d |
| 1532067 |  | Level 1 Trigger Verification/debugging FY11 | 64d | 2011-07-01 | 2011-09-30 | 9-110M FS+184d | 20d |
| 1532025 |  | Plan Front-End Software FY11 | 44d | 2011-08-01 | 2011-09-30 | 9-110M FS+204d | 207d |
| 1532030 |  | Plan DAQ Software Event Unblocking FY11 (FY12 @ 1532030d) | 44d | 2011-08-01 | 2011-09-30 | 9-110M FS+204d | 235d |
| 1532030a |  | Plan DAQ Software Scripts FY11 | 44d | 2011-08-01 | 2011-09-30 | 9-110M FS+204d | 145d |
| 1532030b |  | Plan DAQ Software Run Control FY11 | 44d | 2011-08-01 | 2011-09-30 | 9-110M FS+204d | 135d |
| 1532030c |  | Plan DAQ Software Code Management FY11 | 44d | 2011-08-01 | 2011-09-30 | 9-110M FS+204d | 234d |
| 1532010 |  | Proc L3 Farm infrastructure PR | 58d | 2011-10-03 | 2011-12-30 | 1233040M, 9-120M | 347d |
| 1532012E |  | FY12 Travel (ONLINE COMP) FY12 | 247d | 2011-10-03 | 2012-09-28 | 1532011E | 20d |
| 1532025a |  | Plan Front-End Software FY12 | 140d | 2011-10-03 | 2012-04-27 | 1532025 | 207d |
| 1532030aa |  | Plan DAQ Software Scripts FY12 | 140d | 2011-10-03 | 2012-04-27 | 1532030a | 145d |
| 1532030ba |  | Plan DAQ Software Run Control FY12 | 140d | 2011-10-03 | 2012-04-27 | 1532030b | 135d |
| 1532030ca |  | Plan DAQ Software Code Management FY12 | 140d | 2011-10-03 | 2012-04-27 | 1532030c | 234d |
| 1532030d |  | Plan DAQ Software Event Unblocking FY12 (FY11 @ 1532030) | 140d | 2011-10-03 | 2012-04-27 | 1532030 | 235d |
| 1532035aa |  | Plan Monitoring Scalers FY12 | 163d | 2011-10-03 | 2012-05-31 | 1532035a | 379d |
| 1532035ba |  | Plan Monitoring Histograms FY12 | 163d | 2011-10-03 | 2012-05-31 | 1532035b | 290d |
| 1532035ca |  | Plan Monitoring Remote FY12 | 163d | 2011-10-03 | 2012-05-31 | 1532035c | 284d |
| 1532035da |  | Plan Monitoring Hardware Status FY12 | 163d | 2011-10-03 | 2012-05-31 | 1532035d | 290d |
| 1532035fa |  | Plan Monitoring Process Status FY12 | 163d | 2011-10-03 | 2012-05-31 | 1532035f | 379d |
| 1532035ga |  | Plan Monitoring Trigger FY12 | 163d | 2011-10-03 | 2012-05-31 | 1532035g | 183d |
| 1532035h |  | Plan Monitoring Framework FY12 (FY11 @ 1532035) | 163d | 2011-10-03 | 2012-05-31 | 1532035 | 180d |
| 1532040 |  | Plan Alarm Sys | 181d | 2011-10-03 | 2012-06-27 | 9-120M | 165d |
| 1532045 |  | Plan Archiving DAQ Configuration | 160d | 2011-10-03 | 2012-05-25 | 9-120M | 209d |
| 1532045a |  | Plan Archiving Run Info | 160d | 2011-10-03 | 2012-05-25 | 9-120M | 207d |
| 1532045b |  | Plan Archiving Controls | 160d | 2011-10-03 | 2012-05-25 | 9-120M | 207d |
| 1532050a |  | Plan Event Display FY12 | 117d | 2011-10-03 | 2012-03-27 | 1532050 | 20d |
| 1532055 |  | Plan Storage Mngmnt | 120d | 2011-10-03 | 2012-03-30 | 9-120M | 247d |
| 1532060aa |  | Plan Experiment Controls Display management FY12 | 120d | 2011-10-03 | 2012-03-30 | 1532060a | 157d |
| 1532060ba |  | Plan Experiment Controls Backup/Restore FY12 | 120d | 2011-10-03 | 2012-03-30 | 1532060b | 247d |
| 1532060ca |  | Plan Experiment Controls Magnet PS FY12 | 120d | 2011-10-03 | 2012-03-30 | 1532060c | 247d |
| 1532060da |  | Plan Experiment Controls HV FY12 | 120d | 2011-10-03 | 2012-03-30 | 1532060d | 20d |
| 1532060fa |  | Plan Experiment Controls LV FY12 | 120d | 2011-10-03 | 2012-03-30 | 1532060f | 20d |
| 1532060ga |  | Plan Experiment Controls Motors FY12 | 120d | 2011-10-03 | 2012-03-30 | 1532060g | 20d |
| 1532060ha |  | Plan Experiment Controls Gas Systems FY12 | 120d | 2011-10-03 | 2012-03-30 | 1532060h | 247d |
| 1532060ja |  | Plan Experiment Controls Temperature FY12 | 120d | 2011-10-03 | 2012-03-30 | 1532060j | 247d |
| 1532060ka |  | Plan Experiment Controls Target FY12 | 120d | 2011-10-03 | 2012-03-30 | 1532060k | 227d |
| 1532060na |  | Plan Experiment Controls Interface with DAQ FY12 | 120d | 2011-10-03 | 2012-03-30 | 1532060n | 20d |
| 1532060p |  | Plan Experiment Controls Framework FY12 (FY11 @ 1532060) | 120d | 2011-10-03 | 2012-03-30 | 1532060 | 48d |
| 1532065a |  | Trigger Board Initialization FY12 Part A (Hall D grp and CODA grp) | 78d | 2011-10-03 | 2012-01-31 | 1532065 | 20d |
| 1532067a |  | Level 1 Trigger Verification/debugging FY12 Part A | 78d | 2011-10-03 | 2012-01-31 | 1532067 | 20d |
| 1532005 |  | Proc Trigger Testbed Electrnc's PR | 62d | 2012-01-03 | 2012-03-30 | 9-120M FS+58d | 223d |
| 1532065b |  | Trigger Board Initialization FY12 Part B (Hall D grp and CODA grp) | 169d | 2012-02-01 | 2012-09-28 | 1532065a | 20d |
| 1532067b |  | Level 1 Trigger Verification/debugging FY12 Part B | 169d | 2012-02-01 | 2012-09-28 | 1532067a | 20d |
| 1532095 |  | Write Event Display FY12 | 130d | 2012-03-28 | 2012-09-28 | 9-120M, 1532050a | 20d |

| ID | Task | Duration | Start | Finish | Predecessors | Total float |
| --- | --- | --- | --- | --- | --- | --- |
| 1532105 | Write Experiment Control Framework FY12 (FY13 @ 1532105s) | 127d | 2012-04-02 | 2012-09-28 | 1531240, 1532060p | 48d |
| 1532105g | Write Experiment Control Motors FY12 | 127d | 2012-04-02 | 2012-09-28 | 1532060ga | 20d |
| 1532105n | Write Experiment Control Interface with DAQ FY12 | 127d | 2012-04-02 | 2012-09-28 | 1532060na | 20d |
| 1532075b | Write DAQ Software Run Control FY12 | 107d | 2012-04-30 | 2012-09-28 | 1532030ba | 135d |
| 1532075a | Write DAQ Software Scripts FY12 | 84d | 2012-06-01 | 2012-09-28 | 9-120M FS+163d, 1532030aa | 122d |
| 1532080 | Write Monitoring Framework FY12 | 64d | 2012-06-01 | 2012-08-30 | 1532035h, 9-120M | 180d |
| 1532080b | Write Monitoring Histograms FY12 | 84d | 2012-06-01 | 2012-09-28 | 1532035ba | 290d |
| 1532080d | Write Monitoring Hardware Status FY12 | 84d | 2012-06-01 | 2012-09-28 | 1532035da | 290d |
| 1532105d | Write Experiment Control HV FY12 | 42d | 2012-08-01 | 2012-09-28 | 1532060da FS+85d | 20d |
| 1532105f | Write Experiment Control LV FY12 | 42d | 2012-08-01 | 2012-09-28 | 1532060fa FS+85d | 20d |
| 1532007 | Proc Trigger Testbed Electrnc's (coordinate with Hovanes) Part A | 93d | 2012-10-01 | 2013-02-20 | 9-130M, 1532005 | 96d |
| 1532007a | Proc Trigger Testbed Electrnc's (coordinate with Hovanes) Part B | 93d | 2012-10-01 | 2013-02-20 | 9-130M, 1532005 | 96d |
| 1532012Ea | FY12 Travel (ONLINE COMP) FY13 | 1d | 2012-10-01 | 2012-10-01 | 1532012E, 1532011E | 20d |
| 1532065c | Trigger Board Initialization FY13 (Hall D grp and CODA grp) | 228d | 2012-10-01 | 2013-08-30 | 1532065b | 20d |
| 1532067c | Level 1 Trigger Verification/debugging FY13 | 228d | 2012-10-01 | 2013-08-30 | 1532067b | 20d |
| 1532075ba | Write DAQ Software Run Control FY13 | 113d | 2012-10-01 | 2013-03-20 | 1532075b | 135d |
| 1532080a | Write Monitoring Scalers | 121d | 2012-10-01 | 2013-04-01 | 9-130M, 1532035aa | 295d |
| 1532080ba | Write Monitoring Histograms FY13 | 136d | 2012-10-01 | 2013-04-22 | 1532080b | 290d |
| 1532080da | Write Monitoring Hardware Status FY13 | 136d | 2012-10-01 | 2013-04-22 | 1532080d | 290d |
| 1532095a | Write Event Display FY13 | 90d | 2012-10-01 | 2013-02-14 | 1532095 | 20d |
| 1532105da | Write Experiment Control HV FY13 | 77d | 2012-10-01 | 2013-01-28 | 1532105d | 20d |
| 1532105fa | Write Experiment Control LV FY13 | 77d | 2012-10-01 | 2013-01-28 | 1532105f | 20d |
| 1532105ga | Write Experiment Control Motors FY13 | 93d | 2012-10-01 | 2013-02-20 | 1532105g | 20d |
| 1532105na | Write Experiment Control Interface with DAQ FY13 | 93d | 2012-10-01 | 2013-02-20 | 1532105n | 20d |
| 1532105s | Write Experiment Control Framework FY13 (FY12 @ 1532105) | 93d | 2012-10-01 | 2013-02-20 | 1532105 | 48d |
| 1532013E | FY13 Travel (ONLINE COMP) | 227d | 2012-10-02 | 2013-08-30 | 1532012E, 1532012Ea | 20d |
| 1532075c | Write DAQ Software Code Management | 121d | 2012-10-15 | 2013-04-15 | 9-130M FS+10d, 1532030ca | 117d |
| 1532105a | Write Experiment Control Display Management | 121d | 2012-10-15 | 2013-04-15 | 9-130M FS+10d, 1532060aa | 20d |
| 1532080f | Write Monitoring Process Status | 131d | 2013-01-31 | 2013-08-06 | 9-130M FS+79d, 1532035fa | 216d |
| 1532080g | Write Monitoring Trigger | 149d | 2013-01-31 | 2013-08-30 | 9-130M FS+79d, 1532035ga | 20d |
| 1532085 | Write Alarm Sys | 136d | 2013-01-31 | 2013-08-13 | 9-130M FS+79d, 1532040 | 20d |
| 1532070 | Write Front-End Software | 120d | 2013-02-01 | 2013-07-23 | 1532025a, 9-130M FS+80d | 20d |
| 1532075 | Write DAQ Software Event Unblocking | 120d | 2013-02-01 | 2013-07-23 | 1532030d, 9-130M FS+80d | 48d |
| 1532105k | Write Experiment Control Target | 126d | 2013-02-01 | 2013-07-31 | 1532060ka, 9-130M FS+80d | 20d |
| 1532010a | Proc L3 Farm infrastructure Phase 1 | 90d | 2013-03-04 | 2013-07-09 | 9-130M FS+100d, 1532010 | 58d |
| 1532077 | Write DAQ Software Scripts FY13 | 126d | 2013-03-04 | 2013-08-28 | 1532075a, 9-130M FS+100d | 22d |
| 1532080c | Write Monitoring Remote | 126d | 2013-03-04 | 2013-08-28 | 9-130M FS+100d, 1532035ca | 100d |
| 1532090 | Write Archiving DAQ Configuration | 84d | 2013-03-04 | 2013-06-28 | 1532045, 9-130M FS+100d | 22d |
| 1532090a | Write Archiving Run Info | 126d | 2013-03-04 | 2013-08-28 | 1532045a, 9-130M FS+100d | 20d |
| 1532090b | Write Archiving Controls | 126d | 2013-03-04 | 2013-08-28 | 9-130M FS+100d, 1532045b | 20d |
| 1532100 | Write Storage Mngmnt | 126d | 2013-03-04 | 2013-08-28 | 9-130M FS+100d, 1532055 | 20d |
| 1532105b | Write Experiment Control Display Backup/Restore | 63d | 2013-03-04 | 2013-05-30 | 1532060ba, 9-130M FS+100d | 20d |
| 1532105c | Write Experiment Control Magnet PS | 126d | 2013-03-04 | 2013-08-28 | 9-130M FS+100d, 1532060ca | 20d |
| 1532105h | Write Experiment Control Gas Systems | 126d | 2013-03-04 | 2013-08-28 | 1532060ha, 9-130M FS+100d | 20d |
| 1532105j | Write Experiment Control Temerature | 126d | 2013-03-04 | 2013-08-28 | 9-130M FS+100d, 1532060ja | 20d |
| 1532082 | Write Monitoring Framework FY13 | 88d | 2013-04-29 | 2013-08-30 | 9-130M FS+140d, 1532080 | 20d |
| 1532015 | Install L3 Farm infrastructure | 38d | 2013-07-10 | 2013-08-30 | 9-130M FS+190d | 20d |
| 1532210 | Re-Baseline Actuals Adjustment | 1d | 2013-08-30 | 2013-08-30 | 9-130M FS+227d | 20d |
| 2532000 | Purchased Labor (Sergey) | 20d | 2013-09-03 | 2013-09-30 | 9-130M FS+228d | 247d |
| 2532005 | Install OS system along with network 9settings FY13 | 20d | 2013-09-03 | 2013-09-30 | 9-130M FS+228d | 81.25d |
| 2532013E | FY13 Travel (ONLINE COMP) | 20d | 2013-09-03 | 2013-09-30 | 9-130M FS+228d | 501d |
| 2532020 | Coordination of online computing setup | 20d | 2013-09-03 | 2013-09-30 | 9-130M FS+228d | 129d |
| 2532035 | Create scripts to launch and kill: CODA system, monitoring system FY13 | 20d | 2013-09-03 | 2013-09-30 | 9-130M FS+228d | 65d |
| 2532040 | Run bookkeeping scripts (database;data files and special events) FY13 | 20d | 2013-09-03 | 2013-09-30 | 9-130M FS+228d | 27d |
| 2532050 | Readout Lists FY13 | 20d | 2013-09-03 | 2013-09-30 | 9-130M FS+228d | 0d |
| 2532070 | Implement Translation Tables FY13 | 20d | 2013-09-03 | 2013-09-30 | 2532030 FS-118d | 65d |
| 2532080 | ROOTSpy enabled Monitoring Processes FY13 | 20d | 2013-09-03 | 2013-09-30 | 2532030 FS-118d | 39d |
| 2532170a | HV Controls (FDC; CDC; TOF; FCAL; HODO) Phase 2 FY13 | 20d | 2013-09-03 | 2013-09-30 | 9-130M FS+228d | 162d |
| 2532175 | LV Controls (BCAl; ST; FDC) FY13 | 20d | 2013-09-03 | 2013-09-30 | 9-130M FS+228d | 0d |
| 2532205 | Motors (radiator, converter, collimator, tagger) FY13 | 20d | 2013-09-03 | 2013-09-30 | 9-130M FS+228d | 20d |
| 2532215 | CSS Control GUIs FY13 | 20d | 2013-09-03 | 2013-09-30 | 9-130M FS+228d | 11d |
| 2532230 | Alarms (configuration,display, history) FY13 | 20d | 2013-09-03 | 2013-09-30 | 9-130M FS+228d | 83d |
| 2532250 | EPICS Archving and Restoration FY13 | 20d | 2013-09-03 | 2013-09-30 | 9-130M FS+228d | 0d |
| 2532005a | Install OS system along with network 9settings FY14 | 20.75d | 2013-10-01 | 2013-10-29 | 9-130M FS+228d, 2532005 | 81.25d |
| 2532014E | FY14 Travel (ONLINE COMP) | 246d | 2013-10-01 | 2014-09-29 | 2532013E | 501d |
| 2532035a | Create scripts to launch and kill: CODA system, monitoring system FY14 | 69d | 2013-10-01 | 2014-01-17 | 9-130M FS+228d, 2532035 | 65d |
| 2532040a | Run bookkeeping scripts (database;data files and special events) FY14 | 107d | 2013-10-01 | 2014-03-13 | 2532040, 9-130M FS+228d | 27d |
| 2532050a | Readout Lists FY14 | 134d | 2013-10-01 | 2014-04-21 | 9-130M FS+228d, 2532050 | 0d |
| 2532070a | Implement Translation Tables FY14 | 69d | 2013-10-01 | 2014-01-17 | 2532030 FS-118d, 2532070 | 65d |
| 2532080a | ROOTSpy enabled Monitoring Processes FY14 | 80d | 2013-10-01 | 2014-02-04 | 2532030 FS-118d, 2532080 | 39d |

| ID | WBS | Task | Duration | Start | Finish | Predecessors | Total float |
| --- | --- | --- | --- | --- | --- | --- | --- |
| 2532170aa |  | HV Controls (FDC; CDC; TOF; FCAL; HODO) Phase 2 FY14 | 85d | 2013-10-01 | 2014-02-11 | 2532170a, 9-130M FS+228d | 162d |
| 2532175b |  | LV Controls (BCAl; ST; FDC) FY14 | 120d | 2013-10-01 | 2014-04-01 | 2532175, 9-130M FS+228d | 0d |
| 2532205a |  | Motors (radiator, converter, collimator, tagger) FY14 | 100d | 2013-10-01 | 2014-03-04 | 9-130M FS+228d, 2532205 | 20d |
| 2532215a |  | CSS Control GUIs FY14 | 109d | 2013-10-01 | 2014-03-17 | 9-130M FS+228d, 2532215 | 11d |
| 2532230a |  | Alarms (configuration,display, history) FY14 | 25d | 2013-10-01 | 2013-11-04 | 9-130M FS+228d, 2532230 | 83d |
| 2532250a |  | EPICS Archving and Restoration FY14 | 119d | 2013-10-01 | 2014-03-31 | 9-130M FS+228d, 2532250 | 0d |
| 2532055 |  | Write COOL Config Files | 79d | 2013-11-01 | 2014-03-06 | 2532030 FS-75d | 32d |
| 2532100 |  | Transport from RAID to Tape Silo | 86d | 2013-11-01 | 2014-03-17 | 9-140M FS+23d | 2d |
| 2532185 |  | Tagger magnet and NMR control SWT (accel Grp) | 51d | 2013-11-05 | 2014-01-29 | 2562050a FS+17d, 2562050 FS+17d | 44d |
| 2532130 |  | FDC/CDC Gas Systems Controls | 43d | 2013-11-12 | 2014-01-24 | 2562392 FS+21d, 2562392a FS+21d | 47d |
| 2532190 |  | Sweeping and pair spectrometer magnet control SWT (accel Grp) | 54d | 2013-11-12 | 2014-02-10 | 2553035 FS+30d | 36d |
| 2532245 |  | DAQ monitoring Software | 125d | 2013-11-27 | 2014-06-06 | 9-140M FS+41.5d | 80.5d |
| 2532015 |  | Database web-server wiki installations | 32d | 2013-12-02 | 2014-01-27 | 2532030 FS-56d, 2532005a, 2532005 | 60d |
| 2532030 |  | Install CODA and supporting software | 56d | 2013-12-02 | 2014-02-28 | 9-140M FS+42d | 1d |
| 2532075 |  | Farm Process Manager | 204d | 2013-12-02 | 2014-09-29 | 2532030 FS-56d | 1d |
| 2532115 |  | Archiving DAQ Configuration | 125d | 2013-12-02 | 2014-06-06 | 2532030 FS-56d | 80d |
| 2532145 |  | Temperature/Humidity monitoring | 48d | 2013-12-02 | 2014-02-18 | 9-140M FS+42d | 30d |
| 2532140 |  | Controls for Chillers (FDC;BCAL;Target) | 68d | 2013-12-16 | 2014-04-01 | 9-140M FS+52d | 0d |
| 2532135 |  | BCAL Gas System Controls | 34d | 2014-01-02 | 2014-02-19 | 2562830 FS+37d, 2562830a FS+37d | 29d |
| 2532180 |  | BIAS Control for Microscope | 62d | 2014-01-02 | 2014-03-31 | 2531350 | 128d |
| 2532155 |  | Cryo Target Controls | 50d | 2014-01-09 | 2014-03-20 | 9-140M FS+62d | 8d |
| 2532200 |  | Vacuum System Controls (accel Grp) | 37d | 2014-01-14 | 2014-03-06 | 9-140M FS+65d | 18d |
| 2532110 |  | Archiving Run Conditions | 181d | 2014-01-15 | 2014-09-30 | 9-140M FS+66d | 0d |
| 2532195 |  | Active collimator integration EPICS (Acceler grp) | 173d | 2014-01-17 | 2014-09-22 | 9-140M FS+68d | 6d |
| 2532235 |  | Scaler Monitoring in EPICS | 179d | 2014-01-17 | 2014-09-30 | 9-140M FS+68d | 0d |
| 2532240 |  | Trigger Monitoring in EPICS | 179d | 2014-01-17 | 2014-09-30 | 9-140M FS+68d | 0d |
| 2532150 |  | FCAL Dark Room Controls | 42d | 2014-02-10 | 2014-04-08 | 9-140M FS+83d | 65d |
| 2532085 |  | Archiving and Retrieval of Histogram Files | 138d | 2014-03-04 | 2014-09-16 | 2532030, 9-140M FS+99d | 10d |
| 2532090 |  | Event Display | 122d | 2014-03-05 | 2014-08-25 | 9-140M FS+100d | 25d |
| 2532220 |  | Debug EPICS Controls Sofware | 127d | 2014-03-18 | 2014-09-15 | 2532205a, 2532200, 2531165a, 2532215, 2532190, 2531165, 2532205, 2532185, 2532215a | 11d |
| 2532255 |  | Coherent Peak Alignment Software with Goniometer | 122d | 2014-04-01 | 2014-09-22 | 2532250a, 2532250 | 6d |
| 2532175a |  | LV Controls (BCAl; ST; FDC) Phase 2 | 127d | 2014-04-02 | 2014-09-30 | 2532175b, 2532175 | 0d |
| 2532225 |  | Debug PLC Controls Sofware | 127d | 2014-04-02 | 2014-09-30 | 2532130, 2532145, 2532150 FS-70d, 2532135, 2532155, 2532140 | 0d |
| 2532060 |  | Debug DAQ software | 113d | 2014-04-22 | 2014-09-30 | 2532040a, 2532070, 2532050a, 2532035, 2532050, 2532040, 2532055, 2532015, 2532035a, 2532070a | 0d |
|  | 3 | **1.5.3.3 OFFLINE COMPUTING** |  |  |  |  |  |
|  | 4 | **1.5.4 ELECTRONICS** |  | 2008-11-03 | 2014-09-30 |  |  |
|  | 1 | **1.5.4.1 FADC** |  | 2009-10-01 | 2014-09-30 |  |  |
| 1541010E |  | FY10 Travel (FADC) | 248d | 2009-10-01 | 2010-09-30 | 9-100M | 438d |
| 1541029 |  | Vend Fab First Article fADCs for PMTs (FADC) (IPL 5541140M) | 68d | 2010-06-07 | 2010-09-10 | 9-100M FS+166d | 326d |
| 1541084 |  | First Articles fADCs for DCs (FADC) (IPL 5541170) | 120d | 2010-07-02 | 2010-12-29 | 9-100M FS+185d | 467d |
| 1541005 |  | Calibrate ADC gain and linearity (FADC) | 25d | 2010-10-01 | 2010-11-04 | 9-110M | 253d |
| 1541011E |  | FY11 Travel (FADC) | 248d | 2010-10-01 | 2011-09-30 | 1541010E | 438d |
| 1541010 |  | Develop gain correction database for FADC in FPGA (FADC) | 25d | 2010-11-05 | 2010-12-13 | 9-110M, 1541005 | 253d |
| 1541015 |  | Implement PMT Features Extraction Algorithms (FADC) | 9d | 2010-12-14 | 2010-12-31 | 9-110M, 1541010 | 253d |
| 1541085 |  | fADC125 - Procurement Support Pre Production Modules (QTY 3) | 69d | 2011-03-07 | 2011-06-10 | 9-110M FS+101d, 1541084 | 423d |
| 1541030 |  | fADC250 - Full Single-Crate Acceptance Test (FADC) | 68d | 2011-06-06 | 2011-09-09 | 1541015, 1541029, 9-110M FS+165d | 147d |
| 1541040 |  | fADC250 - Production Procurement Support (FADC) FY11 | 37d | 2011-08-10 | 2011-09-30 | 1541030 FS-22d | 147d |
| 1541012E |  | FY12 Travel (FADC) | 247d | 2011-10-03 | 2012-09-28 | 1541011E | 438d |
| 1541040a |  | fADC250 - Production Procurement Support (FADC) FY12 | 25d | 2011-10-03 | 2011-11-04 | 1541040 | 147d |
| 1541065 |  | Assemble DC Logic/Signal Analyzers (FADC) (in 6 GeV also) | 25d | 2011-10-03 | 2011-11-04 | 9-120M | 395d |
| 1541125 |  | fADC125 - Procurement Support (FADC) | 10d | 2011-10-18 | 2011-10-31 | 9-120M FS+11d | 343d |
| 1541112 |  | Test stand for testing/acceptance of FADC125 | 119d | 2011-11-01 | 2012-04-27 | 1541100 FS-119d, 9-120M | 302d |
| 1541070 |  | Implement DC CODA Libraries (FADC) (in 6 GeV also) | 25d | 2011-11-07 | 2011-12-13 | 1541065, 9-120M | 395d |
| 1541085b |  | fADC125 - Pre Production Modules (QTY 3) | 57d | 2011-12-05 | 2012-03-02 | 1541085, 9-120M FS+43d | 302d |
| 1541075 |  | Implement DC Features Extraction Algorithms (FADC) | 25d | 2011-12-14 | 2012-01-26 | 1541070, 9-120M | 395d |
| 1541045 |  | fADC250 - Production (FADC) | 231d | 2012-01-04 | 2012-11-30 | 9-120M FS+59d, 1541040a | 113d |
| 1541100 |  | fADC125 - Test Pre Production Modules (QTY 3) | 76d | 2012-01-11 | 2012-04-27 | 1541085b FS-36d | 302d |
| 1541080 |  | Dry Run of Test DC Procedures (FADC) (in 6 GeV also) | 25d | 2012-01-27 | 2012-03-02 | 1541075, 9-120M | 395d |
| 1541130 |  | Vend Fab FADC125 Peg Points #1 and # 2 Board Samples Mezzanine and Main | 36d | 2012-07-13 | 2012-08-31 | 9-120M FS+192d, 1541125 | 172d |
| 1541132 |  | Vend Fab FADC125 Peg Points #3 and # 4 First Article Mezzanine and Main (Qty. 1 Each) | 78d | 2012-07-13 | 2012-10-31 | 1541130 FS-36d | 172d |
| 1541134 |  | Vend Fab FADC125 Peg Points #5 and # 6 Production Units Mezzanine and Main (Qty. 50 Each) | 114d | 2012-07-13 | 2012-12-31 | 1541132 FS-78d | 178d |
| 1541136 |  | Vend Fab FADC125 Peg Points #7 and # 8 Production Units Mezzanine and Main (Qty. 50 Each) | 114d | 2012-07-13 | 2012-12-31 | 1541134 FS-114d | 178d |
| 1541138 |  | Vend Fab FADC125 Peg Points #9 and # 10 Production Units Mezzanine and Main (Qty. 50 Each) | 135d | 2012-07-13 | 2013-01-31 | 1541136 FS-114d | 178d |
| 1541143 |  | Vend Fab FADC125 Peg Points #11 and # 12 Production Units Mezzanine and Main (Qty. 66 Each) | 135d | 2012-07-13 | 2013-01-31 | 1541138 FS-135d | 178d |
| 1541057 |  | UMASS - fADC250 - Production Test (FADC) Rediness Review | 5d | 2012-09-24 | 2012-09-28 | 1543125, 1543016a, 1541045 FS-48d | 113d |
| 1541013E |  | FY13 Travel (FADC) | 58d | 2012-10-01 | 2012-12-21 | 1541012E | 438d |
| 1541058M |  | UMASS - Begin fADC250 - Production Test (FADC) | 0d | 2012-10-31 | 2012-10-31 | 1541057 FS+22d | 113d |
| 1541059 |  | UMASS - fADC250 - Production Test (FADC) | 98d | 2012-10-31 | 2013-03-29 | 1541058M | 113d |
| 1541060 |  | Assy of fADC PMT as part of Trigger (FADC) | 65d | 2012-12-03 | 2013-03-13 | 1541045 | 140d |
| 1541145 |  | fADC125 - Test (Qty 217) (FADC) | 84d | 2013-05-03 | 2013-08-30 | 1541112, 9-130M FS+144d, 1541132, 1541143 FS-63d | 51d |

| ID | WBS | Task | Duration | Start | Finish | Predecessors | Total float |
| --- | --- | --- | --- | --- | --- | --- | --- |
| 1541120 |  | fADC125 - Full Single-Crate Acceptance Test (FADC) | 41d | 2013-05-21 | 2013-07-18 | 1541145 FS-72d, 9-130M FS+80d | 51d |
| 1541150 |  | Re-Baseline Actuals Adjustment | 1d | 2013-08-30 | 2013-08-30 | 9-130M FS+227d | 20d |
| 2541000 |  | Vend Fab FADC-125 (Previously Obligated) | 210d | 2013-09-03 | 2014-07-10 | 9-130M FS+228d | 57d |
| 2541015 |  | Rework of Production FADC Modules (FE) FY13 | 20d | 2013-09-03 | 2013-09-30 | 9-130M FS+228d | 57d |
| 2541145 |  | fADC125 - Test (Qty 217) (FADC) FY13 | 20d | 2013-09-03 | 2013-09-30 | 9-130M FS+228d | 111d |
| 2541150 |  | FADC125 Production firmware development FY13 (Hall D EE) | 20d | 2013-09-03 | 2013-09-30 | 9-130M FS+228d | 1d |
| 2541152 |  | Algorithm Development for DC FADC125 FY13 | 20d | 2013-09-03 | 2013-09-30 | 9-130M FS+228d | 0d |
| 2541120 |  | fADC125 - Full Single-Crate Acceptance Test (FADC) FY13 | 16d | 2013-09-09 | 2013-09-30 | 2541145 FS-58d, 2541145a FS-58d | 111d |
| 2541015a |  | Rework of Production FADC Modules (FE) FY14 | 190d | 2013-10-01 | 2014-07-10 | 9-130M FS+228d, 2541015 | 57d |
| 2541120a |  | fADC125 - Full Single-Crate Acceptance Test (FADC) FY14 | 57d | 2013-10-01 | 2013-12-20 | 2541120, 2541145a FS-58d, 2541145 FS-58d | 111d |
| 2541145a |  | fADC125 - Test (Qty 217) (FADC) FY14 | 42d | 2013-10-01 | 2013-11-27 | 9-130M FS+228d, 2541145 | 111d |
| 2541150a |  | FADC125 Production firmware development FY14 (Hall D EE) | 57d | 2013-10-01 | 2013-12-20 | 2541150, 9-130M FS+228d | 1d |
| 2541152a |  | Algorithm Development for DC FADC125 FY14 | 219d | 2013-10-01 | 2014-08-20 | 9-130M FS+228d, 2541152 | 0d |
| 2541155 |  | FADC EE Hardware/software support in FY14 (Hall D EE) | 205d | 2013-12-02 | 2014-09-30 | 2541150 FS-16d, 2541150a FS-16d, 9-140M FS+42d | 0d |
| 2541154 |  | Code Deployment and Full Readout Tests FADC125 | 124d | 2014-04-07 | 2014-09-30 | 2541152a FS-96d, 2541152 FS-96d | 0d |
|  | 2 | **1.5.4.2 TDC** |  | 2008-11-03 | 2014-09-30 |  |  |
| 1542025 |  | Phase 1 Proc TDCs (TDC) | 247d | 2008-11-03 | 2009-10-30 | 9-090M FS+23d | 370d |
| 1542005 |  | Assemble Logic/Signal Analyzers (TDC) (in 6 GeV also) | 43.5d | 2010-10-01 | 2010-12-03 | 9-110M, 1234180M | 85d |
| 1542011E |  | FY11 Travel (TDC) | 248d | 2010-10-01 | 2011-09-30 | 9-110M | 190d |
| 1542010 |  | Measure cross talk for CFD & TDC (TDC) | 15.5d | 2010-12-03 | 2010-12-31 | 9-110M, 1542005 | 85d |
| 1542025a |  | F1TDC - First Article Procurement Support (TDC) | 92d | 2011-01-04 | 2011-05-13 | 1234180M, 1542010, 1542025, 9-110M FS+59d | 85d |
| 1542026 |  | F1TDC - Parts (TDC) | 121d | 2011-01-18 | 2011-07-08 | 1542025a FS-83d | 85d |
| 1542015 |  | Dry Run of Test Procedures TDC | 100d | 2011-03-10 | 2011-07-29 | 1542010 FS+45d | 305d |
| 1542027 |  | F1TDC - First Article Fab V2 (QTY 2) (TDC) | 14d | 2011-08-29 | 2011-09-16 | 1542026 FS+35d | 85d |
| 1542030 |  | F1TDC - First Article Assembly V2 (QTY 2) (TDC) | 15d | 2011-09-19 | 2011-10-07 | 1542027 | 85d |
| 1542012E |  | FY12 Travel (TDC) | 247d | 2011-10-03 | 2012-09-28 | 1542011E | 190d |
| 1542036 |  | Test stand for testing/acceptance of F1TDC | 67d | 2011-10-03 | 2012-01-13 | 1542010, 9-120M, 1542015 | 261d |
| 1542031 |  | F1TDC - First Article Fab V3 (QTY 2) (TDC) | 10d | 2011-10-31 | 2011-11-11 | 1542030 FS+15d | 85d |
| 1542031a |  | F1TDC - First Article Assembly V3 (QTY 2) (TDC) | 41d | 2011-11-21 | 2012-01-27 | 1542031 FS+5d | 85d |
| 1542030a |  | F1TDC - First Article Test V2 (QTY 2) (TDC) | 78d | 2012-03-26 | 2012-07-13 | 9-120M FS+115d, 1542030 | 21d |
| 1542031b |  | F1TDC - First ArticleTest V3 (QTY 2) (TDC) | 53d | 2012-04-16 | 2012-06-29 | 9-120M FS+130d, 1542031a | 31d |
| 1542032 |  | F1TDC - First Article Fab (QTY 18) (TDC) | 20d | 2012-07-16 | 2012-08-10 | 9-120M FS+35d, 1542030a, 1542031b, 1542031a, 1542030 | 21d |
| 1542035 |  | F1TDC - First Article Assembly (QTY 18) (TDC) | 57d | 2012-08-13 | 2012-10-31 | 1542032 | 21d |
| 1542013E |  | FY13 Travel (TDC) | 58d | 2012-10-01 | 2012-12-21 | 1542012E | 190d |
| 1542035a |  | F1TDC - First ArticleTest V2 (QTY 18) (TDC) | 150d | 2012-11-01 | 2013-06-13 | 1542035 | 21d |
| 1542037 |  | F1TDC - Full Single-Crate Acceptance Test (TDC) | 58d | 2012-11-01 | 2013-02-01 | 1542036, 1542035 | 58d |
| 1542040 |  | F1TDC - Production Procurement Prep (TDC) | 62d | 2012-12-17 | 2013-03-22 | 1542037 FS-28d | 58d |
| 1542042 |  | F1TDC - Production (TDC) | 85d | 2013-05-02 | 2013-08-30 | 1542040 FS+28d | 58d |
| 1542045 |  | UMASS - F1TDC - Production Test (TDC) Readiness Review | 5d | 2013-06-07 | 2013-06-13 | 1542042 FS-97d, 1542035a FS-5d | 21d |
| 1542050M |  | UMASS - Begin fADC250 - Production Test (FADC) | 0d | 2013-06-14 | 2013-06-14 | 1542045 | 21d |
| 1542055 |  | UMASS - fADC250 - Production Test (FADC) | 54d | 2013-06-14 | 2013-08-29 | 1542050M | 21d |
| 1542060 |  | Re-Baseline Actuals Adjustment | 1d | 2013-08-30 | 2013-08-30 | 9-130M FS+227d | 20d |
| 2542037 |  | F1TDC - Full Single-Crate Acceptance Test (TDC) | 14d | 2013-09-03 | 2013-09-20 | 9-130M FS+228d | 253d |
| 2542070 |  | F1TDC develop firmware FY13 | 20d | 2013-09-03 | 2013-09-30 | 9-130M FS+228d | 0d |
| 2542070a |  | F1TDC develop firmware FY14 | 61d | 2013-10-01 | 2014-01-07 | 2542070, 9-130M FS+228d | 0d |
| 2542085 |  | Rework of Production F1TDC modules | 134d | 2013-10-10 | 2014-04-30 | 9-140M FS+7d | 106d |
| 2542090 |  | F1TDC EE Hardware/Software Support FY14 | 186d | 2014-01-08 | 2014-09-30 | 2542070a, 2542070 | 0d |
| 2542075 |  | FPGA Coding, Hardware & Firmware Integration Tests F1TDC | 44d | 2014-01-29 | 2014-03-31 | 2542070 FS+14d, 2542070a FS+14d | 84d |
| 2542080 |  | Code Deployment and Full Readout Tests F1TDC | 39d | 2014-04-08 | 2014-06-02 | 2542075 FS+5d | 84d |
|  | 3 | **1.5.4.3 TRIGGER** |  | 2009-10-01 | 2014-09-30 |  |  |
| 1543010E |  | FY10 Travel (TRIGR) | 248d | 2009-10-01 | 2010-09-30 | 9-100M | 438d |
| 1543005 |  | Assemble Logic/Signal Analyzers for Energy Sum Tests (Trigger) | 20d | 2010-10-01 | 2010-10-28 | 9-110M, 1234180M | 606d |
| 1543011E |  | FY11 Travel (TRIGR) | 248d | 2010-10-01 | 2011-09-30 | 1543010E | 438d |
| 1543010 |  | Implement CODA Libraries for Energy Sum (Trigger) (in 6 GeV also) | 20d | 2010-10-29 | 2010-11-29 | 1543005 | 606d |
| 1543015 |  | Implement Features Extraction Algorithms | 20d | 2010-11-30 | 2011-01-04 | 1543010 | 606d |
| 1543120 |  | Prepare test stand for testing/acceptance of FADC250 | 93d | 2011-01-04 | 2011-05-16 | 9-110M FS+59d | 451d |
| 1543125 |  | Procument equipment for testing FADC250 | 93d | 2011-01-04 | 2011-05-16 | 1543120 FS-93d | 451d |
| 1543140 |  | Develop trigger algorithms FY11 | 189d | 2011-01-04 | 2011-09-30 | 9-110M FS+59d | 209d |
| 1543105 |  | Full crate performance testing | 129d | 2011-03-01 | 2011-08-30 | 9-110M FS+97d | 452d |
| 1543016 |  | Programing FADC250 FPGAs FY11 | 128d | 2011-04-01 | 2011-09-30 | 9-110M FS+120d | 235d |
| 1543110 |  | Testing of multi-crate board performance FY11 | 107d | 2011-05-02 | 2011-09-30 | 9-110M FS+141d | 388d |
| 1543023 |  | Preparing procument of CTP boards | 48d | 2011-05-03 | 2011-07-11 | 9-110M FS+142d | 228d |
| 1543050 |  | Preparing procument of SD boards | 15d | 2011-05-09 | 2011-05-27 | 9-110M FS+146d | 219d |
| 1543065 |  | Preparing procument of SSP boards FY11 | 83d | 2011-06-06 | 2011-09-30 | 9-110M FS+165d | 266d |
| 1543035 |  | Preparing procument TI-D boards | 45d | 2011-07-06 | 2011-09-07 | 9-110M FS+186d | 126d |
| 1543080 |  | Preparing procument of GTP boards FY11 | 10d | 2011-09-19 | 2011-09-30 | 9-110M FS+238d | 108d |
| 1543012E |  | FY12 Travel (TRIGR) | 247d | 2011-10-03 | 2012-09-28 | 1543011E | 438d |
| 1543016a |  | Programing FADC250 FPGAs FY12 | 120d | 2011-10-03 | 2012-03-30 | 1543016 | 235d |
| 1543040 |  | Procument of TI-D boards (FE grp) Part A | 270d | 2011-10-03 | 2012-10-31 | 1543035 FS+2d, 9-120M | 111d |
| 1543040a |  | Procument of TI-D boards (FE grp) Part B | 270d | 2011-10-03 | 2012-10-31 | 1543035 FS+2d, 9-120M | 111d |

| ID | WBS | Task | Duration | Start | Finish | Predecessors | Total float |
| --- | --- | --- | --- | --- | --- | --- | --- |
| 1543065a |  | Preparing procument of SSP boards FY12 (FE grp) | 5d | 2011-10-03 | 2011-10-07 | 1543065 | 266d |
| 1543080a |  | Preparing procument of GTP boards FY12 | 13d | 2011-10-03 | 2011-10-19 | 1543080 | 108d |
| 1543095 |  | Preparing procument of Fiber Optics Cable/Patch Pannel | 20d | 2011-10-03 | 2011-10-28 | 9-120M | 370d |
| 1543110a |  | Testing of multi-crate board performance FY12 | 42d | 2011-10-03 | 2011-12-01 | 1543110 | 388d |
| 1543135 |  | Develop FADC250 features extraction algorithms (readout) (Hall D grp) | 120d | 2011-10-03 | 2012-03-30 | 9-120M | 147d |
| 1543140a |  | Develop trigger algorithms FY12 (Hall D grp) | 58d | 2011-10-03 | 2011-12-30 | 1543140 | 209d |
| 1543100 |  | Procument Fiber Optics Cable/Patch Pannel (FE grp) | 40d | 2011-10-31 | 2012-01-04 | 1543095 | 370d |
| 1543055 |  | Procument of SD boards (FE grp) Part A | 249d | 2011-11-01 | 2012-10-31 | 1543050, 9-120M FS+21d | 111d |
| 1543055a |  | Procument of SD boards (FE grp) Part B | 249d | 2011-11-01 | 2012-10-31 | 9-120M FS+21d, 1543050 | 111d |
| 1543085 |  | Procument of GTP boards (FE grp) Part A | 332d | 2012-02-01 | 2013-05-30 | 1543080a, 9-120M FS+78d | 43d |
| 1543085a |  | Procument of GTP boards (FE grp) Part B | 332d | 2012-02-01 | 2013-05-30 | 9-120M FS+78d, 1543080a | 43d |
| 1543141 |  | Procure Equipment for Algorithm Test Stand ( Hall D grp ) Part A | 87d | 2012-05-01 | 2012-08-31 | 9-120M FS+141d | 39d |
| 1543141a |  | Procure Equipment for Algorithm Test Stand ( Hall D grp ) Part B | 87d | 2012-05-01 | 2012-08-31 | 9-120M FS+141d | 39d |
| 1543017 |  | Preparing procument of TS board | 17d | 2012-05-07 | 2012-05-30 | 9-120M FS+145d | 256d |
| 1543130 |  | Implement playback mode | 84d | 2012-06-01 | 2012-09-28 | 9-120M FS+163d | 20d |
| 1543045 |  | Acceptance test of TI boards (FE grp) FY12 | 76d | 2012-06-14 | 2012-09-28 | 1543040 FS-99d, 1543040a FS-99d | 111d |
| 1543060 |  | Acceptance test of SD boards (FE grp) FY12 | 76d | 2012-06-14 | 2012-09-28 | 1543055a FS-99d, 1543055 FS-99d | 111d |
| 1543013E |  | FY13 Travel (TRIGR) | 58d | 2012-10-01 | 2012-12-21 | 1543012E | 438d |
| 1543060a |  | Acceptance test of SD boards (FE grp) FY13 | 72d | 2012-10-01 | 2013-01-18 | 1543055a FS-99d, 1543055 FS-99d, 1543060 | 111d |
| 1543142 |  | Prepare Test Stand for Algorithm Testing, Test Algorithms ( Hall D grp ) | 228d | 2012-10-01 | 2013-08-30 | 1543141a, 9-130M, 9-120M FS+228d, 1543141 | 20d |
| 1543025 |  | Procument of CTP boards (FE grp) | 118d | 2012-10-03 | 2013-03-29 | 1543023 FS+99d, 9-130M FS+2d | 20d |
| 1543070 |  | Procument of SSP boards (FE grp) | 116d | 2012-10-05 | 2013-03-29 | 1543065a, 9-130M FS+4d | 20d |
| 1543020 |  | Procument of TS board (FE grp) | 121d | 2012-12-03 | 2013-05-31 | 1543015, 9-130M FS+43d, 1543017 | 128d |
| 1543115 |  | Performance testing of global trigger system | 65d | 2013-05-31 | 2013-08-30 | 1543060a, 1543100, 182443005, 1543060, 1543110a, 182443015, 1543105, 182443000 FS-150d, 9-120M FS+65d, 182443010 | 20d |
| 1543150 |  | Re-Baseline Actuals Adjustment | 1d | 2013-08-30 | 2013-08-30 | 9-130M FS+227d | 20d |
| 2543025 |  | Procument of CTP boards (FE grp) (Previously Obligated) | 20d | 2013-09-03 | 2013-09-30 | 9-130M FS+228d | 148d |
| 2543030 |  | Procument of CTP boards (FE grp) | 20d | 2013-09-03 | 2013-09-30 | 9-130M FS+228d | 148d |
| 2543144 |  | Study Algorithms with Test Stand (Hall D grp) FY13 | 20d | 2013-09-03 | 2013-09-30 | 9-130M FS+228d | 64d |
| 2543150 |  | Develop Level-1 Monitor (Hall D grp) FY13 | 20d | 2013-09-03 | 2013-09-30 | 9-130M FS+228d | 251d |
| 2543160 |  | Trigger Board Initialization (Hall D grp) FY13 | 20d | 2013-09-03 | 2013-09-30 | 9-130M FS+228d | 7d |
| 2543165 |  | Level-1 Verification and Debugging (Hall D grp) FY13 | 20d | 2013-09-03 | 2013-09-30 | 9-130M FS+228d | 62d |
| 2543185 |  | Procument Structural Components for Trigger Modules (FE Grp) | 17d | 2013-09-03 | 2013-09-25 | 9-130M FS+228d | 250d |
| 2543115 |  | Performance testing of global trigger system (FE grp) | 44d | 2013-10-01 | 2013-12-03 | 2543025 FS-20d, 2543030 FS-20d, 282443010 FS-100d, 2543100 FS-57d, 282443010a FS-100d | 128d |
| 2543144a |  | Study Algorithms with Test Stand (Hall D grp) FY14 | 183d | 2013-10-01 | 2014-06-30 | 2543144, 9-130M FS+228d | 64d |
| 2543150a |  | Develop Level-1 Monitor (Hall D grp) FY14 | 162d | 2013-10-01 | 2014-05-30 | 9-130M FS+228d, 2543150 | 251d |
| 2543160a |  | Trigger Board Initialization (Hall D grp) FY14 | 240d | 2013-10-01 | 2014-09-19 | 9-130M FS+228d, 2543160 | 7d |
| 2543165a |  | Level-1 Verification and Debugging (Hall D grp) FY14 | 185d | 2013-10-01 | 2014-07-02 | 9-130M FS+228d, 2543165 | 62d |
| 2543170 |  | Level-1 Trigger Testbed Electronics (Hall D grp) | 69d | 2013-10-01 | 2014-01-17 | 9-140M | 4d |
| 2543100 |  | Procument Fiber Optics Cable/Patch Pannel (FE grp) | 34d | 2013-11-01 | 2013-12-20 | 9-140M FS+23d | 128d |
| 2543143 |  | Trigger Algorithms Performance Testing in the Hall (Hall D grp) | 184d | 2014-01-09 | 2014-09-29 | 2543170 FS-10d, 9-140M FS+62d | 1d |
| 2543155 |  | Install Level-1 Monitor (Hall D grp) | 85d | 2014-06-02 | 2014-09-30 | 2543150, 2543150a | 251d |
|  | 4 | **1.5.4.4 CRATES/RACKS** |  | 2010-09-30 | 2013-08-30 |  |  |
| 1544005 |  | Vend Fab Crate DAQ Type Phase 1 (CRATES/RACKS) Peg Point #1 VXS Prototype | 59d | 2010-09-30 | 2010-12-30 | 9-110M FS-1d, 1234180M | 445d |
| 1544005a |  | Vend Fab Crate DAQ Type Phase 1 (CRATES/RACKS) Peg Point #2 VME64X Qty 1 | 98d | 2010-09-30 | 2011-02-28 | 1544005 FS-59d | 445d |
| 1544005b |  | Vend Fab Crate DAQ Type Phase 1 (CRATES/RACKS) Peg Point #3 VME64X Qty 6 | 98d | 2010-09-30 | 2011-02-28 | 1544005a FS-98d | 445d |
| 1544005c |  | Vend Fab Crate DAQ Type Phase 1 (CRATES/RACKS) Peg Point #4 VXS Qty 3 | 121d | 2010-09-30 | 2011-03-31 | 1544005b FS-98d | 445d |
| 1544005d |  | Vend Fab Crate DAQ Type Phase 1 (CRATES/RACKS) Peg Point #5 VXS Qty 8 | 121d | 2010-09-30 | 2011-03-31 | 1544005c FS-121d | 445d |
| 1544050 |  | Racks - First Article Procurement Support (CRATES/RACKS) | 35d | 2011-07-11 | 2011-08-26 | 1234180M, 9-110M FS+189d | 270d |
| 1544055 |  | Racks - First Article Parts (QTY 2) (CRATES/RACKS) | 20d | 2011-07-25 | 2011-08-19 | 1544050 FS-25d | 270d |
| 1544060 |  | Racks - Cabling Development (CRATES/RACKS) FY11 | 24d | 2011-08-29 | 2011-09-30 | 1544055 FS+5d | 270d |
| 1544010 |  | Vend Fab Crate DAQ Type Phase 2 (CRATES/RACKS) VME64X | 130d | 2011-10-03 | 2012-04-13 | 9-120M, 1544005d, 1234180M | 317d |
| 1544060a |  | Racks - Cabling Development (CRATES/RACKS) FY12 | 53d | 2011-10-03 | 2011-12-16 | 1544060 | 270d |
| 1544030 |  | Proc TDC Auxiliaries (CRATES/RACKS) | 1d | 2011-12-02 | 2011-12-02 | 1234180M, 1544005d, 9-120M FS+42d | 415d |
| 1544035 |  | Assemble TDC Crates (CRATES/RACKS) | 11d | 2011-12-05 | 2011-12-19 | 1544030 | 415d |
| 1544065 |  | Racks - Production Procurement Support (CRATES/RACKS) | 23d | 2011-12-19 | 2012-01-27 | 1544060a | 270d |
| 1544040 |  | Test TDC Crates (CRATES/RACKS) | 11d | 2011-12-20 | 2012-01-11 | 1544035 | 415d |
| 1544006 |  | Vend Fab Crate DAQ Type Phase 2 (CRATES/RACKS) VXS | 123d | 2012-01-05 | 2012-06-29 | 1544005d, 9-120M FS+60d | 264d |
| 1544070 |  | Racks - Production Parts (QTY 55) (CRATES/RACKS) | 83d | 2012-03-05 | 2012-06-29 | 1544065, 9-120M FS+100d | 246d |
| 1544075 |  | Racks - Production Acceptance (CRATES/RACKS) | 91d | 2012-04-12 | 2012-08-20 | 1544070 FS-55d | 246d |
| 1544015 |  | Vend Fab Crate supl (5 VXS and 2 VME64) | 168d | 2012-04-26 | 2012-12-31 | 9-120M FS+138d | 174d |
| 1544020 |  | Assemble ADC Crates (CRATES/RACKS) | 11d | 2012-07-02 | 2012-07-16 | 1544010, 1544006 | 264d |
| 1544025 |  | Test ADC Crates (CRATES/RACKS) | 22d | 2012-07-17 | 2012-08-15 | 1544020 | 264d |
| 1544080 |  | Re-Baseline Actuals Adjustment | 1d | 2013-08-30 | 2013-08-30 | 9-130M FS+227d | 20d |
|  | 5 | **1.5.4.5 LOGIC, HV** |  | 2009-01-02 | 2013-08-30 |  |  |
| 1545009E |  | FY09 Travel (LOGIC, HV) | 189d | 2009-01-02 | 2009-09-30 | 1545009EX | 310d |
| 1545010E |  | FY10 Travel (LOGIC, HV) | 248d | 2009-10-01 | 2010-09-30 | 1545009E | 310d |
| 1545011E |  | FY11 Travel (LOGIC, HV) | 248d | 2010-10-01 | 2011-09-30 | 1545010E | 310d |
| 1545040 |  | High Voltage - First Article Procurement Support | 24d | 2011-01-04 | 2011-02-07 | 9-110M FS+59d | 433d |
| 1545050 |  | High Voltage - First Article Crates (QTY 1) and Modules (QTY 10) | 23d | 2011-01-05 | 2011-02-07 | 9-110M FS+60d, 1234180M, 1545040 FS-24d | 432d |
| 1545014 |  | Discriminator - First Article Procurement Support | 98d | 2011-01-10 | 2011-05-27 | 9-110M FS+63d, 1234180M | 194d |

| ID | WBS | Task | Duration | Start | Finish | Predecessors | Total float |
| --- | --- | --- | --- | --- | --- | --- | --- |
| 1545051 |  | High Voltage - First Article Crates Acceptance Tests (QTY 1) | 19d | 2011-02-22 | 2011-03-18 | 1545050a FS-60d, 1545050 FS+9d | 432d |
| 1545090 |  | Low Voltage - First Article Procurement Support | 108d | 2011-03-07 | 2011-08-05 | 9-110M FS+101d | 230d |
| 1545095 |  | Low Voltage - First Article Crates (QTY 1) | 108d | 2011-03-07 | 2011-08-05 | 1545090 FS-108d, 9-110M FS+60d | 230d |
| 1545097 |  | Low Voltage - First Article Modules (QTY 8) | 108d | 2011-03-07 | 2011-08-05 | 1545090 FS-108d, 9-110M FS+60d | 250d |
| 1545055 |  | High Voltage - First Article Modules Acceptance Tests (QTY 10) | 20d | 2011-03-14 | 2011-04-08 | 1545050a FS-50d, 1545050, 1545051 FS-5d | 432d |
| 1545015 |  | Discriminator - First Article Parts Fab and Assembly (QTY 25) | 147d | 2011-03-28 | 2011-10-21 | 1234180M, 1545014 FS-45d | 194d |
| 1545017 |  | Test stand for testing/acceptance of discriminator | 64d | 2011-04-01 | 2011-06-30 | 9-110M FS+120d | 199d |
| 1545050a |  | High Voltage - First Article Crates (QTY 1) and Modules (added cost) | 28d | 2011-04-01 | 2011-05-11 | 1545050 FS+37.5d | 435.5d |
| 1545020 |  | Discriminator - First Article Test (QTY 25) FY11 | 59d | 2011-07-11 | 2011-09-30 | 1545017, 1545015 FS-74d | 194d |
| 1545098 |  | Low Voltage - First Article Crates Acceptance Tests (QTY 1) | 20d | 2011-08-08 | 2011-09-02 | 1545095 | 230d |
| 1545100 |  | Low Voltage - First Article Modules Acceptance Tests (QTY 10) | 19d | 2011-09-06 | 2011-09-30 | 1545097, 1545098 | 230d |
| 1545005 |  | Assemble Signal Distrbtn CFD Tests (LOGIC, HV) | 20d | 2011-10-03 | 2011-10-28 | 9-120M, 1234180M | 396d |
| 1545020a |  | Discriminator - First Article Test (QTY 25) FY12 | 58d | 2011-10-03 | 2011-12-30 | 1545020 | 194d |
| 1545060 |  | High Voltage - Production Procurement Support | 100d | 2011-10-03 | 2012-03-02 | 9-120M, 1545055 | 310d |
| 1545065 |  | Vend Fab - Universal Multichannel Power Supply System 750W (QTY 6) | 130d | 2011-10-03 | 2012-04-13 | 1545060 FS-100d, 9-120M, 1545011E | 310d |
| 1545066 |  | Vend Fab - Optional Power Supply 750W (QTY 6) | 130d | 2011-10-03 | 2012-04-13 | 1545065 FS-130d | 310d |
| 1545070 |  | Vend Fab - H.V Channels -3.5 KV 3 MA SHV Floating (QTY 18) | 130d | 2011-10-03 | 2012-04-13 | 1545066 FS-130d | 310d |
| 1545071 |  | Vend Fab - H.V Channels +3.5 KV 3 MA Floating (QTY 8) | 130d | 2011-10-03 | 2012-04-13 | 1545070 FS-130d | 310d |
| 1545075 |  | Vend Fab - H.V Channels -3.5 KV 3 MA Floating (QTY 3) | 130d | 2011-10-03 | 2012-04-13 | 1545071 FS-130d | 310d |
| 1545105 |  | Low Voltage - Production Procurement Support | 51d | 2011-10-10 | 2011-12-21 | 1545100, 9-120M FS+5d | 225d |
| 1545022 |  | Discriminator - Full Single-Crate Acceptance Test | 43d | 2011-10-24 | 2011-12-30 | 1545020a FS-43d | 194d |
| 1545010 |  | Dry Run of Testing Procedures for CFDs (LOGIC, HV) | 6d | 2011-10-31 | 2011-11-07 | 1545005 | 396d |
| 1545110 |  | Low Voltage - Crates Production (QTY 7) | 245d | 2011-11-07 | 2012-10-31 | 9-120M FS+25d, 1545105 FS-51d | 205d |
| 1545115 |  | Low Voltage - Modules Production (QTY 38) | 245d | 2011-11-07 | 2012-10-31 | 1545110 FS-245d, 9-120M | 205d |
| 1545025 |  | Discriminator - Production Procurement Support | 57d | 2012-01-03 | 2012-03-23 | 1545022 | 194d |
| 1545026 |  | Discriminator - Production Parts Non-Recurring Engineering | 104d | 2012-01-04 | 2012-05-31 | 9-120M FS+59d | 194d |
| 1545027 |  | Discriminator - Production Parts Fab and Assembly (QTY 70) | 169d | 2012-01-04 | 2012-08-31 | 1545026 FS-104d, 1545025 FS-56d | 194d |
| 1545080 |  | High Voltage - Crates Production Tests (QTY 6) | 73d | 2012-02-22 | 2012-06-05 | 1545066 FS-38d, 1545065 FS-38d | 310d |
| 1545085 |  | High Voltage - Modules Production Tests (QTY 29) | 73d | 2012-02-22 | 2012-06-05 | 1545075 FS-38d | 310d |
| 1545120 |  | Low Voltage - Crates Production Tests (QTY 7) FY12 | 112d | 2012-04-23 | 2012-09-28 | 1545110 FS-135d | 205d |
| 1545125 |  | Low Voltage - Modules Production Tests (QTY 38) FY12 | 112d | 2012-04-23 | 2012-09-28 | 1545115 FS-135d | 205d |
| 1545028 |  | Procure Discriminators (Qty.24) Supplemental BCAL and PS | 109d | 2012-08-20 | 2013-01-31 | 9-120M FS+218d | 153d |
| 1545030 |  | Discriminator - Production Test (QTY 70) FY12 | 19d | 2012-09-04 | 2012-09-28 | 1545010, 1545027 | 194d |
| 1545030a |  | Discriminator - Production Test (QTY 70) FY13 | 39d | 2012-10-01 | 2012-11-26 | 1545030 | 194d |
| 1545120a |  | Low Voltage - Crates Production Tests (QTY 7) FY13 | 23d | 2012-10-01 | 2012-10-31 | 1545120 | 205d |
| 1545125a |  | Low Voltage - Modules Production Tests (QTY 38) FY13 | 23d | 2012-10-01 | 2012-10-31 | 1545125, 1545115 FS-135d | 205d |
| 1545130 |  | Re-Baseline Actuals Adjustment | 1d | 2013-08-30 | 2013-08-30 | 9-130M FS+227d | 20d |
|  | 6 | **1.5.4.6 DETECTOR ELECTRONICS** |  | 2011-01-04 | 2014-09-30 |  |  |
| 1546005 |  | ASIC - Procurement Support (FDC&CDC) | 42d | 2011-01-04 | 2011-03-04 | 9-110M FS+59d | 77d |
| 1546020 |  | ASIC - Test Fixture Development (FDC&CDC) | 33d | 2011-01-18 | 2011-03-04 | 9-110M FS+68d | 92d |
| 1546125 |  | HVB - Development Revisions (CDC) | 43d | 2011-01-24 | 2011-03-24 | 9-110M FS+72d | 55d |
| 1546140 |  | HVB - First Article Procurement Support (CDC) | 59d | 2011-01-24 | 2011-04-15 | 9-110M FS+72d | 55d |
| 1546145 |  | HVB - First Article Parts (CDC) | 122d | 2011-01-24 | 2011-07-15 | 1546140 FS-59d | 55d |
| 1546025 |  | ASIC - Test Fixture Procurement Support (FDC&CDC) | 15d | 2011-03-07 | 2011-03-25 | 1546020 | 97d |
| 1546030 |  | ASIC - Test Fixture Parts (FDC&CDC) | 10d | 2011-03-07 | 2011-03-18 | 1546020 | 92d |
| 1546130 |  | HVB - Development PCB Fab Files (CDC) | 5d | 2011-03-14 | 2011-03-18 | 1546125 FS-9d | 55d |
| 1546135 |  | HVB - Development PCB Assembly Files (CDC) | 5d | 2011-03-14 | 2011-03-18 | 1546125 FS-9d, 1546130 FS-5d | 55d |
| 1546035 |  | ASIC - Test Fixture Fab (FDC&CDC) | 10d | 2011-03-21 | 2011-04-01 | 1546030 | 92d |
| 1546095 |  | Preamp Card - Test Fixture Development (FDC&CDC) | 40d | 2011-03-21 | 2011-05-13 | 9-110M FS+111d | 59d |
| 1546150 |  | HVB - First Article Fab 2 Units (CDC) | 10d | 2011-03-21 | 2011-04-01 | 1546135, 1546145 FS-83d | 55d |
| 1546040 |  | ASIC - Test Fixture Assembly (FDC&CDC) | 10d | 2011-04-04 | 2011-04-15 | 1546025, 1546035 | 92d |
| 1546155 |  | HVB - First Article Assembly 2 Units (CDC) | 10d | 2011-04-04 | 2011-04-15 | 1546150 | 55d |
| 1546050 |  | Preamp Card - First Article Procurement Support (FDC&CDC) | 59d | 2011-04-11 | 2011-07-01 | 9-110M FS+126d | 20d |
| 1546055 |  | Preamp Card - First Article Parts (FDC&CDC) | 59d | 2011-04-11 | 2011-07-01 | 1546050 FS-59d, 9-110M FS+126d | 20d |
| 1546045 |  | ASIC - Test Fixture Test (FDC&CDC) | 15d | 2011-04-18 | 2011-05-06 | 1546040 | 92d |
| 1546160 |  | HVB - First Article Test 2 Units (CDC) | 10d | 2011-04-18 | 2011-04-29 | 1546155 | 55d |
| 1546165 |  | HVB - Production Procurement Support (CDC) | 58d | 2011-05-02 | 2011-07-22 | 1546160 | 55d |
| 1546100 |  | Preamp Card - Test Fixture Procurement Support (FDC&CDC) | 14d | 2011-05-16 | 2011-06-03 | 1546095 | 59d |
| 1546105 |  | Preamp Card - Test Fixture Parts (FDC&CDC) | 19d | 2011-05-16 | 2011-06-10 | 1546100 FS-14d, 1546095 | 59d |
| 1546185 |  | HVB - Test Fixture Development (CDC) | 15d | 2011-05-27 | 2011-06-17 | 9-110M FS+160d | 79d |
| 1546010 |  | ASIC - Test (FDC&CDC) | 68d | 2011-05-31 | 2011-09-02 | 15211035b, 1546045 | 77d |
| 1546060 |  | Preamp Card - First Article Fab (FDC&CDC) | 39d | 2011-06-06 | 2011-07-29 | 1546055 FS-20d | 20d |
| 1546110 |  | Preamp Card - Test Fixture Fab (FDC&CDC) | 15d | 2011-06-13 | 2011-07-01 | 1546105 | 59d |
| 1546190 |  | HVB - Test Fixture Procurement Support (CDC) | 14d | 2011-06-20 | 2011-07-08 | 1546185 | 79d |
| 1546195 |  | HVB - Test Fixture Parts (CDC) | 19d | 2011-06-20 | 2011-07-15 | 1546185, 1546190 FS-14d | 79d |
| 1546115 |  | Preamp Card - Test Fixture Assembly (FDC&CDC) | 9d | 2011-07-05 | 2011-07-15 | 1546110 | 59d |
| 1546120 |  | Preamp Card - Test Fixture Test (FDC&CDC) | 10d | 2011-07-18 | 2011-07-29 | 1546115 | 59d |
| 1546200 |  | HVB - Test Fixture Fab (CDC) | 15d | 2011-07-18 | 2011-08-05 | 1546195 | 79d |
| 1546170 |  | HVB - Production Fab (CDC) | 25d | 2011-07-25 | 2011-08-26 | 1546165 | 55d |
| 1546065 |  | Preamp Card - First Article Assembly (FDC&CDC) | 39d | 2011-08-01 | 2011-09-23 | 1546060 | 20d |

| ID | Task | Duration | Start | Finish | Predecessors | Total float |
| --- | --- | --- | --- | --- | --- | --- |
| 1546205 | HVB - Test Fixture Assembly (CDC) | 10d | 2011-08-08 | 2011-08-19 | 1546200 | 79d |
| 1546210 | HVB - Test Fixture Test (CDC) | 10d | 2011-08-22 | 2011-09-02 | 1546205 | 79d |
| 1546175 | HVB - Production Assembly (CDC) | 29d | 2011-08-29 | 2011-10-07 | 1546170 | 55d |
| 1546070 | Preamp Card - First Article Acceptance QA (FDC&CDC) FY11 | 5d | 2011-09-26 | 2011-09-30 | 1546120, 1546065 | 20d |
| 1546070a | Preamp Card - First Article Acceptance QA (FDC&CDC) FY12 | 20d | 2011-10-03 | 2011-10-28 | 1546070 | 20d |
| 1546180 | HVB - Production Test (CDC) | 71d | 2011-10-10 | 2012-01-27 | 1546210, 1546175 | 55d |
| 1546075 | Preamp Card - Production Procurement Support (FDC&CDC) | 51d | 2011-10-31 | 2012-01-20 | 1546070a | 20d |
| 1546080 | Preamp Card - Production Fab (FDC&CDC) | 18d | 2011-10-31 | 2011-11-23 | 1546075 FS-51d, 1546070a | 20d |
| 1546085 | Preamp Card - Production Assembly (FDC&CDC) | 33d | 2011-11-28 | 2012-01-20 | 1546080, 1546010 | 20d |
| 1546090 | Preamp Card - Production Tests (FDC&CDC) | 107d | 2012-01-23 | 2012-06-22 | 1546085, 1546120 | 20d |
| 1546300 | BCAL Readout Procurement Support | 137d | 2012-02-21 | 2012-08-31 | 9-120M FS+91d | 213d |
| 1546390 | Power Distribution Engineering | 46d | 2012-02-27 | 2012-04-30 | 9-120M FS+95d | 300d |
| 1546500 | Start Counter Engineering | 20d | 2012-02-27 | 2012-03-23 | 9-120M FS+95d | 216d |
| 1546182 | Testing/manufacturing equipment for electronic boards | 147d | 2012-03-05 | 2012-09-28 | 9-120M FS+100d | 496d |
| 1546305 | Procure BCAL Readout V3 (Qty.96) $$ Reside @ 15221160ab per CR12-021 | 78d | 2012-03-12 | 2012-06-29 | 15221161c FS-500d, 15221161h FS-500d, 15221161a FS-307d, 1546300 FS-123d, 15221161n FS-500d, 15221161f FS-500d, 15221161s FS-500d, 15221161j FS-500d, 15221161b FS-500d, 15221161k FS-500d | 213d |
| 1546310 | Procure U-Boards (Qty.3840) | 58d | 2012-03-12 | 2012-05-31 | 1546305 FS-78d | 213d |
| 1546400 | Pair Spectrometer Engineering | 30d | 2012-03-19 | 2012-04-27 | 9-120M FS+110d | 160d |
| 1546505 | Start Counter Prototype Procurement Prep | 10d | 2012-03-26 | 2012-04-06 | 1546500 | 216d |
| 1546510 | Start Counter Prototype Parts,Fab and Assembly | 25d | 2012-03-26 | 2012-04-27 | 1546505 FS-10d | 216d |
| 1546405 | Pair Spectrometer Prototype Procurement Prep | 25d | 2012-04-16 | 2012-05-18 | 1546400 FS-10d | 160d |
| 1546315 | Procure Thermistor Boards (Qty.384) | 28d | 2012-04-23 | 2012-05-31 | 1546310 FS-28d | 213d |
| 1546410 | Pair Spectrometer Prototype Parts,Fab and Assembly | 38d | 2012-04-23 | 2012-06-15 | 1546405 FS-20d | 160d |
| 1546320 | Procure Transition Boards (Qty.96) | 38d | 2012-05-07 | 2012-06-29 | 1546315 FS-18d | 213d |
| 1546325 | Procure Power Distribution (Qty.18) | 78d | 2012-05-14 | 2012-08-31 | 1546320 FS-33d | 213d |
| 1546515 | Test Start Counter Prototype | 14d | 2012-05-14 | 2012-06-01 | 1546510 FS+10d | 216d |
| 1546360 | Test BCAL Readout V3 | 51d | 2012-06-11 | 2012-08-20 | 1546305 FS-15d | 228d |
| 1546365 | Test U-Boards FY12 | 79d | 2012-06-11 | 2012-09-28 | 1546360 FS-51d, 1546310 | 228d |
| 1546415 | Test Pair Spectrometer Prototype | 25d | 2012-06-18 | 2012-07-20 | 1546410 | 160d |
| 1546370 | Test Thermistor Boards | 64d | 2012-06-25 | 2012-09-21 | 1546365a FS-75d, 1546315 | 228d |
| 1546375 | Test Transition Boards | 25d | 2012-07-09 | 2012-08-10 | 1546370 FS-54d, 1546320 | 228d |
| 1546420 | Pair Spectrometer Production Procurement Prep | 34d | 2012-07-23 | 2012-09-07 | 1546415 | 160d |
| 1546445 | Pair Spectrometer Power Supplies Procurement Prep | 37d | 2012-07-25 | 2012-09-14 | 1546400, 9-120M FS+200d | 129d |
| 1546425 | Procure Pair Spectrometer Readout Board | 25d | 2012-07-30 | 2012-08-31 | 1546420 FS-29d | 215d |
| 1546330 | Procure Coax Cables (Qty.768) | 39d | 2012-08-06 | 2012-09-28 | 1546325 FS-20d | 218d |
| 1546430 | Procure Pair Spectrometer Transition Board | 39d | 2012-08-06 | 2012-09-28 | 1546420 FS-24d | 170d |
| 1546435 | Procure Pair Spectrometer Power Distribution | 34d | 2012-08-13 | 2012-09-28 | 1546420 FS-19d | 160d |
| 1546440 | Procure Pair Spectrometer Coax Cables | 72d | 2012-08-20 | 2012-11-30 | 1546420 FS-14d | 195d |
| 1546380 | Test Power Distribution FY12 | 19d | 2012-09-04 | 2012-09-28 | 1546325, 1546390, 1546375 | 213d |
| 1546365a | Test U-Boards FY13 | 6d | 2012-10-01 | 2012-10-08 | 1546365 | 228d |
| 1546450 | Procure LV Mod Preamp | 99d | 2012-10-01 | 2013-02-28 | 1546445 FS+10d | 129d |
| 1546455 | Procure LV Bias | 99d | 2012-10-01 | 2013-02-28 | 1546445 FS+10d | 129d |
| 1546460 | Procure LV Chassis | 99d | 2012-10-01 | 2013-02-28 | 1546445 FS+10d | 129d |
| 1546465 | Procure LV Cables | 99d | 2012-10-01 | 2013-02-28 | 1546445 FS+10d | 129d |
| 1546550 | Procure LV Mod Preamp | 99d | 2012-10-01 | 2013-02-28 | 9-130M | 129d |
| 1546555 | Procure LV Bias | 99d | 2012-10-01 | 2013-02-28 | 9-130M | 129d |
| 1546560 | Procure LV Chassis | 99d | 2012-10-01 | 2013-02-28 | 9-130M | 129d |
| 1546565 | Procure LV Cables | 99d | 2012-10-01 | 2013-02-28 | 9-130M | 129d |
| 1546345 | Procure Disc/TDC Cable(Qty.24) | 24d | 2013-01-25 | 2013-02-28 | 9-130M FS+75d | 134d |
| 1546520 | Start Counter Production Procurement Prep | 39d | 2013-02-19 | 2013-04-12 | 1546515, 9-130M FS+91d | 42d |
| 1546525 | Procure Start Counter ST Readout Board | 49d | 2013-03-25 | 2013-05-31 | 1546520 FS-15d | 74d |
| 1546530 | Procure Start Counter Transition Board | 17d | 2013-04-08 | 2013-04-30 | 1546520 FS-5d | 69d |
| 1546535 | Procure Start Counter Power Distribution | 39d | 2013-04-08 | 2013-05-31 | 1546520 FS-5d | 50d |
| 1546540 | Procure Start Counter Coax Cables | 81d | 2013-04-08 | 2013-07-31 | 1546520 FS-5d | 42d |
| 1546570 | Re-Baseline Actuals Adjustment | 1d | 2013-08-30 | 2013-08-30 | 9-130M FS+227d | 20d |
| 2546362 | Assemble BCAL Readout V3, Power Dist. & SYST | 20d | 2013-09-03 | 2013-09-30 | 9-130M FS+228d | 179d |
| 2546425 | Procure Pair Spectrometer Readout Board | 20d | 2013-09-03 | 2013-09-30 | 9-130M FS+228d | 199d |
| 2546430 | Procure Pair Spectrometer Transition Board | 20d | 2013-09-03 | 2013-09-30 | 9-130M FS+228d | 199d |
| 2546435 | Procure Pair Spectrometer Power Distribution | 20d | 2013-09-03 | 2013-09-30 | 9-130M FS+228d | 199d |
| 2546465 | Procure LV Cables | 20d | 2013-09-03 | 2013-09-30 | 9-130M FS+228d | 247d |
| 2546565 | Procure LV Cables | 20d | 2013-09-03 | 2013-09-30 | 9-130M FS+228d | 247d |
| 2546567 | Start Counter Integration FY13 | 20d | 2013-09-03 | 2013-09-30 | 9-130M FS+228d | 208d |
| 2546585 | Tagger Microscope PreAmp Board (37) Procurement | 54d | 2013-09-03 | 2013-11-15 | 9-130M FS+228d | 153d |
| 2546585a | Tagger Microscope PreAmp Board (37) Labor FY13 | 20d | 2013-09-03 | 2013-09-30 | 9-130M FS+228d | 153d |
| 2546600 | Tagger Hodoscope PreAmp Board (233) (Previously Obligated) | 49d | 2013-09-03 | 2013-11-08 | 9-130M FS+228d | 158d |
| 2546605 | Tagger Hodoscope PreAmp Board (233) - Procurement | 49d | 2013-09-03 | 2013-11-08 | 9-130M FS+228d | 158d |
| 2546605a | Tagger Hodoscope PreAmp Board (233) - Labor FY13 | 20d | 2013-09-03 | 2013-09-30 | 9-130M FS+228d | 158d |
| 2546610 | BCAL/FCAL Monitoring Distribution Sys. Procurement Support FY13 | 20d | 2013-09-03 | 2013-09-30 | 9-130M FS+228d | 172d |
| 2546615 | BCAL/FCAL Monitoring Distribution COTS Electronics | 77d | 2013-09-03 | 2013-12-20 | 9-130M FS+228d | 190d |
| 2546620 | BCAL/FCAL Monitoring Distribution Box (10) - Procurement | 95d | 2013-09-03 | 2014-01-28 | 9-130M FS+228d | 172d |
| 2546620a | BCAL/FCAL Monitoring Distribution Box (10) - Labor FY13 | 20d | 2013-09-03 | 2013-09-30 | 9-130M FS+228d | 172d |

| ID | WBS | Task | Duration | Start | Finish | Predecessors | Total float |
| --- | --- | --- | --- | --- | --- | --- | --- |
| 2546625 |  | BCAL/FCAL Monitoring Distribution Cables (64+64) (Previously Obligated) | 98d | 2013-09-03 | 2014-01-31 | 9-130M FS+228d | 169d |
| 2546630 |  | BCAL/FCAL Monitoring Distribution Cables (64+64) | 98d | 2013-09-03 | 2014-01-31 | 9-130M FS+228d | 169d |
| 2546640 |  | Cables Type 1 (TAGH PS PSC COLLI) (350) | 77d | 2013-09-03 | 2013-12-20 | 9-130M FS+228d | 190d |
| 2546645 |  | Splitter Output (TOF TAGM PSC) (630) | 54d | 2013-09-03 | 2013-11-15 | 9-130M FS+228d | 213d |
| 2546650 |  | Install Hardware, Labels and Tie Wraps FY13 | 20d | 2013-09-03 | 2013-09-30 | 9-130M FS+228d | 0d |
| 2546660 |  | Twisted Pair Cables for TDCs | 77d | 2013-09-03 | 2013-12-20 | 9-130M FS+228d | 100d |
| 2546470 |  | Pair Spectrometer Integration FY13 | 16d | 2013-09-09 | 2013-09-30 | 9-130M FS+232d | 175d |
| 2546470a |  | Pair Spectrometer Integration FY14 | 57d | 2013-10-01 | 2013-12-20 | 2546470, 9-130M FS+232d | 175d |
| 2546567a |  | Start Counter Integration FY14 | 29d | 2013-10-01 | 2013-11-08 | 9-130M FS+228d, 2546567 | 208d |
| 2546585b |  | Tagger Microscope PreAmp Board (37) Labor FY14 | 34d | 2013-10-01 | 2013-11-15 | 9-130M FS+228d, 2546585a | 153d |
| 2546605b |  | Tagger Hodoscope PreAmp Board (233) - Labor FY14 | 29d | 2013-10-01 | 2013-11-08 | 9-130M FS+228d, 2546605a | 158d |
| 2546610a |  | BCAL/FCAL Monitoring Distribution Sys. Procurement Support FY14 | 75d | 2013-10-01 | 2014-01-28 | 2546610, 9-130M FS+228d | 172d |
| 2546620b |  | BCAL/FCAL Monitoring Distribution Box (10) - Labor FY4 | 75d | 2013-10-01 | 2014-01-28 | 9-130M FS+228d, 2546620a | 172d |
| 2546650a |  | Install Hardware, Labels and Tie Wraps FY14 | 247d | 2013-10-01 | 2014-09-30 | 9-130M FS+228d, 2546650 | 0d |
| 2546655 |  | Splitters Parts Boards and Assembly (10) | 139d | 2013-11-08 | 2014-06-06 | 9-140M FS+28d | 80d |
|  | 7 | **1.5.4.7 DETECTOR CABLING** |  | 2011-01-11 | 2014-01-31 |  |  |
| 1547005 |  | Cables - Low Voltage Cabling Development (FDC&CDC) | 52d | 2011-01-11 | 2011-03-25 | 9-110M FS+64d | 337d |
| 1547010 |  | Cables - Low Voltage Cabling Procurement Support (FDC&CDC) | 108d | 2011-03-28 | 2011-08-26 | 1547005 | 337d |
| 1547020 |  | Cables - Low Voltage Distribution Development (FDC&CDC) | 93d | 2011-03-28 | 2011-08-05 | 1547005 | 340d |
| 1547025 |  | Cables - Low Voltage Distribution Chassis (FDC&CDC) | 93d | 2011-04-18 | 2011-08-26 | 1547020 FS-78d | 340d |
| 1547035 |  | Cables - Coax Signal Procurement Support FY11 | 61d | 2011-07-07 | 2011-09-30 | 9-110M FS+187d | 36d |
| 1547040 |  | Cables - Coax HV Procurement Support FY11 | 61d | 2011-07-07 | 2011-09-30 | 9-110M FS+187d | 123d |
| 1547015 |  | Cables - Low Voltage Assemblies (FDC&CDC) | 80d | 2011-08-29 | 2011-12-21 | 1547010 | 337d |
| 1547030 |  | Cables - Low Voltage Distribution Supply Cables (FDC&CDC) | 77d | 2011-08-29 | 2011-12-16 | 1547025 | 340d |
| 1547035a |  | Cables - Coax Signal Procurement Support FY12 | 53d | 2011-10-03 | 2011-12-16 | 1547035 | 36d |
| 1547040a |  | Cables - Coax HV Procurement Support FY12 | 53d | 2011-10-03 | 2011-12-16 | 1547040 | 123d |
| 1547055 |  | Cables - Coax HV Tagger/Hodoscope | 189d | 2012-01-03 | 2012-09-28 | 1547050 FS-55d | 230d |
| 1547060 |  | Cables - Coax Signal Tagger/Hodoscope | 189d | 2012-01-03 | 2012-09-28 | 1547045 FS-55d | 210d |
| 1547065 |  | Cables - Coax HV Pair Spectrometer | 189d | 2012-01-03 | 2012-09-28 | 1547050 FS-55d | 220d |
| 1547070 |  | Cables - Coax Signal Pair Spectrometer | 189d | 2012-01-03 | 2012-09-28 | 1547045 FS-55d | 175d |
| 1547075 |  | Cables - Coax HV Start Counter | 189d | 2012-01-03 | 2012-09-28 | 1547050 FS-55d | 123d |
| 1547080 |  | Cables - Coax Signal Start Counter | 189d | 2012-01-03 | 2012-09-28 | 1547045 FS-55d | 36d |
| 1547085 |  | Cables - LV BCAL | 189d | 2012-01-03 | 2012-09-28 | 1547050 FS-55d | 220d |
| 1547090 |  | Cables - Bias BCAL | 189d | 2012-01-03 | 2012-09-28 | 1547045 FS-55d | 228d |
| 1547095 |  | Cables - Coax Signal BCAL | 189d | 2012-01-03 | 2012-09-28 | 1547045 FS-55d | 80d |
| 1547100 |  | Cables - Coax HV TOF | 189d | 2012-01-03 | 2012-09-28 | 1547050 FS-55d | 229d |
| 1547105 |  | Cables - Coax Signal TOF | 189d | 2012-01-03 | 2012-09-28 | 1547045 FS-55d | 228d |
| 1547110 |  | Cables - Coax Signal FCAL | 189d | 2012-01-03 | 2012-09-28 | 1547045 FS-55d | 127d |
| 1547045 |  | Cables - Coax Signal Acceptance Tests | 50d | 2012-01-10 | 2012-03-21 | 1547035a FS+10d | 36d |
| 1547050 |  | Cables - Coax HV Acceptance Tests | 50d | 2012-01-10 | 2012-03-21 | 1547040a FS+10d | 123d |
| 1547115 |  | Cables - HV Label and Bundle Tagger/Hodoscope | 18d | 2013-01-03 | 2013-01-29 | 1547055, 9-130M FS+60d | 170d |
| 1547120 |  | Cables - Signal Label and Bundle Tagger/Hodoscope | 18d | 2013-01-03 | 2013-01-29 | 1547060, 9-130M FS+60d | 150d |
| 1547125 |  | Cables - HV Label and Bundle Pair Spectrometer | 10d | 2013-01-03 | 2013-01-16 | 9-130M FS+60d, 1547065 FS+18d | 178d |
| 1547135 |  | Cables - HV Label and Bundle Start Counter | 10d | 2013-01-03 | 2013-01-16 | 9-130M FS+60d, 1547075 FS+33d | 96d |
| 1547185 |  | Cables - Signal Label and Bundle BCAL | 150d | 2013-01-03 | 2013-08-06 | 1547095, 9-130M FS+60d | 20d |
| 1547200 |  | Cables - Signal Label and Bundle FCAL | 97d | 2013-01-03 | 2013-05-21 | 1547110, 9-130M FS+60d | 67d |
| 1547130 |  | Cables - Signal Label and Bundle Pair Spectrometer | 10d | 2013-01-08 | 2013-01-22 | 1547070 FS+63d, 9-130M FS+60d | 175d |
| 1547150 |  | Cables - HV Label and Bundle CDC | 10d | 2013-01-17 | 2013-01-31 | 9-130M FS+60d, 1547135 | 96d |
| 1547140 |  | Cables - Signal Label and Bundle Start Counter | 9d | 2013-01-23 | 2013-02-04 | 1547080 FS+73d, 9-130M FS+60d | 36d |
| 1547195 |  | Cables - Signal Label and Bundle TOF | 20d | 2013-01-30 | 2013-02-27 | 1547105, 1547120, 9-130M FS+60d | 150d |
| 1547165 |  | Cables - HV Label and Bundle FDC | 10d | 2013-02-01 | 2013-02-14 | 1547150, 9-130M FS+60d | 96d |
| 1547145 |  | Cables - LV Label and Bundle CDC | 10d | 2013-02-05 | 2013-02-19 | 1547030, 1547015, 1547140, 9-130M FS+60d | 64d |
| 1547155 |  | Cables - Signal Label and Bundle CDC | 20d | 2013-02-05 | 2013-03-05 | 1547140, 9-130M FS+60d | 36d |
| 1547190 |  | Cables - HV Label and Bundle TOF | 19d | 2013-02-15 | 2013-03-14 | 9-130M FS+60d, 1547100, 1547165 | 139d |
| 1547160 |  | Cables - LV Label and Bundle FDC | 30d | 2013-02-20 | 2013-04-02 | 9-130M FS+60d, 1547145 | 64d |
| 1547170 |  | Cables - Signal Label and Bundle FDC | 48d | 2013-03-06 | 2013-05-10 | 1547155, 9-130M FS+60d | 36d |
| 1547175 |  | Cables - LV Label and Bundle BCAL | 8d | 2013-04-03 | 2013-04-12 | 1547160, 9-130M FS+60d, 1547085 | 98d |
| 1547180 |  | Cables - Bias Label and Bundle BCAL | 10d | 2013-04-15 | 2013-04-26 | 9-130M FS+60d, 1547175, 1547090 | 98d |
| 1547205 |  | Re-Baseline Actuals Adjustment | 1d | 2013-08-30 | 2013-08-30 | 9-130M FS+227d | 20d |
| 2547170 |  | Cables - Signal Label and Bundle FDC (528) FY13 | 20d | 2013-09-03 | 2013-09-30 | 9-130M FS+228d | 5d |
| 2547175 |  | Cables - LV Label and Bundle BCAL (24) | 20d | 2013-09-03 | 2013-09-30 | 9-130M FS+228d | 58d |
| 2547180 |  | Cables - Bias Label and Bundle BCAL (36) | 20d | 2013-09-03 | 2013-09-30 | 2547175 FS-20d | 58d |
| 2547190 |  | Cables - HV Label and Bundle TOF (168) FY13 | 20d | 2013-09-03 | 2013-09-30 | 2547165 FS-25d, 2547165a FS-25d | 127d |
| 2547200 |  | Cables - Signal Label and Bundle TOF (168) FY13 | 20d | 2013-09-03 | 2013-09-30 | 2547190 FS-98d, 2547190a FS-98d | 127d |
| 2547165 |  | Cables - HV Label and Bundle FDC (8) FY13 | 11d | 2013-09-16 | 2013-09-30 | 9-130M FS+237d | 19d |
| 2547135 |  | Cables - HV Label and Bundle CDC (6) | 25d | 2013-10-01 | 2013-11-04 | 9-140M | 134d |
| 2547165a |  | Cables - HV Label and Bundle FDC (8) FY14 | 5d | 2013-10-01 | 2013-10-07 | 2547165, 9-130M FS+237d | 19d |
| 2547170a |  | Cables - Signal Label and Bundle FDC (528) FY14 | 19d | 2013-10-01 | 2013-10-25 | 9-130M FS+228d, 2547170 | 5d |
| 2547190a |  | Cables - HV Label and Bundle TOF (168) FY14 | 78d | 2013-10-01 | 2014-01-31 | 2547165a FS-25d, 2547190, 2547165 FS-25d | 127d |
| 2547200a |  | Cables - Signal Label and Bundle TOF (168) FY14 | 78d | 2013-10-01 | 2014-01-31 | 2547190 FS-98d, 2547200, 2547190a FS-98d | 127d |

| ID | WBS | Task | Duration | Start | Finish | Predecessors | Total float |
| --- | --- | --- | --- | --- | --- | --- | --- |
|  | 8 | **1.5.4.8 FULL CRATE CHECKS** |  | 2012-06-06 | 2013-12-20 |  |  |
| 1548030 |  | Full Crate Check - Pre Installation,Lab,Install Mods,Test,Log&Label High Voltage | 20d | 2012-06-06 | 2012-07-03 | 1545080, 1545085 | 310d |
| 1548010 |  | Full Crate Check - Pre Installation,Lab,Install Mods,Test,Log&Label VME64x Discriminator | 15d | 2013-03-01 | 2013-03-21 | 1545028, 1544040, 1546345, 1545030a, 1544025 | 134d |
| 1548035 |  | Full Crate Check - Pre Installation,Lab,Install Mods,Test,Log&Label Low Voltage | 20d | 2013-03-01 | 2013-03-28 | 1546555, 1546565, 1546560, 1546450, 1546460, 1545120a, 1546465, 1546550, 1545125a, 1546455, 1545125 | 129d |
| 1548015 |  | Full Crate Check - Pre Installation,Lab,Install Mods,Test,Log&Label VXS fADC250 | 15d | 2013-04-01 | 2013-04-19 | 1541059, 1544015 | 113d |
| 1548040 |  | Re-Baseline Actuals Adjustment | 1d | 2013-08-30 | 2013-08-30 | 9-130M FS+227d | 20d |
| 2548025 |  | Full Crate Check - Pre Installation,Lab,Install Mods,Test,Log&Label VXS F1TDC FY13 | 16d | 2013-09-09 | 2013-09-30 | 9-130M FS+232d | 120d |
| 2548020 |  | Full Crate Check - Pre Installation,Lab,Install Mods,Test,Log&Label VXS fADC125 FY13 | 11d | 2013-09-16 | 2013-09-30 | 2541145 FS-88d, 2541145a FS-88d, 2541120a FS-68d, 2541120 FS-68d | 111d |
| 2548020a |  | Full Crate Check - Pre Installation,Lab,Install Mods,Test,Log&Label VXS fADC125 FY14 | 57d | 2013-10-01 | 2013-12-20 | 2541145a FS-88d, 2541120 FS-68d, 2548020, 2541145 FS-88d, 2541120a FS-68d | 111d |
| 2548025a |  | Full Crate Check - Pre Installation,Lab,Install Mods,Test,Log&Label VXS F1TDC FY14 | 52d | 2013-10-01 | 2013-12-13 | 2548025, 9-130M FS+232d | 120d |
|  | 5 | **1.5.5 BEAMLINE** |  | 2009-04-01 | 2015-04-01 |  |  |
|  | 1 | **1.5.5.1 TAGGER** |  | 2009-04-01 | 2014-04-01 |  |  |
|  | 1 | **1.5.5.1.1 TAGGING MAGNET** |  | 2009-04-01 | 2013-10-15 |  |  |
| 15511070 |  | Proc Quad (TAGGING Mag) | 75d | 2009-04-01 | 2009-07-16 | 9-090M FS+120d | 1118d |
| 15511002 |  | Prepare Procurements/Fabrication Packages 2010 ((TAGGING Mag) | 247d | 2009-10-01 | 2010-09-29 | 9-100M | 211d |
| 15511010E |  | FY10 Travel (TAGGING Mag) | 248d | 2009-10-01 | 2010-09-30 | 9-100M | 84d |
| 15511005 |  | Drawings for Yoke Steel (TAGGING Mag) | 120d | 2010-04-01 | 2010-09-20 | 9-100M FS+120d, 12351055M | 274d |
| 15511010 |  | Drawings for Coils (TAGGING Mag) | 100d | 2010-04-01 | 2010-08-20 | 15511005 FS-120d, 9-100M FS+120d | 274d |
| 15511015 |  | Drawings for Vac Chamb (TAGGING Mag) | 120d | 2010-04-01 | 2010-09-20 | 9-100M FS+120d, 15511010 FS-100d | 274d |
| 15511025 |  | Dsgn Stands for Mag (TAGGING Mag) | 60d | 2010-04-01 | 2010-06-24 | 15511010 FS-100d, 9-100M FS+120d | 334d |
| 15511030 |  | Dsgn Supprt for Vac Chamb (TAGGING Mag) | 110d | 2010-04-01 | 2010-09-03 | 9-100M FS+120d, 15511015 FS-120d | 284d |
| 15511040 |  | Write Pwr Supply Spec (TAGGING Mag) | 25d | 2010-08-23 | 2010-09-27 | 15511010 | 535d |
| 15511045 |  | EH&S Review of Dsgn before Constrctn (TAGGING Mag) | 5d | 2010-09-21 | 2010-09-27 | 15511010, 15511025, 15511015, 15511030 | 274d |
| 15511011E |  | FY11 Travel (TAGGING Mag) | 248d | 2010-10-01 | 2011-09-30 | 15511010E | 84d |
| 15511004a |  | Engineering Support for Component Procurements FY11 (TAGGING Mag) | 189d | 2011-01-04 | 2011-09-30 | 9-110M FS+59d | 253d |
| 15511003 |  | Evaluate Procurements 2010 (TAGGING Mag) | 164d | 2011-01-05 | 2011-08-26 | 15511002 FS+61d | 211d |
| 15511050 |  | Vend Fab Tagger Magnet Peg Point #1 Submit Foundry reports | 139d | 2011-04-15 | 2011-10-31 | 15511003 FS-164d, 15511045, 9-110M FS+130d | 141d |
| 15511050a |  | Vend Fab Tagger Magnet Peg Point #2 Winding tooling complete, conductor received | 139d | 2011-04-15 | 2011-10-31 | 15511050 FS-139d | 141d |
| 15511050b |  | Vend Fab Tagger Magnet Peg Point #3 Submit machining sequence and initial ultrasonice inspection report | 176d | 2011-04-15 | 2011-12-30 | 15511050a FS-139d | 141d |
| 15511050c |  | Vend Fab Tagger Magnet Peg Point #4 Twelve coil assemblies wound | 176d | 2011-04-15 | 2011-12-30 | 15511050b FS-176d | 141d |
| 15511050d |  | Vend Fab Tagger Magnet Peg Point #5 Coil resin impregnation complete | 238d | 2011-04-15 | 2012-03-30 | 15511050c FS-176d | 141d |
| 15511050f |  | Vend Fab Tagger Magnet Peg Point #6 Submit hydrostatic pressure test, flow and pressure test data | 259d | 2011-04-15 | 2012-04-30 | 15511050d FS-238d | 141d |
| 15511050g |  | Vend Fab Tagger Magnet Peg Point #7 Submit dimensional and electrical test data | 281d | 2011-04-15 | 2012-05-31 | 15511050f FS-259d | 141d |
| 15511050h |  | Vend Fab Tagger Magnet Peg Point #8 Submit coil dim. and electrical inspection tests if coil manufactured outside Everso | 301d | 2011-04-15 | 2012-06-29 | 15511050g FS-281d | 141d |
| 15511050j |  | Vend Fab Tagger Magnet Peg Point #9 Submit dimension inspection report for core #1 and initial rep. on cores 2,3 and 4 | 346d | 2011-04-15 | 2012-08-31 | 15511050h FS-301d | 141d |
| 15511050k |  | Vend Fab Tagger Magnet Peg Point #10 Magnet assembly complete | 365d | 2011-04-15 | 2012-09-28 | 15511050j FS-346d | 141d |
| 15511050n |  | Vend Fab Tagger Magnet Peg Point #11 Magnet components arrive at JLab | 408d | 2011-04-15 | 2012-11-30 | 15511050k FS-365d | 141d |
| 15511004 |  | Engineering Support for Magnet Acceptance 2012 (TAGGING Mag) | 50d | 2011-10-03 | 2011-12-13 | 9-120M | 431d |
| 15511004b |  | Engineering Support for Component Procurements FY12 (TAGGING Mag) | 228d | 2011-10-03 | 2012-08-31 | 15511004a | 253d |
| 15511012E |  | FY12 Travel (TAGGING Mag) | 183d | 2011-10-03 | 2012-06-29 | 9-110M, 15511011E | 84d |
| 15511035 |  | Dsgn Stands for Quad (TAGGING Mag) | 55d | 2011-10-03 | 2011-12-20 | 9-120M | 580d |
| 15511060 |  | Proc Vac Chamb (TAGGING Mag) | 187d | 2012-01-05 | 2012-09-28 | 15511045, 15511003 FS-164d, 9-120M FS+60d | 184d |
| 15511065 |  | Proc Pwr Supply (TAGGING Mag) | 147d | 2012-03-05 | 2012-09-28 | 15511045, 15511040, 9-120M FS+100d | 184d |
| 15511110 |  | Proc. Tagger magnet stands | 107d | 2012-04-03 | 2012-08-31 | 9-120M FS+121d | 267d |
| 15511095 |  | Proc, calibrate, Install NMR (TAGGING Mag) FY12 | 103d | 2012-05-04 | 2012-09-28 | 9-120M FS+144d, 15511015 | 175d |
| 15511095b |  | Proc, calibrate, Install NMR (TAGGING Mag) Procurement | 168d | 2012-05-04 | 2013-01-09 | 9-120M FS+144d, 15511015 | 175d |
| 15511071 |  | Proc Quad Power Supply (TAGGING Mag) | 102d | 2012-05-07 | 2012-09-28 | 9-120M FS+145d, 15511070 | 424d |
| 15511095a |  | Proc, calibrate, Install NMR (TAGGING Mag) FY13 | 65d | 2012-10-01 | 2013-01-09 | 15511095 | 175d |
| 15511100 |  | Proc Turbo Pumps (TAGGING Mag) | 20d | 2012-10-01 | 2012-10-26 | 9-130M | 228d |
| 15511115 |  | Proc. Tagger beamline stands | 75d | 2012-11-02 | 2013-02-28 | 9-130M FS+24d | 325d |
| 15511105 |  | Tagger Magnet Acceptance Test (TAGGING Mag) | 1d | 2012-12-03 | 2012-12-03 | 15511004 FS-50d, 15511004b FS-50d, 15511065, 15511050n, 15511060 | 141d |
| 15511120 |  | Re-Baseline Actuals Adjustment | 1d | 2013-08-30 | 2013-08-30 | 9-130M FS+227d | 20d |
| 25511095 |  | Proc, calibrate, Install NMR (TAGGING Mag) FY13 | 20d | 2013-09-03 | 2013-09-30 | 9-130M FS+228d | 125d |
| 25511095a |  | Proc, calibrate, Install NMR (TAGGING Mag) FY14 | 11d | 2013-10-01 | 2013-10-15 | 25511095, 9-130M FS+228d | 125d |
|  | 2 | **1.5.5.1.2 HODOSCOPE** |  | 2011-10-03 | 2014-04-01 |  |  |
| 15512004 |  | Prepare Procurement/Fabrication Packages 2012(HODOSCP) | 247d | 2011-10-03 | 2012-09-28 | 9-120M | 178d |
| 15512012E |  | FY12 Travel (HODOSCP) | 247d | 2011-10-03 | 2012-09-28 | 9-120M | 20d |
| 15512136 |  | Design & Layout Preamp Cards (HODOSCP) | 160d | 2011-10-03 | 2012-05-25 | 12351055M, 9-120M | 335d |
| 15512001 |  | Prepare Procurements for Thin Window Test 2011 (HODOSCP) | 46d | 2012-01-05 | 2012-03-12 | 9-120M FS+60d | 169d |
| 15512020 |  | AL Foil for Thin Window (HODOSCP) | 20d | 2012-01-05 | 2012-02-02 | 9-120M FS+60d | 135d |
| 15512170 |  | Purchase Power Supply for DAC Chips (HODOSCP) | 10d | 2012-01-05 | 2012-01-19 | 9-120M FS+60d | 425d |
| 15512120 |  | Proc Cables for Microscope (HODOSCP) | 127d | 2012-03-06 | 2012-08-31 | 9-120M FS+101d, 12351055M | 267d |
| 15512100 |  | Proc Fibers for Microscope (HODOSCP) | 104d | 2012-04-02 | 2012-08-27 | 9-120M FS+120d, 12351055M | 271d |
| 15512025 |  | Frame & Vacuum System for Limit Test of Thin Window (HODOSCP) | 130d | 2012-04-30 | 2012-10-31 | 15512001, 15512020 FS+60d | 135d |
| 15512005 |  | Design Hodoscope Supprt (HODOSCP) | 59d | 2012-07-09 | 2012-09-28 | 9-120M FS+188d | 71d |
| 15512110 |  | Proc SiPMs for Microscope (HODOSCP) Part A | 156d | 2012-07-11 | 2013-02-28 | 9-120M FS+190d | 149d |
| 15512110a |  | Proc SiPMs for Microscope (HODOSCP) Part B | 156d | 2012-07-11 | 2013-02-28 | 9-120M FS+190d | 149d |
| 15512013E |  | FY13 Travel (HODOSCP) | 228d | 2012-10-01 | 2013-08-30 | 15512012E, 15511012E | 20d |
| 15512050 |  | Proc PMTs for Fixed Array (HODOSCP) | 142d | 2012-10-01 | 2013-04-30 | 9-130M | 106d |
| 15512055 |  | Proc Dividers for Fixed Array (HODOSCP) | 142d | 2012-10-01 | 2013-04-30 | 9-130M | 106d |

| ID | WBS | Task | Duration | Start | Finish | Predecessors | Total float |
| --- | --- | --- | --- | --- | --- | --- | --- |
| 15512002 |  | Engineering Support for Testing Thin Window (HODOSCP) | 45d | 2012-11-01 | 2013-01-14 | 9-130M FS+23d | 135d |
| 15512030 |  | Test Window to limit (HODOSCP) | 45d | 2012-11-01 | 2013-01-14 | 15512025, 15512002 FS-45d | 135d |
| 15512003 |  | Prepare Procurement/Fabrication Packages 2013 (HODOSCP) | 25d | 2012-12-03 | 2013-01-14 | 9-130M FS+43d, 15512004 | 135d |
| 15512035 |  | Fab Final Thin Exit Window & AL Flange (HODOSCP) | 45d | 2013-01-15 | 2013-03-20 | 15512030, 15512003 | 135d |
| 15512005a |  | Construct Hodoscope Supprt (HODOSCP) | 52d | 2013-04-08 | 2013-06-19 | 15512005 FS+125d | 71d |
| 15512175 |  | Re-Baseline Actuals Adjustment | 1d | 2013-08-30 | 2013-08-30 | 9-130M FS+227d | 20d |
| 25512005 |  | Design Hodoscope Supprt (HODOSCP) FY13 | 20d | 2013-09-03 | 2013-09-30 | 9-130M FS+228d | 147d |
| 25512010 |  | Catholic University Tagger Hodoscope Fixed Array | 140d | 2013-09-03 | 2014-04-01 | 9-130M FS+228d | 67d |
| 25512010a |  | Catholic University Tagger Hodoscope Fixed Array Oversight FY13 | 20d | 2013-09-03 | 2013-09-30 | 9-130M FS+228d | 89d |
| 25512013LOE |  | FY13 Travel (HODOSCP) | 20d | 2013-09-03 | 2013-09-30 | 9-130M FS+228d | 187d |
| 25512056 |  | Manufacturing Drawings for Hodoscope mag shield (HODOSCP) | 20d | 2013-09-03 | 2013-09-30 | 9-130M FS+228d | 150d |
| 25512065 |  | Manufacturing Drawings for microscope cooling FY13 | 20d | 2013-09-03 | 2013-09-30 | 9-130M FS+228d | 69d |
| 25512131 |  | UConn TAGM Contract - Procurement of Supplies for Construction | 20d | 2013-09-03 | 2013-09-30 | 9-130M FS+228d | 89d |
| 25512136 |  | UConn TAGM Contract - Production 1st Article Opt Fib Bundle | 20d | 2013-09-03 | 2013-09-30 | 25512131 FS-20d | 89d |
| 25512146 |  | UConn TAGM Contract - Complete Construction of TAGM Enclosure | 62d | 2013-09-03 | 2013-11-27 | 25512136 FS-20d | 89d |
| 25512151 |  | UConn TAGM Contract - Testing of TAGM Electronic Boards | 20d | 2013-09-03 | 2013-09-30 | 25512146 FS-62d | 89d |
| 25512156 |  | UConn TAGM Contract - Complete 20 Optical Fiber Bundles | 77d | 2013-09-03 | 2013-12-20 | 25512151 FS-20d | 89d |
| 25512161 |  | UConn TAGM Contract - Complete Construction of Fiber Array Enclosure | 77d | 2013-09-03 | 2013-12-20 | 25512156 FS-77d | 89d |
| 25512166 |  | UConn TAGM Contract - Complete Assembly of Full Enclosure at UConn | 98d | 2013-09-03 | 2014-01-31 | 25512161 FS-77d | 89d |
| 25512171 |  | UConn TAGM Contract - Disassemble TAGM and Prepare for Shipment to JLab | 118d | 2013-09-03 | 2014-02-28 | 25512166 FS-98d | 89d |
| 25512176 |  | UConn TAGM Contract - TAGM Delivered to JLab | 118d | 2013-09-03 | 2014-02-28 | 25512171 FS-118d | 89d |
| 25512005b |  | Design Hodoscope Supprt (HODOSCP) FY14 | 11d | 2013-10-01 | 2013-10-15 | 9-130M FS+228d, 25512005 | 147d |
| 25512010aa |  | Catholic University Tagger Hodoscope Fixed Array Oversight FY14 | 98d | 2013-10-01 | 2014-02-28 | 25512010a, 9-130M FS+228d | 89d |
| 25512060 |  | Fab Hodoscope mag shields | 37d | 2013-10-01 | 2013-11-20 | 25512056 | 150d |
| 25512065a |  | Manufacturing Drawings for microscope cooling FY14 | 82d | 2013-10-01 | 2014-02-06 | 25512065, 9-130M FS+228d | 69d |
| 25512005a |  | Construct Hodoscope Supprt (HODOSCP) Part A | 30d | 2013-10-15 | 2013-11-25 | 25512005 FS-1d, 25512005b FS-1d | 147d |
| 25512070 |  | Fab microscope cooling | 23d | 2014-02-26 | 2014-03-28 | 25512065a FS+13d, 25512065 FS+13d | 69d |
|  | 2 | **1.5.5.2 TARGET** |  | 2011-04-01 | 2014-08-18 |  |  |
| 1552001 |  | Prepare Procurements/Fabrication Packages 2012 (TARGET) | 128d | 2011-04-01 | 2011-09-30 | 9-110M FS+120d | 377d |
| 1552004 |  | Develop gas handling system | 108d | 2011-04-01 | 2011-09-01 | 9-110M FS+120d | 486d |
| 1552002 |  | Evaluate Procuements 2012 (TARGET) FY11 | 101d | 2011-05-10 | 2011-09-30 | 1552001 FS-101d | 377d |
| 1552032 |  | Develop cryo system design | 86d | 2011-06-01 | 2011-09-30 | 9-110M FS+162d | 327d |
| 1552002a |  | Evaluate Procuements 2012 (TARGET) FY12 | 149d | 2011-10-03 | 2012-05-10 | 1552002 | 377d |
| 1552030 |  | Proc Liquid Helium refrigerator (TARGET) | 80d | 2011-10-03 | 2012-02-02 | 1552003 FS-300d, 1552002a FS-300d, 9-120M | 394d |
| 1552003 |  | FY12 Engineering Support for Assembly (TARGET) | 130d | 2012-01-05 | 2012-07-10 | 9-120M FS+60d | 267d |
| 1552018 |  | Fab Outer Vac/Scattering Chamb (TARGET) Labor Original | 18d | 2012-01-05 | 2012-01-31 | 9-120M FS+60d | 207d |
| 1552023 |  | Fab Target Cells (TARGET) Labor Original | 18d | 2012-01-05 | 2012-01-31 | 9-120M FS+60d | 207d |
| 1552023a |  | Fab Target Cells (TARGET) Labor Revised 2012 ETC FY12 | 127d | 2012-04-02 | 2012-09-28 | 1552023 FS+42d | 207d |
| 1552018a |  | Fab Outer Vac/Scattering Chamb (TARGET) Labor Revised 2012 ETC | 102d | 2012-05-07 | 2012-09-28 | 1552018 FS+67d | 207d |
| 1552027 |  | Burst test target cell | 64d | 2012-06-06 | 2012-09-04 | 1552025 FS-229d | 245d |
| 1552023aa |  | Fab Target Cells (TARGET) Labor Revised 2012 ETC FY13 | 20d | 2012-10-01 | 2012-10-26 | 1552023 FS+42d, 1552023a | 207d |
| 1552025 |  | Fab Target Cells (TARGET) | 147d | 2012-10-01 | 2013-05-07 | 9-130M, 1552023aa FS-147d, 1552003 FS-130d, 1552023a FS-147d, 1552023 FS-130d | 80d |
| 1552035 |  | Fab Positioning/Mounting Sys (TARGET) | 124d | 2012-11-05 | 2013-05-09 | 9-130M FS+25d | 78d |
| 1552020 |  | Fab Outer Vac/Scattering Chamb (TARGET) | 147d | 2012-12-03 | 2013-07-09 | 9-130M FS+43d, 1552003 FS-130d, 1552018 FS-130d, 1552018a FS-127d | 37d |
| 1552033 |  | Procure heat xchngr and cryo hardware | 147d | 2013-01-03 | 2013-08-01 | 1552032, 9-130M FS+60d | 20d |
| 1552005 |  | Proc Gas Handling Sys (TARGET) | 120d | 2013-02-15 | 2013-08-06 | 1552004, 9-130M FS+90d, 1552002a FS-60d | 129d |
| 1552045 |  | Program controls | 54d | 2013-03-08 | 2013-05-22 | 9-130M FS+104d | 239d |
| 1552010 |  | Proc Controls (TARGET) | 118d | 2013-03-18 | 2013-08-30 | 9-130M FS+110d | 20d |
| 1552015 |  | Fab Isolation Vac Pumping Sys (TARGET) | 83d | 2013-03-18 | 2013-07-12 | 9-130M FS+110d, 1552003 FS-130d | 94d |
| 1552006 |  | Install Gas Handling Sys (TARGET) | 69d | 2013-05-24 | 2013-08-30 | 1552005 FS-51d | 169d |
| 1552028 |  | Prepare Procurements/Fabrication Packages solid target (TARGET) | 63d | 2013-05-31 | 2013-08-28 | 9-130M FS+163d | 189d |
| 1552040 |  | Assemble Target (TARGET) | 21d | 2013-08-02 | 2013-08-30 | 1552033, 1552020, 1552030, 9-130M FS+6d, 1552045 FS-170d, 1552027, 1552028b FS-190d, 1552035, 1552025, 1552006 FS-170d, 1552015 FS-60d, 1552005 FS-112d | 20d |
| 1552028b |  | Fabricate solid target (labor) | 2d | 2013-08-29 | 2013-08-30 | 1552028 | 189d |
| 1552050 |  | Re-Baseline Actuals Adjustment | 1d | 2013-08-30 | 2013-08-30 | 9-130M FS+227d | 20d |
| 2552001 |  | Prepare Procurements/Fabrication Packages FY13 (TARGET) | 20d | 2013-09-03 | 2013-09-30 | 9-130M FS+228d | 48d |
| 2552005 |  | Proc Gas Handling Sys (TARGET) - Procurement | 50d | 2013-09-03 | 2013-11-11 | 9-130M FS+228d | 68d |
| 2552005a |  | Proc Gas Handling Sys (TARGET) - Expenses FY13 | 20d | 2013-09-03 | 2013-09-30 | 9-130M FS+228d | 68d |
| 2552008 |  | Manufacturing Drawings for gas System (Target) FY13 | 20d | 2013-09-03 | 2013-09-30 | 9-130M FS+228d | 96d |
| 2552010 |  | Proc Controls (TARGET) - Procurement | 65d | 2013-09-03 | 2013-12-04 | 9-130M FS+228d | 167d |
| 2552010a |  | Proc Controls (TARGET) - Expenses FY13 | 20d | 2013-09-03 | 2013-09-30 | 9-130M FS+228d | 167d |
| 2552015 |  | Fab Isolation Vac Pumping Sys (TARGET) (Previously Obligated) | 51d | 2013-09-03 | 2013-11-12 | 2552001 FS-30d, 2552001a FS-30d | 129d |
| 2552015a |  | Fab Isolation Vac Pumping Sys (TARGET) | 51d | 2013-09-03 | 2013-11-12 | 2552001 FS-30d, 2552001a FS-30d | 129d |
| 2552023aa |  | Fab Target Cells (TARGET) FY13 | 20d | 2013-09-03 | 2013-09-30 | 9-130M FS+228d | 11d |
| 2552032 |  | Manufacturing Drawings for cryo system (Target) FY13 | 20d | 2013-09-03 | 2013-09-30 | 9-130M FS+228d | 100d |
| 2552033 |  | Procure heat xchngr and cryo hardware | 20d | 2013-09-03 | 2013-09-30 | 2552032a FS-30d, 2552032 FS-30d | 100d |
| 2552001a |  | Prepare Procurements/Fabrication Packages FY14 (TARGET) | 10d | 2013-10-01 | 2013-10-14 | 2552001, 9-130M FS+228d | 48d |
| 2552005b |  | Proc Gas Handling Sys (TARGET) - Expenses FY14 | 30d | 2013-10-01 | 2013-11-11 | 2552005a, 9-130M FS+228d | 68d |
| 2552008a |  | Manufacturing Drawings for gas System (Target) FY14 | 46d | 2013-10-01 | 2013-12-05 | 2552008, 9-130M FS+228d | 96d |
| 2552010b |  | Proc Controls (TARGET) - Expenses FY14 | 45d | 2013-10-01 | 2013-12-04 | 2552010a, 9-130M FS+228d | 167d |
| 2552023aaa |  | Fab Target Cells (TARGET) FY14 | 89d | 2013-10-01 | 2014-02-17 | 9-130M FS+228d, 2552023aa | 11d |

| ID | WBS | Task | Duration | Start | Finish | Predecessors | Total float |
| --- | --- | --- | --- | --- | --- | --- | --- |
| 2552032a |  | Manufacturing Drawings for cryo system (Target) FY14 | 10d | 2013-10-01 | 2013-10-14 | 2552032, 9-130M FS+228d | 100d |
| 2552012 |  | Program Target Controls | 52d | 2013-10-07 | 2013-12-19 | 2552010b FS-41d, 2552010 FS-41d, 2552010a FS-41d | 214d |
| 2552018a |  | Fab Outer Vac/Scattering Chamb (TARGET) | 38d | 2013-10-15 | 2013-12-09 | 2552001a, 2552001 | 52d |
| 2552035 |  | Fab Positioning/Mounting Sys (TARGET) | 42d | 2013-11-01 | 2014-01-13 | 2552001, 2552001a, 9-140M FS+23d | 35d |
| 2552006 |  | Install Gas Handling Sys (TARGET) | 86d | 2014-01-10 | 2014-05-12 | 2552005a FS+33d, 2552005b FS+33d, 2552008, 2552008a, 2552005 FS+33d | 79d |
| 2552007 |  | Install Gas Tank (TARGET) | 18d | 2014-01-10 | 2014-02-05 | 2552001a, 9-140M FS+63d, 2552001, 2552005 FS-16d, 2552005a FS-16d, 2552005b FS-16d | 19d |
| 2552028 |  | Prepare Procurements/Fabrication Packages solid target (TARGET) | 42d | 2014-02-03 | 2014-04-01 | 9-140M FS+78d | 131d |
| 2552040 |  | Assemble Target (TARGET) | 128d | 2014-02-18 | 2014-08-18 | 2552018a, 2552010b FS-112d, 2552035, 2552006 FS-170d, 2552015 FS-60d, 2552007, 2552010 FS-112d, 2552028a FS-190d, 2552028b FS-190d, 2552015a FS-60d, 2552010a FS-112d, 2552023aaa, 2552023aa, 2552033, 2552012 FS-170d | 11d |
| 2552028a |  | Fabricate solid target (proc) | 38d | 2014-04-03 | 2014-05-27 | 2552028 FS+1d | 131d |
| 2552028b |  | Fabricate solid target (labor) | 38d | 2014-04-03 | 2014-05-27 | 2552028 FS+1d | 131d |
|  | 3 | **1.5.5.3 BEAMLINE COMPONENTS** |  | 2009-10-01 | 2015-04-01 |  |  |
| 1553010E |  | FY10 Travel (BL Compnts) | 248d | 2009-10-01 | 2010-09-30 | 9-100M | 20d |
| 1553001 |  | Engineering Support for Obtaining/Tstng Pair Spectrmtr Mag (BL Compnts) | 65d | 2010-10-01 | 2011-01-11 | 9-110M | 678d |
| 1553011E |  | FY11 Travel (BL Compnts) | 248d | 2010-10-01 | 2011-09-30 | 1553010E | 20d |
| 1553030 |  | Obtain Surplus Mag (BL Compnts) | 65d | 2010-10-01 | 2011-01-11 | 1553001 FS-65d, 9-110M | 678d |
| 1553001a |  | Prepare Procurements Packages 2011 (BL Compnts) | 188d | 2011-01-05 | 2011-09-30 | 9-110M FS+60d | 383d |
| 1553100 |  | Prepare Environment for Sweep Magnets (BL Compnts) | 50d | 2011-03-18 | 2011-05-26 | 9-110M FS+110d | 552d |
| 1553031 |  | Develop magnet gap modification | 44d | 2011-08-01 | 2011-09-30 | 9-110M FS+204d | 349d |
| 1553012E |  | FY12 Travel (BL Compnts) | 247d | 2011-10-03 | 2012-09-28 | 1553011E | 20d |
| 1553032 |  | Fabricate magnet gap modification | 81d | 2011-10-03 | 2012-02-03 | 1553031 | 349d |
| 1553048 |  | Proc Pair convertor (BL Compnts) Labor Original | 18d | 2012-01-05 | 2012-01-31 | 9-120M FS+60d | 270d |
| 1553065 |  | Proc Active Collimator Compnts (BL Compnts) | 130d | 2012-01-05 | 2012-07-10 | 9-120M FS+60d | 358d |
| 1553080 |  | Proc Passive Collimator Sys (BL Compnts) | 130d | 2012-01-05 | 2012-07-10 | 9-120M FS+60d | 265d |
| 1553085 |  | Design Primary Collimator Support (BL Compnts) | 55d | 2012-01-05 | 2012-03-23 | 9-120M FS+60d | 393d |
| 1553002 |  | Prepare Procurements Packages 2012 (BL Compnts) | 112d | 2012-02-01 | 2012-07-10 | 1553001a, 9-120M FS+78d | 305d |
| 1553048a |  | Proc Pair convertor (BL Compnts) Labor Revised 2012 ETC | 167d | 2012-02-03 | 2012-09-28 | 1553048 FS+2d | 270d |
| 1553036 |  | Build Pair Spectrometer Vacuum Box Labor (BL Compnts) Labor | 59d | 2012-02-28 | 2012-05-18 | 9-120M FS+96d | 238d |
| 1553034 |  | Develop Pair Spec magnet support | 44d | 2012-03-05 | 2012-05-03 | 9-120M FS+100d | 267d |
| 1553090 |  | Fabricate Collimator Support (BL Compnts) | 40d | 2012-03-26 | 2012-05-18 | 1553085 | 393d |
| 1553035 |  | Proc Pair Spectrometer Mag Pwr Supply (BL Compnts) | 206d | 2012-04-03 | 2013-01-31 | 9-120M FS+121d | 168d |
| 1553038 |  | Build Pair Spectrometer Vacuum Box (BL Compnts) | 59d | 2012-04-09 | 2012-07-02 | 1553036 FS-30d | 238d |
| 1553033 |  | Install magnet gap modification | 65d | 2012-05-04 | 2012-08-06 | 9-120M FS+144d, 1553032 | 286d |
| 1553034a |  | Procure Pair Spec magnet support | 84d | 2012-05-04 | 2012-08-31 | 1553034 | 267d |
| 1553040 |  | Proc Pair Spectrometer Detctr's (BL Compnts) Part A | 162d | 2012-05-04 | 2012-12-31 | 9-120M FS+144d | 128d |
| 1553040a |  | Proc Pair Spectrometer Detctr's (BL Compnts) Part B | 162d | 2012-05-04 | 2012-12-31 | 9-120M FS+144d | 128d |
| 1553095 |  | Purchase Lead for Cave Exit Wall (BL Compnts) | 63d | 2012-05-07 | 2012-08-03 | 9-120M FS+145d | 287d |
| 1553105 |  | Purchase Slow Control Crate (BL Compnts) | 65d | 2012-06-06 | 2012-09-05 | 9-120M FS+165d | 203d |
| 1553070 |  | Assemble Active Collimator (BL Compnts) FY12 | 57d | 2012-07-11 | 2012-09-28 | 1553065, 1553090 | 358d |
| 1553072 |  | Program & test Collimator Table (BL Components) FY12 | 57d | 2012-07-11 | 2012-09-28 | 1553080 | 378d |
| 1553013E |  | FY13 Travel (BL Compnts) | 228d | 2012-10-01 | 2013-08-30 | 1553012E | 20d |
| 1553070a |  | Assemble Active Collimator (BL Compnts) FY13 | 73d | 2012-10-01 | 2013-01-22 | 1553065, 1553090, 1553070 | 358d |
| 1553072a |  | Program & test Collimator Table (BL Components) FY13 | 53d | 2012-10-01 | 2012-12-14 | 1553072 | 378d |
| 1553015 |  | Proc Goniometer (BL Compnts) | 123d | 2012-11-26 | 2013-05-28 | 9-130M FS+38d | 25d |
| 1553045 |  | Manufacture, Mount and Test Pair Spectrometer Detctr's (BL Compnts) | 73d | 2012-12-07 | 2013-03-29 | 1553040 FS-12d, 1553040a FS-12d, 1553038, 1553036 | 128d |
| 1553017 |  | Procure vacuum gauges and valves for tagger beamline | 59d | 2013-01-03 | 2013-03-28 | 9-130M FS+60d | 129d |
| 1553075 |  | Test Active Collimator (BL Compnts) | 65d | 2013-01-23 | 2013-04-24 | 1553070, 1553070a, 1553072a | 358d |
| 1553060 |  | Proc Roughing Pump (BL Compnts) | 130d | 2013-02-08 | 2013-08-13 | 9-130M FS+85d | 33d |
| 1553050 |  | Proc Pair convertor (BL Compnts) | 59d | 2013-04-08 | 2013-06-28 | 9-130M FS+125d, 1553048a FS-125d, 1553048 FS-130d | 20d |
| 1553020 |  | Write Control Software for Goniometer (BL Compnts) | 62d | 2013-05-29 | 2013-08-23 | 1553015, 1553105 | 25d |
| 1553055 |  | Assemble and Test Pair convertor (BL Compnts) | 36d | 2013-07-12 | 2013-08-30 | 1553050 FS+8d | 20d |
| 1553110 |  | Re-Baseline Actuals Adjustment | 1d | 2013-08-30 | 2013-08-30 | 9-130M FS+227d | 20d |
| 2553011 |  | Diamond contractor and procurements support (BL Compnts) FY13 | 20d | 2013-09-03 | 2013-09-30 | 9-130M FS+228d | 0d |
| 2553017 |  | Procure vacuum gauges and valves for tagger beamline | 36d | 2013-09-03 | 2013-10-22 | 9-130M FS+228d | 208d |
| 2553035 |  | Proc Pair Spectrometer Mag Pwr Supply (BL Compnts) | 20d | 2013-09-03 | 2013-09-30 | 9-130M FS+228d | 36d |
| 2553036 |  | Proc Parts for Pair Spectrometer | 20d | 2013-09-03 | 2013-09-30 | 9-130M FS+228d | 155d |
| 2553041 |  | Build PS low granularity Support Frame | 21d | 2013-09-03 | 2013-10-01 | 2553036 FS-20d | 155d |
| 2553042 |  | Fabricate PS High Granularity Counters | 20d | 2013-09-03 | 2013-09-30 | 9-130M FS+228d | 213d |
| 2553050 |  | Proc Pair convertor insertion device (BL Compnts) (Previously Obligated) | 51d | 2013-09-03 | 2013-11-12 | 9-130M FS+228d | 108d |
| 2553052 |  | Proc Pair convertor insertion device (BL Compnts) | 51d | 2013-09-03 | 2013-11-12 | 9-130M FS+228d | 108d |
| 2553062 |  | UConn Contract - Procure Readout Electronics for Active Collimator | 40d | 2013-09-03 | 2013-10-28 | 9-130M FS+228d | 150d |
| 2553063 |  | UConn Contract - Assembly and Test of Active Collimator | 77d | 2013-09-03 | 2013-12-20 | 2553062 FS-40d | 150d |
| 2553064 |  | UConn Contract - Delivery of Active Collimator to JLab | 77d | 2013-09-03 | 2013-12-20 | 2553063 FS-77d | 150d |
| 2553072a |  | Program & test Collimator Table (BL Components) FY13 | 20d | 2013-09-03 | 2013-09-30 | 9-130M FS+228d | 156d |
| 2553080 |  | Proc Active Collimator Control Equipment (HallD) | 205d | 2013-09-03 | 2014-07-02 | 9-130M FS+228d | 22d |
| 2553085 |  | Support Control Active Collimator (HallD) FY13 | 20d | 2013-09-03 | 2013-09-30 | 9-130M FS+228d | 20d |
| 2553090 |  | Proc Hardware for Active Collimator Control (Accelerator Grp) | 183d | 2013-09-03 | 2014-06-02 | 9-130M FS+228d | 44d |
| 2553095 |  | Design Install Feedback System for Active Collimator (Accelerator Grp) FY13 | 20d | 2013-09-03 | 2013-09-30 | 9-130M FS+228d, 2553064 FS-187d | 44d |
| 2553110 |  | Manufacturing Drawings for Goniometer vacuum chamber | 20d | 2013-09-03 | 2013-09-30 | 9-130M FS+228d | 95d |
| 2553140 |  | Manufacturing Drawings of Amorphous target insertion device (E-beam) FY13 | 20d | 2013-09-03 | 2013-09-30 | 9-130M FS+228d | 117d |
| 2553145 |  | Fab Amorphous insertion device (e-beam) (Previously Obligated) | 70d | 2013-09-03 | 2013-12-11 | 2553140a FS-53d, 2553140 FS-53d | 117d |

| ID | WBS | Task | Duration | Start | Finish | Predecessors | Total float |
| --- | --- | --- | --- | --- | --- | --- | --- |
| 2553147 |  | Fab Amorphous insertion device (e-beam) | 70d | 2013-09-03 | 2013-12-11 | 2553140a FS-53d, 2553140 FS-53d | 117d |
| 2553170 |  | Procure goniometer vacuum pump/instrumentation | 73d | 2013-09-03 | 2013-12-16 | 9-130M FS+228d | 154d |
| 2553175 |  | Fab Tagger beamline components | 20d | 2013-09-03 | 2013-09-30 | 9-130M FS+228d | 263d |
| 2553057 |  | Sientific support for Pair spectrometer characterization(BL Compnts) FY13 | 1d | 2013-09-30 | 2013-09-30 | 2553050 FS-32d, 2553052 FS-32d | 191d |
| 2553005 |  | Proc Raw Radiator Diamond Crystals (BL Compnts) | 219d | 2013-10-01 | 2014-08-20 | 9-140M | 377d |
| 2553011a |  | Diamond contractor and procurements support (BL Compnts) FY14 | 247d | 2013-10-01 | 2014-09-30 | 2553011, 9-130M FS+228d | 0d |
| 2553057a |  | Sientific support for Pair spectrometer characterization(BL Compnts) FY14 | 154d | 2013-10-01 | 2014-05-19 | 2553050 FS-32d, 2553052 FS-32d, 2553057 | 191d |
| 2553072b |  | Program & test Collimator Table (BL Components) FY14 | 51d | 2013-10-01 | 2013-12-12 | 9-130M FS+228d, 2553072a | 156d |
| 2553085a |  | Support Control Active Collimator (HallD) FY14 | 187d | 2013-10-01 | 2014-07-07 | 9-130M FS+228d, 2553085 | 20d |
| 2553095a |  | Design Install Feedback System for Active Collimator (Accelerator Grp) FY14 | 163d | 2013-10-01 | 2014-06-02 | 9-130M FS+228d, 2553095, 2553064 FS-187d | 44d |
| 2553140a |  | Manufacturing Drawings of Amorphous target insertion device (E-beam) FY14 | 33d | 2013-10-01 | 2013-11-14 | 2553140, 9-130M FS+228d | 117d |
| 2553044 |  | Build PS High granularity Support Frame | 55d | 2013-10-03 | 2013-12-20 | 9-140M FS+2d | 155d |
| 2553130 |  | Manufacturing Drawings of cooling system for PS detector | 48d | 2013-10-04 | 2013-12-12 | 9-140M FS+3d | 137d |
| 2553125 |  | Install mounting frame for low granularity PS detectors | 43d | 2013-10-21 | 2013-12-20 | 2553041 FS+13d | 155d |
| 2553016 |  | Build Vacuum Housing for Goniometer (BL Compnts) | 58d | 2013-11-04 | 2014-02-06 | 9-140M FS+24d, 2553110 | 71d |
| 2553055 |  | Assemble and Test Pair convertor (BL Compnts) | 70d | 2013-11-26 | 2014-03-18 | 2553052 FS+9d, 2553050 FS+9d | 108d |
| 2553185 |  | Manufacturing Drawings of Photon beamline to dump | 21d | 2013-11-26 | 2014-01-07 | 9-140M FS+40d | 133d |
| 2553020 |  | Write Control Software for Goniometer (BL Compnts) | 125d | 2013-12-02 | 2014-06-06 | 9-140M FS+42d | 27d |
| 2553190 |  | Fabricate photon beamline to dump | 29d | 2013-12-02 | 2014-01-22 | 2553185 FS-19d | 133d |
| 2553010 |  | Thinning-Characterization-Mounting of Radiator Diamond Crystals (BL Compnts) Phase 1 | 202d | 2013-12-05 | 2014-09-30 | 2553005 FS-174d | 377d |
| 2553160 |  | Manufacturing Drawings of radiator holder | 34d | 2013-12-05 | 2014-02-03 | 9-140M FS+45d | 18d |
| 2553135 |  | Procure cooling system for PS detector | 44d | 2013-12-12 | 2014-02-24 | 2553130 FS-1d | 137d |
| 2553150 |  | Manufacturing Drawings of polarimeter vacuum chamber | 49d | 2013-12-16 | 2014-03-05 | 9-140M FS+52d | 81d |
| 2553195 |  | Install photon beamline to dump | 39d | 2014-01-29 | 2014-03-24 | 2553190 FS+4d | 133d |
| 2553165 |  | Fab radiator holder | 31d | 2014-02-05 | 2014-03-19 | 2553160 FS+1d, 9-140M FS+70d | 18d |
| 2553200 |  | Manufacturing Drawings of Total Absorption Counter | 24d | 2014-02-05 | 2014-03-10 | 9-140M FS+80d | 35d |
| 2553155 |  | Fab polarimeter vacuum chamber | 5d | 2014-03-18 | 2014-03-24 | 2553150 FS+8d | 81d |
| 2553157 |  | Install polarimeter | 52d | 2014-03-25 | 2014-06-05 | 2553155 | 81d |
| 2553205 |  | Fabricate Total Absorption Counter Support | 64d | 2014-04-02 | 2014-07-01 | 2553200 FS+16d | 35d |
| 2553027 |  | Install Goniometer (BL Compnts) | 41d | 2014-04-23 | 2014-06-19 | 2553016, 282453000 FS-94d, 2553020 FS-41d, 2553016 FF | 18d |
| 2553029 |  | Survey Goniometer (BL Compnts) | 53d | 2014-06-20 | 2014-09-04 | 2553027 | 18d |
| 2553210 |  | Install Total Absorption Counter | 28d | 2014-07-02 | 2014-08-11 | 2553205 | 35d |
| 2553075 |  | Test Active Collimator (BL Compnts) | 40d | 2014-07-08 | 2014-09-02 | 2553095a, 2553085a, 2553064, 2553085, 2553072a, 2553080, 2553072b, 2553062 FS+22d, 2553090, 2553095 | 20d |
| 2553010a |  | Thinning-Characterization-Mounting of Radiator Diamond Crystals (BL Compnts) | 120d | 2014-10-01 | 2015-04-01 | 2553010 | 377d |
|  | 6 | **1.5.6 INFRASTRUCTURE** |  | 2009-06-01 | 2014-10-01 |  |  |
|  | 1 | **1.5.6.1 ASSEMBLY** |  | 2010-02-11 | 2014-04-25 |  |  |
| 1561065 |  | Receive Modules 1-4 (Assy) | 5d | 2010-02-11 | 2010-02-18 | 15221215, 15221235, 15221205, 15221225 | 646d |
| 1561070 |  | Receive Modules 5-8 (Assy) | 5d | 2010-04-28 | 2010-05-04 | 15221265, 15221275, 15221245, 15221255 | 593d |
| 1561075 |  | Receive Modules 9-12 (Assy) | 5d | 2010-07-13 | 2010-07-19 | 195221065, 195221035, 195221055, 195221045 | 541d |
| 1561080 |  | Receive Modules 13-16 (Assy) FY10 | 4d | 2010-09-27 | 2010-09-30 | 195221085, 195221105, 195221075, 195221095 | 488d |
| 1561080b |  | Receive Modules 13-16 (Assy) Procurement | 5d | 2010-09-27 | 2010-10-01 | 195221085, 195221105, 195221075, 195221095 | 488d |
| 1561080a |  | Receive Modules 13-16 (Assy) FY11 | 1d | 2010-10-01 | 2010-10-01 | 1561080 | 488d |
| 1561085 |  | Receive Modules 17-20 (Assy) | 5d | 2010-12-30 | 2011-01-06 | 195221145, 195221125, 195221115, 195221135 | 427d |
| 1561090 |  | Receive Modules 21-24 (Assy) | 5d | 2011-02-24 | 2011-03-02 | 195221155, 195221175, 195221185, 195221165 | 390d |
| 1561095 |  | Receive Modules 25-28 (Assy) | 5d | 2011-05-11 | 2011-05-17 | 195221215, 195221225, 195221205, 195221195 | 336d |
| 1561100 |  | Receive Modules 29-32 (Assy) | 5d | 2011-07-26 | 2011-08-01 | 195221235, 195221245, 195221255, 195221265 | 284d |
| 1561101 |  | Receive Modules 33-36 (Assy) | 5d | 2011-10-10 | 2011-10-14 | 195221275, 195221310, 195221300, 195221290 | 231d |
| 1561102 |  | Receive Modules 37-40 (Assy) | 5d | 2011-12-29 | 2012-01-05 | 195221340, 195221330, 195221350, 195221320 | 180d |
| 1561103 |  | Receive Modules 41-44 (Assy) | 5d | 2012-03-08 | 2012-03-14 | 195221390, 195221380, 195221370, 195221360 | 133d |
| 1561104 |  | Receive Modules 45-48 (Assy) | 5d | 2012-05-23 | 2012-05-30 | 195221400, 195221420, 195221410, 195221430 | 79d |
| 1561155 |  | Assemble BCal readout wedges(Assy) FY12 | 40d | 2012-08-03 | 2012-09-28 | 1562242, 1562240b, 15221156n FS-40d, 1561105a FS-85d, 1562240a | 20d |
| 1561155b |  | Assemble BCal readout wedges(Assy) Procurement | 119d | 2012-08-03 | 2013-01-30 | 1562242, 1562240a, 1562240b, 15221156n FS-40d, 1561105a FS-85d | 130d |
| 1561105 |  | BCAL lightguide gluing, preparation for installation (Assy) FY12 | 28d | 2012-08-21 | 2012-09-28 | 15221030, 1561080b, 195221435M, 1561103, 1561075, 15221160aba, 15221009, 15221160ab, 15221160b, 1561085, 15221020, 1561102, 1561070, 1561104, 15221165, 1561090, 1561101, 1561095, 1561065, 1561080a, 1561100 | 22d |
| 1561105a |  | BCAL lightguide gluing, preparation for installation (Assy) FY13 | 43d | 2012-10-01 | 2012-11-30 | 1561105 | 22d |
| 1561155a |  | Assemble BCal readout wedges(Assy) FY13 | 79d | 2012-10-01 | 2013-01-30 | 1561105a FS-85d, 1562240a, 1561155, 1562242, 15221156n FS-40d, 1562240b | 20d |
| 1561050M |  | Complete FDC (Assy) | 0d | 2013-03-22 | 2013-03-22 | 15211230 | 32d |
| 1561040M |  | Delivery Complete for CDC (Assy) | 0d | 2013-04-05 | 2013-04-05 | 15212013E, 15212200 | 54d |
| 1561110 |  | Receive CDC (Assy) | 10d | 2013-04-05 | 2013-04-18 | 195212260, 1561040M | 54d |
| 1561140 |  | Receive FDC (Assy) | 10d | 2013-04-09 | 2013-04-22 | 15211191 FS-25d, 15211220, 15211012E, 1561050M, 15211185 | 20d |
| 1561115 |  | Mounting CDC (Assy) | 20d | 2013-04-19 | 2013-05-16 | 1561110 | 54d |
| 1561145 |  | Rail Mounting for FDC (Assy) | 10d | 2013-04-23 | 2013-05-06 | 1561140 | 20d |
| 1561120 |  | Alignment CDC (Assy) | 20d | 2013-05-17 | 2013-06-14 | 12361005, 1561115 | 54d |
| 1561125 |  | Operational Checks CDC (outside Solenoid) (Assy) | 20d | 2013-06-17 | 2013-07-15 | 1561120 | 54d |
| 1561170 |  | Re-Baseline Actuals Adjustment | 1d | 2013-08-30 | 2013-08-30 | 9-130M FS+227d | 20d |
| 2561145 |  | Rail Mounting for FDC (Assy) FY13 | 18d | 2013-09-05 | 2013-09-30 | 2562225 FS-18d | 0d |
| 2561050M |  | Complete FDC (Assy) | 0d | 2013-10-01 | 2013-10-01 | 25211208 | 1d |
| 2561145a |  | Rail Mounting for FDC (Assy) FY14 | 14d | 2013-10-01 | 2013-10-18 | 2561145, 2562225 FS-18d | 0d |
| 2561140 |  | Receive FDC (Assy) | 5d | 2013-10-02 | 2013-10-08 | 25211172 FS-9d, 2561050M, 25211220 FS-55d, 25211172a FS-9d | 0d |
| 2561110 |  | Receive CDC for Storage (Assy) | 25d | 2013-10-24 | 2013-11-27 | 2561040M FS-6d, 295212260 FS-6d | 63d |
| 2561040M |  | Delivery Complete for CDC (Assy) | 0d | 2013-11-01 | 2013-11-01 | 295212260 | 63d |

| ID | WBS | Task | Duration | Start | Finish | Predecessors | Total float |
| --- | --- | --- | --- | --- | --- | --- | --- |
| 2561060M |  | Delivery Complete for TOF (Assy) | 0d | 2013-12-02 | 2013-12-02 | 25231010 FS-200d, 25231090, 25231010a FS-200d, 25231145 FS-15d, 25231085 | 69d |
| 2561160 |  | Receive TOF Detector Units (Assy) | 10d | 2013-12-02 | 2013-12-13 | 2561060M | 69d |
| 2561165 |  | Mount TOF Counters onto Detector Frame (Assy) | 60d | 2014-02-03 | 2014-04-25 | 25231030, 25231045, 2561160 FS+20d | 64d |
|  | 2 | **1.5.6.2 INSTALLATION** |  | 2009-06-01 | 2014-10-01 |  |  |
| 1562001LOE |  | FY09 Work Cordinator (Installtn) | 86d | 2009-06-01 | 2009-09-30 | 9-090M FS+162d | 20d |
| 1562002LOE |  | FY10 Work Cordinator (Installtn) | 248d | 2009-10-01 | 2010-09-30 | 1562001LOE | 20d |
| 1562010E |  | FY10 Travel (Installtn) | 248d | 2009-10-01 | 2010-09-30 | 9-100M | 20d |
| 1562149 |  | Installation Safety & Planning Platform #5 (Installtn) | 50d | 2010-05-17 | 2010-07-27 | 2-10M FS-135d | 340d |
| 1562003LOE |  | FY11 Work Cordinator (Installtn) | 248d | 2010-10-01 | 2011-09-30 | 1562002LOE | 20d |
| 1562011E |  | FY11 Travel (Installtn) | 248d | 2010-10-01 | 2011-09-30 | 1562010E | 20d |
| 1562099d |  | Prepare procurement packages for col cave vacuum | 61d | 2011-01-05 | 2011-04-01 | 9-110M FS+60d | 433d |
| 1562101 |  | Procure hdwre for collimator cave utilities | 103d | 2011-01-05 | 2011-06-01 | 9-110M FS+60d | 558d |
| 1562105 |  | Fab Collimator Cave Stands (Installtn) | 103d | 2011-01-05 | 2011-06-01 | 9-110M FS+60d | 549d |
| 1562237 |  | Prepare procurement packages for upstream platform | 37d | 2011-01-05 | 2011-02-28 | 9-110M FS+60d | 236d |
| 1562102 |  | Install collimator cave utilities(Installtn) | 86d | 2011-01-20 | 2011-05-20 | 1562101 FS-95d, 9-110M FS+70d | 556d |
| 1562595 |  | Installation work space infrastructure (TW's Doublewide) Part A | 167d | 2011-02-04 | 2011-09-30 | 9-110M FS+81d | 743d |
| 1562595a |  | Installation work space infrastructure (TW's Doublewide) Part B | 167d | 2011-02-04 | 2011-09-30 | 9-110M FS+81d | 743d |
| 1562600 |  | Installation Equipment infrastructure | 167d | 2011-02-04 | 2011-09-30 | 9-110M FS+81d | 743d |
| 1562100 |  | Fab Collimator Cave Vac (Installtn) | 103d | 2011-02-18 | 2011-07-15 | 1562099d FS-30d, 9-110M FS+60d | 433d |
| 1562132 |  | Install Collimator cave stands (Installtn) | 85d | 2011-03-03 | 2011-06-30 | 1562105 FS-64d | 549d |
| 1562423 |  | Prepare solenoid and temporary platform Procurements/Fabrication Packages (Installtn) | 107d | 2011-05-02 | 2011-09-30 | 9-110M FS+141d | 172d |
| 1562240 |  | Fab Upstream Platform CDC #1 (Installtn) Expenses FY11 | 87d | 2011-05-31 | 2011-09-30 | 2-10M, 1562237, 1562425 FS-150d | 172d |
| 1562240b |  | Fab Upstream Platform CDC #1 (Installtn) Procurement | 122d | 2011-05-31 | 2011-11-18 | 2-10M, 1562425 FS-150d, 1562237 | 172d |
| 1562100b |  | Install col cave vacuum FY11 | 54d | 2011-07-18 | 2011-09-30 | 1562100, 1562099d | 433d |
| 1562004LOE |  | FY12 Work Cordinator (Installtn) | 247d | 2011-10-03 | 2012-09-28 | 1562003LOE | 20d |
| 1562012E |  | FY12 Travel (Installtn) | 247d | 2011-10-03 | 2012-09-28 | 1562011E | 20d |
| 1562100ba |  | Install col cave vacuum FY12 | 31d | 2011-10-03 | 2011-11-14 | 1562100b | 433d |
| 1562240a |  | Fab Upstream Platform CDC #1 (Installtn) Expenses FY12 | 35d | 2011-10-03 | 2011-11-18 | 1562240 | 172d |
| 1562425 |  | Evaluate Procurements 2011 (Installtn) | 44d | 2011-10-28 | 2012-01-09 | 1562423 FS+19d | 172d |
| 1562130 |  | Install Collimator Mag Sweep # 1 (Installtn) | 21d | 2011-11-15 | 2011-12-15 | 1562100, 1562102, 1553100, 1562105, 1562100ba | 433d |
| 1562242 |  | Oversee installation for upstream platform | 20d | 2011-11-21 | 2011-12-20 | 1562240a, 1562240b | 172d |
| 1562110 |  | Proc Collimator #2 and Obtain SEG Blocks (Installtn) | 65d | 2012-01-05 | 2012-04-06 | 9-120M FS+60d | 360d |
| 1562394 |  | Prepare procurement packages for downstream platform | 38d | 2012-01-05 | 2012-02-29 | 9-120M FS+60d | 570d |
| 1562325 |  | Fab SOLENOID Platform #2 (Installtn) Original | 15d | 2012-01-10 | 2012-01-31 | 9-120M FS+62d, 1562425 | 456d |
| 1562605LOE |  | Electrical power engineer support 2012 | 169d | 2012-02-01 | 2012-09-28 | 9-120M FS+78d | 20d |
| 1562655 |  | Cable mock up trials | 100d | 2012-02-03 | 2012-06-26 | 9-120M FS+80d | 563d |
| 1562660 |  | Tagger Gantry design | 65d | 2012-02-03 | 2012-05-04 | 9-120M FS+80d | 538d |
| 1562670 |  | Materials for installation Part A | 167d | 2012-02-03 | 2012-09-28 | 9-120M FS+80d | 496d |
| 1562670a |  | Materials for installation Part B | 167d | 2012-02-03 | 2012-09-28 | 9-120M FS+80d | 496d |
| 1562675 |  | Tagger LCW design | 65d | 2012-02-03 | 2012-05-04 | 9-120M FS+80d | 350d |
| 1562680 |  | Fiducialize and survey equipment (2012) | 167d | 2012-02-03 | 2012-09-28 | 9-120M FS+80d | 268d |
| 1562395 |  | Fab Downstream Platform #3 TOF, Fcal (Installtn) | 20d | 2012-03-01 | 2012-03-28 | 9-120M FS+93d, 1562394, 1562425 | 570d |
| 1562391 |  | Develop drift chamber gas system design | 80d | 2012-03-05 | 2012-06-26 | 9-120M FS+100d | 213d |
| 1562325a |  | Fab SOLENOID Platform #2 (Installtn) Revised 2012 ETC Labor | 80d | 2012-03-29 | 2012-07-20 | 1562325 FS+40d | 476d |
| 1562135 |  | Install Collimator #2 (Installtn) | 10d | 2012-04-09 | 2012-04-20 | 1562132, 1562110, 1562130 | 360d |
| 1562325b |  | Fab SOLENOID Platform #2 (Installtn) Revised 2012 ETC Procurement | 80d | 2012-04-26 | 2012-08-17 | 1562325 FS+60d | 456d |
| 1562665 |  | Tagger Gantry Fab | 65d | 2012-04-30 | 2012-07-31 | 1562660 FS-5d | 538d |
| 1562185 |  | Install Racks Counting Room (Installtn) | 32d | 2012-05-04 | 2012-06-20 | 16332030, 9-120M FS+144d | 75d |
| 1562115 |  | install Collimator Concrete Shielding (Installtn) | 44d | 2012-06-05 | 2012-08-03 | 9-120M FS+164d | 248d |
| 1562359 |  | Install Temporary Platform #5 (Installtn) | 22d | 2012-06-15 | 2012-07-16 | 9-120M FS+172d | 301d |
| 1562430 |  | Engineering Support for Tagger Installation 2012 (Installtn) | 73d | 2012-06-19 | 2012-09-28 | 9-120M FS+174d | 210d |
| 1562190 |  | Install Pwr to Racks Counting Room (Installtn) | 52d | 2012-06-21 | 2012-08-31 | 1562185 | 75d |
| 1562125 |  | Install Primary Collimator (Installtn) | 40d | 2012-07-11 | 2012-09-05 | 1553080, 9-120M | 265d |
| 1562120 |  | Install Lead Shielding for Wall (Installtn) | 39d | 2012-08-06 | 2012-09-28 | 1562115, 9-120M FS+60d | 248d |
| 1562055 |  | Install LCW Connections (Installtn) | 20d | 2012-08-22 | 2012-09-19 | 1562430 FS-47d, 1562050 FS-105d | 247d |
| 1562195 |  | Install Cooling to Racks in Counting Room (Installtn) | 44d | 2012-09-04 | 2012-11-02 | 1562190 | 75d |
| 1562005LOE |  | FY13 Work Cordinator (Installtn) | 228d | 2012-10-01 | 2013-08-30 | 1562004LOE | 20d |
| 1562013E |  | FY13 Travel (Installtn) | 228d | 2012-10-01 | 2013-08-30 | 1562012E | 20d |
| 1562610LOE |  | Electrical power engineer support 2013 | 228d | 2012-10-01 | 2013-08-30 | 1562605LOE | 20d |
| 1562620 |  | Procure Electrical Power cable/conduit Part A | 120d | 2012-10-01 | 2013-03-29 | 9-130M | 351d |
| 1562620a |  | Procure Electrical Power cable/conduit Part B | 120d | 2012-10-01 | 2013-03-29 | 9-130M | 351d |
| 1562640 |  | Procure cable trays and hardware | 125d | 2012-10-01 | 2013-04-05 | 9-130M | 268d |
| 1562685 |  | Fiducialize and survey equipment (2013) | 228d | 2012-10-01 | 2013-08-30 | 1562680 | 268d |
| 1562435 |  | Engineering Support for Detector Installation 2013 (Installtn) | 211d | 2012-10-24 | 2013-08-30 | 1562430 FS+17d | 210d |
| 1562440 |  | Engineering Support for Tagger Installation 2013 (Installtn) | 207d | 2012-10-30 | 2013-08-30 | 9-130M FS+21d | 212d |
| 1562200 |  | Install Fire Protection to Racks in Counting Room (Installtn) | 44d | 2012-11-05 | 2013-01-15 | 1562195 | 139d |
| 1562050 |  | Install Tagger Pwr Supply (Installtn) | 38d | 2012-11-28 | 2013-01-29 | 1562430 FS-47d, 9-130M FS+40d | 247d |
| 1562020M |  | Shipment of Bcal Modules (Installtn) | 0d | 2012-12-03 | 2012-12-03 | 1561105a | 166d |
| 1562625 |  | Install Electrical Power cable/conduit | 102d | 2012-12-03 | 2013-05-03 | 1562620 FS-77d, 1562620a FS-77d | 351d |
| 1562010M |  | Tagger Magnets Fabbed (Installtn) | 0d | 2012-12-04 | 2012-12-04 | 15511105 | 141d |

| ID | Task | Duration | Start | Finish | Predecessors | Total float |
| --- | --- | --- | --- | --- | --- | --- |
| 1562260 | Install Fire Protection (Installtn) Part A | 20d | 2012-12-04 | 2013-01-08 | 1562245 FS-81d | 306d |
| 1562260a | Install Fire Protection (Installtn) Part B | 20d | 2012-12-04 | 2013-01-08 | 1562245 FS-81d | 306d |
| 1562392 | Procure final hardware for gas systems | 128d | 2013-01-03 | 2013-07-05 | 9-130M FS+60d, 1562391 | 86d |
| 1562650 | Procure power transformers | 76d | 2013-02-01 | 2013-05-20 | 9-130M FS+80d | 340d |
| 1562393 | Install/test gas systems | 80d | 2013-02-05 | 2013-05-29 | 9-130M FS+2d, 1562392 FS-106d | 86d |
| 1562098 | Install Tagger Quad Stand & Magnet (Installtn) | 21d | 2013-03-01 | 2013-03-29 | 15511071, 15511035 FS+36d, 9-130M, 15511115 | 325d |
| 1562630 | Install nitrogen lines in hall D | 89d | 2013-03-04 | 2013-07-08 | 9-130M FS+100d | 307d |
| 1562085 | Racks - Install Tagger | 10d | 2013-03-11 | 2013-03-22 | 3C-10M FS+230d, 9-130M FS+105d | 40d |
| 1562090 | Install Tagger Electrnc's (Installtn) | 10d | 2013-03-25 | 2013-04-05 | 1562085 | 123d |
| 1562245 | Racks - Install Hall Lower Level Upstream (U1) | 10d | 2013-03-25 | 2013-04-05 | 1544075, 1562085 | 103d |
| 1562180 | Install Photon BL Tag Hall (Installtn) | 51d | 2013-04-01 | 2013-06-11 | 1562098 | 325d |
| 1562246 | Racks - Install Hall Lower Level Upstream South (US1) | 10d | 2013-04-08 | 2013-04-19 | 1562245 | 274d |
| 1562250 | Install Pwr to Racks Platform #1 (Installtn) | 20d | 2013-04-08 | 2013-05-03 | 1562245 | 103d |
| 1562255 | Install Cooling to Racks Platform #1 (Installtn) | 20d | 2013-04-08 | 2013-05-03 | 1562245 | 103d |
| 1562645 | Install cable trays and hardware | 96d | 2013-04-17 | 2013-08-30 | 1562640 FS+7d | 268d |
| 1562075 | Install Fire Protection for Tagger Electrnc's (Installtn) | 44d | 2013-04-19 | 2013-06-20 | 1562085 FS+19d | 40d |
| 1562025M | Assy of Fcal (Installtn) | 0d | 2013-04-22 | 2013-04-22 | 15222004, 15222105 FS+10d | 44d |
| 1562247 | Racks - Install Hall Lower Level North (N1) | 8d | 2013-04-22 | 2013-05-01 | 1562246 | 274d |
| 1562465 | Erect Dark Room for Fcal (Installtn) | 45d | 2013-04-22 | 2013-06-24 | 1562025M | 44d |
| 1562470 | Register Single Channel FCAL Detector to Readout (Installtn) | 65d | 2013-04-22 | 2013-07-23 | 15222105 FS+10d | 24d |
| 1562248 | Racks - Install Hall Lower Level South (S1) | 10d | 2013-05-02 | 2013-05-15 | 1562247 | 274d |
| 1562635 | Install air lines in hall D | 84d | 2013-05-03 | 2013-08-30 | 9-130M FS+144d | 268d |
| 1562270 | Install Supprt Electrnc's, Platform #1 (Installtn) | 45d | 2013-05-06 | 2013-07-09 | 1562260a FS+81d, 1562260 FS+81d | 306d |
| 1562360 | Install FDC on Platform (Installtn) | 10d | 2013-05-07 | 2013-05-20 | 1561140, 1561145 | 20d |
| 1562330 | Racks - Install Hall Upper Level Upstream (U2) | 10d | 2013-05-16 | 2013-05-30 | 1544075, 1562325, 1562325a, 1562248, 1562325b | 274d |
| 1562365 | Alignment of FDC (Installtn) | 10d | 2013-05-21 | 2013-06-04 | 1562360 | 20d |
| 1562335 | Install Pwr to Racks Platform #2 (Installtn) | 45d | 2013-05-31 | 2013-08-02 | 1562330 | 288d |
| 1562045 | Install Tagger Magnets & Chamber (Installtn) | 45d | 2013-06-04 | 2013-08-06 | 1562010M, 1562430 FS-73d, 9-130M FS+165d, 3C-10M | 20d |
| 1562370 | Cables - Install on Trays Detector to Racks FDC | 62d | 2013-06-05 | 2013-08-30 | 1547170, 1562365, 1547160, 1547165 | 20d |
| 1562400 | Racks - Install Hall Upper Level Downstream (D2) | 10d | 2013-06-06 | 2013-06-19 | 1544075, 1562395, 1562330 FS+4d | 274d |
| 1562405 | Install Pwr to Racks Platform #3 (Installtn) | 45d | 2013-06-20 | 2013-08-22 | 1562400 | 274d |
| 1562070 | Install Cooling for Tagger Electrnc's (Installtn) | 10d | 2013-06-21 | 2013-07-05 | 1562075 | 40d |
| 1562205 | Install Computers in Counting Room (Installtn) Part A | 20d | 2013-07-01 | 2013-07-29 | 1531057, 9-120M, 1531052, 1531032a, 1531018, 1531087, 1531042, 1531070, 1531012, 1531062, 1531047, 1531022, 1531077, 1531032, 1562200, 1531082, 1531048 | 24d |
| 1562065 | Install Pwr for Tagger Electrnc's (Installtn) | 20d | 2013-07-08 | 2013-08-02 | 1562070 | 40d |
| 1562225 | Mount Bcal Modules in Solenoid (Installtn) | 39d | 2013-07-09 | 2013-08-30 | 1561155, 15221155a, 1561155a FS+110d, 151173n, 15221155b, 15221180, 12361010, 15221156n, 1561155b, 1562020M, 15221180a, 1562435 FS-229d | 20d |
| 1562015M | Assy of CDC (Installtn) | 0d | 2013-07-16 | 2013-07-16 | 1561125 | 54d |
| 1562210 | Install Supprt Electrnc's in Counting Room (Installtn) | 20d | 2013-07-30 | 2013-08-26 | 1562205 | 24d |
| 1562475 | Cables - Install on Trays Detector to Racks FCAL | 24d | 2013-07-30 | 2013-08-30 | 1547200, 15222100a, 1562465, 1562470 | 20d |
| 1562060 | Survey & Align Magnets (Installtn) | 10d | 2013-08-07 | 2013-08-20 | 1562440 FS-210d, 1562045 | 20d |
| 1562275 | Cables - Install on Trays Detector to Racks BCAL | 10d | 2013-08-19 | 2013-08-30 | 1547175, 1547185 FS+8d, 1547180 | 20d |
| 1562061 | Field Map Tagging Magnet (Installtn) | 8d | 2013-08-21 | 2013-08-30 | 1562055, 15511095a, 1562060, 1562045, 1562440 FS-200d, 15511095b | 20d |
| 1562096 | Install Permanent Magnet Stand (Installtn) (Future Activity Complete prior to Rebaseline) | 1d | 2013-08-30 | 2013-08-30 | 9-130M FS+227d | 20d |
| 1562097 | Install Permanent Magnet (Installtn) (Future Activity Complete prior to Rebaseline) | 1d | 2013-08-30 | 2013-08-30 | 9-130M FS+227d | 20d |
| 1562140 | Install Collimator Concrete Shielding (Installtn) Part A (Future Activity Complete prior to Rebaseline) | 1d | 2013-08-30 | 2013-08-30 | 9-130M FS+227d | 20d |
| 1562140a | Install Collimator Concrete Shielding (Installtn) Part B (Future Activity Complete prior to Rebaseline) | 1d | 2013-08-30 | 2013-08-30 | 9-130M FS+227d | 20d |
| 1562145 | Install Collimator Lead Shielding Wall (Installtn) (Future Activity Complete prior to Rebaseline) | 1d | 2013-08-30 | 2013-08-30 | 9-130M FS+227d | 20d |
| 1562345 | Install Fire Protection (Installtn) (Future Activity Complete prior to Rebaseline) | 1d | 2013-08-30 | 2013-08-30 | 9-130M FS+227d | 20d |
| 1562413 | Install Fire Protection (Installtn) (Future Activity Complete prior to Rebaseline) | 1d | 2013-08-30 | 2013-08-30 | 9-130M FS+227d | 20d |
| 1562420 | Install Supprt Electrnc's Platform #3 (Installtn) (Future Activity Complete prior to Rebaseline) | 1d | 2013-08-30 | 2013-08-30 | 9-130M FS+227d | 20d |
| 1562690 | Re-Baseline Actuals Adjustment | 1d | 2013-08-30 | 2013-08-30 | 9-130M FS+227d | 20d |
| 2562000 | Procured Labor (Bill Vulcan) | 20d | 2013-09-03 | 2013-09-30 | 9-130M FS+228d | 0d |
| 2562005LOE | FY13 Work Cordinator (Installtn) | 20d | 2013-09-03 | 2013-09-30 | 9-130M FS+228d | 2d |
| 2562013E | FY13 Travel (Installtn) | 20d | 2013-09-03 | 2013-09-30 | 9-130M FS+228d | 0d |
| 2562045 | Install Tagger Magnets & Chamber (Installtn) FY13 | 20d | 2013-09-03 | 2013-09-30 | 9-130M FS+228d | 124d |
| 2562050 | Install Tagger Pwr Supply (Installtn) FY13 | 20d | 2013-09-03 | 2013-09-30 | 9-130M FS+228d | 44d |
| 2562063 | Fab field map fixture tagging magnet | 32d | 2013-09-03 | 2013-10-16 | 9-130M FS+228d | 144d |
| 2562085 | Racks - Install Tagger FY13 | 20d | 2013-09-03 | 2013-09-30 | 9-130M FS+228d | 169d |
| 2562099 | Cables - Install on Trays Detector to Racks Pair Spectrometer | 14d | 2013-09-03 | 2013-09-20 | 9-130M FS+228d | 215d |
| 2562181 | Install Photon BL Colli. Cave (Installtn) - Procurement | 77d | 2013-09-03 | 2013-12-20 | 2553057a FS-175d, 2553057 FS-175d, 2553055 FS-130d | 190d |
| 2562181a | Install Photon BL Colli. Cave (Installtn) - Labor/Expenses FY13 | 20d | 2013-09-03 | 2013-09-30 | 2553055 FS-130d, 2553057a FS-175d, 2553057 FS-175d | 190d |
| 2562225 | Mount Bcal in Solenoid (Installtn) | 20d | 2013-09-03 | 2013-09-30 | 251195 FS-4d | 0d |
| 2562230 | Attach readout wedges to the BCAL modules in situ (Installtn) FY13 | 20d | 2013-09-03 | 2013-09-30 | 2546362 FS-20d, 2562225 FS-25d | 179d |
| 2562250a | Install Pwr to Racks Upstream Platform (Installtn) - Labor FY13 | 20d | 2013-09-03 | 2013-09-30 | 2562245 FS-28d | 166d |
| 2562330 | Racks - Install Hall Upper Level Upstream (U2) | 20d | 2013-09-03 | 2013-09-30 | 2562225 FS-20d | 179d |
| 2562335 | Install Pwr to Racks Platform #2 (Installtn) - Procurement | 77d | 2013-09-03 | 2013-12-20 | 2562330 FS-20d | 190d |
| 2562335a | Install Pwr to Racks Platform #2 (Installtn) - Labor FY13 | 20d | 2013-09-03 | 2013-09-30 | 2562330 FS-20d | 190d |
| 2562355 | Install Supprt Electrnc's Platform #2 (Installtn) - Procurement | 45d | 2013-09-03 | 2013-11-04 | 9-130M FS+228d | 222d |
| 2562355a | Install Supprt Electrnc's Platform #2 (Installtn) - Labor FY13 | 20d | 2013-09-03 | 2013-09-30 | 9-130M FS+228d | 222d |
| 2562392 | Procure final hardware for Drift Chamber gas systems (Previously Obligated) | 29d | 2013-09-03 | 2013-10-11 | 9-130M FS+228d | 47d |
| 2562392a | Procure final hardware for Drift Chamber gas systems | 29d | 2013-09-03 | 2013-10-11 | 9-130M FS+228d | 47d |

| ID | Task | Duration | Start | Finish | Predecessors | Total float |
| --- | --- | --- | --- | --- | --- | --- |
| 2562405 | Install Pwr to FCAL/TOF Racks (Installtn) | 75d | 2013-09-03 | 2013-12-18 | 9-130M FS+228d | 0d |
| 2562435 | Engineering Support for Detector Installation 2013 (Installtn) | 20d | 2013-09-03 | 2013-09-30 | 9-130M FS+228d | 129d |
| 2562440 | Engineering Support for Tagger Installation 2013 (Installtn) | 20d | 2013-09-03 | 2013-09-30 | 9-130M FS+228d | 231d |
| 2562445 | Engineering Support for Installation 2013 (Installtn) | 20d | 2013-09-03 | 2013-09-30 | 9-130M FS+228d | 19d |
| 2562466 | Install Dark Room for Fcal (Installtn) | 20d | 2013-09-03 | 2013-09-30 | 9-130M FS+228d | 79d |
| 2562475 | Cables - Install on Trays Detector to Racks FCAL FY13 (FY14 @ 2562475d) | 20d | 2013-09-03 | 2013-09-30 | 2562466 FS-20d | 79d |
| 2562475a | Cables - Route and Connect on Detector FCAL FY13 | 20d | 2013-09-03 | 2013-09-30 | 2562475d FS-26d, 2562475 FS-26d | 83d |
| 2562475b | Cables - Route on Racks FCAL FY13 | 20d | 2013-09-03 | 2013-09-30 | 2562475aa FS-39d, 2562475a FS-39d | 83d |
| 2562475c | Cables - Connect to Crate Electronics FCAL FY13 | 20d | 2013-09-03 | 2013-09-30 | 2562475b FS-46d, 2562475ba FS-46d | 83d |
| 2562478 | FCAL DAQ and Trigger_Setup FY13 | 20d | 2013-09-03 | 2013-09-30 | 2562475c FS-62d, 2562475ca FS-62d | 83d |
| 2562480 | Install Pulsing Sys for Fcal (Installtn) FY13 | 20d | 2013-09-03 | 2013-09-30 | 25222085 FS-88d, 25222085a FS-88d, 25222090 FS-88d, 2562475 FS-26d, 2562475d FS-26d | 79d |
| 2562482 | Test and analyze FCAL detector FY13 | 20d | 2013-09-03 | 2013-09-30 | 2562478a FS-117d, 2562478 FS-117d | 83d |
| 2562595a | Installation work space infrastructure (TW's Doublewide) | 267d | 2013-09-03 | 2014-09-30 | 9-130M FS+228d | 0d |
| 2562610LOE | Electrical power engineer support 2013 | 20d | 2013-09-03 | 2013-09-30 | 9-130M FS+228d | 245d |
| 2562620a | Procure Electrical Power cable/conduit Part B FY13 | 20d | 2013-09-03 | 2013-09-30 | 9-130M FS+228d | 230d |
| 2562626 | Install Transformers and Panels in Hall D | 62d | 2013-09-03 | 2013-11-27 | 9-130M FS+228d | 160d |
| 2562640 | Procure cable trays and hardware | 20d | 2013-09-03 | 2013-09-30 | 9-130M FS+228d | 124d |
| 2562645 | Install cable trays and hardware FY13 | 20d | 2013-09-03 | 2013-09-30 | 2562640 FS-20d | 124d |
| 2562685 | Fiducialize and survey equipment (2013) | 20d | 2013-09-03 | 2013-09-30 | 9-130M FS+228d | 247d |
| 2562690 | Manufacturing Drawings of cooling system for FCAL dark room FY13 | 20d | 2013-09-03 | 2013-09-30 | 9-130M FS+228d | 190d |
| 2562705 | Manufacturing Drawings of Chilled water system for Hall D | 12d | 2013-09-03 | 2013-09-18 | 9-130M FS+228d | 134d |
| 2562730 | Install Upstream cable trays (FDC/CDC/SC) FY13 | 20d | 2013-09-03 | 2013-09-30 | 2562225 FS-20d | 56d |
| 2562785 | Materials for install 2013 (Previously Obligated) | 20d | 2013-09-03 | 2013-09-30 | 9-130M FS+228d | 747d |
| 2562790 | Materials for install 2013 | 20d | 2013-09-03 | 2013-09-30 | 9-130M FS+228d | 747d |
| 2562830 | Install BCAL cooling manifold FY13 | 20d | 2013-09-03 | 2013-09-30 | 25221320 FS-23d | 29d |
| 2562865 | Procure lighting fixture under US platform | 24d | 2013-09-03 | 2013-10-04 | 9-130M FS+228d | 124d |
| 2562895 | Preparing OSP ESAD documentation Rediness Review for April 14 Beam Run FY13 | 20d | 2013-09-03 | 2013-09-30 | 9-130M FS+228d | 97d |
| 2562805 | Manufacturing Drawings of N2 purge system FY13 | 18d | 2013-09-05 | 2013-09-30 | 9-130M FS+230d | 94d |
| 2562250 | Install Pwr to Racks Upstream Platform (Installtn) - Procurement | 57d | 2013-09-09 | 2013-11-26 | 2562245 FS-24d | 162d |
| 2562275 | Cables - Install on Trays Detector to Racks BCAL FY13 | 2d | 2013-09-27 | 2013-09-30 | 2547180 FS-2d, 2547175 FS-2d | 58d |
| 2562006LOE | FY14 Work Cordinator (Installtn) | 245d | 2013-10-01 | 2014-09-26 | 2562005LOE | 2d |
| 2562014E | FY14 Travel (Installtn) | 247d | 2013-10-01 | 2014-09-30 | 2562013E, 2562000 | 0d |
| 2562045a | Install Tagger Magnets & Chamber (Installtn) FY14 | 11d | 2013-10-01 | 2013-10-15 | 2562045, 9-130M FS+228d | 124d |
| 2562050a | Install Tagger Pwr Supply (Installtn) FY14 | 8d | 2013-10-01 | 2013-10-10 | 9-130M FS+228d, 2562050 | 44d |
| 2562061 | Field Map Tagging Magnet (Installtn) | 63d | 2013-10-01 | 2014-01-09 | 2562045a FS-11d, 2562050a FS-13d, 25511095a FS-12d, 2562050 FS-13d, 2562440 FS-200d, 25511095 FS-12d, 2562063 FS-32d, 2562845 FS-120d, 2562045 FS-11d | 124d |
| 2562085a | Racks - Install Tagger FY14 | 9d | 2013-10-01 | 2013-10-11 | 9-130M FS+228d, 2562085 | 169d |
| 2562181b | Install Photon BL Colli. Cave (Installtn) - Labor/Expenses FY14 | 57d | 2013-10-01 | 2013-12-20 | 2562181a, 2553055 FS-130d, 2553057 FS-175d, 2553057a FS-175d | 190d |
| 2562230a | Attach readout wedges to the BCAL modules in situ (Installtn) FY14 | 57d | 2013-10-01 | 2013-12-20 | 2562225 FS-25d, 2562230, 2546362 FS-20d | 179d |
| 2562245 | Racks - Install Hall Lower Level Upstream (U1) | 8d | 2013-10-01 | 2013-10-10 | 9-140M, 2562225 FS-4d | 162d |
| 2562250b | Install Pwr to Racks Upstream Platform (Installtn) - Labor FY14 | 37d | 2013-10-01 | 2013-11-20 | 2562245 FS-24d, 2562250a | 166d |
| 2562275d | Cables - Install on Trays Detector to Racks BCAL FY14 | 22d | 2013-10-01 | 2013-10-30 | 2547180 FS-2d, 2562275, 2547175 FS-2d | 58d |
| 2562335b | Install Pwr to Racks Platform #2 (Installtn) - Labor FY14 | 57d | 2013-10-01 | 2013-12-20 | 2562330 FS-21d, 2562335a | 190d |
| 2562355b | Install Supprt Electrnc's Platform #2 (Installtn) - Labor FY14 | 25d | 2013-10-01 | 2013-11-04 | 2562355a, 9-130M FS+228d | 222d |
| 2562445a | Engineering Support for Installation 2014 (Installtn) | 228d | 2013-10-01 | 2014-09-03 | 2562445, 9-130M FS+228d | 19d |
| 2562475aa | Cables - Route and Connect on Detector FCAL FY14 | 19d | 2013-10-01 | 2013-10-25 | 2562475a, 2562475 FS-26d, 2562475d FS-26d | 83d |
| 2562475ba | Cables - Route on Racks FCAL FY14 | 26d | 2013-10-01 | 2013-11-05 | 2562475b, 2562475a FS-39d, 2562475aa FS-39d | 83d |
| 2562475ca | Cables - Connect to Crate Electronics FCAL FY14 | 42d | 2013-10-01 | 2013-11-27 | 2562475b FS-46d, 2562475ba FS-46d, 2562475c | 83d |
| 2562475d | Cables - Install on Trays Detector to Racks FCAL FY14 (FY13 @ 2562475) | 6d | 2013-10-01 | 2013-10-08 | 2562475, 2562466 FS-20d | 79d |
| 2562478a | FCAL DAQ and Trigger_Setup FY14 | 97d | 2013-10-01 | 2014-02-27 | 2562475ca FS-62d, 2562478, 2562475c FS-62d | 83d |
| 2562480a | Install Pulsing Sys for Fcal (Installtn) FY14 | 109d | 2013-10-01 | 2014-03-17 | 25222085 FS-88d, 2562475d FS-26d, 25222085a FS-88d, 2562480, 2562475 FS-26d, 25222090 FS-88d | 79d |
| 2562482a | Test and analyze FCAL detector FY14 | 164d | 2013-10-01 | 2014-06-03 | 2562478 FS-117d, 2562478a FS-117d, 2562482 | 83d |
| 2562615LOE | Electrical power engineer support 2014 | 247d | 2013-10-01 | 2014-09-30 | 2562610LOE | 245d |
| 2562620aa | Procure Electrical Power cable/conduit Part B FY14 | 4d | 2013-10-01 | 2013-10-04 | 9-130M FS+228d, 2562620a | 230d |
| 2562645a | Install cable trays and hardware FY14 | 34d | 2013-10-01 | 2013-11-15 | 2562645, 2562640 FS-20d | 124d |
| 2562690a | Manufacturing Drawings of cooling system for FCAL dark room FY14 | 16d | 2013-10-01 | 2013-10-22 | 2562690, 9-130M FS+228d | 190d |
| 2562730a | Install Upstream cable trays (FDC/CDC/SC) FY14 | 9d | 2013-10-01 | 2013-10-11 | 2562225 FS-20d, 2562730 | 56d |
| 2562805a | Manufacturing Drawings of N2 purge system FY14 | 33d | 2013-10-01 | 2013-11-14 | 9-130M FS+230d, 2562805 | 94d |
| 2562830a | Install BCAL cooling manifold FY14 | 20d | 2013-10-01 | 2013-10-28 | 25221320 FS-23d, 2562830 | 29d |
| 2562890 | Detector Readout Electronics Support Documentation and OSP | 248d | 2013-10-01 | 2014-10-01 | 9-140M | 10d |
| 2562895a | Preparing OSP ESAD documentation Rediness Review for April 14 Beam Run FY14 | 150d | 2013-10-01 | 2014-05-13 | 2562895, 9-130M FS+228d | 97d |
| 2562231 | Manufacturing Drawings of BCAL Lateral support | 20d | 2013-10-03 | 2013-10-30 | 9-140M FS+2d | 160d |
| 2562710 | Procure Chilled water components | 33d | 2013-10-03 | 2013-11-18 | 9-140M FS+2d, 2562705 | 124d |
| 2562740 | Manufacturing Drawings of dry air cooling upstream racks/drift chambers | 30d | 2013-10-04 | 2013-11-14 | 9-140M FS+3d | 143d |
| 2562835 | Install PS shielding | 31d | 2013-10-04 | 2013-11-15 | 9-140M FS+3d | 213d |
| 2562360 | Install FDC on Platform (Installtn) | 6d | 2013-10-07 | 2013-10-14 | 2561145 FS-10d, 2561145a FS-10d, 2561140 FS-2d | 0d |
| 2562214 | Fab field map fixture for PS magnet | 49d | 2013-10-11 | 2013-12-20 | 9-140M FS+8d | 158d |
| 2562365 | Alignment of FDC (Installtn) | 7d | 2013-10-15 | 2013-10-23 | 2562360 | 0d |
| 2562810 | Procure N2 purge system | 54d | 2013-10-15 | 2014-01-10 | 2562805 FS-23d, 2562805a FS-23d | 94d |
| 2562850 | Procure UPS system for critical controls | 67d | 2013-10-16 | 2014-01-31 | 9-140M FS+11d | 165d |
| 2562098 | Install Tagger Quad Stand & Magnet (Installtn) | 64d | 2013-10-18 | 2014-01-30 | 2562045 FS+2d, 2562045a FS+2d | 170d |

| ID | Task | Duration | Start | Finish | Predecessors | Total float |
| --- | --- | --- | --- | --- | --- | --- |
| 2562770 | Manufacturing Drawings of fixture for commissioning target | 52d | 2013-10-18 | 2014-01-13 | 9-140M FS+13d | 128d |
| 2562246 | Racks - Install Hall Lower Level Upstream South (US1) | 24d | 2013-10-21 | 2013-11-21 | 2562225 FS-19d, 2562245 FS+6d | 199d |
| 2562180 | Install Photon BL Tag Hall (Installtn) | 24d | 2013-10-22 | 2013-11-22 | 2562098 FS-80d, 2553175 FS-40d, 2553017 FS-1d | 208d |
| 2562745 | Fabricate dry air cooling system up racks/drift chambers | 28d | 2013-10-22 | 2013-12-02 | 2562740 FS-18d | 143d |
| 2562700 | Install Cooling system for FCAL dark room | 21d | 2013-10-23 | 2013-11-20 | 9-140M FS+13d, 2562690, 2562690a | 190d |
| 2562715 | Install Chilled water sytem Hall D | 46d | 2013-10-24 | 2014-01-09 | 2562710 FS-18d | 124d |
| 2562232 | Fab BCAL lateral support | 22d | 2013-10-28 | 2013-11-26 | 2562231 FS-3d | 160d |
| 2562275a | Cables - Route and Connect on Detector BCAL | 28d | 2013-10-28 | 2013-12-06 | 2562275d FS-3d, 2562275 FS-3d | 63d |
| 2562060 | Survey & Align tagger beamline (Installtn) | 16d | 2013-11-01 | 2013-11-22 | 2562440, 2562045 FS+12d, 2562045a FS+12d | 208d |
| 2562393 | Install/test gas systems | 52d | 2013-11-01 | 2014-01-28 | 2562392a FS-106d, 2562392 FS-106d, 9-140M FS+23d | 4d |
| 2562875 | Develop flammable gas detection system in solenoid | 46d | 2013-11-01 | 2014-01-17 | 9-140M FS+23d | 99d |
| 2562270 | Install Supprt Electrnc's, Platform #1 (Installtn) | 43d | 2013-11-04 | 2014-01-15 | 9-140M FS+24d | 56d |
| 2562370 | Cables - Install on Trays Detector to Racks FDC | 20d | 2013-11-04 | 2013-12-03 | 2547165, 2547170a, 2547165a, 2547170, 2562365 FS+7d | 0d |
| 2562370a | Cables - Route and Connect on Detector FDC | 28d | 2013-11-04 | 2013-12-13 | 2562370 FS-20d | 3d |
| 2562625 | Install Electrical Dirty Power cable/conduit from Panels | 68d | 2013-11-04 | 2014-02-20 | 2562626 FS-23d, 9-140M FS+24d, 2562620aa FS-55d, 2562620a FS-55d | 155d |
| 2562840 | Install dirty power cable/conduit tagger | 33d | 2013-11-04 | 2013-12-20 | 9-140M FS+24d | 154d |
| 2562278 | BCAL DAQ Control and Trigger set-up | 41d | 2013-11-05 | 2014-01-14 | 2562275c FS-32d | 63d |
| 2562880 | Procure flammable gas detection system | 53d | 2013-11-05 | 2014-01-31 | 2562875 FS-44d | 99d |
| 2562870 | Install lighting fixtures under US platform | 23d | 2013-11-12 | 2013-12-16 | 2562865 FS+26d | 124d |
| 2562636 | Manufacture Drawing Inst Air Sys | 25d | 2013-11-15 | 2014-01-02 | 2562805, 2562805a | 159d |
| 2562275b | Cables - Route on Racks BCAL | 23d | 2013-11-18 | 2013-12-20 | 2562275a FS-13d | 63d |
| 2562205 | Install NIM and CAEN Crates in Counting Room (Installtn) | 20d | 2013-11-21 | 2013-12-20 | 2531070 FS-1d, 2531047, 2531077 | 17d |
| 2562275c | Cables - Connect to Crate Electronics BCAL | 18d | 2013-11-25 | 2013-12-20 | 2562275b FS-18d | 63d |
| 2562035M | Assy of TOF (Installtn) | 0d | 2013-12-02 | 2013-12-02 | 2561060M | 163d |
| 2562535 | Crates - Loaded (VME64x VXS HV LV) Install Hall FDC | 50d | 2013-12-02 | 2014-02-20 | 9-140M FS+42d, 2548020a FS-46d, 2548025 FS-64d, 2548020 FS-46d, 2548025a FS-64d | 80d |
| 2562855 | Install UPS system for critical controls | 38d | 2013-12-04 | 2014-02-06 | 2562850 FS-34d | 165d |
| 2562290 | Cables - Install on Trays Detector to Racks CDC | 6d | 2013-12-05 | 2013-12-12 | 2547135 FS+20d, 2562330 | 134d |
| 2562775 | Fab Fixture for commissioning target | 48d | 2013-12-05 | 2014-02-21 | 2562770 FS-20d | 128d |
| 2562290a | Cables - Route and Connect on Detector CDC | 20d | 2013-12-09 | 2014-01-15 | 2562290 FS-4d | 134d |
| 2562370b | Cables - Route on Racks FDC | 14d | 2013-12-09 | 2014-01-07 | 2562370a FS-5d, 2562730a FS-15d, 2562730 FS-15d | 3d |
| 2562370c | Cables - Connect to Crate Electronics FDC | 48d | 2013-12-09 | 2014-02-25 | 2562370b FS-14d | 3d |
| 2562233 | Install BCAL lateral support | 24d | 2013-12-16 | 2014-01-29 | 2562232 FS+11d | 160d |
| 2562750 | Install dry air cooling system up racks/drift chamber | 32d | 2013-12-17 | 2014-02-11 | 2562870, 2562745 FS-9d | 124d |
| 2562206 | Install Computers in Counting Room (Installtn) Part B | 17d | 2014-01-02 | 2014-01-27 | 2562205, 2531022, 2531027 | 173d |
| 2562210 | Install Supprt Electrnc's in Counting Room (Installtn) | 20d | 2014-01-02 | 2014-01-30 | 2562205 | 17d |
| 2562216 | Field Map PS magnet | 32d | 2014-01-02 | 2014-02-17 | 2562214 | 158d |
| 2562530 | Crates - Loaded (VME64x VXS HV LV) Install Hall CDC | 26d | 2014-01-02 | 2014-02-07 | 2548020a, 2548020 | 126d |
| 2562845 | Install Power cable/conduit tagger | 33d | 2014-01-02 | 2014-02-18 | 2562840 | 154d |
| 2562637 | Procure Inst Air Sys | 30d | 2014-01-03 | 2014-02-14 | 2562636 | 159d |
| 2562099a | Cables - Route and Connect on Detector Pair Spectrometer | 10d | 2014-01-06 | 2014-01-17 | 2562099, 9-140M FS+59d | 150d |
| 2562090 | Install Tagger Electrnc's (Installtn) | 10d | 2014-01-07 | 2014-01-21 | 9-140M FS+60d | 128d |
| 2562505 | Install Trigger Electrnc's (Installtn) | 20d | 2014-01-07 | 2014-02-04 | 2543115 FS+16d, 282443020a, 282443020 | 128d |
| 2562635 | Install air lines in hall D | 45d | 2014-01-07 | 2014-03-11 | 9-140M FS+60d | 142d |
| 2562860 | Install Electron beamline to dump | 31d | 2014-01-08 | 2014-02-20 | 9-140M FS+61d | 155d |
| 2562065 | Install Pwr for Tagger Electrnc's (Installtn) | 20d | 2014-01-09 | 2014-02-06 | 2562085, 9-140M FS+62d, 2562085a | 116d |
| 2562280 | Technical Support for Bcal Testing (Installtn) | 73d | 2014-01-10 | 2014-04-23 | 2562210 FS-14d, 25221060a FS-16d, 2562270 FS-43d, 2562275, 25221060 FS-16d, 2562275d | 17d |
| 2562290b | Cables - Route on Racks CDC | 7d | 2014-01-13 | 2014-01-22 | 2562290a FS-3d | 134d |
| 2562380 | Insertion of FDC (Installtn) | 7d | 2014-01-13 | 2014-01-22 | 282462005 | 0d |
| 2562281 | Analyze BCAL Performance inside solenoid | 118d | 2014-01-15 | 2014-07-01 | 2562278 | 63d |
| 2562540 | Crates - Loaded (VME64x VXS HV LV) Install Hall BCAL | 10d | 2014-01-16 | 2014-01-30 | 2562535 FS-25d, 2548025a FS-25d, 2548025 FS-25d | 80d |
| 2562099b | Cables - Route on Racks Pair Spectrometer | 5d | 2014-01-21 | 2014-01-27 | 2562099a | 150d |
| 2562290c | Cables - Connect to Crate Electronics CDC | 6d | 2014-01-21 | 2014-01-28 | 2562250b, 2562250a, 2562250, 2562290b FS-2d | 134d |
| 2562300 | Mounting CDC on cart align and insert into solenoid (Installtn) | 13d | 2014-01-23 | 2014-02-10 | 2562380, 2561110 | 34d |
| 2562385 | Cooling Sys Checks for FDC (Installtn) | 8d | 2014-01-23 | 2014-02-03 | 2562380 | 0d |
| 2562099c | Cables - Connect to Crate Electronics Pair Spectrometer | 10d | 2014-01-28 | 2014-02-10 | 2562099b | 150d |
| 2562165 | Install High Granularity Pair Spectrometer (Installtn) | 35d | 2014-01-29 | 2014-03-18 | 2553135 FS-19d, 2546470 FS-20d, 2553125, 2546470a FS-20d, 2553044 | 137d |
| 2562235 | Comp B-cal Assy (Installtn) | 10d | 2014-01-30 | 2014-02-12 | 25221057b, 2562830, 25221057ba, 25221057c, 2562233, 2562225, 2562245 FS+42d, 2562230a, 2562830a, 2562230, 25221057ca | 161d |
| 2562545 | Crates - Loaded (VME64x VXS HV LV) Install Hall TOF | 5d | 2014-01-31 | 2014-02-06 | 2548025, 2562540, 2548025a | 145d |
| 2562420 | Install Supprt Electrnc's FCAL/TOF Racks (Installtn) | 41d | 2014-02-03 | 2014-03-31 | 9-140M FS+78d | 128d |
| 2562303 | Install FDC/CDC Alignment Check System (Installtn) | 10d | 2014-02-10 | 2014-02-21 | 2562300 FS-1d | 51d |
| 2562301 | CDC mounting electronics and other connections in situ (Installtn) | 15d | 2014-02-11 | 2014-03-03 | 2562300 | 34d |
| 2562520 | Crates - Loaded (VME64x VXS HV LV) Install Hall Pair Spectrometer | 5d | 2014-02-11 | 2014-02-17 | 2548025a FS+32d, 2548025 FS+32d | 146d |
| 2562525 | Crates - Loaded (VME64x VXS HV LV) Install Hal Start Counter | 5d | 2014-02-18 | 2014-02-24 | 2548025, 2548025a, 2562520 | 146d |
| 2562780 | Install Commissioning target with Start Counter | 21d | 2014-03-03 | 2014-03-31 | 2562775 FS+5d | 128d |
| 2562885 | Install flammable gas detection system | 45d | 2014-03-10 | 2014-05-09 | 2562880 FS+25d | 99d |
| 2562170 | Install Photon Beam Profiler (Installtn) | 24d | 2014-03-26 | 2014-04-28 | 2553055 FS+5d | 108d |
| 2562080 | Install Hodoscope (Installtn) | 10d | 2014-04-02 | 2014-04-15 | 2546585, 2546605a, 2546605b, 2546600, 2562440 FS-200d, 2562061, 25512070, 2546585b, 25512005a, 25512010aa, 25512010, 25512010a, 2546605, 2546585a, 25512060, 25512176, 25512013LOE | 67d |
| 2562450 | Install TOF Sys (Installtn) | 17d | 2014-04-08 | 2014-04-30 | 2561165 FS-14d, 2562480a, 2562480 | 64d |
| 2562630 | Install nitrogen lines in hall D | 26d | 2014-04-11 | 2014-05-16 | 2562810 FS+63d | 94d |
| 2562095 | Cables - Install on Trays Detector to Racks Tagger | 10d | 2014-04-17 | 2014-04-30 | 2562085, 2562080 FS+1d, 2562090, 2562085a, 2562065 | 67d |

| ID | WBS | Task | Duration | Start | Finish | Predecessors | Total float |
| --- | --- | --- | --- | --- | --- | --- | --- |
| 2562515 |  | Crates - Loaded (VME64x VXS HV LV) Install Hall Tagger | 5d | 2014-04-22 | 2014-04-28 | 2548025a, 9-140M FS+134d, 2548025 | 98d |
| 2562455 |  | Cables - Install on Trays Detector to Racks TOF | 5d | 2014-05-01 | 2014-05-07 | 2547190a, 2547200a, 2547200, 2547190, 2562450, 2562035M | 64d |
| 2562900 |  | Preparing OSP ESAD documentation Rediness Review for October 14 Beam Run | 93d | 2014-05-06 | 2014-09-16 | 2562890 FS-104d | 10d |
| 2562095a |  | Cables - Route and Connect on Detector Tagger | 10d | 2014-05-07 | 2014-05-20 | 2562095 FS+4d | 67d |
| 2562460 |  | Test TOF Sys (Installtn) | 20d | 2014-05-08 | 2014-06-05 | 2562455 | 81d |
| 2562455a |  | Cables - Route and Connect on Detector TOF | 5d | 2014-05-15 | 2014-05-21 | 2562455 FS+5d | 64d |
| 2562095b |  | Cables - Route on Racks Tagger | 5d | 2014-05-21 | 2014-05-28 | 2562095a | 67d |
| 2562455b |  | Cables - Route on Racks TOF | 5d | 2014-05-22 | 2014-05-29 | 2562455a | 64d |
| 2562095c |  | Cables - Connect to Crate Electronics Tagger | 10d | 2014-05-29 | 2014-06-11 | 2562095b | 67d |
| 2562455c |  | Cables - Connect to Crate Electronics TOF | 2d | 2014-05-30 | 2014-06-02 | 2562455b | 64d |
| 2562510 |  | Check-out Trigger Electrnc's (Installtn) | 39d | 2014-07-10 | 2014-09-03 | 2562505, 2531125 FS-20d | 19d |
| 2562490 |  | Cables - Install on Trays Detector to Racks Start Counter | 2d | 2014-08-18 | 2014-08-19 | 2562485 FS-11d, 2562245 | 19d |
| 2562485 |  | Install Start Counter Onto LH Target (Installtn) | 10d | 2014-08-19 | 2014-09-02 | 25213005, 2552040, 2552007, 282462000, 2552006 | 11d |
| 2562490a |  | Cables - Route and Connect on Detector Start Counter | 2d | 2014-08-20 | 2014-08-21 | 2562490 | 41d |
| 2562495 |  | Test Start Counter (Installtn) | 10d | 2014-08-20 | 2014-09-03 | 2562490 | 19d |
| 2562490b |  | Cables - Route on Racks Start Counter | 2d | 2014-08-22 | 2014-08-25 | 2562490a | 41d |
| 2562490c |  | Cables - Connect to Crate Electronics Start Counter | 2d | 2014-08-26 | 2014-08-27 | 2562490b | 41d |
| 2562175 |  | Install Hydrogen Target and Start Counter Inside Detector (Installtn) | 10d | 2014-09-02 | 2014-09-15 | 282446035, 25213025, 2552040, 2546567a, 282446030, 2546567, 282446040a, 282446040, 2562485 FS-1d, 282446030a, 282446035a | 11d |
| 2562091M |  | Tagger Ready For Beam (Installtn) | 0d | 2014-09-04 | 2014-09-04 | 282453000, 2562061, 2553195, 2562098, 2562060 | 18d |
|  | 3 | **1.5.6.3 CRYOGENICS** |  | 2010-01-05 | 2013-08-30 |  |  |
| 1563005 |  | Release U-tube Fabrication Drawings (CRYOGENICS) | 130d | 2010-01-05 | 2010-07-09 | 9-100M FS+60d | 443d |
| 1563010 |  | Release Warm Gas Plumbing Fabrication Drawings (CRYOGENICS) (Frozen per CR11-036) | 130d | 2010-01-05 | 2010-07-09 | 9-100M FS+60d | 454d |
| 1563015 |  | Release Transfer Line Fabrication Drawings (CRYOGENICS) (Frozen per CR11-036) | 130d | 2010-01-05 | 2010-07-09 | 9-100M FS+60d | 408d |
| 1563020 |  | Release Cryogenic Instrumentation Drawings (CRYOGENICS) (Frozen per CR11-036) | 130d | 2010-01-05 | 2010-07-09 | 9-100M FS+60d | 437d |
| 1563016 |  | Proc Transfer Line (CRYOGENICS) (Frozen per CR11-036) | 141d | 2010-06-04 | 2010-12-30 | 1563015 FS-25d | 437d |
| 1563011 |  | Proc Warm Gas Plumbing (CRYOGENICS) (Frozen per CR11-036) | 116d | 2010-06-16 | 2010-11-30 | 1563010 FS-17d | 454d |
| 1563006 |  | Proc U-tubes (CRYOGENICS) (Frozen per CR11-036) | 116d | 2010-07-01 | 2010-12-15 | 1563005 FS-6d | 443d |
| 1563017 |  | Proc Cryo Distribution for Magnet (Labor) (CRYOGENICS) FY10 (Frozen per CR11-036) | 58d | 2010-07-12 | 2010-09-30 | 1563015 | 408d |
| 1563025 |  | Proc Cryogenic Instrumentation (CRYOGENICS) (Frozen per CR11-036) | 101d | 2010-08-02 | 2010-12-30 | 1563020 FS+15d | 437d |
| 1563017a |  | Proc Cryo Distribution for Magnet (Labor) (CRYOGENICS) FY11 (Frozen per CR11-036) | 87d | 2010-10-01 | 2011-02-11 | 1563017 | 408d |
| 1563030 |  | Reverse Entry per CR11-036 | 5d | 2011-08-01 | 2011-08-05 | 9-110M FS+204d | 39d |
| 1563035 |  | Re-Baseline Actuals Adjustment | 1d | 2013-08-30 | 2013-08-30 | 9-130M FS+227d | 20d |
|  | 7 | **1.5.7 SPARE HALL D SOLENOID** |  | 2011-07-01 | 2013-08-30 |  |  |
| 157005 |  | Spare Hall D Solenoid Procurement Process FY11 Labor | 64d | 2011-07-01 | 2011-09-30 | 9-110M FS+184d | 373d |
| 157010 |  | Spare Hall D Solenoid Procurement Process FY12 Labor | 58d | 2011-10-03 | 2011-12-30 | 157005 | 373d |
| 157020 |  | Spare Hall D Solenoid FY12 Oversight Labor | 20d | 2012-01-03 | 2012-01-31 | 157010 | 373d |
| 157030 |  | Spare Hall D Solenoid FY13 Oversight Labor | 44d | 2013-07-01 | 2013-08-30 | 157020, 9-130M FS+184d | 20d |
| 157045 |  | Re-Baseline Actuals Adjustment | 1d | 2013-08-30 | 2013-08-30 | 9-130M FS+227d | 20d |
|  | 6 | **1.6 CONVENTIONAL FACILITIES** |  | 2008-12-12 | 2015-10-02 |  |  |
|  | 1 | **1.6.1 ACCELERATOR** |  | 2009-10-01 | 2015-10-02 |  |  |
|  | 1 | **1.6.1.1 BUILDINGS** |  | 2009-10-01 | 2015-10-02 |  |  |
|  | 1 | **1.6.1.1.1 NORTH & SOUTH ACCESS BUILDING ADDITIONS** |  | 2009-10-01 | 2013-08-30 |  |  |
| 16111000M |  | N&S Access Addition Begin Constr | 0d | 2009-10-01 | 2009-10-01 | 9-100M, 1241035M | 162d |
| 16111005 |  | N&S Access Addition Award Contract | 60d | 2009-10-01 | 2010-01-04 | 16111000M | 278d |
| 16111010 |  | N&S Access Constrctn Contract April Progress Payment | 72d | 2010-01-20 | 2010-04-30 | 16111005 FS+10d | 278d |
| 16111010A |  | N&S Access Constrctn Contract May Progress Payment | 92d | 2010-01-20 | 2010-05-28 | 16111010 FS-72d | 278d |
| 16111010B |  | N&S Access Constrctn Contract June Progress Payment | 114d | 2010-01-20 | 2010-06-30 | 16111010A FS-92d | 278d |
| 16111010C |  | N&S Access Constrctn Contract July Progress Payment | 135d | 2010-01-20 | 2010-07-30 | 16111010B FS-114d | 278d |
| 16111010D |  | N&S Access Constrctn Contract August Progress Payment | 157d | 2010-01-20 | 2010-08-31 | 16111010C FS-135d | 278d |
| 16111010G |  | N&S Access Constrctn Contract September Progress Payment | 178d | 2010-01-20 | 2010-09-30 | 16111010D FS-157d | 278d |
| 16111010H |  | N&S Access Constrctn Contract October Progress Payment | 199d | 2010-01-20 | 2010-10-29 | 16111010G FS-178d | 278d |
| 16111010J |  | N&S Access Constrctn Contract November Progress Payment | 219d | 2010-01-20 | 2010-11-30 | 16111010H FS-199d | 278d |
| 16111010K |  | N&S Access Constrctn Contract December Progress Payment | 236d | 2010-01-20 | 2010-12-30 | 16111010J FS-219d | 278d |
| 16111010N |  | N&S Access Constrctn Contract January Progress Payment | 249d | 2010-01-20 | 2011-01-20 | 16111010K FS-236d | 278d |
| 16111012 |  | N&S Access Constrctn Contract Modifications | 249d | 2010-01-20 | 2011-01-20 | 16111005 FS+10d | 278d |
| 16111020 |  | N&S Access Addition Constrctn Mngmnt FY10 | 178d | 2010-01-20 | 2010-09-30 | 16111005 FS+10d | 278d |
| 16111020a |  | N&S Access Addition Constrctn Mngmnt FY11 | 111d | 2010-10-01 | 2011-03-18 | 16111020, 16111005 FS+10d | 278d |
| 16111015 |  | N&S Access Addition Bldng Cmmssng | 20d | 2011-01-21 | 2011-02-17 | 16111010N, 16111012 | 278d |
| 16111025 |  | N&S Access Addition Beneficial Occupancy | 20d | 2011-02-18 | 2011-03-18 | 16111015 | 278d |
| 16111030M |  | N&S Access Addition Constr Compltn | 0d | 2011-03-18 | 2011-03-18 | 16111025, 16111020a, 16111020 | 278d |
| 16111035 |  | Re-Baseline Actuals Adjustment | 1d | 2013-08-30 | 2013-08-30 | 9-130M FS+227d | 20d |
|  | 2 | **1.6.1.1.2 NORTH & SOUTH ACCESS BUILDING UTILITIES** |  | 2010-02-02 | 2015-10-02 |  |  |
| 16112000 |  | Redesign N&S Access LCW Upgrades | 105d | 2010-02-02 | 2010-06-30 | 9-100M FS+79d | 492d |
| 16112000M |  | N&S Access LCW Upgrades Begin Constr | 0d | 2010-07-01 | 2010-07-01 | 16112000, 1241195M, 1241075M | 492d |
| 16112005 |  | N&S Access LCW Upgrades Award Contract | 60d | 2010-07-01 | 2010-09-24 | 16112000M | 492d |
| 16112010 |  | West Arc LCW Header installation | 17d | 2010-12-01 | 2010-12-30 | 16112005, 16111025 FS-70d | 625d |
| 16112020 |  | N&S Access LCW Upgrades Constrctn Mngmnt FY11 | 207d | 2010-12-01 | 2011-09-30 | 16112005 FS+45d | 492d |
| 16112015 |  | N&S Access LCW Upgrades Bldng Cmmssng | 40d | 2011-08-05 | 2011-09-30 | 16112010, 1961000n FS-61d, 1961005 FS-61d | 475d |
| 16112020a |  | N&S Access LCW Upgrades Constrctn Mngmnt FY12 | 3d | 2011-10-03 | 2011-10-05 | 16112020 | 492d |
| 16112025 |  | N&S Access LCW Upgrades Beneficial Occupancy | 20d | 2011-10-03 | 2011-10-28 | 16112015 | 475d |

| ID | WBS | Task | Duration | Start | Finish | Predecessors | Total float |
| --- | --- | --- | --- | --- | --- | --- | --- |
| 16112035 |  | Re-Baseline Actuals Adjustment | 1d | 2013-08-30 | 2013-08-30 | 9-130M FS+227d | 20d |
| 26112011 |  | Redundant Cooling Towers Award Contract | 60d | 2014-10-01 | 2015-01-06 | 9-155M | 56d |
| 26112012 |  | Redundant Cooling Towers | 188d | 2015-01-07 | 2015-10-02 | 26112011 | 56d |
| 26112013 |  | Redundant Cooling Towers Construction Management | 187d | 2015-01-07 | 2015-10-01 | 26112011 | 57d |
| 26112030M |  | N&S Access LCW Upgrades Constr Comp | 0d | 2015-10-02 | 2015-10-02 | 26112012, 26112013 | 56d |
|  | 3 | **1.6.1.1.3 BEAM SWITCHYARD SERVICE BUILDING ADDITION** |  | 2010-10-01 | 2013-08-30 |  |  |
| 16113000M |  | BSY Addition Begin Constr | 0d | 2010-10-01 | 2010-10-01 | 9-110M, 1241115M | 49d |
| 16113005 |  | BSY Addition Award Contract | 60d | 2010-10-01 | 2011-01-04 | 16113000M | 49d |
| 16113010 |  | BSY Addition Constrctn Contract Progress | 220d | 2011-01-05 | 2011-11-15 | 16113005 | 49d |
| 16113020 |  | BSY Addition Consrtuction Mngmnt FY11 | 188d | 2011-01-05 | 2011-09-30 | 16113005 | 956d |
| 16113020a |  | BSY Addition Consrtuction Mngmnt FY12 | 92d | 2011-10-03 | 2012-02-21 | 16113020 | 956d |
| 16113012 |  | BSY Modify LCW Piping | 20d | 2011-11-16 | 2011-12-15 | 16113010 | 69d |
| 16113015 |  | BSY Addition Bldng Cmmssng | 40d | 2011-11-16 | 2012-01-23 | 16113010 | 49d |
| 16113025 |  | BSY Addition Beneficial Occupancy | 20d | 2012-01-24 | 2012-02-21 | 16113012, 16113015 | 49d |
| 16113030M |  | BSY Addition Constr Compltn | 0d | 2012-02-21 | 2012-02-21 | 16113025, 16113020a | 956d |
| 16113035 |  | Re-Baseline Actuals Adjustment | 1d | 2013-08-30 | 2013-08-30 | 9-130M FS+227d | 20d |
|  | 4 | **1.6.1.1.4 TUNNEL AIR CONDITIONING** |  | 2013-08-30 | 2015-08-04 |  |  |
| 16114035 |  | Re-Baseline Actuals Adjustment | 1d | 2013-08-30 | 2013-08-30 | 9-130M FS+227d | 20d |
| 26114000M |  | Tunnel A/C Begin Constr | 0d | 2014-10-01 | 2014-10-01 | 9-155M | 98d |
| 26114005 |  | Tunnel A/C Award Contract | 65d | 2014-10-01 | 2015-01-13 | 26114000M | 98d |
| 26114010 |  | Tunnel A/C Constrctn Contract Progress | 131d | 2015-01-14 | 2015-07-21 | 26114005 | 98d |
| 26114020 |  | Tunnel A/C Constrctn Mngmnt | 140d | 2015-01-14 | 2015-08-03 | 26114005 | 99d |
| 26114015 |  | Tunnel A/C Bldng Cmmssng | 5d | 2015-07-22 | 2015-07-28 | 26114010 | 98d |
| 26114025 |  | Tunnel A/C Beneficial Occupancy | 5d | 2015-07-29 | 2015-08-04 | 26114015 | 98d |
| 26114030M |  | Tunnel A/C Constr Comp | 0d | 2015-08-04 | 2015-08-04 | 26114020, 26114025 | 98d |
|  | 5 | **1.6.1.1.5. N&S LINAC SERVICE BUILDING AIR CONDITIONING** |  | 2012-10-01 | 2013-11-07 |  |  |
| 16115005 |  | Design N&S Linac A/C | 20d | 2012-10-01 | 2012-10-26 | 9-130M | 20d |
| 16115010 |  | Design and Safety Review of N&S Linac A/C | 10d | 2012-10-29 | 2012-11-09 | 16115005 | 20d |
| 16115015 |  | Finalize Design N&S Linac A/C | 10d | 2012-11-12 | 2012-11-27 | 16115010 | 20d |
| 16115020 |  | N&S Linac A/C Award Const Contract | 60d | 2012-11-28 | 2013-03-01 | 16115015 | 20d |
| 16115025 |  | N&S Linac A/C Construction Contract Progress | 128d | 2013-03-04 | 2013-08-30 | 16115020 | 20d |
| 16115030 |  | N&S Linac A/C Construction Management | 128d | 2013-03-04 | 2013-08-30 | 16115020 | 20d |
| 16115050 |  | Re-Baseline Actuals Adjustment | 1d | 2013-08-30 | 2013-08-30 | 9-130M FS+227d | 20d |
| 26115025 |  | N&S Linac A/C Construction Contract Progress | 38d | 2013-09-03 | 2013-10-24 | 9-130M FS+228d | 523d |
| 26115030 |  | N&S Linac A/C Construction Management FY13 | 20d | 2013-09-03 | 2013-09-30 | 26115025 FS-38d | 523d |
| 26115030a |  | N&S Linac A/C Construction Management FY14 | 28d | 2013-10-01 | 2013-11-07 | 26115025 FS-38d, 26115030 | 523d |
| 26115035 |  | N&S Linac A/C Building Commissioning | 5d | 2013-10-25 | 2013-10-31 | 26115025 | 523d |
| 26115040 |  | N&S Linac A/C Beneficial Occupancy | 5d | 2013-11-01 | 2013-11-07 | 26115035 | 523d |
| 26115045M |  | N&S Linac A/C Construction Complete | 0d | 2013-11-07 | 2013-11-07 | 26115040, 26115030, 26115030a | 523d |
|  | 2 | **1.6.1.2 SITEWORK** |  | 2010-01-21 | 2013-08-30 |  |  |
|  | 1 | **1.6.1.2.1** |  |  |  |  |  |
|  | 2 | **1.6.1.2.2 ELECTRICAL DISTRIBUTION - N&S LINAC** |  | 2010-01-21 | 2013-08-30 |  |  |
| 16122010 |  | N&S Linac Constrctn Contract Progress (ED) May Progress Payment | 91d | 2010-01-21 | 2010-05-28 | 16122005 FS-250d, 9-100M FS+71d | 329d |
| 16122010A |  | N&S Linac Constrctn Contract Progress (ED) June Progress Payment | 113d | 2010-01-21 | 2010-06-30 | 16122010 FS-91d | 329d |
| 16122010B |  | N&S Linac Constrctn Contract Progress (ED) July Progress Payment | 134d | 2010-01-21 | 2010-07-30 | 16122010A FS-113d | 329d |
| 16122010C |  | N&S Linac Constrctn Contract Progress (ED) August Progress Payment | 156d | 2010-01-21 | 2010-08-31 | 16122010B FS-134d | 329d |
| 16122010D |  | N&S Linac Constrctn Contract Progress (ED)September Progress Payment | 177d | 2010-01-21 | 2010-09-30 | 16122010C FS-156d | 329d |
| 16122012 |  | N&S Linac Constrctn Contract Modifications (ED) | 177d | 2010-01-21 | 2010-09-30 | 16122010D FS-177d | 329d |
| 16122020 |  | N&S Linac Constrctn Mngmnt (ED) | 173d | 2010-01-21 | 2010-09-24 | 16122005 FS-250d, 9-100M FS+71d | 1300d |
| 16122000M |  | Electrical Distrbtn N&S Linac Begin Constr | 0d | 2010-10-01 | 2010-10-01 | 1241195M, 9-110M | 342d |
| 16122005 |  | N&S Linac Award Contract (ED) | 60d | 2010-10-01 | 2011-01-04 | 16122000M | 342d |
| 16122015 |  | N&S Linac Bldng Cmmssng (ED) | 40d | 2010-10-01 | 2010-11-29 | 16122010D, 16122012, 16122010 | 329d |
| 16122025 |  | N&S Linac Beneficial Occupancy (ED) | 20d | 2010-11-30 | 2011-01-04 | 16122015 | 329d |
| 16122030M |  | Electrical Distrbtn N&S Linac Constr Comp | 0d | 2011-01-04 | 2011-01-04 | 16122020, 16122025 | 1236d |
| 16122035 |  | Re-Baseline Actuals Adjustment | 1d | 2013-08-30 | 2013-08-30 | 9-130M FS+227d | 20d |
|  | 3 | **1.6.1.2.3** |  |  |  |  |  |
|  | 4 | **1.6.1.2.4** |  |  |  |  |  |
|  | 5 | **1.6.1.2.5** |  |  |  |  |  |
|  | 6 | **1.6.1.2.6** |  |  |  |  |  |
|  | 7 | **1.6.1.2.7** |  |  |  |  |  |
|  | 2 | **1.6.2 CHL** |  | 2008-12-12 | 2013-08-30 |  |  |
|  | 1 | **1.6.2.1 CHL BUILDING ADDITION** |  | 2008-12-12 | 2013-08-30 |  |  |
| 1621009 |  | CHL Addition Constrctn Contract Award (BONDS) | 5d | 2008-12-12 | 2008-12-18 | 3C-04M FS-20d, 1621005 FS-20d | 141d |
| 1621015 |  | CHL Addition Constrctn Mngmnt FY09 | 198d | 2008-12-12 | 2009-09-30 | 1621005 FS-20d | 334d |
| 1621020 |  | CHL Addition A/E Supprt | 270d | 2008-12-12 | 2010-01-21 | 1621005 FS-20d | 334d |
| 1621010 |  | CHL Addition Constrctn Contract Progress | 240d | 2008-12-19 | 2009-12-08 | 1621009 | 141d |
| 1621005 |  | Prcrmnt Prep for CHL Addition to Award Contract | 11d | 2009-01-02 | 2009-01-16 | 1621005X | 72d |
| 1621011LOE |  | PPI Adjustment FY09 | 86d | 2009-06-01 | 2009-09-30 | 9-090M FS+162d | 575d |
| 1621011LOEb |  | PPI Adjustment FY10 | 47d | 2009-10-01 | 2009-12-08 | 1621011LOE | 575d |
| 1621015b |  | CHL Addition Constrctn Mngmnt FY10 | 72d | 2009-10-01 | 2010-01-21 | 1621015 | 334d |

| ID | WBS | Task | Duration | Start | Finish | Predecessors | Total float |
| --- | --- | --- | --- | --- | --- | --- | --- |
| 1621025 |  | CHl Addition Cmmssng | 20d | 2009-12-09 | 2010-01-13 | 1621010, 1621011LOEb | 575d |
| 1621030 |  | CHL Addition Beneficial Occupancy | 5d | 2010-01-14 | 2010-01-21 | 1621025 | 1472d |
| 1621035 |  | Re-Baseline Actuals Adjustment | 1d | 2013-08-30 | 2013-08-30 | 9-130M FS+227d | 20d |
|  | 2 | **1.6.2.2 SITEWORK** |  | 2009-10-01 | 2013-08-30 |  |  |
| 1622000 |  | Re-Baseline Actuals Adjustment | 1d | 2013-08-30 | 2013-08-30 | 9-130M FS+227d | 20d |
|  | 1 | **1.6.2.2.1** |  |  |  |  |  |
|  | 2 | **1.6.2.2.2 ELECTRICAL DISTRIBUTION** |  | 2009-10-01 | 2011-05-27 |  |  |
| 16222000M |  | Electrical Distrbtn Begin Constr | 0d | 2009-10-01 | 2009-10-01 | 16222000 FS-130d, 9-100M | 62d |
| 16222007 |  | Elect Distrbtn Original Labor | 130d | 2009-10-01 | 2010-04-14 | 16222000M | 62d |
| 16222000 |  | Redesign CHL Utilities Upgrades | 51d | 2010-02-01 | 2010-04-13 | 9-100M FS+78d | 23d |
| 16222032 |  | Elect Distrbtn 40 MVA Switchgear Modification Labor Original | 84d | 2010-02-01 | 2010-05-28 | 9-100M FS+78d | 270d |
| 16222005 |  | Elect Distrbtn Award Contract | 40d | 2010-04-14 | 2010-06-09 | 16222000M, 16222000 | 23d |
| 16222009 |  | CHL Utility Upgrades Modifications | 220d | 2010-06-10 | 2011-04-29 | 16222005, 16222007 | 23d |
| 16222010 |  | CHL Utility Upgrades Contract Progress July 2010 | 36d | 2010-06-10 | 2010-07-30 | 16222007, 16222005 | 23d |
| 16222010A |  | CHL Utility Upgrades Contract Progress August 2010 | 58d | 2010-06-10 | 2010-08-31 | 16222010 FS-36d | 23d |
| 16222010B |  | CHL Utility Upgrades Contract Progress September 2010 | 79d | 2010-06-10 | 2010-09-30 | 16222010A FS-58d | 23d |
| 16222010C |  | CHL Utility Upgrades Contract Progress October 2010 | 100d | 2010-06-10 | 2010-10-29 | 16222010B FS-79d | 23d |
| 16222010D |  | CHL Utility Upgrades Contract Progress November 2010 | 120d | 2010-06-10 | 2010-11-30 | 16222010C FS-100d | 23d |
| 16222010F |  | CHL Utility Upgrades Contract Progress December 2010 | 137d | 2010-06-10 | 2010-12-30 | 16222010D FS-120d | 23d |
| 16222010G |  | CHL Utility Upgrades Contract Progress January 2010 | 157d | 2010-06-10 | 2011-01-31 | 16222010F FS-137d | 23d |
| 16222010H |  | CHL Utility Upgrades Contract Progress February 2010 | 176d | 2010-06-10 | 2011-02-28 | 16222010G FS-157d | 23d |
| 16222010J |  | CHL Utility Upgrades Contract Progress March 2010 | 199d | 2010-06-10 | 2011-03-31 | 16222010H FS-176d | 23d |
| 16222010K |  | CHL Utility Upgrades Contract Progress April 2010 | 220d | 2010-06-10 | 2011-04-29 | 16222010J FS-199d | 23d |
| 16222015 |  | CHL Utility Upgrades Mngmnt FY10 | 79d | 2010-06-10 | 2010-09-30 | 16222005 | 23d |
| 16222020 |  | CHL Utility Upgrades A/E Supprt | 240d | 2010-06-10 | 2011-05-27 | 16222005 | 23d |
| 16222015a |  | CHL Utility Upgrades Mngmnt FY11 | 161d | 2010-10-01 | 2011-05-27 | 16222015 | 23d |
| 16222025 |  | CHL Utility Upgrades Cmmssng | 20d | 2011-04-04 | 2011-04-29 | 16222009 FS-20d, 16222010K FS-20d | 23d |
| 16222030 |  | CHL Utility Upgrades Beneficial Occupancy | 20d | 2011-05-02 | 2011-05-27 | 16222025 | 23d |
| 16222035M |  | CHL Utility Upgrades Complete | 0d | 2011-05-27 | 2011-05-27 | 16222030, 16222032, 16223007, 16222015a, 16222020, 16223005 | 23d |
|  | 3 | **1.6.2.2.3 COOLING WATER** |  | 2009-10-01 | 2010-02-03 |  |  |
| 16223000M |  | Cooling Water Tower Begin Constr | 0d | 2009-10-01 | 2009-10-01 | 9-100M, 16222000 FS-130d | 352d |
| 16223007 |  | Cooling Water Tower Original Labor | 80d | 2009-10-01 | 2010-02-02 | 16223000M | 352d |
| 16223005 |  | Cooling Water Tower Award Contract | 70d | 2009-10-15 | 2010-02-02 | 16223000M FS+10d | 352d |
| 16223008 |  | Reverse Entry per CR10-021 P6 5% Spread Fix | 1d | 2010-02-03 | 2010-02-03 | 9-100M FS+80d | 167d |
|  | 4 | **1.6.2.2.4** |  |  |  |  |  |
|  | 5 | **1.6.2.2.5** |  |  |  |  |  |
|  | 6 | **1.6.2.2.6** |  |  |  |  |  |
|  | 7 | **1.6.2.2.7** |  |  |  |  |  |
|  | 3 | **1.6.3 HALL D** |  | 2009-02-02 | 2013-08-30 |  |  |
|  | 1 | **1.6.3.1 TUNNEL & BUILDINGS** |  |  |  |  |  |
|  | 1 | **1.6.3.1.1 HALL D** |  |  |  |  |  |
|  | 2 | **1.6.3.1.2 TUNNEL EXTENSION** |  |  |  |  |  |
|  | 3 | **1.6.3.1.3 COUNTING HOUSE** |  |  |  |  |  |
|  | 4 | **1.6.3.1.4 TAGGER AREA** |  |  |  |  |  |
|  | 5 | **1.6.3.1.5 SERVICE BUILDINGS** |  |  |  |  |  |
|  | 6 | **1.6.3.1.6 CRYO PLANT** |  |  |  |  |  |
|  | 7 | **1.6.3.1.7 BEAM DUMP** |  |  |  |  |  |
|  | 2 | **1.6.3.2 SITEWORK** |  |  |  |  |  |
|  | 1 | **1.6.3.2.1 CIVIL UTILITIES** |  |  |  |  |  |
|  | 2 | **1.6.3.2.2 ELECTRICAL UTILITIES** |  |  |  |  |  |
|  | 3 | **1.6.3.2.3 COOLING WATER** |  |  |  |  |  |
|  | 4 | **1.6.3.2.4** |  |  |  |  |  |
|  | 5 | **1.6.3.2.5 SITE PREP, ROADS, & PARKING** |  |  |  |  |  |
|  | 6 | **1.6.3.2.6** |  |  |  |  |  |
|  | 7 | **1.6.3.2.7** |  |  |  |  |  |
|  | 8 | **1.6.3.2.8** |  |  |  |  |  |
|  | 9 | **1.6.3.2.9** |  |  |  |  |  |
|  | 3 | **1.6.3.3 CONSTRUCTION** |  | 2009-02-02 | 2013-08-30 |  |  |
|  | 1 | **1.6.3.3.1 PHASE 1** |  | 2009-02-02 | 2013-08-30 |  |  |
| 16331000M |  | H-D Complex P- I Begin Constr | 0d | 2009-02-02 | 2009-02-02 | 9-090M FS+79d | 62d |
| 16331005 |  | H-D Complex P- I Award Contract (BONDS) | 1d | 2009-02-02 | 2009-02-02 | 1243050b, 1243050, 1243055, 16331000M, 1243045 | 62d |
| 16331010 |  | H-D Complex P- I Constrctn Contract Progress August 09 | 147d | 2009-02-03 | 2009-08-31 | 3C-03M, 16331005, 9-090M FS+80d | 253d |
| 16331010A |  | H-D Complex P- I Constrctn Contract Progress September 09 | 168d | 2009-02-03 | 2009-09-30 | 9-090M FS+80d | 232d |
| 16331010B |  | H-D Complex P- I Constrctn Contract Progress October 09 | 190d | 2009-02-03 | 2009-10-30 | 9-090M FS+80d | 210d |
| 16331010C |  | H-D Complex P- I Constrctn Contract Progress November 09 | 209d | 2009-02-03 | 2009-11-30 | 9-090M FS+80d | 191d |
| 16331010D |  | H-D Complex P- I Constrctn Contract Progress December 09 | 226d | 2009-02-03 | 2009-12-30 | 9-090M FS+80d | 174d |
| 16331010F |  | H-D Complex P- I Constrctn Contract Progress January 10 | 246d | 2009-02-03 | 2010-01-29 | 9-090M FS+80d | 154d |
| 16331010G |  | H-D Complex P- I Constrctn Contract Progress February 10 | 265d | 2009-02-03 | 2010-02-26 | 9-090M FS+80d | 135d |
| 16331010H |  | H-D Complex P- I Constrctn Contract Progress March 10 | 288d | 2009-02-03 | 2010-03-31 | 9-090M FS+80d | 112d |
| 16331010J |  | H-D Complex P- I Constrctn Contract Progress April 10 | 310d | 2009-02-03 | 2010-04-30 | 9-090M FS+80d | 90d |

| ID | WBS | Task | Duration | Start | Finish | Predecessors | Total float |
| --- | --- | --- | --- | --- | --- | --- | --- |
| 16331010K |  | H-D Complex P- I Constrctn Contract Progress May 10 | 330d | 2009-02-03 | 2010-05-28 | 9-090M FS+80d | 70d |
| 16331010L |  | H-D Complex P- I Constrctn Contract Progress June 10 | 352d | 2009-02-03 | 2010-06-30 | 9-090M FS+80d | 48d |
| 16331010N |  | H-D Complex P- I Constrctn Contract Progress July 10 Original | 352d | 2009-02-03 | 2010-06-30 | 9-090M FS+80d | 19d |
| 16331010N5 |  | H-D Complex P- I Constrctn Contract Progress July 10 Revised Delivery per CR10-061 | 370d | 2009-02-03 | 2010-07-27 | 9-090M FS+80d | 1d |
| 16331010P |  | H-D Complex P- I Constrctn Contract Progress August 10 | 395d | 2009-02-03 | 2010-08-31 | 16331010N FS-370d, 16331010N5 FS-370d | 1d |
| 16331010Q |  | H-D Complex P- I Constrctn Contract Progress September 10 | 416d | 2009-02-03 | 2010-09-30 | 16331010P FS-395d | 1d |
| 16331010R |  | H-D Complex P- I Constrctn Contract Progress October 10 | 437d | 2009-02-03 | 2010-10-29 | 16331010Q FS-416d | 1d |
| 16331010S |  | H-D Complex P- I Constrctn Contract Progress November 10 | 455d | 2009-02-03 | 2010-11-24 | 16331010R FS-437d | 1d |
| 16331011 |  | H-D Complex P- I Constrctn Contract Modifications | 370d | 2009-02-03 | 2010-07-27 | 16331005 | 90d |
| 16331020 |  | H-D Complex P- I Constrctn Mngmnt Labor FY09 | 168d | 2009-02-03 | 2009-09-30 | 16331005 | 1402d |
| 16331020c |  | H-D Complex P- I Constrctn Mngmnt Procurement | 310d | 2009-02-03 | 2010-04-30 | 16331005 | 1402d |
| 16331025 |  | H-D Complex P- I A-E Constrctn Supprt | 310d | 2009-02-03 | 2010-04-30 | 16331005 | 1402d |
| 16331012 |  | H-D Complex P- I ARRA Funds | 241d | 2009-08-06 | 2010-07-27 | 9-090M FS+209d | 1342d |
| 16331020b |  | H-D Complex P- I Constrctn Mngmnt Labor FY10 | 142d | 2009-10-01 | 2010-04-30 | 16331020 | 1402d |
| 16331013 |  | H-D Complex P- I Floor Slab Contract Modification | 22d | 2010-04-01 | 2010-04-30 | 9-100M FS+120d | 90d |
| 16331015 |  | H-D Complex P- I Cmmssng Original | 40d | 2010-05-03 | 2010-06-28 | 16331011 FS-60d, 16331010G, 16331010L FS-42d, 16331010A, 16331010K FS-20d, 16331010N FS-60d, 16331010D, 16331010C, 16331010H, 16331010B, 16331013, 16331010F, 16331010J, 16331010 | 90d |
| 16331030 |  | H-D Complex P- I Beneficial Occupancy Original | 2d | 2010-06-29 | 2010-06-30 | 16331010N FS-22d, 16331010N5 FS-22d, 16331010G, 16331010L FS-2d, 16331010B, 16331010H, 16331010J, 16331010D, 16331010K, 16331015 FS-4d, 16331010A, 16331010F, 16331010, 16331010C | 104d |
| 16331014 |  | H-D Complex P- I Settlement Agreement and Release | 21d | 2010-07-01 | 2010-07-30 | 9-100M FS+184d | 27d |
| 16331017 |  | Reverse Entry Per CR10-061 | 1d | 2010-07-01 | 2010-07-01 | 9-100M FS+184d | 63d |
| 16331016 |  | H-D Complex P- I Cmmssng Revised Date per CR10-061 | 40d | 2010-09-01 | 2010-10-27 | 16331013, 16331010F, 16331011 FS-60d, 16331010D, 16331010K, 16331010A, 16331014, 16331010, 16331010G, 16331010H, 16331010R FS-42d, 16331010B, 16331010J, 16331010L, 16331010C | 5d |
| 16331032 |  | H-D Complex P- I Beneficial Occupancy Revised Date per CR10-061 | 20d | 2010-10-28 | 2010-11-24 | 16331010, 16331010J, 16331010S FS-20d, 16331010K, 16331010L FS-2d, 16331010C, 16331010B, 16331010A, 16331010G, 16331016 FS-4d, 16331010F, 16331010H, 16331010R FS-10d, 16331015 FS-4d, 16331010D | 1d |
| 16331035M |  | H-D Complex P- I Constr Comp | 0d | 2010-11-24 | 2010-11-24 | 3C-06M, 16331030, 16331025, 16331032, 16331020c, 16331020b, 16331012 | 1257d |
| 16331040 |  | Re-Baseline Actuals Adjustment | 1d | 2013-08-30 | 2013-08-30 | 9-130M FS+227d | 20d |
|  | 2 | **1.6.3.3.2 PHASE 2** |  | 2009-08-06 | 2013-08-30 |  |  |
| 16332005 |  | H-D Complex P- II Award Contract | 1d | 2009-08-06 | 2009-08-06 | 9-090M FS+209d | 6d |
| 16332010 |  | H-D Complex P- II Contract Progress June 2010 Progress Payment | 223d | 2009-08-06 | 2010-06-30 | 16332005 FS-1d | 6d |
| 16332010B |  | H-D Complex P- II Contract Progress July 2010 Progress Payment | 244d | 2009-08-06 | 2010-07-30 | 16332010 FS-223d | 6d |
| 16332010C |  | H-D Complex P- II Contract Progress August 2010 Progress Payment | 266d | 2009-08-06 | 2010-08-31 | 16332010B FS-244d | 6d |
| 16332010D |  | H-D Complex P- II Contract Progress September 2010 Progress Payment | 287d | 2009-08-06 | 2010-09-30 | 16332010C FS-266d | 6d |
| 16332010F |  | H-D Complex P- II Contract Progress October 2010 Progress Payment | 308d | 2009-08-06 | 2010-10-29 | 16332010D FS-287d | 6d |
| 16332010G |  | H-D Complex P- II Contract Progress November 2010 Progress Payment | 328d | 2009-08-06 | 2010-11-30 | 16332010F FS-308d | 6d |
| 16332010H |  | H-D Complex P- II Contract Progress December 2010 Progress Payment | 345d | 2009-08-06 | 2010-12-30 | 16332010G FS-328d | 6d |
| 16332010J |  | H-D Complex P- II Contract Progress January 2011 Progress Payment | 365d | 2009-08-06 | 2011-01-31 | 16332010H FS-345d | 6d |
| 16332010K |  | H-D Complex P- II Contract Progress February 2011 Progress Payment | 384d | 2009-08-06 | 2011-02-28 | 16332010J FS-365d | 6d |
| 16332010N |  | H-D Complex P- II Contract Progress March 2011 Progress Payment | 407d | 2009-08-06 | 2011-03-31 | 16332010K FS-384d | 6d |
| 16332010P |  | H-D Complex P- II Contract Progress April 2011 Progress Payment | 428d | 2009-08-06 | 2011-04-29 | 16332010N FS-407d | 6d |
| 16332010Q |  | H-D Complex P- II Contract Progress May 2011 Progress Payment | 449d | 2009-08-06 | 2011-05-31 | 16332010P FS-428d | 6d |
| 16332010R |  | H-D Complex P- II Contract Progress June 2011 Progress Payment | 471d | 2009-08-06 | 2011-06-30 | 16332010Q FS-449d | 6d |
| 16332010S |  | H-D Complex P- II Contract Progress July 2011 Progress Payment | 491d | 2009-08-06 | 2011-07-29 | 16332010R FS-471d | 6d |
| 16332010T |  | H-D Complex P- II Contract Progress August 2011 Progress Payment | 514d | 2009-08-06 | 2011-08-31 | 16332010S FS-491d | 6d |
| 16332010U |  | H-D Complex P- II Contract Progress September 2011 Progress Payment | 535d | 2009-08-06 | 2011-09-30 | 16332010T FS-514d | 6d |
| 16332010V |  | H-D Complex P- II Contract Progress October 2011 Progress Payment | 556d | 2009-08-06 | 2011-10-31 | 16332010U FS-535d | 6d |
| 16332000M |  | H-D Complex P- II Begin Constr | 0d | 2010-01-05 | 2010-01-05 | 9-100M FS+60d | 87d |
| 16332008 |  | H-D Complex P- II Notice to Proceed | 20d | 2010-01-05 | 2010-02-02 | 16332000M | 87d |
| 16332011 |  | H-D Complex & Cryo Plant P- II Contract Modifications | 300d | 2010-02-03 | 2011-04-18 | 16332008 | 97d |
| 16332012 |  | H-D Complex P- II ARRA Funds | 300d | 2010-02-03 | 2011-04-18 | 16332008 | 97d |
| 16332020 |  | H-D Complex P- II Constrctn Mngmnt Labor FY10 | 168d | 2010-02-03 | 2010-09-30 | 16332008 | 1084d |
| 16332020ba |  | H-D Complex P- II Constrctn Mngmnt Procurement | 380d | 2010-02-03 | 2011-08-10 | 16332008 | 1084d |
| 16332025 |  | H-D Complex P- II A-E Constrctn Supprt | 380d | 2010-02-03 | 2011-08-10 | 16332008 | 1084d |
| 16332040 |  | H-D Complex Cryo Plant P- II Contract Progress September 2010 Progress Payment | 168d | 2010-02-03 | 2010-09-30 | 16332008 | 87d |
| 16332040A |  | H-D Complex Cryo Plant P- II Contract Progress October 2010 Progress Payment | 189d | 2010-02-03 | 2010-10-29 | 16332040 FS-168d | 87d |
| 16332040B |  | H-D Complex Cryo Plant P- II Contract Progress November 2010 Progress Payment | 209d | 2010-02-03 | 2010-11-30 | 16332040A FS-189d | 87d |
| 16332040C |  | H-D Complex Cryo Plant P- II Contract Progress December 2010 Progress Payment | 226d | 2010-02-03 | 2010-12-30 | 16332040B FS-209d | 87d |
| 16332040D |  | H-D Complex Cryo Plant P- II Contract Progress January 2011 Progress Payment | 246d | 2010-02-03 | 2011-01-31 | 16332040C FS-226d | 87d |
| 16332040F |  | H-D Complex Cryo Plant P- II Contract Progress February 2011 Progress Payment | 265d | 2010-02-03 | 2011-02-28 | 16332040D FS-246d | 87d |
| 16332010A |  | H-D Complex P- II Contract Progress 2010 ETC FY10 | 151d | 2010-03-01 | 2010-09-30 | 9-100M FS+97d | 97d |
| 16332020A |  | H-D Complex P- II Constrctn Mngmnt 2010 ETC Labor FY11 | 151d | 2010-03-01 | 2010-09-30 | 9-100M FS+97d | 1084d |
| 16332020Ab |  | H-D Complex P- II Constrctn Mngmnt 2010 ETC Procurement | 363d | 2010-03-01 | 2011-08-10 | 9-100M FS+97d | 1084d |
| 16332010Ab |  | H-D Complex P- II Contract Progress 2010 ETC FY11 | 132d | 2010-10-01 | 2011-04-18 | 16332010A | 97d |
| 16332020Aa |  | H-D Complex P- II Constrctn Mngmnt 2010 ETC Labor FY11 | 212d | 2010-10-01 | 2011-08-10 | 16332020A | 1084d |
| 16332020b |  | H-D Complex P- II Constrctn Mngmnt Labor FY11 | 212d | 2010-10-01 | 2011-08-10 | 16332020 | 1084d |
| 16332045 |  | H-D Elect Utilities Proc Telecomm Cable & Equip | 100d | 2011-03-16 | 2011-08-04 | 16332010 FS-80d, 16332010U FS-140d | 27d |
| 16332015 |  | H-D Complex P- II Cmmssng | 40d | 2011-08-05 | 2011-09-30 | 16332010Ab, 16332011, 16332040F, 16332010U FS-40d, 16332040, 16332010, 16332012 | 21d |
| 16332050 |  | H-D Elect Utilities Install Telecomm Cable & Equip | 40d | 2011-08-05 | 2011-09-30 | 16332010U FS-40d, 16332010, 16332045 | 27d |
| 16332030 |  | H-D Complex P- II Beneficial Occupancy | 20d | 2011-11-01 | 2011-11-30 | 16332010U, 16332050, 16332010, 16332015, 16332010V | 6d |
| 16332035 |  | H-D Complex P- II Constr Comp | 0d | 2011-11-30 | 2011-11-30 | 16332025, 16332020b, 16332020ba, 16332030, 16332020Ab, 16332020Aa, 16332010W FS-60d, 13455145, 13455135 | 1007d |
| 16332010W |  | H-D Complex P-II Contractor Claim #2 | 19d | 2012-01-04 | 2012-01-31 | 9-120M FS+59d | 1030d |
| 16332055 |  | Re-Baseline Actuals Adjustment | 1d | 2013-08-30 | 2013-08-30 | 9-130M FS+227d | 20d |
|  | 3 | **1.6.3.3.3 PHASE 3** |  | 2009-08-06 | 2013-08-30 |  |  |
| 16333005 |  | H-D Complex P- III Award Contract | 1d | 2009-08-06 | 2009-08-06 | 9-090M FS+209d | 184d |

| ID | WBS | Task | Duration | Start | Finish | Predecessors | Total float |
| --- | --- | --- | --- | --- | --- | --- | --- |
| 16333010 |  | H-D Complex P- III Contract Progress June 2011 | 471d | 2009-08-06 | 2011-06-30 | 16333005 FS-1d | 184d |
| 16333010A |  | H-D Complex P- III Contract Progress July 2011 | 491d | 2009-08-06 | 2011-07-29 | 16333010 FS-471d | 184d |
| 16333010B |  | H-D Complex P- III Contract Progress August 2011 | 514d | 2009-08-06 | 2011-08-31 | 16333010A FS-491d | 184d |
| 16333010C |  | H-D Complex P- III Contract Progress September 2011 | 535d | 2009-08-06 | 2011-09-30 | 16333010B FS-514d | 184d |
| 16333010D |  | H-D Complex P- III Contract Progress October 2011 | 556d | 2009-08-06 | 2011-10-31 | 16333010C FS-535d | 184d |
| 16333000M |  | H-D Complex P- III Begin Constr | 0d | 2011-01-05 | 2011-01-05 | 9-110M FS+60d | 232d |
| 16333008 |  | H-D Complex P- III Notice to Proceed | 1d | 2011-01-05 | 2011-01-05 | 16333000M | 232d |
| 16333011 |  | H-D Complex P- III Contract Modifications | 130d | 2011-03-18 | 2011-09-20 | 4A-01M FS-40d, 16333008 | 183d |
| 16333012 |  | H-D Complex P- III ARRA Funds | 130d | 2011-03-18 | 2011-09-20 | 4A-01M FS-40d, 16333008 | 183d |
| 16333020 |  | H-D Complex P- III Constrctn Mngmnt | 130d | 2011-03-18 | 2011-09-20 | 4A-01M FS-40d, 16333008 | 1056d |
| 16333025 |  | H-D Complex P- III A-E Constrctn Supprt | 130d | 2011-03-18 | 2011-09-20 | 16333008, 4A-01M FS-40d | 1056d |
| 16333015 |  | H-D Complex P- III Cmmssng | 20d | 2011-09-21 | 2011-10-18 | 16333012, 16333011, 16333010D FS-30d | 183d |
| 16333030 |  | H-D Complex P- III Beneficial Occupancy | 10d | 2011-10-19 | 2011-11-01 | 16333015, 16333011, 16333010D FS-556d | 183d |
| 16333035 |  | H-D Complex P- III Constr Comp | 0d | 2011-11-01 | 2011-11-01 | 16333020, 16333030, 16333010F FS-60d, 16333025 | 1026d |
| 16333010F |  | H-D Complex P-III Contractor Claim #2 | 5d | 2011-12-01 | 2011-12-07 | 9-120M FS+41d | 1062d |
| 16333040 |  | Re-Baseline Actuals Adjustment | 1d | 2013-08-30 | 2013-08-30 | 9-130M FS+227d | 20d |
|  | 7 | **1.7 PROJECT MANAGEMENT** |  | 2008-10-01 | 2014-09-30 |  |  |
|  | 1 | **1.7.1 PROJECT OFFICE** |  | 2009-01-02 | 2014-09-30 |  |  |
| 171909LOE |  | FY09 Constrctn Proj Office Proj Mngmnt | 189d | 2009-01-02 | 2009-09-30 | 171909LOEX | 20d |
| 171910LOE |  | FY10 Constrctn Proj Office Proj Mngmnt | 248d | 2009-10-01 | 2010-09-30 | 171909LOE | 20d |
| 171910ALOE |  | FY10 Constrctn Proj Office Proj Mngmnt (Accelerator Work Coordinator) | 151d | 2010-03-01 | 2010-09-30 | 9-100M FS+97d | 20d |
| 171910BLOE |  | FY10 Constrctn Proj Office Proj Mngmnt (CR 10-050) | 128d | 2010-04-01 | 2010-09-30 | 9-100M FS+120d | 20d |
| 171911LOE |  | FY11 Constrctn Proj Office Proj Mngmnt | 248d | 2010-10-01 | 2011-09-30 | 171910BLOE, 171910ALOE, 171910LOE | 20d |
| 171911LOEA |  | FY11 Constrctn Proj Office Proj Mngmnt CR11-007 Reductions | 227d | 2010-11-01 | 2011-09-30 | 171910LOE FS+21d | 20d |
| 171911LOEB |  | FY11 Constrctn Proj Office Proj Mngmnt CR11-007 | 227d | 2010-11-01 | 2011-09-30 | 171910LOE FS+21d | 20d |
| 171912LOE |  | FY12 Constrctn Proj Office Proj Mngmnt Part A | 120d | 2011-10-03 | 2012-03-30 | 171911LOE, 171911LOEB, 171911LOEA | 20d |
| 171912LOEA |  | FY12 Constrctn Proj Office Proj Mngmnt Part B | 127d | 2012-04-02 | 2012-09-28 | 171912LOE | 20d |
| 171913LOE |  | FY13 Constrctn Proj Office Proj Mngmnt Part A | 120d | 2012-10-01 | 2013-03-29 | 171912LOE, 13451912LOE, 171912LOEA | 20d |
| 171913LOEA |  | FY13 Constrctn Proj Office Proj Mngmnt Part B | 108d | 2013-04-01 | 2013-08-30 | 171913LOE | 20d |
| 171950 |  | Re-Baseline Actuals Adjustment | 1d | 2013-08-30 | 2013-08-30 | 9-130M FS+227d | 20d |
| 271913LOEB |  | FY13 Constrctn Proj Office Proj Mngmnt Part B | 20d | 2013-09-03 | 2013-09-30 | 9-130M FS+228d | 311d |
| 271914LOE |  | FY14 Constrctn Proj Office Proj Mngmnt | 247d | 2013-10-01 | 2014-09-30 | 271913LOEB | 311d |
|  | 2 | **1.7.2 OFFICE OF PROJECT MANAGEMENT** |  | 2008-10-01 | 2013-08-30 |  |  |
| 172909LOE |  | FY09 OPM Proj Mngmnt | 248d | 2008-10-01 | 2009-09-30 | 1251908LOEB | 20d |
| 172910LOE |  | FY10 OPM Proj Mngmnt | 248d | 2009-10-01 | 2010-09-30 | 172909LOE | 20d |
| 172911LOE |  | FY11 OPM Proj Mngmnt | 248d | 2010-10-01 | 2011-09-30 | 172910LOE | 20d |
| 172912LOE |  | FY12 OPM Proj Mngmnt | 247d | 2011-10-03 | 2012-09-28 | 1356911LOE, 1354911LOE, 172911LOE, 13614911LOE, 1355911LOE, 13461050LOE, 1351911LOE, 13462015LOE | 20d |
| 172913LOE |  | FY13 OPM Proj Mngmnt | 228d | 2012-10-01 | 2013-08-30 | 1366912LOE, 13421912LOE, 13411912LOE, 1362912LOE, 13463045LOE, 172912LOE | 20d |
|  | 8 | **1.8 CONSTRUCTION PRE-OPS** |  | 2006-10-02 | 2017-08-02 |  |  |
| 28005 |  | Hall A Schedule Contingency Activity | 245d | 2014-03-06 | 2015-03-03 | 2-09M | 643d |
| 28000 |  | Accelerator Schedule Contingency Activity | 125d | 2014-06-26 | 2014-12-23 | 2-25M, 2-03M, 23221023L FS-200d | 0d |
| 28010 |  | Hall D Schedule Contingency Activity | 245d | 2015-04-02 | 2016-03-29 | 3P-25M, 2-13M, 2553010a, 2531033 | 377d |
| 28025 |  | Civil Schedule Contingency Activity | 245d | 2015-10-05 | 2016-09-28 | 2-38M | 249d |
| 28020 |  | Hall C Schedule Contingency Activity | 370d | 2016-02-09 | 2017-07-31 | 243161020, 2-33M, 3P-22M | 43d |
| 28015 |  | Hall B Schedule Contingency Activity | 370d | 2016-02-11 | 2017-08-02 | 2-37M, 3P-21M | 41d |
|  | 1 | **1.8.1 CONSTRUCTION ACCELERATOR PRE-OPS** |  | 2006-10-02 | 2016-02-10 |  |  |
|  | 1 | **1.8.1.1 CONSTRUCTION ACCELERATOR PRE-OPS BEAM COMMISIONING** |  | 2006-10-02 | 2016-02-10 |  |  |
| 1811001 |  | Accel ARR Process | 60d | 2006-10-02 | 2007-01-03 |  | 1674d |
| 1811019 |  | H-A ARR Process | 20d | 2012-11-15 | 2012-12-14 | 14132020, 14151010a, 14153020, 14152025 | 1185d |
| 1811070 |  | Re-Baseline Actuals Adjustment | 1d | 2013-08-30 | 2013-08-30 | 9-130M FS+227d | 20d |
| 2811001 |  | Accel ARR Process | 44d | 2013-10-11 | 2013-12-13 | 2812000 FS-52d, 2811000 FS-40d | 0d |
| 2811019 |  | H-A ARR Process | 20d | 2013-10-14 | 2013-11-08 | 3A-43M, 2-08M | 87d |
| 2811000 |  | Accel Hot Check-out | 38d | 2013-10-15 | 2013-12-09 | 4A-10M | 0d |
| 2811005 |  | Accel Commisioning | 25d | 2013-11-14 | 2013-12-20 | 32-05M | 0d |
| 2811020 |  | H-A Beam Cmmssng | 3d | 2014-03-03 | 2014-03-05 | 4A-06M, 23643175M, 4A-11M FS-40d, 23613050, 23427067, 3P-12M, 2367050 | 18d |
| 2811064 |  | H-D ARR Process | 75d | 2014-08-05 | 2014-11-18 | 2-12M FS-40d, 3A-53M | 8d |
| 2811065 |  | H-D Beam Cmmssng | 15d | 2014-11-19 | 2014-12-11 | 3P-16M | 8d |
| 2811034 |  | H-B ARR Process | 40d | 2015-11-19 | 2016-01-27 | 2-36M FS-20d, 3A-44M | 36d |
| 2811049 |  | H-C ARR Process | 40d | 2015-11-24 | 2016-02-01 | 3A-46M, 2-32M FS-20d | 38d |
| 2811035 |  | H-B Beam Cmmssng | 10d | 2016-01-28 | 2016-02-10 | 3P-20M | 36d |
| 2811050 |  | H-C Beam Cmmssng | 5d | 2016-02-02 | 2016-02-08 | 3P-18M, 32-05M | 38d |
|  | 2 | **1.8.1.2 CONSTRUCTION ACCELERATOR PRE-OPS UTILITIES** |  | 2013-10-15 | 2016-02-10 |  |  |
| 2812000 |  | Accel Hot Check-out (Utilities) | 32d | 2013-10-15 | 2013-11-27 | 4A-10M | 18d |
| 2812005 |  | Accel Beam Commissioning (Utilities) | 25d | 2013-11-14 | 2013-12-20 | 32-05M | 0d |
| 2812065 |  | H-A Beam Cmmssng (Utilities) | 3d | 2014-02-28 | 2014-03-04 | 3P-12M | 19d |
| 2812050 |  | H-D Beam Cmmssng (Utilities) | 15d | 2014-11-19 | 2014-12-11 | 3P-16M | 8d |
| 2812020 |  | H-B Beam Cmmssng (Utilities) | 10d | 2016-01-28 | 2016-02-10 | 3P-20M | 36d |
| 2812035 |  | H-C Beam Cmmssng (Utilities) | 5d | 2016-02-02 | 2016-02-08 | 3P-18M | 38d |
|  | 3 | **1.8.1.3 ACCELERATOR PRE-OPS CHECKOUT** |  | 2012-10-01 | 2014-06-25 |  |  |
|  | 1 | **1.8.1.3.1 CRYOMODULES ACCELERATOR PRE-OPS** |  | 2013-01-29 | 2014-02-28 |  |  |

| ID | WBS | Task | Duration | Start | Finish | Predecessors | Total float |
| --- | --- | --- | --- | --- | --- | --- | --- |
|  | 5 | **1.8.1.3.1.5 CRYOMODULES IN-TUNNEL CHECKOUT** |  | 2013-01-29 | 2014-02-28 |  |  |
| 181315000 |  | In-Tunnel Checkout and Commisioning Cryomodule #3 5th | 24d | 2013-01-29 | 2013-03-04 | 132122025M, 131505005 FS+121d, 181321000, 131503000 | 35d |
| 181315005 |  | In-Tunnel Checkout and Commisioning Cryomodule #6 | 24d | 2013-03-05 | 2013-04-05 | 181321005, 181315000, 131506000 | 35d |
| 181315010 |  | In-Tunnel Checkout and Commisioning Cryomodule #7 | 25d | 2013-04-08 | 2013-05-10 | 131507000, 181315005, 181321010 | 35d |
| 181315015 |  | In-Tunnel Checkout and Commisioning Cryomodule #8 | 24d | 2013-05-13 | 2013-06-14 | 181315010, 181321015, 131508000 | 35d |
| 181315020 |  | In-Tunnel Checkout and Commisioning Cryomodule #9 | 24d | 2013-06-17 | 2013-07-19 | 131509000, 181315015, 181321020 | 35d |
| 181315025 |  | In-Tunnel Checkout and Commisioning Cryomodule #10 | 25d | 2013-07-22 | 2013-08-23 | 181315020, 181321025, 131510000 | 35d |
| 181315030 |  | Re-Baseline Actuals Adjustment | 1d | 2013-08-30 | 2013-08-30 | 9-130M FS+227d | 20d |
| 281315015 |  | In-Tunnel Checkout and Commisioning Cryomodule #8 | 14d | 2013-09-03 | 2013-09-20 | 9-130M FS+228d | 36d |
| 281315025 |  | In-Tunnel Checkout and Commisioning Cryomodule #10 FY13 | 20d | 2013-09-03 | 2013-09-30 | 281321025 FS-5d | 21d |
| 281315030 |  | Installation & Test of Individual Heater Control & Piezo Operation FY13 | 20d | 2013-09-03 | 2013-09-30 | 9-130M FS+228d | 207d |
| 281315025a |  | In-Tunnel Checkout and Commisioning Cryomodule #10 FY14 | 9d | 2013-10-01 | 2013-10-11 | 281315025, 281321025 FS-5d | 21d |
| 281315030a |  | Installation & Test of Individual Heater Control & Piezo Operation FY14 | 98d | 2013-10-01 | 2014-02-28 | 9-130M FS+228d, 281315030 | 207d |
|  | 2 | **1.8.1.3.2 POWER PRE-OPS CHECKOUT** |  | 2012-10-30 | 2014-06-25 |  |  |
|  | 1 | **1.8.1.3.2.1 RF PRE-OPS CHECKOUT** |  | 2012-10-30 | 2013-11-06 |  |  |
| 181321000 |  | RF Sys Tests #5 (Install & SYS COMMIS) | 15d | 2012-10-30 | 2012-11-19 | 132121065M, 132112085M FS-36d | 76d |
| 181321005 |  | RF Sys Tests #6 (Install & SYS COMMIS) | 15d | 2013-01-17 | 2013-02-07 | 132112086M, 132121066M | 51d |
| 181321030 |  | RF Cavity Tests Cryomodule #3 (Install & SYS COMMIS) | 18d | 2013-02-06 | 2013-03-04 | 181315000 FS-18d, 181321000 | 157d |
| 181321010 |  | RF Sys Tests #7 (Install & SYS COMMIS) | 15d | 2013-02-07 | 2013-02-28 | 132121067M, 132112087M | 61d |
| 181321015 |  | RF Sys Tests #8 (Install & SYS COMMIS) | 15d | 2013-02-27 | 2013-03-19 | 132121068M, 132112088M | 73d |
| 181321035 |  | RF Cavity Tests Cryomodule #6 (Install & SYS COMMIS) | 18d | 2013-03-13 | 2013-04-05 | 181315005 FS-18d, 181321005 | 133d |
| 181321020 |  | RF Sys Tests #9 (Install & SYS COMMIS) | 15d | 2013-03-18 | 2013-04-05 | 132112089M, 132121069M | 84d |
| 181321025 |  | RF Sys Tests #10 (Install & SYS COMMIS) | 15d | 2013-04-04 | 2013-04-24 | 132121070M, 132112090M | 95d |
| 181321040 |  | RF Cavity Tests Cryomodule #7 (Install & SYS COMMIS) | 18d | 2013-04-17 | 2013-05-10 | 181315010 FS-18d, 181321010 | 108d |
| 181321045 |  | RF Cavity Tests Cryomodule #8 (Install & SYS COMMIS) | 18d | 2013-05-21 | 2013-06-14 | 181315015 FS-18d, 181321015 | 84d |
| 181321050 |  | RF Cavity Tests Cryomodule #9 (Install & SYS COMMIS) | 18d | 2013-06-25 | 2013-07-19 | 181321020, 181315020 FS-18d | 60d |
| 181321055 |  | RF Cavity Tests Cryomodule #10 (Install & SYS COMMIS) | 18d | 2013-07-31 | 2013-08-23 | 181321025, 181315025 FS-18d | 35d |
| 181321060 |  | Re-Baseline Actuals Adjustment | 1d | 2013-08-30 | 2013-08-30 | 9-130M FS+227d | 20d |
| 281321025 |  | RF Sys Tests #10 (Install & SYS COMMIS) | 5d | 2013-09-03 | 2013-09-09 | 9-130M FS+228d | 21d |
| 281321050 |  | RF Cavity Tests Cryomodule #9 (Install & SYS COMMIS) | 10d | 2013-09-03 | 2013-09-16 | 9-130M FS+228d | 65d |
| 281321055 |  | RF Cavity Tests Cryomodule #10 (Install & SYS COMMIS) | 18d | 2013-10-14 | 2013-11-06 | 281315025a, 281315025, 281321025 | 28d |
|  | 2 | **1.8.1.3.2.2 POWER SUPPLY TESTING** |  | 2013-08-30 | 2014-06-25 |  |  |
|  | 1 | **1.8.1.3.2.2.1 POWER SUPPLY TESTING** |  | 2013-08-30 | 2014-06-25 |  |  |
| 1813221000 |  | Re-Baseline Actuals Adjustment | 1d | 2013-08-30 | 2013-08-30 | 9-130M FS+227d | 20d |
| 2813221000 |  | Test Magnet System Box Power Supplies w/Dummy Load FY13 | 16d | 2013-09-09 | 2013-09-30 | 3A-23M, 23221024ba FS-194d | 0d |
| 2813221005 |  | Test Arc 1 and Hall A PS w/ Dummy Load FY13 | 16d | 2013-09-09 | 2013-09-30 | 23221133 FS-55d, 23221133a FS-55d | 62d |
| 2813221000a |  | Test Magnet System Box Power Supplies w/Dummy Load FY14 | 180d | 2013-10-01 | 2014-06-25 | 3A-23M, 2813221000, 23221024ba FS-194d | 0d |
| 2813221005a |  | Test Arc 1 and Hall A PS w/ Dummy Load FY14 | 46d | 2013-10-01 | 2013-12-05 | 2813221005, 23221133 FS-55d, 23221133a FS-55d | 62d |
|  | 4 | **1.8.1.3.2.2.4 POWER SUPPLY INTEGRATED TESTING** |  | 2013-09-19 | 2014-05-30 |  |  |
| 2813224000 |  | Integration Testing- Box PS FY13 | 8d | 2013-09-19 | 2013-09-30 | 23224055 FS-35d, 23224055a FS-35d | 18d |
| 2813224000a |  | Integration Testing- Box PS FY14 | 162d | 2013-10-01 | 2014-05-30 | 23224055 FS-35d, 2813224000, 23224055a FS-35d | 18d |
| 2813224005 |  | Intergation Testing- Trim PS | 80d | 2013-10-01 | 2014-02-04 | 23224085Aa FS-22d, 23224085A FS-23d | 36d |
|  | 3 | **1.8.1.3.3 CRYOGENICS PRE-OPS CHECKOUT** |  | 2012-10-01 | 2013-08-30 |  |  |
|  | 1 | **1.8.1.3.3.1 CHL II PRE-OPS CHECKOUT** |  | 2013-01-02 | 2013-08-30 |  |  |
| 181331000 |  | Cmmssn CHL Helium Plant Revised | 86d | 2013-01-02 | 2013-05-03 | 1331.11000 FS+165d | 146d |
| 181331005 |  | Re-Baseline Actuals Adjustment | 1d | 2013-08-30 | 2013-08-30 | 9-130M FS+227d | 20d |
|  | 2 | **1.8.1.3.3.2 HALL D CRYOGENICS PRE-OPS CHECKOUT** |  | 2012-10-01 | 2013-08-30 |  |  |
| 181332000 |  | Commission Solenoid Distribution Can (Header) | 10d | 2012-10-01 | 2012-10-12 | 13321050, 13321070 | 28d |
| 181332005 |  | Re-Baseline Actuals Adjustment | 1d | 2013-08-30 | 2013-08-30 | 9-130M FS+227d | 20d |
|  | 2 | **1.8.2 HALLS PRE-OPS** |  | 2012-10-01 | 2016-02-10 |  |  |
|  | 1 | **1.8.2.1 HALL A CHECKOUT AND BEAM COMMISSIONING** |  | 2014-02-28 | 2014-03-04 |  |  |
|  | X | **1.8.2.1.X HALL A COMMISSIONING WITH BEAM** |  | 2014-02-28 | 2014-03-04 |  |  |
| 2821X000 |  | H-A PRE-OPS Cmmssn with Beam | 3d | 2014-02-28 | 2014-03-04 | 3P-12M | 19d |
|  | 2 | **1.8.2.2 HALL B CHECKOUT AND BEAM COMMISSIONING** |  | 2012-10-01 | 2016-02-10 |  |  |
|  | X | **1.8.2.2.X HALL B COMMISSIONING WITH BEAM** |  | 2016-01-28 | 2016-02-10 |  |  |
| 2822X000 |  | H-B PRE-OPS Cmmssn with Beam | 10d | 2016-01-28 | 2016-02-10 | 3P-20M | 36d |
|  | 1 | **1.8.2.2.1 NOT USED** |  |  |  |  |  |
|  | 2 | **1.8.2.2.2 NOT USED** |  |  |  |  |  |
|  | 3 | **1.8.2.2.3 HALL B TRIGGER, DAQ AND ONLINE SOFTWARE CHECKOUT** |  | 2012-10-01 | 2015-10-23 |  |  |
| 18223030 |  | CLAS12 DAQ/online software updates FY13 | 228d | 2012-10-01 | 2013-08-30 | 14232010 | 20d |
| 18223015 |  | TI testing of 52 boards | 169d | 2013-01-02 | 2013-08-30 | 14231075 | 20d |
| 18223020 |  | TD testing of 10 boards | 169d | 2013-01-02 | 2013-08-30 | 14231090 | 20d |
| 18223025 |  | DAQ Commissioning | 168d | 2013-01-03 | 2013-08-30 | 9-130M FS+60d | 20d |
| 18223000 |  | CTP testing of 22 boards | 129d | 2013-03-01 | 2013-08-30 | 14231007, 9-120M | 20d |
| 18223005 |  | SSP testing of 15 boards | 98d | 2013-04-15 | 2013-08-30 | 14231025 | 20d |
| 18223010 |  | GTP testing of 2 boards | 49d | 2013-06-24 | 2013-08-30 | 14231045 | 20d |
| 18223035 |  | Re-Baseline Actuals Adjustment | 1d | 2013-08-30 | 2013-08-30 | 9-130M FS+227d | 20d |
| 28223010 |  | GTP testing of 2 boards | 62d | 2014-02-03 | 2014-04-29 | 24231045 | 351d |
| 28223025 |  | DAQ Commissioning | 267d | 2014-09-04 | 2015-10-02 | 9-140M FS+228d | 56d |
| 28223030 |  | CLAS12 DAQ/online software updates | 267d | 2014-09-04 | 2015-10-02 | 9-140M FS+228d | 56d |

| ID | WBS | Task | Duration | Start | Finish | Predecessors | Total float |
| --- | --- | --- | --- | --- | --- | --- | --- |
| 28223000 |  | CTP testing of 22 boards | 64d | 2015-04-29 | 2015-07-30 | 24231007 | 41d |
| 28223040 |  | Trigger system commissioning | 60d | 2015-07-31 | 2015-10-23 | 24242057, 28223000, 28223010 | 41d |
|  | 6 | **1.8.2.2.6 HALL B MAGNET INSTALLATION TESTING** |  | 2015-07-14 | 2015-10-02 |  |  |
| 28226000 |  | Commission Cryogenic System | 10d | 2015-07-14 | 2015-07-27 | 24264780 | 17d |
| 28226005 |  | Cooldown | 20d | 2015-07-28 | 2015-08-24 | 24264780, 28226000, 24264555 | 17d |
| 28226020 |  | Solenoid Cool Down | 18d | 2015-08-18 | 2015-09-11 | 24264825 | 3d |
| 28226010 |  | Torus Operational Tests | 10d | 2015-08-25 | 2015-09-08 | 28226005 | 17d |
| 28226015 |  | Map CLAS12 Torus Field both polarities | 16d | 2015-09-09 | 2015-09-30 | 28226010 | 17d |
| 28226025 |  | Solenoid Acceptance Tests and Mapping | 15d | 2015-09-14 | 2015-10-02 | 28226020 | 3d |
|  | 3 | **1.8.2.3 HALL C CHECKOUT AND BEAM COMMISSIONING** |  | 2014-07-15 | 2016-02-08 |  |  |
|  | 1 | **1.8.2.3.1 HALL C HB AND Q1 TESTING** |  | 2014-07-15 | 2014-09-30 |  |  |
| 28231005 |  | Q1 Cooldown and Acceptance Test | 30d | 2014-07-15 | 2014-08-25 | 2-27M, 24312053M, 24368265, 24368290, 24368185, 24312050c FS-36d | 269d |
| 28231010 |  | Q1 Harmonic Coil Test | 5d | 2014-08-26 | 2014-09-02 | 28231005, 24353015 | 289d |
| 28231000 |  | HB-Acceptance Test | 20d | 2014-09-03 | 2014-09-30 | 2-28M, 24368265, 24368295 | 269d |
|  | 6 | **1.8.2.3.6 HALL C DIPOLE AND Q2Q3 MAGNET TESTING** |  | 2015-07-02 | 2015-12-23 |  |  |
| 28236000 |  | Cool Down Dipole Magnet | 25d | 2015-07-02 | 2015-08-06 | 24368265, 24368185, 24368310, 24368305, 24368315 | 0d |
| 28236010 |  | Q2 Cooldown and Acceptance Test | 30d | 2015-07-23 | 2015-09-02 | 24368325, 24315037ba, 24368185, 24368265, 24368340, 24315037b | 0d |
| 28236005 |  | Dipole Acceptance Test | 18d | 2015-08-07 | 2015-09-01 | 28236000 | 0d |
| 28236015 |  | Q2 HC & FF Test | 5d | 2015-08-27 | 2015-09-02 | 28236010 FS-5d | 42d |
| 28236020 |  | Q3 Cooldown and Acceptance Test | 37d | 2015-09-11 | 2015-11-02 | 24315037b, 24315037ba, 24368265, 24368360, 24368185, 24368370 | 0d |
| 28236025 |  | Q3- HC & FF Test | 5d | 2015-10-27 | 2015-11-02 | 28236020 FS-5d, 243161015 FS-5d | 0d |
| 28236030 |  | Power all Magnets together | 35d | 2015-11-03 | 2015-12-23 | 28231010, 28236010, 24368300, 28231000, 24368390, 28236015, 28236025, 24368335M, 24312051M, 24368280, 24368365 | 0d |
|  | X | **1.8.2.3.X HALL C COMMISSIONG WITH BEAM** |  | 2016-02-02 | 2016-02-08 |  |  |
| 2823X000 |  | H-C PRE-OPS Cmmssn with Beam | 5d | 2016-02-02 | 2016-02-08 | 3P-18M | 38d |
|  | 4 | **1.8.2.4 HALL D CHECKOUT AND BEAM COMMISSIONING** |  | 2012-10-01 | 2014-12-11 |  |  |
|  | X | **1.8.2.4.X HALL D COMMISSIONING WITH BEAM** |  | 2014-11-19 | 2014-12-11 |  |  |
| 2824X000 |  | H-D PRE-OPS Cmmssn with Beam | 15d | 2014-11-19 | 2014-12-11 | 3P-16M | 8d |
|  | 1 | **1.8.2.4.1 HALL D SOLENOID COMMISSIONING** |  | 2012-10-01 | 2014-10-06 |  |  |
| 18241000 |  | Install cryo/magnet elect/pipe interface | 58d | 2012-10-01 | 2012-12-21 | 9-130M, 151173a, 151173aa | 126d |
| 18241005 |  | Prepare for Solenoid Readiness review | 49d | 2012-10-12 | 2012-12-21 | 9-130M FS+9d | 126d |
| 18241010 |  | Controls Test (SOLENOID) | 23d | 2012-10-30 | 2012-12-03 | 151080, 151185 FS+21d | 8d |
| 18241015 |  | Cooldown to 100 K (SOLENOID) | 13d | 2012-11-12 | 2012-11-30 | 3P-24M | 91d |
| 18241020 |  | Cooldown to 4 K (SOLENOID) | 7d | 2012-12-03 | 2012-12-11 | 18241015 | 91d |
| 18241025 |  | Fill with LHE (SOLENOID) | 7d | 2012-12-13 | 2012-12-21 | 18241020 FS+1d | 91d |
| 18241030 |  | Static Test Coils (SOLENOID) | 7d | 2012-12-31 | 2013-01-09 | 18241025 | 91d |
| 18241035 |  | Controls Test Solenoid (SOLENOID) | 12d | 2013-01-10 | 2013-01-28 | 18241030 | 91d |
| 18241040 |  | Pwr Test Solenoid (SOLENOID) | 16d | 2013-01-29 | 2013-02-20 | 18241035 | 91d |
| 18241050 |  | Re-Baseline Actuals Adjustment | 1d | 2013-08-30 | 2013-08-30 | 9-130M FS+227d | 20d |
| 25213030 |  | Consultant Fee (Quench Study WS) | 20d | 2013-09-03 | 2013-09-30 | 9-130M FS+228d | 247d |
| 28241000 |  | Maintanence Support Solenoid FY13 | 20d | 2013-09-03 | 2013-09-30 | 9-130M FS+228d, 251250M FS-20d | 54d |
| 28241000a |  | Maintanence Support Solenoid FY14 | 251d | 2013-10-01 | 2014-10-06 | 28241000, 9-130M FS+228d, 251250M FS-20d | 54d |
|  | 3 | **1.8.2.4.3 HALL D ONLINE CHECKOUT** |  | 2013-01-29 | 2014-09-30 |  |  |
|  | 1 | **1.8.2.4.3.1 HALL D DAQ CHECKOUT** |  | 2013-04-22 | 2013-08-30 |  |  |
| 182431000 |  | Check-out Counting House & Equip (DAQ) | 42d | 2013-04-22 | 2013-06-19 | 1531110 FS-21d | 71d |
| 182431010 |  | Check-out DAQ Electrnc's (DAQ) | 72d | 2013-05-21 | 2013-08-30 | 1531110 | 20d |
| 182431015 |  | Re-Baseline Actuals Adjustment | 1d | 2013-08-30 | 2013-08-30 | 9-130M FS+227d | 20d |
|  | 2 | **1.8.2.4.3.2 HALL D SOFTWARE CHECKOUT** |  | 2013-01-29 | 2014-09-30 |  |  |
| 182432050 |  | Check-out Experiment Control Software HV | 151d | 2013-01-29 | 2013-08-30 | 1532105da | 20d |
| 182432055 |  | Check-out Experiment Control Software LV | 151d | 2013-01-29 | 2013-08-30 | 1532105fa | 20d |
| 182432020 |  | Check-out Event Displays | 138d | 2013-02-15 | 2013-08-30 | 1532095a | 20d |
| 182432060 |  | Check-out Experiment Control Software Motors | 135d | 2013-02-21 | 2013-08-30 | 1532105ga | 20d |
| 182432080 |  | Check-out Experiment Control Software DAQ Interface | 135d | 2013-02-21 | 2013-08-30 | 1532105na | 20d |
| 182432000 |  | Check-out Front-End Software | 128d | 2013-03-04 | 2013-08-30 | 1532070 FS-100d | 20d |
| 182432075 |  | Check-out Experiment Control Software Target | 122d | 2013-03-12 | 2013-08-30 | 1532105k FS-100d | 20d |
| 182432030 |  | Check-out Experiment Control Software Framework | 107d | 2013-04-02 | 2013-08-30 | 1531165, 1531227a, 1531195, 1531225, 1532105s, 1531150 FS-20d, 1531227 | 20d |
| 182432040 |  | Check-out Experiment Control Software Backup/Restore | 105d | 2013-04-04 | 2013-08-30 | 1532105b FS-40d | 20d |
| 182432015 |  | Check-out Archiving Sys | 102d | 2013-04-09 | 2013-08-30 | 1532090a FS-100d, 1532090b FS-100d, 1532090 FS-60d | 20d |
| 182432025 |  | Check-out Storage Mngmnt Software | 102d | 2013-04-09 | 2013-08-30 | 1532100 FS-100d | 20d |
| 182432045 |  | Check-out Experiment Control Software Magnet PS | 102d | 2013-04-09 | 2013-08-30 | 1532105c FS-100d | 20d |
| 182432065 |  | Check-out Experiment Control Software Gas Systems | 102d | 2013-04-09 | 2013-08-30 | 1532105h FS-100d | 20d |
| 182432070 |  | Check-out Experiment Control Software Temperature | 102d | 2013-04-09 | 2013-08-30 | 1532105j FS-100d | 20d |
| 182432085 |  | Level 1 Trigger Expert Software | 101d | 2013-04-10 | 2013-08-30 | 9-130M FS+127d | 20d |
| 182432035 |  | Check-out Experiment Control Software Display Manegement | 97d | 2013-04-16 | 2013-08-30 | 1532105a | 20d |
| 182432010 |  | Check-out Alarm Sys | 33d | 2013-07-17 | 2013-08-30 | 1532085 FS-20d | 20d |
| 182432005 |  | Check-out Monitoring | 22d | 2013-08-01 | 2013-08-30 | 1532080ba FS-200d, 1532080f FS-200d, 1532082 FS-22d, 1532080c FS-100d, 1532080da FS-200d, 1532080a FS-190d, 1532080g FS-22d, 1532080 | 20d |
| 182432090 |  | Re-Baseline Actuals Adjustment | 1d | 2013-08-30 | 2013-08-30 | 9-130M FS+227d | 20d |
| 282432010 |  | Check-out Alarm Sys | 128d | 2013-11-20 | 2014-06-03 | 2532230 FS+11d, 2532230a FS+11d | 83d |
| 282432005 |  | Check-out Monitoring | 106d | 2014-03-07 | 2014-08-05 | 2532080 FS+22d, 2532080a FS+22d | 39d |
| 282432015 |  | Check-out Archiving Sys | 128d | 2014-04-01 | 2014-09-30 | 2532250a, 2532250 | 0d |
| 282432025 |  | Check-out Storage Mngmnt Software | 58d | 2014-07-08 | 2014-09-26 | 2532100 FS+78d | 2d |

| ID | WBS | Task | Duration | Start | Finish | Predecessors | Total float |
| --- | --- | --- | --- | --- | --- | --- | --- |
|  | 4 | **1.8.2.4.4 HALL D TRIGGER AND ELECTRONICS CHECKOUT** |  | 2012-10-01 | 2014-09-30 |  |  |
|  | 3 | **1.8.2.4.4.3 HALL D TRIGGER BOARDS ACCEPTANCE TESTING** |  | 2012-10-01 | 2014-09-30 |  |  |
| 182443005 |  | Acceptance test of TI boards (FE grp) FY13 | 72d | 2012-10-01 | 2013-01-18 | 1543045 | 111d |
| 182443025 |  | Trigger Calibration (Hall D grp) | 228d | 2012-10-01 | 2013-08-30 | 1543130, 9-120M FS+120d, 1543140a, 1543135 | 20d |
| 182443010 |  | Acceptance test of CTP boards (FE grp) | 98d | 2013-01-10 | 2013-05-30 | 1543025 FS-55d | 20d |
| 182443015 |  | Acceptance test of SSP boards (FE grp) | 98d | 2013-01-10 | 2013-05-30 | 1543070 FS-55d | 20d |
| 182443000 |  | Acceptance test of TS board (FE grp) | 106d | 2013-03-01 | 2013-07-30 | 1543020 FS-65d | 128d |
| 182443020 |  | Acceptance test of GTP boards (FE grp) | 57d | 2013-05-09 | 2013-07-30 | 1543085 FS-15d, 1543085a FS-15d | 43d |
| 182443030 |  | Re-Baseline Actuals Adjustment | 1d | 2013-08-30 | 2013-08-30 | 9-130M FS+227d | 20d |
| 282443010 |  | Acceptance test of CTP boards (FE grp) FY13 | 20d | 2013-09-03 | 2013-09-30 | 2543025 FS-20d, 2543030 FS-20d | 214d |
| 282443020 |  | Acceptance test of GTP boards (FE grp) FY13 | 20d | 2013-09-03 | 2013-09-30 | 9-130M FS+228d | 151d |
| 282443025a5 |  | Acceptance test of TS boards (FE_grp) FY13 | 20d | 2013-09-03 | 2013-09-30 | 9-130M FS+228d, 2543155 FS-286d | 232d |
| 282443010a |  | Acceptance test of CTP boards (FE grp) FY14 | 14d | 2013-10-01 | 2013-10-18 | 282443010, 2543025 FS-20d, 2543030 FS-20d | 214d |
| 282443020a |  | Acceptance test of GTP boards (FE grp) FY14 | 37d | 2013-10-01 | 2013-11-20 | 9-130M FS+228d, 282443020 | 151d |
| 282443025a5a |  | Acceptance test of TS boards (FE_grp) FY14 | 15d | 2013-10-01 | 2013-10-21 | 282443025a5, 9-130M FS+228d, 2543155 FS-286d | 232d |
| 282443025a |  | Trigger Calibration (Hall D grp) | 184d | 2014-01-10 | 2014-09-30 | 9-140M FS+63d | 0d |
|  | 6 | **1.8.2.4.4.6 HALL D DETECTOR ELECTRONICS BOARDS CHECKOUT** |  | 2012-10-01 | 2013-11-21 |  |  |
| 182446000 |  | Test Power Distribution FY13 | 10d | 2012-10-01 | 2012-10-12 | 1546380 | 213d |
| 182446005 |  | Test BCAL Readout System | 30d | 2012-10-08 | 2012-11-16 | 182446000 FS-5d, 1546330 | 213d |
| 182446015 |  | Test Pair Spectrometer Transition Board | 30d | 2012-11-05 | 2012-12-18 | 1546430 FS+25d | 170d |
| 182446020 |  | Test Pair Spectrometer Power Distribution | 30d | 2012-11-19 | 2013-01-09 | 1546435 FS+35d | 160d |
| 182446010 |  | Test Pair Spectrometer PS Readout Board | 29d | 2012-12-05 | 2013-01-23 | 9-130M FS+45d, 1546425 | 151d |
| 182446025 |  | Test Pair Spectrometer System | 23d | 2013-01-24 | 2013-02-26 | 1546440 FS-13d, 182446010, 182446020, 182446015 | 151d |
| 182446030 |  | Test Start Counter Readout Board | 24d | 2013-05-13 | 2013-06-14 | 1546525 FS-14d | 74d |
| 182446035 |  | Test Start Counter Transition Board | 24d | 2013-05-20 | 2013-06-21 | 1546530 FS+13d | 69d |
| 182446040 |  | Test Start Counter Power Distribution | 29d | 2013-06-10 | 2013-07-19 | 1546535 FS+5d | 50d |
| 182446045 |  | Re-Baseline Actuals Adjustment | 1d | 2013-08-30 | 2013-08-30 | 9-130M FS+227d | 20d |
| 282446000 |  | Test Power Distribution FY13 | 16d | 2013-09-09 | 2013-09-30 | 9-130M FS+232d | 213d |
| 282446030 |  | Test Start Counter Readout Board FY13 | 16d | 2013-09-09 | 2013-09-30 | 9-130M FS+232d | 199d |
| 282446035 |  | Test Start Counter Transition Board FY13 | 16d | 2013-09-09 | 2013-09-30 | 9-130M FS+232d | 228d |
| 282446040 |  | Test Start Counter Power Distribution FY13 | 16d | 2013-09-09 | 2013-09-30 | 9-130M FS+232d | 213d |
| 282446000a |  | Test Power Distribution FY14 | 34d | 2013-10-01 | 2013-11-15 | 9-130M FS+232d, 282446000 | 213d |
| 282446030a |  | Test Start Counter Readout Board FY14 | 38d | 2013-10-01 | 2013-11-21 | 282446030, 9-130M FS+232d | 199d |
| 282446035a |  | Test Start Counter Transition Board FY14 | 9d | 2013-10-01 | 2013-10-11 | 9-130M FS+232d, 282446035 | 228d |
| 282446040a |  | Test Start Counter Power Distribution FY14 | 24d | 2013-10-01 | 2013-11-01 | 9-130M FS+232d, 282446040 | 213d |
| 282446010 |  | Test Pair Spectrometer PS Readout Board | 34d | 2013-10-07 | 2013-11-21 | 2546425 FS+4d | 199d |
| 282446015a |  | Test Pair Spectrometer Transition Board | 34d | 2013-10-07 | 2013-11-21 | 2546430 FS+4d | 199d |
| 282446020 |  | Test Pair Spectrometer Power Distribution | 34d | 2013-10-07 | 2013-11-21 | 2546435 FS+4d | 199d |
| 282446025 |  | Test Pair Spectrometer System | 34d | 2013-10-07 | 2013-11-21 | 282446015a FS-34d, 282446020 FS-34d, 282446010 FS-34d, 2546430 FS+4d | 199d |
|  | 5 | **1.8.2.4.5 HALL D BEAMLINE** |  | 2013-09-03 | 2014-09-04 |  |  |
|  | 3 | **1.8.2.4.5.3 HALL D BEAMLINE COMPONENT TESTING** |  | 2013-09-03 | 2014-09-04 |  |  |
| 282453010 |  | Test PS High Granularity Counters FY13 | 20d | 2013-09-03 | 2013-09-30 | 2553042 FS-20d | 213d |
| 282453010a |  | Test PS High Granularity Counters FY14 | 24d | 2013-10-01 | 2013-11-01 | 2553042 FS-20d, 282453010 | 213d |
| 282453000 |  | Check Operation of Goniometer (BL Compnts) | 160d | 2014-01-21 | 2014-09-04 | 2553165 FS-42d, 2553145 FS-80d, 2553147 FS-80d, 2553170 FS-120d | 18d |
|  | 6 | **1.8.2.4.6 HALL D INFRASTUCTURE** |  | 2013-12-02 | 2014-09-30 |  |  |
|  | 2 | **1.8.2.4.6.2 HALL D INSTALLATION TESTING** |  | 2013-12-02 | 2014-09-30 |  |  |
| 282462005 |  | Operation Checks FDC (outside Solenoid) (Installtn) | 22d | 2013-12-02 | 2014-01-10 | 2562370c FS-56d, 25211191, 2562370 FS-2d | 0d |
| 282462050 |  | System Check-out Install Hall FCAL | 20d | 2013-12-02 | 2014-01-08 | 2562700, 2562475ca, 2562475c | 185d |
| 282462040 |  | System Check-out Install Hall BCAL | 90d | 2014-01-31 | 2014-06-06 | 2562275c, 2562540, 2546660 | 80d |
| 282462010 |  | Operation Checks FDC (Inside Solenoid) (Installtn) | 168d | 2014-02-04 | 2014-09-30 | 2562393, 2562385 | 0d |
| 282462030 |  | System Check-out Install Hall CDC | 38d | 2014-02-12 | 2014-04-04 | 2562530, 2562750, 2562290c | 124d |
| 282462020 |  | System Check-out Install Hall Pair Spectrometer | 10d | 2014-02-18 | 2014-03-03 | 2562520, 282446025, 2562246, 2562099c FS+3d, 282453010a, 282453010 | 148d |
| 282462035 |  | System Check-out Install Hall FDC | 60d | 2014-02-26 | 2014-05-20 | 2562715, 2562370c, 2562535 | 92d |
| 282462000 |  | Operational Checks CDC (Inside Solenoid) (Installtn) | 94d | 2014-03-28 | 2014-08-08 | 2562280 FS-19d, 2562303 FS-10d, 2562300, 2562301 FS+1d | 17d |
| 282462045 |  | System Check-out Install Hall TOF | 20d | 2014-06-03 | 2014-06-30 | 2562455c, 2562545 | 64d |
| 282462015 |  | System Check-out Install Hall Tagger | 10d | 2014-06-12 | 2014-06-25 | 2562515, 2562095c | 67d |
| 282462025 |  | System Check-out Install Hall Start Counter | 7d | 2014-07-24 | 2014-08-01 | 2562525, 2562490c FS-25d | 41d |
|  | 3 | **1.8.3 PRE-OPS SUPPORT** |  | 2013-08-30 | 2016-06-30 |  |  |
|  | 1 | **1.8.3.1 PRE-OPS SUPPORT - PROJECT OFFICE** |  | 2013-08-30 | 2016-06-30 |  |  |
| 1831950 |  | Re-Baseline Actuals Adjustment | 1d | 2013-08-30 | 2013-08-30 | 9-130M FS+227d | 20d |
| 2831913LOE |  | FY13 Pre-Ops Supprt - Proj Office | 20d | 2013-09-03 | 2013-09-30 | 9-130M FS+228d | 311d |
| 2831914LOE |  | FY14 Pre-Ops Supprt - Proj Office | 247d | 2013-10-01 | 2014-09-30 | 2831913LOE | 311d |
| 2831915LOE |  | FY15 Pre-Ops Supprt - Proj Office | 247d | 2014-10-01 | 2015-10-01 | 271914LOE, 2831914LOE | 311d |
| 2831916LOE |  | FY16 Pre-Ops Supprt - Proj Office | 184d | 2015-10-02 | 2016-06-30 | 2831915LOE | 311d |
|  | 2 | **1.8.3.2 PRE-OPS SUPPORT - OFFICE OF PROJECT MANAGEMENT** |  |  |  |  |  |
|  | 9 | **1.9 VA STATE** |  | 2010-03-01 | 2013-10-31 |  |  |
|  | 5 | **1.9.5 HALL D - VA STATE** |  | 2010-03-01 | 2013-10-31 |  |  |
|  | 1 | **1.9.5.1 NOT USED** |  | 2013-08-30 | 2013-08-30 |  |  |
| 1951000 |  | Re-Baseline Actuals Adjustment | 1d | 2013-08-30 | 2013-08-30 | 9-130M FS+227d | 20d |
|  | 2 | **1.9.5.2 HALL D DETECTORS** |  | 2010-03-01 | 2013-10-31 |  |  |

| ID | WBS | Task | Duration | Start | Finish | Predecessors | Total float |
| --- | --- | --- | --- | --- | --- | --- | --- |
|  | 1 | **1.9.5.2.1 HALL D TRACKING** |  | 2010-04-06 | 2013-10-31 |  |  |
|  | 2 | **1.9.5.2.1.2 HALL D CENTRAL CHAMBERS** |  | 2010-04-06 | 2013-10-31 |  |  |
| 195212010 |  | Procurement epoxy with delivery in phases (P1 Construction Setup & Straw Penetration) | 82d | 2010-04-06 | 2010-07-30 | 9-100M FS+123d | 58d |
| 195212015 |  | Installation mandril and end plates (P1 Construction Setup & Straw Penetration) | 82d | 2010-04-06 | 2010-07-30 | 195212010 FS-82d | 58d |
| 195212020 |  | Aligned and fix end plates (P1 Construction Setup & Straw Penetration) (P2 Straw Insertion) | 82d | 2010-04-06 | 2010-07-30 | 195212015 FS-82d | 58d |
| 195212025 |  | Straw Preparation Axial section I (P2 Straw Insertion) | 104d | 2010-04-06 | 2010-08-31 | 195212020 FS-82d | 58d |
| 195212030 |  | Insert straws Axial section I (P2 Straw Insertion) | 104d | 2010-04-06 | 2010-08-31 | 195212025 FS-104d | 58d |
| 195212035 |  | Straw preparation Stereo section I-L (P2 Straw Insertion) | 104d | 2010-04-06 | 2010-08-31 | 195212030 FS-104d | 58d |
| 195212040 |  | Insert straws Stereo section 1-L (Phase 2 Straw Insertion) | 104d | 2010-04-06 | 2010-08-31 | 195212035 FS-104d | 58d |
| 195212045 |  | Straw preparation Stereo section 1-R (P2 Straw Insertion) | 125d | 2010-04-06 | 2010-09-30 | 195212040 FS-104d | 58d |
| 195212050 |  | Insert straws Stereo section 1-R (P2 Straw Insertion) | 125d | 2010-04-06 | 2010-09-30 | 195212045 FS-125d | 58d |
| 195212055 |  | Straw preparation Axial section 2 (P2 Straw Insertion) | 125d | 2010-04-06 | 2010-09-30 | 195212050 FS-125d | 58d |
| 195212060 |  | Insert straws axial section 2 (P2 Straw Insertion) | 146d | 2010-04-06 | 2010-10-29 | 195212055 FS-125d | 58d |
| 195212065 |  | Straw preparation stereo section 2-R-1 (P2 Straw Insertion) | 166d | 2010-04-06 | 2010-11-30 | 195212060 FS-146d | 58d |
| 195212070 |  | Insert strwas stereo section 2-R-1 (P2 Straw Insertion) | 166d | 2010-04-06 | 2010-11-30 | 195212065 FS-166d | 58d |
| 195212075 |  | Straw preparation stereo section 2-R-2 (P2 Straw Insertion) | 183d | 2010-04-06 | 2010-12-30 | 195212070 FS-166d | 58d |
| 195212080 |  | Insert straws stereo section 2-R-2 (P2 Straw Insertion) | 183d | 2010-04-06 | 2010-12-30 | 195212075 FS-183d | 58d |
| 195212085 |  | Straw preparation stereo section 2-L-1 (P2 Straw Insertion) | 203d | 2010-04-06 | 2011-01-31 | 195212080 FS-183d | 58d |
| 195212090 |  | Insert straws stereo section 2-L-1 (P2 Straw Insertion) | 203d | 2010-04-06 | 2011-01-31 | 195212085 FS-203d | 58d |
| 195212095 |  | Straw preparation stereo section 2-L-2 (P2 Straw Insertion) | 203d | 2010-04-06 | 2011-01-31 | 195212090 FS-203d | 58d |
| 195212100 |  | Insert straws stereo section 2-L-2 (P2 Straw Insertion) | 203d | 2010-04-06 | 2011-01-31 | 195212095 FS-203d | 58d |
| 195212105 |  | Straw preparation Axial Section 3-1 (P2 Straw Insertion) | 222d | 2010-04-06 | 2011-02-28 | 195212100 FS-203d | 58d |
| 195212110 |  | Insert straws axial section 3-1 (P2 Straw Insertion) | 222d | 2010-04-06 | 2011-02-28 | 195212105 FS-222d | 58d |
| 195212115 |  | Straw preparation Axial Section 3-2 (P2 Straw Insertion) | 245d | 2010-04-06 | 2011-03-31 | 195212110 FS-222d | 58d |
| 195212120 |  | Insert Straws Axial Section 3-2 (P2 Straw Insertion) | 245d | 2010-04-06 | 2011-03-31 | 195212115 FS-245d | 58d |
| 195212125 |  | Install Gas lines in CDC volume (P3 Shell Installation) | 266d | 2010-04-06 | 2011-04-29 | 195212120 FS-245d | 58d |
| 195212130 |  | Install sensors in CDC Volume (P3 Shell Installation) | 266d | 2010-04-06 | 2011-04-29 | 195212125 FS-266d | 58d |
| 195212135 |  | Installation outer shell (P3 Shell Installation) | 287d | 2010-04-06 | 2011-05-31 | 195212130 FS-266d | 58d |
| 195212140 |  | String 1st axial section (P3 Chamber stringing) | 287d | 2010-04-06 | 2011-05-31 | 195212135 FS-287d | 58d |
| 195212145 |  | String 1st stereo section (P3 Chamber stringing) | 309d | 2010-04-06 | 2011-06-30 | 195212140 FS-287d | 58d |
| 195212150 |  | String 2nd stereo section (P3 Chamber stringing) | 287d | 2010-04-06 | 2011-05-31 | 195212145 FS-309d | 58d |
| 195212155 |  | String 2nd axial section (P3 Chamber stringing) | 352d | 2010-04-06 | 2011-08-31 | 195212150 FS-287d | 58d |
| 195212160 |  | String 3rd stereo section (inner) (P3 Chamber stringing) | 352d | 2010-04-06 | 2011-08-31 | 195212155 FS-352d | 58d |
| 195212165 |  | String 3rd stereo section (outer) (P3 Chamber stringing) | 373d | 2010-04-06 | 2011-09-30 | 195212160 FS-352d | 58d |
| 195212170 |  | String 4th stereo section (inner) (P3 Chamber stringing) | 394d | 2010-04-06 | 2011-10-31 | 195212165 FS-373d | 58d |
| 195212175 |  | String 4th stereo section (outer) (P3 Chamber stringing) | 414d | 2010-04-06 | 2011-11-30 | 195212170 FS-394d | 58d |
| 195212180 |  | String 3rd axial section (inner) (P3 Chamber stringing) | 431d | 2010-04-06 | 2011-12-30 | 195212175 FS-414d | 58d |
| 195212185 |  | String 3rd axial section (outer) (P3 Chamber stringing) | 451d | 2010-04-06 | 2012-01-31 | 195212180 FS-431d | 58d |
| 195212190 |  | Electronics installation 1st axial section (P4 Chamber instrumentation) | 451d | 2010-04-06 | 2012-01-31 | 195212185 FS-451d | 58d |
| 195212195 |  | Electronics installation 1st stereo section (P4 Chamber instrumentation) | 471d | 2010-04-06 | 2012-02-29 | 195212190 FS-451d | 58d |
| 195212200 |  | Electronics installation 2nd stereo section (P4 Chamber instrumentation) | 471d | 2010-04-06 | 2012-02-29 | 195212195 FS-471d | 58d |
| 195212205 |  | Electronics installation 2nd axial section (P4 Chamber instrumentation) | 493d | 2010-04-06 | 2012-03-30 | 195212200 FS-471d | 58d |
| 195212210 |  | Electronics installation 3rd stereo section (inner) (P4 Chamber instrumentation) | 493d | 2010-04-06 | 2012-03-30 | 195212205 FS-493d | 58d |
| 195212215 |  | Electronics installation 3rd stereo section (outer) (P4 Chamber instrumentation) | 514d | 2010-04-06 | 2012-04-30 | 195212210 FS-493d | 58d |
| 195212220 |  | Electronics installation 4th stereo section (inner) (P4 Chamber instrumentation) | 514d | 2010-04-06 | 2012-04-30 | 195212215 FS-514d | 58d |
| 195212225 |  | Electronics installation 4th stereo section (outer) (P4 Chamber instrumentation) | 536d | 2010-04-06 | 2012-05-31 | 195212220 FS-514d | 58d |
| 195212230 |  | Electronics installation 3rd axial section (inner) (P4 Chamber instrumentation) | 536d | 2010-04-06 | 2012-05-31 | 195212225 FS-536d | 58d |
| 195212235 |  | Electronics installation 3rd axial section (outer) (P4 Chamber instrumentation) | 556d | 2010-04-06 | 2012-06-29 | 195212230 FS-536d | 58d |
| 195212240 |  | Close up gas upstream and downstream gas plenum (P5 Chamber operational tests) | 578d | 2010-04-06 | 2012-07-31 | 195212235 FS-556d | 58d |
| 195212245 |  | Gas leak tests (P5 Chamber operational tests) | 601d | 2010-04-06 | 2012-08-31 | 195212240 FS-578d | 58d |
| 195212250 |  | HV tests (P5 Chamber operational tests) | 643d | 2010-04-06 | 2012-10-31 | 195212245 FS-601d | 58d |
| 195212255 |  | Operations Test (P5 Chamber operational tests) | 719d | 2010-04-06 | 2013-02-28 | 195212250 FS-643d | 58d |
| 195212260 |  | Phase 7 Chamber shipping | 740d | 2010-04-06 | 2013-03-29 | 195212255 FS-719d | 58d |
| 195212265 |  | Re-Baseline Actuals Adjustment | 1d | 2013-08-30 | 2013-08-30 | 9-130M FS+227d | 20d |
| 295212255 |  | Operations Test (P5 Chamber operational tests) | 43d | 2013-09-03 | 2013-10-31 | 9-130M FS+228d | 63d |
| 295212260 |  | Phase 7 Chamber shipping | 43d | 2013-09-03 | 2013-10-31 | 295212255 FS-43d | 63d |
|  | 4 | **1.9.5.2.4 HALL D DETECTOR SUPPORT** |  | 2013-08-30 | 2013-08-30 |  |  |
| 19524000 |  | Re-Baseline Actuals Adjustment | 1d | 2013-08-30 | 2013-08-30 | 9-130M FS+227d | 20d |
|  | 2 | **1.9.5.2.2 HALL D CALORIMETRY** |  | 2010-03-01 | 2013-10-31 |  |  |
|  | 1 | **1.9.5.2.2.1 HALL D BARREL CALORIMETER** |  | 2010-03-02 | 2013-08-30 |  |  |
| 195221015 |  | Bcal Module Construction Manager Phase 2 (LOE) | 209d | 2010-03-02 | 2010-12-31 | 15221195 | 84d |
| 195221030 |  | Module #9 Matrix Fabrication | 44d | 2010-03-02 | 2010-04-30 | 15221050, 9-100M FS+98d | 595d |
| 195221035 |  | Module #9 Machining and Shipping | 93d | 2010-03-02 | 2010-07-12 | 9-100M FS+98d | 541d |
| 195221040 |  | Module #10 Matrix Fabrication | 44d | 2010-03-02 | 2010-04-30 | 9-100M FS+98d | 595d |
| 195221045 |  | Module #10 Machining and Shipping | 93d | 2010-03-02 | 2010-07-12 | 9-100M FS+98d | 541d |
| 195221050 |  | Module #11 Matrix Fabrication | 70d | 2010-03-02 | 2010-06-08 | 9-100M FS+98d | 569d |
| 195221055 |  | Module #11 Machining and Shipping | 93d | 2010-03-02 | 2010-07-12 | 9-100M FS+98d | 541d |
| 195221060 |  | Module #12 Matrix Fabrication | 70d | 2010-03-02 | 2010-06-08 | 9-100M FS+98d | 569d |
| 195221065 |  | Module #12 Machining and Shipping | 93d | 2010-03-02 | 2010-07-12 | 9-100M FS+98d | 541d |
| 195221070 |  | Module #13 Matrix Fabrication | 96d | 2010-03-02 | 2010-07-15 | 9-100M FS+98d | 543d |

| ID | Task | Duration | Start | Finish | Predecessors | Total float |
| --- | --- | --- | --- | --- | --- | --- |
| 195221075 | Module #13 Machining and Shipping | 146d | 2010-03-02 | 2010-09-24 | 9-100M FS+98d | 488d |
| 195221080 | Module #14 Matrix Fabrication | 96d | 2010-03-02 | 2010-07-15 | 9-100M FS+98d | 543d |
| 195221085 | Module #14 Machining and Shipping | 146d | 2010-03-02 | 2010-09-24 | 9-100M FS+98d | 488d |
| 195221090 | Module #15 Matrix Fabrication | 123d | 2010-03-02 | 2010-08-23 | 9-100M FS+98d | 516d |
| 195221095 | Module #15 Machining and Shipping | 146d | 2010-03-02 | 2010-09-24 | 9-100M FS+98d | 488d |
| 195221100 | Module #16 Matrix Fabrication | 123d | 2010-03-02 | 2010-08-23 | 9-100M FS+98d | 516d |
| 195221105 | Module #16 Machining and Shipping | 146d | 2010-03-02 | 2010-09-24 | 9-100M FS+98d | 488d |
| 195221110 | Module #17 Matrix Fabrication | 149d | 2010-03-02 | 2010-09-29 | 9-100M FS+98d | 490d |
| 195221115 | Module #17 Machining and Shipping | 198d | 2010-03-02 | 2010-12-09 | 9-100M FS+98d | 436d |
| 195221120 | Module #18 Matrix Fabrication | 149d | 2010-03-02 | 2010-09-29 | 9-100M FS+98d | 490d |
| 195221125 | Module #18 Machining and Shipping | 198d | 2010-03-02 | 2010-12-09 | 9-100M FS+98d | 436d |
| 195221130 | Module #19 Matrix Fabrication | 176d | 2010-03-02 | 2010-11-05 | 9-100M FS+98d | 463d |
| 195221135 | Module #19 Machining and Shipping | 207d | 2010-03-02 | 2010-12-29 | 9-100M FS+98d | 427d |
| 195221140 | Module #20 Matrix Fabrication | 176d | 2010-03-02 | 2010-11-05 | 9-100M FS+98d | 463d |
| 195221145 | Module #20 Machining and Shipping | 198d | 2010-03-02 | 2010-12-09 | 9-100M FS+98d | 436d |
| 195221150 | Module #21 Matrix Fabrication | 201d | 2010-03-02 | 2010-12-14 | 9-100M FS+98d | 438d |
| 195221155 | Module #21 Machining and Shipping | 244d | 2010-03-02 | 2011-02-23 | 9-100M FS+98d | 390d |
| 195221160 | Module #22 Matrix Fabrication | 201d | 2010-03-02 | 2010-12-14 | 9-100M FS+98d | 438d |
| 195221165 | Module #22 Machining and Shipping | 244d | 2010-03-02 | 2011-02-23 | 9-100M FS+98d | 390d |
| 195221170 | Module #23 Matrix Fabrication | 221d | 2010-03-02 | 2011-01-20 | 9-100M FS+98d | 418d |
| 195221175 | Module #23 Machining and Shipping | 244d | 2010-03-02 | 2011-02-23 | 9-100M FS+98d | 390d |
| 195221180 | Module #24 Matrix Fabrication | 221d | 2010-03-02 | 2011-01-20 | 9-100M FS+98d | 418d |
| 195221185 | Module #24 Machining and Shipping | 244d | 2010-03-02 | 2011-02-23 | 9-100M FS+98d | 390d |
| 195221000 | Proc SciFi Mods P-3 FY11 October Delivery | 21d | 2010-10-01 | 2010-10-29 | 15221018K | 220d |
| 195221001 | Proc SciFi Mods P-3 FY11 November Delivery | 41d | 2010-10-01 | 2010-11-30 | 195221000 FS-21d | 220d |
| 195221020 | Bcal Module Construction Manager Phase 3 (LOE) | 247d | 2011-01-04 | 2011-12-30 | 195221015 | 84d |
| 195221190 | Module #25 Matrix Fabrication | 38d | 2011-01-04 | 2011-02-28 | 9-110M FS+59d | 392d |
| 195221195 | Module #25 Machining and Shipping | 89d | 2011-01-04 | 2011-05-10 | 9-110M FS+59d | 336d |
| 195221200 | Module #26 Matrix Fabrication | 38d | 2011-01-04 | 2011-02-28 | 9-110M FS+59d | 392d |
| 195221205 | Module #26 Machining and Shipping | 89d | 2011-01-04 | 2011-05-10 | 9-110M FS+59d | 336d |
| 195221210 | Module #27 Matrix Fabrication | 65d | 2011-01-04 | 2011-04-06 | 9-110M FS+59d | 365d |
| 195221215 | Module #27 Machining and Shipping | 89d | 2011-01-04 | 2011-05-10 | 9-110M FS+59d | 336d |
| 195221220 | Module #28 Matrix Fabrication | 65d | 2011-01-04 | 2011-04-06 | 9-110M FS+59d | 365d |
| 195221225 | Module #28 Machining and Shipping | 89d | 2011-01-04 | 2011-05-10 | 9-110M FS+59d | 336d |
| 195221230 | Module #29 Matrix Fabrication | 92d | 2011-01-04 | 2011-05-13 | 9-110M FS+59d | 338d |
| 195221235 | Module #29 Machining and Shipping | 141d | 2011-01-04 | 2011-07-25 | 9-110M FS+59d | 284d |
| 195221240 | Module #30 Matrix Fabrication | 92d | 2011-01-04 | 2011-05-13 | 9-110M FS+59d | 338d |
| 195221245 | Module #30 Machining and Shipping | 141d | 2011-01-04 | 2011-07-25 | 9-110M FS+59d | 284d |
| 195221250 | Module #31 Matrix Fabrication | 118d | 2011-01-04 | 2011-06-21 | 9-110M FS+59d | 312d |
| 195221255 | Module #31 Machining and Shipping | 141d | 2011-01-04 | 2011-07-25 | 9-110M FS+59d | 284d |
| 195221260 | Module #32 Matrix Fabrication | 118d | 2011-01-04 | 2011-06-21 | 9-110M FS+59d | 312d |
| 195221265 | Module #32 Machining and Shipping | 141d | 2011-01-04 | 2011-07-25 | 9-110M FS+59d | 284d |
| 195221270 | Module #33 Matrix Fabrication | 144d | 2011-01-04 | 2011-07-28 | 9-110M FS+59d | 286d |
| 195221275 | Module #33 Machining and Shipping | 194d | 2011-01-04 | 2011-10-07 | 9-110M FS+59d | 231d |
| 195221285 | Module #34 Matrix Fabrication | 144d | 2011-01-04 | 2011-07-28 | 9-110M FS+59d | 286d |
| 195221290 | Module #34 Machining and Shipping | 194d | 2011-01-04 | 2011-10-07 | 9-110M FS+59d | 231d |
| 195221295 | Module #35 Matrix Fabrication | 171d | 2011-01-04 | 2011-09-06 | 9-110M FS+59d | 259d |
| 195221300 | Module #35 Machining and Shipping | 194d | 2011-01-04 | 2011-10-07 | 9-110M FS+59d | 231d |
| 195221305 | Module #36 Matrix Fabrication | 171d | 2011-01-04 | 2011-09-06 | 9-110M FS+59d | 259d |
| 195221310 | Module #36 Machining and Shipping | 194d | 2011-01-04 | 2011-10-07 | 9-110M FS+59d | 231d |
| 195221315 | Module #37 Matrix Fabrication | 197d | 2011-01-04 | 2011-10-12 | 9-110M FS+59d | 233d |
| 195221320 | Module #37 Machining and Shipping | 245d | 2011-01-04 | 2011-12-21 | 9-110M FS+59d | 180d |
| 195221325 | Module #38 Matrix Fabrication | 197d | 2011-01-04 | 2011-10-12 | 9-110M FS+59d | 233d |
| 195221330 | Module #38 Machining and Shipping | 245d | 2011-01-04 | 2011-12-21 | 9-110M FS+59d | 180d |
| 195221335 | Module #39 Matrix Fabrication | 224d | 2011-01-04 | 2011-11-18 | 9-110M FS+59d | 206d |
| 195221340 | Module #39 Machining and Shipping | 245d | 2011-01-04 | 2011-12-21 | 9-110M FS+59d | 180d |
| 195221345 | Module #40 Matrix Fabrication | 224d | 2011-01-04 | 2011-11-18 | 9-110M FS+59d | 206d |
| 195221350 | Module #40 Machining and Shipping | 245d | 2011-01-04 | 2011-12-21 | 9-110M FS+59d | 180d |
| 195221355 | Module #41 Matrix Fabrication | 246d | 2011-01-04 | 2011-12-29 | 9-110M FS+59d | 184d |
| 195221360 | Module #41 Machining and Shipping | 292d | 2011-01-04 | 2012-03-07 | 9-110M FS+59d | 133d |
| 195221365 | Module #42 Matrix Fabrication | 246d | 2011-01-04 | 2011-12-29 | 9-110M FS+59d | 184d |
| 195221370 | Module #42 Machining and Shipping | 292d | 2011-01-04 | 2012-03-07 | 9-110M FS+59d | 133d |
| 195221450 | USM Peg Point # 1 Initial Order Placed | 36d | 2011-06-09 | 2011-07-29 | 9-110M FS+168d | 312d |
| 195221455 | USM Peg Point # 2 On-site Review passed | 121d | 2011-06-09 | 2011-11-30 | 195221450 FS-36d | 312d |
| 195221460 | USM Peg Point # 3 Batch #1 Arrival at USM | 138d | 2011-06-09 | 2011-12-30 | 195221455 FS-121d | 312d |
| 195221465 | USM Peg Point # 4 Batch #2 Arrival at USM | 158d | 2011-06-09 | 2012-01-31 | 195221460 FS-138d | 312d |
| 195221470 | USM Peg Point # 5 Qty. 500 MPPCs tested and shipped to JLab | 158d | 2011-06-09 | 2012-01-31 | 195221465 FS-158d | 312d |
| 195221475 | USM Peg Point # 6 Batch #3 Arrival at USM | 178d | 2011-06-09 | 2012-02-29 | 195221470 FS-158d | 312d |
| 195221480 | USM Peg Point # 7 Qty. 500 MPPCs tested and shipped to JLab | 178d | 2011-06-09 | 2012-02-29 | 195221475 FS-178d | 312d |
| 195221485 | USM Peg Point # 8 Batch #4 Arrival at USM | 200d | 2011-06-09 | 2012-03-30 | 195221480 FS-178d | 312d |

| ID | WBS | Task | Duration | Start | Finish | Predecessors | Total float |
| --- | --- | --- | --- | --- | --- | --- | --- |
| 195221490 |  | USM Peg Point # 9 Qty. 500 MPPCs tested and shipped to JLab | 200d | 2011-06-09 | 2012-03-30 | 195221485 FS-200d | 312d |
| 195221495 |  | USM Peg Point # 10 Qty. 500 MPPCs tested and shipped to JLab | 221d | 2011-06-09 | 2012-04-30 | 195221490 FS-200d | 312d |
| 195221500 |  | USM Peg Point # 11 Qty. 500 MPPCs tested and shipped to JLab | 243d | 2011-06-09 | 2012-05-31 | 195221495 FS-221d | 312d |
| 195221505 |  | USM Peg Point # 12 Qty. 300 MPPCs tested and shipped to JLab | 263d | 2011-06-09 | 2012-06-29 | 195221500 FS-243d | 312d |
| 195221025 |  | Bcal Module Construction Manager Phase 4 (LOE) | 99d | 2012-01-03 | 2012-05-22 | 195221020 | 84d |
| 195221375 |  | Module #43 Matrix Fabrication | 21d | 2012-01-04 | 2012-02-02 | 9-120M FS+59d, 15221145, 15221018X | 161d |
| 195221380 |  | Module #43 Machining and Shipping | 44d | 2012-01-04 | 2012-03-07 | 9-120M FS+59d | 133d |
| 195221385 |  | Module #44 Matrix Fabrication | 21d | 2012-01-04 | 2012-02-02 | 9-120M FS+59d | 161d |
| 195221390 |  | Module #44 Machining and Shipping | 44d | 2012-01-04 | 2012-03-07 | 9-120M FS+59d | 133d |
| 195221395 |  | Module #45 Matrix Fabrication | 47d | 2012-01-04 | 2012-03-12 | 9-120M FS+59d | 135d |
| 195221400 |  | Module #45 Machining and Shipping | 98d | 2012-01-04 | 2012-05-22 | 9-120M FS+59d | 79d |
| 195221405 |  | Module #46 Matrix Fabrication | 47d | 2012-01-04 | 2012-03-12 | 9-120M FS+59d | 135d |
| 195221410 |  | Module #46 Machining and Shipping | 98d | 2012-01-04 | 2012-05-22 | 9-120M FS+59d | 79d |
| 195221415 |  | Module #47 Matrix Fabrication | 74d | 2012-01-04 | 2012-04-18 | 9-120M FS+59d | 108d |
| 195221420 |  | Module #47 Machining and Shipping | 98d | 2012-01-04 | 2012-05-22 | 9-120M FS+59d | 79d |
| 195221425 |  | Module #48 Matrix Fabrication | 74d | 2012-01-04 | 2012-04-18 | 9-120M FS+59d | 108d |
| 195221430 |  | Module #48 Machining and Shipping | 98d | 2012-01-04 | 2012-05-22 | 9-120M FS+59d | 79d |
| 195221435M |  | All Barrel Cal Mods Comptd & Shipped | 0d | 2012-05-22 | 2012-05-22 | 195221115, 195221050, 195221430, 195221285, 195221100, 195221230, 195221140, 195221320, 195221415, 195221195, 15221205, 15221220, 195221365, 195221120, 195221330, 195221175, 195221185, 195221235, 195221395, 195221375, 195221130, 15221265, 15221225, 195221025, 195221145, 195221170, 195221055, 195221225, 195221340, 195221190, 195221110, 15221275, 195221310, 195221355, 195221350, 195221210, 195221380, 195221245, 195221075, 195221095, 195221125, 195221390, 15221230, 15221240, 15221200, 195221370, 195221275, 195221425, 195221300, 195221410, 195221250, 195221090, 195221295, 195221400, 15221260, 15221055a, 15221255, 15221250, 15221245, 195221325, 195221035, 195221135, 195221220, 195221080, 195221105, 195221290, 195221150, 195221345, 195221200, 195221420, 195221040, 15221055b, 15221215, 195221385, 195221180, 195221335, 195221215, 195221160, 195221030, 195221085, 195221060, 195221065, 195221260, 195221165, 195221255, 195221305, 195221240, 15221235, 15221270, 15221173, 195221270, 195221360, 195221045, 195221070, 195221155, 195221405, 195221265, 195221205, 195221315, 15221210 | 84d |
| 195221510 |  | Re-Baseline Actuals Adjustment | 1d | 2013-08-30 | 2013-08-30 | 9-130M FS+227d | 20d |
|  | 2 | **1.9.5.2.2.2 HALL D FORWARD CALORIMETER** |  | 2010-03-01 | 2013-10-31 |  |  |
| 195222010 |  | Prepare top level drawing documentation | 43d | 2010-03-01 | 2010-04-28 | 9-100M FS+97d | 148d |
| 195222020 |  | Build Steel Tubes (fab) | 87d | 2010-03-01 | 2010-06-30 | 195222010 FS-43d, 195222015M FS-43d | 148d |
| 195222025 |  | Build Steel Tubes (coat) | 108d | 2010-03-01 | 2010-07-30 | 195222020 FS-87d | 148d |
| 195222030 |  | Build Tube Straps (procure material) | 87d | 2010-03-01 | 2010-06-30 | 195222025 FS-108d | 148d |
| 195222035 |  | Build Tube Straps (shear) | 108d | 2010-03-01 | 2010-07-30 | 195222030 FS-87d | 148d |
| 195222040 |  | Build Jack Plates | 108d | 2010-03-01 | 2010-07-30 | 195222035 FS-108d | 148d |
| 195222045 |  | Build Face Plates | 65d | 2010-03-01 | 2010-05-28 | 195222040 FS-108d | 148d |
| 195222050 |  | Pb Glass Preparation (weld straps) | 172d | 2010-03-01 | 2010-10-29 | 195222045 FS-65d | 148d |
| 195222055 |  | Pb Glass Preparation (clean and wrap glass) | 209d | 2010-03-01 | 2010-12-30 | 195222050 FS-172d | 148d |
| 195222060 |  | Pb Glass Preparation (attach sheild) | 248d | 2010-03-01 | 2011-02-28 | 195222055 FS-209d | 148d |
| 195222065 |  | Pb Glass Preparation (prepare shippment) | 271d | 2010-03-01 | 2011-03-31 | 195222060 FS-248d | 148d |
| 195222070 |  | Replacement pmts Testing | 5d | 2010-03-01 | 2010-03-05 | 195222065 FS-271d | 148d |
| 195222075 |  | PMT Base Rods (procure) | 108d | 2010-03-01 | 2010-07-30 | 195222070 FS-5d | 148d |
| 195222080 |  | PMT Base Housing (procure tubes) | 87d | 2010-03-01 | 2010-06-30 | 195222075 FS-108d | 148d |
| 195222085 |  | PMT Base Housing (machine tubes) | 130d | 2010-03-01 | 2010-08-31 | 195222080 FS-87d | 148d |
| 195222090 |  | PMT Base Housing (fabricate sockets) | 108d | 2010-03-01 | 2010-07-30 | 195222085 FS-130d | 148d |
| 195222095 |  | PMT Base Housing (insert pins) | 130d | 2010-03-01 | 2010-08-31 | 195222090 FS-108d | 148d |
| 195222100 |  | PMT Base Housing (package for assembly) | 130d | 2010-03-01 | 2010-08-31 | 195222095 FS-130d | 148d |
| 195222105 |  | PMT Base Housing (back plate) | 108d | 2010-03-01 | 2010-07-30 | 195222100 FS-130d | 148d |
| 195222110 |  | PMT Base Housing assembly | 23d | 2010-03-01 | 2010-03-31 | 195222105 FS-108d | 148d |
| 195222115 |  | Prepare Base Circuit Fabrication Drawings | 108d | 2010-03-01 | 2010-07-30 | 195222110 FS-23d | 148d |
| 195222125 |  | First Circuit Board Run PCB's (1/6 total) | 151d | 2010-03-01 | 2010-09-30 | 195222115 FS-108d, 195222120M FS-108d | 148d |
| 195222130 |  | First Circuit Board Run Parts (1/6 total) | 130d | 2010-03-01 | 2010-08-31 | 195222125 FS-151d | 148d |
| 195222135 |  | First Circuit Board Run Populate (1/6 total) | 151d | 2010-03-01 | 2010-09-30 | 195222130 FS-130d | 148d |
| 195222140 |  | First Circuit Board Tester (1/6 total) | 130d | 2010-03-01 | 2010-08-31 | 195222135 FS-151d | 148d |
| 195222145 |  | First Circuit Board Run Assembly (1/6 total) | 209d | 2010-03-01 | 2010-12-30 | 195222140 FS-130d | 148d |
| 195222150 |  | First Circuit Board Run Testing (1/6 total) | 271d | 2010-03-01 | 2011-03-31 | 195222145 FS-209d | 148d |
| 195222155 |  | Second Circuit Board Run PCBs (5/6 total) | 457d | 2010-03-01 | 2011-12-30 | 195222150 FS-271d | 148d |
| 195222160 |  | Second Circuit Board Run Parts (5/6 total) | 378d | 2010-03-01 | 2011-08-31 | 195222155 FS-457d | 148d |
| 195222165 |  | Second Circuit Board Run Populate (5/6 total) | 457d | 2010-03-01 | 2011-12-30 | 195222160 FS-378d | 148d |
| 195222170 |  | Second Circuit Board Run Assemble and Test (5/6 total) | 519d | 2010-03-01 | 2012-03-30 | 195222165 FS-457d | 148d |
| 195222175 |  | Prepare Pb Glass Drawings | 65d | 2010-03-01 | 2010-05-28 | 195222170 FS-519d | 148d |
| 195222180M |  | Jlab Reveiw and Approval of Support Drawings | 0d | 2010-03-01 | 2010-03-01 | 195222175 SS | 213d |
| 195222185 |  | Procure Materials for PB Glass Support | 151d | 2010-03-01 | 2010-09-30 | 195222180M FS-65d, 195222175 FS-65d | 148d |
| 195222190 |  | Machine Componants for PB Glass Support | 292d | 2010-03-01 | 2011-04-29 | 195222185 FF, 195222185 FS-151d | 148d |
| 195222195 |  | Assemble Pb Glass Support Structure | 313d | 2010-03-01 | 2011-05-31 | 195222190 FS-292d | 148d |
| 195222200 |  | Light Guide Material Procurement | 108d | 2010-03-01 | 2010-07-30 | 195222195 FS-313d | 148d |
| 195222205 |  | Glue and Wrap Light Guides | 497d | 2010-03-01 | 2012-02-29 | 195222200 FS-108d | 148d |
| 195222210 |  | Slow Control (procure CAN/ethernet devices) | 562d | 2010-03-01 | 2012-05-31 | 195222205 FS-497d | 148d |
| 195222215 |  | Slow Control (procure cables) | 562d | 2010-03-01 | 2012-05-31 | 195222210 FS-562d | 148d |
| 195222220 |  | Slow Control (assemble and test slow control) | 582d | 2010-03-01 | 2012-06-29 | 195222215 FS-562d | 148d |
| 195222225 |  | Final PMT Test (test fixture) | 108d | 2010-03-01 | 2010-07-30 | 195222220 FS-582d | 148d |
| 195222230 |  | Final PMT Test (test PMT and bases) | 540d | 2010-03-01 | 2012-04-30 | 195222225 FS-108d | 148d |
| 195222235 |  | Final PMT Test (package and shipment) | 540d | 2010-03-01 | 2012-04-30 | 195222230 FS-540d | 148d |
| 195222240 |  | Fabricate Optical Cookies (material) | 562d | 2010-03-01 | 2012-05-31 | 195222235 FS-540d | 148d |
| 195222245 |  | Fabricate Optical Cookies (cut cookies) | 582d | 2010-03-01 | 2012-06-29 | 195222240 FS-562d | 148d |
| 195222250 |  | Fabricate Optical Cookies (Package for shipment) | 582d | 2010-03-01 | 2012-06-29 | 195222245 FS-582d | 148d |
| 195222255 |  | Cable Refurbishment (locate and acquire cables) | 209d | 2010-03-01 | 2010-12-30 | 195222250 FS-582d | 148d |
| 195222260 |  | Cable Refurbishment (procure connectors) | 209d | 2010-03-01 | 2010-12-30 | 195222255 FS-209d | 148d |
| 195222265 |  | Cable Refurbishment (install connectors) | 229d | 2010-03-01 | 2011-01-31 | 195222260 FS-209d | 148d |

| ID | WBS | Task | Duration | Start | Finish | Predecessors | Total float |
| --- | --- | --- | --- | --- | --- | --- | --- |
| 195222270 |  | Cable Refurbishment (package for shipment) | 229d | 2010-03-01 | 2011-01-31 | 195222265 FS-229d | 148d |
| 195222275 |  | Procure Magnetic Sheilds | 582d | 2010-03-01 | 2012-06-29 | 195222270 FS-229d | 148d |
| 195222280 |  | Procure Shipping Materials | 130d | 2010-03-01 | 2010-08-31 | 195222275 FS-582d | 148d |
| 195222285 |  | Shipping to Jlab | 582d | 2010-03-01 | 2012-06-29 | 195222280 FS-130d | 148d |
| 195222015M |  | Readiness Review | 0d | 2010-04-29 | 2010-04-29 | 195222010 SS, 195222010 | 148d |
| 195222120M |  | Jlab Reveiw and Approval of Base Circuit Design | 0d | 2010-07-21 | 2010-07-21 | 195222115 FS-8d | 156d |
| 195222290 |  | Re-Baseline Actuals Adjustment | 1d | 2013-08-30 | 2013-08-30 | 9-130M FS+227d | 20d |
| 295222000 |  | Indiana Contract Completion | 43d | 2013-09-03 | 2013-10-31 | 9-130M FS+228d | 224d |
|  | 6 | **1.9.6 12 GeV ACCEL BUILDINGS** |  | 2010-12-01 | 2013-08-30 |  |  |
|  | 1 | **1.9.6.1 12 GeV N&S ACCESS LCW UPGRADES** |  | 2010-12-01 | 2013-08-30 |  |  |
| 1961000 |  | N&S Access LCW Upgrades Constrctn Contract Progress December 2010 | 17d | 2010-12-01 | 2010-12-30 | 9-110M FS+41d | 475d |
| 1961000a |  | N&S Access LCW Upgrades Constrctn Contract Progress January 2011 | 37d | 2010-12-01 | 2011-01-31 | 1961000 FS-17d | 475d |
| 1961000b |  | N&S Access LCW Upgrades Constrctn Contract Progress February 2011 | 56d | 2010-12-01 | 2011-02-28 | 1961000a FS-37d | 475d |
| 1961000c |  | N&S Access LCW Upgrades Constrctn Contract Progress March 2011 | 79d | 2010-12-01 | 2011-03-31 | 1961000b FS-56d | 475d |
| 1961000d |  | N&S Access LCW Upgrades Constrctn Contract Progress April 2011 | 100d | 2010-12-01 | 2011-04-29 | 1961000c FS-79d | 475d |
| 1961000f |  | N&S Access LCW Upgrades Constrctn Contract Progress May 2011 | 121d | 2010-12-01 | 2011-05-31 | 1961000d FS-100d | 475d |
| 1961000g |  | N&S Access LCW Upgrades Constrctn Contract Progress June 2011 | 143d | 2010-12-01 | 2011-06-30 | 1961000f FS-121d | 475d |
| 1961000h |  | N&S Access LCW Upgrades Constrctn Contract Progress July 2011 | 163d | 2010-12-01 | 2011-07-29 | 1961000g FS-143d | 475d |
| 1961000j |  | N&S Access LCW Upgrades Constrctn Contract Progress August 2011 | 186d | 2010-12-01 | 2011-08-31 | 1961000h FS-163d | 475d |
| 1961000k |  | N&S Access LCW Upgrades Constrctn Contract Progress September 2011 | 207d | 2010-12-01 | 2011-09-30 | 1961000j FS-186d | 475d |
| 1961000n |  | N&S Access LCW Upgrades Constrctn Contract Progress October 2011 | 228d | 2010-12-01 | 2011-10-31 | 1961000k FS-207d | 475d |
| 1961005 |  | N&S Access LCW Upgrades Contract Modifications | 228d | 2010-12-01 | 2011-10-31 | 9-110M FS+41d | 475d |
| 1961010 |  | Re-Baseline Actuals Adjustment | 1d | 2013-08-30 | 2013-08-30 | 9-130M FS+227d | 20d |
|  | 7 | **1.9.7 12 Gev Infastructure** |  | 2010-07-01 | 2013-10-31 |  |  |
|  | 1 | **1.9.7.1 12 Gev Misc Infastructure** |  | 2010-07-01 | 2013-10-31 |  |  |
| 197111005 |  | Procure 2000 Sq. Ft. CLASS 10,000 Clean Room | 85d | 2010-07-01 | 2010-10-29 | 9-100M FS+184d | 126.5d |
| 197111010 |  | Procure HVAC Unit | 43d | 2010-07-01 | 2010-08-31 | 9-100M FS+184d | 148.5d |
| 197111001M |  | Space rented for Chamber Work | 0d | 2010-08-02 | 2010-08-02 | 9-100M FS+205d | 126.5d |
| 197111020 |  | Modify Building Electrical Distribution FY10 | 43d | 2010-08-02 | 2010-09-30 | 197111001M | 126.5d |
| 197111015 |  | Install HVAC Unit | 20d | 2010-09-01 | 2010-09-29 | 197111010 | 148.5d |
| 197111020a |  | Modify Building Electrical Distribution FY11 | 21d | 2010-10-01 | 2010-10-29 | 197111020 | 126.5d |
| 197111060 |  | Blue Crab Lease October-2010 | 21d | 2010-10-01 | 2010-10-29 | 9-110M | 6d |
| 197111065 |  | Blue Crab Lease | 717d | 2010-10-01 | 2013-08-22 | 197111060 FS-21d | 6d |
| 197111080 |  | Blue Crab Utilities October-2010 | 21d | 2010-10-01 | 2010-10-29 | 9-110M | 6d |
| 197111085 |  | Blue Crab Utilities | 717d | 2010-10-01 | 2013-08-22 | 197111080 FS-21d | 6d |
| 197111100 |  | Blue Crab Fork Lift-2010 | 21d | 2010-10-01 | 2010-10-29 | 9-110M | 355d |
| 197111105 |  | Blue Crab Fork Lift-FY11/12 | 368d | 2010-10-01 | 2012-03-30 | 197111100 FS-21d | 355d |
| 197111110 |  | Blue Crab Shelving | 21d | 2010-10-01 | 2010-10-29 | 9-110M | 702d |
| 197111115 |  | Blue Crab Janitorial October-2010 | 21d | 2010-10-01 | 2010-10-29 | 9-110M | 64d |
| 197111030M |  | Space Ready | 0d | 2010-11-01 | 2010-11-01 | 197111015, 197111020a, 197111005 | 126.5d |
| 197111045 |  | Blue Crab Phone Lines Upfront Costs | 20d | 2010-11-01 | 2010-11-30 | 9-110M FS+21d | 6d |
| 197111055 |  | Blue Crab Phone Lines FY11 | 248d | 2010-11-01 | 2011-10-31 | 197111045 FS-20d | 6d |
| 197111135 |  | Blue Crab Misc. Supplies FY11 | 207d | 2010-12-01 | 2011-09-30 | 9-110M FS+41d | 6d |
| 197111120 |  | Blue Crab Janitorial FY11 | 189d | 2011-01-04 | 2011-09-30 | 197111115 FS+38d | 64d |
| 197111125 |  | Blue Crab Janitorial FY12 | 247d | 2011-10-03 | 2012-09-28 | 197111120 | 64d |
| 197111140 |  | Blue Crab Misc. Supplies FY12 | 247d | 2011-10-03 | 2012-09-28 | 197111135 | 6d |
| 197111058 |  | Blue Crab Phone Lines FY12 | 226d | 2011-11-01 | 2012-09-28 | 197111055 | 6d |
| 197111059 |  | Blue Crab Phone Lines FY13 | 222d | 2012-10-01 | 2013-08-22 | 197111058 | 6d |
| 197111130 |  | Blue Crab Janitorial FY13 | 164d | 2012-10-01 | 2013-05-31 | 197111125 | 64d |
| 197111145 |  | Blue Crab Misc. Supplies FY13 | 222d | 2012-10-01 | 2013-08-22 | 197111140 | 6d |
| 197111150 |  | Re-Baseline Actuals Adjustment | 1d | 2013-08-30 | 2013-08-30 | 9-130M FS+227d | 20d |
| 2971000 |  | Blue Crab Cleanroom Completion | 43d | 2013-09-03 | 2013-10-31 | 295212255 FS-43d | 224d |
|  | 10 | **1.10 NON DOE SCOPE** |  | 2009-12-01 | 2013-06-21 |  |  |
|  | 2 | **1.10.2 HALL B NSF-FUNDED DETECTORS** |  | 2009-12-01 | 2010-09-30 |  |  |
|  | 2 | **1.10.2.2 HALL B NSF-FUNDED DETECTORS-CALORIMETERS** |  | 2009-12-01 | 2010-09-30 |  |  |
|  | 3 | **1.10.2.2.3 NSF-MRI ACTIVITIES FOR CLAS 12 PRESHOWER CALORIMETER** |  | 2009-12-01 | 2010-09-30 |  |  |
|  | 1 | **1.10.2.2.3.1 WAVELENGTH SHIFTING FIBERS** |  | 2009-12-01 | 2010-09-30 |  |  |
| 1102231000 |  | Placeholder NSF Wavelength Shifting Fiber Procurement | 207d | 2009-12-01 | 2010-09-30 | 9-100M FS+41d | 0d |
|  | 2 | **1.10.2.2.3.2 PMT SYSTEM** |  | 2009-12-01 | 2010-09-30 |  |  |
|  | 1 | **1.10.2.2.3.2.1 PHOTOMULTIPLIER TUBES** |  | 2009-12-01 | 2010-09-30 |  |  |
| 11022321000 |  | Placeholder NSF Photomultiplier Tube Procurement | 207d | 2009-12-01 | 2010-09-30 | 9-100M FS+41d | 0d |
|  | 2 | **1.10.2.2.3.2.2 MU-METAL SHIELDS** |  | 2009-12-01 | 2010-09-30 |  |  |
| 11022322000 |  | Placeholder NSF Mu-Metal Shield Procurement | 207d | 2009-12-01 | 2010-09-30 | 9-100M FS+41d | 0d |
|  | 3 | **1.10.2.2.3.2.3 HIGH VOLTAGE CABLES** |  | 2009-12-01 | 2010-09-30 |  |  |
| 11022323000 |  | Placeholder NSF High Voltage Cable Procurement | 207d | 2009-12-01 | 2010-09-30 | 9-100M FS+41d | 0d |
|  | 4 | **1.10.2.2.3.2.4 SIGNAL SPLITTERS** |  | 2009-12-01 | 2010-09-30 |  |  |
| 11022324000 |  | Placeholder NSF Signal Splitters Procurement | 207d | 2009-12-01 | 2010-09-30 | 9-100M FS+41d | 0d |
|  | 5 | **1.10.2.2.3.2.5 ELECTRONICS CABLES** |  | 2009-12-01 | 2010-09-30 |  |  |
| 11022325000 |  | Placeholder NSF Electronics Cables Procurement | 207d | 2009-12-01 | 2010-09-30 | 9-100M FS+41d | 0d |
|  | 3 | **1.10.3 HALL C NSERC-FUNDED DETECTORS** |  | 2010-10-01 | 2013-06-21 |  |  |

| ID | WBS | Task | Duration | Start | Finish | Predecessors | Total float |
| --- | --- | --- | --- | --- | --- | --- | --- |
|  | 2 | **1.10.3.2 HALL C NSERC-FUNDED DETECTORS- HEAVY GAS CERENKOV** |  | 2010-10-01 | 2013-06-21 |  |  |
|  | 4 | **1.10.3.2.4 HALL C NSERC-FUNDED-HEAVY GAS CERENKOV** |  | 2010-10-01 | 2013-06-21 |  |  |
| 110324000 |  | Fab Heavy Gas Cerenkov | 674d | 2010-10-01 | 2013-06-21 | 9-110M | 69d |

## Version 2 (data date 2013-10-31, saved 2024-04-29, file 12_GeV_October_13_Progress_15_November_13_PMK.xer)

Last finish 2017-09-29 → 2017-12-19 (+81d). Complete tasks 4 → 7363.

Added:

| ID | Task | Duration | Start | Finish | Predecessors | Resources |
| --- | --- | --- | --- | --- | --- | --- |
| 1 | **1.3.1.1.1.3.1 WAVEGUIDES FABRICATION** |  | 2009-01-26 | 2011-09-11 |  |  |
| 13613035M | Viewers Sys Comp | 0d | 2013-08-30 A | 2013-08-30 A | 1363030a, 1362035M, 13613030, 1363035, 13613020, 13613025 |  |
| 14341080 | Proc TS Module for DF2 | 103d | 2013-07-01 A | 2013-08-26 A | 9-130M FS+180d | PROCUREMENT<$50K 60 |
| 15512010 | Catholic University Tagger Hodoscope Fixed Array | 160d | 2013-02-11 A | 2013-08-30 A | 15512005a FS-250d, 9-130M | PROCUREMENT<$50K 60 NO ESCALATION FY14; PROCUREMENT>$50K 69 NO ESCALATION FY14 |

Removed: 1.3.1.1.1.3.1 WAVEGUIDE FABRICATION; 1811001 Accel ARR Process

Changed:

| ID | Task | Start | Finish | Complete | Total float | Predecessors | Other |
| --- | --- | --- | --- | --- | --- | --- | --- |
| 1-5M | CD-2 (Approve Performance Baseline) | 2008-01-02 → 2007-11-09 A (-54d) | 2008-01-02 → 2007-11-09 A (-54d) | 0% → 100% | 0d → none | 121224030, 121223030, 1241176M, 1241056M, 1241016M, 121224022, 123221007ALOE, 1241096M, 3R-3M, 1241136M, 121221055 → 121224022, 1241056M, 121224030, 3R-3M, 1241096M, 121221055, 1241016M, 1241176M, 1241136M, 121223030 |  |
| 1-6M | CD-3 (Approve Start of Constr) | 2008-09-30 → 2008-09-15 A (-15d) | 2008-09-30 → 2008-09-15 A (-15d) | 0% → 100% | 0d → none | 1142030, 3R-05M, 117908LOE, 3R-08M, 122311908LOE, 1212112908LOE, 1211005M5, 1152945LOE, 123221025, 1212111120, 122312070 FS-40d, 1212111908LOE → 1142030, 1212112908LOE, 1152945LOE, 117908LOE, 3R-05M, 3R-08M, 122311908LOE, 1211005M5, 1212111908LOE |  |
| 1-7M | CD-4A ( Approve Accelerator Completion & Start of Operations) |  |  |  |  | 2-S10M, 2-S01M, 2-S02M, 23221023Da, 23641914LOE, 2-S09M, 2-S03M, 2-S11M, 2-S05M, 2-S06M, 13421050M, 23221140LOEa, 23221023Ga, 2-S04M, 281315030, 281315030a, 23642914LOE, 23643914LOE, 28000, 2-S07M, 3C-13M, 23224087, 23224087a, 2-S08M, 3A-59M → 2-S09M, 23224087a, 281315030a, 3A-59M, 2-S01M, 3C-13M, 2-S08M, 23641914LOE, 23221023Ga, 2-S11M, 2-S02M, 2-S05M, 2-S04M, 13421050M, 23221023Da, 2-S03M, 2-S06M, 2-S10M, 28000, 23642914LOE, 23643914LOE, 13422123b, 23221140LOEa, 23224087, 2-S07M, 281315030 |  |
| 1.02A | **1.02A LEVEL 2 ACCELERATOR MILESTONES** | 2010-07-14 → 2011-03-08 (+237d) |  |  |  |  |  |
| 2-01M | Klystron Mass Production Authorization | 2010-07-14 → 2011-03-08 A (+237d) | 2010-07-14 → 2011-03-08 A (+237d) | 0% → 100% | 154d → none | 132111049 → 132111049 FS+15d |  |
| 2-02M | Start Accelerator Installation Shutdown (IPL) | 2012-05-14 → 2012-05-18 A (+4d) | 2012-05-14 → 2012-05-18 A (+4d) | 0% → 100% | 0d → none | 13445005, 13421030a, 1317015, 13411200a, 13411140a, 13416049B, 13456030M FS+130d, 13454040 FS-50d, 13446010b, 13435010, 13454047, 13444015, 13432015, 13411070M, 13416049A, 13416035M, 13444025, 13444020, 13411145, 13414055, 13456022LOEa, 13434005a, 13411196, 13414030M FS-175d, 13414095M FS-99d, 13425030, 13456029, 13451095, 13441010, 13433005, 13421070M, 13456042, 13456047 FS-40d, 13451100a, 13451105a, 13417015 → 13416035M FS-80d, 13417015, 13444020, 13444015, 13433005, 13432015, 13435010, 13451100a, 13456045, 13456042, 13444025, 13421030a, 13411140a, 13451105a, 13454040 FS-60d, 13414095M FS-150d, 13414030M FS-175d, 13416049A, 13411070M, 13456022LOEa, 13414055, 13445005, 13446010b, 13454047, 13434005a, 13451095, 13421070M, 13411200a, 13456035, 1317015, 13416049B FS-50d, 13411196 FS-40d |  |
| 2-26M | Accel Installtn Comptd Except for All Power Supplies | 2013-10-29 → 2013-11-27 (+29d) | 2013-10-29 → 2013-11-27 (+29d) |  | 22d → 19d |  |  |
| 2-03M | Accelerator Commissioned | 2013-12-20 → 2013-12-19 (-1d) | 2013-12-20 → 2013-12-19 (-1d) |  | 0d → 21d |  | constraint finish on or before 2013-12-31 → finish on or before 2014-09-30 |
| 1.02H | **1.02H LEVEL 2 HALLS A, B & C MILESTONES** | 2006-10-02 → 2007-10-01 (+364d) | 2016-02-10 → 2016-06-24 (+135d) |  |  |  |  |
| 2-04M | Design Report on Superconducting Magnets | 2006-10-02 → 2007-10-01 A (+364d) | 2006-10-02 → 2007-10-01 A (+364d) | 0% → 100% | 247d → none |  |  |
| 2-05M | Design Review on Superconducting Magnets | 2008-05-30 → 2008-05-28 A (-2d) | 2008-05-30 → 2008-05-28 A (-2d) | 0% → 100% | 43d → none | 12221060M, 122311045M, 122312080, 122312050M, 12221045M → 122312080, 12221060M, 12221045M, 122311045M | constraint finish on or before 2008-07-31 → finish on or before 2008-05-30 |
| 2-06M | Award First Superconducting Magnet Contract | 2009-03-16 → 2009-07-10 A (+116d) | 2009-03-16 → 2009-07-10 A (+116d) | 0% → 100% | 98d → none |  |  |
| 2-07M | Start Installation for Existing Halls | 2012-05-14 → 2012-09-01 A (+110d) | 2012-05-14 → 2012-09-01 A (+110d) | 0% → 100% | 54d → none | 2-02M, 14368010M → 2-02M FS+40d, 14368010M |  |
| 2-08M | Installation of Experimental Equipment into H-A is Completed | 2013-10-11 → 2013-12-20 (+70d) | 2013-10-11 → 2013-12-20 (+70d) |  | 48d → 39d | 14132020, 3A-43M, 14153020, 24153020, 14151010a, 24152025, 14152025 → 3A-43M, 24152025, 24153020 | constraint finish on or before 2013-12-31 → none |
| 2-09M | Hall-A Beam Commissioning Completed | 2014-03-05 → 2014-03-12 (+7d) | 2014-03-05 → 2014-03-12 (+7d) |  | 18d → 13d |  |  |
| 2-27M | Hall C Q1 Magnet Delivered | 2014-06-30 → 2014-07-15 (+15d) | 2014-06-30 → 2014-07-15 (+15d) |  | 87d → 77d |  |  |
| 2-34M | Hall B Torus Cold Mass Delivered | 2014-09-30 → 2014-07-28 (-64d) | 2014-09-30 → 2014-07-28 (-64d) |  | 0d → 45d | 14271012, 14273005, 14271020, 14271000, 24271740M, 14273000 → 24271740M |  |
| 2-31M | Hall C Q3 Magnet Delivered |  |  |  |  | 24313019a FS-25d, 14313019a → 24313019a FS-25d |  |
| 2-35M | Hall B Solenoid Cryostated Coil Delivered | 2014-11-26 → 2015-08-31 (+278d) | 2014-11-26 → 2015-08-31 (+278d) |  | 17d → -167d | 14271080, 242781005LOE, 24272075k, 24272075n → 24272075k, 24272075n, 242781005LOE |  |
| 2-32M | Installtn of Expermntl Equipmnt into H-C is Comptd |  |  |  |  | 14362812LOE FS-500d, 24363041, 24363046, 24315090, 14314P4TLOE, 14314P4LOE FS-502d, 143118P3LOE FS-502d, 243118P6LOE FS-500d, 143128P5TLOE, 24312915LOE5 FS-500d, 24315015Bba, 24368540, 24368515, 24314P6LOE FS-500d, 24311170, 24311165, 24313P6LOE5 FS-500d, 14368335M, 24368505, 24315015Bb, 14315050LOEg FS-500d, 24315015Ba, 24311071, 243161000, 143248P1LOE5 FS-500d, 14368425, 24368450 FS-5d, 24368590LOE FS-500d, 243128PC13LOE FS-500d, 243128P6LOE5, 24353010a, 24368565, 24368455, 24368052, 24368475, 14315095 FS-2d, 24314110 FS-500d, 243128PC13LOE5 FS-500d, 24313270M FS-50d, 143238P1LOEb FS-500d, 24368110, 24368570, 24368545, 24362000, 24315007 FS-2d, 24314051M, 24311072a, 24312050d, 24353010, 24315050LOEg FS-500d, 143128PC13LOE, 14353010, 28236030, 24311168, 24312055, 143218P2LOE FS-500d, 243238P1LOEb, 14351020 FS-2d → 143218P2LOE FS-500d, 243128PC13LOE5 FS-500d, 24313P6LOE5 FS-500d, 24315015Bb, 24362000, 24363041, 28236030, 143238P1LOEa FS-500d, 14315050LOEg FS-500d, 143118P3LOE FS-502d, 24312050d, 24312915LOE5 FS-500d, 24314051M, 24315090, 243161000, 24368052, 24368110, 24368590LOE FS-500d, 24353010a, 143248P1LOE5 FS-500d, 14314P4LOE FS-502d, 143128P5TLOE, 14353010, 24311071, 24314P6LOE FS-500d, 24368475, 24368505, 14362812LOE FS-500d, 143248P1LOE FS-500d, 14315050LOEf FS-500d, 14315095 FS-2d, 14351020 FS-2d, 24312055, 24315015Ba, 24363046, 24368540, 243118P6LOE FS-500d, 24368515, 24368545, 24311170, 24311165, 24315007 FS-2d, 243238P1LOEb, 24353010, 14368335M, 14314P4TLOE, 24311072a, 24311168, 24313270M FS-50d, 24314110 FS-500d, 24315050LOEg FS-500d, 24368450 FS-5d, 24368565, 24368570, 14368176, 14368425, 143238P1LOEb FS-500d, 14315050LOEd FS-500d, 143128PC13LOE, 243128PC13LOE FS-500d, 243128P6LOE5, 24368455 |  |
| 2-36M | Installtn of Expermntl Equipmnt into H-B is Comptd | 2015-12-18 → 2016-05-12 (+146d) | 2015-12-18 → 2016-05-12 (+146d) |  | 3d → -92d | 28223040, 24212000 FS-250d, 24211095 FS-250d, 24264065M, 24264360, 24264395, 242742020, 24254005, 14247015, 24273012a, 242711.5010a, 14211051o FS-250d, 24264995, 24264003LOE FS-500d, 14235015, 242711.5010, 24272085 FS-500d, 24273007, 242751435, 14254020, 14254008, 24254105, 14241015, 242742020a, 24211090 FS-250d, 14211080 FS-250d, 24264281, 242211620, 24272075r, 24273012, 242742030, 14254010, 24254070, 24254080, 24243010, 14242060M, 14211040C, 24264860M, 14264235, 24264410, 14264002LOE FS-500d, 14264000dLOE FS-500d, 14271028LOEA, 24271725 LOE, 24271735, 24273022, 242781025, 14251005, 24254115, 24264878, 24264470, 242241457, 14234005, 24271730, 242742025, 242751450, 14254025, 24254050, 24254090, 24242060M, 14244025, 24244035, 242711.5010b, 28223030, 28223025, 24212005 FS-250d, 14212005s FS-250d, 14211025a, 24264006LOE FS-500d, 24264230, 14264360, 242241452, 242223570, 24232025, 242711.5025, 24273017, 242781010LOE FS-500d, 24254020, 24254060, 14252010, 24244030, 14247010, 24247060M, 14264345, 24264440, 14264000bLOE FS-500d, 242241462, 242232685M, 24231000, 24235015, 14254007, 24254040, 24254035, 242742030a, 24264888, 24264345, 14264280, 24264390, 14264410, 14264230, 24264500, 242223575, 24233070M, 24272410, 24272405, 24254000, 14244010, 242751435a → 14251005, 14254010, 24212005 FS-250d, 24231000, 24232025, 24233070M, 24264860M, 24264395, 24272410, 24273017, 242781025, 14235015, 242232685M, 24244030, 24254070, 24254050, 24254060, 24264281, 24264065M, 24264230, 24264390, 242742030, 242711.5010, 242751435a, 14271028LOEA, 14234005, 14264000bLOE FS-500d, 14264002LOE FS-500d, 14254007, 24212000 FS-250d, 242223570, 24244035, 24254020, 24254035, 24254115, 24264500, 24264440, 242781010LOE, 242711.5025, 14264280, 14264000dLOE FS-500d, 14244010, 242223575, 24235015, 24242060M, 24247060M, 24254005, 24254090, 24264878, 24264995, 24264003LOE FS-500d, 24264345, 24264470, 24271725 LOE, 24272085 FS-500d, 24272075r, 24273007, 242742025, 242751435, 242751450, 14211080 FS-250d, 14264230, 14264360, 14247015, 14242060M, 14254025, 24264888, 24271735, 24273027, 28223030, 28223025, 242742020a, 14247010, 14254020, 24211095 FS-250d, 242241457, 242241462, 24243010, 24254105, 24264006LOE FS-500d, 24271730, 28223040, 14212005s FS-250d, 14211051o FS-250d, 14264235, 14264410, 14244025, 14241015, 14252010, 24211090 FS-250d, 24254080, 24264360, 24264410, 24272405, 24273012, 24273022, 242742020, 24273012a, 242742030a, 242711.5010b, 14264345, 14254008, 242211620, 242241452, 24254000, 24254040 |  |
| 2-37M | Hall B Beam Commissioning Complete | 2016-02-10 → 2016-06-24 (+135d) | 2016-02-10 → 2016-06-24 (+135d) |  | 36d → -60d |  |  |
| 1.02D1 | **1.02D LEVEL 2 HALL D MILESTONES** | 2010-11-29 → 2010-11-24 (-5d) |  |  |  |  |  |
| 2-10M | Start Hall-D Installation | 2010-11-29 → 2010-11-24 A (-5d) | 2010-11-29 → 2010-11-24 A (-5d) | 0% → 100% | 1d → none |  |  |
| 2-11M | Installation of Hall-D Solenoid Completed | 2013-02-20 → 2013-08-19 A (+180d) | 2013-02-20 → 2013-08-19 A (+180d) | 0% → 100% | 91d → none |  |  |
| 2-12M | Hall-D Equipment Installation Completed |  |  |  |  | 3A-53M, 282462045, 282462010, 1546182, 1543013E, 2543144, 251666, 15221012E, 1562180, 2562180, 2562790 FS-500d, 1562670a, 1562260, 1562335, 2562780, 2562835, 2562355, 2562495, 2562445, 2531375, 2532060, 2532195, 1553075, 2553011, 2553210, 25211217a, 2532170aa, 2562355b, 282443025a5a, 282446000a, 282462050, 2546655, 2541000, 2543185, 25221010, 2562170, 2562181, 1562650, 1562330, 1562670, 2562281, 2562420, 2562630, 2531370, 2531227aa, 2532115, 25211260a, 2546620b, 2553011a, 13326000, 282443025a, 282446000, 282432015, 2546640, 15211210, 25211255LOE5, 25221005, 1562630, 1562405, 2562855, 2562510, 2562460, 2562006LOE, 2531089, 2532000, 2532014E FS-500d, 2553029, 2541015a, 2543144a, 2543160a, 2562181a, 2562181b, 2562355a, 2562445a, 13326015, 2546465, 2546565, 2546610, 2546620, 2541015, 25211250, 25221000, 25221010LOE, 2562235, 1562625, 1562635, 1562595a, 1562600, 1562595, 2562860, 2562335, 2562625, 2562635, 2531227aa5, 2531360, 2531380, 2531400, 2531178 FS-100d, 2532220, 2532240, 2553157, 2546650a, 282443025a5, 25213030, 282462030, 2541154, 2541155, 2543160, 2562175, 2562206, 1562645, 1562270, 2562482, 2562216, 2562785 FS-500d, 2562595a, 2532170a, 2532255, 2532110, 2546610a, 2546620a, 2562335a, 2562335b, 2562482a, 13326010, 282432010, 282432005, 282462015, 282462040, 2546630, 2542085, 2542090, 2543165, 25211217, 2562165, 1562685, 1562400, 2562895, 2562900, 2562685, 2562014E, 2531385, 2531395, 2531088, 2532245, 2532175a, 2532075, 2532090, 2543165a, 2971000, 282462025, 2546615, 2546625, 2546645, 1541013E, 2542037, 25212010, 25212185 FS-103d, 1562260a, 2562637, 2532225, 2532085, 2532180, 2553075, 295222000, 282432025, 282462020, 282462035, 2546650, 2542080, 2543143, 25211255LOE, 25211260, 1562655, 1562665, 2562885, 2562615LOE FS-245d, 2562091M, 2531365 FS-500d, 2532235, 25212185a FS-103d, 2562895a → 1543013E, 1541013E, 1562685, 1562635, 1562650, 1562630, 1562655, 1562665, 15212195, 15211210, 25221005, 2531400, 2532075, 2532085, 2546615, 2546625, 2553210, 2553029, 2562625, 2562165, 2562235, 282462045, 2541015a, 2562895a, 1562260a, 1562595a, 1562645, 1562670, 25211250, 25211217, 2531360, 2532255, 2532014E FS-500d, 2532220, 2541154, 2542090, 2546620, 2546650, 2553011, 2562855, 2562091M, 1546182, 1553075, 1562405, 1562600, 1562270, 2531227aa5, 2531380, 2531370, 2532175a, 2543143, 2546655, 2562637, 2562785 FS-500d, 2562860, 2562615LOE FS-245d, 2562685, 2562006LOE FS-250d, 2562181, 25213030, 282462015, 282462010, 25211217a, 2553011a, 2562335b, 1562180, 1562345, 1562420, 1562330, 251666, 2532110, 2532115, 2532225, 2532235, 2543144, 2546645, 2562630, 2562635, 2562175, 2562790 FS-500d, 282462025, 282462030, 282462035, 2543144a, 2546620b, 2562482a, 13326000, 25221010LOE, 2531385, 2532000, 2532090, 2542085, 2553075, 2562780, 2562335, 282432005, 282462020, 2971000, 1562625, 3A-53M, 25211260, 25212010, 25212185, 25221010, 2531365 FS-500d, 2531395, 2531089, 2532180, 2532195, 2532240, 2541015, 2541155, 2546465, 2546630, 2562835, 2562895, 2562420, 2562445 FS-250d, 2562014E FS-250d, 2562170, 2562206, 282432010, 282462040, 295222000, 2532170aa, 2562181b, 2562445a, 282446000a, 1562260, 1562335, 15221012E, 13326015, 25211255LOE, 25211255LOE5, 25221000, 2531178, 2531227aa, 2532170a, 2541000, 2546565, 2562355, 2562900, 2562495, 2562460, 282432025, 282443025a, 282446000, 282462050, 25211260a, 2543165a, 2546610a, 2546650a, 1562670a, 1562595, 1562400, 13326010, 2531375, 2531088, 2532060, 2532245, 2542080, 2542037, 2543185, 2543160, 2543165, 2546610, 2546640, 2553157, 2562281, 2562482, 2562216, 2562885, 2562510, 2562595a FS-250d, 2562180, 282432015, 282443025a5, 2543160a, 2562355b, 282443025a5a |  |
| 2-13M | Hall-D Beam Commissioning Completed |  |  |  | 8d → 9d | 2824X000, 28241000a, 2812050, 2811065, 28241000 → 2812050, 2824X000, 13613035M, 2811065, 13422117, 28241000, 28241000a |  |
| 1.02C | **1.02C LEVEL 2 CIVIL MILESTONES** | 2008-09-04 → 2008-09-26 (+22d) |  |  |  |  |  |
| 2-14M | Design of Conventional Facilties Completed | 2008-09-04 → 2008-09-26 A (+22d) | 2008-09-04 → 2008-09-26 A (+22d) | 0% → 100% | 18d → none | 3C-02M FS+40d, 1241075M, 1241155M, 1241195M, 1241115M, 3C-01M → 1241155M, 3C-02M, 1241195M, 1241115M, 3C-01M, 1241075M |  |
| 2-15M | Ready for Equipment - CHL Addition (RFE) (does not Include the Elect & Cooling Water Utility Distrbtn) | 2010-03-12 → 2010-05-05 A (+54d) | 2010-03-12 → 2010-05-05 A (+54d) | 0% → 100% | 141d → none | 1621010 FS+60d → 1621010 | was named Ready for Equipment-CHL Addition (RFE) (doesn't Include Elect & Cooling Water Util Distrbtn) |
| 2-16M | Ready for Equipment - H-D (RFE) | 2010-11-24 → 2010-12-28 A (+34d) | 2010-11-24 → 2010-12-28 A (+34d) | 0% → 100% | 1d → none |  |  |
| 2-17M | Accelerator Tunnel Extension Completed (existing tunnel) | 2011-11-01 → 2011-11-02 A (+1d) | 2011-11-01 → 2011-11-02 A (+1d) | 0% → 100% | 183d → none |  |  |
| 2-38M | Conventional Facilt's Comptd |  |  |  | 56d → 248d |  | constraint finish on or before 2015-12-31 → none |
| 1.02PM | **1.02PM LEVEL 2 PROJECT MANAGEMENT MILESTONES-1** |  | 2008-06-30 → 2008-06-26 (-4d) |  |  |  |  |
| 2-19M | EA Completed | 2006-10-02 → 2007-01-31 A (+121d) | 2006-10-02 → 2007-01-31 A (+121d) | 0% → 100% | 1d → none |  |  |
| 2-20M | Completion of Land Transfer | 2006-10-02 → 2007-10-04 A (+367d) | 2006-10-02 → 2007-10-04 A (+367d) | 0% → 100% | 184d → none |  |  |
| 2-21M | PEP Issued | 2006-10-02 → 2007-11-06 A (+400d) | 2006-10-02 → 2007-11-06 A (+400d) | 0% → 100% | 184d → none |  |  |
| 2-22M | OECM EVMS Contractor Certification REVIEW Complete | 2008-01-31 → 2007-12-07 A (-55d) | 2008-01-31 → 2007-12-07 A (-55d) | 0% → 100% | 0d → none |  | was named OECM EVMS Contractor Certification REVIEW CompleteD |
| 2-23M | Accelerator Safety Envelope (ASE) Completed | 2008-06-30 → 2008-06-26 A (-4d) | 2008-06-30 → 2008-06-26 A (-4d) | 0% → 100% | 1d → none |  |  |
| 2-24M | Safety Assessmnt Document (SAD) Completed | 2008-06-30 → 2008-06-26 A (-4d) | 2008-06-30 → 2008-06-26 A (-4d) | 0% → 100% | 1d → none |  |  |
| 1.02S | **1.02S LEVEL 2 STIMULUS MILESTONES** | 2009-01-08 → 2009-05-29 (+141d) | 2010-10-01 → 2010-09-23 (-8d) |  |  |  |  |
| 2-S01M | Award 4 Meter Dipole Magnet Subcontract | 2009-01-13 → 2009-05-29 A (+136d) | 2009-01-13 → 2009-05-29 A (+136d) | 0% → 100% | 117d → none |  |  |
| 2-S03M | Award Quad Magnets Subcontracts | 2009-08-03 → 2009-06-30 A (-34d) | 2009-08-03 → 2009-06-30 A (-34d) | 0% → 100% | -23d → none |  |  |
| 2-S04M | Award Cryomodules Spaceframes Subcontract | 2009-08-04 → 2009-08-31 A (+27d) | 2009-08-04 → 2009-08-31 A (+27d) | 0% → 100% | 19d → none |  |  |
| 2-S02M | Award Central Helium Liquifer 4.5K Coldbox Subcontract | 2009-01-08 → 2009-09-30 A (+265d) | 2009-01-08 → 2009-09-30 A (+265d) | 0% → 100% | 120d → none | 1331.02000 FS-185d → 1331.02015, 1331.02000 FS-185d |  |
| 2-S05M | Award Cryomodules Vacuum Vessels Subcontract | 2009-11-03 → 2009-11-25 A (+22d) | 2009-11-03 → 2009-11-25 A (+22d) | 0% → 100% | 17d → none |  |  |
| 2-S06M | Award End Can Subcontract | 2010-02-03 → 2009-12-23 A (-42d) | 2010-02-03 → 2009-12-23 A (-42d) | 0% → 100% | -25d → none |  |  |
| 2-S10M | Award North & South Access Building Subcontract | 2009-10-01 → 2010-01-13 A (+104d) | 2009-10-01 → 2010-01-13 A (+104d) | 0% → 100% | 162d → none | 16111000M → 16111005 FS-1d, 16111000M |  |
| 2-S07M | Award High-Voltage Cathode Power Supply Subcontract | 2009-10-08 → 2010-01-22 A (+106d) | 2009-10-08 → 2010-01-22 A (+106d) | 0% → 100% | 72d → none |  |  |
| 2-S08M | Award Central Helium Liquifer Compressors Subcontract | 2010-01-12 → 2010-03-08 A (+55d) | 2010-01-12 → 2010-03-08 A (+55d) | 0% → 100% | 31d → none |  |  |
| 2-S09M | Award Box Power Supply Subcontract | 2010-10-01 → 2010-03-19 A (-196d) | 2010-10-01 → 2010-03-19 A (-196d) | 0% → 100% | -129d → none |  |  |
| 2-S11M | Award Final Stimulus Subcontract | 2010-09-30 → 2010-09-23 A (-7d) | 2010-09-30 → 2010-09-23 A (-7d) | 0% → 100% | 0d → none |  |  |
| 1.03A | **1.03A LEVEL 3 ACCELERATOR MILESTONES** |  | 2014-02-07 → 2014-03-07 (+28d) |  |  |  |  |
| 32-01M | Award Initial Major Acc contract | 2009-04-21 A | 2009-04-21 A | 0% → 100% | -37d → none |  | constraint start on or before 2009-02-27 → none |
| 3A-01M | Start Linac Installtn | 2009-10-01 → 2010-01-04 A (+95d) | 2009-10-01 → 2010-01-04 A (+95d) | 0% → 100% | 431d → none | 9-100M → 9-100M FS+60d |  |
| 32-02M | Vendor Preliminary Dsgn Review of 4K Coldbox | 2010-01-29 → 2010-02-10 A (+12d) | 2010-01-29 → 2010-02-10 A (+12d) | 0% → 100% | 0d → none | 1331.02025, 1331.02000 FS-65d → 1331.02025 | was named Vendor Dsgn Review of 4K Coldbox |
| 32-03M | Start Accel Component Assy | 2010-03-18 → 2010-04-01 A (+14d) | 2010-03-18 → 2010-04-01 A (+14d) | 0% → 100% | 73d → none | 9-100M FS+110d → 132113060 |  |
| 3A-02M | Start LLRF Installtn | 2010-10-01 A | 2010-10-01 A | 0% → 100% | 161d → none |  |  |
| 3A-08M | Start MPS Installtn | 2012-03-19 → 2011-06-01 A (-292d) | 2012-03-19 → 2011-06-01 A (-292d) | 0% → 100% | 30d → none | 13641014, 3A-09M, 16332030, 16331032, 16331030 → 3A-09M, 16331032, 16331030, 16332030 FS-250d, 13641014 |  |
| 3A-09M | Start I&C/Sfty Installtn | 2012-01-23 → 2011-06-01 A (-236d) | 2012-01-23 → 2011-06-01 A (-236d) | 0% → 100% | 6d → none | 13643090, 13643085 → 13643085 FS-160d, 13643090 FS-160d |  |
| 3A-13M | Start West Arc Removl | 2012-05-14 → 2011-06-01 A (-348d) | 2012-05-14 → 2011-06-01 A (-348d) | 0% → 100% | 200d → none |  |  |
| 3A-14M | Start East Arc Removl | 2012-05-14 → 2011-06-01 A (-348d) | 2012-05-14 → 2011-06-01 A (-348d) | 0% → 100% | 200d → none | 3A-13M, 2-02M → 2-02M |  |
| 3A-21M | Start Pwr (Mag) Installtn | 2011-06-13 → 2011-06-01 A (-12d) | 2011-06-13 → 2011-06-01 A (-12d) | 0% → 100% | 324d → none |  |  |
| 3A-03M | Start Pwr (rf) Installtn | 2011-01-04 → 2011-06-01 A (+148d) | 2011-01-04 → 2011-06-01 A (+148d) | 0% → 100% | 267d → none |  |  |
| 3A-07M | Start PSS Installtn | 2012-01-23 → 2011-06-01 A (-236d) | 2012-01-23 → 2011-06-01 A (-236d) | 0% → 100% | 6d → none | 16331032, 3A-09M, 16332030, 16331030, 13643040b, 13643040c → 3A-09M FS+20d, 16331032, 16331030 | constraint start on or before 2012-01-31 → none |
| 3A-34M | Start West Arc Installtn | 2011-05-13 → 2011-06-01 A (+19d) | 2011-05-13 → 2011-06-01 A (+19d) | 0% → 100% | 60d → none | 3A-29M → 2-02M, 3A-29M |  |
| 3A-36M | Start East Arc Installtn | 2012-08-14 → 2011-06-01 A (-440d) | 2012-08-14 → 2011-06-01 A (-440d) | 0% → 100% | 193d → none |  |  |
| 3A-29M | West Arc Removl Comptd | 2011-05-13 → 2011-06-01 A (+19d) | 2011-05-13 → 2011-06-01 A (+19d) | 0% → 100% | 60d → none | 4A-01M → none |  |
| 3A-20M | Start Cryomodule Installtn | 2011-08-12 → 2011-08-02 A (-10d) | 2011-08-12 → 2011-08-02 A (-10d) | 0% → 100% | 83d → none | 131401000, 3A-01M, 13643172M → 3A-01M, 131401000 |  |
| 3A-04M | Start 2nd Cryogenics Plant Commssng (IPL) | 2011-10-03 A | 2011-10-03 A | 0% → 100% | 40d → none | 3C-07M, 1331.07000a, 1331.01000, 1331.02001, 1331.09000 FS+60d, 1331.1000a, 1331.1000b, 1331.02000, 1331.12000, 1331.08000, 1331.02070, 1331.01110, 1331.02012, 12131.11010, 16222035M, 1621015b FS+130d, 9-120M, 1621020 FS+130d, 1331.06000, 1331.03000, 1331.07000b, 1331.01005A, 1331.02015 → 1621015b FS+130d, 1331.07000b, 1331.02015 FS-1d, 1331.01110 FS-125d, 1331.02012, 1331.06000, 1621020 FS+130d, 16222035M, 12131.11010, 1331.02070 FS-100d, 1331.09000 FS+60d, 1331.03000, 1331.10000 FS-100d, 9-120M, 1331.02001, 3C-07M, 1331.08000, 1331.1000a FS-100d, 1331.01005A, 1331.12000 FS-100d, 1331.07000a FS-100d, 1331.02000, 1331.1000b FS-100d, 1331.01000 | was named Start 2nd Cryogenics Plant Commssng |

| ID | Task | Start | Finish | Complete | Total float | Predecessors | Other |
| --- | --- | --- | --- | --- | --- | --- | --- |
| 3A-59M | Test Lab Ready for Renovation | 2012-05-01 A | 2012-05-01 A | 0% → 100% | 0d → none | 1312410010 → none |  |
| 3A-19M | Start S/R Removl | 2012-05-14 → 2012-05-21 A (+7d) | 2012-05-14 → 2012-05-21 A (+7d) | 0% → 100% | 307d → none |  |  |
| 3A-22M | Start Trim Supply Installtn | 2012-05-14 → 2012-05-21 A (+7d) | 2012-05-14 → 2012-05-21 A (+7d) | 0% → 100% | 216d → none |  |  |
| 3A-16M | Start H-A BL Removl | 2012-05-14 → 2012-08-13 A (+91d) | 2012-05-14 → 2012-08-13 A (+91d) | 0% → 100% | 313d → none |  |  |
| 3A-17M | Start H-B BL Removl | 2012-05-14 → 2012-08-13 A (+91d) | 2012-05-14 → 2012-08-13 A (+91d) | 0% → 100% | 315d → none |  |  |
| 3A-18M | Start H-C BL Removl | 2012-05-14 → 2012-08-13 A (+91d) | 2012-05-14 → 2012-08-13 A (+91d) | 0% → 100% | 320d → none |  |  |
| 3A-12M | Start H-D BL Installtn | 2012-05-14 → 2012-09-04 A (+113d) | 2012-05-14 → 2012-09-04 A (+113d) | 0% → 100% | 402d → none |  |  |
| 3A-30M | East Arc Removl Comptd | 2012-08-13 → 2012-09-17 A (+35d) | 2012-08-13 → 2012-09-17 A (+35d) | 0% → 100% | 193d → none |  |  |
| 3A-28M | H-A BL Removl Comptd | 2012-10-19 → 2013-05-13 A (+206d) | 2012-10-19 → 2013-05-13 A (+206d) | 0% → 100% | 201d → none |  |  |
| 3A-31M | H-B BL Removl Comptd | 2012-11-02 → 2013-05-15 A (+194d) | 2012-11-02 → 2013-05-15 A (+194d) | 0% → 100% | 290d → none |  |  |
| 3A-32M | H-C BL Removl Comptd | 2012-11-09 → 2013-05-20 A (+192d) | 2012-11-09 → 2013-05-20 A (+192d) | 0% → 100% | 346d → none |  |  |
| 3A-38M | Start H-B BL Installtn | 2012-11-05 → 2013-06-01 A (+208d) | 2012-11-05 → 2013-06-01 A (+208d) | 0% → 100% | 292d → none |  |  |
| 3A-37M | Start H-A BL Installtn | 2012-10-22 → 2013-07-15 A (+266d) | 2012-10-22 → 2013-07-15 A (+266d) | 0% → 100% | 201d → none |  |  |
| 3A-52M | East arc Installtn Comptd | 2013-02-14 → 2013-07-15 A (+151d) | 2013-02-14 → 2013-07-15 A (+151d) | 0% → 100% | 168d → none |  |  |
| 3A-40M | HPA Installtn Comptd | 2013-04-03 → 2013-08-09 A (+128d) | 2013-04-03 → 2013-08-09 A (+128d) | 0% → 100% | 135d → none |  |  |
| 3A-33M | Start H-C BL Installtn | 2012-11-12 → 2013-08-19 A (+280d) | 2012-11-12 → 2013-08-19 A (+280d) | 0% → 100% | 347d → none | 3A-32M, 2-02M → 2-02M, 3A-32M, 3A-18M |  |
| 3A-56M | West arc Installtn Comptd | 2013-03-12 → 2013-08-26 A (+167d) | 2013-03-12 → 2013-08-26 A (+167d) | 0% → 100% | 151d → none |  |  |
| 3A-10M | LLRF Installtn Comptd | 2013-02-15 → 2013-08-30 A (+196d) | 2013-02-15 → 2013-08-30 A (+196d) | 0% → 100% | 167d → none |  |  |
| 3A-23M | Start Box Supply Installtn | 2013-03-12 → 2013-08-30 A (+171d) | 2013-03-12 → 2013-08-30 A (+171d) | 0% → 100% | 126d → none |  |  |
| 3A-41M | Pwr (rf) Installtn Comptd | 2013-04-03 → 2013-08-30 A (+149d) | 2013-04-03 → 2013-08-30 A (+149d) | 0% → 100% | 135d → none |  |  |
| 3A-58M | End of Long Accel Constr Down | 2013-09-13 → 2013-10-01 A (+18d) | 2013-09-13 → 2013-10-01 A (+18d) | 0% → 100% | 0d → none | 13417170, 23417065 FS-15d, 13411150LOE, 23411145 FS-25d, 23427016LOE FS-45d, 13427021a, 13427024a, 132113135, 1352020, 23643355 FS-40d, 13643360, 23613913LOE FS-100d, 13422123, 23223125a FS-100d, 23612913LOE FS-100d, 23463050a FS-20d, 23447010 FS-5d, 13417030, 23417165 FS-15d, 13458045, 23611026b FS-15d, 23427016LOEa FS-45d, 23417150 FS-45d, 13416049, 23463050 FS-20d, 23223125 FS-100d, 13643355, 13436040, 13417035, 13417150, 13427050, 13427030, 2363913LOE FS-100d, 1367050, 13611026b, 13417040a, 13417020, 13427016LOE, 13422123b, 13422060, 13223125, 232111914LOE FS-500d, 2365913LOE FS-100d, 13447010, 23417170 FS-15d, 13427022a, 13427023a, 23223125b FS-100d, 23411145a FS-25d → 13417040a, 13427016LOE, 1367050, 23411145 FS-25d, 23463050 FS-20d, 13417020, 13411150LOE, 13422060, 23417150 FS-45d, 23417165 FS-15d, 23417170 FS-15d, 23447010 FS-5d, 23223125 FS-100d, 13427021a, 1352020, 13611026b, 23417065 FS-15d, 23463050a FS-20d, 13417170, 13417030, 13458045, 13427050, 13427030, 132113135, 23613913LOE FS-100d, 13455145, 13427022a, 13427023a, 23427016LOE FS-45d, 23612913LOE FS-100d, 13447010, 13436040, 13416049, 13417150, 13417035, 13441010, 13427024a, 13223125, 2363913LOE FS-100d, 23643355 FS-60d, 23223125b FS-100d, 23411145a FS-25d, 23427016LOEa FS-45d, 13643355, 13643360, 23611026b FS-15d, 2365913LOE FS-100d, 23223125a FS-100d, 232111914LOE FS-500d |  |
| 32-05M | Start Accel Beam Commssng | 2013-11-14 → 2013-11-13 (-1d) | 2013-11-14 → 2013-11-13 (-1d) |  | 0d → 19d |  |  |
| 3A-44M | H-B BL Installtn Comptd | 2013-11-11 → 2013-11-14 (+3d) | 2013-11-11 → 2013-11-14 (+3d) |  | 126d → 30d |  |  |
| 3A-47M | Cryomodule Installtn Comptd | 2013-10-11 → 2013-11-20 (+40d) | 2013-10-11 → 2013-11-20 (+40d) |  | 21d → 26d | 281315025a, 281315015, 181315025, 281315025 → 181315025, 281315025, 281315015 |  |
| 3A-43M | H-A BL Installtn Comptd | 2013-10-11 → 2013-11-27 (+47d) | 2013-10-11 → 2013-11-27 (+47d) |  | 48d → 21d |  |  |
| 3A-46M | H-C BL Installtn Comptd | 2013-11-15 → 2013-11-27 (+12d) | 2013-11-15 → 2013-11-27 (+12d) |  | 122d → 21d |  |  |
| 3A-54M | S/R Installtn Comptd | 2013-10-29 → 2013-11-27 (+29d) | 2013-10-29 → 2013-11-27 (+29d) |  | 14d → 21d | 13417040a, 23417145, 23417145a → 13417145, 13411145 FS+40d, 23417145a, 13417040a, 23417145 |  |
| 3A-49M | PSS Installtn Comptd |  |  |  |  | 13643165, 23643105a, 23643140a, 13643172M, 23643117, 13643105, 13643070, 23643105, 13643345, 23643165, 23643170M, 23643117a, 13643075, 13643140, 13643170M, 13643120, 23643140, 23643117b → 13643170M, 13643165, 13643075, 23643117, 23643105a, 13643345, 13643120, 13643105, 13643172M, 13643140, 13643070, 23643105, 23643170M, 23643117b, 23643140a, 23643140, 23643165 |  |
| 3A-53M | H-D BL Installtn Comptd | 2014-02-07 → 2014-02-20 (+13d) | 2014-02-07 → 2014-02-20 (+13d) |  | 46d → 37d |  |  |
| 3A-42M | MPS Installtn Comptd | 2013-12-20 → 2014-02-28 (+70d) | 2013-12-20 → 2014-02-28 (+70d) |  | 100d → 58d |  |  |
| 3A-48M | Trim Supply Installtn Comptd | 2014-02-04 → 2014-03-07 (+31d) | 2014-02-04 → 2014-03-07 (+31d) |  | 35d → 13d |  |  |
| 1.03C | **1.03C LEVEL 3 CIVIL MILESTONES** | 2007-11-30 → 2008-04-25 (+147d) |  |  |  |  |  |
| 3C-01M | Civil A-E Dsgns of H-D Complex & CHL Addition are Comptd. | 2007-11-30 → 2008-04-25 A (+147d) | 2007-11-30 → 2008-04-25 A (+147d) | 0% → 100% | 15d → none |  |  |
| 3C-02M | Civil Dsgn Work by Facilt's Management for the Accel projects (does not Include CHL) is Comptd. | 2008-07-09 → 2008-09-26 A (+79d) | 2008-07-09 → 2008-09-26 A (+79d) | 0% → 100% | 16d → none |  |  |
| 3C-04M | Civil Constr Contract Award of the CHL Bldng Addition, Doesn't Include the Elect & Cooling Water Utility distrib. | 2009-01-16 → 2008-12-19 A (-28d) | 2009-01-16 → 2008-12-19 A (-28d) | 0% → 100% | 72d → none |  |  |
| 3C-03M | Civil Constr Contract Award for P- I of the H-D Complex conventional Facilt's. | 2009-02-02 → 2009-01-21 A (-12d) | 2009-02-02 → 2009-01-21 A (-12d) | 0% → 100% | 62d → none |  |  |
| 3C-06M | Civil Sitework & Utility Distrbtn Associated with P- I of the H-D complex Comptd. | 2010-05-28 → 2010-10-22 A (+147d) | 2010-05-28 → 2010-10-22 A (+147d) | 0% → 100% | 1382d → none | 16331010A, 16331010C, 16331010F, 16331010G, 16331010L FS-23d, 16331010H, 16331010J, 16331010K, 16331010, 16331010D, 16331010B → 16331010K FS+25d, 16331010D, 16331010H, 16331010A, 16331010J, 16331010B, 16331010L FS-10d, 16331010, 16331010C, 16331010G, 16331010F |  |
| 3C-11M | Civil Constr Electrical Distrbtn Upgrades at the N&S Access Bldngs & at the N&S Linac bldgs Comptd . | 2011-03-18 → 2010-10-25 A (-144d) | 2011-03-18 → 2010-10-25 A (-144d) | 0% → 100% | 278d → none | 16122025, 16111030M → 16122025 |  |
| 3C-09M | Start Installtn, RFE of H-D Cryo Plant Bldng Comptd. | 2011-02-28 → 2011-09-30 A (+214d) | 2011-02-28 → 2011-09-30 A (+214d) | 0% → 100% | 87d → none |  |  |
| 3C-07M | Civil Constr Elect & Cooling Water Utility Distrbtn to Supprt CHL#2 Comptd. | 2011-05-27 → 2011-10-12 A (+138d) | 2011-05-27 → 2011-10-12 A (+138d) | 0% → 100% | 23d → none | 16222035M, 16222030 → 16222035M FS-10d |  |
| 3C-08M | Civil Constr N&S Access Bldng Additions & BSW Service bldng Addition Comptd. | 2012-02-21 → 2011-12-06 A (-77d) | 2012-02-21 → 2011-12-06 A (-77d) | 0% → 100% | 49d → none |  |  |
| 3C-10M | Start Installtn, RFE of Tagger Area portion of the Underground Accel Tunnel Comptd. | 2011-11-30 → 2012-01-31 A (+62d) | 2011-11-30 → 2012-01-31 A (+62d) | 0% → 100% | 17d → none | 16332030, 16332010U → 16332010, 16332030 FS-250d, 16332010U |  |
| 3C-13M | Blue Crab End of Occupation | 2013-08-30 A | 2013-08-30 A | 0% → 100% | 0d → none |  |  |
| 1.03P | **1.03P LEVEL 3 PHYSICS MILESTONES** | 2009-05-20 → 2009-10-30 (+163d) | 2016-02-10 → 2016-06-24 (+135d) |  |  |  |  |
| 32-12M | H-D Expermntl Equipment Dsgn Comptd | 2009-05-20 → 2009-10-30 A (+163d) | 2009-05-20 → 2009-10-30 A (+163d) | 0% → 100% | 92d → none | 12353045M → 12353045M FS+69d, 123221025, 123212035, 123212015, 123211055, 12323039, 12321017, 9-100M FS+22d |  |
| 3P-23M | Hall D Life Safety Systems Operational | 2011-09-02 → 2011-09-15 A (+13d) | 2011-09-02 → 2011-09-15 A (+13d) | 0% → 100% | 21d → none |  |  |
| 3P-03M | Start Removl of Expermntl Equipmnt from H-B Prior to major Installtns of New Equipmnt | 2012-05-14 → 2012-05-18 A (+4d) | 2012-05-14 → 2012-05-18 A (+4d) | 0% → 100% | -10d → none |  |  |
| 3P-04M | Start Removl of Expermntl Equipmnt from H-C Prior to major Installtns of New Equipmnt | 2012-05-14 → 2012-05-18 A (+4d) | 2012-05-14 → 2012-05-18 A (+4d) | 0% → 100% | 12d → none |  |  |
| 3P-01M | Start Expermntl Equipmnt Installtn into H-A | 2012-05-07 → 2012-06-11 A (+35d) | 2012-05-07 → 2012-06-11 A (+35d) | 0% → 100% | 5d → none | 14151005, 14152015 → 14151005 FS-40d, 14152015 FS-80d | constraint start on or before 2012-05-14 → none |
| 3P-08M | Start Expermntl Equipmnt Installtn into H-B | 2012-05-14 → 2012-12-10 A (+210d) | 2012-05-14 → 2012-12-10 A (+210d) | 0% → 100% | 119d → none |  | constraint start on or before 2012-10-31 → none |
| 3P-24M | Start Hall D Cooldown | 2012-11-12 → 2012-12-17 A (+35d) | 2012-11-12 → 2012-12-17 A (+35d) | 0% → 100% | 8d → none | 13321050, 18241010 FS-14d, 181332000, 13327000 → 181332000 FS-40d, 13327000 FS-20d, 18241010 FS-20d, 13321050 FS-20d, 13643345 FS-30d | constraint start on or before 2012-11-26 → start on or before 2012-12-17 |
| 3P-07M | Start Expermntl Equipmnt Installtn into H-C | 2012-05-14 → 2013-02-01 A (+263d) | 2012-05-14 → 2013-02-01 A (+263d) | 0% → 100% | 233d → none |  | constraint none → start on or before 2012-05-31 |
| 3P-02M | Removl of Expermntl Equipmnt Prior to major Installtns of New Equipmnt in H-B is Comptd. | 2012-05-14 → 2013-02-11 A (+273d) | 2012-05-14 → 2013-02-11 A (+273d) | 0% → 100% | 33d → none | 3P-03M → 3P-03M, 14264002M, 2-02M | constraint finish on or before 2012-06-29 → none |
| 3P-12M | Start E-B Commssng of H-A Detctr's, Electrnc's, & BL Devices | 2014-02-28 → 2014-02-26 (-2d) | 2014-02-28 → 2014-02-26 (-2d) |  | 19d → 21d |  |  |
| 3P-25M | 10 GeV Beam to Hall D Tagger | 2014-03-14 → 2014-03-21 (+7d) | 2014-03-14 → 2014-03-21 (+7d) |  | 21d → 16d |  |  |
| 3P-16M | Start E-B Commssng of H-D Detctr's, Electrnc's, & BL Devices |  |  |  |  | 2-03M FS+100d, 23611065M, 2-25M FS-120d, 2-12M, 23614045M, 2811064 → 2-12M, 2811064, 23611065M, 23614045M, 2-25M FS-120d, 2-03M FS+100d, 13611065M, 1562180 |  |
| 3P-26M | Torus Assembled and Tested | 2015-10-01 → 2015-09-21 (-10d) | 2015-10-01 → 2015-09-21 (-10d) |  | 17d → 25d |  |  |
| 3P-20M | Start E-B Commssng of H-B Detctr's, Electrnc's, & BL Devices | 2016-01-28 → 2016-06-13 (+137d) | 2016-01-28 → 2016-06-13 (+137d) |  | 36d → -60d |  |  |
| 3P-21M | E-B Commssng of H-B Detctr's, Electrnc's, & BL Devices Comptd | 2016-02-10 → 2016-06-24 (+135d) | 2016-02-10 → 2016-06-24 (+135d) |  | 40d → -55d |  |  |
| 1.03R | **1.03R LEVEL 3 REVIEW MILESTONES** |  | 2009-09-30 → 2009-10-30 (+30d) |  |  |  |  |
| 3R-2M | CD-2 Review IPR | 2007-06-29 → 2007-06-28 A (-1d) | 2007-06-29 → 2007-06-28 A (-1d) | 0% → 100% | 0d → none |  |  |
| 3R-3M | CD-2 Review EIR | 2007-08-15 → 2007-08-14 A (-1d) | 2007-08-15 → 2007-08-14 A (-1d) | 0% → 100% | 0d → none |  |  |
| 3R-07M | EVMS Assessment | 2007-09-17 → 2007-10-01 A (+14d) | 2007-09-17 → 2007-10-01 A (+14d) | 0% → 100% | 0d → none |  |  |
| 3R-05M | CD-3 Review IPR | 2008-07-31 → 2008-07-23 A (-8d) | 2008-07-31 → 2008-07-23 A (-8d) | 0% → 100% | 0d → none | 1135025, 1132890M FS-45d, 11111005RKC, 12225045, 1152005A, 1154001RKC, 1155001RKC, 1132800M FS-45d, 1141005RKC5, 1251006RKC, 121221140, 1212111170, 12224005, 121221120, 12131.10010, 1152001RKC, 1132865M FS-45d, 1132895, 1132841 FS-45d, 1132021RKC, 121221145, 121111010M, 121613027, 12163170, 121642170, 2-05M, 2-23M, 3C-01M, 1155020, 123221908LOE, 121224999, 12166027, 2-24M, 19005RKC, 1155025, 1155030, 1132875M FS-45d, 1242040M, 12162027, 12131.04020, 19001RKC, 1152040, 1154025, 1141005RKC, 121223050, 12165027, 12131.03010, 12131.11010, 1132831M FS-45d, 1112015M, 121221135, 12167027, 121614027, 121611041, 121612022 → 1132865M FS-45d, 1112015M, 12131.10010, 3C-01M, 1132875M FS-45d, 11111005RKC, 1141005RKC5, 121613027, 1141005RKC, 1251006RKC, 121111010M, 1152001RKC, 12167027, 19001RKC, 1152040, 1155001RKC, 1132800M FS-45d, 1132841 FS-45d, 1132021RKC, 12131.04020, 121611041, 12162027, 1154001RKC, 1132890M FS-45d, 1132831M FS-45d, 12131.11010, 12165027, 121612022, 2-05M, 19005RKC, 1242040M, 12131.03010, 121614027, 1212111170, 2-23M, 1152005A, 2-24M |  |
| 3R-08M | OECM EVMS Contractor CERTIFICATION Completed | 2008-01-31 → 2008-09-19 A (+232d) | 2008-01-31 → 2008-09-19 A (+232d) | 0% → 100% | 105d → none | 2-22M → 2-22M FS+167d |  |
| 3R-06M | PED Complete (30 Sep 09) (IPL) | 2009-09-30 → 2009-10-30 A (+30d) | 2009-09-30 → 2009-10-30 A (+30d) | 0% → 100% | 0d → none | 12361010, 12223040M, 1222241035M, 12222065, 1222223041M, 122322015b, 122325020, 122324015, 1212122110M, 1212127065M, 1211020M, 121138060, 121614035M, 12162040M, 12156040M, 12156045, 121324000, 12131.09000, 121411110M, 32-12M, 1241035M, 12223045, 12232020, 122323015, 122311055a, 122312095, 1212124170, 1212122170, 1212123050, 1212126170, 1212112020, 1211020M10, 12166035, 121643140, 12131.07015b, 121416005a, 121456999, 1233039, 1233040M, 12353045M, 12226010a, 12225020, 12222015M, 12222055, 12222060, 12236040, 122311056, 1212127170, 1212121170, 12165030, 12163050M, 12156035, 12131.08000, 121416010, 121454015a, 126080M, 12323040M, 12351055M, 12226020a, 12222055b, 12222000a, 1222223040, 122153010, 1212125025M, 1212123055M, 121613040M, 121611055M, 121643045A, 121642010A, 121322000, 12131.03020, 12131.07015, 12361005, 12321018M, 12225040, 12222015a, 12236025, 12236060, 121221150, 1212123170, 1212121095, 1212112145M, 1211020M5, 12115005M, 121113005, 121643080A, 121643010A, 121642015A, 12151020M, 121323000, 121414016, 121446999, 12222070, 12222080, 12236830LOE, 122152020, 1212121145M, 1211020M15, 121114010M, 12167028, 121612030, 121612035, 121643065A, 121414015a, 121425015, 12322018M, 1234180M, 12226015a, 12225050, 12222045, 1222232030, 12232015, 12236020, 1212127060, 1212113170, 12165035, 121414020a, 121434999, 12222035M, 12236015b, 12236010b, 121223060a, 12156002, 121325000, 12131.04025 → 12232020, 12236025, 122152020, 12222065, 12222015M, 1241176M, 12361010, 12323040M, 12321018M, 1211020M5, 121114010M, 12131.07015b, 12131.03020, 12131.09000, 121642010A, 121641110M, 1212123050, 1212127065M, 121414016, 122323015, 14315055x, 12236010b, 12226010a, 12223040M, 12351055M, 1234060, 12156035, 12131.07015, 121643140, 121643010A, 12162040M, 1212125025M, 1212122170, 1212126170, 121221150, 121416010, 121414020a, 121414015a, 121456999, 122325020, 122312045b, 12236830LOE, 12226020a, 12224005, 1211020M10, 1211020M15, 12156002, 121642015A, 121612030, 121612035, 1212121170, 1212121145M, 1212113170, 121224999, 121434999, 12232015, 122322015b, 12225040, 12222080, 1222223041M, 1222223040, 1233040M, 1211020M, 12156040M, 121641170, 12236020, 12225045, 12225050, 12222055b, 12222060, 12222055, 126080M, 12361005, 12353045M, 1234180M, 1234055, 121113005, 121114005, 12131.04025, 121324000, 121322000, 12167028, 121643045A, 121613040M, 12166035, 1212121095, 1212124170, 1212112145M, 121411110M, 121446999, 121454015a, 121425015, 12225020, 1222232030, 12222015a, 12222045, 1233039, 12131.08000, 121323000, 121642170, 121643065A, 1212123055M, 1212112020, 122324015, 122153010, 12221050M, 1222241035M, 12222035M, 12222015, 12222070, 1241035M, 12322018M, 121325000, 121643170, 121643080A, 12163050M, 12163170, 121416005a, 122311055a, 12236015b, 12226015a, 12222000a, 123231030, 123221908LOE, 121138060, 12156045, 12165030, 12165035, 121611055M, 121614035M, 1212123170, 1212127170, 1212127060, 1212122110M, 121223060a, 121416005, 121414020, 32-12M | was named PED Complete (30 Sep 09) (IPL 521224170M); constraint mandatory finish 2009-09-30 → mandatory finish 2009-10-30 |
| 1.04A | **1.04A LEVEL 4 ACCELERATOR MILESTONES** | 2011-01-04 → 2011-06-01 (+148d) | 2014-03-14 → 2014-03-21 (+7d) |  |  |  |  |
| 4A-01M | Start Precurser Maint Down (6 mo dur?, ~1 yr before Installtn Down?) (IPL) | 2011-05-13 → 2011-06-01 A (+19d) | 2011-05-13 → 2011-06-01 A (+19d) | 0% → 100% | 0d → none | 13434007, 13427063LOE, 13427180a, 13427055, 13421095, 13421046ab, 13433015, 13421046b, 13421090, 13456045 → 13451105a, 13421095, 13421046a, 13421090, 13421046ab, 13421046b, 13427180, 13434007, 13427063LOE, 13427055, 13433015, 13427180a | was named Start Precurser Maint Down (6 mo dur, ~1yr before Installtn Down) (IPL534213075,534213105,534213135,53427000M,5348065M) |
| 4A-03M | Start HPA Installtn | 2011-01-04 → 2011-06-01 A (+148d) | 2011-01-04 → 2011-06-01 A (+148d) | 0% → 100% | 168d → none | 1321122050 FS+182d, 3A-01M → 1321122050, 3A-01M |  |
| 4A-04M | End of Precurser Maint Down (6 mo dur?, ~1 yr before Installtn Down?) | 2011-11-11 → 2011-11-14 A (+3d) | 2011-11-11 → 2011-11-14 A (+3d) | 0% → 100% | 0d → none | 13427060, 131502005a FS+15d, 14368171, 14341007, 13427062LOE, 13436035, 13427115M, 14368170, 13221093a → 14368171, 13427115M, 131502005a FS+15d, 14368170, 13427062LOE, 13427060, 13221093, 13221093a, 14341007, 13436035 | was named End of Precurser Maint Down (6 mo dur, ~1 yr before Installtn Down) |

| ID | Task | Start | Finish | Duration | Complete | Total float | Predecessors | Other |
| --- | --- | --- | --- | --- | --- | --- | --- | --- |
| 4A-10M | Start Accel Hot Chkout | 2013-10-15 → 2013-10-14 A (-1d) | 2013-10-15 → 2013-10-14 A (-1d) |  | 0% → 100% | 0d → none | 3C-11M, 13221095, 13213020M, 3A-54M FS-25d, 3A-52M, 3A-58M, 4A-09M FS-20d, 9-140M FS+10d, 23454055 FS-20d, 1351080, 1352035, 2367055 FS-34d, 1367055, 3A-10M, 13643185M, 23454055b FS-20d, 1363014a, 1363025b, 23224100a FS-40d, 1366030M, 1367025a, 13454055, 13224100, 13221097LOE, 23213020M FS-45d, 1363025a, 3A-41M, 3A-56M, 23224100 FS-40d, 1353095, 13642030M, 13643175M, 13612035M, 3A-47M FS-20d, 3A-40M, 13454050, 13611065M, 23454055a FS-20d → 3A-04M, 3A-41M, 1351080, 1363025b, 1367025a, 23224100 FS-40d, 13454050, 1353095, 1363025a, 2367055 FS-40d, 23454055b FS-20d, 3A-40M, 23213020M FS-45d, 3A-54M FS-30d, 3A-52M, 4A-09M FS-20d, 13221097LOE, 1363025, 13642030M, 1367025, 3C-11M, 3A-58M FS-1d, 13213020M, 23224100a FS-40d, 3A-47M FS-20d, 13454055, 1366030M, 3A-56M, 3A-10M, 13224100, 1352035, 13612035M, 23454055 FS-20d, 13221095, 1363014a, 13643185M, 1367055 |  |
| 4A-07M | Linac Installtn Comptd | 2013-10-11 → 2013-11-20 (+40d) | 2013-10-11 → 2013-11-20 (+40d) |  |  | 34d → 26d |  |  |
| 4A-08M | Accelerator Beam Transport Comptd | 2013-10-29 → 2013-11-27 (+29d) | 2013-10-29 → 2013-11-27 (+29d) |  |  | 22d → 21d | 3A-52M, 3A-56M, 3A-54M → 3A-52M, 3A-56M, 3A-46M, 3A-44M, 3A-54M, 3A-43M |  |
| 4A-09M | I&C/Sfty for Accelerator Installtn Comptd | 2013-10-25 → 2013-11-27 (+33d) | 2013-10-25 → 2013-11-27 (+33d) |  |  | 11d → 21d |  |  |
| 4A-11M | Beam Transport to Halls Comptd | 2014-02-07 → 2014-02-28 (+21d) | 2014-02-07 → 2014-02-28 (+21d) |  |  | 73d → 58d |  |  |
| 4A-06M | Pwr (Mag) Installtn Comptd | 2014-02-04 → 2014-03-07 (+31d) | 2014-02-04 → 2014-03-07 (+31d) |  |  | 35d → 13d |  |  |
| 4A-12M | I&C/Sfty Installtn Comptd | 2014-03-14 → 2014-03-21 (+7d) | 2014-03-14 → 2014-03-21 (+7d) |  |  | 21d → 16d |  |  |
| 9-070M | FY07 Funds Available | 2006-10-02 A | 2006-10-02 A |  | 0% → 100% | 0d → none |  |  |
| 9-080M | FY08 Funds Available | 2007-10-01 A | 2007-10-01 A |  | 0% → 100% | 0d → none | none → 9-070M |  |
| 9-090M | FY09 Funds Available | 2008-10-01 A | 2008-10-01 A |  | 0% → 100% | 0d → none | none → 9-080M |  |
| 9-150M | End of R&D Funds | 2008-10-01 → 2008-11-03 A (+33d) | 2008-10-01 → 2008-11-03 A (+33d) |  | 0% → 100% | 0d → none | 1152040, 1135025, 1132831M, 1132875M, 11114070M, 1152035, 1154040, 1152055, 1154025, 1155005A, 1132897, 1132900, 1141015, 1141011, 1132865M, 1132815, 1132800M, 1154060, 1141005RKC, 117908LOE, 1152030, 1154045, 1114010, 1141005RKC5, 1154055, 1155020, 1132895, 1132905, 1132890M, 1142030, 1141012, 1154050, 1155010A, 1155025, 1155030, 1132851M → 1152030, 1155030, 1154025, 1135025, 1155010A, 1154060, 1154045, 1154050, 1132897, 1132851M, 1152035, 1155005A, 1132800M, 1132900, 1141005RKC5, 1155020, 1132831M, 1132895, 1141015, 1154040, 1132865M, 1132875M, 1114010, 1141011, 1152040, 1132890M, 11114070M, 1154055, 117908LOE, 1142030, 1141005RKC |  |
| 9-100M | FY10 Funds Available | 2009-10-01 A | 2009-10-01 A |  | 0% → 100% | 0d → none |  |  |
| 9-110M | FY11 Funds Available | 2010-10-01 A | 2010-10-01 A |  | 0% → 100% | 0d → none | 15212075, 1102231000, 11022325000, 11022321000, 15222025, 11022324000, 15222110, 16223008, 11022322000, 15212070, 16331017, 11022323000 → 16331017, 15222110, 15212070, 15212075, 16223008, 15222025 |  |
| 9-120M | FY12 Funds Available | 2011-10-03 → 2011-10-01 A (-2d) | 2011-10-03 → 2011-10-01 A (-2d) |  | 0% → 100% | 0d → none |  |  |
| 9-130M | FY13 Funds Available | 2012-10-01 A | 2012-10-01 A |  | 0% → 100% | 0d → none | 13222061, 13221125A, 132127040, 14212025, 13463012, 1563006, 14212012E, 14211085, 14211012E, 13224053, 13221021, 14212005sA, 13422065, 13223035A, 132122020f, 1563017a, 1563016, 1563025, 1563011, 14312034, 14324003a, 13221021A, 13221026, 13414028, 14321900a, 132121060f, 1321122210 → 14211085, 13221021, 1321122210, 132121060f, 1563025, 14312034, 13463012, 13422065, 13221026, 132127040, 1563006, 14212025, 13221021A, 1563016, 14324003a, 13414028, 13222061, 13223035A, 1563011, 1563017a, 14212005sA, 13221125A, 14212012E, 14211012E, 14321900a, 132122020f |  |
| 9-140M | FY14 Funds Available | 2013-10-01 A | 2013-10-01 A |  | 0% → 100% | 0d → none | 1-5M, 1961010, 1622000, 16332055, 16331040, 16111035, 1131010, 1135030, 13447040, 13224055, 132124015, 132125025, 1331.07005, 13325020, 1351950, 131137055, 131115020, 13641950, 13642913LOE, 13643950, 1365950, 12226025, 1212113175, 1212112150, 121134025, 121135025, 12115010, 121641175, 121642175, 12131.10015, 12131.01010, 121441015, 181331005, 18223025, 182443025, 182432055, 1547125, 15231055, 15213010, 15213015, 15221182, 1562210, 1562225, 1562120, 1562690, 15311013E, 1532010a, 15512055, 15512120, 15511120, 14264308, 142241555, 142241255, 142241530, 142241560, 142211370, 142211870, 142211855, 142211800, 142211520, 142213342, 142231325, 142231005, 142231014, 142231265a, 142232620, 142232232, 142232640, 142232390, 142232227, 142223017, 142223120, 142223515, 14231030, 14233005, 14271085, 142762000, 142781000, 14243015, 14243005, 14247065, 14368333, 14368027, 14368510, 14342045, 14341070, 14341110, 14311086g, 14312913LOE, 14328010b, 14324005, 14324003, 14355035, 14132913LOE, 2-11M, 3C-08M, 16113035, 16122035, 171913LOEA, 13451950, 13222240, 13223130, 132122035, 132111914LOE, 1331.03005, 1331.01115, 13326020, 1312000, 131138070, 131131025, 131139030, 131133135, 131114135, 13643913LOE, 13611085, 13611950, 1362035M, 123211060, 123213015, 1243060, 1212127175, 121133025, 121138065, 121124025, 121121015, 121125025, 12165040, 121322005, 12131.11015, 121454020, 1813221000, 18223005, 18223015, 182446025, 182431010, 182432040, 182432000, 182432075, 182432045, 182432060, 182432070, 182432030, 182432005, 1546540, 1547205, 1547190, 1541120, 1541080, 1542055, 1544080, 15231015, 15231150, 15213001a, 1562140a, 1562345, 1562250, 1532013E, 1553110, 15511100, 142241647c, 142241375a, 142242225, 142242135a, 142242245, 142211020, 142211013E, 142213012E, 142231430a, 142231015, 142231330a, 142232655, 142232247, 142232615, 142232255, 14233075, 14273015, 14273020, 1427.10000, 14368383, 14362950, 14363035, 14364040, 14364055, 1433015, 14341090, 14341115a, 14341000, 14341050, 14314115, 14312005, 14312042, 14328005b, 14328010a, 14352000a, 14354030, 14355010, 14153025, 2-18M, 197111150, 195221505, 16112025, 16115025, 1152060, 1154065, 1114015, 117910, 110324000, 13417175, 13427185, 13421950, 13452055, 1331.08005, 1331.09005, 1331.02100, 13327005, 13322015, 1356950, 13613030, 13611913LOE, 13614950, 12332030, 12345010, 123511055, 1222242020, 122311060, 122152025, 1212123175, 1212121135B, 121131025, 121137025, 121116025, 121111015, 121613045, 12163175, 12152035, 12151025, 12154025, 12155055, 12131.04030, 12131.07020, 121414025, 121432010, 121433010, 121452025, 1811070, 18223000, 182446035, 182432010, 182432050, 1547115, 1548010, 1542013E, 15221057a, 15221160baa, 1562065, 1562255, 1562097, 1562370, 1531033, 1552010, 1552040, 1553017, 1553034a, 15512110a, 15512136, 15511110, 14264545, 14264998, 142242060, 142242165a, 142242125, 142211010, 142211430, 142211470, 142211110, 142211950, 142213322P, 142231013E, 142232305, 142232385, 142232665, 142232265, 142232320P, 142232025, 142223530, 14232030, 14231065, 14231125, 14234025, 14235020, 14271045, 142761000, 142771000, 14251010, 14247006, 14247035, 14365020, 14365055, 14363021b, 14364075, 14341015, 14341045, 14341030, 14321905, 14321015M, 14328015, 14325028, 14323015, 14323005a, 14351025, 14151040, 1951000, 16112035, 19010, 13444950, 13454060, 132127045, 1331.1010, 1315000, 13114025, 131301015, 131302015, 13641913LOE, 13613913LOE, 13611025, 1362950, 123212040, 123222035, 1241200, 122231025, 122254020, 122363025, 122312100, 1252910, 121223065, 121113015, 121115015, 121614040, 121416015, 121451060, Accel ARR Process, 18223030, 182443030, 182432085, 182432020, 157030, 1548015, 15231060, 15231120, 15212205, 15213010a, 15211255, 1561170, 1562135, 1562015M, 1562359, 1562393, 1531035, 1531105, 1531005ca, 1532077, 1532075c, 1532210, 1532065c, 1553020, 15512110, 15512170, 14212030, 142241415a, 142241565, 142241535, 142241305a, 142242175, 142211400a, 142211445, 142211115a, 142231275, 142231475, 142232234, 142232180, 142232635, 142232396, 142223022, 14271060, 14366025, 14366007, 14368280LOE, 14368120M, 14362070, 14363065, 14364080, 14341120, 14341095, 14341005, 14315045F, 14312032, 14313220, 14328005ba, 14328005a, 14322015, 14325027c, 14323005b, 14351005, 14353015, 14152030, 2-14M, 3P-08M, 19524000, 16115030, 16115050, 1155035, 111121010, 13416050, 13463055, 13426000, 13425035, 13456050, 13221023B, 13213025, 132123030, 1321122215, 132111950, 132113140, 1331.11005, 131116030, 131121050, 1363030a, 1363913LOE, 1366950, 1367060, 13611025c, 13614015, 1231000, 12353050, 1242045, 122325025, 1212122175, 1212125030, 1212126175, 121132025, 12114010, 121126025, 12153025, 121324005, 12131.05020, 121411120, 121421025, 121456020, 181321060, 182446030, 1546570, 1547195, 1547130, 1548040, 1542060, 1543115, 15231025, 15221057b, 15221160bb, 1562145, 1562413, 1531027, 1532067c, 1532075, 1553033, 1553095, 15512005a, 15512035, 14211095, 14264328, 14264204M, 142241395a, 142241345a, 142241595, 142241550, 142241575, 142242110, 142211160v, 142211105h, 142211540, 142211550, 142213220, 142232625, 142232605, 142232560, 142232525, 142223570, 142223319, 14271090, 14254030, 14241020, 14244040, 14366005, 14363060, 14342050, 14342060, 14341025, 14341100, 14341097, 14315046b, 14312025, 14312950, 14312050c, 14313P4LOE, 14328020, 14324010, 14324015, 14325030, 3R-1M, 195222290, 16333040, 16114035, 1121000, 13441015, 13435020, 13422130, 13221022b, 132121075, 1321121085, 1331.06005, 1353100, 1314000, 131135070, 131113000, 131111025, 13642950, 13613950, 13612950, 123221030, 122212050, 122151015, 1212111175, 121136025, 121114015, 12167030, 12156050, 121323005, 121325005, 12131.03025, 12131.06015, 12131.08010, 12131.09005, 121446010, 1831950, 181332005, 181315030, 18223010, 182446040, 182446005, 18241050, 182432025, 1548035, 15231013E, 15231030, 15231065, 15231002, 15213005, 15221315, 1562140, 1562675, 1562420, 1562275, 1531245, 1552050, 1553055, 1553035, 1553045, 1553060, 1553002, 15512013E, 14261000, 14263000, 142241400a, 142241472, 142241545, 142241382a, 142241405ba, 142241655, 142242215, 142242030, 142242195, 142211410, 142213042M, 142213330b, 142213360, 142232330a, 142232680, 142232295, 142743000, 142751000, 14242065, 14247025, 14365023, 14365035, 14365040, 14368265, 14364060, 14364045, 14364016, 14341060, 14315046, 14315105, 14311950, 14312015, 14312045, 14321910, 14328010ba, 14322020, 14325015, 14325027a, 14353020, 9-150M, 195212265, 1621035, 1132910, 1161000, 1112020, 172913LOE, 13433020, 13436070, 13414105, 13462020, 13458070, 13224115, 1331.12005, 13323025, 1355950, 131134025, 131136070, 131123035, 1363950, 13612913LOE, 13614020, 126085, 12361015, 123232040, 12333025, 122153015, 121221155, 1212121175, 121123015, 121444025, 121422000, 121424015, 18223020, 182443020, 1543142, 1545130, 15231045, 15221159b, 15222115, 1562610LOE, 1562475, 1562061, 1562125, 1563035, 1531140, 1531037, 1531100, 1532075ba, 15512100, 15512175, 14264375, 142241580, 142242165b, 142242010, 142211380, 142211160t, 142211535, 142211185, 142211890, 142213322, 142232370a, 142232650, 142232515, 142232610, 142232546, 142232660, 142232285, 142232555, 142232630, 14233007, 14271030, 14271075c, 142741000, 14252015, 14247005, 14366020, 14366030, 14367010, 14364065, 14364035, 14341075, 14341020a, 14341055, 14315100, 14315043, 14314030a, 14311072a, 143118P4LOE, 14312036, 14313280, 14321900, 14352010, 14354035, 14355015, 2-04M, 3R-06M, 195221510, 16112020a, 1142035, 1141025, 171950, 13446015, 13432020, 13411950, 13461055, 13221140, 13324020, 13321075, 1354950, 1352040, 1316015, 131132035, 131112000, 131122115, 1365913LOE, 12331015, 12224010, 122132015, 1251910, 121224070, 1212124175, 121122015, 12166040, 121611060, 121612040, 12162045, 121643175, 182446045, 182431000, 182432035, 182432015, 182432080, 182432065, 157045, 1548030, 1541150, 1541060, 1543150, 151255, 15231070, 15231020, 1562096, 1562013E, 1562090, 1562005LOE, 1531005c, 1531175, 1532015, 1553030, 1553013E, 15512050, 14264886, 14264202M, 142241410a, 142241527, 142241302, 142241600, 142241540, 142242155, 142242205, 142211130, 142213320, 142213242a, 142213320P, 142231420, 142231330b, 142232645, 142232010, 142232015, 142232690, 142223037, 142223575, 14231105, 14231095, 14271025Q, 142791000, 14365025, 14366010, 14368028, 14362065, 14363025, 14341035, 14341105, 14341010, 14341040, 14315037b, 14314100, 14312020, 14321900b, 14322010, 14322013, 14325010, 14325027b, 14323020, 14354025, 18223035, 182431015, 182432090 → none |  |
| 19001 | FY06 Obligations RKC (Oct-Dec 06) | 2006-10-02 A | 2006-12-22 → 2007-02-01 A (+41d) | 58d → 80d | 0% → 100% | 0d → none |  | resources PROCUREMENT<$50K 60; PLABOR → PLABOR; PROCUREMENT<$50K 60 |
| 19002RKC | FY06 Obligations Exp over $50k RKC (Oct-Dec 06) | 2006-10-02 A | 2006-12-22 → 2007-02-01 A (+41d) | 58d → 80d | 0% → 100% | 0d → none |  |  |
| 19001RKC | FY06 Obligations RKC (Jan-Sep 06) | 2007-01-02 A | 2007-09-28 → 2007-10-31 A (+33d) | 189d → 212d | 0% → 100% | 0d → none |  | resources PLABOR; SUPPLIES & MATERIALS; PROCUREMENT<$50K 60 → SUPPLIES & MATERIALS; PLABOR; PROCUREMENT<$50K 60 |
| 19005RKC | FY06 Obligations Exp over $50k RKC (Jan-Sep 06) | 2007-01-02 A | 2007-09-28 → 2007-10-31 A (+33d) | 189d → 212d | 0% → 100% | 0d → none |  |  |
| 19010 | Re-Baseline Actuals Adjustment | 2013-08-30 A | 2013-08-30 A |  | 0% → 100% | 20d → none | 9-130M FS+227d → none |  |
| 1 | **1.1.1.1.1 FY06/07 R&D Plan** |  | 2007-04-11 → 2007-04-20 (+9d) |  |  |  |  |  |
| 11111005RKC | FY06 Obligations RKC | 2006-10-02 A | 2007-03-30 → 2007-04-20 A (+21d) | 120d → 135d | 0% → 100% | 333d → none |  | resources PLABOR; SUPPLIES & MATERIALS → SUPPLIES & MATERIALS; PLABOR |
| 11111000M | 12 GeV R&D & CDs (Finish 1 Month Later) (R&D PLAN) | 2007-04-11 → 2007-02-28 A (-42d) | 2007-04-11 → 2007-02-28 A (-42d) |  | 0% → 100% | 56d → none |  |  |
| 111121000 | Fab. C100 Niobium Cavities x 2 (CAVITY) | 2006-10-02 A | 2006-10-16 → 2006-10-31 A (+15d) | 11d → 21d | 0% → 100% | 34d → none |  | resources MSHOP; MECH TECH [30.8 h]; ELEC TECH [22 h]; MECH DES [13.2 h]; MECH ENG [8.8 h]; MECH ENG [22 h]; MECH ENG [7.04 h]; MECH ENG [17.6 h] → MECH ENG [17.6 h]; MECH ENG [22 h]; MECH ENG [8.8 h]; ELEC TECH [22 h]; MECH ENG [7.04 h]; MECH TECH [30.8 h]; MECH DES [13.2 h]; MSHOP |
| 111121005M | Cavity Fabrication Complete (Finish 9/29/06) (CAVITY) | 2006-10-16 → 2006-11-01 A (+16d) | 2006-10-16 → 2006-11-01 A (+16d) |  | 0% → 100% | 34d → none |  |  |
| 111121010 | Re-Baseline Actuals Adjustment | 2013-08-30 A | 2013-08-30 A |  | 0% → 100% | 20d → none | 9-130M FS+227d → none |  |
| 2 | **1.1.1.1.2.2 Power Coupler** |  | 2007-01-02 → 2006-12-15 (-18d) |  |  |  |  |  |
| 111122000 | Fabricate FPC for HTB Testing (PWR CPLR) | 2006-10-02 A | 2007-01-02 → 2006-12-15 A (-18d) | 59d → 52d | 0% → 100% | 13d → none |  | resources ELEC TECH [80 h]; PROCUREMENT<$50K 60; MECH ENG [40 h]; PROCUREMENT>$50K 69; MECH DES [80 h]; MECH ENG [80 h] → PROCUREMENT>$50K 69; MECH ENG [40 h]; MECH DES [80 h]; MECH ENG [80 h]; ELEC TECH [80 h]; PROCUREMENT<$50K 60 |
| 111122005M | Power Coupler Prototype Fab Complete (PWR CPLR) | 2007-01-02 → 2006-12-15 A (-18d) | 2007-01-02 → 2006-12-15 A (-18d) |  | 0% → 100% | 13d → none |  |  |
| 3 | **1.1.1.1.2.3 Evaluation** | 2006-10-17 → 2006-11-21 (+35d) | 2007-04-11 → 2007-02-28 (-42d) |  |  |  |  |  |
| 111123000 | Conduct VTA Test C100 Cavities (EVALUATION) | 2006-10-17 → 2006-11-21 A (+35d) | 2006-12-22 → 2006-11-29 A (-23d) | 47d → 4d | 0% → 100% | 34d → none |  | resources MECH TECH [40 h]; ELEC TECH [80 h]; MECH TECH [160 h]; ELEC ENG [40 h]; MECH ENG [80 h]; MECH ENG [160 h]; PROCUREMENT<$50K 60; MECH TECH [32 h]; SCIENTIST [16 h] → MECH ENG [80 h]; PROCUREMENT<$50K 60; ELEC ENG [80 h]; SCIENTIST [16 h]; MECH TECH [40 h]; MECH ENG [160 h]; ELEC TECH [80 h]; MECH TECH [160 h]; MECH TECH [32 h] |
| 111123005 | Conduct Integrated Test in HTB (EVALUATION) | 2007-02-01 → 2006-12-22 A (-41d) | 2007-03-15 → 2007-02-02 A (-41d) | 30d → 23d | 0% → 100% | 13d → none |  | resources MECH ENG [40 h]; MECH TECH [40 h]; MECH DES [40 h]; ELEC ENG [200 h]; MECH ENG [120 h]; PROCUREMENT<$50K 60 → MECH ENG [40 h]; MECH TECH [40 h]; MECH ENG [120 h]; PROCUREMENT<$50K 60; ELEC ENG [400 h]; MECH DES [40 h] |
| 111123010M | Integrated Testing Complete (EVALUATION) | 2007-03-15 → 2007-02-02 A (-41d) | 2007-03-15 → 2007-02-02 A (-41d) |  | 0% → 100% | 13d → none |  |  |
| 111123015 | 1/4 Cryomodule CR Accounting Change Request (Finish by 4/30/07) | 2007-03-16 → 2007-02-05 A (-39d) | 2007-04-11 → 2007-02-28 A (-42d) | 19d → 16d | 0% → 100% | 13d → none |  | resources MECH ENG [891.1 h]; MSHOP; SR STAFF [178 h]; PROCUREMENT<$50K 60; PROCUREMENT>$50K 69; MECH DES [175.2 h]; ELEC TECH [32.4 h]; ELEC ENG [-162.51 h]; SCIENTIST [-8.8 h]; MECH TECH [1152.53 h]; SUPPLIES & MATERIALS → SUPPLIES & MATERIALS; ELEC TECH [32.4 h]; ELEC ENG [-162.51 h]; MECH ENG [891.1 h]; MECH TECH [1152.53 h]; PROCUREMENT>$50K 69; SCIENTIST [-8.8 h]; SR STAFF [178 h]; PROCUREMENT<$50K 60; MECH DES [175.2 h]; MSHOP |
| 4 | **1.1.1.1.2.4 Tuner** | 2006-10-17 → 2006-11-01 (+15d) | 2006-12-15 → 2006-11-20 (-25d) |  |  |  |  |  |
| 111124000 | Procure Prototype Components (TUNER) | 2006-10-17 → 2006-11-01 A (+15d) | 2006-12-15 → 2006-11-20 A (-25d) | 42d → 13d | 0% → 100% | 39d → none |  | resources MECH ENG [8 h]; PROCUREMENT>$50K 69; MECH ENG [16 h]; PROCUREMENT<$50K 60; MECH DES [32 h] → PROCUREMENT<$50K 60; MECH ENG [16 h]; MECH DES [32 h]; MECH ENG [8 h]; PROCUREMENT>$50K 69 |
| 4 | **1.1.1.1.4 HOM MEASUREMENTS** |  | 2008-07-11 → 2008-09-30 (+81d) |  |  |  |  |  |
| 11114000 | Prepare for HTB test | 2008-03-13 A | 2008-04-03 → 2008-05-19 A (+46d) | 16d → 48d | 0% → 100% | 56.5d → none |  | resources SUPPLIES & MATERIALS; MECH ENG [240 h]; MECH DES [60 h] → MECH DES [60 h]; MECH ENG [240 h]; SUPPLIES & MATERIALS |
| 11114005 | Procure/fabricate/modify HOM hardware | 2008-03-24 → 2008-03-13 A (-11d) | 2008-04-10 → 2008-06-10 A (+61d) | 13.5d → 62d | 0% → 100% | 56.5d → none |  |  |
| 11114010 | Assemble HTB | 2008-04-10 → 2008-04-16 A (+6d) | 2008-04-18 → 2008-05-21 A (+33d) | 6d → 26d | 0% → 100% | 56.5d → none | 11114005 → 9-080M |  |
| 11114015M | HTB Assembly Completed | 2008-04-18 → 2008-05-21 A (+33d) | 2008-04-18 → 2008-05-21 A (+33d) |  | 0% → 100% | 56.5d → none |  |  |
| 11114020 | Install into CMTF/Cooldown | 2008-04-18 → 2008-05-22 A (+34d) | 2008-04-25 → 2008-05-23 A (+28d) | 5d → 2d | 0% → 100% | 56.5d → none |  |  |
| 11114025 | Perform HOM measurements in HTB | 2008-04-25 → 2008-05-29 A (+34d) | 2008-05-02 → 2008-06-17 A (+46d) | 5d → 13d | 0% → 100% | 56.5d → none |  |  |
| 11114035 | Perform thermal measurements | 2008-05-02 → 2008-06-02 A (+31d) | 2008-05-09 → 2008-06-26 A (+48d) | 5d → 18d | 0% → 100% | 56.5d → none |  |  |
| 11114045 | Data Analysis | 2008-05-09 → 2008-06-02 A (+24d) | 2008-05-30 → 2008-07-21 A (+52d) | 14d → 35d | 0% → 100% | 56.5d → none |  |  |
| 11114030M | Q's measured and analyzed Completed | 2008-05-02 → 2008-06-17 A (+46d) | 2008-05-02 → 2008-06-17 A (+46d) |  | 0% → 100% | 56.5d → none |  |  |
| 11114040 | WarmUp & Disassemble | 2008-05-30 → 2008-06-26 A (+27d) | 2008-06-13 → 2008-06-30 A (+17d) | 10d → 2d | 0% → 100% | 56.5d → none | 11114045 → 11114035 |  |
| 11114055 | VTA tests: prep and execution | 2008-06-13 → 2008-06-30 A (+17d) | 2008-07-03 → 2008-07-21 A (+18d) |  | 0% → 100% | 56.5d → none | 11114050M, 11114040 → 11114005, 11114040, 11114050M | resources ELEC ENG [80 h]; MECH ENG [80 h]; MECH TECH [160 h] → MECH TECH [160 h]; ELEC ENG [80 h]; MECH ENG [80 h] |
| 11114050M | Interim report Completed | 2008-05-09 → 2008-07-11 A (+63d) | 2008-05-09 → 2008-07-11 A (+63d) |  | 0% → 100% | 80.5d → none | 11114035 → 11114035 FS+11d |  |
| 11114060 | Disassemble and store components | 2008-07-07 → 2008-07-21 A (+14d) | 2008-07-11 → 2008-07-28 A (+17d) |  | 0% → 100% | 56.5d → none |  |  |
| 11114065 | Data Analysis | 2008-07-07 → 2008-07-21 A (+14d) | 2008-07-11 → 2008-07-28 A (+17d) |  | 0% → 100% | 56.5d → none | 11114055 → 11114045, 11114055 |  |
| 11114070M | Final Report and All Tasks Completed | 2008-07-11 → 2008-09-30 A (+81d) | 2008-07-11 → 2008-09-30 A (+81d) |  | 0% → 100% | 56.5d → none |  |  |
| 5 | **1.1.1.1.5 WAVEGUIDE FUNDAMENTAL POWER COUPLER TESTS** | 2008-06-02 → 2008-06-24 (+22d) | 2008-12-18 → 2009-11-30 (+347d) |  |  |  |  |  |
| 11115000 | Developement of Documentation & Detail Plans | 2008-06-02 → 2008-06-24 A (+22d) | 2008-06-27 → 2008-08-29 A (+63d) | 20d → 48d | 0% → 100% | 368d → none | 9-080M FS+163d → 9-080M | resources MECH ENG [80 h]; MECH TECH [200 h]; SUPPLIES & MATERIALS; COMP SCIENT [40 h]; SCIENTIST [40 h] → SUPPLIES & MATERIALS; SCIENTIST [40 h]; COMP SCIENT [40 h]; MECH ENG [80 h]; MECH TECH [200 h] |
| 11115005 | Vendor Fab 15 Waveguide Fundamental Power Couplers | 2008-06-30 A | 2008-12-18 → 2009-11-30 A (+347d) | 120d → 354d | 0% → 100% | 368d → none |  | resources PROCUREMENT>$50K 69 NO ESCALATION FY09; PROCUREMENT<$50K 60 NO ESCALATION FY09 → PROCUREMENT<$50K 60 NO ESCALATION FY09; PROCUREMENT>$50K 69 NO ESCALATION FY09 |
| 2 | **1.1.1.2 POWER SYSTEMS** | 2007-03-15 → 2007-07-02 (+109d) |  |  |  |  |  |  |
| 1112000 | Conduct Interlock Check Out (POWER SYSTEMS) | 2007-03-15 → 2007-07-02 A (+109d) | 2007-03-28 → 2007-07-09 A (+103d) | 10d → 5d | 0% → 100% | 269d → none |  | resources ELEC TECH [40 h]; ELEC ENG [40 h] → ELEC ENG [40 h]; ELEC TECH [40 h] |
| 1112005 | Conduct RF - Cavity System Tests (POWER SYSTEMS) | 2007-04-16 → 2007-07-10 A (+85d) | 2007-06-15 → 2007-07-17 A (+32d) | 44d → 5d | 0% → 100% | 269d → none |  | constraint none → start on or after 2007-07-10; resources SCIENTIST [80 h]; ELEC TECH [80 h]; ELEC ENG [320 h]; COMP SCIENT [80 h] → ELEC TECH [80 h]; COMP SCIENT [80 h]; SCIENTIST [80 h]; ELEC ENG [320 h] |
| 1112010 | Report Writing (POWER SYSTEMS) | 2007-05-30 → 2007-07-18 A (+49d) | 2007-06-15 → 2007-07-31 A (+46d) | 13d → 9d | 0% → 100% | 269d → none |  |  |
| 1112015M | Report sent to DOE (POWER SYSTEMS) | 2007-06-29 → 2007-07-31 A (+32d) | 2007-06-29 → 2007-07-31 A (+32d) |  | 0% → 100% | 269d → none |  |  |
| 1112020 | Re-Baseline Actuals Adjustment | 2013-08-30 A | 2013-08-30 A |  | 0% → 100% | 20d → none | 9-130M FS+227d → none |  |
| 4 | **1.1.1.4 BEAM TRANSPORT** | 2007-11-01 → 2007-11-13 (+12d) |  |  |  |  |  |  |
| 1114000 | Fabricate QP and QR Laminations | 2007-11-01 → 2007-11-13 A (+12d) | 2008-02-08 → 2008-06-05 A (+118d) | 62d → 136d | 0% → 100% | 78d → none |  |  |
| 1114005 | Fabricate Coils and Assemble magnets | 2007-12-03 A | 2008-04-04 → 2008-07-09 A (+96d) | 81d → 147d | 0% → 100% | 78d → none |  |  |
| 1114010 | Test and measure QP and QR | 2008-03-18 → 2008-06-30 A (+104d) | 2008-06-10 → 2008-08-29 A (+80d) | 60d → 44d | 0% → 100% | 78d → none |  | resources MECH ENG [80 h]; MECH TECH [172 h]; PROCUREMENT<$50K 60 → MECH TECH [172 h]; PROCUREMENT<$50K 60; MECH ENG [80 h] |
| 1114015 | Re-Baseline Actuals Adjustment | 2013-08-30 A | 2013-08-30 A |  | 0% → 100% | 20d → none | 9-130M FS+227d → none |  |
| 1121000 | Re-Baseline Actuals Adjustment | 2013-08-30 A | 2013-08-30 A |  | 0% → 100% | 20d → none | 9-130M FS+227d → none |  |
| 1 | **1.1.3.1 TORUS MAGNET R&D** | 2007-06-18 → 2007-07-02 (+14d) |  |  |  |  |  |  |
| 1131005 | Conduct SC Magnet Cable Testing | 2007-06-18 → 2007-07-02 A (+14d) | 2007-07-16 → 2007-08-16 A (+31d) | 20d → 33d | 0% → 100% | 162d → none |  |  |

| ID | Task | Start | Finish | Duration | Complete | Total float | Predecessors | Other |
| --- | --- | --- | --- | --- | --- | --- | --- | --- |
| 1131010 | Re-Baseline Actuals Adjustment | 2013-08-30 A | 2013-08-30 A |  | 0% → 100% | 20d → none | 9-130M FS+227d → none |  |
| 1132021RKC | FY06 Obligations RKC | 2006-10-02 A | 2007-03-30 → 2007-10-31 A (+215d) | 120d → 270d | 0% → 100% | 333d → none |  |  |
| 1132028 | FY07-HTCC - Testing of the prototype (DTCTR R&D) | 2006-10-02 A | 2007-01-04 → 2007-09-25 A (+264d) | 61d → 244d | 0% → 100% | 1d → none |  | resources SCIENTIST [34.4 h]; PD UNIV STUDNT [217.6 h]; CONTRB UNIV LBR [121 h] → PD UNIV STUDNT [217.6 h]; CONTRB UNIV LBR [121 h]; SCIENTIST [34.4 h] |
| 1132055 | FY07-DC - Mechanical protoptyping (DTCTR R&D) | 2006-10-02 A | 2007-04-06 → 2007-10-10 A (+187d) | 125d → 255d | 0% → 100% | 1d → none |  | resources CONTRB UNIV LBR [479.62 h]; MECH TECH [479.62 h]; MECH DES [218.01 h]; MECH ENG [22 h]; PROCUREMENT<$50K 60 → MECH TECH [479.62 h]; MECH DES [218.01 h]; MECH ENG [22 h]; PROCUREMENT<$50K 60; CONTRB UNIV LBR [479.62 h] |
| 1132060 | FY07-DC - Electrical prototyping (DTCTR R&D) | 2006-10-02 A | 2007-04-06 → 2007-10-16 A (+193d) | 125d → 258d | 0% → 100% | 1d → none |  | resources ELEC ENG [21.8 h]; PROCUREMENT<$50K 60; ELEC DES [239.81 h]; ELEC TECH [109.01 h] → ELEC DES [239.81 h]; ELEC ENG [21.8 h]; PROCUREMENT<$50K 60; ELEC TECH [109.01 h] |
| 1132095 | FY07-SVT - prototyping (DTCTR R&D) | 2006-10-02 A | 2007-04-06 → 2007-10-16 A (+193d) | 125d → 259d | 0% → 100% | 1d → none |  | resources CONTRB UNIV LBR [479.62 h]; ELEC ENG [545.03 h]; SCIENTIST [43.6 h]; PROCUREMENT<$50K 60 → CONTRB UNIV LBR [479.62 h]; PROCUREMENT<$50K 60; ELEC ENG [545.03 h]; SCIENTIST [43.6 h] |
| 1132026M | FY07-HTCC -R&D Plans & Initial Safety Assessment (DTCTR R&D) | 2006-10-02 → 2006-11-01 A (+30d) | 2006-10-02 → 2006-11-01 A (+30d) |  | 0% → 100% | 1d → none |  |  |
| 1132033M | FY07-EC -R&D Plans & Initial Safety Assessment (DTCTR R&D) | 2006-10-02 → 2006-11-01 A (+30d) | 2006-10-02 → 2006-11-01 A (+30d) |  | 0% → 100% | 1d → none |  |  |
| 1132035 | FY07-EC - Fullscale prototype design (DTCTR R&D) | 2006-10-02 → 2006-11-01 A (+30d) | 2007-01-31 → 2007-04-02 A (+61d) | 79d → 99d | 0% → 100% | 1d → none |  |  |
| 1132054M | FY07-DC Plans & Initial Safety Assessment (DTCTR R&D) | 2006-10-02 → 2006-11-01 A (+30d) | 2006-10-02 → 2006-11-01 A (+30d) |  | 0% → 100% | 1d → none |  |  |
| 1132069M | FY07-FTOF -R&D Plans & Initial Safety Assessment (DTCTR R&D) | 2006-10-02 → 2006-11-01 A (+30d) | 2006-10-02 → 2006-11-01 A (+30d) |  | 0% → 100% | 1d → none |  |  |
| 1132070 | FY07-FTOF - Building the prototype (DTCTR R&D) | 2006-10-02 → 2006-11-01 A (+30d) | 2007-02-28 → 2007-09-25 A (+209d) | 98d → 222d | 0% → 100% | 1d → none |  |  |
| 1132075 | FY07-FTOF - Testing and data analysis from the prototype (DTCTR R&D) | 2007-03-01 → 2006-11-01 A (-120d) | 2007-09-28 A | 149d → 225d | 0% → 100% | 1d → none | 1132070 → 1132070 FS-25d |  |
| 1132079M | FY07-CTOF -R&D Plans & Initial Safety Assessment (DTCTR R&D) | 2006-10-02 → 2006-11-01 A (+30d) | 2006-10-02 → 2006-11-01 A (+30d) |  | 0% → 100% | 1d → none |  |  |
| 1132080 | FY07-CTOF - Design of the prototype (DTCTR R&D) | 2006-10-02 → 2006-11-01 A (+30d) | 2006-12-19 → 2007-03-30 A (+101d) | 55d → 98d | 0% → 100% | 1d → none |  |  |
| 1132085 | FY07-CTOF - Building the prototype (DTCTR R&D) | 2006-12-20 → 2006-11-01 A (-49d) | 2007-04-03 → 2007-04-13 A (+10d) | 67d → 108d | 0% → 100% | 1d → none | 1132080 → 1132080 FS-50d |  |
| 1132094M | FY07-SVT -R&D Plans & Initial Safety Assessment (DTCTR R&D) | 2006-10-02 → 2006-11-01 A (+30d) | 2006-10-02 → 2006-11-01 A (+30d) |  | 0% → 100% | 1d → none |  |  |
| 1132030 | FY07-HTCC - Analysis of the prototype (DTCTR R&D) | 2007-01-05 → 2007-04-02 A (+87d) | 2007-09-28 → 2007-09-25 A (-3d) | 186d → 124d | 0% → 100% | 1d → none | 1132028 → 1132028 FS-21d |  |
| 1132045 | FY07-EC - Manufacturing the box and fixtures for the full scale protoptye (DTCTR R&D) | 2007-02-01 → 2007-04-02 A (+60d) | 2007-05-03 → 2007-04-20 A (-13d) | 65d → 15d | 0% → 100% | 1d → none |  | resources MECH DES [43.6 h]; MECH TECH [387.6 h]; PROCUREMENT<$50K 60; MECH ENG [22 h] → PROCUREMENT<$50K 60; MECH DES [43.6 h]; MECH TECH [387.6 h]; MECH ENG [22 h] |
| 1132090 | FY07-CTOF - Testing of the prototype (DTCTR R&D) | 2007-04-04 → 2007-04-02 A (-2d) | 2007-09-28 → 2007-09-15 A (-13d) | 125d → 117d | 0% → 100% | 1d → none | 1132085, 1132080 → 1132085 FS-21d, 1132080 FS-21d |  |
| 1132050 | FY07-EC - Assembly & testing of the protoptype (DTCTR R&D) | 2007-05-04 → 2007-04-23 A (-11d) | 2007-09-28 → 2007-08-24 A (-35d) | 103d → 88d | 0% → 100% | 1d → none |  | resources VISTNG USERS [523.2 h]; MECH TECH [222.8 h] → MECH TECH [222.8 h]; VISTNG USERS [523.2 h] |
| 1132030M | FY07-HTCC -R&D Report (DTCTR R&D) | 2007-09-28 → 2007-05-31 A (-120d) | 2007-09-28 → 2007-05-31 A (-120d) |  | 0% → 100% | 1d → none |  |  |
| 1132065 | FY07-DC - Testing & analysis of the prototype (DTCTR R&D) | 2007-04-09 → 2007-06-15 A (+67d) | 2007-09-28 → 2007-10-22 A (+24d) | 122d → 90d | 0% → 100% | 1d → none | 1132055, 1132060 → 1132055 FS-26d, 1132060 FS-26d | resources ELEC TECH [108.8 h]; ELEC DES [239.6 h]; ELEC ENG [21.6 h] → ELEC TECH [108.8 h]; ELEC ENG [21.6 h]; ELEC DES [239.6 h] |
| 1132100 | FY07-SVT - testing of the prototype (DTCTR R&D) | 2007-04-09 → 2007-06-15 A (+67d) | 2007-09-28 → 2008-02-19 A (+144d) | 122d → 164d | 0% → 100% | 1d → none |  | resources ELEC ENG [545.03 h]; CONTRB UNIV LBR [479.62 h]; PROCUREMENT<$50K 60; SCIENTIST [261.61 h] → ELEC ENG [545.03 h]; CONTRB UNIV LBR [479.62 h]; SCIENTIST [261.61 h]; PROCUREMENT<$50K 60 |
| 1132050M | FY07-EC -R&D Report (DTCTR R&D) | 2007-09-28 → 2007-07-24 A (-66d) | 2007-09-28 → 2007-07-24 A (-66d) |  | 0% → 100% | 1d → none |  |  |
| 1132065M | FY07-DC -R&D Report (DTCTR R&D) | 2007-09-28 A | 2007-09-28 A |  | 0% → 100% | 1d → none |  |  |
| 1132075M | FY07-FTOF -R&D Report (DTCTR R&D) | 2007-09-28 A | 2007-09-28 A |  | 0% → 100% | 1d → none |  |  |
| 1132090M | FY07-CTOF-R&D Report (DTCTR R&D) | 2007-09-28 A | 2007-09-28 A |  | 0% → 100% | 1d → none |  |  |
| 1132820 | FY08-DC - Mech protoptyping (DETCTR R&D) | 2007-10-01 A | 2008-04-07 → 2008-08-29 A (+144d) | 125d → 227d | 0% → 100% | 1d → none |  | resources MECH DES [64 h]; MECH ENG [8 h]; PROCUREMENT<$50K 60; CONTRB UNIV LBR [144 h]; MECH TECH [144 h] → PROCUREMENT<$50K 60; CONTRB UNIV LBR [144 h]; MECH TECH [144 h]; MECH DES [64 h]; MECH ENG [8 h] |
| 1132825 | FY08-DC - Elect Prototypng (DETCTR R&D) | 2007-10-01 A | 2008-04-07 → 2008-08-29 A (+144d) | 125d → 227d | 0% → 100% | 1d → none |  |  |
| 1132834M | FY08-EC -R&D Plans & Initl Sfty Assessmnt (DETCTR R&D) | 2007-10-01 A | 2007-10-01 A |  | 0% → 100% | 1d → none |  |  |
| 1132835 | FY08-FTOF - Fab Proto (DETCTR R&D) | 2007-10-01 A | 2008-02-28 → 2008-09-26 A (+211d) | 98d → 246d | 0% → 100% | 1d → none |  |  |
| 1132845 | FY08-CTOF - Dsgn of Proto (DETCTR R&D) | 2007-10-01 A | 2007-12-18 → 2008-05-15 A (+149d) | 55d → 153d | 0% → 100% | 1d → none |  |  |
| 1132854M | FY08-DC Plans & Initl Sfty Assessmnt (DETCTR R&D) | 2007-10-01 A | 2007-10-01 A |  | 0% → 100% | 1d → none |  |  |
| 1132860 | FY08-SVT - Prototypng (DETCTR R&D) | 2007-10-01 A | 2008-04-07 → 2008-08-29 A (+144d) | 125d → 227d | 0% → 100% | 1d → none |  | resources CONTRB UNIV LBR [144 h]; PROCUREMENT<$50K 60; ELEC ENG [164 h]; SCIENTIST [12 h] → SCIENTIST [12 h]; CONTRB UNIV LBR [144 h]; PROCUREMENT<$50K 60; ELEC ENG [164 h] |
| 1132895 | FY08-DC- Protoype Testing & Data Analysis (DETCTR R&D) | 2007-10-01 A | 2008-05-12 → 2008-08-29 A (+109d) | 150d → 227d | 0% → 100% | 56d → none |  | resources CONTRB UNIV LBR [1120 h]; PD UNIV STUDNT [16 h]; MECH ENG [12 h]; SCIENTIST [160 h]; VISTNG USERS [280 h]; MECH TECH [40 h]; COMP SCIENT [20 h] → CONTRB UNIV LBR [1120 h]; PD UNIV STUDNT [16 h]; MECH ENG [12 h]; VISTNG USERS [280 h]; MECH TECH [40 h]; COMP SCIENT [20 h]; SCIENTIST [160 h] |
| 1132897 | FY08-SVT- Protoype Testing & Data Analysis (DETCTR R&D) | 2007-10-01 A | 2008-05-12 → 2008-08-29 A (+109d) | 150d → 227d | 0% → 100% | 98d → none |  | resources COMP SCIENT [20 h]; MECH TECH [80 h]; SCIENTIST [132 h]; ELEC TECH [16 h]; CONTRB UNIV LBR [1188 h]; VISTNG USERS [788 h] → MECH TECH [80 h]; ELEC TECH [16 h]; COMP SCIENT [20 h]; CONTRB UNIV LBR [1188 h]; SCIENTIST [132 h]; VISTNG USERS [788 h] |
| 1132840 | FY08-FTOF - Testing & Data Analysis from Proto (DETCTR R&D) | 2008-02-29 → 2007-10-15 A (-137d) | 2008-09-29 → 2008-09-26 A (-3d) | 149d → 236d | 0% → 100% | 1d → none | 1132835 → 1132835 FS-20d |  |
| 1132841 | FY08-HTCC - Analysis of Proto (DETCTR R&D) | 2008-01-07 → 2007-10-15 A (-84d) | 2008-09-29 → 2008-09-26 A (-3d) | 186d → 236d | 0% → 100% | 1d → none | 1132829 → 1132829 FS-20d | resources SCIENTIST [8 h]; CONTRB UNIV LBR [32 h]; PD UNIV STUDNT [60 h] → PD UNIV STUDNT [60 h]; SCIENTIST [8 h]; CONTRB UNIV LBR [32 h] |
| 1132850 | FY08-CTOF - Fab Proto (DETCTR R&D) | 2007-12-19 → 2007-10-15 A (-65d) | 2008-04-02 → 2008-08-29 A (+149d) | 67d → 217d | 0% → 100% | 1d → none |  |  |
| 1132855 | FY08-CTOF - Testing of Proto (DETCTR R&D) | 2008-04-03 → 2007-10-15 A (-171d) | 2008-09-29 A | 125d → 237d | 0% → 100% | 1d → none |  |  |
| 1132865 | FY08-SVT - Testing of Proto (DETCTR R&D) | 2008-04-08 → 2007-10-15 A (-176d) | 2008-09-29 A | 122d → 237d | 0% → 100% | 1d → none | 1132860 → 1132860 FS-10d |  |
| 1132827M | FY08-HTCC -R&D Plans & Initl Sfty Assessmnt (DETCTR R&D) | 2007-10-01 → 2007-10-16 A (+15d) | 2007-10-01 → 2007-10-16 A (+15d) |  | 0% → 100% | 1d → none |  |  |
| 1132829 | FY08-HTCC - Testing of Proto (DETCTR R&D) | 2007-10-01 → 2007-10-16 A (+15d) | 2008-01-04 → 2008-09-26 A (+266d) | 61d → 235d | 0% → 100% | 1d → none |  | resources SCIENTIST [12 h]; CONTRB UNIV LBR [36 h]; PD UNIV STUDNT [64 h] → CONTRB UNIV LBR [36 h]; SCIENTIST [12 h]; PD UNIV STUDNT [64 h] |
| 1132830 | FY08-DC - Testing & Analysis of Proto (DETCTR R&D) | 2008-04-08 → 2007-10-16 A (-175d) | 2008-09-29 → 2008-09-26 A (-3d) | 122d → 235d | 0% → 100% | 1d → none |  | resources ELEC TECH [32 h]; ELEC ENG [8 h]; ELEC DES [80 h] → ELEC ENG [8 h]; ELEC DES [80 h]; ELEC TECH [32 h] |
| 1132869M | FY08-FTOF -R&D Plans & Initl Sfty Assessmnt (DETCTR R&D) | 2007-10-01 → 2007-10-16 A (+15d) | 2007-10-01 → 2007-10-16 A (+15d) |  | 0% → 100% | 1d → none |  |  |
| 1132894M | FY08-SVT -R&D Plans & Initl Sfty Assessmnt (DETCTR R&D) | 2007-10-01 → 2007-10-16 A (+15d) | 2007-10-01 → 2007-10-16 A (+15d) |  | 0% → 100% | 1d → none |  |  |
| 1132100M | FY07-SVT -R&D Report (DTCTR R&D) | 2007-09-28 → 2008-02-19 A (+144d) | 2007-09-28 → 2008-02-19 A (+144d) |  | 0% → 100% | 1d → none |  |  |
| 1132805 | FY08-EC - Smallscale Proto Dsgn (DETCTR R&D) | 2007-10-01 → 2008-03-03 A (+154d) | 2008-01-31 → 2008-03-10 A (+39d) | 79d → 6d | 0% → 100% | 1d → none |  | was named FY08-EC - Fullscale Proto Dsgn (DETCTR R&D); resources SCIENTIST [8 h]; CONTRB UNIV LBR [32 h]; PD UNIV STUDNT [60 h] → PD UNIV STUDNT [60 h]; SCIENTIST [8 h]; CONTRB UNIV LBR [32 h] |
| 1132810 | FY08-EC - Manufacturing Box & Fixtures for Full Scale Proto (DETCTR R&D) | 2008-02-01 → 2008-03-10 A (+38d) | 2008-05-02 → 2008-03-17 A (-46d) | 65d → 6d | 0% → 100% | 1d → none |  | resources MECH TECH [80 h]; PROCUREMENT<$50K 60; MECH DES [12 h]; MECH ENG [8 h] → PROCUREMENT<$50K 60; MECH ENG [8 h]; MECH DES [12 h]; MECH TECH [80 h] |
| 1132815 | FY08-EC - Assy & Testing of protoptype (DETCTR R&D) | 2008-05-05 → 2008-03-17 A (-49d) | 2008-09-29 → 2008-08-29 A (-31d) | 103d → 118d | 0% → 100% | 1d → none |  | resources MECH TECH [104.19 h]; VISTNG USERS [156 h] → VISTNG USERS [156 h]; MECH TECH [104.19 h] |
| 1132900 | SVT Readout (DETCTR R&D) | 2008-04-01 A | 2008-09-30 → 2008-08-29 A (-32d) | 128d → 107d | 0% → 100% | 0d → none |  | resources PROCUREMENT<$50K 60; TRAVEL; ELEC ENG [200 h]; ELEC TECH [280 h] → TRAVEL; ELEC ENG [200 h]; ELEC TECH [280 h]; PROCUREMENT<$50K 60 |
| 1132905 | CTOF PMT's & Mag Sheild Tests (DETCTR R&D) | 2008-04-01 A | 2008-09-30 → 2008-10-15 A (+15d) | 128d → 139d | 0% → 100% | 0d → none |  | resources SCIENTIST [320 h]; PROCUREMENT<$50K 60 → PROCUREMENT<$50K 60; SCIENTIST [320 h] |
| 1132879M | FY08-CTOF -R&D Plans & Initl Sfty Assessmnt (DETCTR R&D) | 2007-10-01 → 2008-04-14 A (+196d) | 2007-10-01 → 2008-04-14 A (+196d) |  | 0% → 100% | 1d → none |  |  |
| 1132851M | FY08-EC -R&D Report (DETCTR R&D) | 2008-09-29 → 2008-09-01 A (-28d) | 2008-09-29 → 2008-09-01 A (-28d) |  | 0% → 100% | 1d → none |  |  |
| 1132875M | FY08-FTOF -R&D Report (DETCTR R&D) | 2008-09-29 → 2008-09-11 A (-18d) | 2008-09-29 → 2008-09-11 A (-18d) |  | 0% → 100% | 1d → none |  |  |
| 1132800M | FY08-SVT -R&D Report (DETCTR R&D) | 2008-09-29 → 2008-09-19 A (-10d) | 2008-09-29 → 2008-09-19 A (-10d) |  | 0% → 100% | 1d → none |  |  |
| 1132831M | FY08-HTCC -R&D Report (DETCTR R&D) | 2008-09-29 → 2008-09-26 A (-3d) | 2008-09-29 → 2008-09-26 A (-3d) |  | 0% → 100% | 1d → none |  |  |
| 1132865M | FY08-DC -R&D Report (DETCTR R&D) | 2008-09-29 A | 2008-09-29 A |  | 0% → 100% | 1d → none |  |  |
| 1132890M | FY08-CTOF-R&D Report (DETCTR R&D) | 2008-09-29 A | 2008-09-29 A |  | 0% → 100% | 1d → none |  |  |
| 1132910 | Re-Baseline Actuals Adjustment | 2013-08-30 A | 2013-08-30 A |  | 0% → 100% | 20d → none | 9-130M FS+227d → none |  |
| 1135015 | BL - Conduct rates studies and optimization of the beam line at FDC (BEAMLINE) | 2006-10-02 A | 2007-05-10 → 2007-06-28 A (+49d) | 149d → 183d | 0% → 100% | 179d → none |  | resources TRAVEL; VISTNG USERS [906.02 h] → VISTNG USERS [906.02 h]; TRAVEL |
| 1135010 | BL - Conduct rates studies and beam line optimization at HTCC (BEAMLINE) | 2006-10-02 → 2007-02-05 A (+126d) | 2007-04-06 → 2007-06-28 A (+83d) | 125d → 102d | 0% → 100% | 203d → none |  | resources VISTNG USERS [906.02 h]; TRAVEL → TRAVEL; VISTNG USERS [906.02 h] |
| 1135020M | BL -R&D Report (BEAMLINE) | 2007-05-11 → 2007-07-24 A (+74d) | 2007-05-11 → 2007-07-24 A (+74d) |  | 0% → 100% | 179d → none |  |  |
| 1135025 | BL- Rates Studies & Beam Line Optimztn of Forward Detctr | 2008-01-02 → 2007-10-22 A (-72d) | 2008-06-27 → 2008-08-29 A (+63d) | 125d → 212d | 0% → 100% | 23d → none |  | resources VISTNG USERS [540 h]; SCIENTIST [544 h] → SCIENTIST [544 h]; VISTNG USERS [540 h] |
| 1135030 | Re-Baseline Actuals Adjustment | 2013-08-30 A | 2013-08-30 A |  | 0% → 100% | 20d → none | 9-130M FS+227d → none |  |
| 1141005RKC | FY06 Obligations RKC | 2006-10-02 A | 2007-03-30 → 2006-10-31 A (-150d) | 120d → 22d | 0% → 100% | 333d → none |  |  |
| 1141020 | Cable reshaping and testing for HB and Q1 magnets | 2006-10-02 → 2006-11-01 A (+30d) | 2007-04-12 → 2007-08-30 A (+140d) | 129d → 205d | 0% → 100% | 134d → none |  |  |
| 1141015 | Build a Test Device to Measure Heat Distribution at the HB Magnet | 2006-10-02 → 2007-02-23 A (+144d) | 2007-05-31 → 2007-08-30 A (+91d) | 163d → 133d | 0% → 100% | 100d → none |  |  |
| 1141010 | Design a scale cross section model of the HB magnet FY 07 | 2007-06-01 → 2007-08-01 A (+61d) | 2007-09-28 → 2007-10-29 A (+31d) | 84d → 62d | 0% → 100% | 0d → none |  | constraint start on or after 2007-06-01 → none |

| ID | Task | Start | Finish | Duration | Complete | Total float | Predecessors | Other |
| --- | --- | --- | --- | --- | --- | --- | --- | --- |
| 1141011 | Design a scale cross section model of the HB magnet FY 08 | 2007-10-01 → 2007-11-01 A (+31d) | 2008-04-30 → 2008-05-30 A (+30d) | 142d → 140d | 0% → 100% | 86d → none |  | resources MECH ENG [80 h]; TRAVEL → TRAVEL; MECH ENG [80 h] |
| 1141013 | Prepare Tooling for Coil Winding & Wind Several Subcoils for the HB Magnet | 2007-12-03 → 2008-01-21 A (+49d) | 2008-04-30 → 2008-07-18 A (+79d) | 99d → 126d | 0% → 100% | 0d → none | 1141010 FS+43d → 1141010 |  |
| 1141012 | Fab 1 full HB Coil & Test Mech, Elect & Insulation Properities @ Room Temp | 2008-05-01 → 2008-07-21 A (+81d) | 2008-09-30 → 2009-02-11 A (+134d) | 106d → 138d | 0% → 100% | 0d → none |  |  |
| 1141025 | Re-Baseline Actuals Adjustment | 2013-08-30 A | 2013-08-30 A |  | 0% → 100% | 20d → none | 9-130M FS+227d → none |  |
| 1141005RKC5 | FY06 Obligations RKC | 2006-10-02 A | 2007-03-30 → 2007-02-23 A (-35d) | 120d → 95d | 0% → 100% | 333d → none |  |  |
| 1142020 | Continue exploration of alternative calorimeter designs (DTCTR) | 2006-10-02 → 2006-11-01 A (+30d) | 2007-07-17 → 2008-03-31 A (+258d) | 195d → 345d | 0% → 100% | 425d → none |  | resources TRAVEL; VISTNG USERS [1040 h] → VISTNG USERS [1040 h]; TRAVEL |
| 1142025 | In beam test of new prototype quartz hodoscope (DTCTR) | 2006-10-02 → 2007-05-15 A (+225d) | 2007-04-13 → 2007-12-07 A (+238d) | 130d → 144d | 0% → 100% | 353d → none |  | resources TRAVEL; PD UNIV STUDNT [320 h]; VISTNG USERS [1480 h]; PROCUREMENT<$50K 60; SCIENTIST [400 h] → PD UNIV STUDNT [320 h]; PROCUREMENT<$50K 60; VISTNG USERS [1480 h]; SCIENTIST [400 h]; TRAVEL |
| 1142030 | Test Blocks & PMT's and Map Out Optmal Placement (DTCTR) | 2008-04-08 → 2008-04-01 A (-7d) | 2008-07-09 → 2008-08-29 A (+51d) | 65d → 107d | 0% → 100% | 58d → none |  |  |
| 1142035 | Re-Baseline Actuals Adjustment | 2013-08-30 A | 2013-08-30 A |  | 0% → 100% | 20d → none | 9-130M FS+227d → none |  |
| 1152001RKC | FY06 Obligations RKC | 2006-10-02 A | 2007-03-30 → 2007-08-31 A (+154d) | 120d → 228d | 0% → 100% | 333d → none |  | resources PLABOR; PROCUREMENT>$50K 69; SUPPLIES & MATERIALS; PROCUREMENT<$50K 60 → PROCUREMENT<$50K 60; PROCUREMENT>$50K 69; SUPPLIES & MATERIALS; PLABOR |
| 1152015LOE | BCAL postdoc (DTCTR) | 2006-10-02 A | 2007-02-01 A |  | 0% → 100% | 591d → none |  |  |
| 1152005 | Drift chamber prototyping (DTCTR) | 2006-10-02 → 2006-11-01 A (+30d) | 2007-02-01 A | 80d → 58d | 0% → 100% | 206d → none |  |  |
| 1152010 | BCAL prototyping (DTCTR) | 2006-10-02 → 2006-11-01 A (+30d) | 2007-02-01 A | 80d → 58d | 0% → 100% | 462d → none |  |  |
| 1152020 | UPV prototyping (DTCTR) | 2006-10-02 → 2006-12-01 A (+60d) | 2007-09-28 → 2008-03-28 A (+182d) | 247d → 324d | 0% → 100% | 353d → none |  |  |
| 1152025 | CER prototyping (DTCTR) | 2006-10-02 → 2006-12-01 A (+60d) | 2007-02-01 A | 79d → 37d | 0% → 100% | 354d → none |  |  |
| 1152005A | Drift chamber prototyping (DTCTR) | 2007-02-02 → 2007-02-01 A (-1d) | 2007-09-28 A | 167d → 168d | 0% → 100% | 206d → none |  | resources MECH DES [520 h]; MECH ENG [1080 h]; PROCUREMENT<$50K 60; PD UNIV STAFF [360 h]; SCIENTIST [240 h]; ELEC DES [440 h] → PROCUREMENT<$50K 60; SCIENTIST [240 h]; MECH DES [520 h]; ELEC DES [440 h]; MECH ENG [1080 h]; PD UNIV STAFF [360 h] |
| 1152010A | BCAL prototyping (DTCTR) | 2007-02-02 → 2007-02-01 A (-1d) | 2007-10-01 → 2007-09-28 A (-3d) |  | 0% → 100% | 462d → none |  |  |
| 1152015LOEA | BCAL postdoc (DTCTR) | 2007-02-01 A | 2007-03-30 → 2007-05-01 A (+32d) | 40d → 62d | 0% → 100% | 591d → none |  |  |
| 1152025A | CER prototyping (DTCTR) | 2007-02-01 A | 2007-09-28 → 2007-08-31 A (-28d) | 167d → 149d | 0% → 100% | 354d → none |  |  |
| 1152030 | FY08 DC Chamb Prototypng (H-D DETCTR) | 2007-11-07 → 2007-10-01 A (-37d) | 2008-09-29 → 2008-09-30 A (+1d) | 220d → 247d | 0% → 100% | 1d → none |  | resources CONTRB UNIV LBR [1160 h]; SCIENTIST [1440 h] → SCIENTIST [1440 h]; CONTRB UNIV LBR [1160 h] |
| 1152035 | CDC University Supprt (H-D DETCTR) | 2007-11-07 → 2007-10-01 A (-37d) | 2008-09-29 → 2008-09-30 A (+1d) | 220d → 248d | 0% → 100% | 1d → none |  |  |
| 1152945LOE | FY08 UPV University Supprt (H-D DETCTR) | 2007-10-01 A | 2008-09-30 → 2008-03-31 A (-183d) | 248d → 120d | 0% → 100% | 0d → none |  |  |
| 1152040 | BCAL Evaluation & Testing of Module 2 (H-D DETCTR) | 2007-10-01 → 2007-11-01 A (+31d) | 2008-03-24 → 2008-06-30 A (+98d) | 115d → 161d | 0% → 100% | 42d → none |  |  |
| 1152055 | Invstg common solutn for Gain Monitrng/Calibr Sys in H-D for Calirim's & TOF | 2008-03-03 → 2008-04-01 A (+29d) | 2008-09-30 → 2009-02-04 A (+127d) | 149d → 210d | 0% → 100% | 0d → none |  | resources PROCUREMENT<$50K 60; SCIENTIST [113.6 h] → SCIENTIST [113.6 h]; PROCUREMENT<$50K 60 |
| 1152060 | Re-Baseline Actuals Adjustment | 2013-08-30 A | 2013-08-30 A |  | 0% → 100% | 20d → none | 9-130M FS+227d → none |  |
| 1154001RKC | FY06 Obligations RKC | 2006-10-02 A | 2007-03-30 → 2006-11-30 A (-120d) | 120d → 42d | 0% → 100% | 333d → none |  |  |
| 1154010 | Trigger development (ELCTRNICS) | 2006-10-02 A | 2007-02-01 A |  | 0% → 100% | 454d → none |  |  |
| 1154005 | FADC development (ELCTRNICS) | 2006-10-02 → 2006-11-01 A (+30d) | 2007-02-01 A | 79d → 57d | 0% → 100% | 114d → none |  |  |
| 1154005A | FADC development (ELCTRNICS) | 2007-02-02 → 2007-02-01 A (-1d) | 2007-09-28 → 2008-01-31 A (+125d) | 167d → 247d | 0% → 100% | 113d → none |  |  |
| 1154010A | Trigger development (ELCTRNICS) | 2007-02-02 → 2007-03-01 A (+27d) | 2007-09-28 A | 167d → 149d | 0% → 100% | 453d → none |  | resources VISTNG USERS [1559.2 h]; PROCUREMENT<$50K 60; SCIENTIST [648 h] → SCIENTIST [648 h]; VISTNG USERS [1559.2 h]; PROCUREMENT<$50K 60 |
| 1154020 | Develop a Clock Distrbtn Sys to FADC Boards (Electrnc's) | 2007-10-01 A | 2008-01-10 → 2008-07-11 A (+183d) | 65d → 192d | 0% → 100% | 23d → none |  |  |
| 1154025 | Develop Clock Distrbtn for TDCs (Electrnc's) | 2007-10-01 A | 2008-04-14 → 2008-08-29 A (+137d) | 130d → 227d | 0% → 100% | 76d → none |  |  |
| 1154035 | Collection of Track Counts into Trigger (Electrnc's) | 2007-10-01 A | 2008-04-14 → 2008-08-29 A (+137d) | 130d → 227d | 0% → 100% | 3d → none |  |  |
| 1154045 | Develop Signal Distrbtn to All Crates (Electrnc's) | 2007-10-01 A | 2008-04-14 → 2008-07-15 A (+92d) | 130d → 194d | 0% → 100% | 118d → none |  |  |
| 1154050 | Evaluate Backplane Use of Crates for Dataways, especially FADCs (Electrnc's) | 2007-10-01 → 2007-11-01 A (+31d) | 2008-04-14 → 2008-08-29 A (+137d) | 130d → 204d | 0% → 100% | 118d → none |  |  |
| 1154015 | Logic & HV Supprt (Electrnc's) | 2007-10-01 → 2007-12-03 A (+63d) | 2008-08-20 → 2008-08-29 A (+9d) | 220d → 184d | 0% → 100% | 3d → none |  |  |
| 1154030 | Collection of Energy Sums into Trigger (Electrnc's) | 2008-01-11 → 2008-01-31 A (+20d) | 2008-07-16 → 2008-08-29 A (+44d) | 130d → 149d | 0% → 100% | 23d → none |  |  |
| 1154040 | Proto Dsgn for Master Trigger (Electrnc's) | 2008-03-25 → 2008-04-01 A (+7d) | 2008-09-25 A | 130d → 125d | 0% → 100% | 3d → none |  |  |
| 1154055 | Specify HV & Low Voltage Supplies (Electrnc's) | 2008-06-25 → 2008-06-30 A (+5d) | 2008-09-25 → 2008-09-24 A (-1d) | 65d → 61d | 0% → 100% | 3d → none |  |  |
| 1154060 | Specify Discriminators & Logic for DAQ/Trigger Integration (Electrnc's) | 2008-06-25 → 2008-06-30 A (+5d) | 2008-09-25 → 2008-09-24 A (-1d) | 65d → 61d | 0% → 100% | 3d → none |  |  |
| 1154065 | Re-Baseline Actuals Adjustment | 2013-08-30 A | 2013-08-30 A |  | 0% → 100% | 20d → none | 9-130M FS+227d → none |  |
| 1155001RKC | FY06 Obligations RKC | 2006-10-02 A | 2007-03-30 → 2007-03-21 A (-9d) | 120d → 113d | 0% → 100% | 333d → none |  |  |
| 1155005 | Hodoscope prototyping (BEAMLINE) | 2006-10-02 A | 2007-02-01 A |  | 0% → 100% | 174d → none |  |  |
| 1155010 | Conduct Diamond studies (BEAMLINE) | 2006-10-02 → 2007-01-15 A (+105d) | 2007-02-01 A | 80d → 13d | 0% → 100% | 133d → none |  |  |
| 1155010A | Conduct Diamond studies (BEAMLINE) | 2007-02-02 A | 2007-09-28 → 2008-08-29 A (+336d) | 167d → 394d | 0% → 100% | 133d → none |  | resources PD UNIV STUDNT [580 h]; PROCUREMENT<$50K 60 → PROCUREMENT<$50K 60; PD UNIV STUDNT [580 h] |
| 1155005A | Hodoscope prototyping (BEAMLINE) | 2007-02-02 → 2007-03-30 A (+56d) | 2007-09-28 → 2008-07-01 A (+277d) | 167d → 313d | 0% → 100% | 173d → none |  |  |
| 1155015 | Proto SiPM Readout for Microscope (BL) | 2007-10-01 → 2007-11-01 A (+31d) | 2008-01-03 → 2008-08-29 A (+239d) | 60d → 204d | 0% → 100% | 86d → none |  |  |
| 1155030 | Check Current Sensitivity of Active Collimator Electrnc's (BL) | 2007-10-01 → 2007-11-01 A (+31d) | 2008-01-03 → 2008-08-29 A (+239d) | 60d → 204d | 0% → 100% | 146d → none |  |  |
| 1155020 | Proto Microscope Mounting Frame (BL) | 2008-01-04 → 2008-04-01 A (+88d) | 2008-03-31 → 2008-09-24 A (+177d) | 60d → 124d | 0% → 100% | 86d → none |  |  |
| 1155025 | Proto Mounting Schemes for Thin Crystals (BL) | 2007-10-01 → 2008-05-01 A (+213d) | 2008-01-03 → 2008-10-31 A (+302d) | 60d → 129d | 0% → 100% | 146d → none |  |  |
| 1155035 | Re-Baseline Actuals Adjustment | 2013-08-30 A | 2013-08-30 A |  | 0% → 100% | 20d → none | 9-130M FS+227d → none |  |
| 1161000 | Re-Baseline Actuals Adjustment | 2013-08-30 A | 2013-08-30 A |  | 0% → 100% | 20d → none | 9-130M FS+227d → none |  |
| 117000LOE | FY07 R&D Project Management | 2006-10-02 A | 2007-09-28 A |  | 0% → 100% | 0d → none |  | resources OFFICE [880 h]; ELEC ENG [360 h]; DIRECTORATE [148 h]; ADMIN [1760 h]; MECH ENG [140 h]; SR STAFF [148 h] → SR STAFF [148 h]; ADMIN [1760 h]; OFFICE [880 h]; ELEC ENG [360 h]; DIRECTORATE [148 h]; MECH ENG [140 h] |
| 117908LOE | FY08 R&D Project Management | 2007-10-01 A | 2008-09-30 A |  | 0% → 100% | 0d → none |  | resources SR STAFF [598.4 h]; SCIENTIST [246.4 h]; ADMIN [880 h]; OFFICE [880 h]; MECH ENG [352 h] → ADMIN [880 h]; OFFICE [880 h]; MECH ENG [352 h]; SR STAFF [598.4 h]; SCIENTIST [246.4 h] |
| 117910 | Re-Baseline Actuals Adjustment | 2013-08-30 A | 2013-08-30 A |  | 0% → 100% | 20d → none | 9-130M FS+227d → none |  |
| 1211005M5 | FY07 Internal Intermediate Design and Safety Review | 2007-06-25 → 2007-05-21 A (-35d) | 2007-06-25 → 2007-05-21 A (-35d) |  | 0% → 100% | 315d → none |  |  |
| 1211020M | FY09 Cvity String Pre-Construction Dsgn & Stfy Review for CM | 2009-04-28 → 2008-10-20 A (-190d) | 2009-04-28 → 2008-10-20 A (-190d) |  | 0% → 100% | 108d → none | 121116020M, 121111010M, 121113010M, 121115010M → 121116020M FS+20d, 121113010M, 121115010M, 121111010M |  |
| 1211020M5 | FY09 Space Frame Pre-construction Dsgn & Sfty Review for CM | 2009-09-29 → 2008-11-14 A (-319d) | 2009-09-29 → 2008-11-14 A (-319d) |  | 0% → 100% | 1d → none |  |  |
| 1211020M10 | FY09 Cryomodule Pre-construction Dsgn & Sfty Review for CM | 2009-09-29 → 2009-10-02 A (+3d) | 2009-09-29 → 2009-10-02 A (+3d) |  | 0% → 100% | -24d → none |  |  |
| 1211020M15 | FY09 Cryomodule Misc Pre-construction Dsgn & Sfty Review for CM | 2009-09-29 → 2010-02-25 A (+149d) | 2009-09-29 → 2010-02-25 A (+149d) |  | 0% → 100% | 1d → none |  |  |
| 1 | **1.2.1.1.1 CAVITY STRING ASSEMBLY** | 2007-08-15 → 2007-06-04 (-72d) |  |  |  |  |  |  |
| 1 | **1.2.1.1.1.1 CAVITIES** | 2007-11-12 → 2007-12-03 (+21d) |  |  |  |  |  |  |
| 121111005 | FY08 Final Dsgn Cavity | 2007-11-12 → 2007-12-03 A (+21d) | 2008-06-10 → 2008-06-30 A (+20d) |  | 0% → 100% | 36d → none |  | resources MECH ENG [40 h]; MECH DES [80 h]; ELEC ENG [40 h]; SR STAFF [80 h]; SCIENTIST [40 h]; OFFICE [40 h] → SCIENTIST [40 h]; OFFICE [40 h]; SR STAFF [80 h]; MECH ENG [40 h]; MECH DES [80 h]; ELEC ENG [40 h] |
| 121111010M | FY08 Final Dsgn Comptd for Cavity | 2008-06-10 → 2008-06-30 A (+20d) | 2008-06-10 → 2008-06-30 A (+20d) |  | 0% → 100% | 36d → none |  |  |
| 121111015 | Re-Baseline Actuals Adjustment | 2013-08-30 A | 2013-08-30 A |  | 0% → 100% | 20d → none | 9-130M FS+227d → none |  |
| 3 | **1.2.1.1.1.3 FUNDAMENTAL POWER COUPLER** | 2008-03-13 → 2007-12-03 (-101d) |  |  |  |  |  |  |
| 121113005 | FY08 Final Dsgn FPC | 2008-03-13 → 2007-12-03 A (-101d) | 2008-09-29 → 2008-06-30 A (-91d) |  | 0% → 100% | 230d → none | 9-080M FS+107d → 9-080M FS+50d | resources MECH DES [120 h]; OFFICE [40 h]; SR STAFF [40 h]; SCIENTIST [40 h]; MECH TECH [80 h]; MECH ENG [80 h] → SCIENTIST [40 h]; OFFICE [40 h]; MECH ENG [80 h]; MECH DES [120 h]; SR STAFF [40 h]; MECH TECH [80 h] |
| 121113010M | FY08 Final Dsgn Comptd for FPC | 2008-09-29 → 2008-06-30 A (-91d) | 2008-09-29 → 2008-06-30 A (-91d) |  | 0% → 100% | 249d → none |  |  |
| 121113015 | Re-Baseline Actuals Adjustment | 2013-08-30 A | 2013-08-30 A |  | 0% → 100% | 20d → none | 9-130M FS+227d → none |  |
| 4 | **1.2.1.1.1.4 MISC. CAVITY STRING COMPONENTS** | 2009-03-04 → 2008-01-14 (-415d) |  |  |  |  |  |  |

| ID | Task | Start | Finish | Duration | Complete | Total float | Predecessors | Other |
| --- | --- | --- | --- | --- | --- | --- | --- | --- |
| 121114005 | Final Dsgn, Misc Cavity String Components | 2009-03-04 → 2008-01-14 A (-415d) | 2009-09-18 → 2009-01-26 A (-235d) | 140d → 257d | 0% → 100% | 8d → none | 121111010M, 9-090M FS+100d → 121111010M |  |
| 121114010M | FY09 Final Dsgn Comptd for Misc Cavity String Components | 2009-09-18 → 2009-01-26 A (-235d) | 2009-09-18 → 2009-01-26 A (-235d) |  | 0% → 100% | 8d → none |  |  |
| 121114015 | Re-Baseline Actuals Adjustment | 2013-08-30 A | 2013-08-30 A |  | 0% → 100% | 20d → none | 9-130M FS+227d → none |  |
| 5 | **1.2.1.1.1.5 HOM/FIELD PROBES** | 2007-10-01 → 2007-12-03 (+63d) |  |  |  |  |  |  |
| 121115005 | Final Dsgn HOM/Field Probes | 2007-10-01 → 2007-12-03 A (+63d) | 2008-04-28 → 2008-06-30 A (+63d) |  | 0% → 100% | 356d → none |  | resources MECH DES [80 h]; MECH ENG [40 h]; SR STAFF [40 h]; ELEC ENG [40 h]; SCIENTIST [40 h]; MECH TECH [80 h] → MECH TECH [80 h]; MECH ENG [40 h]; SR STAFF [40 h]; SCIENTIST [40 h]; ELEC ENG [40 h]; MECH DES [80 h] |
| 121115010M | FY08 Final Dsgn Comptd for HOM/Field Probes | 2008-04-28 → 2008-06-30 A (+63d) | 2008-04-28 → 2008-06-30 A (+63d) |  | 0% → 100% | 356d → none |  |  |
| 121115015 | Re-Baseline Actuals Adjustment | 2013-08-30 A | 2013-08-30 A |  | 0% → 100% | 20d → none | 9-130M FS+227d → none |  |
| 6 | **1.2.1.1.1.6 HELIUM VESSELS** | 2007-08-15 → 2007-06-04 (-72d) |  |  |  |  |  |  |
| 121116005 | Design Helium Headers Preliminary (HELIUM VESSLS) | 2007-08-15 → 2007-06-04 A (-72d) | 2007-09-25 → 2007-08-27 A (-29d) | 28d → 59d | 0% → 100% | 97d → none |  |  |
| 121116010 | Design Helium Headers Initial Phase Final Design (HELIUM VESSLS) | 2008-11-26 → 2007-08-06 A (-478d) | 2008-12-15 → 2007-09-28 A (-444d) | 12d → 39d | 0% → 100% | 7d → none | 9-090M FS+40d, 121133010, 121124010 → 121124010, 121133010 | resources MECH ENG [20.88 h]; MECH DES [10.44 h] → MECH DES [10.44 h]; MECH ENG [20.88 h] |
| 121116015 | Final Phase Final Dsgn, Helium Headers | 2008-10-01 → 2007-12-03 A (-303d) | 2009-04-28 → 2008-09-30 A (-210d) | 140d → 205d | 0% → 100% | 108d → none | 9-090M → 9-080M | resources MECH ENG [40 h]; MECH DES [40 h]; SUPPLIES & MATERIALS → MECH DES [40 h]; SUPPLIES & MATERIALS; MECH ENG [40 h] |
| 121116020M | FY09 Final Dsgn Comptd for Helium Headers | 2009-04-28 → 2008-09-30 A (-210d) | 2009-04-28 → 2008-09-30 A (-210d) |  | 0% → 100% | 108d → none |  | was named FY08 Final Dsgn Comptd for Helium Headers |
| 121116025 | Re-Baseline Actuals Adjustment | 2013-08-30 A | 2013-08-30 A |  | 0% → 100% | 20d → none | 9-130M FS+227d → none |  |
| 1 | **1.2.1.1.2.1 TUNER ASSEMBLY** | 2009-03-13 → 2007-08-06 (-585d) |  |  |  |  |  |  |
| 121121005 | Final Dsgn, Tuner | 2009-03-13 → 2007-08-06 A (-585d) | 2009-09-29 → 2008-08-15 A (-410d) | 140d → 256d | 0% → 100% | 1d → none | 9-090M FS+107d → 9-080M | resources MECH TECH [160 h]; SUPPLIES & MATERIALS; SR STAFF [40 h]; OFFICE [40 h]; MSHOP; MECH ENG [40 h]; MECH DES [80 h]; ELEC ENG [40 h] → MECH ENG [40 h]; MECH DES [80 h]; ELEC ENG [40 h]; MECH TECH [160 h]; SUPPLIES & MATERIALS; SR STAFF [40 h]; OFFICE [40 h]; MSHOP |
| 121121010M | FY09 Final Dsgn Comptd for Tuner | 2009-09-29 → 2008-08-15 A (-410d) | 2009-09-29 → 2008-08-15 A (-410d) |  | 0% → 100% | 1d → none |  | was named FY08 Final Dsgn Comptd for Tuner |
| 121121015 | Re-Baseline Actuals Adjustment | 2013-08-30 A | 2013-08-30 A |  | 0% → 100% | 20d → none | 9-130M FS+227d → none |  |
| 2 | **1.2.1.1.2.2 HEADER ASSEMBLY, SUPPLY & RETURN** | 2008-10-01 → 2007-08-13 (-415d) |  |  |  |  |  |  |
| 121122005 | Final Dsgn, Header Assy (Supply & Return) | 2008-10-01 → 2007-08-13 A (-415d) | 2009-04-28 → 2007-09-28 A (-578d) | 140d → 34d | 0% → 100% | 108d → none |  |  |
| 121122010M | FY09 Final Dsgn Comptd for Header Assy (Supply & Return) | 2009-04-28 → 2007-09-28 A (-578d) | 2009-04-28 → 2007-09-28 A (-578d) |  | 0% → 100% | 108d → none |  | was named FY08 Final Dsgn Comptd for Header Assy (Supply & Return) |
| 121122015 | Re-Baseline Actuals Adjustment | 2013-08-30 A | 2013-08-30 A |  | 0% → 100% | 20d → none | 9-130M FS+227d → none |  |
| 3 | **1.2.1.1.2.3 MAGNETIC SHIELD ASSEMBLY** | 2008-10-01 → 2007-10-01 (-366d) |  |  |  |  |  |  |
| 121123005 | Final Dsgn, Magnetic Shield | 2009-01-05 → 2007-10-01 A (-462d) | 2009-07-23 → 2008-09-30 A (-296d) | 140d → 248d | 0% → 100% | 48d → none | 9-090M FS+60d → 9-080M | resources OFFICE [40 h]; MECH DES [80 h]; MECH ENG [40 h]; SUPPLIES & MATERIALS; SR STAFF [40 h] → SUPPLIES & MATERIALS; SR STAFF [40 h]; OFFICE [40 h]; MECH ENG [40 h]; MECH DES [80 h] |
| 121123010M | FY09 Final Dsgn Comptd for Magnetic Shield | 2009-07-23 → 2008-09-30 A (-296d) | 2009-07-23 → 2008-09-30 A (-296d) |  | 0% → 100% | 48d → none |  | was named FY08 Final Dsgn Comptd for Magnetic Shield |
| 131133010XD | Prcrmnt Prep for Magnetic Shield | 2008-10-01 → 2008-11-03 A (+33d) | 2008-12-24 → 2009-01-26 A (+33d) | 59d → 52d | 0% → 100% | 101d → none |  |  |
| 121123015 | Re-Baseline Actuals Adjustment | 2013-08-30 A | 2013-08-30 A |  | 0% → 100% | 20d → none | 9-130M FS+227d → none |  |
| 4 | **1.2.1.1.2.4 THERMAL SHEILD ASSEMBLY, MLI BLANKETS 2&** | 2007-07-06 → 2007-07-02 (-4d) |  |  |  |  |  |  |
| 121124005 | Design Thermal Shield Preliminary (THRML SHLD) | 2007-07-06 → 2007-07-02 A (-4d) | 2007-08-15 → 2007-11-30 A (+107d) | 28d → 105d | 0% → 100% | 97d → none | 121135005, 121131005 → 121131005 | resources MECH ENG [97.44 h]; MECH DES [48.72 h] → MECH DES [48.72 h]; MECH ENG [97.44 h] |
| 121124010 | Design Thermal Shield Initial Phase Final Design (THRML SHLD) | 2008-07-03 → 2008-01-17 A (-168d) | 2008-07-21 → 2008-02-08 A (-164d) | 12d → 16d | 0% → 100% | 97d → none |  | resources MECH DES [41.76 h]; MECH ENG [20.88 h] → MECH ENG [20.88 h]; MECH DES [41.76 h] |
| 121124015 | Dsgn Thermal Shield, Final Phase Final Dsgn | 2008-10-01 → 2008-02-11 A (-233d) | 2009-04-28 → 2008-02-15 A (-438d) | 140d → 5d | 0% → 100% | 108d → none |  |  |
| 121124020M | FY09 Final Dsgn Comptd for Thermal Shield | 2009-04-28 → 2008-06-02 A (-330d) | 2009-04-28 → 2008-06-02 A (-330d) |  | 0% → 100% | 108d → none |  | was named FY08 Final Dsgn Comptd for Thermal Shield |
| 121124025 | Re-Baseline Actuals Adjustment | 2013-08-30 A | 2013-08-30 A |  | 0% → 100% | 20d → none | 9-130M FS+227d → none |  |
| 5 | **1.2.1.1.2.5 SEALS & MISC. SPACE FRAME COMPONENTS** | 2008-03-26 → 2007-06-01 (-299d) |  |  |  |  |  |  |
| 121125005 | Design Seals & Misc Space Frame Preliminary (SEALS) | 2008-03-26 → 2007-06-01 A (-299d) | 2008-05-05 → 2008-02-13 A (-82d) | 28d → 171d | 0% → 100% | 97d → none |  |  |
| 121125010 | Design Seals & Misc Space Frame Initial Phase Final Design (SEALS) | 2008-12-16 → 2008-03-17 A (-274d) | 2009-01-08 → 2008-03-21 A (-293d) | 12d → 5d | 0% → 100% | 7d → none |  |  |
| 121125015 | Final Phase Final Dsgn, Seals & Misc Space Frame | 2009-03-13 → 2008-03-24 A (-354d) | 2009-09-29 → 2008-11-14 A (-319d) | 140d → 167d | 0% → 100% | 1d → none | 9-090M FS+107d → 9-090M | resources MECH ENG [160 h]; MECH DES [160 h]; ELEC ENG [80 h]; MECH TECH [40 h] → MECH TECH [40 h]; MECH ENG [160 h]; ELEC ENG [80 h]; MECH DES [160 h] |
| 121125020M | FY09 Final Dsgn Comptd for Seals & Misc Space Frame | 2009-09-29 → 2008-11-14 A (-319d) | 2009-09-29 → 2008-11-14 A (-319d) |  | 0% → 100% | 1d → none |  | was named FY08 Final Dsgn Comptd for Seals & Misc Space Frame |
| 121125025 | Re-Baseline Actuals Adjustment | 2013-08-30 A | 2013-08-30 A |  | 0% → 100% | 20d → none | 9-130M FS+227d → none |  |
| 121126005 | Design Space Frame Preliminary (SPC FRM) | 2006-10-02 A | 2007-06-29 A |  | 0% → 100% | 97d → none |  | resources MECH DES [48.72 h]; MECH ENG [146.16 h] → MECH ENG [146.16 h]; MECH DES [48.72 h] |
| 121126010 | Design Space Frame Initial Phase Final Design (SPC FRM) | 2008-06-13 → 2007-09-03 A (-284d) | 2008-07-01 → 2007-11-30 A (-214d) | 12d → 61.5d | 0% → 100% | 97d → none |  |  |
| 121126015 | Final Phase Final Dsgn, Space Frame | 2009-02-03 → 2007-12-03 A (-428d) | 2009-08-20 → 2008-09-30 A (-324d) | 140d → 205d | 0% → 100% | 28d → none | 9-090M FS+80d → 9-090M | resources OFFICE [40 h]; MECH DES [240 h]; MECH ENG [160 h]; MECH TECH [40 h]; SR STAFF [40 h] → MECH ENG [160 h]; SR STAFF [40 h]; OFFICE [40 h]; MECH TECH [40 h]; MECH DES [240 h] |
| 121126020M | FY09 Final Dsgn Comptd for Space Frame | 2009-08-20 → 2008-09-30 A (-324d) | 2009-08-20 → 2008-09-30 A (-324d) |  | 0% → 100% | 28d → none |  | was named FY08 Final Dsgn Comptd for Space Frame |
| 121126025 | Re-Baseline Actuals Adjustment | 2013-08-30 A | 2013-08-30 A |  | 0% → 100% | 20d → none | 9-130M FS+227d → none |  |
| 3 | **1.2.1.1.3 CRYOMODULE ASSEMBLY** | 2006-10-02 → 2007-06-04 (+245d) |  |  |  |  |  |  |
| 1 | **1.2.1.1.3.1 ALIGNMENT FIDUCIALS** | 2007-07-02 → 2008-01-07 (+189d) |  |  |  |  |  |  |
| 121131005 | Design Alignment Fiducials Preliminary (ALGNMT FIDUCLS) | 2007-07-02 → 2008-01-07 A (+189d) | 2007-07-06 → 2008-04-04 A (+273d) | 3.5d → 62.5d | 0% → 100% | 97d → none |  |  |
| 121131010 | Design Alignment Fiducials Initial Phase Final Design (ALGNMT FIDUCLS) | 2008-07-01 → 2008-04-01 A (-91d) | 2008-07-02 → 2008-04-30 A (-63d) | 1.5d → 21.5d | 0% → 100% | 97d → none |  | resources MECH ENG [10.44 h]; MECH DES [10.44 h] → MECH DES [10.44 h]; MECH ENG [10.44 h] |
| 121131015 | Final Phase Final Dsgn, Alignment Fiducials | 2008-10-01 → 2008-08-15 A (-47d) | 2009-04-28 → 2008-09-30 A (-210d) | 140d → 32d | 0% → 100% | 83d → none |  |  |
| 121131020M | FY09 Final Dsgn Comptd for Alignment Fiducials | 2009-04-28 → 2008-09-30 A (-210d) | 2009-04-28 → 2008-09-30 A (-210d) |  | 0% → 100% | 83d → none |  | was named FY08 Final Dsgn Comptd for Alignment Fiducials |
| 121131025 | Re-Baseline Actuals Adjustment | 2013-08-30 A | 2013-08-30 A |  | 0% → 100% | 20d → none | 9-130M FS+227d → none |  |
| 2 | **1.2.1.1.3.2 VACUUM TANK ASSEMBLY** | 2006-10-02 → 2007-07-02 (+273d) |  |  |  |  |  |  |
| 121132005 | Design Vacuum Tank Preliminary (VAC TNK ASSMBLY) | 2006-10-02 → 2007-07-02 A (+273d) | 2006-11-08 → 2007-09-28 A (+324d) | 28d → 63d | 0% → 100% | 253d → none |  | resources MECH DES [48.72 h]; MECH ENG [146.16 h] → MECH ENG [146.16 h]; MECH DES [48.72 h] |
| 121132010 | Design Vacuum Tank Initial Phase Final Design (VAC TNK ASSMBLY) | 2008-06-13 → 2007-09-03 A (-284d) | 2008-07-01 → 2007-11-30 A (-214d) | 12d → 61.5d | 0% → 100% | 97d → none |  | resources MECH ENG [62.64 h]; MECH DES [20.88 h] → MECH DES [20.88 h]; MECH ENG [62.64 h] |
| 121132015 | Final Phase Final Dsgn, Vac Tank | 2009-03-13 → 2007-12-03 A (-466d) | 2009-09-29 → 2008-09-30 A (-364d) | 140d → 205d | 0% → 100% | -24d → none | 9-090M FS+107d → 9-080M | resources MECH DES [160 h]; SR STAFF [40 h]; MECH TECH [40 h]; OFFICE [40 h]; MECH ENG [120 h] → MECH TECH [40 h]; OFFICE [40 h]; MECH ENG [120 h]; MECH DES [160 h]; SR STAFF [40 h] |
| 121132020M | FY09 Final Dsgn Comptd for Vac Tank | 2009-09-29 → 2008-09-30 A (-364d) | 2009-09-29 → 2008-09-30 A (-364d) |  | 0% → 100% | -24d → none |  | was named FY08 Final Dsgn Comptd for Vac Tank |
| 121132025 | Re-Baseline Actuals Adjustment | 2013-08-30 A | 2013-08-30 A |  | 0% → 100% | 20d → none | 9-130M FS+227d → none |  |
| 3 | **1.2.1.1.3.3 END CAN ASSEMBLY** | 2007-07-06 → 2007-09-10 (+66d) |  |  |  |  |  |  |
| 121133010 | Design End Cans Initial Phase Final Design (END CAN ASSMBLY) | 2008-07-03 → 2007-09-10 A (-297d) | 2008-07-21 → 2008-03-21 A (-122d) | 12d → 129d | 0% → 100% | 97d → none |  |  |
| 121133005 | Design End Cans Preliminary (END CAN ASSMBLY) | 2007-07-06 → 2007-09-10 A (+66d) | 2007-08-15 → 2007-09-28 A (+44d) | 28d → 14d | 0% → 100% | 97d → none | 121131005, 121135005 → 121131005 | resources MECH DES [48.72 h]; MECH ENG [146.16 h] → MECH ENG [146.16 h]; MECH DES [48.72 h] |
| 121133015 | Final Phase Final Dsgn, End Cans | 2008-10-01 → 2008-07-14 A (-79d) | 2009-04-28 → 2009-03-25 A (-34d) | 140d → 172d | 0% → 100% | 83d → none |  | resources ELEC ENG [40 h]; OFFICE [40 h]; MECH ENG [80 h]; MECH DES [160 h]; SR STAFF [40 h] → MECH DES [160 h]; MECH ENG [80 h]; SR STAFF [40 h]; ELEC ENG [40 h]; OFFICE [40 h] |
| 121133020M | FY09 Final Dsgn Comptd for End Cans | 2009-04-28 → 2009-03-25 A (-34d) | 2009-04-28 → 2009-03-25 A (-34d) |  | 0% → 100% | 83d → none |  | was named FY08 Final Dsgn Comptd for End Cans |
| 121133025 | Re-Baseline Actuals Adjustment | 2013-08-30 A | 2013-08-30 A |  | 0% → 100% | 20d → none | 9-130M FS+227d → none |  |
| 4 | **1.2.1.1.3.4 BEAM LINE ASSEMBLY WITHIN CM** | 2007-08-15 → 2008-02-06 (+175d) |  |  |  |  |  |  |
| 121134005 | Design Transition Beamline Preliminary (BEAMLINE ASSMBLY) | 2007-08-15 → 2008-02-06 A (+175d) | 2007-09-25 → 2008-04-16 A (+204d) | 28d → 49d | 0% → 100% | 97d → none |  | resources MECH DES [48.72 h]; MECH ENG [73.08 h] → MECH ENG [73.08 h]; MECH DES [48.72 h] |
| 121134010 | Design Transition Beamline Initial Phase Final Design (BEAMLINE ASSMBLY) | 2008-07-22 → 2008-04-07 A (-106d) | 2008-08-06 → 2008-05-19 A (-79d) | 12d → 31d | 0% → 100% | 97d → none |  | resources MECH ENG [31.32 h]; MECH DES [20.88 h] → MECH DES [20.88 h]; MECH ENG [31.32 h] |
| 121134015 | Final Phase Final Dsgn, Transition BL in CM | 2009-03-13 → 2008-05-20 A (-297d) | 2009-09-29 → 2008-10-20 A (-344d) | 140d → 107d | 0% → 100% | -24d → none | 9-090M FS+107d → 9-080M | resources SUPPLIES & MATERIALS; MECH ENG [80 h]; MECH DES [120 h]; ELEC ENG [80 h]; MECH TECH [80 h] → MECH ENG [80 h]; MECH DES [120 h]; SUPPLIES & MATERIALS; MECH TECH [80 h]; ELEC ENG [80 h] |
| 121134020M | FY09 Final Dsgn Comptd for Transition BL in CM | 2009-09-29 → 2008-10-20 A (-344d) | 2009-09-29 → 2008-10-20 A (-344d) |  | 0% → 100% | -24d → none |  | was named FY08 Final Dsgn Comptd for Transition BL in CM |
| 121134025 | Re-Baseline Actuals Adjustment | 2013-08-30 A | 2013-08-30 A |  | 0% → 100% | 20d → none | 9-130M FS+227d → none |  |
| 5 | **1.2.1.1.3.5 STANDS** | 2007-07-02 → 2008-07-01 (+365d) |  |  |  |  |  |  |
| 121135005 | Design Stands Preliminary (STANDS) | 2007-07-02 → 2008-07-01 A (+365d) | 2007-07-02 → 2008-07-01 A (+365d) | 0.7d → 1d | 0% → 100% | 99.8d → none |  | resources MECH ENG [24.36 h]; MECH DES [24.36 h] → MECH DES [24.36 h]; MECH ENG [24.36 h] |

| ID | Task | Start | Finish | Duration | Complete | Total float | Predecessors | Other |
| --- | --- | --- | --- | --- | --- | --- | --- | --- |
| 121135010 | Design Stands Initial Phase Final Design (STANDS) | 2008-07-01 A | 2008-07-01 → 2008-07-02 A (+1d) | 0.3d → 2d | 0% → 100% | 98.2d → none | 121126010, 121132010 → 121126010, 121132010, 121135005 |  |
| 121135015 | Final Phase Final Dsgn, Stands | 2009-03-11 → 2008-08-15 A (-208d) | 2009-09-25 → 2008-09-30 A (-360d) | 140d → 32d | 0% → 100% | -22d → none | 9-090M FS+105d → 9-090M | resources MECH ENG [40 h]; MECH DES [40 h] → MECH DES [40 h]; MECH ENG [40 h] |
| 121135020M | FY09 Final Dsgn Comptd for Stands | 2009-09-25 → 2008-09-30 A (-360d) | 2009-09-25 → 2008-09-30 A (-360d) |  | 0% → 100% | -22d → none |  | was named FY08 Final Dsgn Comptd for Stands |
| 121135025 | Re-Baseline Actuals Adjustment | 2013-08-30 A | 2013-08-30 A |  | 0% → 100% | 20d → none | 9-130M FS+227d → none |  |
| 6 | **1.2.1.1.3.6 WIRING INCL HOM & FP CABLES** | 2007-08-15 → 2008-02-06 (+175d) |  |  |  |  |  |  |
| 121136005 | Design Wiring Preliminary (WIRING) | 2007-08-15 → 2008-02-06 A (+175d) | 2007-09-25 → 2008-02-15 A (+143d) | 28d → 7d | 0% → 100% | 97d → none |  |  |
| 121136015 | Final Phase Final Dsgn, Wiring | 2009-03-13 → 2008-04-14 A (-333d) | 2009-09-29 → 2008-11-20 A (-313d) | 140d → 155d | 0% → 100% | -24d → none | 9-090M FS+107d → 9-080M | resources ELEC DES [120 h]; MECH DES [160 h]; MECH ENG [40 h]; ELEC ENG [80 h]; SUPPLIES & MATERIALS → ELEC DES [120 h]; MECH ENG [40 h]; MECH DES [160 h]; SUPPLIES & MATERIALS; ELEC ENG [80 h] |
| 121136010 | Design Wiring Initial Phase Final Design (WIRING) | 2008-07-22 → 2008-04-16 A (-97d) | 2008-08-06 → 2008-04-30 A (-98d) | 12d → 11d | 0% → 100% | 97d → none |  | resources MECH ENG [20.88 h]; MECH DES [10.44 h] → MECH DES [10.44 h]; MECH ENG [20.88 h] |
| 121136020M | FY09 Final Dsgn Comptd for Wiring | 2009-09-29 → 2008-11-20 A (-313d) | 2009-09-29 → 2008-11-20 A (-313d) |  | 0% → 100% | -24d → none |  | was named FY08 Final Dsgn Comptd for Wiring |
| 121136025 | Re-Baseline Actuals Adjustment | 2013-08-30 A | 2013-08-30 A |  | 0% → 100% | 20d → none | 9-130M FS+227d → none |  |
| 7 | **1.2.1.1.3.7 FEEDTHROUGHS INCL WARM/COLD HOM/FP** | 2008-03-26 → 2007-06-04 (-296d) |  |  |  |  |  |  |
| 121137005 | Design Feedthroughs Preliminary (FEEDTHRU) | 2008-03-26 → 2007-06-04 A (-296d) | 2008-05-05 → 2007-06-29 A (-311d) | 28d → 19d | 0% → 100% | 97d → none |  |  |
| 121137010 | Design Feedthroughs Initial Phase Final Design (FEEDTHRU) | 2008-12-16 → 2008-02-04 A (-316d) | 2009-01-08 → 2008-02-14 A (-329d) | 12d → 9d | 0% → 100% | 7d → none |  |  |
| 121137015 | Final Phase Final Dsgn, Feedthroughs | 2008-10-01 → 2008-03-17 A (-198d) | 2009-04-28 → 2009-01-26 A (-92d) | 140d → 214d | 0% → 100% | 83d → none | 9-090M → 9-080M | resources ELEC TECH [40 h]; MECH ENG [120 h]; MECH DES [320 h]; MECH TECH [160 h]; SUPPLIES & MATERIALS; ELEC ENG [40 h] → ELEC ENG [40 h]; ELEC TECH [40 h]; MECH ENG [120 h]; MECH DES [320 h]; MECH TECH [160 h]; SUPPLIES & MATERIALS |
| 121137020M | FY09 Final Dsgn Comptd for Feedthroughs | 2009-04-28 → 2009-01-26 A (-92d) | 2009-04-28 → 2009-01-26 A (-92d) |  | 0% → 100% | 83d → none |  | was named FY08 Final Dsgn Comptd for Feedthroughs |
| 121137025 | Re-Baseline Actuals Adjustment | 2013-08-30 A | 2013-08-30 A |  | 0% → 100% | 20d → none | 9-130M FS+227d → none |  |
| 8 | **1.2.1.1.3.8 HOM LOADS** | 2008-05-05 → 2008-02-04 (-91d) |  |  |  |  |  |  |
| 121138005 | Design HOM Loads Preliminary (HOM LOADS) | 2008-05-05 → 2008-02-04 A (-91d) | 2008-06-13 → 2008-02-12 A (-122d) | 28d → 6d | 0% → 100% | 97d → none |  | resources MECH DES [24.36 h]; MECH ENG [24.36 h] → MECH ENG [24.36 h]; MECH DES [24.36 h] |
| 121138010 | Design HOM Loads Initial Phase Final Design (HOM LOADS) | 2009-01-09 → 2008-03-10 A (-305d) | 2009-01-27 → 2008-03-21 A (-312d) | 12d → 10d | 0% → 100% | 7d → none |  |  |
| 121138015 | Final Phase Final Dsgn, HOM Loads | 2009-03-13 → 2008-05-20 A (-297d) | 2009-09-29 → 2009-07-17 A (-74d) | 140d → 289d | 0% → 100% | -24d → none | 121138010, 9-090M FS+107d → 121138010 | resources SUPPLIES & MATERIALS; MECH ENG [160 h]; MECH DES [160 h]; MECH TECH [160 h]; ELEC ENG [80 h]; SR STAFF [40 h]; SCIENTIST [80 h] → MECH ENG [160 h]; MECH DES [160 h]; MECH TECH [160 h]; ELEC ENG [80 h]; SCIENTIST [80 h]; SUPPLIES & MATERIALS; SR STAFF [40 h] |
| 121138025 | Computational Analysis | 2009-03-16 A | 2009-03-23 → 2009-07-07 A (+106d) | 5d → 80d | 0% → 100% | 74.5d → none |  |  |
| 121138030 | Fabricate Test Hardware | 2009-03-23 A | 2009-04-06 → 2009-03-30 A (-7d) | 10d → 5d | 0% → 100% | 74.5d → none |  | resources MECH DES [40 h]; MECH TECH [80 h]; SUPPLIES & MATERIALS; MECH ENG [40 h] → MECH ENG [40 h]; MECH DES [40 h]; MECH TECH [80 h]; SUPPLIES & MATERIALS |
| 121138035 | Measure (First) HOM Damping in VTA | 2009-04-06 → 2009-03-25 A (-12d) | 2009-04-20 A | 10d → 18d | 0% → 100% | 74.5d → none |  | resources COMP SCIENT [40 h]; SCIENTIST [80 h]; ELEC TECH [120 h]; MECH TECH [120 h]; ELEC ENG [80 h] → ELEC TECH [120 h]; MECH TECH [120 h]; COMP SCIENT [40 h]; SCIENTIST [80 h]; ELEC ENG [80 h] |
| 121138040 | Evaluate (First) Measurement results | 2009-04-20 → 2009-03-25 A (-26d) | 2009-04-27 → 2009-05-29 A (+32d) | 5d → 47d | 0% → 100% | 74.5d → none |  | resources SCIENTIST [80 h]; SR STAFF [40 h]; ELEC ENG [40 h] → SR STAFF [40 h]; SCIENTIST [80 h]; ELEC ENG [40 h] |
| 121138045 | Modify Test Hardware | 2009-04-27 → 2009-06-01 A (+35d) | 2009-05-11 → 2009-06-22 A (+42d) | 10d → 16d | 0% → 100% | 74.5d → none |  | resources MECH DES [40 h]; SUPPLIES & MATERIALS; MECH TECH [80 h]; MECH ENG [40 h] → MECH TECH [80 h]; MECH ENG [40 h]; MECH DES [40 h]; SUPPLIES & MATERIALS |
| 121138050 | Measure (Second) HOM Damping in VTA | 2009-05-11 → 2009-06-01 A (+21d) | 2009-05-26 → 2009-06-22 A (+27d) | 10d → 16d | 0% → 100% | 74.5d → none |  | resources ELEC TECH [120 h]; MECH TECH [120 h]; COMP SCIENT [40 h]; SCIENTIST [80 h]; ELEC ENG [80 h] → SCIENTIST [80 h]; ELEC ENG [80 h]; ELEC TECH [120 h]; MECH TECH [120 h]; COMP SCIENT [40 h] |
| 121138055 | Evaluate (Second) Measurement results | 2009-05-26 → 2009-06-01 A (+6d) | 2009-06-02 → 2009-06-22 A (+20d) | 5d → 16d | 0% → 100% | 74.5d → none |  | resources SR STAFF [40 h]; ELEC ENG [40 h] → ELEC ENG [40 h]; SR STAFF [40 h] |
| 121138060 | Document HOM damping results and final | 2009-06-02 → 2009-06-01 A (-1d) | 2009-06-16 → 2009-06-22 A (+6d) | 10d → 16d | 0% → 100% | 74.5d → none |  |  |
| 121138020M | FY09 Final Dsgn Comptd for HOM Loads | 2009-09-29 → 2009-07-17 A (-74d) | 2009-09-29 → 2009-07-17 A (-74d) |  | 0% → 100% | -24d → none |  | was named FY08 Final Dsgn Comptd for HOM Loads |
| 121138065 | Re-Baseline Actuals Adjustment | 2013-08-30 A | 2013-08-30 A |  | 0% → 100% | 20d → none | 9-130M FS+227d → none |  |
| 4 | **1.2.1.1.4 INSTALLATION & ASSEMBLY TOOLING** | 2008-10-01 → 2008-07-14 (-79d) |  |  |  |  |  |  |
| 12114000 | Final Dsgn of Installtn & Assy Tooling | 2008-10-01 → 2008-07-14 A (-79d) | 2009-04-28 → 2010-02-25 A (+303d) | 140d → 400d | 0% → 100% | 108d → none |  | resources MECH DES [320 h]; MECH ENG [160 h]; SUPPLIES & MATERIALS; MECH TECH [80 h] → MECH ENG [160 h]; MECH DES [320 h]; SUPPLIES & MATERIALS; MECH TECH [80 h] |
| 12114005M | FY09 Final Dsgn Comptd for Installtn & Assy Tooling | 2009-04-28 → 2010-02-25 A (+303d) | 2009-04-28 → 2010-02-25 A (+303d) |  | 0% → 100% | 108d → none |  | was named FY08 Final Dsgn Comptd for Installtn & Assy Tooling |
| 12114010 | Re-Baseline Actuals Adjustment | 2013-08-30 A | 2013-08-30 A |  | 0% → 100% | 20d → none | 9-130M FS+227d → none |  |
| 5 | **1.2.1.1.5 CRYOMODULE TEST INSTRUMENTATION & INTERLOCKS** | 2009-03-13 → 2008-07-14 (-242d) |  |  |  |  |  |  |
| 12115000 | Final Dsgn of Instrmenttn & Interlocks | 2009-03-13 → 2008-07-14 A (-242d) | 2009-09-29 → 2010-02-25 A (+149d) | 140d → 400d | 0% → 100% | 1d → none | 9-090M FS+107d → 9-090M | resources MECH DES [40 h]; MECH TECH [80 h]; SUPPLIES & MATERIALS; ELEC ENG [160 h]; ELEC DES [160 h]; ELEC TECH [80 h] → SUPPLIES & MATERIALS; ELEC ENG [160 h]; ELEC TECH [80 h]; MECH DES [40 h]; ELEC DES [160 h]; MECH TECH [80 h] |
| 12115005M | FY09 Final Dsgn Comptd for Instrmenttn & Interlocks | 2009-09-29 → 2010-02-25 A (+149d) | 2009-09-29 → 2010-02-25 A (+149d) |  | 0% → 100% | 1d → none |  | was named FY08 Final Dsgn Comptd for Instrmenttn & Interlocks |
| 12115010 | Re-Baseline Actuals Adjustment | 2013-08-30 A | 2013-08-30 A |  | 0% → 100% | 20d → none | 9-130M FS+227d → none |  |
| 1212111000M | Start Klystron PED effort (KLYSTRONS) | 2006-10-02 A | 2006-10-02 A |  | 0% → 100% | 0d → none |  |  |
| 1212111007LOE | FY07 Project administration (KLYSTRONS) | 2006-10-02 A | 2007-09-28 A |  | 0% → 100% | 0d → none |  |  |
| 1212111010 | Refine klystron specifications w/driver (KLYSTRONS) | 2006-10-02 A | 2007-03-02 → 2007-03-30 A (+28d) | 100d → 120d | 0% → 100% | 8d → none |  | resources ELEC ENG [52.2 h]; ELEC DES [69.6 h] → ELEC DES [69.6 h]; ELEC ENG [52.2 h] |
| 1212111020 | Update budgetary pricing through vendor requests (KLYSTRONS) | 2007-04-16 → 2007-03-15 A (-32d) | 2007-05-11 → 2007-04-23 A (-18d) | 20d → 28d | 0% → 100% | 8d → none |  |  |
| 1212111015M | Specifications revision complete (KLYSTRONS) | 2007-03-02 → 2007-04-02 A (+31d) | 2007-03-02 → 2007-04-02 A (+31d) |  | 0% → 100% | 8d → none |  |  |
| 1212111030 | Internal design & safety review of klystron specifications (KLYSTRONS) | 2007-03-05 → 2007-04-09 A (+35d) | 2007-03-16 → 2007-05-22 A (+67d) | 10d → 32d | 0% → 100% | 8d → none |  |  |
| 1212111045 | Revise costbook based on new pricing (KLYSTRONS) | 2007-05-14 → 2007-04-09 A (-35d) | 2007-05-18 → 2007-04-23 A (-25d) | 5d → 11d | 0% → 100% | 8d → none |  |  |
| 1212111025M | Budgetary pricing received from vendors (KLYSTRONS) | 2007-05-11 → 2007-04-23 A (-18d) | 2007-05-11 → 2007-04-23 A (-18d) |  | 0% → 100% | 8d → none |  |  |
| 1212111035M | Preliminary internal design & safety review complete (KLYSTRONS) | 2007-03-16 → 2007-05-22 A (+67d) | 2007-03-16 → 2007-05-22 A (+67d) |  | 0% → 100% | 8d → none |  |  |
| 1212111040 | Revise preliminary klystron specifications per design & safety review (KLYSTRONS) | 2007-03-19 → 2007-05-23 A (+65d) | 2007-04-13 → 2007-06-28 A (+76d) | 20d → 26d | 0% → 100% | 8d → none |  |  |
| 1212111055 | Begin final design (FY07 continuing into FY08) (KLYSTRONS) | 2007-05-21 → 2007-05-28 A (+7d) | 2007-09-28 → 2007-08-20 A (-39d) | 92d → 58d | 0% → 100% | 8d → none |  |  |
| 1212111050M | Klystron preliminary design complete (KLYSTRONS) | 2007-05-18 → 2007-08-01 A (+75d) | 2007-05-18 → 2007-08-01 A (+75d) |  | 0% → 100% | 8d → none |  |  |
| 1212111070 | Develop Final Klystron Spec's (Klystrons) | 2007-10-01 A | 2008-01-03 → 2008-04-25 A (+113d) | 60d → 139d | 0% → 100% | 8d → none |  | resources ELEC TECH [80 h]; TRAVEL; ELEC DES [44 h] → ELEC TECH [80 h]; ELEC DES [44 h]; TRAVEL |
| 1212111908LOE | FY08 Proj Admin (Klystrons) | 2007-10-01 A | 2008-09-30 A |  | 0% → 100% | 0d → none |  |  |
| 1212111075 | Write Final Rquirmnts/Prcrmnt Packages (Klystrons) | 2008-01-04 → 2008-01-14 A (+10d) | 2008-03-31 → 2008-06-17 A (+78d) | 60d → 108d | 0% → 100% | 8d → none |  | resources ELEC ENG [48 h]; SUPPLIES & MATERIALS → SUPPLIES & MATERIALS; ELEC ENG [48 h] |
| 1212111080M | Comp klystron PED 2008 (KLYSTRONS) | 2008-03-31 → 2008-06-17 A (+78d) | 2008-03-31 → 2008-06-17 A (+78d) |  | 0% → 100% | 81d → none |  |  |
| 1212111170 | Pre-Constrctn Dsgn Review (Klystrons) | 2008-04-01 → 2008-07-01 A (+91d) | 2008-04-07 → 2008-07-07 A (+91d) | 5d → 4d | 0% → 100% | 81d → none |  |  |
| 1212111085 | Release Prcrmnt Package for Klystron Solicitation (Klystrons) | 2008-04-01 → 2008-08-06 A (+127d) | 2008-05-27 → 2008-08-29 A (+94d) | 40d → 18d | 0% → 100% | 8d → none | 1212111075 → 1212111075 FS+35d | resources ELEC DES [40 h]; ELEC ENG [8 h]; SUPPLIES & MATERIALS → SUPPLIES & MATERIALS; ELEC DES [40 h]; ELEC ENG [8 h] |
| 1212111100 | Eng-Receive & Evaluate Klystron Proposals (Klystrons) | 2008-05-28 → 2008-10-01 A (+126d) | 2008-06-10 → 2008-11-26 A (+169d) | 10d → 41d | 0% → 100% | 8d → none |  |  |
| 1212111110 | Des-Receive & Evaluate Klystron Proposals (Klystrons) | 2008-06-11 → 2008-10-15 A (+126d) | 2008-06-24 → 2008-12-22 A (+181d) | 10d → 47d | 0% → 100% | 8d → none | 1212111100 → 1212111100 FS-10d |  |
| 1212111115 | Release Best & Final for Klystrons (Klystrons) | 2008-08-07 → 2009-02-11 A (+188d) | 2008-09-04 → 2009-02-20 A (+169d) | 20d → 7d | 0% → 100% | 8d → none |  |  |
| 1212111120 | Final Klystron Evaluation (Klystrons)+ | 2008-09-05 → 2009-02-23 A (+171d) | 2008-09-18 → 2009-03-23 A (+186d) | 10d → 21d | 0% → 100% | 8d → none |  |  |
| 1212111175 | Re-Baseline Actuals Adjustment | 2013-08-30 A | 2013-08-30 A |  | 0% → 100% | 20d → none | 9-130M FS+227d → none |  |
| 1212112000M | FY07 Begin DC Power PED efforts (DC POWER) | 2006-10-02 A | 2006-10-02 A |  | 0% → 100% | 160d → none |  |  |
| 1212112005 | Develop preliminary requirements for klystron HVPS (DC POWER) | 2006-10-02 A | 2006-10-20 → 2006-12-22 A (+63d) | 15d → 58d | 0% → 100% | 160d → none |  |  |
| 1212112015 | Develop aux power supply requirements preliminary designs (includes rack configuration) (DC POWER) | 2006-10-23 → 2006-11-01 A (+9d) | 2007-02-23 → 2007-11-19 A (+269d) | 80d → 261d | 0% → 100% | 548d → none |  | resources ELEC DES [34.8 h]; ELEC ENG [208.8 h]; OFFICE [34.8 h] → ELEC DES [34.8 h]; OFFICE [34.8 h]; ELEC ENG [208.8 h] |
| 1212112010M | Preliminary HVPS requirements document complete (DC POWER) | 2006-10-20 → 2006-12-22 A (+63d) | 2006-10-20 → 2006-12-22 A (+63d) |  | 0% → 100% | 160d → none |  |  |
| 1212112045 | Request budgetary pricing for HVPS (DC POWER) | 2006-11-29 → 2007-03-02 A (+93d) | 2007-01-03 → 2007-04-23 A (+110d) | 20d → 37d | 0% → 100% | 160d → none |  |  |
| 1212112080 | Update costbook (DC POWER) | 2007-01-04 → 2007-03-23 A (+78d) | 2007-01-10 → 2007-04-23 A (+103d) | 5d → 22d | 0% → 100% | 160d → none |  |  |
| 1212112020 | Develop preliminary layout/packaging designs (DC POWER) | 2007-02-26 → 2007-03-30 A (+32d) | 2007-07-17 → 2008-04-25 A (+283d) | 100d → 266.5d | 0% → 100% | 548d → none |  |  |
| 1212112025 | Conduct internal design & safety review (DC POWER) | 2006-10-30 → 2007-04-16 A (+168d) | 2006-11-10 → 2007-05-14 A (+185d) | 10d → 21d | 0% → 100% | 160d → none |  |  |
| 1212112050M | Budgetary pricing received (DC POWER) | 2007-01-03 → 2007-04-23 A (+110d) | 2007-01-03 → 2007-04-23 A (+110d) |  | 0% → 100% | 160d → none |  |  |

| ID | Task | Start | Finish | Duration | Complete | Total float | Predecessors | Other |
| --- | --- | --- | --- | --- | --- | --- | --- | --- |
| 1212112085M | Costbook pricing updated (DC POWER) | 2007-01-10 → 2007-04-23 A (+103d) | 2007-01-10 → 2007-04-23 A (+103d) |  | 0% → 100% | 160d → none |  |  |
| 1212112030M | Internal design & safety review complete (DC POWER) | 2006-11-10 → 2007-05-14 A (+185d) | 2006-11-10 → 2007-05-14 A (+185d) |  | 0% → 100% | 160d → none |  |  |
| 1212112035 | Revise requirements based on review outcome (DC POWER) | 2006-11-13 → 2007-05-15 A (+183d) | 2006-11-28 → 2007-06-21 A (+205d) | 10d → 27d | 0% → 100% | 160d → none |  |  |
| 1212112055 | Procure components for preliminary design tests (DC POWER) | 2007-01-11 → 2007-05-28 A (+137d) | 2007-01-25 → 2007-11-16 A (+295d) | 10d → 122d | 0% → 100% | 160d → none |  | resources PROCUREMENT<$50K 60; OFFICE [34.8 h]; ELEC ENG [17.4 h] → ELEC ENG [17.4 h]; OFFICE [34.8 h]; PROCUREMENT<$50K 60 |
| 1212112040M | Requirements revised (DC POWER) | 2006-11-28 → 2007-09-03 A (+279d) | 2006-11-28 → 2007-09-03 A (+279d) |  | 0% → 100% | 160d → none |  |  |
| 1212112908LOE | FY08 Office Supprt for Document Prep (DC POWER) | 2007-10-01 A | 2008-09-30 A |  | 0% → 100% | 0d → none |  |  |
| 1212112090M | FY08 Begin DC Pwr PED (DC POWER) | 2007-10-01 → 2007-10-03 A (+2d) | 2007-10-01 → 2007-10-03 A (+2d) |  | 0% → 100% | 18d → none |  |  |
| 1212112065 | Build & test preliminary designs (fil/mod anode) (DC POWER) | 2006-12-20 → 2007-10-04 A (+288d) | 2007-02-23 → 2008-05-30 A (+462d) | 40d → 160d | 0% → 100% | 160d → none |  |  |
| 1212112060M | Components received for preliminary design tests (DC POWER) | 2007-01-25 → 2007-11-16 A (+295d) | 2007-01-25 → 2007-11-16 A (+295d) |  | 0% → 100% | 160d → none |  |  |
| 1212112070 | Revise preliminary designs (DC POWER) | 2007-02-26 → 2008-04-11 A (+410d) | 2007-03-09 → 2008-06-20 A (+469d) | 10d → 49d | 0% → 100% | 160d → none |  |  |
| 1212112075M | Preliminary designs revised (DC POWER) | 2007-03-09 → 2008-06-20 A (+469d) | 2007-03-09 → 2008-06-20 A (+469d) |  | 0% → 100% | 160d → none |  |  |
| 1212112100 | Dsgn & Test filament Pwr Supply (DC POWER) | 2008-04-01 → 2008-06-23 A (+83d) | 2008-06-24 → 2008-11-24 A (+153d) | 60d → 109d | 0% → 100% | 131d → none |  | resources ELEC TECH [560 h]; PROCUREMENT<$50K 60; ELEC ENG [360 h]; ELEC DES [120 h] → PROCUREMENT<$50K 60; ELEC ENG [360 h]; ELEC TECH [560 h]; ELEC DES [120 h] |
| 1212112110 | Dsgn & Test Mods anode Pwr Supply (DC POWER) | 2008-05-28 → 2008-06-23 A (+26d) | 2008-08-20 → 2009-02-20 A (+184d) | 60d → 163d | 0% → 100% | 143d → none |  | resources ELEC DES [120 h]; ELEC TECH [480 h]; PROCUREMENT<$50K 60; ELEC ENG [480 h] → PROCUREMENT<$50K 60; ELEC ENG [480 h]; ELEC DES [120 h]; ELEC TECH [480 h] |
| 1212112105 | Prep Documentation for Fab:/Prcrmnt filament (DC POWER) | 2008-06-25 → 2008-07-24 A (+29d) | 2008-07-23 → 2009-04-24 A (+275d) | 20d → 186d | 0% → 100% | 143d → none |  |  |
| 1212112115 | FY08 Prep Documentation for Fab/Prcrmnt: Mods anode (DC POWER) | 2008-08-21 → 2008-08-15 A (-6d) | 2008-09-30 → 2008-10-13 A (+13d) | 28d → 40d | 0% → 100% | 143d → none |  |  |
| 1212112120 | PROC Dsgn & Test Ion Pump Pwr Supply (DC POWER) | 2008-09-12 → 2008-08-15 A (-28d) | 2009-01-09 → 2009-04-24 A (+105d) | 78d → 170d | 0% → 100% | 143d → none |  |  |
| 1212112120b | FY09 LAB/EXP Dsgn & Test Ion Pump Pwr Supply (DC POWER) | 2008-10-01 → 2008-09-08 A (-23d) | 2009-01-09 → 2009-05-22 A (+133d) | 65d → 175d | 0% → 100% | 143d → none |  | was named FY09 LAB Dsgn & Test Ion Pump Pwr Supply (DC POWER); resources ELEC TECH [400 h]; ELEC ENG [400 h]; ELEC DES [100 h] → ELEC ENG [400 h]; ELEC DES [100 h]; ELEC TECH [400 h] |
| 1212112120a | FY08 LAB/EXP Dsgn & Test Ion Pump Pwr Supply (DC POWER) | 2008-09-12 A | 2008-09-30 A |  | 0% → 100% | 143d → none |  | was named FY08 LAB Dsgn & Test Ion Pump Pwr Supply (DC POWER) |
| 1212112115a | FY09 Prep Documentation for Fab/Prcrmnt: Mods anode (DC POWER) | 2008-10-01 → 2008-10-31 A (+30d) | 2008-10-02 → 2009-02-20 A (+141d) | 2d → 71d | 0% → 100% | 143d → none |  |  |
| 1212112130a | FY08 LAB/EXP Dsgn HPA/Rack Sys & Inj. Upgrade(DC POWER) | 2008-06-25 → 2008-11-20 A (+148d) | 2008-09-30 → 2009-03-23 A (+174d) | 68d → 78d | 0% → 100% | 131d → none |  | resources ELEC TECH [150.07 h]; MECH DES [225.1 h]; SUPPLIES & MATERIALS; ELEC DES [93.79 h]; ELEC ENG [281.38 h] → ELEC DES [93.79 h]; ELEC ENG [281.38 h]; ELEC TECH [150.07 h]; SUPPLIES & MATERIALS; MECH DES [225.1 h] |
| 1212112130 | PROC Dsgn HPA/Rack Sys & Inj. Upgrade(DC POWER) | 2008-06-25 → 2009-01-16 A (+205d) | 2009-01-28 → 2009-08-31 A (+215d) | 145d → 158d | 0% → 100% | 131d → none |  |  |
| 1212112140 | Prep Final Rquirmnts Package for HV PS Prcrmnt (DC POWER) | 2009-02-27 → 2009-01-16 A (-42d) | 2009-03-26 → 2009-04-24 A (+29d) | 20d → 69d | 0% → 100% | 131d → none |  | resources ELEC ENG [120 h]; TRAVEL; ELEC DES [40 h] → TRAVEL; ELEC ENG [120 h]; ELEC DES [40 h] |
| 1212112130b | FY09 LAB/EXP Dsgn HPA/Rack Sys & Inj. Upgrade(DC POWER) | 2008-10-01 → 2009-03-23 A (+173d) | 2009-01-28 → 2009-09-29 A (+244d) | 77d → 134d | 0% → 100% | 131d → none |  |  |
| 1212112125 | Prep Documentation for Fab/Prcrmnt; ION (DC POWER) | 2009-01-12 → 2009-04-30 A (+108d) | 2009-02-09 → 2009-07-24 A (+165d) | 20d → 60d | 0% → 100% | 143d → none |  |  |
| 1212112135 | Prep Documentation for Fab/Prcrmnt (DC POWER) | 2009-01-29 → 2009-05-29 A (+120d) | 2009-02-26 → 2009-10-30 A (+246d) | 20d → 109d | 0% → 100% | 131d → none | 1212112130, 1212112130b → 1212112130 FS-125d, 1212112130b FS-100d |  |
| 1212112145M | Finish 2008 DC Pwr PED (DC POWER)+ | 2009-03-26 → 2009-10-30 A (+218d) | 2009-03-26 → 2009-10-30 A (+218d) |  | 0% → 100% | 131d → none |  |  |
| 1212112150 | Re-Baseline Actuals Adjustment | 2013-08-30 A | 2013-08-30 A |  | 0% → 100% | 20d → none | 9-130M FS+227d → none |  |
| 1212113000M | Begin waveguide PED effort (WVGUIDE COMPON) | 2006-10-02 A | 2006-10-02 A |  | 0% → 100% | 429d → none |  |  |
| 1212113005 | Develop preliminary waveguide requirements and layout (WVGUIDE COMPON) | 2006-10-02 → 2006-12-14 A (+73d) | 2007-03-30 → 2007-11-19 A (+234d) | 120d → 232d | 0% → 100% | 429d → none |  |  |
| 1212113030 | Request budgetary pricing for waveguide components (WVGUIDE COMPON) | 2007-04-23 → 2007-03-05 A (-49d) | 2007-05-18 → 2007-04-23 A (-25d) | 20d → 36d | 0% → 100% | 429d → none |  |  |
| 1212113040 | Revise costbook pricing (WVGUIDE COMPON) | 2007-05-21 → 2007-03-23 A (-59d) | 2007-05-25 → 2007-04-23 A (-32d) | 5d → 22d | 0% → 100% | 429d → none |  |  |
| 1212113045M | Costbook revised (WVGUIDE COMPON) | 2007-05-25 → 2007-04-23 A (-32d) | 2007-05-25 → 2007-04-23 A (-32d) |  | 0% → 100% | 429d → none |  |  |
| 1212113010 | Conduct internal design & safety review (WVGUIDE COMPON) | 2007-04-02 → 2007-05-14 A (+42d) | 2007-04-13 → 2007-05-18 A (+35d) | 10d → 5d | 0% → 100% | 429d → none |  | resources OFFICE [34.8 h]; ELEC ENG [17.4 h] → ELEC ENG [17.4 h]; OFFICE [34.8 h] |
| 1212113020 | Revise preliminary designs (WVGUIDE COMPON) | 2007-04-16 → 2007-05-18 A (+32d) | 2007-04-20 → 2007-11-15 A (+209d) | 5d → 127d | 0% → 100% | 429d → none |  |  |
| 1212113015M | Design & safety review complete (WVGUIDE COMPON) | 2007-04-13 → 2007-05-18 A (+35d) | 2007-04-13 → 2007-05-18 A (+35d) |  | 0% → 100% | 429d → none |  |  |
| 1212113035M | Receive budgetary pricing (WVGUIDE COMPON) | 2007-05-18 → 2007-06-23 A (+36d) | 2007-05-18 → 2007-06-23 A (+36d) |  | 0% → 100% | 429d → none |  |  |
| 1212113025M | Requirements revised (WVGUIDE COMPON) | 2007-04-20 → 2007-11-15 A (+209d) | 2007-04-20 → 2007-11-15 A (+209d) |  | 0% → 100% | 429d → none |  |  |
| 1212113050M | Begin final design (WVGUIDE COMPON) | 2007-05-29 → 2007-11-16 A (+171d) | 2007-05-29 → 2007-11-16 A (+171d) |  | 0% → 100% | 429d → none |  |  |
| 1212113055 | Final design Phase (WVGUIDE COMPON) | 2007-05-29 → 2007-11-16 A (+171d) | 2007-08-20 → 2008-10-31 A (+438d) | 59d → 237d | 0% → 100% | 429d → none |  | was named Final design FY07 Phase (WVGUIDE COMPON) |
| 1212113060M | Begin 2008 Waveguide Systems PED (WVGUIDE COMPON) | 2008-06-25 → 2008-01-25 A (-152d) | 2008-06-25 → 2008-01-25 A (-152d) |  | 0% → 100% | 221d → none |  |  |
| 1212113075 | Develop Rquirmnts Package for HOM Filter (WVGUIDE COMPON) | 2008-08-14 → 2008-01-25 A (-202d) | 2008-08-14 → 2008-01-25 A (-202d) |  | 0% → 100% | 221d → none | 1212113070 FS+5d → 1212113070 FS-20d |  |
| 1212113070 | Develop Rquirmnts Package for circulator (WVGUIDE COMPON) | 2008-06-25 → 2008-02-11 A (-135d) | 2008-08-06 → 2009-02-25 A (+203d) | 30d → 259d | 0% → 100% | 221d → none |  | resources ELEC DES [20 h]; ELEC TECH [40 h]; ELEC ENG [80 h]; SUPPLIES & MATERIALS → ELEC DES [20 h]; SUPPLIES & MATERIALS; ELEC TECH [40 h]; ELEC ENG [80 h] |
| 1212113080 | FY08 Develop Rquirmnts Packages for Custom Waveguide pcs (WVGUIDE COMPON) | 2008-08-14 → 2008-02-11 A (-185d) | 2008-09-30 A | 33d → 162.48d | 0% → 100% | 221d → none |  | was named FY08 LAB/EXPDevelop Rquirmnts Packages for Custom Waveguide pcs (WVGUIDE COMPON); resources SUPPLIES & MATERIALS; ELEC ENG [105.6 h]; ELEC TECH [52.8 h]; MECH DES [105.6 h]; ELEC DES [52.8 h] → MECH DES [105.6 h]; SUPPLIES & MATERIALS; ELEC ENG [105.6 h]; ELEC DES [52.8 h]; ELEC TECH [52.8 h] |
| 1212113065 | Office Admin Supprt (WVGUIDE COMPON) | 2008-06-25 → 2008-09-01 A (+68d) | 2008-09-25 → 2008-09-30 A (+5d) | 65d → 21d | 0% → 100% | 246d → none |  |  |
| 1212113080a | FY09 Develop Rquirmnts Packages for Custom Waveguide pcs (WVGUIDE COMPON) | 2008-10-01 → 2008-09-22 A (-9d) | 2008-10-23 → 2009-02-25 A (+125d) | 17d → 103d | 0% → 100% | 221d → none |  | was named FY09 LAB/EXP Develop Rquirmnts Packages for Custom Waveguide pcs (WVGUIDE COMPON); resources ELEC DES [27.2 h]; ELEC ENG [54.4 h]; ELEC TECH [27.2 h]; MECH DES [54.4 h]; SUPPLIES & MATERIALS → SUPPLIES & MATERIALS; ELEC DES [27.2 h]; ELEC ENG [54.4 h]; ELEC TECH [27.2 h]; MECH DES [54.4 h] |
| 1212113085 | Revise Vend Pricing for Waveguide Compnts (WVGUIDE COMPON) | 2008-10-24 → 2008-11-26 A (+33d) | 2008-10-30 → 2008-12-22 A (+53d) | 5d → 17d | 0% → 100% | 221d → none |  |  |
| 1212113090M | Waveguide PED Comp 2008 (WVGUIDE COMPON)++ | 2008-10-30 → 2009-02-25 A (+118d) | 2008-10-30 → 2009-02-25 A (+118d) |  | 0% → 100% | 221d → none |  |  |
| 1212113170 | Pre-Constrctn Dsgn Review (WVGUIDE COMPON)+ | 2008-10-31 → 2009-07-01 A (+243d) | 2008-11-06 → 2009-07-06 A (+242d) | 5d → 3d | 0% → 100% | 221d → none |  |  |
| 1212113175 | Re-Baseline Actuals Adjustment | 2013-08-30 A | 2013-08-30 A |  | 0% → 100% | 20d → none | 9-130M FS+227d → none |  |
| 1212121000M | Preliminary Integrated LLRF System Design (FLD CNTL) | 2006-12-05 → 2006-10-02 A (-64d) | 2006-12-05 → 2006-10-02 A (-64d) |  | 0% → 100% | 131.5d → none |  |  |
| 1212121030M | Begin Preliminary Digital Board Design (FLD CNTL) | 2006-10-02 A | 2006-10-02 A |  | 0% → 100% | 34d → none |  |  |
| 1212121035 | Develop Detailed Specification (FLD CNTL) | 2006-10-02 A | 2006-10-27 → 2007-01-31 A (+96d) | 20d → 79d | 0% → 100% | 34d → none |  |  |
| 1212121065 | Develop RF Board Detailed specification (FLD CNTL) | 2006-10-02 A | 2006-10-27 → 2007-02-28 A (+124d) | 20d → 98d | 0% → 100% | 14d → none |  |  |
| 1212121040 | Develop Preliminary Design Digital Board (FLD CNTL) | 2006-10-30 → 2006-11-01 A (+2d) | 2007-02-01 → 2007-09-24 A (+235d) | 60d → 221d | 0% → 100% | 34d → none |  | resources ELEC TECH [69.6 h]; ELEC ENG [278.4 h]; ELEC DES [243.6 h] → ELEC DES [243.6 h]; ELEC TECH [69.6 h]; ELEC ENG [278.4 h] |
| 1212121070 | Preliminary RF Board Design Complete (FLD CNTL) | 2006-10-30 → 2006-11-01 A (+2d) | 2007-01-03 → 2007-04-18 A (+105d) | 40d → 111d | 0% → 100% | 14d → none |  |  |
| 1212121005 | Develop Preliminary System Design (FLD CNTL) | 2006-12-05 → 2006-12-01 A (-4d) | 2007-04-05 → 2007-04-30 A (+25d) | 80d → 99d | 0% → 100% | 591d → none |  |  |
| 1212121010 | Investigate Comparitive System Designs (FLD CNTL) | 2007-01-10 → 2006-12-01 A (-40d) | 2007-04-05 → 2007-04-30 A (+25d) | 60d → 99d | 0% → 100% | 591d → none |  | resources SCIENTIST [34.8 h]; TRAVEL; ELEC ENG [104.4 h] → SCIENTIST [34.8 h]; ELEC ENG [104.4 h]; TRAVEL |
| 1212121045 | Procure Digital Board validation unit (FLD CNTL) | 2007-02-02 → 2006-12-01 A (-63d) | 2007-02-07 → 2007-10-05 A (+240d) | 4d → 210d | 0% → 100% | 34d → none |  |  |
| 1212121015 | Update LLRF Model (FLD CNTL) | 2006-12-05 → 2007-01-02 A (+28d) | 2007-03-08 → 2007-05-18 A (+71d) | 60d → 97d | 0% → 100% | 131.5d → none |  | resources SCIENTIST [156.6 h]; ELEC ENG [17.4 h] → ELEC ENG [17.4 h]; SCIENTIST [156.6 h] |
| 1212121050 | Conduct Digital Board Validation Tests (FLD CNTL) | 2007-02-08 → 2007-01-02 A (-37d) | 2007-04-05 → 2008-01-21 A (+291d) | 40d → 260d | 0% → 100% | 34d → none |  | resources ELEC ENG [174 h]; ELEC DES [34.8 h]; COMP SCIENT [34.8 h]; ELEC TECH [69.6 h] → ELEC DES [34.8 h]; COMP SCIENT [34.8 h]; ELEC TECH [69.6 h]; ELEC ENG [174 h] |
| 1212121075 | Procure RF Board validation unit (FLD CNTL) | 2007-01-04 → 2007-02-27 A (+54d) | 2007-01-09 → 2007-07-31 A (+203d) | 4d → 109d | 0% → 100% | 14d → none |  |  |
| 1212121020 | Develop Preliminary Design (FLD CNTL) | 2007-04-13 → 2007-03-02 A (-42d) | 2007-04-17 → 2007-03-28 A (-20d) | 2.5d → 18.5d | 0% → 100% | 106.5d → none |  |  |
| 1212121115 | Update PED Cost and Schedule (FLD CNTL) | 2007-02-08 → 2007-03-02 A (+22d) | 2007-04-12 → 2007-04-16 A (+4d) | 45d → 32d | 0% → 100% | 106.5d → none |  |  |
| 1212121120 | Update Construction Cost and Schedule (FLD CNTL) | 2007-02-08 → 2007-03-02 A (+22d) | 2007-03-22 → 2007-04-23 A (+32d) | 30d → 37d | 0% → 100% | 124d → none |  |  |
| 1212121125 | Prepare for EIR (FLD CNTL) | 2006-10-02 → 2007-03-02 A (+151d) | 2006-12-22 → 2007-05-25 A (+154d) | 58d → 61d | 0% → 100% | 158d → none | none → 1212121110M |  |
| 1212121020M | Preliminary Design Complete (FLD CNTL) | 2007-04-17 → 2007-03-28 A (-20d) | 2007-04-17 → 2007-03-28 A (-20d) |  | 0% → 100% | 106.5d → none |  |  |
| 1212121110M | Start Cost & Schedule Update (FLD CNTL) | 2007-02-08 → 2007-04-23 A (+74d) | 2007-02-08 → 2007-04-23 A (+74d) |  | 0% → 100% | 106.5d → none |  |  |
| 1212121025 | Conduct Preliminary Design & Safety Review 1.2.1.2.1.2 LLRF (FLD CNTL) | 2007-04-17 → 2007-04-30 A (+13d) | 2007-05-15 → 2007-06-08 A (+24d) | 20d → 28d | 0% → 100% | 106.5d → none |  | resources OFFICE [34.8 h]; COMP SCIENT [34.8 h]; SCIENTIST [34.8 h]; ELEC ENG [139.2 h]; TRAVEL → ELEC ENG [139.2 h]; SCIENTIST [34.8 h]; COMP SCIENT [34.8 h]; OFFICE [34.8 h]; TRAVEL |
| 1212121130M | Field Control Ready for Baseline (FLD CNTL) | 2006-12-22 → 2007-05-25 A (+154d) | 2006-12-22 → 2007-05-25 A (+154d) |  | 0% → 100% | 158d → none |  |  |
| 1212121060M | Start Preliminary RF Board design (FLD CNTL) | 2006-10-02 → 2007-07-02 A (+273d) | 2006-10-02 → 2007-07-02 A (+273d) |  | 0% → 100% | 14d → none |  |  |

| ID | Task | Start | Finish | Duration | Complete | Total float | Predecessors | Other |
| --- | --- | --- | --- | --- | --- | --- | --- | --- |
| 1212121080 | Conduct RF Board Validation tests (FLD CNTL) | 2007-03-09 → 2007-07-02 A (+115d) | 2007-05-03 → 2007-12-20 A (+231d) | 40d → 120d | 0% → 100% | 14d → none |  |  |
| 1212121085M | RF Board Validation Tests complete (FLD CNTL) | 2007-05-03 → 2007-12-20 A (+231d) | 2007-05-03 → 2007-12-20 A (+231d) |  | 0% → 100% | 14d → none |  |  |
| 1212121090M | Start Field Control System Test (FLD CNTL) | 2007-07-31 → 2008-01-14 A (+167d) | 2007-07-31 → 2008-01-14 A (+167d) |  | 0% → 100% | 511d → none |  |  |
| 1212121095 | Modify Field Control Firmware (FLD CNTL) | 2007-07-31 → 2008-01-14 A (+167d) | 2007-09-07 → 2008-03-13 A (+188d) | 28d → 42d | 0% → 100% | 511d → none |  | resources COMP SCIENT [34.8 h]; PROCUREMENT<$50K 60; ELEC ENG [139.2 h] → ELEC ENG [139.2 h]; PROCUREMENT<$50K 60; COMP SCIENT [34.8 h] |
| 1212121100 | Conduct Field Control System Validation (FLD CNTL) | 2007-05-04 → 2008-01-14 A (+255d) | 2007-09-25 → 2008-04-15 A (+203d) | 100d → 65d | 0% → 100% | 14d → none |  | resources ELEC ENG [139.2 h]; PROCUREMENT<$50K 60 → PROCUREMENT<$50K 60; ELEC ENG [139.2 h] |
| 1212121140 | Assess Hardware Dsgn (FLD CONT) | 2009-02-12 → 2008-01-19 A (-390d) | 2009-06-16 → 2009-01-19 A (-148d) | 87d → 247d | 0% → 100% | 11d → none | 1212121135Bb FS-40d → 1212121135B, 1212121135Bb FS-40d | resources ELEC TECH [172 h]; ELEC ENG [828 h]; PROCUREMENT<$50K 60; ELEC DES [640 h] → ELEC ENG [828 h]; ELEC DES [640 h]; PROCUREMENT<$50K 60; ELEC TECH [172 h] |
| 1212121055M | Digital Board Validation Tests complete (FLD CNTL) | 2007-04-05 → 2008-01-21 A (+291d) | 2007-04-05 → 2008-01-21 A (+291d) |  | 0% → 100% | 167d → none | 1212121050 → 1212121050 FS+8d |  |
| 1212121105M | Field Control System validation complete (FLD CNTL) | 2007-09-25 → 2008-04-15 A (+203d) | 2007-09-25 → 2008-04-15 A (+203d) |  | 0% → 100% | 14d → none |  |  |
| 1212121135 | Validation Testing on Cavity Phase 1 (FLD CONT) | 2007-10-01 → 2008-05-01 A (+213d) | 2007-11-30 → 2008-07-01 A (+214d) |  | 0% → 100% | 11d → none |  | resources SCIENTIST [20.36 h]; COMP SCIENT [81.42 h]; ELEC ENG [81.42 h]; ELEC TECH [50.89 h] → SCIENTIST [20.36 h]; ELEC TECH [50.89 h]; COMP SCIENT [81.42 h]; ELEC ENG [81.42 h] |
| 1212121135Ba | FY08 LAB/EXP Validation Testing on Cavity Phase 2A (FLD CONT) | 2008-08-01 → 2008-12-01 A (+122d) | 2008-09-30 → 2009-03-20 A (+171d) | 42d → 72d | 0% → 100% | 11d → none | 1212121135 FS+163d → 1212121135 | was named FY08 LAB Validation Testing on Cavity Phase 2A (FLD CONT); resources ELEC TECH [37.06 h]; SCIENTIST [14.82 h]; ELEC ENG [59.29 h] → ELEC ENG [59.29 h]; ELEC TECH [37.06 h]; SCIENTIST [14.82 h] |
| 1212121135B | PROC Validation Testing on Cavity Phase 2 (FLD CONT) | 2008-08-01 → 2009-01-02 A (+154d) | 2009-04-09 → 2009-04-20 A (+11d) | 169d → 75d | 0% → 100% | 1112d → none | 1212121135 FS+163d → 1212121135 |  |
| 1212121145 | Update Documentation and Procurement Prep (FLD CONT)+ | 2009-05-14 → 2009-01-26 A (-108d) | 2009-09-15 → 2009-08-28 A (-18d) | 86d → 152d | 0% → 100% | 11d → none |  | resources ELEC DES [320 h]; OFFICE [80 h]; ELEC ENG [160 h] → OFFICE [80 h]; ELEC ENG [160 h]; ELEC DES [320 h] |
| 1212121135Bb | FY09 LAB/EXP Validation Testing on Cavity Phase 2B (FLD CONT) | 2008-10-01 → 2009-03-20 A (+170d) | 2009-04-09 → 2009-04-20 A (+11d) | 127d → 22d | 0% → 100% | 11d → none |  | was named FY09 LAB Validation Testing on Cavity Phase 2B (FLD CONT); resources ELEC TECH [112.05 h]; SCIENTIST [44.82 h]; ELEC ENG [179.28 h] → SCIENTIST [44.82 h]; ELEC ENG [179.28 h]; ELEC TECH [112.05 h] |
| 1212121170 | Pre-Constrctn Dsgn Review (FLD CONT) | 2009-05-01 → 2009-04-27 A (-4d) | 2009-05-29 → 2009-05-20 A (-9d) | 20d → 18d | 0% → 100% | 86d → none | 1212121135Bb FS+15d → 1212121135B, 1212121135Bb FS+15d | resources MECH DES [12 h]; MECH ENG [12 h]; ELEC DES [80 h]; ELEC ENG [320 h] → MECH DES [12 h]; ELEC DES [80 h]; MECH ENG [12 h]; ELEC ENG [320 h] |
| 1212121145M | Documentation Ready for Procurement (FLD CONT)+ | 2009-09-15 → 2009-08-28 A (-18d) | 2009-09-15 → 2009-08-28 A (-18d) |  | 0% → 100% | 11d → none |  | was named Documentation Ready for Prcrmnt (FLD CONT)+ |
| 1212121175 | Re-Baseline Actuals Adjustment | 2013-08-30 A | 2013-08-30 A |  | 0% → 100% | 20d → none | 9-130M FS+227d → none |  |
| 2 | **1.2.1.2.1.2.2 RESONANCE CONTROL & INTERLOCKS** | 2007-01-04 → 2006-10-02 (-94d) |  |  |  |  |  |  |
| 1212122000M | Start Preliminary Integrated System Design (RESON CNTL & INTRLCKS) | 2007-01-04 → 2006-10-02 A (-94d) | 2007-01-04 → 2006-10-02 A (-94d) |  | 0% → 100% | 86d → none |  |  |
| 1212122005 | Prepare Preliminary Integrated System Design (RESON CNTL & INTRLCKS) | 2007-01-04 → 2006-10-02 A (-94d) | 2007-03-02 → 2007-05-28 A (+87d) | 40d → 160d | 0% → 100% | 244d → none |  | resources ELEC DES [34.8 h]; COMP SCIENT [69.6 h]; ELEC ENG [104.4 h] → ELEC ENG [104.4 h]; ELEC DES [34.8 h]; COMP SCIENT [69.6 h] |
| 1212122015 | Develop Detailed Preliminary Integrated System Design specification (RESON CNTL & INTRLCKS) | 2007-01-04 → 2006-11-01 A (-64d) | 2007-02-01 → 2007-03-12 A (+39d) | 20d → 84d | 0% → 100% | 86d → none |  |  |
| 1212122025 | Develop Interlock Preliminary Design (RESON CNTL & INTRLCKS) | 2007-02-02 → 2007-01-02 A (-31d) | 2007-04-27 → 2007-08-20 A (+115d) | 60d → 161d | 0% → 100% | 184d → none |  | resources ELEC DES [208.8 h]; ELEC TECH [104.4 h]; COMP SCIENT [69.6 h]; ELEC ENG [208.8 h]; PROCUREMENT<$50K 60 → ELEC TECH [104.4 h]; ELEC DES [208.8 h]; COMP SCIENT [69.6 h]; ELEC ENG [208.8 h]; PROCUREMENT<$50K 60 |
| 1212122050 | Develop PZT Driver chassis Preliminary Design (RESON CNTL & INTRLCKS) | 2007-05-03 → 2007-01-02 A (-121d) | 2007-08-03 → 2007-07-31 A (-3d) | 65d → 147d | 0% → 100% | 86d → none |  | resources PROCUREMENT<$50K 60; COMP SCIENT [69.6 h]; ELEC DES [174 h]; ELEC ENG [139.2 h]; ELEC TECH [104.4 h] → ELEC ENG [139.2 h]; COMP SCIENT [69.6 h]; ELEC DES [174 h]; PROCUREMENT<$50K 60; ELEC TECH [104.4 h] |
| 1212122080 | Update Construction Cost and Schedule (RESON CNTL & INTRLCKS) | 2007-05-17 → 2007-03-16 A (-62d) | 2007-05-31 → 2007-04-23 A (-38d) | 10d → 27d | 0% → 100% | 201d → none |  |  |
| 1212122055 | Build PZT Driver chassis validation unit (RESON CNTL & INTRLCKS) | 2007-08-06 → 2007-03-26 A (-133d) | 2007-08-17 → 2007-09-14 A (+28d) | 10d → 121d | 0% → 100% | 86d → none |  |  |
| 1212122075 | Update PED Cost and Schedule (RESON CNTL & INTRLCKS) | 2007-05-03 → 2007-03-29 A (-35d) | 2007-05-16 → 2007-04-09 A (-37d) | 10d → 8d | 0% → 100% | 201d → none |  |  |
| 1212122045M | Start PZT Driver chassis design (RESON CNTL & INTRLCKS) | 2007-05-03 → 2007-04-02 A (-31d) | 2007-05-03 → 2007-04-02 A (-31d) |  | 0% → 100% | 86d → none |  |  |
| 1212122020M | Interlock and Step Chassis (RESON CNTL & INTRLCKS) | 2007-02-02 → 2007-05-01 A (+88d) | 2007-02-02 → 2007-05-01 A (+88d) |  | 0% → 100% | 86d → none |  |  |
| 1212122070M | Start Cost & Schedule Update (RESON CNTL & INTRLCKS) | 2007-05-03 → 2007-05-01 A (-2d) | 2007-05-03 → 2007-05-01 A (-2d) |  | 0% → 100% | 201d → none |  |  |
| 1212122085M | Resonance Control Ready for Baseline (RESON CNTL & INTRLCKS) | 2007-05-31 → 2007-05-01 A (-30d) | 2007-05-31 → 2007-05-01 A (-30d) |  | 0% → 100% | 201d → none |  |  |
| 1212122030 | Build Design Interlock validation unit (RESON CNTL & INTRLCKS) | 2007-04-30 → 2007-05-21 A (+21d) | 2007-05-11 → 2007-10-31 A (+173d) | 10d → 114.5d | 0% → 100% | 184d → none |  |  |
| 1212122010M | Preliminary Integrated System Design Complete (RESON CNTL & INTRLCKS) | 2007-03-02 → 2007-05-28 A (+87d) | 2007-03-02 → 2007-05-28 A (+87d) |  | 0% → 100% | 244d → none |  |  |
| 1212122060 | Conduct PZT Driver chassis Validation testing (RESON CNTL & INTRLCKS) | 2007-08-20 → 2007-07-02 A (-49d) | 2007-11-12 → 2007-10-08 A (-35d) | 60d → 69d | 0% → 100% | 86d → none |  | resources ELEC TECH [34.8 h]; COMP SCIENT [69.6 h]; ELEC ENG [69.6 h] → COMP SCIENT [69.6 h]; ELEC ENG [69.6 h]; ELEC TECH [34.8 h] |
| 1212122065M | PZT Driver chassis Validation test complete (RESON CNTL & INTRLCKS) | 2007-11-12 → 2007-10-08 A (-35d) | 2007-11-12 → 2007-10-08 A (-35d) |  | 0% → 100% | 86d → none |  |  |
| 1212122035 | Interlock Validation Testing (RESON CNTL & INTRLCKS) | 2007-08-01 → 2007-11-01 A (+92d) | 2007-10-24 → 2007-11-13 A (+20d) | 60d → 8d | 0% → 100% | 184d → none |  | resources ELEC TECH [34.8 h]; COMP SCIENT [69.6 h]; ELEC ENG [69.6 h] → ELEC ENG [69.6 h]; ELEC TECH [34.8 h]; COMP SCIENT [69.6 h] |
| 1212122040M | Interlock Validation Completed (RESON CNTL & INTRLCKS) | 2007-10-24 → 2007-11-13 A (+20d) | 2007-10-24 → 2007-11-13 A (+20d) |  | 0% → 100% | 184d → none |  |  |
| 1212122100 | Resonance & Interlock Dsgn Assessmnt (RESON CNTL & INTRLCKS) | 2009-01-21 → 2008-01-21 A (-366d) | 2009-06-22 → 2009-07-27 A (+35d) | 107d → 379d | 0% → 100% | 7d → none |  | resources ELEC DES [400 h]; ELEC TECH [160 h]; PROCUREMENT<$50K 60; ELEC ENG [545.45 h] → ELEC TECH [160 h]; ELEC ENG [545.45 h]; ELEC DES [400 h]; PROCUREMENT<$50K 60 |
| 1212122090 | Resonance Cavity Tests P-1 (RESON CNTL & INTRLCKS) | 2007-11-13 → 2008-06-02 A (+202d) | 2007-11-30 → 2008-06-17 A (+200d) | 12d → 11d | 0% → 100% | 86d → none |  | resources ELEC DES [24 h]; ELEC ENG [36 h]; ELEC TECH [24 h]; SUPPLIES & MATERIALS; COMP SCIENT [36 h] → ELEC TECH [24 h]; ELEC DES [24 h]; COMP SCIENT [36 h]; SUPPLIES & MATERIALS; ELEC ENG [36 h] |
| 1212122090B | FY08 Resonance Cavity Tests P-2 (RESON CNTL & INTRLCKS) | 2008-09-24 → 2008-11-03 A (+40d) | 2008-09-30 → 2008-11-26 A (+57d) | 5d → 18d | 0% → 100% | 86d → none | 1212122090 FS+200d → 1212122090 FS+110d | was named FY08 LAB/EXP Resonance Cavity Tests P-2 (RESON CNTL & INTRLCKS); resources COMP SCIENT [1.36 h]; SUPPLIES & MATERIALS; ELEC ENG [6.94 h]; ELEC TECH [1.36 h] → ELEC ENG [6.94 h]; COMP SCIENT [1.36 h]; SUPPLIES & MATERIALS; ELEC TECH [1.36 h] |
| 1212122095 | Cavity Interlock Tests P-1(RESON CNTL & INTRLCKS) | 2007-10-25 → 2008-11-03 A (+375d) | 2007-11-30 → 2008-11-26 A (+362d) | 25d → 18d | 0% → 100% | 184d → none | 1212122040M → 1212122040M FS+250d | resources COMP SCIENT [40 h]; ELEC ENG [80 h]; ELEC DES [53.34 h]; ELEC TECH [53.34 h] → COMP SCIENT [40 h]; ELEC TECH [53.34 h]; ELEC ENG [80 h]; ELEC DES [53.34 h] |
| 1212122090Ba | FY09 Resonance Cavity Tests P-2 (RESON CNTL & INTRLCKS) | 2008-10-01 → 2008-12-01 A (+61d) | 2009-04-30 → 2008-12-22 A (-129d) | 142d → 16d | 0% → 100% | 86d → none |  | was named FY08 LAB/EXP Resonance Cavity Tests P-2 (RESON CNTL & INTRLCKS); resources COMP SCIENT [38.64 h]; ELEC ENG [197.06 h]; ELEC TECH [38.64 h]; SUPPLIES & MATERIALS → ELEC TECH [38.64 h]; SUPPLIES & MATERIALS; COMP SCIENT [38.64 h]; ELEC ENG [197.06 h] |
| 1212122095B | FY08 Cavity Interlock Tests P-2 (RESON CNTL & INTRLCKS) | 2008-09-02 → 2009-02-02 A (+153d) | 2008-09-30 → 2009-03-20 A (+171d) | 21d → 34d | 0% → 100% | 0d → none | 1212122095 → 1212122095 FS-15d | constraint start on 2008-09-02 → none; resources ELEC TECH [7.18 h]; ELEC ENG [28.72 h]; COMP SCIENT [7.18 h] → COMP SCIENT [7.18 h]; ELEC TECH [7.18 h]; ELEC ENG [28.72 h] |
| 1212122095Ba | FY09 Cavity Interlock Tests P-2 (RESON CNTL & INTRLCKS) | 2008-10-01 → 2009-03-20 A (+170d) | 2009-02-25 → 2009-04-16 A (+50d) | 96d → 20d | 0% → 100% | 7d → none |  |  |
| 1212122170 | Pre-Constrctn Dsgn Review (RESON CNTL & INTRLCKS) | 2009-05-01 → 2009-03-25 A (-37d) | 2009-05-29 → 2009-05-21 A (-8d) | 20d → 42d | 0% → 100% | 86d → none |  | resources MECH ENG [12 h]; MECH DES [12 h]; ELEC ENG [80 h] → ELEC ENG [80 h]; MECH DES [12 h]; MECH ENG [12 h] |
| 1212122105 | Update Documentation and Procurement Prep (RESON CNTL & INTRLCKS) | 2009-05-20 → 2009-04-20 A (-30d) | 2009-09-21 A | 86d → 108d | 0% → 100% | 7d → none |  | resources ELEC TECH [40 h]; ELEC DES [160 h]; OFFICE [40 h] → ELEC DES [160 h]; OFFICE [40 h]; ELEC TECH [40 h] |
| 1212122110M | Documentation Ready for Prcrmnt (RESON CNTL & INTRLCKS)+ | 2009-09-21 A | 2009-09-21 A |  | 0% → 100% | 7d → none |  |  |
| 1212122175 | Re-Baseline Actuals Adjustment | 2013-08-30 A | 2013-08-30 A |  | 0% → 100% | 20d → none | 9-130M FS+227d → none |  |
| 3 | **1.2.1.2.1.2.3 PACKAGE/INTERFACE** | 2007-03-15 → 2007-02-27 (-16d) |  |  |  |  |  |  |
| 1212123005 | Develop Preliminary Integrated System Design (PKG/INTRFC) | 2007-03-15 → 2007-02-27 A (-16d) | 2007-05-09 → 2007-05-15 A (+6d) | 40d → 56d | 0% → 100% | 321d → none |  | resources ELEC ENG [17.4 h]; ELEC TECH [34.8 h]; ELEC DES [34.8 h]; PROCUREMENT<$50K 60 → ELEC ENG [17.4 h]; ELEC DES [34.8 h]; ELEC TECH [34.8 h]; PROCUREMENT<$50K 60 |
| 1212123020 | Update PED Cost and Schedule (PKG/INTRFC) | 2007-03-15 → 2007-03-02 A (-13d) | 2007-04-25 → 2007-04-16 A (-9d) | 30d → 32d | 0% → 100% | 301d → none |  |  |
| 1212123025 | Update Construction Cost and Schedule (PKG/INTRFC) | 2007-04-26 → 2007-03-14 A (-43d) | 2007-06-07 → 2007-04-23 A (-45d) | 30d → 29d | 0% → 100% | 301d → none |  |  |
| 1212123000M | Start Preliminary Integrated System Design (PKG/INTRFC) | 2007-03-15 → 2007-04-02 A (+18d) | 2007-03-15 → 2007-04-02 A (+18d) |  | 0% → 100% | 301d → none |  |  |
| 1212123015M | Start Cost & Schedule Update (PKG/INTRFC) | 2007-03-15 → 2007-04-02 A (+18d) | 2007-03-15 → 2007-04-02 A (+18d) |  | 0% → 100% | 301d → none |  |  |
| 1212123030M | Racks-Interface Ready for Baseline (PKG/INTRFC) | 2007-06-07 → 2007-04-23 A (-45d) | 2007-06-07 → 2007-04-23 A (-45d) |  | 0% → 100% | 301d → none |  |  |
| 1212123010M | Preliminary Integrated Design Complete (PKG/INTRFC) | 2007-05-09 → 2007-05-15 A (+6d) | 2007-05-09 → 2007-05-15 A (+6d) |  | 0% → 100% | 321d → none |  |  |
| 1212123035 | Dsgn Chassis Pwr Supply (PKG/INTRFC) | 2007-10-01 → 2007-12-03 A (+63d) | 2007-10-26 → 2008-01-21 A (+87d) | 20d → 28d | 0% → 100% | 69d → none |  | resources ELEC TECH [80 h]; SUPPLIES & MATERIALS; PROCUREMENT<$50K 60; ELEC ENG [80 h]; ELEC DES [160 h] → ELEC DES [160 h]; ELEC TECH [80 h]; SUPPLIES & MATERIALS; ELEC ENG [80 h]; PROCUREMENT<$50K 60 |
| 1212123040 | Proc & Test PS P-1 (PKG/INTRFC) | 2007-10-29 → 2008-01-21 A (+84d) | 2007-11-30 → 2008-01-28 A (+59d) | 23d → 5d | 0% → 100% | 69d → none |  |  |
| 1212123040B | Proc & Test PS P-2 (PKG/INTRFC) | 2008-02-22 → 2008-01-28 A (-25d) | 2008-05-15 → 2008-09-30 A (+138d) | 60d → 173d | 0% → 100% | 69d → none |  | resources ELEC ENG [43.2 h]; ELEC DES [129.6 h]; ELEC TECH [64.8 h]; PROCUREMENT<$50K 60 → ELEC DES [129.6 h]; ELEC TECH [64.8 h]; PROCUREMENT<$50K 60; ELEC ENG [43.2 h] |
| 1212123045 | Final Dsgn Rack Layout with FC, Res & PS (PKG/INTRFC) | 2008-05-16 → 2008-04-25 A (-21d) | 2008-09-30 → 2009-02-27 A (+150d) | 95d → 208d | 0% → 100% | 69d → none |  | resources PROCUREMENT<$50K 60; ELEC TECH [160 h]; ELEC DES [240 h]; ELEC ENG [80 h] → ELEC ENG [80 h]; ELEC DES [240 h]; ELEC TECH [160 h]; PROCUREMENT<$50K 60 |
| 1212123050 | Update Documentation and Procurement Prep(PKG/INTRFC) | 2008-10-01 → 2009-02-23 A (+145d) | 2009-06-23 → 2009-08-31 A (+69d) | 179d → 134d | 0% → 100% | 69d → none |  | resources ELEC DES [240 h]; ELEC ENG [40 h]; OFFICE [80 h] → ELEC DES [240 h]; OFFICE [80 h]; ELEC ENG [40 h] |
| 1212123170 | Pre-Constrctn Dsgn Review (PKG/INTRFC) | 2009-05-01 → 2009-03-25 A (-37d) | 2009-05-29 → 2009-05-21 A (-8d) | 20d → 42d | 0% → 100% | 86d → none | 1212123045 FS+142d → 1212123045 FS+40d | resources MECH DES [12 h]; MECH ENG [12 h]; ELEC DES [40 h]; ELEC ENG [40 h] → ELEC DES [40 h]; ELEC ENG [40 h]; MECH DES [12 h]; MECH ENG [12 h] |
| 1212123055M | Rack Documentation Ready for Prcrmnt (PKG/INTRFC)+ | 2009-06-23 → 2009-08-31 A (+69d) | 2009-06-23 → 2009-08-31 A (+69d) |  | 0% → 100% | 69d → none |  |  |
| 1212123175 | Re-Baseline Actuals Adjustment | 2013-08-30 A | 2013-08-30 A |  | 0% → 100% | 20d → none | 9-130M FS+227d → none |  |
| 4 | **1.2.1.2.1.2.4 CPU & SOFTWARE** | 2006-11-01 → 2007-01-02 (+62d) |  |  |  |  |  |  |
| 1212124000M | Start Preliminary Integrated System Design (CPU & SW)100 | 2006-11-01 → 2007-01-02 A (+62d) | 2006-11-01 → 2007-01-02 A (+62d) |  | 0% → 100% | 172d → none |  |  |
| 1212124005 | Develop Preliminary Integrated System Design (CPU & SW)100 | 2006-11-01 → 2007-01-02 A (+62d) | 2007-03-06 → 2007-04-24 A (+49d) | 80d → 79d | 0% → 100% | 191d → none |  |  |
| 1212124025 | Develop Preliminary Embedded IOC Design (CPU & SW)85 | 2007-01-02 → 2007-02-28 A (+57d) | 2007-03-28 → 2007-07-31 A (+125d) | 60d → 108d | 0% → 100% | 173d → none |  | resources PROCUREMENT<$50K 60; ELEC ENG [29.6 h]; ELEC TECH [29.6 h]; COMP SCIENT [118.4 h] → PROCUREMENT<$50K 60; ELEC ENG [29.6 h]; COMP SCIENT [118.4 h]; ELEC TECH [29.6 h] |
| 1212124050 | Update PED Cost and Schedule (CPU & SW)100 | 2007-04-03 → 2007-03-05 A (-29d) | 2007-04-30 → 2007-04-16 A (-14d) | 20d → 31d | 0% → 100% | 172d → none |  |  |
| 1212124055 | Update Construction Cost and Schedule (CPU & SW)100 | 2007-05-01 → 2007-03-13 A (-49d) | 2007-05-29 → 2007-04-23 A (-36d) | 20d → 30d | 0% → 100% | 172d → none |  |  |
| 1212124020M | Start Embedded IOC Design (CPU & SW)100 | 2007-01-02 → 2007-04-02 A (+90d) | 2007-01-02 → 2007-04-02 A (+90d) |  | 0% → 100% | 173d → none |  |  |
| 1212124015 | Refine Embedded IOC Detailed specification (CPU & SW)30 | 2007-03-07 → 2007-04-23 A (+47d) | 2007-04-03 → 2007-07-31 A (+119d) | 20d → 70d | 0% → 100% | 191d → none |  |  |

| ID | Task | Start | Finish | Duration | Complete | Total float | Predecessors | Other |
| --- | --- | --- | --- | --- | --- | --- | --- | --- |
| 1212124045M | Start Cost & Schedule Update (CPU & SW)100 | 2007-04-03 → 2007-04-23 A (+20d) | 2007-04-03 → 2007-04-23 A (+20d) |  | 0% → 100% | 172d → none |  |  |
| 1212124060M | Controls Ready for Baseline (CPU & SW)100 | 2007-05-29 → 2007-04-23 A (-36d) | 2007-05-29 → 2007-04-23 A (-36d) |  | 0% → 100% | 172d → none |  |  |
| 1212124010M | Preliminary Integrated Design Complete (CPU & SW)100 | 2007-03-06 → 2007-04-24 A (+49d) | 2007-03-06 → 2007-04-24 A (+49d) |  | 0% → 100% | 191d → none |  |  |
| 1212124065 | Program EPICS Interface P-1 (CPU&SW) | 2007-10-01 → 2008-01-02 A (+93d) | 2007-11-30 → 2008-01-21 A (+52d) | 43d → 13d | 0% → 100% | 86d → none |  |  |
| 1212124030M | Start Validation Unit Testing (CPU & SW) | 2007-03-29 → 2008-01-07 A (+284d) | 2007-03-29 → 2008-01-07 A (+284d) |  | 0% → 100% | 173d → none |  |  |
| 1212124035 | Conduct Validation Testing w Digital Board (CPU & SW) | 2007-04-06 → 2008-01-07 A (+276d) | 2007-06-05 → 2008-03-28 A (+297d) | 42d → 58d | 0% → 100% | 167d → none |  | resources ELEC ENG [160 h]; SUPPLIES & MATERIALS → SUPPLIES & MATERIALS; ELEC ENG [160 h] |
| 1212124065B | Program EPICS Interface P-2 (CPU&SW) | 2008-06-02 → 2008-01-22 A (-132d) | 2008-08-15 → 2009-02-27 A (+196d) | 54d → 275d | 0% → 100% | 86d → none |  |  |
| 1212124040M | CPU & Software Validation Tests | 2007-06-05 → 2008-03-28 A (+297d) | 2007-06-05 → 2008-03-28 A (+297d) |  | 0% → 100% | 167d → none |  | was named Validation Tests Complete (CPU & SW) |
| 1212124070M | EPICS Ready for Test (CPU&SW) | 2008-08-15 → 2009-02-27 A (+196d) | 2008-08-15 → 2009-02-27 A (+196d) |  | 0% → 100% | 86d → none |  |  |
| 1212124075 | Cavity Tests & Modifications (CPU&SW) | 2008-09-15 → 2009-03-25 A (+191d) | 2009-04-01 → 2009-04-20 A (+19d) | 133d → 19d | 0% → 100% | 86d → none | 1212124070M FS+19d → 1212124070M |  |
| 1212124170 | Pre-Constrctn Dsgn Review (CPU&SW)++ | 2009-05-01 → 2009-03-25 A (-37d) | 2009-05-29 → 2009-05-20 A (-9d) | 20d → 41d | 0% → 100% | 86d → none | 1212124080M FS+11d → 1212124080M |  |
| 1212124080M | CPU & Software tested on Cavity (CPU&SW)++ | 2009-04-15 → 2009-04-20 A (+5d) | 2009-04-15 → 2009-04-20 A (+5d) |  | 0% → 100% | 86d → none | 1212124075 FS+10d → 1212124075 |  |
| 1212124175 | Re-Baseline Actuals Adjustment | 2013-08-30 A | 2013-08-30 A |  | 0% → 100% | 20d → none | 9-130M FS+227d → none |  |
| 5 | **1.2.1.2.1.2.5 TEST STAND** | 2007-03-15 → 2007-04-02 (+18d) |  |  |  |  |  |  |
| 1212125000M | Start Cost & Schedule Update (TEST STAND) | 2007-03-15 → 2007-04-02 A (+18d) | 2007-03-15 → 2007-04-02 A (+18d) |  | 0% → 100% | 26d → none |  |  |
| 1212125005 | Update PED Cost and Schedule (TEST STAND) | 2007-03-15 → 2007-04-02 A (+18d) | 2007-04-25 → 2007-04-16 A (-9d) | 30d → 11d | 0% → 100% | 26d → none |  |  |
| 1212125010 | Update Construction Cost and Schedule (TEST STAND) | 2007-04-26 → 2007-04-16 A (-10d) | 2007-06-07 → 2007-04-23 A (-45d) | 30d → 6d | 0% → 100% | 26d → none |  |  |
| 1212125015M | Test Stand Ready for Baseline (TEST STAND) | 2007-06-07 → 2007-04-23 A (-45d) | 2007-06-07 → 2007-04-23 A (-45d) |  | 0% → 100% | 26d → none |  |  |
| 1212125020 | Dsgn & Fab RF Test Stand (Test STAND)-seeNotebook Entry | 2008-04-08 → 2008-01-14 A (-85d) | 2009-09-28 → 2009-08-31 A (-28d) | 369d → 409d | 0% → 100% | 2d → none |  |  |
| 1212125025M | RF Test Stand Ready for Production Tests (TEST STAND)+ | 2009-09-28 → 2009-08-31 A (-28d) | 2009-09-28 → 2009-08-31 A (-28d) |  | 0% → 100% | 2d → none |  |  |
| 1212125030 | Re-Baseline Actuals Adjustment | 2013-08-30 A | 2013-08-30 A |  | 0% → 100% | 20d → none | 9-130M FS+227d → none |  |
| 6 | **1.2.1.2.1.2.6 MASTER OSCILLATOR** | 2007-03-15 → 2007-04-02 (+18d) |  |  |  |  |  |  |
| 1212126000M | Start Cost & Schedule Update (MSTR OSC) | 2007-03-15 → 2007-04-02 A (+18d) | 2007-03-15 → 2007-04-02 A (+18d) |  | 0% → 100% | 570d → none |  |  |
| 1212126005 | Update PED Cost and Schedule (MSTR OSC) | 2007-03-15 → 2007-04-02 A (+18d) | 2007-04-25 → 2007-04-16 A (-9d) | 30d → 11d | 0% → 100% | 570d → none |  |  |
| 1212126010 | Update Construction Cost and Schedule (MSTR OSC) | 2007-04-26 → 2007-04-16 A (-10d) | 2007-06-07 → 2007-04-23 A (-45d) | 30d → 6d | 0% → 100% | 570d → none |  |  |
| 1212126015M | MO Ready for Baseline (MSTR OSC) | 2007-06-07 → 2007-04-23 A (-45d) | 2007-06-07 → 2007-04-23 A (-45d) |  | 0% → 100% | 570d → none |  |  |
| 1212126170 | Pre-Constrctn Dsgn Review (MSTR OSC) | 2007-06-08 → 2009-03-25 A (+656d) | 2007-06-14 → 2009-05-20 A (+706d) | 5d → 41d | 0% → 100% | 570d → none | 1212126010, 1212126015M → 1212126015M FS+515d, 1212126010 |  |
| 1212126175 | Re-Baseline Actuals Adjustment | 2013-08-30 A | 2013-08-30 A |  | 0% → 100% | 20d → none | 9-130M FS+227d → none |  |
| 7 | **1.2.1.2.1.2.7 HPA CONTROL** | 2006-11-01 → 2007-04-02 (+152d) |  |  |  |  |  |  |
| 1212127000M | Start Preliminary Integrated System Design (HPA CNTRL) | 2006-11-01 → 2007-04-02 A (+152d) | 2006-11-01 → 2007-04-02 A (+152d) |  | 0% → 100% | 243d → none |  |  |
| 1212127005 | Develop Preliminary System Design (HPA CNTRL) | 2006-11-01 → 2007-04-02 A (+152d) | 2007-01-22 → 2007-08-27 A (+217d) | 50d → 104d | 0% → 100% | 276d → none |  |  |
| 1212127020M | Start Cost & Schedule Update (HPA CNTRL) | 2007-04-03 → 2007-04-02 A (-1d) | 2007-04-03 → 2007-04-02 A (-1d) |  | 0% → 100% | 187d → none |  |  |
| 1212127025 | Update PED Cost and Schedule (HPA CNTRL) | 2007-04-03 → 2007-04-02 A (-1d) | 2007-04-30 → 2007-04-16 A (-14d) | 20d → 11d | 0% → 100% | 187d → none |  |  |
| 1212127030 | Update Construction Cost and Schedule (HPA CNTRL) | 2007-05-01 → 2007-04-16 A (-15d) | 2007-05-29 → 2007-04-23 A (-36d) | 20d → 6d | 0% → 100% | 187d → none |  |  |
| 1212127035M | HPA Controls Ready for Baseline (HPA CNTRL) | 2007-05-29 → 2007-04-23 A (-36d) | 2007-05-29 → 2007-04-23 A (-36d) |  | 0% → 100% | 187d → none |  |  |
| 1212127010M | Preliminary Design Complete (HPA CNTRL) | 2007-01-22 → 2007-08-27 A (+217d) | 2007-01-22 → 2007-08-27 A (+217d) |  | 0% → 100% | 276d → none |  |  |
| 1212127015 | Develop Detailed specification P-1 (HPA CNTRL) | 2007-10-01 → 2007-11-01 A (+31d) | 2007-11-30 → 2007-11-19 A (-11d) | 43d → 13d | 0% → 100% | 18d → none |  |  |
| 1212127015B | Develop Detailed specification P-2 (HPA CNTRL) | 2007-12-03 A | 2008-02-06 → 2007-12-21 A (-47d) | 40d → 15d | 0% → 100% | 18d → none |  |  |
| 1212127040 | Dsgn HPA Control Board & Chassis (HPA CNTL) | 2008-02-07 → 2008-01-14 A (-24d) | 2008-08-27 → 2008-06-30 A (-58d) | 142d → 117d | 0% → 100% | 18d → none |  | resources ELEC ENG [160 h]; ELEC DES [400 h]; ELEC TECH [160 h]; SUPPLIES & MATERIALS; PROCUREMENT<$50K 60 → ELEC TECH [160 h]; SUPPLIES & MATERIALS; PROCUREMENT<$50K 60; ELEC ENG [160 h]; ELEC DES [400 h] |
| 1212127045 | PROC Test & Validate Dsgn (HPA CNTL) | 2008-09-12 → 2008-04-16 A (-149d) | 2009-02-06 → 2009-01-26 A (-11d) | 97d → 192d | 0% → 100% | 35d → none |  |  |
| 1212127045a | FY08 LAB/EXP Test & Validate Dsgn (HPA CNTL) | 2008-09-12 → 2008-04-16 A (-149d) | 2008-09-30 A | 13d → 117d | 0% → 100% | 18d → none |  | resources SUPPLIES & MATERIALS; ELEC TECH [21.44 h]; COMP SCIENT [26.8 h]; ELEC DES [53.61 h]; ELEC ENG [16.08 h] → ELEC TECH [21.44 h]; COMP SCIENT [26.8 h]; ELEC DES [53.61 h]; ELEC ENG [16.08 h]; SUPPLIES & MATERIALS |
| 1212127045b | FY09 LAB/EXP Test & Validate Dsgn (HPA CNTL) | 2008-10-01 → 2008-09-22 A (-9d) | 2009-02-06 → 2009-01-26 A (-11d) | 84d → 82d | 0% → 100% | 18d → none |  | resources SUPPLIES & MATERIALS; COMP SCIENT [173.2 h]; ELEC DES [346.39 h]; ELEC ENG [103.92 h]; ELEC TECH [138.56 h] → ELEC DES [346.39 h]; ELEC ENG [103.92 h]; ELEC TECH [138.56 h]; SUPPLIES & MATERIALS; COMP SCIENT [173.2 h] |
| 1212127055 | Assess & Modify Dsgn (HPA CNTL) | 2009-03-05 → 2009-01-26 A (-38d) | 2009-08-05 → 2009-06-24 A (-42d) | 108d → 106d | 0% → 100% | 18d → none |  | resources ELEC DES [160 h]; ELEC ENG [40 h] → ELEC ENG [40 h]; ELEC DES [160 h] |
| 1212127050M | HPA Control Dsgn Tested (HPA CNTL) | 2009-03-04 → 2009-01-26 A (-37d) | 2009-03-04 → 2009-01-26 A (-37d) |  | 0% → 100% | 18d → none | 1212127045, 1212127045b FS+17d → 1212127045, 1212127045b |  |
| 1212127170 | Pre-Constrctn Dsgn Review (HPA CNTL) + | 2009-05-01 → 2009-04-28 A (-3d) | 2009-05-29 → 2009-05-21 A (-8d) | 20d → 18d | 0% → 100% | 86d → none | 1212127050M FS+41d → 1212127050M FS+64d | resources MECH ENG [12 h]; MECH DES [12 h]; ELEC ENG [80 h] → MECH ENG [12 h]; ELEC ENG [80 h]; MECH DES [12 h] |
| 1212127060 | Update Documentation and Procurement Prep (HPA CNTL) | 2009-06-03 → 2009-05-01 A (-33d) | 2009-09-03 → 2009-07-27 A (-38d) | 66d → 60d | 0% → 100% | 18d → none |  |  |
| 1212127065M | HPA control Documentation Ready for Prcrmnt (HPA CNTL)++ | 2009-09-03 → 2009-07-27 A (-38d) | 2009-09-03 → 2009-07-27 A (-38d) |  | 0% → 100% | 18d → none |  |  |
| 1212127175 | Re-Baseline Actuals Adjustment | 2013-08-30 A | 2013-08-30 A |  | 0% → 100% | 20d → none | 9-130M FS+227d → none |  |
| 121221000M | Begin Box PS PED (BOX SUP) | 2006-10-02 A | 2006-10-02 A |  | 0% → 100% | 150d → none |  |  |
| 121221005 | Conduct Spec & Cost Review of Other Projects (BOX SUP) | 2006-10-02 A | 2006-11-10 → 2007-04-20 A (+161d) | 30d → 135d | 0% → 100% | 150d → none |  |  |
| 121221015 | Refine/Update Preliminary Performance Requirements (BOX SUP) | 2006-11-13 → 2006-11-01 A (-12d) | 2006-12-12 → 2007-04-18 A (+127d) | 20d → 111d | 0% → 100% | 150d → none |  |  |
| 121221025M | Begin Preliminary Design Box Power Supplies (BOX SUP) | 2006-12-13 → 2007-01-02 A (+20d) | 2006-12-13 → 2007-01-02 A (+20d) |  | 0% → 100% | 150d → none |  |  |
| 121221030 | Develop Preliminary PS Design (BOX SUP) | 2006-12-13 → 2007-01-02 A (+20d) | 2007-02-01 → 2007-04-23 A (+81d) | 30d → 78d | 0% → 100% | 150d → none |  | resources ELEC ENG [174 h]; ELEC DES [139.2 h]; ELEC TECH [34.8 h]; COMP SCIENT [104.4 h] → ELEC DES [139.2 h]; COMP SCIENT [104.4 h]; ELEC ENG [174 h]; ELEC TECH [34.8 h] |
| 121221035 | Review & Revise PS Re-use Plan & Cost Estimate (BOX SUP) | 2007-02-02 → 2007-01-02 A (-31d) | 2007-03-02 → 2007-04-20 A (+49d) | 20d → 77d | 0% → 100% | 150d → none |  | resources ELEC ENG [13.92 h]; ELEC DES [69.6 h]; ELEC TECH [69.6 h] → ELEC DES [69.6 h]; ELEC TECH [69.6 h]; ELEC ENG [13.92 h] |
| 121221050 | Update Cost and Labor Estimates (BOX SUP) | 2007-03-26 → 2007-01-15 A (-70d) | 2007-04-20 → 2007-04-24 A (+4d) | 20d → 70d | 0% → 100% | 150d → none |  |  |
| 121221065 | Investigate Potential Vendors to Develop Bidders list (BOX SUP) | 2007-05-21 → 2007-01-15 A (-126d) | 2007-06-18 → 2007-08-20 A (+63d) | 20d → 152d | 0% → 100% | 157d → none |  |  |
| 121221010 | Travel _ Visit Other Projects (BOX SUP) | 2006-10-02 → 2007-03-02 A (+151d) | 2006-11-10 → 2007-07-31 A (+263d) | 30d → 106d | 0% → 100% | 150d → none |  |  |
| 121221055 | Update Resource Loaded Schedule (BOX SUP) | 2007-04-23 → 2007-03-02 A (-52d) | 2007-05-18 → 2007-04-24 A (-24d) | 20d → 38d | 0% → 100% | 150d → none |  |  |
| 121221040 | Prepare & Conduct Preliminary Design & Safety Review (BOX SUP) | 2007-03-05 → 2007-04-09 A (+35d) | 2007-03-23 → 2007-05-18 A (+56d) | 15d → 30d | 0% → 100% | 150d → none |  |  |
| 121221020M | Preliminary Preformance Requirements Update Complete (BOX SUP) | 2006-12-12 → 2007-04-18 A (+127d) | 2006-12-12 → 2007-04-18 A (+127d) |  | 0% → 100% | 150d → none |  |  |
| 121221045M | Preliminary Design & Safety Review Complete (BOX SUP) | 2007-03-23 → 2007-05-18 A (+56d) | 2007-03-23 → 2007-05-18 A (+56d) |  | 0% → 100% | 150d → none |  |  |
| 121221070 | Write Preliminary PS Design Document (BOX SUP) | 2007-06-19 → 2007-08-20 A (+62d) | 2007-08-01 → 2007-10-15 A (+75d) | 31d → 40d | 0% → 100% | 157d → none |  | resources ELEC ENG [34.8 h]; ELEC DES [34.8 h]; COMP SCIENT [34.8 h] → COMP SCIENT [34.8 h]; ELEC ENG [34.8 h]; ELEC DES [34.8 h] |
| 121221085 | Develop Dsgn & Specification for 1000 kW Box PS | 2007-10-01 A | 2008-01-03 → 2008-11-06 A (+308d) | 60d → 275d | 0% → 100% | 116d → none |  |  |
| 121221090 | Develop Dsgn & Specification for 600 kW Box PS | 2007-10-01 A | 2008-01-03 → 2008-11-06 A (+308d) | 60d → 275d | 0% → 100% | 116d → none |  | resources COMP SCIENT [40 h]; ELEC DES [20 h]; ELEC ENG [80 h] → ELEC DES [20 h]; ELEC ENG [80 h]; COMP SCIENT [40 h] |
| 121221095 | Develop Dsgn & Specification for Low Power (100/30 kW) Box PS | 2007-10-01 A | 2008-01-03 → 2008-11-06 A (+308d) | 60d → 275d | 0% → 100% | 116d → none |  | resources ELEC DES [20 h]; ELEC ENG [80 h]; COMP SCIENT [40 h] → COMP SCIENT [40 h]; ELEC DES [20 h]; ELEC ENG [80 h] |
| 121221100 | Develop Design Spec for Dummy load | 2008-02-04 → 2007-11-05 A (-91d) | 2008-03-03 → 2008-12-22 A (+294d) | 20d → 280d | 0% → 100% | 46d → none |  | resources ELEC DES [80 h]; ELEC ENG [80 h]; ELEC TECH [40 h] → ELEC ENG [80 h]; ELEC DES [80 h]; ELEC TECH [40 h] |
| 121221075M | Preliminary PS Design Document Complete (BOX SUP) | 2007-08-01 → 2007-11-15 A (+106d) | 2007-08-01 → 2007-11-15 A (+106d) |  | 0% → 100% | 157d → none |  |  |
| 121221105 | Develop Box PS Re-use Plans | 2008-02-04 → 2008-02-19 A (+15d) | 2008-03-03 → 2009-01-27 A (+330d) | 20d → 234d | 0% → 100% | 336d → none |  |  |
| 121221110 | Prepare Procurement Plan for Box PS Refurbishment | 2008-03-04 → 2008-02-19 A (-14d) | 2008-04-14 → 2009-01-27 A (+288d) | 30d → 234d | 0% → 100% | 336d → none |  |  |
| 121221125 | Create Bill of Materials & Parts List for YA and Shunt PS | 2008-02-19 → 2008-05-14 A (+85d) | 2008-03-31 → 2009-05-29 A (+424d) | 30d → 259d | 0% → 100% | 346d → none |  |  |

| ID | Task | Start | Finish | Duration | Complete | Total float | Predecessors | Other |
| --- | --- | --- | --- | --- | --- | --- | --- | --- |
| 121221120 | Develop Plan for YA and Shunt PS | 2008-01-04 → 2008-05-15 A (+132d) | 2008-02-15 → 2009-03-27 A (+406d) | 30d → 214d | 0% → 100% | 116d → none |  |  |
| 121221140 | Update Cost & Labor Estimates (Box SUPPLIES) | 2008-04-15 → 2008-07-14 A (+90d) | 2008-05-27 → 2009-03-25 A (+302d) | 30d → 172d | 0% → 100% | 46d → none |  |  |
| 121221145 | Update Schedule (Box SUPPLIES) | 2008-04-15 → 2008-07-16 A (+92d) | 2008-05-27 → 2009-06-22 A (+391d) | 30d → 232d | 0% → 100% | 46d → none |  |  |
| 121221150 | Prep Final Specification & Prcrmnt Package (Box SUPPLIES)+ | 2008-07-24 → 2008-12-18 A (+147d) | 2008-09-04 → 2009-01-21 A (+139d) | 30d → 18d | 0% → 100% | 266d → none | 121221125, 121221140 FS+40d, 121221110, 121221145 FS+40d → 121221125 FS-25d, 121221140 FS-25d, 121221110 FS-25d, 121221145 FS-25d |  |
| 121221135 | Pre-Constrctn Final Sys & Safty Review (Box SUPPLIES) | 2008-03-04 → 2009-09-21 A (+566d) | 2008-04-14 → 2009-10-30 A (+564d) |  | 0% → 100% | 46d → none |  | resources ELEC ENG [160 h]; ELEC TECH [20 h] → ELEC TECH [20 h]; ELEC ENG [160 h] |
| 121221155 | Re-Baseline Actuals Adjustment | 2013-08-30 A | 2013-08-30 A |  | 0% → 100% | 20d → none | 9-130M FS+227d → none |  |
| 3 | **1.2.1.2.2.3 TRIMS - PED** | 2006-10-02 → 2006-11-01 (+30d) |  |  |  |  |  |  |
| 121223000M | Start Trim PED (TRIMS) | 2006-10-02 → 2006-11-01 A (+30d) | 2006-10-02 → 2006-11-01 A (+30d) |  | 0% → 100% | 146d → none |  |  |
| 121223005 | Update Trim PS Counts and System design- update TDR (TRIMS) | 2006-10-02 → 2006-11-01 A (+30d) | 2007-01-10 → 2007-04-05 A (+85d) | 65d → 102d | 0% → 100% | 170d → none |  |  |
| 121223010 | Procure utility chassis sample and Bulk PS sample (TRIMS) | 2006-10-02 → 2006-12-15 A (+74d) | 2007-01-02 → 2007-04-12 A (+100d) | 59d → 77d | 0% → 100% | 146d → none |  |  |
| 121223025 | Update Trim PS Cost estimate (TRIMS) | 2007-02-15 → 2007-01-31 A (-15d) | 2007-03-29 → 2007-04-23 A (+25d) | 30d → 58d | 0% → 100% | 146d → none |  |  |
| 121223020 | Install samples into Trim test stand and Test (TRIMS) | 2007-01-03 → 2007-03-19 A (+75d) | 2007-02-14 → 2007-09-19 A (+217d) | 30d → 130d | 0% → 100% | 146d → none |  |  |
| 121223030 | Develop resource loaded schedule (TRIMS) | 2007-03-30 → 2007-03-26 A (-4d) | 2007-05-24 → 2007-04-23 A (-31d) | 40d → 21d | 0% → 100% | 146d → none |  |  |
| 121223015M | Receive sample hardware (TRIMS) | 2007-01-02 → 2007-04-12 A (+100d) | 2007-01-02 → 2007-04-12 A (+100d) |  | 0% → 100% | 146d → none |  |  |
| 121223030M | Start Trim FY08 PED (TRIMS) | 2007-10-01 A | 2007-10-01 A |  | 0% → 100% | 36d → none |  |  |
| 121223032 | Proc Sample Commercial PS (TRIMS) | 2007-10-01 A | 2008-01-03 → 2008-03-18 A (+75d) | 60d → 111d | 0% → 100% | 36d → none |  | resources PROCUREMENT<$50K 60; ELEC ENG [40 h] → ELEC ENG [40 h]; PROCUREMENT<$50K 60 |
| 121223045 | Prep Trim Sys Database (TRIMS) | 2008-03-04 → 2007-11-02 A (-123d) | 2008-04-14 A | 30d → 106d | 0% → 100% | 36d → none |  | resources ELEC ENG [120 h]; COMP SCIENT [160 h] → COMP SCIENT [160 h]; ELEC ENG [120 h] |
| 121223040 | Develop Specification for 20 amp trim (TRIMS) | 2008-01-18 → 2008-01-14 A (-4d) | 2008-03-03 → 2008-12-22 A (+294d) | 30d → 239d | 0% → 100% | 36d → none |  | resources SUPPLIES & MATERIALS; ELEC ENG [120 h]; ELEC DES [40 h]; COMP SCIENT [40 h] → ELEC ENG [120 h]; ELEC DES [40 h]; COMP SCIENT [40 h]; SUPPLIES & MATERIALS |
| 121223035 | Test Sample PS (TRIMS) | 2008-01-04 → 2008-03-03 A (+59d) | 2008-01-17 → 2008-03-11 A (+54d) | 10d → 7d | 0% → 100% | 36d → none |  |  |
| 121223060 | FY08 Prep Final Specification & Prcrmnt Package (TRIMS) | 2008-06-11 → 2008-05-15 A (-27d) | 2008-09-30 → 2009-08-24 A (+328d) | 78d → 318d | 0% → 100% | 196d → none | 121223055, 9-080M, 121223050 → 121223050 FS-60d, 9-080M, 121223055 FS-43d |  |
| 121223055 | Develop Sys Drawings (TRIMS)++ | 2008-04-15 → 2008-06-23 A (+69d) | 2008-05-27 → 2009-06-22 A (+391d) | 30d → 248d | 0% → 100% | 36d → none | 121223045 → 121223045 FS-15d |  |
| 121223060a | FY09 Prep Final Specification & Prcrmnt Package (TRIMS) | 2008-10-01 → 2009-03-25 A (+175d) | 2008-12-15 → 2009-08-24 A (+252d) | 52d → 107d | 0% → 100% | 196d → none | 121223060 → 121223060 FS-250d |  |
| 121223050 | Pre-Constrctn Final Sys & Safty Review (TRIMS)++ | 2008-05-28 → 2009-09-21 A (+481d) | 2008-06-10 → 2009-10-30 A (+507d) | 10d → 30d | 0% → 100% | 36d → none | 121223045, 121223055 → 121223045, 121223055 FS-27d | resources COMP SCIENT [40 h]; ELEC ENG [80 h] → ELEC ENG [80 h]; COMP SCIENT [40 h] |
| 121223065 | Re-Baseline Actuals Adjustment | 2013-08-30 A | 2013-08-30 A |  | 0% → 100% | 20d → none | 9-130M FS+227d → none |  |
| 121224022 | Preliminary Installation Integration (INSTALL) | 2006-11-01 A | 2007-05-30 → 2007-10-26 A (+149d) | 140d → 245d | 0% → 100% | 143d → none |  |  |
| 121224010 | Update Hall D Equipment Layout (INSTALL) | 2007-03-15 → 2007-01-15 A (-59d) | 2007-04-04 → 2007-08-27 A (+145d) | 15d → 157d | 0% → 100% | 125d → none |  |  |
| 121224020 | Develop Box PS Cable Installation requirements (INSTALL) | 2007-04-05 → 2007-01-31 A (-64d) | 2007-05-02 → 2007-09-26 A (+147d) | 20d → 167d | 0% → 100% | 125d → none |  | resources ELEC DES [17.4 h]; ELEC ENG [17.4 h] → ELEC ENG [17.4 h]; ELEC DES [17.4 h] |
| 121224005 | Update Trim PS Counts (INSTALL) | 2007-03-15 A | 2007-03-28 → 2007-04-16 A (+19d) | 10d → 23d | 0% → 100% | 130d → none |  |  |
| 121224015 | Develop Trim Installation requirements (INSTALL) | 2007-04-05 → 2007-03-15 A (-21d) | 2007-05-02 → 2007-10-19 A (+170d) | 20d → 154d | 0% → 100% | 125d → none |  |  |
| 121224025 | Update cost estimate (INSTALL) | 2007-05-03 → 2007-03-19 A (-45d) | 2007-05-23 → 2007-04-16 A (-37d) | 15d → 21d | 0% → 100% | 125d → none |  |  |
| 121224000M | Start Installation Planning (INSTALL) | 2007-03-15 → 2007-05-01 A (+47d) | 2007-03-15 → 2007-05-01 A (+47d) |  | 0% → 100% | 125d → none |  |  |
| 121224030 | Create Installation Plan and schedule (INSTALL) | 2007-05-24 → 2007-10-01 A (+130d) | 2007-06-25 → 2007-10-04 A (+101d) | 22d → 4d | 0% → 100% | 125d → none |  |  |
| 121224035 | Dsgn & Assemble Proto Box PS Cable Interconnection Sys (Installtn) | 2007-10-01 A | 2007-12-11 → 2008-03-21 A (+101d) | 50d → 114d | 0% → 100% | 151d → none |  | resources ELEC ENG [80 h]; ELEC TECH [20 h]; SKLLD TRADE [80 h]; PROCUREMENT<$50K 60; ELEC DES [20 h] → PROCUREMENT<$50K 60; ELEC ENG [80 h]; ELEC DES [20 h]; ELEC TECH [20 h]; SKLLD TRADE [80 h] |
| 121224040 | Review/Revise Cable Lists- DC Pwr, Interlocks, Controls - Develop Installtn Database (Installtn) | 2007-10-01 A | 2008-01-03 → 2008-12-05 A (+337d) | 60d → 294d | 0% → 100% | 41d → none |  | resources SUPPLIES & MATERIALS; ELEC ENG [60 h]; ELEC TECH [40 h]; COMP SCIENT [160 h] → ELEC ENG [60 h]; ELEC TECH [40 h]; COMP SCIENT [160 h]; SUPPLIES & MATERIALS |
| 121224045 | Dsgn Cable Tray Layout, Prep Installtn Drawings (Installtn) | 2008-01-04 → 2008-01-14 A (+10d) | 2008-02-01 → 2008-10-28 A (+270d) | 20d → 202d | 0% → 100% | 41d → none |  | resources ELEC DES [60 h]; ELEC ENG [40 h] → ELEC ENG [40 h]; ELEC DES [60 h] |
| 121224050 | Develop Box Supply Shuffle-Rebuild-Install Plan & S/R Plan (Installtn) | 2008-02-04 → 2008-03-03 A (+28d) | 2008-03-03 → 2009-01-02 A (+305d) | 20d → 209d | 0% → 100% | 41d → none | 121224045 → 121224045 FS-20d |  |
| 121224055 | Prep/Dsgn Utility Installtn - LCW & AC Pwr (Installtn) | 2008-03-04 → 2008-03-31 A (+27d) | 2008-04-14 → 2009-02-27 A (+319d) | 30d → 227d | 0% → 100% | 41d → none | 121224050 → 121224050 FS-40d | resources ELEC ENG [20 h]; ELEC DES [80 h]; PROCUREMENT<$50K 60; ELEC TECH [40 h] → ELEC DES [80 h]; ELEC ENG [20 h]; PROCUREMENT<$50K 60; ELEC TECH [40 h] |
| 121224060 | Prep Bill of Matrl's & Update Matrl's & Labor Cost Estimate (Installtn) | 2008-04-15 → 2008-07-04 A (+80d) | 2008-05-05 → 2009-06-22 A (+413d) | 15d → 239d | 0% → 100% | 41d → none | 121224055 → 121224055 FS-20d | resources ELEC TECH [40 h]; COMP SCIENT [40 h]; SKLLD TRADE [40 h]; ELEC ENG [40 h] → COMP SCIENT [40 h]; SKLLD TRADE [40 h]; ELEC ENG [40 h]; ELEC TECH [40 h] |
| 121224065 | Perform Installtn Hazard Analysis & Revise Schedule (Installtn)++ | 2008-05-06 → 2009-02-02 A (+272d) | 2008-05-27 → 2009-10-30 A (+521d) | 15d → 191d | 0% → 100% | 41d → none | 121224060 → 121224060 FS-5d |  |
| 121224999 | Pre-Constrctn Final Sys & Safty Review (Installtn)++ | 2008-05-28 → 2009-10-12 A (+502d) | 2008-06-03 → 2009-10-30 A (+514d) | 5d → 15d | 0% → 100% | 41d → none |  |  |
| 121224070 | Re-Baseline Actuals Adjustment | 2013-08-30 A | 2013-08-30 A |  | 0% → 100% | 20d → none | 9-130M FS+227d → none |  |
| 12131010M | Preliminary Engineering Design & Safety Review Completed (ACCEL) | 2007-01-12 → 2007-07-23 A (+192d) | 2007-01-12 → 2007-07-23 A (+192d) |  | 0% → 100% | 21d → none |  |  |
| 12131.01005 | Develop CHL Building Layout and Utility Schedule (CHL BLDG) | 2006-10-02 A | 2006-10-20 → 2006-12-22 A (+63d) | 15d → 58d | 0% → 100% | 68d → none |  |  |
| 12131.01010 | Re-Baseline Actuals Adjustment | 2013-08-30 A | 2013-08-30 A |  | 0% → 100% | 20d → none | 9-130M FS+227d → none |  |
| 03 | **1.2.1.3.1.03 CHL WARM HELIUM COMPRESSORS** | 2006-10-02 → 2006-12-07 (+66d) |  |  |  |  |  |  |
| 12131.03005 | Develop Warm Helium Compressor Piping Dsgn, Prelim | 2006-10-02 → 2006-12-07 A (+66d) | 2007-01-05 → 2007-03-22 A (+76d) | 62d → 68d | 0% → 100% | 21d → none |  | resources ELEC DES [52 h]; SUPPLIES & MATERIALS; MECH ENG [104.4 h]; TRAVEL; SR STAFF [20.8 h]; MECH DES [146.16 h]; ELEC ENG [89.09 h] → ELEC DES [52 h]; SUPPLIES & MATERIALS; TRAVEL; SR STAFF [20.8 h]; MECH ENG [104.4 h]; MECH DES [146.16 h]; ELEC ENG [89.09 h] |
| 12131.03010 | FY-07 Develop Warm Helium Compressor Piping Design Initial Phase Final Design (CHL WARM HEL COMPR) | 2007-04-23 → 2007-08-03 A (+102d) | 2007-05-31 → 2007-09-10 A (+102d) | 28d → 26d | 0% → 100% | 290d → none |  | resources SUPPLIES & MATERIALS; TRAVEL; MECH ENG [111.6 h]; SR STAFF [118.4 h]; MECH DES [28.4 h]; ELEC ENG [22.4 h] → ELEC ENG [22.4 h]; SUPPLIES & MATERIALS; TRAVEL; MECH ENG [111.6 h]; SR STAFF [118.4 h]; MECH DES [28.4 h] |
| 12131.03012 | FY-08 Develop Wrm He Cmprssr Piping Dsgn, Initl Phase Final Dsgn | 2008-10-01 → 2008-03-12 A (-203d) | 2008-11-07 → 2008-04-30 A (-191d) | 28d → 36d | 0% → 100% | 140d → none | 12131.03010, 9-090M → 12131.03010 FS+120d | resources ELEC ENG [200 h]; ELEC DES [120 h]; MECH DES [800 h]; MECH ENG [1520 h] → ELEC ENG [200 h]; MECH ENG [1520 h]; MECH DES [800 h]; ELEC DES [120 h] |
| 12131.03015 | CHL Warm Helium Compressors++ | 2008-11-10 → 2008-04-04 A (-220d) | 2009-03-06 → 2008-10-13 A (-144d) | 75d → 134d | 0% → 100% | 140d → none |  | resources SR STAFF [280 h]; MECH ENG [600 h]; ELEC ENG [160 h]; MECH DES [320 h]; ELEC DES [120 h] → ELEC DES [120 h]; SR STAFF [280 h]; MECH ENG [600 h]; MECH DES [320 h]; ELEC ENG [160 h] |
| 12131.03020 | CHL Warm Helium Compressors Pre-Constrctn Dsgn Review+ | 2009-03-09 A | 2009-03-13 → 2009-04-20 A (+38d) | 5d → 31d | 0% → 100% | 140d → none | 12131.03015 → 12131.03015, 9-090M FS+100d |  |
| 12131.03025 | Re-Baseline Actuals Adjustment | 2013-08-30 A | 2013-08-30 A |  | 0% → 100% | 20d → none | 9-130M FS+227d → none |  |
| 04 | **1.2.1.3.1.04 CHL COLD BOXES** | 2006-10-02 → 2006-12-07 (+66d) |  |  |  |  |  |  |
| 12131.04005 | Develop CHL Cold Box Field Piping Design Preliminary (CHL COLD BOX) | 2006-10-02 → 2006-12-07 A (+66d) | 2007-01-05 → 2007-03-16 A (+70d) | 62d → 64d | 0% → 100% | 21d → none |  | resources MECH DES [141.29 h]; SR STAFF [20.8 h]; MECH ENG [151.73 h]; ELEC ENG [41.76 h]; ELEC DES [36.19 h]; SUPPLIES & MATERIALS; TRAVEL → MECH ENG [151.73 h]; ELEC DES [36.19 h]; SUPPLIES & MATERIALS; TRAVEL; SR STAFF [20.8 h]; MECH DES [141.29 h]; ELEC ENG [41.76 h] |
| 12131.04010 | Conduct Prelimin Eng Design & Safety Review for WBS 1.2.1.3.1 Elements (CHL COLD BOX) | 2007-01-08 → 2007-03-16 A (+67d) | 2007-01-12 → 2007-05-14 A (+122d) | 5d → 42d | 0% → 100% | 21d → none |  |  |
| 12131.04015 | FY-07 Develop CHL Cold Box Field Piping Design Initial Phase Final Design (CHL COLD BOX) | 2007-01-16 → 2007-03-28 A (+71d) | 2007-05-15 → 2007-08-31 A (+108d) | 85d → 111d | 0% → 100% | 146d → none |  | resources ELEC ENG [76.8 h]; MECH ENG [57.6 h]; SUPPLIES & MATERIALS; TRAVEL; SR STAFF [118.4 h] → ELEC ENG [76.8 h]; TRAVEL; SUPPLIES & MATERIALS; MECH ENG [57.6 h]; SR STAFF [118.4 h] |
| 12131.04017 | FY-08 Develop CHL Cold Box Field Piping Dsgn, Final Phase Final Dsgn | 2007-10-01 A | 2008-01-10 → 2008-01-08 A (-2d) | 65d → 63d | 0% → 100% | 51d → none |  | resources ELEC ENG [160 h]; ELEC DES [120 h]; MECH DES [800 h]; MECH ENG [800 h] → ELEC DES [120 h]; MECH DES [800 h]; MECH ENG [800 h]; ELEC ENG [160 h] |
| 12131.04020 | P-1 CHL Cold Box, Dsgn Installtn+ | 2008-01-11 → 2008-01-09 A (-2d) | 2008-05-19 A | 90d → 92d | 0% → 100% | 51d → none |  | resources MECH ENG [480 h]; SUPPLIES & MATERIALS; SR STAFF [120 h]; MECH DES [360 h]; ELEC ENG [80 h] → SR STAFF [120 h]; MECH ENG [480 h]; MECH DES [360 h]; ELEC ENG [80 h]; SUPPLIES & MATERIALS |
| 12131.04025 | P-2 CHL Cold Box, Dsgn Installtn+ | 2009-01-05 A | 2009-05-12 → 2009-09-30 A (+141d) | 90d → 188d | 0% → 100% | 98d → none |  | resources SUPPLIES & MATERIALS; MECH DES [400 h]; SR STAFF [160 h]; MECH ENG [480 h]; ELEC ENG [80 h] → SR STAFF [160 h]; MECH ENG [480 h]; MECH DES [400 h]; ELEC ENG [80 h]; SUPPLIES & MATERIALS |
| 12131.04030 | Re-Baseline Actuals Adjustment | 2013-08-30 A | 2013-08-30 A |  | 0% → 100% | 20d → none | 9-130M FS+227d → none |  |
| 05 | **1.2.1.3.1.05 CHL OIL REMOVAL SYSTEMS** | 2006-10-02 → 2006-12-07 (+66d) |  |  |  |  |  |  |
| 12131.05005 | Develop Oil Removal Equipment Fabricaton Drawings Preliminary (CHL OIL REM SYS) | 2006-10-02 → 2006-12-07 A (+66d) | 2007-01-05 → 2007-02-27 A (+53d) | 62d → 51d | 0% → 100% | 21d → none |  | resources MECH DES [31.32 h]; ELEC DES [10.44 h]; MECH ENG [15.31 h]; ELEC ENG [15.31 h] → ELEC DES [10.44 h]; MECH ENG [15.31 h]; MECH DES [31.32 h]; ELEC ENG [15.31 h] |
| 12131.05010 | Develop Oil Removal Equipment Fabricaton Drawings Initial Phase Final Design (CHL OIL REM SYS) | 2007-03-23 → 2007-06-11 A (+80d) | 2007-05-01 → 2007-08-22 A (+113d) | 28d → 52d | 0% → 100% | 304d → none |  | resources ELEC DES [59.16 h]; MECH ENG [89.09 h]; MECH DES [177.48 h]; ELEC ENG [89.09 h] → ELEC DES [59.16 h]; ELEC ENG [89.09 h]; MECH DES [177.48 h]; MECH ENG [89.09 h] |
| 12131.05020 | Re-Baseline Actuals Adjustment | 2013-08-30 A | 2013-08-30 A |  | 0% → 100% | 20d → none | 9-130M FS+227d → none |  |
| 06 | **1.2.1.3.1.06 CHL GAS MANAGEMENT RACK** | 2006-10-02 → 2006-12-07 (+66d) |  |  |  |  |  |  |
| 12131.06005 | Develop Gas Management Rack Assembly and Fabrication Drawings Preliminary (CHL GAS MNGMT RACK) | 2006-10-02 → 2006-12-07 A (+66d) | 2007-01-05 → 2007-02-23 A (+49d) | 62d → 49d | 0% → 100% | 21d → none |  | resources MECH DES [20.88 h]; ELEC DES [16.01 h]; ELEC ENG [16.01 h] → ELEC DES [16.01 h]; ELEC ENG [16.01 h]; MECH DES [20.88 h] |
| 12131.06010 | Develop Gas Management Rack Assembly and Fabrication Drawings Initial Phase Final Design (CHL GAS MNGMT RACK) | 2007-03-14 A | 2007-04-20 → 2007-07-30 A (+101d) | 28d → 97d | 0% → 100% | 290d → none |  | resources ELEC DES [88.39 h]; ELEC ENG [88.39 h]; MECH DES [118.32 h] → ELEC ENG [88.39 h]; ELEC DES [88.39 h]; MECH DES [118.32 h] |
| 12131.06015 | Re-Baseline Actuals Adjustment | 2013-08-30 A | 2013-08-30 A |  | 0% → 100% | 20d → none | 9-130M FS+227d → none |  |
| 07 | **1.2.1.3.1.07 CHL SYSTEM INSTRUMENTATION & CONTROLS** | 2006-10-02 → 2007-01-04 (+94d) |  |  |  |  |  |  |
| 12131.07005 | Develop CHL Instrumentation and Controls Assembly Design Preliminary (CHL SYS INSTR & CNTRLS) | 2006-10-02 → 2007-01-04 A (+94d) | 2007-01-05 → 2007-03-16 A (+70d) | 62d → 50d | 0% → 100% | 21d → none |  | resources ELEC DES [183.05 h]; SUPPLIES & MATERIALS; PROCUREMENT<$50K 60; ELEC ENG [350.09 h] → SUPPLIES & MATERIALS; ELEC ENG [350.09 h]; ELEC DES [183.05 h]; PROCUREMENT<$50K 60 |
| 12131.07010 | FY-07 Develop CHL Instrumentation and Controls Assembly Design Initial Phase Final Design (CHL SYS INSTR & CNTRLS) | 2007-01-16 → 2007-03-09 A (+52d) | 2007-09-28 → 2007-09-25 A (-3d) | 180d → 140d | 0% → 100% | 21d → none |  | resources SUPPLIES & MATERIALS; ELEC ENG [181.6 h]; ELEC DES [114.8 h]; PROCUREMENT<$50K 60 → ELEC ENG [181.6 h]; SUPPLIES & MATERIALS; ELEC DES [114.8 h]; PROCUREMENT<$50K 60 |

| ID | Task | Start | Finish | Duration | Complete | Total float | Predecessors | Other |
| --- | --- | --- | --- | --- | --- | --- | --- | --- |
| 12131.07012 | FY-08 Develop CHL Inst & Controls Assy Dsgn, Initl Phase Final Dsgn | 2007-10-01 A | 2008-05-12 → 2008-05-09 A (-3d) | 150d → 149d | 0% → 100% | 21d → none |  |  |
| 12131.07015 | PROC Engineer CHL Sys Instrmenttn & Controls+ | 2008-05-13 → 2008-05-12 A (-1d) | 2009-08-31 → 2009-09-30 A (+30d) | 325d → 347d | 0% → 100% | 21d → none |  |  |
| 12131.07015a | FY08 LAB/EXP Engineer CHL Sys Instrmenttn & Controls+ | 2008-05-13 → 2008-05-12 A (-1d) | 2008-09-30 → 2008-09-15 A (-15d) | 98d → 88d | 0% → 100% | 21d → none |  | resources ELEC DES [84.43 h]; SUPPLIES & MATERIALS; ELEC ENG [156.8 h] → ELEC ENG [156.8 h]; ELEC DES [84.43 h]; SUPPLIES & MATERIALS |
| 12131.07015b | FY09 LAB/EXP Engineer CHL Sys Instrmenttn & Controls+ | 2008-10-01 → 2008-09-16 A (-15d) | 2009-08-31 A | 227d → 238d | 0% → 100% | 21d → none |  | resources SUPPLIES & MATERIALS; ELEC DES [195.57 h]; ELEC ENG [363.2 h] → ELEC DES [195.57 h]; ELEC ENG [363.2 h]; SUPPLIES & MATERIALS |
| 12131.07020 | Re-Baseline Actuals Adjustment | 2013-08-30 A | 2013-08-30 A |  | 0% → 100% | 20d → none | 9-130M FS+227d → none |  |
| 08 | **1.2.1.3.1.08 CHL INSTRUMENT AIR SYSTEM** | 2009-04-08 → 2009-01-19 (-79d) |  |  |  |  |  |  |
| 12131.08000 | CHL Instrument Air Sys Engrng+ | 2009-04-08 → 2009-01-19 A (-79d) | 2009-08-27 → 2009-05-29 A (-90d) | 100d → 92d | 0% → 100% | 23d → none |  |  |
| 12131.08010 | Re-Baseline Actuals Adjustment | 2013-08-30 A | 2013-08-30 A |  | 0% → 100% | 20d → none | 9-130M FS+227d → none |  |
| 09 | **1.2.1.3.1.09 MOTOR CONTROL CENTERS** | 2009-04-08 → 2008-12-16 (-113d) |  |  |  |  |  |  |
| 12131.09000 | Motor Control Center Specification Development+ | 2009-04-08 → 2008-12-16 A (-113d) | 2009-05-19 → 2009-05-29 A (+10d) | 30d → 110d | 0% → 100% | 93d → none | 9-090M FS+125d → 9-090M FS+85d |  |
| 12131.09005 | Re-Baseline Actuals Adjustment | 2013-08-30 A | 2013-08-30 A |  | 0% → 100% | 20d → none | 9-130M FS+227d → none |  |
| 10 | **1.2.1.3.1.10 CHL INSTALLATION DESIGN** | 2006-10-02 → 2007-01-04 (+94d) |  |  |  |  |  |  |
| 12131.10005 | Develop Utility Field Piping Installation Design Preliminary (CHL INSTAL DES) | 2006-10-02 → 2007-01-04 A (+94d) | 2006-12-19 → 2007-03-19 A (+90d) | 55d → 51d | 0% → 100% | 28d → none |  | resources MECH ENG [278.4 h]; MECH DES [626.4 h] → MECH DES [626.4 h]; MECH ENG [278.4 h] |
| 12131.10010 | Engineer & Dsgn CHL Installtn+ | 2007-10-01 → 2007-09-10 A (-21d) | 2008-06-24 → 2008-07-25 A (+31d) | 180d → 216d | 0% → 100% | 26d → none |  | resources ELEC DES [200 h]; SR STAFF [240 h]; ELEC ENG [240 h]; MECH DES [720 h]; SUPPLIES & MATERIALS; MECH ENG [320 h] → MECH DES [720 h]; SUPPLIES & MATERIALS; MECH ENG [320 h]; SR STAFF [240 h]; ELEC ENG [240 h]; ELEC DES [200 h] |
| 12131.10015 | Re-Baseline Actuals Adjustment | 2013-08-30 A | 2013-08-30 A |  | 0% → 100% | 20d → none | 9-130M FS+227d → none |  |
| 12131.11005 | Develop CHL Commissioning Design and Plan Preliminary (CHL COMMIS) | 2006-10-02 A | 2006-11-17 → 2007-01-12 A (+56d) | 35d → 67d | 0% → 100% | 48d → none |  | resources MECH ENG [348 h]; ELEC ENG [174 h]; MECH TECH [522 h]; ELEC TECH [174 h] → MECH ENG [348 h]; MECH TECH [522 h]; ELEC TECH [174 h]; ELEC ENG [174 h] |
| 12131.11010 | Develop CHL Cmmssng Plan++ | 2008-01-04 → 2008-01-03 A (-1d) | 2008-03-10 → 2008-03-03 A (-7d) | 45d → 41d | 0% → 100% | 101d → none |  | resources ELEC ENG [160 h]; MECH ENG [280 h] → MECH ENG [280 h]; ELEC ENG [160 h] |
| 12131.11015 | Re-Baseline Actuals Adjustment | 2013-08-30 A | 2013-08-30 A |  | 0% → 100% | 20d → none | 9-130M FS+227d → none |  |
| 2 | **1.2.1.3.2 HALL D** | 2009-01-12 → 2008-01-28 (-350d) |  |  |  |  |  |  |
| 2 | **1.2.1.3.2.2 HALL D COLD BOX** | 2009-04-08 → 2009-02-11 (-56d) |  |  |  |  |  |  |
| 121322000 | Evaluate H-D Refrigerator Cold Box+ | 2009-04-08 → 2009-02-11 A (-56d) | 2009-05-27 → 2009-06-08 A (+12d) | 35d → 82d | 0% → 100% | 88d → none |  |  |
| 121322005 | Re-Baseline Actuals Adjustment | 2013-08-30 A | 2013-08-30 A |  | 0% → 100% | 20d → none | 9-130M FS+227d → none |  |
| 3 | **1.2.1.3.2.3 HALL D DISTRIBUTION SYSTEM** | 2009-01-12 → 2009-01-09 (-3d) |  |  |  |  |  |  |
| 121323000 | Dsgn H-D Refrigerator Interconnecting Piping+ | 2009-01-12 → 2009-01-09 A (-3d) | 2009-06-17 → 2009-05-29 A (-19d) | 110d → 98d | 0% → 100% | 3d → none |  |  |
| 121323005 | Re-Baseline Actuals Adjustment | 2013-08-30 A | 2013-08-30 A |  | 0% → 100% | 20d → none | 9-130M FS+227d → none |  |
| 4 | **1.2.1.3.2.4 INSTRUMENTATION & CONTROLS** | 2009-06-18 → 2008-01-28 (-507d) |  |  |  |  |  |  |
| 121324000 | Dsgn H-D Refrgerator Controls+ | 2009-06-18 → 2008-01-28 A (-507d) | 2009-09-25 → 2009-03-02 A (-207d) | 70d → 272d | 0% → 100% | 3d → none | 121323000 → 121323000 FS-90d |  |
| 121324005 | Re-Baseline Actuals Adjustment | 2013-08-30 A | 2013-08-30 A |  | 0% → 100% | 20d → none | 9-130M FS+227d → none |  |
| 5 | **1.2.1.3.2.5 U-TUBES** | 2009-04-08 → 2009-01-13 (-85d) |  |  |  |  |  |  |
| 121325000 | Dsgn H-D Refrigerator U-Tubes+ | 2009-04-08 → 2009-01-13 A (-85d) | 2009-05-12 → 2009-05-29 A (+17d) | 25d → 96d | 0% → 100% | 98d → none |  |  |
| 121325005 | Re-Baseline Actuals Adjustment | 2013-08-30 A | 2013-08-30 A |  | 0% → 100% | 20d → none | 9-130M FS+227d → none |  |
| 121411007LOE | FY07 Management of S/R PED Effort (DIPOLES) | 2006-10-02 A | 2007-09-28 A |  | 0% → 100% | 20d → none |  | resources SUPPLIES & MATERIALS; SCIENTIST [139.2 h]; MECH TECH [104.4 h]; MECH ENG [452.4 h] → SCIENTIST [139.2 h]; MECH TECH [104.4 h]; MECH ENG [452.4 h]; SUPPLIES & MATERIALS |
| 121411025 | Develop Preliminary design of S/R Dipoles and Septa (DIPOLES) | 2006-10-02 A | 2007-03-16 → 2007-05-25 A (+70d) | 110d → 160d | 0% → 100% | 404d → none |  | resources MECH DES [208.8 h]; MECH ENG [417.6 h] → MECH ENG [417.6 h]; MECH DES [208.8 h] |
| 121411015 | Beam Transport Physics Design & Safety Review (DIPOLES) | 2006-12-06 A | 2007-01-25 → 2007-01-24 A (-1d) | 30d → 29d | 0% → 100% | 109d → none |  |  |
| 121411015M | Beam Transport Physics Design & Safety Review Completed (DIPOLES) | 2007-01-25 → 2007-01-24 A (-1d) | 2007-01-25 → 2007-01-24 A (-1d) |  | 0% → 100% | 109d → none |  |  |
| 121411055 | Develop Detailed Design of New AG and 2m AH Replacements (DIPOLES) | 2007-03-19 → 2007-02-12 A (-35d) | 2007-08-21 → 2007-08-20 A (-1d) | 110d → 133d | 0% → 100% | 464d → none |  | resources MECH ENG [139.2 h]; MECH DES [382.8 h] → MECH DES [382.8 h]; MECH ENG [139.2 h] |
| 121411020 | Installation Cost Schedule and Safety Review (DIPOLES) | 2007-05-09 → 2007-03-14 A (-56d) | 2007-06-06 → 2007-05-18 A (-19d) | 20d → 48d | 0% → 100% | 517d → none |  |  |
| 121411030 | Preliminary Design & Safety Review of S/R Dipoles and Septa (DIPOLES) | 2007-02-16 → 2007-04-09 A (+52d) | 2007-03-16 → 2007-05-25 A (+70d) | 20d → 35d | 0% → 100% | 404d → none |  |  |
| 121411020M | Installation Cost Schedule and Safety Review Complete (DIPOLES) | 2007-06-06 → 2007-05-18 A (-19d) | 2007-06-06 → 2007-05-18 A (-19d) |  | 0% → 100% | 517d → none |  |  |
| 121411035 | FY07 Develop Detailed Design of West curved dipoles (DIPOLES) | 2007-03-19 → 2007-05-21 A (+63d) | 2007-09-28 → 2007-09-27 A (-1d) | 137d → 91d | 0% → 100% | 404d → none |  |  |
| 121411045 | FY07 Develop Detailed Design of New 3m Septa (DIPOLES) | 2007-03-19 → 2007-05-21 A (+63d) | 2007-09-28 → 2007-10-30 A (+32d) | 137d → 114d | 0% → 100% | 496d → none |  |  |
| 121411030M | S/R Dipoles & Septa Preliminary Design & Safety Review Completed (DIPOLES) | 2007-03-16 → 2007-05-25 A (+70d) | 2007-03-16 → 2007-05-25 A (+70d) |  | 0% → 100% | 404d → none |  |  |
| 121411075 | Detailed Dsgn of New 2m Septa (S/R Dipoles) | 2007-10-01 A | 2008-04-14 → 2008-06-27 A (+74d) | 130d → 183d | 0% → 100% | 366d → none |  | resources MECH ENG [200 h]; MECH DES [360 h] → MECH DES [360 h]; MECH ENG [200 h] |
| 121411080 | Detailed Dsgn of New 2m Narrow Pole Septa (S/R Dipoles) | 2007-10-01 A | 2008-07-16 → 2008-10-29 A (+105d) | 195d → 269d | 0% → 100% | 301d → none |  |  |
| 121411908LOE | FY08 Mngmnt of S/R PED Effort (S/R Dipoles) | 2007-10-01 A | 2008-09-30 A |  | 0% → 100% | 20d → none |  | resources SCIENTIST [160 h]; MECH TECH [200 h]; SR STAFF [680 h]; SUPPLIES & MATERIALS; MECH ENG [200 h] → MECH ENG [200 h]; SCIENTIST [160 h]; MECH TECH [200 h]; SR STAFF [680 h]; SUPPLIES & MATERIALS |
| 121411046 | Develop Detailed Dsgn of New 3m Septa (S/R Dipoles) | 2007-10-01 A | 2008-01-02 → 2009-02-26 A (+421d) | 59d → 345d | 0% → 100% | 437d → none |  | resources MECH ENG [400 h]; MECH DES [760 h] → MECH DES [760 h]; MECH ENG [400 h] |
| 121411060M | Finish All New S/R C Shaped Dipoles (DIPOLES) | 2007-08-21 → 2007-10-01 A (+41d) | 2007-08-21 → 2007-10-01 A (+41d) |  | 0% → 100% | 464d → none |  |  |
| 121411036 | Develop Detailed Dsgn of West Curved Dipoles (S/R Dipoles) | 2007-10-01 → 2007-10-08 A (+7d) | 2008-01-02 → 2008-12-22 A (+355d) | 59d → 300d | 0% → 100% | 404d → none |  | resources MECH ENG [120 h]; MECH DES [240 h] → MECH DES [240 h]; MECH ENG [120 h] |
| 121411065 | Detailed Dsgn of East Curved Dipoles (S/R Dipoles) | 2007-12-03 → 2008-01-10 A (+38d) | 2008-06-13 → 2008-12-15 A (+185d) | 130d → 236d | 0% → 100% | 323d → none |  |  |
| 121411909LOE | FY09 Mngmnt of S/R PED Effort (S/R Dipoles) | 2008-10-01 A | 2009-09-30 A |  | 0% → 100% | 20d → none |  | resources SR STAFF [480 h]; SCIENTIST [120 h] → SCIENTIST [120 h]; SR STAFF [480 h] |
| 13411909LOEXD | FY09 Mngmnt & Oversight (S/R Dipoles) | 2008-10-01 A | 2008-12-24 A |  | 0% → 100% | 20d → none |  | resources SR STAFF [123.71 h]; TRAVEL → TRAVEL; SR STAFF [123.71 h] |
| 121411085 | Top Leg Return Dsgns for Trapezoid Dipoles (S/R Dipoles) | 2009-01-05 → 2008-11-11 A (-55d) | 2009-03-03 → 2009-10-26 A (+237d) | 40d → 237d | 0% → 100% | 148d → none | 9-090M FS+60d → 9-090M |  |
| 121411090 | FY08 Top Assy Dsgns for Modified S/R Dipoles (S/R Dipoles) | 2008-04-01 → 2008-12-09 A (+252d) | 2008-09-30 → 2009-08-28 A (+332d) | 128d → 179d | 0% → 100% | 226d → none |  |  |
| 121411090a | FY09 Top Assy Dsgns for Modified S/R Dipoles (S/R Dipoles) | 2008-10-01 → 2008-12-09 A (+69d) | 2008-10-30 → 2009-09-24 A (+329d) | 22d → 197d | 0% → 100% | 226d → none | 121411090 → 121411090 FS-200d |  |
| 121411066 | Design Option B of East XM Curved Dipoles (S/R Dipoles) | 2008-12-01 → 2008-12-16 A (+15d) | 2009-01-16 → 2009-03-16 A (+59d) | 29d → 57d | 0% → 100% | 178d → none |  | resources PLABOR; MECH ENG [80 h] → MECH ENG [80 h]; PLABOR |
| 121411038 | Design Option B of West XV Curved Dipoles (S/R Dipoles) | 2009-01-09 → 2009-01-14 A (+5d) | 2009-02-26 → 2009-03-20 A (+22d) | 33d → 46d | 0% → 100% | 151d → none |  |  |
| 121411037 | Design Option B of West XU Curved Dipoles (S/R Dipoles) | 2009-01-16 → 2009-02-03 A (+18d) | 2009-03-05 → 2009-03-30 A (+25d) | 33d → 39d | 0% → 100% | 146d → none |  | resources PLABOR; MECH ENG [80 h] → MECH ENG [80 h]; PLABOR |
| 121411081 | Design New Dipole for Launch into ARC 10 (S/R Dipoles) | 2009-01-12 → 2009-02-23 A (+42d) | 2009-02-27 → 2009-04-10 A (+42d) | 33d → 35d | 0% → 100% | 150d → none | 9-090M FS+65d → 9-090M FS+105d | resources PLABOR; MECH ENG [80 h] → MECH ENG [80 h]; PLABOR |
| 121411050M | Detailed Dsgn of New 3m Septa Comp (S/R DIPOLES) | 2008-01-02 → 2009-02-26 A (+421d) | 2008-01-02 → 2009-02-26 A (+421d) |  | 0% → 100% | 437d → none |  |  |
| 121411070M | Dsgn of East Curved Dipoles Comp (S/R DIPOLES) | 2009-01-16 → 2009-03-16 A (+59d) | 2009-01-16 → 2009-03-16 A (+59d) |  | 0% → 100% | 178d → none |  |  |
| 121411040M | Dsgn of West Curved Dipoles Comp (S/R DIPOLES) | 2009-03-05 → 2009-03-30 A (+25d) | 2009-03-05 → 2009-03-30 A (+25d) |  | 0% → 100% | 146d → none |  |  |
| 121411091 | East Option B Top Assy Dsgns for Modified S/R Dipoles (S/R Dipoles) | 2009-04-01 → 2009-05-11 A (+40d) | 2009-06-30 → 2009-10-26 A (+118d) | 64d → 118d | 0% → 100% | 64d → none |  |  |
| 121411092 | West Option B Top Assy Dsgns for Modified S/R Dipoles (S/R Dipoles) | 2009-05-01 → 2009-07-01 A (+61d) | 2009-07-30 → 2009-10-26 A (+88d) | 63d → 82d | 0% → 100% | 43d → none |  |  |
| 121411110M | All S/R Dipole & Septa Dsgns Comp (S/R DIPOLES)++ | 2009-07-30 → 2009-10-26 A (+88d) | 2009-07-30 → 2009-10-26 A (+88d) |  | 0% → 100% | 43d → none | 121411092, 121411070M, 121411090a, 121411091, 121411040M, 121411080, 121411085, 121411050M, 121411075, 121411081 → 121411070M, 121411090a, 121411085, 121411092, 121411081, 121411090, 121411091, 121411075, 121411050M, 121411080, 121411040M |  |
| 121411120 | Re-Baseline Actuals Adjustment | 2013-08-30 A | 2013-08-30 A |  | 0% → 100% | 20d → none | 9-130M FS+227d → none |  |
| 4 | **1.2.1.4.1.4 STANDS** | 2006-11-01 → 2006-10-02 (-30d) |  |  |  |  |  |  |
| 121414005 | Develop Preliminary S/R Stand and Layout Design (STANDS) | 2006-11-01 → 2006-10-02 A (-30d) | 2007-04-17 → 2007-06-29 A (+73d) | 110d → 184d | 0% → 100% | 231d → none |  |  |
| 121414010 | Preliminary Design & Safety Review of Stands (STANDS) | 2007-03-21 → 2007-05-01 A (+41d) | 2007-04-17 → 2007-05-28 A (+41d) | 20d → 19d | 0% → 100% | 231d → none |  | resources MECH ENG [34.8 h]; MECH DES [34.8 h] → MECH DES [34.8 h]; MECH ENG [34.8 h] |
| 121414010M | Preliminary S/R Stand and Layout Design & Safety Review Completed (STANDS) | 2007-04-17 → 2007-05-28 A (+41d) | 2007-04-17 → 2007-05-28 A (+41d) |  | 0% → 100% | 231d → none |  |  |
| 121414015 | FY08 Detailed Dsgn of East S/R (S/R Stands) PED++ | 2008-01-02 A | 2008-09-30 → 2008-12-22 A (+83d) | 190d → 246.02d | 0% → 100% | 58d → none |  | resources MECH ENG [360 h]; PLABOR; MECH DES [1120 h] → PLABOR; MECH ENG [360 h]; MECH DES [1120 h] |

| ID | Task | Start | Finish | Duration | Complete | Total float | Predecessors | Other |
| --- | --- | --- | --- | --- | --- | --- | --- | --- |
| 121414020 | FY08 Detailed Dsgn of West S/R (S/R Stands)++ | 2008-04-22 → 2008-11-03 A (+195d) | 2008-09-30 → 2009-09-29 A (+364d) | 113d → 224d | 0% → 100% | 1d → none |  | resources MECH DES [891.44 h]; PLABOR; MECH ENG [301.33 h] → PLABOR; MECH ENG [301.33 h]; MECH DES [891.44 h] |
| 121414020a | FY09 Detailed Dsgn of West S/R (S/R Stands)++ | 2008-10-01 → 2008-11-03 A (+33d) | 2009-09-29 → 2009-10-26 A (+27d) | 247d → 243d | 0% → 100% | 1d → none | 121414020 → 121414020 FS-250d |  |
| 121414015a | FY09 Detailed Dsgn of East S/R (S/R Stands) PED++ | 2008-10-01 → 2008-12-23 A (+83d) | 2009-07-09 → 2009-03-31 A (-100d) | 190d → 63d | 0% → 100% | 58d → none |  | resources MECH ENG [360 h]; PLABOR; MECH DES [1120 h] → PLABOR; MECH DES [1120 h]; MECH ENG [360 h] |
| 121414016 | Incorporate Changes B to the Modified East S/R (S/R Dipoles) | 2009-03-02 → 2009-04-01 A (+30d) | 2009-08-14 → 2009-09-25 A (+42d) | 118d → 125d | 0% → 100% | 32d → none |  |  |
| 121414025 | Re-Baseline Actuals Adjustment | 2013-08-30 A | 2013-08-30 A |  | 0% → 100% | 20d → none | 9-130M FS+227d → none |  |
| 6 | **1.2.1.4.1.6 VACUUM** | 2008-02-04 → 2008-11-03 (+273d) |  |  |  |  |  |  |
| 121416000 | FY08 Detailed Dsgn of East S/R Dipole Chambers (S/R Vac)++ | 2008-02-04 → 2008-11-03 A (+273d) | 2008-09-30 → 2009-11-30 A (+426d) | 168d → 266d | 0% → 100% | 211d → none |  |  |
| 121416000a | FY09 Detailed Dsgn of East S/R Dipole Chambers (S/R Vac)++ | 2008-10-01 → 2008-11-03 A (+33d) | 2008-11-13 → 2009-11-30 A (+382d) | 32d → 266d | 0% → 100% | 211d → none | 121416000 → 121416000 FS-250d | resources MECH DES [134.4 h]; MECH ENG [41.6 h] → MECH ENG [41.6 h]; MECH DES [134.4 h] |
| 121416005 | FY08 Detailed Dsgn of West S/R Dipole Chambers (S/R Vac)++ | 2008-04-15 → 2009-02-02 A (+293d) | 2008-09-30 → 2009-10-26 A (+391d) | 118d → 187d | 0% → 100% | 246d → none | 121416000a FS-150d → 121416000a FS-250d |  |
| 121416005a | FY09 Detailed Dsgn of West S/R Dipole Chambers (S/R Vac)++ | 2008-10-01 → 2009-02-02 A (+124d) | 2008-10-02 → 2009-10-26 A (+389d) | 2d → 187d | 0% → 100% | 246d → none | 121416005 → 121416005 FS-250d |  |
| 121416010 | Pre-Constrctn Dsgn Review for S/R's++ | 2009-06-04 → 2009-10-19 A (+137d) | 2009-06-10 → 2009-10-26 A (+138d) | 5d → 6d | 0% → 100% | 78d → none | 121411110M FS-40d, 121414020a FS-300d, 121414015a FS-300d, 121416000a, 121416005a FS-50d → 121411110M FS-40d, 121416005a, 121414020a FS-300d, 121416000 FS-60d, 121414016, 121414015a FS-300d, 121416000a FS-60d |  |
| 121416015 | Re-Baseline Actuals Adjustment | 2013-08-30 A | 2013-08-30 A |  | 0% → 100% | 20d → none | 9-130M FS+227d → none |  |
| 121421005 | Develop Partial Design of Arc Dipole H-Iron (DIPOLES) | 2006-10-02 A | 2007-02-01 → 2007-03-30 A (+57d) | 80d → 120d | 0% → 100% | 598d → none |  | resources MECH DES [278.4 h]; MECH ENG [139.2 h] → MECH ENG [139.2 h]; MECH DES [278.4 h] |
| 121421010 | Preliminary Design & Safety Review of Existing Arcs Dipoles (DIPOLES) | 2007-01-04 → 2007-01-29 A (+25d) | 2007-02-01 → 2007-02-23 A (+22d) | 20d → 19d | 0% → 100% | 598d → none |  |  |
| 121421010M | Existing Arcs Dipoles Preliminary Design & Safety Review Completed (DIPOLES) | 2007-02-01 → 2007-02-23 A (+22d) | 2007-02-01 → 2007-02-23 A (+22d) |  | 0% → 100% | 598d → none |  |  |
| 121421908LOE | FY08 Mngmnt of Existing Arcs (EXIST ARC Dipoles) | 2007-10-01 A | 2008-09-30 A |  | 0% → 100% | 20d → none |  | resources SR STAFF [240 h]; SUPPLIES & MATERIALS → SUPPLIES & MATERIALS; SR STAFF [240 h] |
| 121421020 | Finish Dsgn of Arc Dipole H-Iron (EXIST ARC Dipoles) ++ | 2008-10-01 → 2008-04-21 A (-163d) | 2009-01-02 → 2009-07-30 A (+209d) | 60d → 319d | 0% → 100% | 183d → none |  | resources MECH DES [360 h]; MECH ENG [80 h] → MECH ENG [80 h]; MECH DES [360 h] |
| 13421909LOEXD | FY09 Mngmnt & Oversight (EXIST ARC Dipoles) | 2008-10-01 A | 2008-12-24 A |  | 0% → 100% | 20d → none |  |  |
| 121421021 | Add H Steel to ARC 1 & 2 Design (S/R Dipoles) | 2009-03-17 → 2009-05-18 A (+62d) | 2009-04-28 → 2009-07-30 A (+93d) | 31d → 52d | 0% → 100% | 279d → none | 121421020 FS+49d → 121421020 FS-100d |  |
| 121421022 | Synchrotron Radiation Compensation Design (S/R Dipoles) | 2009-04-28 → 2009-07-01 A (+64d) | 2009-05-22 → 2009-08-31 A (+101d) | 19d → 43d | 0% → 100% | 281d → none |  |  |
| 121421025 | Re-Baseline Actuals Adjustment | 2013-08-30 A | 2013-08-30 A |  | 0% → 100% | 20d → none | 9-130M FS+227d → none |  |
| 2 | **1.2.1.4.2.2 QUADRUPOLES** | 2008-10-01 → 2008-10-03 (+2d) |  |  |  |  |  |  |
| 13422035XD | Prcrmnt Prep for Quads (EXIST ARC Q-POLES) | 2008-10-01 → 2008-10-03 A (+2d) | 2008-12-24 → 2008-12-23 A (-1d) | 59d → 56d | 0% → 100% | 1477d → none |  |  |
| 121422000 | Re-Baseline Actuals Adjustment | 2013-08-30 A | 2013-08-30 A |  | 0% → 100% | 20d → none | 9-130M FS+227d → none |  |
| 121424005 | Develop Cartridge Design for Path Length Change (STANDS) | 2006-10-16 A | 2006-12-19 → 2007-03-21 A (+92d) | 45d → 103d | 0% → 100% | 623d → none |  | resources MECH DES [69.6 h]; MECH ENG [34.8 h] → MECH ENG [34.8 h]; MECH DES [69.6 h] |
| 121425005 | Dsgn of Modifed QR & QC/QB Girders (EXIST ARC Girders) | 2008-01-28 → 2008-03-03 A (+35d) | 2008-04-07 → 2008-09-30 A (+176d) | 50d → 149d | 0% → 100% | 341d → none |  |  |
| 121425010 | Dsgn of simple QR Girder for H-B (EXIST ARC Girders)++ | 2008-04-08 → 2008-07-21 A (+104d) | 2008-05-12 → 2008-09-15 A (+126d) | 25d → 40d | 0% → 100% | 341d → none | 121425005 → 121425005 FS-50d | resources MECH ENG [40 h]; MECH DES [120 h] → MECH DES [120 h]; MECH ENG [40 h] |
| 121424010 | New Stands for H-B Transport (EXIST ARC Stands)+ | 2008-12-24 → 2008-08-01 A (-145d) | 2009-03-27 → 2008-09-30 A (-178d) | 60d → 42d | 0% → 100% | 125d → none | 9-090M FS+58d → 9-090M | resources MECH DES [320 h]; MECH ENG [80 h] → MECH ENG [80 h]; MECH DES [320 h] |
| 121425015 | Pre-Constrctn Dsgn Review for Existing ARCs++ | 2009-03-30 → 2009-10-05 A (+189d) | 2009-04-03 → 2009-10-19 A (+199d) | 5d → 11d | 0% → 100% | 125d → none |  |  |
| 121424015 | Re-Baseline Actuals Adjustment | 2013-08-30 A | 2013-08-30 A |  | 0% → 100% | 20d → none | 9-130M FS+227d → none |  |
| 3 | **1.2.1.4.3 LINACS** | 2007-02-01 → 2007-02-08 (+7d) |  |  |  |  |  |  |
| 2 | **1.2.1.4.3.2 CORRECTORS** | 2008-07-24 → 2008-07-21 (-3d) |  |  |  |  |  |  |
| 121432005 | Final Dsgn of Linac Correctors & Skew Quads (Linac Correctors)++ | 2008-07-24 → 2008-07-21 A (-3d) | 2008-09-04 → 2009-08-21 A (+351d) | 30d → 272d | 0% → 100% | 261d → none |  | resources MECH DES [120 h]; MECH ENG [80 h] → MECH ENG [80 h]; MECH DES [120 h] |
| 121432010 | Re-Baseline Actuals Adjustment | 2013-08-30 A | 2013-08-30 A |  | 0% → 100% | 20d → none | 9-130M FS+227d → none |  |
| 3 | **1.2.1.4.3.3 STANDS** | 2007-02-01 → 2007-02-08 (+7d) |  |  |  |  |  |  |
| 121433005 | Initial layout of LINAC Stands and Girders (STANDS) | 2007-02-01 → 2007-02-08 A (+7d) | 2007-06-01 → 2007-05-18 A (-14d) | 85d → 71d | 0% → 100% | 402d → none |  | resources MECH DES [139.2 h]; MECH ENG [69.6 h] → MECH ENG [69.6 h]; MECH DES [139.2 h] |
| 121433908LOE | FY08 Mngmnt of Linac Stands | 2007-10-01 A | 2008-09-30 A |  | 0% → 100% | 20d → none |  |  |
| 121434005 | Final Dsgn of Linac Girders (Linac Girders)++ | 2008-07-24 → 2007-12-05 A (-232d) | 2008-09-18 → 2009-02-25 A (+160d) | 40d → 299d | 0% → 100% | 251d → none |  |  |
| 121434999 | Pre-Constrctn Dsgn Review for Linacs++ | 2008-09-19 → 2009-10-02 A (+378d) | 2008-09-25 → 2009-10-06 A (+376d) | 5d → 3d | 0% → 100% | 251d → none |  |  |
| 121433010 | Re-Baseline Actuals Adjustment | 2013-08-30 A | 2013-08-30 A |  | 0% → 100% | 20d → none | 9-130M FS+227d → none |  |
| 4 | **1.2.1.4.4 INJECTOR & RE-INJECTION** | 2007-02-02 → 2007-02-15 (+13d) |  |  |  |  |  |  |
| 1 | **1.2.1.4.4.1 DIPOLES** | 2007-03-15 → 2007-03-19 (+4d) |  |  |  |  |  |  |
| 121441005 | Develop Preliminary Design of Re-injection Dipoles (DIPOLES) | 2007-03-15 → 2007-03-19 A (+4d) | 2007-06-14 → 2007-05-18 A (-27d) | 65d → 45d | 0% → 100% | 393d → none |  | resources MECH DES [69.6 h]; MECH ENG [104.4 h] → MECH ENG [104.4 h]; MECH DES [69.6 h] |
| 121441010 | FY08 Final Dsgn of Re-injection Dipoles (INJ/RE-INJ Dipoles)++ | 2008-07-24 → 2008-01-04 A (-202d) | 2008-09-30 → 2008-09-15 A (-15d) | 48d → 176.97d | 0% → 100% | 234d → none |  |  |
| 121441010a | FY09 Final Dsgn of Re-injection Dipoles (INJ/RE-INJ Dipoles)++ | 2008-10-01 → 2008-09-16 A (-15d) | 2008-10-16 → 2009-08-31 A (+319d) | 12d → 238d | 0% → 100% | 234d → none |  |  |
| 121441015 | Re-Baseline Actuals Adjustment | 2013-08-30 A | 2013-08-30 A |  | 0% → 100% | 20d → none | 9-130M FS+227d → none |  |
| 4 | **1.2.1.4.4.4 STANDS** | 2007-02-02 → 2007-02-15 (+13d) |  |  |  |  |  |  |
| 121444010 | Preliminary Design & Safety Review of Layout & Stand Design | 2007-05-14 → 2007-02-15 A (-88d) | 2007-06-11 → 2007-05-18 A (-24d) | 20d → 66d | 0% → 100% | 396d → none |  | resources MECH ENG [34.8 h]; MECH DES [34.8 h] → MECH DES [34.8 h]; MECH ENG [34.8 h] |
| 121444005 | Develop Preliminary Layout & Stand Design | 2007-02-02 → 2007-03-05 A (+31d) | 2007-06-11 → 2007-05-18 A (-24d) | 90d → 55d | 0% → 100% | 396d → none |  |  |
| 121444010M | Re-Injection & Linac Preliminary Design & Safety Review Completed | 2007-06-14 → 2007-05-18 A (-27d) | 2007-06-14 → 2007-05-18 A (-27d) |  | 0% → 100% | 393d → none |  |  |
| 121444015 | Detailed Dsgn of Re-Injection Line & Stands (Injector & Re-Injection Stands)++ | 2007-10-01 → 2007-11-12 A (+42d) | 2008-02-08 → 2008-03-21 A (+42d) | 85d → 83d | 0% → 100% | 319d → none |  | was named Detailed Dsgn of Re-Injection Line & Stands (Injector & Re-Injection Stands) ++ |
| 121444020 | Detailed Dsgn of Spectrometer Move (Injector & Re-Injection Stands)++ | 2008-02-11 → 2008-01-10 A (-32d) | 2008-06-17 → 2008-08-15 A (+59d) | 90d → 153d | 0% → 100% | 319d → none |  | resources MECH DES [480 h]; MECH ENG [280 h] → MECH ENG [280 h]; MECH DES [480 h] |
| 13444909LOEXD | FY09 Mngmnt/Planning for Reinjection Modifications (INJ/RE-INJ Stands) | 2008-10-01 A | 2008-12-24 A |  | 0% → 100% | 20d → none |  | resources SR STAFF [47.58 h]; MECH DES [38.06 h] → MECH DES [38.06 h]; SR STAFF [47.58 h] |
| 121444025 | Re-Baseline Actuals Adjustment | 2013-08-30 A | 2013-08-30 A |  | 0% → 100% | 20d → none | 9-130M FS+227d → none |  |
| 6 | **1.2.1.4.4.6 VACUUM** | 2008-07-31 → 2008-03-10 (-143d) |  |  |  |  |  |  |
| 121446005 | Dsgn New Vac Chambers for Re-Injections (INJ/RE-INJ Vac)++ | 2008-07-31 → 2008-03-10 A (-143d) | 2008-09-11 → 2008-06-30 A (-73d) | 30d → 80d | 0% → 100% | 259d → none |  |  |
| 121446999 | Pre-Constrctn Dsgn Review for Injector & Re-Injection+ | 2008-10-17 → 2009-10-02 A (+350d) | 2008-10-20 → 2009-10-05 A (+350d) |  | 0% → 100% | 234d → none |  |  |
| 121446010 | Re-Baseline Actuals Adjustment | 2013-08-30 A | 2013-08-30 A |  | 0% → 100% | 20d → none | 9-130M FS+227d → none |  |
| 121451007LOE | FY07 Management of ARC 10 and Hall D (DIPOLES) | 2006-10-02 A | 2007-09-28 A |  | 0% → 100% | 20d → none |  | resources SUPPLIES & MATERIALS; MECH ENG [156.6 h]; SCIENTIST [139.2 h]; MECH TECH [69.6 h] → SCIENTIST [139.2 h]; SUPPLIES & MATERIALS; MECH ENG [156.6 h]; MECH TECH [69.6 h] |
| 121451020 | Develop Design of ARC 10 4m Dipole (DIPOLES) | 2006-10-02 A | 2007-02-15 → 2007-07-20 A (+155d) | 90d → 198d | 0% → 100% | 472d → none |  | resources MECH DES [348 h]; MECH ENG [208.8 h] → MECH ENG [208.8 h]; MECH DES [348 h] |
| 121451025 | Preliminary Design & Safety Review of General Dipoles | 2007-01-19 → 2007-01-29 A (+10d) | 2007-02-15 → 2007-02-23 A (+8d) | 20d → 19d | 0% → 100% | 472d → none |  |  |
| 121451025M | General Dipole Design & Safety Review Completed | 2007-02-15 → 2007-02-23 A (+8d) | 2007-02-15 → 2007-02-23 A (+8d) |  | 0% → 100% | 472d → none |  |  |
| 121451030M | Finish Detailed Design of ARC 10 4m Dipole (DIPOLES) | 2007-04-27 → 2007-07-20 A (+84d) | 2007-04-27 → 2007-07-20 A (+84d) |  | 0% → 100% | 472d → none |  | was named Finish Detailed Design of ARC 10 4m Dipole (DIPOLES)+ |
| 121451035 | Detailed Dsgn of 2m First bend Dipole (ARC 10/H-D Dipoles)++ | 2007-10-01 → 2007-08-15 A (-47d) | 2007-12-11 → 2008-08-27 A (+260d) | 50d → 257d | 0% → 100% | 401d → none |  | resources MECH ENG [280 h]; MECH DES [520 h] → MECH DES [520 h]; MECH ENG [280 h] |
| 121451908LOE | FY08 Mngmnt of ARC 10 & H-D (ARC 10/H-D Dipoles) | 2007-10-01 A | 2008-09-30 A |  | 0% → 100% | 20d → none |  | resources MECH ENG [160 h]; MECH TECH [200 h]; SR STAFF [280 h]; SCIENTIST [160 h]; SUPPLIES & MATERIALS → SUPPLIES & MATERIALS; MECH ENG [160 h]; MECH TECH [200 h]; SR STAFF [280 h]; SCIENTIST [160 h] |
| 121451040 | Modify Alignment Fixture (ARC 10/H-D Dipoles) | 2007-10-01 → 2007-12-10 A (+70d) | 2007-10-26 → 2008-01-25 A (+91d) | 20d → 27d | 0% → 100% | 471d → none |  |  |
| 121451909LOE | FY09 Mngmnt of ARC 10 & H-D (ARC 10/H-D Dipoles) | 2008-10-01 A | 2009-09-30 A |  | 0% → 100% | 20d → none |  | resources SR STAFF [280 h]; SCIENTIST [120 h] → SCIENTIST [120 h]; SR STAFF [280 h] |
| 13451055XD | Prcrmnt Prep of 4m Dipoles (ARC10/H-D Dipoles) | 2008-10-01 A | 2008-12-24 → 2008-12-22 A (-2d) | 59d → 57d | 0% → 100% | 117d → none |  |  |
| 13451909LOEXD | FY09 Mngmnt & Oversight (ARC10/H-D Dipoles) | 2008-10-01 A | 2008-12-24 A |  | 0% → 100% | 20d → none |  | resources TRAVEL; SR STAFF [47.58 h] → SR STAFF [47.58 h]; TRAVEL |
| 121451060 | Re-Baseline Actuals Adjustment | 2013-08-30 A | 2013-08-30 A |  | 0% → 100% | 20d → none | 9-130M FS+227d → none |  |

| ID | Task | Start | Finish | Duration | Complete | Total float | Predecessors | Other |
| --- | --- | --- | --- | --- | --- | --- | --- | --- |
| 2 | **1.2.1.4.5.2 QUADRUPOLES** | 2006-12-05 → 2006-10-09 (-57d) |  |  |  |  |  |  |
| 121452005 | Develop Preliminary Design of New Quadrupoles | 2006-12-05 → 2006-10-09 A (-57d) | 2007-05-17 → 2007-05-07 A (-10d) | 110d → 141d | 0% → 100% | 343d → none |  | resources MECH ENG [208.8 h]; MECH DES [208.8 h] → MECH DES [208.8 h]; MECH ENG [208.8 h] |
| 121452010 | Preliminary Design & Safety Review of Quads | 2007-04-20 → 2007-03-16 A (-35d) | 2007-05-17 → 2007-05-07 A (-10d) | 20d → 37d | 0% → 100% | 343d → none |  |  |
| 121452010M | Preliminary Quad Design & Safety Review Completed | 2007-05-17 → 2007-05-07 A (-10d) | 2007-05-17 → 2007-05-07 A (-10d) |  | 0% → 100% | 343d → none |  |  |
| 121452015 | Develop Detailed Design of New Quadrupoles (QUAD POLES) | 2007-05-18 → 2007-05-14 A (-4d) | 2007-09-25 → 2007-10-19 A (+24d) | 90d → 112d | 0% → 100% | 343d → none |  | resources MECH DES [417.6 h]; MECH ENG [174 h] → MECH ENG [174 h]; MECH DES [417.6 h] |
| 121452020M | New Quad Designs Complete (QUAD POLES) | 2007-09-25 → 2007-10-19 A (+24d) | 2007-09-25 → 2007-10-19 A (+24d) |  | 0% → 100% | 343d → none |  | was named New Quad Designs Complete (QUAD POLES)++ |
| 13452025X | Prcrmnt Prep for Quads (ARC 10/H-D Q-POLES) | 2008-10-01 A | 2008-12-24 → 2008-12-23 A (-1d) | 59d → 58d | 0% → 100% | 92d → none |  |  |
| 121452025 | Re-Baseline Actuals Adjustment | 2013-08-30 A | 2013-08-30 A |  | 0% → 100% | 20d → none | 9-130M FS+227d → none |  |
| 4 | **1.2.1.4.5.4 STANDS** | 2006-12-05 → 2006-12-07 (+2d) |  |  |  |  |  |  |
| 121454005 | Develop Preliminary Design of Arc 10 and Hall D Layout (STANDS) | 2006-12-05 → 2006-12-07 A (+2d) | 2007-05-17 → 2007-05-04 A (-13d) | 110d → 99d | 0% → 100% | 401d → none |  |  |
| 121455000M | Begin Arc 10 and Hall D Girder Designs (GIRDERS) | 2007-03-01 → 2007-02-20 A (-9d) | 2007-03-01 → 2007-02-20 A (-9d) |  | 0% → 100% | 414d → none |  |  |
| 121455005 | Preliminary Design Arc 10 & Hall D Quad Girders (GIRDERS) | 2007-03-01 → 2007-02-20 A (-9d) | 2007-04-30 → 2007-05-11 A (+11d) | 43d → 59d | 0% → 100% | 414d → none |  | resources MECH ENG [48.8 h]; MECH DES [137.6 h] → MECH DES [137.6 h]; MECH ENG [48.8 h] |
| 121454010 | Preliminary Design & Safety Review of Arc 10 and Hall D Layout (STANDS) | 2007-04-20 → 2007-04-09 A (-11d) | 2007-05-17 → 2007-05-04 A (-13d) |  | 0% → 100% | 401d → none |  |  |
| 121454010M | Preliminary Design & Safety Review of Arc 10 and Hall D Layout Completed | 2007-05-17 → 2007-05-04 A (-13d) | 2007-05-17 → 2007-05-04 A (-13d) |  | 0% → 100% | 401d → none |  |  |
| 121455006 | FY07 Phase of Final Design Arc 10 & Hall D Quad Girders (GIRDERS) | 2007-05-18 → 2007-05-14 A (-4d) | 2007-09-28 A | 93d → 97d | 0% → 100% | 401d → none |  |  |
| 121454015 | FY08 Detailed Dsgn of ARC 10 Stands++ | 2007-10-01 → 2007-07-09 A (-84d) | 2008-09-30 → 2008-09-15 A (-15d) | 248d → 295d | 0% → 100% | 146d → none |  |  |
| 121455010 | Final Dsgn H-D & Arc 10 Quad Girders (IARC 10/H-D Girders) | 2007-10-01 → 2007-10-19 A (+18d) | 2008-02-15 → 2008-06-30 A (+136d) | 90d → 170d | 0% → 100% | 401d → none |  |  |
| 121455015M | Finish H-D & Arc 10 Girders (IARC 10/H-D GIRDERS)++ | 2008-02-15 → 2008-06-30 A (+136d) | 2008-02-15 → 2008-06-30 A (+136d) |  | 0% → 100% | 401d → none |  |  |
| 121454015a | FY09 Detailed Dsgn of ARC 10 Stands++ | 2008-10-01 → 2008-09-16 A (-15d) | 2009-03-05 → 2009-09-21 A (+200d) | 102d → 252d | 0% → 100% | 146d → none |  | resources MECH ENG [501.26 h]; MECH DES [711.09 h]; PLABOR → PLABOR; MECH ENG [501.26 h]; MECH DES [711.09 h] |
| 121454020 | Re-Baseline Actuals Adjustment | 2013-08-30 A | 2013-08-30 A |  | 0% → 100% | 20d → none | 9-130M FS+227d → none |  |
| 6 | **1.2.1.4.5.6 VACUUM** | 2007-04-02 → 2007-03-02 (-31d) |  |  |  |  |  |  |
| 121456005 | PreliminaryDesign 4m Dipole Chambers (VACUUM) | 2007-04-02 → 2007-03-02 A (-31d) | 2007-05-04 → 2007-04-27 A (-7d) | 25d → 41d | 0% → 100% | 410d → none |  |  |
| 121456010 | Detail Design 4m Dipole Chambers (VACUUM) | 2007-05-18 → 2008-04-15 A (+333d) | 2007-07-24 → 2008-09-30 A (+434d) | 46d → 118d | 0% → 100% | 498d → none |  |  |
| 121456015 | Dsgn 2m Dipole Chamb for First bend (ARC 10 & H-D Vac)++ | 2008-07-24 → 2008-07-23 A (-1d) | 2008-09-18 → 2008-09-30 A (+12d) | 40d → 49d | 0% → 100% | 251d → none |  |  |
| 121456999 | Pre-Constrctn Dsgn Review (ARC 10 & H-D)++ | 2008-09-19 → 2009-09-22 A (+368d) | 2008-09-25 → 2009-09-25 A (+365d) | 5d → 4d | 0% → 100% | 251d → none |  |  |
| 121456020 | Re-Baseline Actuals Adjustment | 2013-08-30 A | 2013-08-30 A |  | 0% → 100% | 20d → none | 9-130M FS+227d → none |  |
| 12151007LOE | FY07 Management of Extraction WBS (CAVITIES) | 2006-10-02 A | 2007-09-28 A |  | 0% → 100% | 148d → none |  |  |
| 12151009 | Develop Design Package for Cavities (CAVITIES) | 2006-11-01 A | 2006-12-07 → 2007-01-29 A (+53d) | 25d → 55d | 0% → 100% | 673d → none |  | resources ELEC ENG [83.52 h]; MECH ENG [83.52 h] → MECH ENG [83.52 h]; ELEC ENG [83.52 h] |
| 12151010 | Design & Safety Review for Cavity Package (CAVITIES) | 2006-12-08 → 2007-01-30 A (+53d) | 2006-12-08 → 2007-01-30 A (+53d) |  | 0% → 100% | 673d → none |  |  |
| 12151015 | Post-review development of Design Package for Cavities (CAVITIES) | 2006-12-11 → 2007-07-02 A (+203d) | 2007-01-18 → 2007-09-25 A (+250d) | 22d → 60d | 0% → 100% | 673d → none |  |  |
| 12151020M | Finish Design of RF Cavities (CAVITIES) | 2007-01-18 → 2007-09-25 A (+250d) | 2007-01-18 → 2007-09-25 A (+250d) |  | 0% → 100% | 673d → none |  |  |
| 12151908LOE | FY08 Mngmnt of Extraction WBS | 2007-10-01 A | 2008-09-30 A |  | 0% → 100% | 148d → none |  |  |
| 1351909LOEX | FY09 Mngmnt Oversight (Cavities) | 2008-10-01 A | 2008-12-24 A |  | 0% → 100% | 20d → none | 9-090M → 12151908LOE, 9-090M | resources TRAVEL; SCIENTIST [132.27 h] → SCIENTIST [132.27 h]; TRAVEL |
| 12151025 | Re-Baseline Actuals Adjustment | 2013-08-30 A | 2013-08-30 A |  | 0% → 100% | 20d → none | 9-130M FS+227d → none |  |
| 2 | **1.2.1.5.2 RF COMPONENTS** | 2007-02-14 → 2007-03-02 (+16d) |  |  |  |  |  |  |
| 12152005 | Develop design package for RF Components (RF COMPON) | 2007-02-14 → 2007-03-02 A (+16d) | 2007-03-28 → 2007-05-24 A (+57d) | 30d → 60d | 0% → 100% | 573d → none |  |  |
| 12152010 | Design & Safety Review for RF Components (RF COMPON) | 2007-03-29 → 2007-05-24 A (+56d) | 2007-03-29 → 2007-05-24 A (+56d) |  | 0% → 100% | 573d → none |  |  |
| 12152015 | Post-review development of Design Package for RF Components (RF COMPON) | 2007-03-30 → 2007-09-03 A (+157d) | 2007-04-20 → 2007-09-21 A (+154d) | 16d → 14d | 0% → 100% | 573d → none |  |  |
| 12152025 | Continue Dsgn Package for RF Compnts (RF COMPON) | 2007-10-01 → 2007-09-17 A (-14d) | 2007-11-09 → 2007-09-28 A (-42d) | 30d → 10d | 0% → 100% | 461d → none |  | resources ELEC ENG [80 h]; ELEC DES [80 h] → ELEC DES [80 h]; ELEC ENG [80 h] |
| 12152030M | Comp Dsgn for RF Components++ | 2007-11-09 → 2007-09-28 A (-42d) | 2007-11-09 → 2007-09-28 A (-42d) |  | 0% → 100% | 461d → none |  |  |
| 12152035 | Re-Baseline Actuals Adjustment | 2013-08-30 A | 2013-08-30 A |  | 0% → 100% | 20d → none | 9-130M FS+227d → none |  |
| 3 | **1.2.1.5.3 RESONANCE CONTROL** | 2006-10-02 → 2007-03-07 (+156d) |  |  |  |  |  |  |
| 12153005 | Determine and checkout LCW capacity (RESON CNTRL) | 2006-10-02 → 2007-03-07 A (+156d) | 2006-10-06 → 2007-03-07 A (+152d) | 5d → 1d | 0% → 100% | 727d → none |  |  |
| 12153010 | Develop Design Package for Resonance Control (RESON CNTRL) | 2006-10-02 → 2007-03-08 A (+157d) | 2006-11-10 → 2007-10-24 A (+348d) | 30d → 162d | 0% → 100% | 699d → none |  | resources MECH DES [48.72 h]; ELEC ENG [104.4 h]; ELEC DES [104.4 h]; ELEC TECH [62.64 h] → ELEC DES [104.4 h]; ELEC TECH [62.64 h]; MECH DES [48.72 h]; ELEC ENG [104.4 h] |
| 12153015 | Design & Safety Review for Resonance Control (RESON CNTRL) | 2006-11-16 → 2007-10-25 A (+343d) | 2006-11-16 → 2007-10-25 A (+343d) |  | 0% → 100% | 699d → none |  | resources ELEC ENG [6.96 h]; ELEC DES [6.96 h]; MECH DES [6.96 h] → MECH DES [6.96 h]; ELEC ENG [6.96 h]; ELEC DES [6.96 h] |
| 12153020 | Post-review development of Design Package for Resonance Control (RESON CNTRL) | 2006-11-17 → 2007-10-26 A (+343d) | 2006-11-27 → 2007-11-30 A (+368d) | 5d → 24d | 0% → 100% | 699d → none |  | resources ELEC TECH [6.96 h]; ELEC DES [27.84 h]; MECH DES [13.92 h]; ELEC ENG [27.84 h] → MECH DES [13.92 h]; ELEC ENG [27.84 h]; ELEC DES [27.84 h]; ELEC TECH [6.96 h] |
| 12153025M | Finish Resonance Control Design (RESON CNTRL) | 2006-11-27 → 2007-11-30 A (+368d) | 2006-11-27 → 2007-11-30 A (+368d) |  | 0% → 100% | 699d → none |  |  |
| 12153025 | Re-Baseline Actuals Adjustment | 2013-08-30 A | 2013-08-30 A |  | 0% → 100% | 20d → none | 9-130M FS+227d → none |  |
| 4 | **1.2.1.5.4 LAMBERTSON** | 2007-03-15 → 2007-04-09 (+25d) |  |  |  |  |  |  |
| 12154005 | Develop Design Package for Lambertson (LAMBERTSON) | 2007-03-15 → 2007-04-09 A (+25d) | 2007-05-23 → 2007-07-27 A (+65d) | 50d → 78d | 0% → 100% | 564d → none |  | resources MECH ENG [132.4 h]; MECH DES [122 h] → MECH DES [122 h]; MECH ENG [132.4 h] |
| 12154010 | Design & Safety Review for Lambertson (LAMBERTSON) | 2007-05-24 A | 2007-05-24 A |  | 0% → 100% | 564d → none |  |  |
| 12154015 | Post-review development of Design Package for Lambertson (LAMBERTSON) | 2007-05-25 → 2007-07-16 A (+52d) | 2007-06-15 → 2009-02-20 A (+616d) | 15d → 395d | 0% → 100% | 564d → none |  | resources MECH DES [45.24 h]; MECH ENG [34.8 h] → MECH ENG [34.8 h]; MECH DES [45.24 h] |
| 1354909LOEX | FY09 Engrng Oversight (LAMBERTSON) | 2008-10-01 A | 2008-12-24 A |  | 0% → 100% | 148d → none | 12151908LOE → 9-090M |  |
| 12154020M | Finished Lambertson Design (LAMBERTSON) | 2007-06-15 → 2009-02-20 A (+616d) | 2007-06-15 → 2009-02-20 A (+616d) |  | 0% → 100% | 564d → none |  |  |
| 12154025 | Re-Baseline Actuals Adjustment | 2013-08-30 A | 2013-08-30 A |  | 0% → 100% | 20d → none | 9-130M FS+227d → none |  |
| 12155005 | Develop Design Package for Septa and Dipoles (SEPTA/DIPOLES) | 2007-02-13 A | 2007-05-30 → 2007-08-27 A (+89d) | 75d → 137d | 0% → 100% | 424d → none |  |  |
| 12155006 | Preliminary Design & Safety Review for Septa and Dipoles (SEPTA/DIPOLES) | 2007-05-31 → 2007-05-24 A (-7d) | 2007-05-31 → 2007-05-24 A (-7d) |  | 0% → 100% | 424d → none |  |  |
| 12155007 | Post-review development of Design Package for Septa and dipoles (SEPTA/DIPOLES) | 2007-06-01 → 2007-07-16 A (+45d) | 2007-06-14 → 2007-08-27 A (+74d) | 10d → 31d | 0% → 100% | 424d → none |  |  |
| 12155908LOE | FY08 Oversee Dsgn Package for Septa & Dipoles | 2007-10-01 A | 2008-09-30 A |  | 0% → 100% | 20d → none |  |  |
| 12155035 | Dsgn Septa & Dipoles | 2007-10-01 → 2008-01-14 A (+105d) | 2008-02-15 → 2009-04-20 A (+430d) | 90d → 316d | 0% → 100% | 350d → none |  | resources MECH DES [92 h]; MECH ENG [136 h] → MECH ENG [136 h]; MECH DES [92 h] |
| 12155045 | Post-Review Development of Dsgn Package for Septa & Dipoles | 2008-02-20 → 2008-05-20 A (+90d) | 2008-04-29 → 2008-05-29 A (+30d) | 50d → 7d | 0% → 100% | 350d → none |  | resources MECH ENG [76 h]; MECH DES [68 h] → MECH DES [68 h]; MECH ENG [76 h] |
| 12155040 | Prelim Dsgn Review for Septa & Dipoles | 2008-02-19 → 2008-05-27 A (+98d) | 2008-02-19 → 2008-05-30 A (+101d) | 1d → 4d | 0% → 100% | 350d → none |  |  |
| 12155050M | End of Extraction Septa & Dipole PED Effort | 2008-04-29 → 2009-04-20 A (+356d) | 2008-04-29 → 2009-04-20 A (+356d) |  | 0% → 100% | 350d → none | 12155045 → 12155035, 12155045 | was named End of Extraction Septa & Dipole PED Effort+ |
| 12155055 | Re-Baseline Actuals Adjustment | 2013-08-30 A | 2013-08-30 A |  | 0% → 100% | 20d → none | 9-130M FS+227d → none |  |
| 6 | **1.2.1.5.6 STANDS** | 2006-11-01 → 2007-01-10 (+70d) |  |  |  |  |  |  |
| 12156005 | Develop Design Package for Stands (STANDS) | 2006-11-01 → 2007-01-10 A (+70d) | 2007-03-06 → 2007-09-25 A (+203d) | 80d → 180d | 0% → 100% | 185d → none |  |  |
| 12156010 | Preliminary Design & Safety Review for Stands (STANDS) | 2007-03-07 → 2007-05-24 A (+78d) | 2007-03-07 → 2007-05-24 A (+78d) |  | 0% → 100% | 185d → none |  |  |
| 12156000 | FY08 Expenses | 2007-10-01 A | 2008-09-30 A | 248d → 247d | 0% → 100% | 0d → none |  | resources SUPPLIES & MATERIALS; TRAVEL → TRAVEL; SUPPLIES & MATERIALS |
| 12156015 | Post-review development of Design Package for Stands (STANDS) | 2007-03-08 → 2007-11-01 A (+238d) | 2007-04-04 → 2007-11-30 A (+240d) |  | 0% → 100% | 185d → none |  | resources MECH ENG [34.8 h]; MECH DES [56 h] → MECH DES [56 h]; MECH ENG [34.8 h] |
| 12156030 | FY08 Develop Dsgn Package for Stands | 2007-10-01 → 2007-11-26 A (+56d) | 2008-09-30 → 2008-08-11 A (-50d) | 248d → 175d | 0% → 100% | 61d → none |  | resources MECH ENG [440.89 h]; MECH DES [1047.11 h] → MECH DES [1047.2 h]; MECH ENG [440.8 h] |

| ID | Task | Start | Finish | Duration | Complete | Total float | Predecessors | Other |
| --- | --- | --- | --- | --- | --- | --- | --- | --- |
| 12156030a | FY09 Develop Dsgn Package for Stands | 2008-10-01 → 2008-08-12 A (-50d) | 2009-03-19 → 2008-09-05 A (-195d) | 112d → 18d | 0% → 100% | 61d → none |  |  |
| 12156035 | Finalize Dsgn Package for Stands | 2009-04-08 → 2008-09-08 A (-212d) | 2009-07-23 → 2009-09-22 A (+61d) | 75d → 259d | 0% → 100% | 48d → none | 9-090M FS+125d, 12156030a → 12156030a |  |
| 12156002 | FY09 Expenses | 2008-10-01 → 2008-11-03 A (+33d) | 2009-09-30 → 2009-06-29 A (-93d) | 248d → 160d | 0% → 100% | 0d → none |  | resources SUPPLIES & MATERIALS; TRAVEL → TRAVEL; SUPPLIES & MATERIALS |
| 12156040M | Stands Dsgn Comp++ | 2009-04-13 → 2009-09-22 A (+162d) | 2009-04-13 → 2009-09-22 A (+162d) |  | 0% → 100% | 115d → none | 12156035 FS-72d → 12156035 |  |
| 12156045 | Pre-Constrctn Dsgn Review for Extraction++ | 2009-04-13 → 2009-09-23 A (+163d) | 2009-04-17 → 2009-09-23 A (+159d) | 5d → 1d | 0% → 100% | 115d → none |  |  |
| 12156050 | Re-Baseline Actuals Adjustment | 2013-08-30 A | 2013-08-30 A |  | 0% → 100% | 20d → none | 9-130M FS+227d → none |  |
| 121611007LOE | FY07 Management Effort (BPMs) | 2006-10-02 A | 2007-09-28 A |  | 0% → 100% | 111d → none |  |  |
| 121611010 | Define & Package System Layout (BPMs) | 2006-12-05 → 2006-10-16 A (-50d) | 2007-01-12 → 2007-02-28 A (+47d) | 22.5d → 87.5d | 0% → 100% | 268d → none |  | resources SCIENTIST [52.4 h]; ELEC ENG [52.2 h] → ELEC ENG [52.2 h]; SCIENTIST [52.4 h] |
| 121611015 | Design Top-Level System Layout (BPMs) | 2007-01-12 → 2007-01-02 A (-10d) | 2007-02-14 → 2007-02-28 A (+14d) | 22.5d → 39.5d | 0% → 100% | 268d → none |  | resources ELEC ENG [87 h]; ELEC DES [121.8 h]; SCIENTIST [34.8 h]; ELEC TECH [87 h] → ELEC DES [121.8 h]; ELEC ENG [87 h]; SCIENTIST [34.8 h]; ELEC TECH [87 h] |
| 121611020 | Evaluate System Interface (BPMs) | 2007-01-12 → 2007-02-13 A (+32d) | 2007-02-14 → 2007-05-25 A (+100d) | 22.5d → 72.5d | 0% → 100% | 268d → none |  |  |
| 121611025 | Preliminary Design & Safety Review (BPMs) | 2007-02-15 A | 2007-02-15 → 2007-06-01 A (+106d) | 1d → 75d | 0% → 100% | 268d → none |  |  |
| 121611025M | Complete Preliminary Design & Safety Review (BPMs) | 2007-02-15 → 2007-06-01 A (+106d) | 2007-02-15 → 2007-06-01 A (+106d) |  | 0% → 100% | 268d → none |  |  |
| 121611030M | Ready to Baseline (BPMs) | 2007-02-14 → 2007-06-01 A (+107d) | 2007-02-14 → 2007-06-01 A (+107d) |  | 0% → 100% | 268d → none |  |  |
| 121611908LOE | FY08 Mngmnt Effort for BPMs | 2007-10-01 A | 2008-09-30 A |  | 0% → 100% | 20d → none |  |  |
| 121611040 | FY08 Comp BPM Sys Dsgn | 2007-10-01 → 2007-11-01 A (+31d) | 2008-02-15 → 2008-06-27 A (+133d) | 90d → 159d | 0% → 100% | 111d → none |  | resources ELEC ENG [180 h]; ELEC TECH [120 h]; COMP SCIENT [80 h]; SCIENTIST [80 h] → SCIENTIST [80 h]; ELEC ENG [180 h]; ELEC TECH [120 h]; COMP SCIENT [80 h] |
| 121611041 | Pre-Constrctn Final Dsgn Review for BPM's | 2008-02-19 → 2008-05-01 A (+72d) | 2008-02-25 → 2008-05-30 A (+95d) | 5d → 21d | 0% → 100% | 111d → none |  |  |
| 121611045 | Compile Mech BPM Prcrmnt Packages | 2008-07-02 → 2008-05-01 A (-62d) | 2008-08-27 → 2008-05-30 A (-89d) | 40d → 21d | 0% → 100% | 271d → none |  | resources ELEC ENG [80 h]; ELEC TECH [80 h]; SCIENTIST [40 h]; TRAVEL; PROCUREMENT<$50K 60 → TRAVEL; PROCUREMENT<$50K 60; ELEC ENG [80 h]; ELEC TECH [80 h]; SCIENTIST [40 h] |
| 13611909LOEX | FY09 Mngmnt Effort for BPMs | 2008-10-01 A | 2008-12-24 A |  | 0% → 100% | 20d → none |  |  |
| 121611050 | Compile Elect BPM Prcrmnt Packages | 2009-04-01 → 2009-05-15 A (+44d) | 2009-05-27 → 2009-09-30 A (+126d) | 40d → 96d | 0% → 100% | 88d → none |  | resources TRAVEL; PROCUREMENT<$50K 60; ELEC ENG [120 h]; ELEC TECH [80 h]; SCIENTIST [40 h] → SCIENTIST [40 h]; TRAVEL; PROCUREMENT<$50K 60; ELEC ENG [120 h]; ELEC TECH [80 h] |
| 121611055M | BPM PED Comp++ | 2009-05-27 → 2009-09-30 A (+126d) | 2009-05-27 → 2009-09-30 A (+126d) |  | 0% → 100% | 88d → none |  |  |
| 121611060 | Re-Baseline Actuals Adjustment | 2013-08-30 A | 2013-08-30 A |  | 0% → 100% | 20d → none | 9-130M FS+227d → none |  |
| 121612007LOE | FY07 Management Effort Harps (HARPS) | 2006-10-02 A | 2007-09-28 A |  | 0% → 100% | 20d → none |  |  |
| 121612010 | Design Top-Level System Layout (HARPS) | 2006-10-02 → 2006-11-01 A (+30d) | 2006-11-01 → 2007-02-26 A (+117d) | 22.5d → 73.5d | 0% → 100% | 327d → none |  | resources ELEC ENG [34.8 h]; ELEC DES [34.8 h] → ELEC DES [34.8 h]; ELEC ENG [34.8 h] |
| 121612011 | Preliminary Design & Safety Review Harps (HARPS) | 2007-02-28 → 2007-02-20 A (-8d) | 2007-03-01 → 2007-06-15 A (+106d) | 1d → 82d | 0% → 100% | 327d → none |  |  |
| 121612015M | Complete Preliminary Design & Safety Review Harps (HARPS) | 2007-03-01 → 2007-06-15 A (+106d) | 2007-03-01 → 2007-06-15 A (+106d) |  | 0% → 100% | 327d → none |  |  |
| 121612020M | Ready to baseline Harp WBS (HARPS) | 2007-03-01 → 2007-06-15 A (+106d) | 2007-03-01 → 2007-06-15 A (+106d) |  | 0% → 100% | 327d → none |  |  |
| 121612908LOE | FY08 Mngmnt Effort Harps | 2007-10-01 A | 2008-09-30 A |  | 0% → 100% | 20d → none |  |  |
| 121612021 | FY08 Comp Harp Sys Dsgn | 2007-10-01 → 2007-11-01 A (+31d) | 2007-11-02 → 2008-02-07 A (+97d) | 25d → 61d | 0% → 100% | 178.5d → none |  |  |
| 121612022 | Pre-Constrctn Final Dsgn Review for Harps | 2007-11-05 → 2008-02-08 A (+95d) | 2007-11-07 → 2008-02-12 A (+97d) |  | 0% → 100% | 178.5d → none |  |  |
| 13612909LOEX | FY09 Mngmnt Effort for Harps | 2008-10-01 A | 2008-12-24 A |  | 0% → 100% | 20d → none |  |  |
| 121612030 | Compile Harp Sys Elect Prcrmnt Packages+ | 2009-04-08 → 2009-05-16 A (+38d) | 2009-05-07 → 2009-09-15 A (+131d) | 21.5d → 83.5d | 0% → 100% | 101.5d → none |  |  |
| 121612035 | Compile Harp Sys Mech Prcrmnt Packages+ | 2009-04-08 → 2009-05-16 A (+38d) | 2009-05-07 → 2009-09-15 A (+131d) | 21.5d → 83.5d | 0% → 100% | 101.5d → none |  |  |
| 121612040 | Re-Baseline Actuals Adjustment | 2013-08-30 A | 2013-08-30 A |  | 0% → 100% | 20d → none | 9-130M FS+227d → none |  |
| 121613007LOE | FY07 Management Effort for Viewers (VIEWERS) | 2006-10-02 A | 2007-09-28 A |  | 0% → 100% | 20d → none |  |  |
| 121613010 | Design Top-Level System Layout (VIEWERS) | 2006-10-02 → 2006-11-01 A (+30d) | 2006-11-01 → 2007-02-26 A (+117d) | 22.5d → 73.5d | 0% → 100% | 327d → none |  | resources ELEC ENG [34.8 h]; ELEC DES [34.8 h] → ELEC DES [34.8 h]; ELEC ENG [34.8 h] |
| 121613011 | Preliminary Design & Safety Review Viewers (VIEWERS) | 2007-02-28 → 2007-02-19 A (-9d) | 2007-03-01 → 2007-06-15 A (+106d) | 1d → 82.5d | 0% → 100% | 327d → none |  |  |
| 121613015M | Complete Preliminary Design & Safety Review Viewers (VIEWERS) | 2007-03-01 → 2007-06-15 A (+106d) | 2007-03-01 → 2007-06-15 A (+106d) |  | 0% → 100% | 327d → none |  |  |
| 121613020M | Ready to Baseline Viewers (VIEWERS) | 2007-03-01 → 2007-06-15 A (+106d) | 2007-03-01 → 2007-06-15 A (+106d) |  | 0% → 100% | 326.5d → none |  |  |
| 121613908LOE | FY08 Mngmnt Effort for Viewers | 2007-10-01 A | 2008-09-30 A |  | 0% → 100% | 20d → none |  |  |
| 121613026 | FY08 Comp Viewer Sys Dsgn | 2007-10-01 → 2007-11-01 A (+31d) | 2007-11-02 → 2008-02-07 A (+97d) | 25d → 61d | 0% → 100% | 178.5d → none |  |  |
| 121613027 | Pre-Constrctn Final Dsgn Review for Viewers | 2007-11-05 → 2008-02-08 A (+95d) | 2007-11-07 → 2008-02-12 A (+97d) |  | 0% → 100% | 178.5d → none |  |  |
| 13613909LOEX | FY09 Mngmnt Effort for Viewer Syss | 2008-10-01 A | 2008-12-24 A |  | 0% → 100% | 20d → none |  |  |
| 121613030 | Compile Viewer Sys Elect Prcrmnt Packages | 2009-04-01 → 2009-05-15 A (+44d) | 2009-06-10 → 2009-09-15 A (+97d) | 50d → 85d | 0% → 100% | 78d → none |  |  |
| 121613035 | Compile Viewer Sys Mech Prcrmnt Packages | 2009-04-01 → 2009-05-15 A (+44d) | 2009-06-17 → 2009-09-15 A (+90d) | 55d → 85d | 0% → 100% | 73d → none |  | resources ELEC ENG [20 h]; ELEC TECH [20 h]; SUPPLIES & MATERIALS → ELEC TECH [20 h]; SUPPLIES & MATERIALS; ELEC ENG [20 h] |
| 121613040M | Viewer Sys PED Comp++ | 2009-06-17 → 2009-09-15 A (+90d) | 2009-06-17 → 2009-09-15 A (+90d) |  | 0% → 100% | 73d → none |  |  |
| 121613045 | Re-Baseline Actuals Adjustment | 2013-08-30 A | 2013-08-30 A |  | 0% → 100% | 20d → none | 9-130M FS+227d → none |  |
| 121614007LOE | FY07 Management Effort for Beam Based Feedback (BEAM-BASED FB SYS) | 2006-10-02 A | 2007-09-28 A |  | 0% → 100% | 20d → none |  |  |
| 121614010 | Define System Requirements & High Level Design (BEAM-BASED FB SYS) | 2006-10-02 → 2007-04-02 A (+182d) | 2006-11-28 → 2007-05-25 A (+178d) |  | 0% → 100% | 324d → none |  |  |
| 121614011 | Preliminary Design & Safety Review Beam Based Feedback Systems (BEAM-BASED FB SYS) | 2007-03-01 → 2007-05-01 A (+61d) | 2007-03-01 → 2007-06-22 A (+113d) | 1d → 38d | 0% → 100% | 326.5d → none |  |  |
| 121614015M | Complete Preliminary Design & Safety Review BBFB (BEAM-BASED FB SYS) | 2007-03-01 → 2007-06-22 A (+113d) | 2007-03-01 → 2007-06-22 A (+113d) |  | 0% → 100% | 326.5d → none |  |  |
| 121614020M | Ready to Baseline Beam Based Feedback System (BEAM-BASED FB SYS) | 2007-03-01 → 2007-06-22 A (+113d) | 2007-03-01 → 2007-06-22 A (+113d) |  | 0% → 100% | 324d → none |  |  |
| 121614908LOE | FY08 Mngmnt Effort for Beam Based Feedback 2 | 2007-10-01 A | 2008-09-30 A |  | 0% → 100% | 20d → none |  |  |
| 121614026 | FY08 Comp BBFB Sys Dsgn | 2007-10-01 → 2007-11-01 A (+31d) | 2007-11-02 → 2008-01-08 A (+67d) | 25d → 40d | 0% → 100% | 176d → none |  |  |
| 121614027 | Pre-Constrctn Final Dsgn Review for BBFB | 2007-11-05 → 2008-02-04 A (+91d) | 2007-11-09 → 2008-02-07 A (+90d) | 5d → 4d | 0% → 100% | 176d → none |  |  |
| 13614909LOEX | FY09 FFB Sys Mangement Effort | 2008-10-01 A | 2008-12-24 A |  | 0% → 100% | 20d → none |  |  |
| 121614030 | Compile BBFB Hardware Prcrmnt Package (Beam-BASED FB SYS) | 2009-04-01 → 2009-05-15 A (+44d) | 2009-05-27 → 2009-09-15 A (+111d) | 40d → 85d | 0% → 100% | 88d → none |  | resources SUPPLIES & MATERIALS; ELEC ENG [120 h]; SCIENTIST [160 h]; COMP SCIENT [80 h]; ELEC TECH [120 h] → COMP SCIENT [80 h]; ELEC TECH [120 h]; SUPPLIES & MATERIALS; SCIENTIST [160 h]; ELEC ENG [120 h] |
| 121614035M | Beam Based Feedback PED Comp+ | 2009-05-27 → 2009-09-15 A (+111d) | 2009-05-27 → 2009-09-15 A (+111d) |  | 0% → 100% | 88d → none |  |  |
| 121614040 | Re-Baseline Actuals Adjustment | 2013-08-30 A | 2013-08-30 A |  | 0% → 100% | 20d → none | 9-130M FS+227d → none |  |
| 12162007LOE | FY07 Management Effort for Control System HW (CONT SYS HW) | 2006-10-02 A | 2007-09-28 A |  | 0% → 100% | 20d → none |  |  |
| 12162010 | Define & Package System Layout (CONT SYS HW) | 2006-12-05 → 2006-10-02 A (-64d) | 2007-01-12 → 2007-02-26 A (+45d) | 22.5d → 95.5d | 0% → 100% | 322d → none |  | resources ELEC TECH [34.8 h]; ELEC ENG [34.8 h] → ELEC ENG [34.8 h]; ELEC TECH [34.8 h] |
| 12162015 | Design Top-Level System Layout (CONT SYS HW) | 2007-01-12 → 2007-02-01 A (+20d) | 2007-02-14 → 2007-02-26 A (+12d) | 22.5d → 16.5d | 0% → 100% | 322d → none |  | resources ELEC TECH [23.32 h]; ELEC DES [57.77 h]; ELEC ENG [23.32 h] → ELEC ENG [23.32 h]; ELEC TECH [23.32 h]; ELEC DES [57.77 h] |
| 12162016 | Preliminary Design & Safety Review Control System Hardware (CONT SYS HW) | 2007-03-05 → 2007-02-20 A (-13d) | 2007-03-05 → 2007-04-27 A (+53d) | 1d → 49d | 0% → 100% | 322d → none |  |  |
| 12162020M | Complete Preliminary Design & Safety Review Control System HW (CONT SYS HW) | 2007-03-05 → 2007-05-31 A (+87d) | 2007-03-05 → 2007-05-31 A (+87d) |  | 0% → 100% | 322d → none |  |  |
| 12162025M | Ready to Baseline Control System Hardware (CONT SYS HW) | 2007-03-05 → 2007-05-31 A (+87d) | 2007-03-05 → 2007-05-31 A (+87d) |  | 0% → 100% | 322d → none |  |  |
| 12162908LOE | FY08 Mngmnt Effort for Control Sys HW 2 | 2007-10-01 A | 2008-09-30 A |  | 0% → 100% | 20d → none |  |  |
| 12162026 | FY08 Comp CSH Sys Dsgn | 2007-10-01 → 2007-11-01 A (+31d) | 2007-11-02 → 2008-06-30 A (+241d) | 25d → 160d | 0% → 100% | 176d → none |  |  |
| 12162027 | Pre-Constrctn Final Dsgn Review for CSH | 2007-11-05 → 2008-05-01 A (+178d) | 2007-11-09 → 2008-05-30 A (+203d) | 5d → 21d | 0% → 100% | 176d → none |  |  |
| 1362909LOEX | FY09 CSH Sys Mngmnt Effort | 2008-10-01 A | 2008-12-24 A |  | 0% → 100% | 20d → none |  |  |
| 12162035 | Compile CSH Prcrmnt Packages | 2008-10-01 → 2009-05-15 A (+226d) | 2008-11-25 → 2009-09-15 A (+294d) | 40d → 85d | 0% → 100% | 208d → none |  |  |
| 12162040M | PED for Control Sys Hardware Comp+ | 2008-11-25 → 2009-09-15 A (+294d) | 2008-11-25 → 2009-09-15 A (+294d) |  | 0% → 100% | 208d → none |  |  |

| ID | Task | Start | Finish | Duration | Complete | Total float | Predecessors | Other |
| --- | --- | --- | --- | --- | --- | --- | --- | --- |
| 12162045 | Re-Baseline Actuals Adjustment | 2013-08-30 A | 2013-08-30 A |  | 0% → 100% | 20d → none | 9-130M FS+227d → none |  |
| 12163007LOE | FY07 Management Effort for Control System Software (CONT SYS SW) | 2006-10-02 A | 2007-09-28 A |  | 0% → 100% | 20d → none |  | was named FY07Management Effort for Control System Software (CONT SYS SW) |
| 12163010 | Identify and document hall dependecies (CONT SYS SW) | 2006-10-02 A | 2006-11-28 → 2006-12-22 A (+24d) | 40d → 58d | 0% → 100% | 343d → none |  |  |
| 12163015 | Identify and document HLA modifications (CONT SYS SW) | 2006-10-02 → 2007-01-18 A (+108d) | 2006-11-28 → 2007-07-27 A (+241d) | 40d → 134d | 0% → 100% | 183d → none |  |  |
| 12163020 | Preliminary Design & Safety Review Control System Software (CONT SYS SW) | 2007-02-01 → 2007-04-09 A (+67d) | 2007-02-01 → 2007-05-04 A (+92d) | 1d → 20d | 0% → 100% | 343d → none |  |  |
| 12163020M | Complete Preliminary Design & Safety Review Control System SW (CONT SYS SW) | 2007-02-01 → 2007-05-04 A (+92d) | 2007-02-01 → 2007-05-04 A (+92d) |  | 0% → 100% | 343d → none |  |  |
| 12163025M | Ready to Baseline Control System Software (CONT SYS SW) | 2007-02-01 → 2007-06-29 A (+148d) | 2007-02-01 → 2007-06-29 A (+148d) |  | 0% → 100% | 183d → none |  |  |
| 12163908LOE | FY08 Mngmnt Effort for Control Sys Software 2 | 2007-10-01 A | 2008-09-30 A |  | 0% → 100% | 20d → none |  |  |
| 12163035 | FY08 Finalize Application Rquirmnts | 2007-10-01 → 2008-01-11 A (+102d) | 2008-04-28 → 2009-01-26 A (+273d) | 140d → 258d | 0% → 100% | 16d → none |  |  |
| 1363909LOEX | FY09 CSS Sys Mngmnt Effort | 2008-10-01 A | 2008-12-24 A |  | 0% → 100% | 20d → none |  |  |
| 12163040 | Comp Detailed Application Dsgn (CONT SYS SW) | 2008-01-18 → 2009-01-05 A (+353d) | 2008-07-23 → 2009-01-19 A (+180d) | 130d → 10d | 0% → 100% | 16d → none |  |  |
| 12163045 | Comp Implementn Plan (CONT SYS SW) | 2009-04-03 → 2009-01-12 A (-81d) | 2009-09-08 → 2009-01-26 A (-225d) | 110d → 10d | 0% → 100% | 16d → none | 12163040 FS+170d → 12163040 |  |
| 12163050M | Control Sys Software PED Comp+ | 2009-09-08 → 2009-01-26 A (-225d) | 2009-09-08 → 2009-01-26 A (-225d) |  | 0% → 100% | 16d → none |  |  |
| 12163170 | Pre-Constrctn Dsgn Review | 2008-06-18 → 2009-09-21 A (+460d) | 2008-06-24 → 2009-09-24 A (+457d) | 5d → 4d | 0% → 100% | 26d → none | 12163040 FS-25d → 12163040 |  |
| 12163175 | Re-Baseline Actuals Adjustment | 2013-08-30 A | 2013-08-30 A |  | 0% → 100% | 20d → none | 9-130M FS+227d → none |  |
| 121641007LOE | FY07 Management effort for Machine Protection Systems (MACHINE PROTECT) | 2006-10-02 A | 2007-09-28 A |  | 0% → 100% | 20d → none |  |  |
| 121641010 | Define MPS System Requirements (MACHINE PROTECT) | 2006-11-01 A | 2007-06-29 A |  | 0% → 100% | 734d → none |  |  |
| 121641025 | Design and Test Eng Dev Ion Chamber (MACHINE PROTECT) | 2006-12-18 A | 2007-06-29 A |  | 0% → 100% | 726.5d → none |  | resources ELEC DES [5.2 h]; SUPPLIES & MATERIALS; SCIENTIST [5.2 h]; ELEC TECH [26.08 h]; ELEC ENG [26.08 h] → ELEC DES [5.2 h]; ELEC TECH [26.08 h]; SCIENTIST [5.2 h]; SUPPLIES & MATERIALS; ELEC ENG [26.08 h] |
| 121641015 | Design System Detail Architecture (MACHINE PROTECT) | 2007-02-12 A | 2007-06-29 A |  | 0% → 100% | 800.5d → none |  |  |
| 121641020 | Design FSD Master (MACHINE PROTECT) | 2007-03-19 A | 2007-06-29 A |  | 0% → 100% | 711.5d → none |  | resources ELEC DES [15.34 h]; ELEC TECH [37.44 h]; ELEC ENG [15.08 h]; SUPPLIES & MATERIALS → ELEC DES [15.34 h]; ELEC ENG [15.08 h]; SUPPLIES & MATERIALS; ELEC TECH [37.44 h] |
| 121641030 | Complete Internal Preliminary Design & Safety Review (MACHINE PROTECT) | 2007-10-24 → 2007-05-14 A (-163d) | 2007-10-30 → 2007-06-22 A (-130d) | 5d → 29d | 0% → 100% | 711.5d → none |  |  |
| 121641035 | Complete External Preliminary Design & Safety Review (MACHINE PROTECT) | 2007-11-13 → 2007-06-04 A (-162d) | 2007-11-19 → 2007-06-25 A (-147d) | 5d → 16d | 0% → 100% | 711.5d → none | 121641030 FS+9d, 121641025A FS-40d → 121641030 FS+9d |  |
| 121641040M | MPS 35% Design Complete (MACHINE PROTECT) | 2007-12-17 → 2007-06-25 A (-175d) | 2007-12-17 → 2007-06-25 A (-175d) |  | 0% → 100% | 711.5d → none |  |  |
| 121641010A | Define MPS System Requirements (MACHINE PROTECT) | 2007-10-01 → 2007-07-09 A (-84d) | 2007-11-08 → 2007-11-30 A (+22d) | 28.5d → 101.5d | 0% → 100% | 734d → none |  |  |
| 121641025A | Design and Test Eng Dev Ion Chamber (MACHINE PROTECT)++ | 2007-10-01 → 2007-07-17 A (-76d) | 2007-12-19 → 2009-05-14 A (+512d) | 56d → 453d | 0% → 100% | 726.5d → none |  | was named Design and Test Eng Dev Ion Chamber (MACHINE PROTECT); resources ELEC TECH [104.32 h]; ELEC DES [20.8 h]; SUPPLIES & MATERIALS; SCIENTIST [20.8 h]; ELEC ENG [104.32 h] → ELEC DES [20.8 h]; SCIENTIST [20.8 h]; SUPPLIES & MATERIALS; ELEC ENG [104.32 h]; ELEC TECH [104.32 h] |
| 121641015A | Design System Detail Architecture (MACHINE PROTECT) | 2007-10-01 A | 2007-10-03 → 2008-08-15 A (+317d) | 3d → 217d | 0% → 100% | 800.5d → none |  |  |
| 121641020A | Design FSD Master (MACHINE PROTECT) | 2007-10-01 A | 2008-01-22 → 2008-08-15 A (+206d) | 72d → 217d | 0% → 100% | 711.5d → none |  | resources ELEC ENG [8.12 h]; SUPPLIES & MATERIALS; ELEC DES [8.26 h]; ELEC TECH [20.16 h] → ELEC DES [8.26 h]; ELEC TECH [20.16 h]; ELEC ENG [8.12 h]; SUPPLIES & MATERIALS |
| 121641045M | Start P-#2 of MPS PED - FY08 | 2007-12-18 → 2007-10-15 A (-64d) | 2007-12-18 → 2007-10-15 A (-64d) |  | 0% → 100% | 711.5d → none |  |  |
| 121641050 | Detail Dsgn FSD Sys (MACHINE PROTECT) | 2007-12-18 → 2007-12-11 A (-7d) | 2008-02-29 → 2008-08-15 A (+168d) | 45d → 168d | 0% → 100% | 711.5d → none |  |  |
| 121641055 | Develop FSD CAD Drawigns to 80% (MACHINE PROTECT)++ | 2008-03-03 → 2008-01-14 A (-49d) | 2008-04-11 → 2008-08-29 A (+140d) | 30d → 161d | 0% → 100% | 711.5d → none |  | was named Develop FSD CAD Drawigns to 80% (MACHINE PROTECT); resources ELEC DES [80 h]; ELEC ENG [40 h]; ELEC TECH [40 h] → ELEC TECH [40 h]; ELEC ENG [40 h]; ELEC DES [80 h] |
| 121641060 | FSD Dsgn & Safty Review (MACHINE PROTECT) | 2008-06-30 → 2008-05-16 A (-45d) | 2008-07-14 → 2008-05-30 A (-45d) |  | 0% → 100% | 806.5d → none | 121641055 FS+54d → 121641055 |  |
| 121641065 | FSD Mock-up (MACHINE PROTECT) | 2008-06-30 → 2008-06-20 A (-10d) | 2008-08-11 → 2008-12-22 A (+133d) | 30d → 128d | 0% → 100% | 711.5d → none | 121641055 FS+54d → 121641055 | resources ELEC TECH [80 h]; ELEC ENG [60 h]; PROCUREMENT<$50K 60 → ELEC TECH [80 h]; PROCUREMENT<$50K 60; ELEC ENG [60 h] |
| 121641070 | FY08 Detail Dsgn BLM Sys (MACHINE PROTECT) | 2008-08-12 → 2008-07-03 A (-40d) | 2008-09-30 → 2009-02-16 A (+139d) | 35d → 151d | 0% → 100% | 711.5d → none |  | resources COMP SCIENT [62.22 h]; MECH DES [31.11 h]; ELEC ENG [93.33 h]; SCIENTIST [31.11 h] → ELEC ENG [93.33 h]; SCIENTIST [31.11 h]; MECH DES [31.11 h]; COMP SCIENT [62.22 h] |
| 121641075 | Develop BLM CAD Drawigns to 80% (MACHINE PROTECT)++ | 2008-10-15 → 2008-07-21 A (-86d) | 2008-11-04 → 2009-02-26 A (+114d) | 15d → 148d | 0% → 100% | 711.5d → none |  | was named Develop BLM CAD Drawigns to 80% (MACHINE PROTECT); resources ELEC TECH [60 h]; ELEC ENG [80 h]; ELEC DES [60 h] → ELEC DES [60 h]; ELEC TECH [60 h]; ELEC ENG [80 h] |
| 13641909LOEX | FY09 Mngmnt & Elect Dsgn Supprt Effort for MPS | 2008-10-01 A | 2008-12-24 A |  | 0% → 100% | 20d → none |  | resources ELEC DES [0.95 h]; SR STAFF [0.95 h] → SR STAFF [0.95 h]; ELEC DES [0.95 h] |
| 121641070a | FY09 Detail Dsgn BLM Sys (MACHINE PROTECT) | 2008-10-01 → 2008-11-10 A (+40d) | 2008-10-14 → 2009-02-16 A (+125d) | 10d → 61d | 0% → 100% | 711.5d → none | 121641070 → 121641070 FS-250d | resources ELEC ENG [26.67 h]; SCIENTIST [8.89 h]; COMP SCIENT [17.78 h]; MECH DES [8.89 h] → SCIENTIST [8.89 h]; COMP SCIENT [17.78 h]; ELEC ENG [26.67 h]; MECH DES [8.89 h] |
| 121641085 | BLM Mock-up (MACHINE PROTECT) | 2008-11-05 → 2009-02-04 A (+91d) | 2008-12-18 → 2009-04-09 A (+112d) | 30d → 46d | 0% → 100% | 779d → none |  |  |
| 121641100 | Develop FSD Proc Packages (MACHINE PROTECT)++ | 2009-01-29 → 2009-03-16 A (+46d) | 2009-04-03 → 2009-07-23 A (+111d) | 45d → 91.5d | 0% → 100% | 711.5d → none | 121641095 → 121641095 FS-40d | was named Develop FSD Proc Packages (MACHINE PROTECT) |
| 121641105 | Develop BLM Proc Packages (MACHINE PROTECT)++ | 2009-01-29 → 2009-03-16 A (+46d) | 2009-04-03 → 2009-07-23 A (+111d) | 45d → 91.5d | 0% → 100% | 711.5d → none | 121641095 → 121641095 FS-40d | was named Develop BLM Proc Packages (MACHINE PROTECT); resources SR STAFF [40 h]; ELEC ENG [40 h]; ELEC TECH [40 h] → ELEC ENG [40 h]; ELEC TECH [40 h]; SR STAFF [40 h] |
| 121641080 | BLM Dsgn Review (MACHINE PROTECT) | 2008-11-05 → 2009-05-01 A (+177d) | 2008-11-25 → 2009-09-16 A (+295d) | 15d → 96d | 0% → 100% | 711.5d → none |  | resources SUPPLIES & MATERIALS; ELEC ENG [40 h] → ELEC ENG [40 h]; SUPPLIES & MATERIALS |
| 121641090 | Machine Protection Sys Dsgn & Safty Review | 2008-11-26 → 2009-06-25 A (+211d) | 2008-12-18 → 2009-09-30 A (+286d) | 15d → 68d | 0% → 100% | 711.5d → none | 121641060, 121641080 → 121641060, 121641080 FS-500d |  |
| 121641170 | Pre-Constrctn Dsgn Review++ | 2008-10-17 → 2009-07-01 A (+257d) | 2008-10-28 → 2009-09-30 A (+337d) | 7.5d → 63.5d | 0% → 100% | 814d → none |  |  |
| 121641095 | Update MPS Dsgn Based on Desgin Review | 2008-12-19 → 2009-09-21 A (+276d) | 2009-01-29 → 2009-09-30 A (+244d) | 22.5d → 8d | 0% → 100% | 711.5d → none |  | resources ELEC DES [20 h]; ELEC ENG [20 h] → ELEC ENG [20 h]; ELEC DES [20 h] |
| 121641110M | MPS PED Comp++ | 2009-04-03 → 2009-09-30 A (+180d) | 2009-04-03 → 2009-09-30 A (+180d) |  | 0% → 100% | 711.5d → none | 121641065, 121641100, 121641105, 121641085 → 121641025A, 121641085, 121641105, 121641065, 121641100 |  |
| 121641175 | Re-Baseline Actuals Adjustment | 2013-08-30 A | 2013-08-30 A |  | 0% → 100% | 20d → none | 9-130M FS+227d → none |  |
| 121642007LOE | FY07 Management Effort for Beam Envelope Limit System (BELS) | 2006-10-02 A | 2007-09-28 A |  | 0% → 100% | 20d → none |  |  |
| 121642010 | Define BELS System Requirements (BELS) | 2007-02-26 A | 2007-06-29 A |  | 0% → 100% | 378d → none |  |  |
| 121642015 | Design and Test Eng Dev BELS - Hall D Interface (BELS) | 2007-05-14 A | 2007-06-29 A |  | 0% → 100% | 101d → none |  |  |
| 121642020M | Complete Preliminary Design & Safety Review (BELS) | 2007-07-18 → 2007-06-25 A (-23d) | 2007-07-18 → 2007-06-25 A (-23d) |  | 0% → 100% | 101d → none |  |  |
| 121642025M | 35% Design Complete (BELS) | 2007-07-18 → 2007-06-25 A (-23d) | 2007-07-18 → 2007-06-25 A (-23d) |  | 0% → 100% | 101d → none |  |  |
| 121642010A | Define BELS System Requirements (BELS) | 2007-10-01 → 2007-07-16 A (-77d) | 2007-12-17 → 2008-08-20 A (+247d) | 54d → 274d | 0% → 100% | 442d → none |  |  |
| 121642015A | Design and Test Eng Dev BELS - Hall D Interface (BELS) | 2007-10-01 A | 2008-06-02 → 2009-02-25 A (+268d) | 164d → 344d | 0% → 100% | 332d → none |  | resources SUPPLIES & MATERIALS; ELEC TECH [34.8 h]; ELEC ENG [17.4 h] → ELEC TECH [34.8 h]; SUPPLIES & MATERIALS; ELEC ENG [17.4 h] |
| 121642030M | Start P-#2 of BELS PED - FY08 | 2007-10-01 A | 2007-10-01 A |  | 0% → 100% | 50d → none |  |  |
| 121642035 | Develop Detail Dsgn (BELS) | 2007-10-01 A | 2008-03-03 → 2009-01-12 A (+315d) | 100d → 314d | 0% → 100% | 50d → none |  |  |
| 121642908LOE | FY08 Mngmnt Effort for BELS | 2007-10-01 A | 2008-09-30 A |  | 0% → 100% | 20d → none |  |  |
| 121642040 | Develop mock-up (BELS) | 2008-03-04 A | 2008-05-27 → 2009-01-12 A (+230d) | 60d → 214d | 0% → 100% | 151d → none | 121642035 → 121642035 FS-40d |  |
| 121642045 | Develop CAD Drawings to 80% BELS | 2008-03-04 A | 2008-05-27 → 2009-04-20 A (+328d) | 60d → 282d | 0% → 100% | 50d → none | 121642035 → 121642035 FS-40d | resources ELEC ENG [20 h]; ELEC DES [40 h] → ELEC DES [40 h]; ELEC ENG [20 h] |
| 121642050 | Dsgn Review BELS | 2008-06-26 → 2008-05-19 A (-38d) | 2008-07-10 → 2008-06-30 A (-10d) | 10d → 30d | 0% → 100% | 50d → none | 121642045 FS+21d → 121642045 | resources SUPPLIES & MATERIALS; PROCUREMENT<$50K 60 → PROCUREMENT<$50K 60; SUPPLIES & MATERIALS |
| 121642055 | Update Dsgn Based on Dsgn Review BELS | 2008-07-11 → 2008-07-21 A (+10d) | 2008-07-24 → 2008-07-28 A (+4d) | 10d → 6d | 0% → 100% | 50d → none |  |  |
| 13642909LOEX | FY09 Mngmnt & Elect Dsgn Supprt Effort for BELS | 2008-10-01 A | 2008-12-24 A |  | 0% → 100% | 20d → none |  | resources ELEC DES [0.95 h]; SR STAFF [0.95 h] → SR STAFF [0.95 h]; ELEC DES [0.95 h] |
| 121642060 | Develop Proc Packages BELS++ | 2008-07-25 → 2009-01-13 A (+172d) | 2008-10-17 → 2009-05-19 A (+214d) | 60d → 89d | 0% → 100% | 50d → none |  | was named Develop Proc Packages BELS |
| 121642070M | BELS PED Comp++ | 2008-10-17 → 2009-05-19 A (+214d) | 2008-10-17 → 2009-05-19 A (+214d) |  | 0% → 100% | 50d → none |  |  |
| 121642170 | Pre-Constrctn Dsgn Review++ | 2008-05-14 → 2009-07-01 A (+413d) | 2008-05-20 → 2009-09-30 A (+498d) | 5d → 64d | 0% → 100% | 50d → none | 121642070M FS-110d → 121642070M |  |
| 121642175 | Re-Baseline Actuals Adjustment | 2013-08-30 A | 2013-08-30 A |  | 0% → 100% | 20d → none | 9-130M FS+227d → none |  |
| 121643007LOE | FY07 Management effort for Personnel Safety Systems (PSS) | 2006-10-02 A | 2007-09-28 A |  | 0% → 100% | 20d → none |  |  |
| 121643010 | Define Programmable Electronics Specification (PSS) | 2006-10-02 A | 2007-06-29 A |  | 0% → 100% | 324.75d → none |  |  |
| 121643035 | Test Safety PLC 1 & PLC 2 (PSS) | 2006-10-02 A | 2007-04-27 A |  | 0% → 100% | 340.75d → none |  |  |
| 121643040 | Attend Training for Safety PLC Software (PSS) | 2006-10-02 A | 2007-01-10 → 2007-03-19 A (+68d) | 65d → 111d | 0% → 100% | 363.75d → none |  | resources ELEC ENG [69.6 h]; TRAVEL → TRAVEL; ELEC ENG [69.6 h] |
| 121643015 | Write PSS Systems Safety Specificaiton (PSS) | 2006-11-01 A | 2006-11-14 → 2007-06-13 A (+211d) | 10d → 150d | 0% → 100% | 156.75d → none |  |  |
| 121643045 | Design Beam Transport Monitor (PSS) | 2006-11-01 A | 2007-06-29 A |  | 0% → 100% | 411d → none |  | resources ELEC DES [28.8 h]; SCIENTIST [29 h]; ELEC ENG [29 h] → SCIENTIST [29 h]; ELEC DES [28.8 h]; ELEC ENG [29 h] |

| ID | Task | Start | Finish | Duration | Complete | Total float | Predecessors | Other |
| --- | --- | --- | --- | --- | --- | --- | --- | --- |
| 121643050 | Construct and Test Eng Dev Beam Transport Monitor (PSS) | 2006-12-11 A | 2007-06-29 A |  | 0% → 100% | 231.75d → none |  | resources SUPPLIES & MATERIALS; ELEC ENG [12.2 h]; ELEC TECH [12.2 h] → ELEC TECH [12.2 h]; SUPPLIES & MATERIALS; ELEC ENG [12.2 h] |
| 121643070 | Prepare Baseline Cost Estimate (PSS) | 2007-03-09 A | 2007-04-12 → 2007-04-23 A (+11d) | 25d → 32d | 0% → 100% | 324.75d → none |  | resources MECH ENG [17.4 h]; ELEC ENG [69.6 h] → ELEC ENG [69.6 h]; MECH ENG [17.4 h] |
| 121643055 | Develop Cable Plant Design (PSS) | 2007-04-02 A | 2007-06-29 A |  | 0% → 100% | 231.5d → none |  | resources ELEC ENG [12.2 h]; ELEC DES [8.68 h] → ELEC DES [8.68 h]; ELEC ENG [12.2 h] |
| 121643060 | Develop PSS Insertion Device Design (PSS) | 2007-04-02 A | 2007-06-29 A |  | 0% → 100% | 156.75d → none |  | resources SCIENTIST [17.4 h]; MECH DES [7.8 h]; ELEC ENG [7.8 h]; ELEC DES [7.8 h]; MECH ENG [11.3 h] → ELEC DES [7.8 h]; SCIENTIST [17.4 h]; MECH ENG [11.3 h]; MECH DES [7.8 h]; ELEC ENG [7.8 h] |
| 121643065 | Define PSS BCM Requirements (PSS) | 2007-04-02 A | 2007-06-29 A |  | 0% → 100% | 284.75d → none |  |  |
| 121643080 | Develop Software Specification (PSS) | 2007-04-09 A | 2007-06-29 A |  | 0% → 100% | 320.75d → none |  |  |
| 121643075 | Prepare Review Material (PSS) | 2007-04-09 → 2007-04-18 A (+9d) | 2007-04-27 → 2007-05-22 A (+25d) | 15d → 25d | 0% → 100% | 320.75d → none |  |  |
| 121643020 | Review PSS Systems Safety Specificaiton (PSS) | 2006-12-01 → 2007-05-14 A (+164d) | 2006-12-07 → 2007-06-13 A (+188d) | 5d → 22d | 0% → 100% | 377.75d → none |  |  |
| 121643085 | Complete Design & Safety Review - External Reviewers (PSS) | 2007-05-14 A | 2007-05-18 → 2007-05-21 A (+3d) | 5d → 6d | 0% → 100% | 284.75d → none |  | resources TRAVEL; OFFICE [43.6 h]; ELEC ENG [60.9 h] → OFFICE [43.6 h]; ELEC ENG [60.9 h]; TRAVEL |
| 121643025 | Conduct Internal PSS Design & Safety Review (PSS) | 2006-12-15 → 2007-05-24 A (+160d) | 2006-12-21 → 2007-05-24 A (+154d) | 5d → 1d | 0% → 100% | 377.75d → none |  |  |
| 121643090M | PSS Design 35% Complete (PSS) | 2008-01-25 → 2007-06-13 A (-226d) | 2008-01-25 → 2007-06-13 A (-226d) |  | 0% → 100% | 156.75d → none |  |  |
| 121643045A | Design Beam Transport Monitor (PSS) | 2007-10-01 → 2007-07-16 A (-77d) | 2008-02-08 → 2009-01-08 A (+335d) | 85d → 366d | 0% → 100% | 411d → none |  |  |
| 121643010A | Define Programmable Electronics Specification (PSS) | 2007-10-01 A | 2007-11-12 → 2008-11-14 A (+368d) | 30.5d → 280.5d | 0% → 100% | 465.5d → none |  |  |
| 121643055A | Develop Cable Plant Design (PSS) | 2007-10-01 A | 2007-12-13 → 2009-02-23 A (+438d) | 51.75d → 342d | 0% → 100% | 231.5d → none |  | resources ELEC ENG [109.8 h]; ELEC DES [78.12 h] → ELEC DES [78.12 h]; ELEC ENG [109.8 h] |
| 121643060A | Develop PSS Insertion Device Design (PSS) | 2007-10-01 A | 2008-01-25 → 2008-10-13 A (+262d) | 75d → 257d | 0% → 100% | 156.75d → none |  | resources MECH DES [23.4 h]; MECH ENG [33.9 h]; ELEC DES [23.4 h]; SCIENTIST [52.2 h]; ELEC ENG [23.4 h] → SCIENTIST [52.2 h]; MECH ENG [33.9 h]; MECH DES [23.4 h]; ELEC ENG [23.4 h]; ELEC DES [23.4 h] |
| 121643065A | Define PSS BCM Requirements (PSS) | 2007-10-01 A | 2008-01-25 → 2008-11-26 A (+306d) | 75d → 289d | 0% → 100% | 421d → none |  |  |
| 121643080A | Develop Software Specification (PSS) | 2007-10-01 A | 2008-01-25 → 2008-12-22 A (+332d) | 75d → 305d | 0% → 100% | 421d → none |  |  |
| 121643050A | Construct and Test Eng Dev Beam Transport Monitor (PSS) | 2008-01-28 → 2007-12-17 A (-42d) | 2008-07-25 → 2009-01-09 A (+168d) | 126.5d → 260d | 0% → 100% | 156.75d → none | 121643090M, 121643050 FS+63d → 121643090M, 121643050 FS+53d | resources ELEC TECH [109.8 h]; SUPPLIES & MATERIALS; ELEC ENG [109.8 h] → ELEC ENG [109.8 h]; ELEC TECH [109.8 h]; SUPPLIES & MATERIALS |
| 121643100 | FY08 Develop PSS Detail Dsgn | 2008-04-09 → 2008-01-14 A (-86d) | 2008-09-30 → 2009-04-15 A (+197d) | 121.5d → 312.5d | 0% → 100% | 157.75d → none | 121643050A FS-75d → 121643095M | resources MECH ENG [76.84 h]; ELEC ENG [845.22 h]; ELEC TECH [230.51 h]; SCIENTIST [76.84 h]; ELEC DES [461.03 h] → MECH ENG [76.84 h]; ELEC ENG [845.22 h]; ELEC DES [461.03 h]; ELEC TECH [230.51 h]; SCIENTIST [76.84 h] |
| 121643095M | Start P-#2 of PSS PED - FY08 | 2008-10-07 → 2008-05-30 A (-130d) | 2008-10-07 → 2008-05-30 A (-130d) |  | 0% → 100% | 31.25d → none | 121643055, 121643055A, 9-080M, 121643050, 121643050A FS-75d, 9-090M FS+4d → 121643050, 121643050A FS-75d, 121643055, 9-080M, 121643055A |  |
| 121643105 | Develop PSS Mock-up & Test-bed | 2008-10-07 → 2008-07-10 A (-89d) | 2009-01-07 → 2009-05-29 A (+142d) | 58.5d → 220d | 0% → 100% | 31.25d → none |  | resources SUPPLIES & MATERIALS; ELEC TECH [200 h]; MECH TECH [40 h]; PROCUREMENT<$50K 60; ELEC ENG [160 h] → SUPPLIES & MATERIALS; PROCUREMENT<$50K 60; MECH TECH [40 h]; ELEC ENG [160 h]; ELEC TECH [200 h] |
| 13643909LOEX | FY09 Mngmnt & Supprt Effort for PSS | 2008-10-01 A | 2008-12-24 A |  | 0% → 100% | 20d → none |  | resources OFFICE [5.71 h]; SR STAFF [1.9 h]; ELEC ENG [2.85 h]; ELEC DES [5.71 h] → SR STAFF [1.9 h]; ELEC DES [5.71 h]; OFFICE [5.71 h]; ELEC ENG [2.85 h] |
| 121643115 | Develop Logic Specificaiton for Tagger/H-D (PSS) | 2008-10-07 → 2008-11-10 A (+34d) | 2008-11-07 → 2008-12-22 A (+45d) | 24d → 29d | 0% → 100% | 99.25d → none |  |  |
| 121643110 | Develop New Logic Specification for CEBAF Segements (PSS) | 2009-01-07 → 2008-12-22 A (-16d) | 2009-02-26 → 2009-04-30 A (+63d) | 34.5d → 85d | 0% → 100% | 31.25d → none | 121643095M, 121643105 → 121643105 FS-250d, 121643095M FS-250d |  |
| 121643100a | FY09 Develop PSS Detail Dsgn | 2008-10-01 → 2009-02-02 A (+124d) | 2008-10-07 → 2009-04-30 A (+205d) | 5d → 62d | 0% → 100% | 157.75d → none | 121643100 → 121643100 FS-28d | resources ELEC TECH [9.49 h]; ELEC DES [18.97 h]; SCIENTIST [3.16 h]; MECH ENG [3.16 h]; ELEC ENG [34.78 h] → MECH ENG [3.16 h]; ELEC ENG [34.78 h]; ELEC TECH [9.49 h]; ELEC DES [18.97 h]; SCIENTIST [3.16 h] |
| 121643120 | Develop Screen Specification (PSS) | 2009-02-26 → 2009-02-02 A (-24d) | 2009-03-24 → 2009-04-30 A (+37d) | 18.5d → 62.5d | 0% → 100% | 48.25d → none | 121643115, 121643110 FS-1d → 121643110, 121643115 |  |
| 121643125 | Develop PSS-EPICS Software Spec (PSS) | 2009-02-26 → 2009-02-09 A (-17d) | 2009-04-16 → 2009-05-26 A (+40d) | 35.5d → 74d | 0% → 100% | 31.25d → none | 121643110 FS-1d, 121643115 → 121643110, 121643115 | resources PROCUREMENT<$50K 60; ELEC ENG [80 h]; COMP SCIENT [40 h] → COMP SCIENT [40 h]; PROCUREMENT<$50K 60; ELEC ENG [80 h] |
| 121643140 | Develop Proc Packages (PSS)++ | 2009-06-29 → 2009-02-16 A (-133d) | 2009-08-17 → 2009-09-30 A (+44d) | 34.5d → 158.5d | 0% → 100% | 31.25d → none | 121643170, 121643145, 121643135 → 121643145, 121643135 | resources MECH DES [40 h]; ELEC ENG [200 h]; ELEC TECH [120 h] → ELEC ENG [200 h]; ELEC TECH [120 h]; MECH DES [40 h] |
| 121643145 | Develop QA Documentation (PSS) | 2008-10-16 → 2009-05-08 A (+204d) | 2008-11-17 → 2009-07-23 A (+248d) | 23d → 53d | 0% → 100% | 179.5d → none |  | resources SR STAFF [80 h]; ELEC ENG [120 h]; ELEC DES [40 h]; ELEC TECH [80 h] → ELEC TECH [80 h]; SR STAFF [80 h]; ELEC ENG [120 h]; ELEC DES [40 h] |
| 121643130 | Comp Detail Dsgn Review - External Reviewers (PSS) | 2009-04-16 → 2009-06-01 A (+46d) | 2009-05-27 → 2009-09-15 A (+111d) | 27.75d → 75d | 0% → 100% | 31.25d → none |  | resources TRAVEL; ELEC ENG [160 h]; SCIENTIST [40 h]; ELEC TECH [80 h]; ELEC DES [80 h]; OFFICE [80 h] → ELEC TECH [80 h]; ELEC DES [80 h]; OFFICE [80 h]; SCIENTIST [40 h]; TRAVEL; ELEC ENG [160 h] |
| 121643135 | Update Dsgn Based on Review recommendations (PSS) | 2009-05-27 → 2009-09-21 A (+117d) | 2009-06-29 → 2009-09-30 A (+93d) | 23d → 8d | 0% → 100% | 31.25d → none | 121643130 → 121643130 FS-7d |  |
| 121643170 | Pre-Constrctn Dsgn Review++ | 2009-01-22 → 2009-09-21 A (+242d) | 2009-01-29 → 2009-09-30 A (+244d) | 5.75d → 7.75d | 0% → 100% | 135.5d → none |  | was named Pre-Constrctn Dsgn Review |
| 121643175 | Re-Baseline Actuals Adjustment | 2013-08-30 A | 2013-08-30 A |  | 0% → 100% | 20d → none | 9-130M FS+227d → none |  |
| 12165007LOE | FY07 Management Effort for Dump Controls (INSERT DUMP) | 2006-10-02 A | 2007-09-28 A |  | 0% → 100% | 20d → none |  | resources ELEC ENG [11.48 h]; SR STAFF [11.6 h]; SCIENTIST [11.83 h] → SCIENTIST [11.83 h]; ELEC ENG [11.48 h]; SR STAFF [11.6 h] |
| 12165010 | Define & Package System Layout (INSERT DUMP) | 2006-10-02 → 2006-11-01 A (+30d) | 2006-11-10 → 2007-04-27 A (+168d) | 30d → 118d | 0% → 100% | 326.5d → none |  |  |
| 12165015 | Design Top-Level System Layout (INSERT DUMP) | 2006-11-29 → 2007-02-15 A (+78d) | 2007-01-18 → 2007-04-27 A (+99d) | 30d → 51d | 0% → 100% | 326.5d → none |  | resources ELEC DES [113.1 h]; SCIENTIST [26 h]; ELEC ENG [113.1 h]; ELEC TECH [60.9 h] → ELEC ENG [113.1 h]; SCIENTIST [26 h]; ELEC TECH [60.9 h]; ELEC DES [113.1 h] |
| 12165016 | Preliminary Design & Safety Review (INSERT DUMP) | 2007-03-01 → 2007-02-22 A (-7d) | 2007-03-01 → 2007-06-22 A (+113d) | 1d → 86d | 0% → 100% | 326.5d → none |  | resources COMP SCIENT [6.8 h]; ELEC ENG [6.8 h] → ELEC ENG [6.8 h]; COMP SCIENT [6.8 h] |
| 12165016M | Complete Preliminary Design & Safety Review for Dump Controls (INSERT DUMP) | 2007-03-01 → 2007-06-22 A (+113d) | 2007-03-01 → 2007-06-22 A (+113d) |  | 0% → 100% | 326.5d → none |  |  |
| 12165020M | Ready to Baseline Milestone for Dump Controls (INSERT DUMP) | 2007-03-01 → 2007-06-22 A (+113d) | 2007-03-01 → 2007-06-22 A (+113d) |  | 0% → 100% | 326.5d → none |  |  |
| 12165908LOE | FY08 Mngmnt Effort for Dump Controls | 2007-10-01 A | 2008-09-30 A |  | 0% → 100% | 20d → none |  |  |
| 12165026 | FY08 Comp Dump Sys Dsgn | 2007-10-01 → 2007-12-03 A (+63d) | 2007-11-02 → 2008-07-15 A (+256d) | 25d → 150d | 0% → 100% | 178.5d → none |  |  |
| 12165027 | Pre-Constrctn Final Dsgn Review for Dump | 2007-11-05 → 2008-07-15 A (+253d) | 2007-11-07 → 2008-07-18 A (+254d) | 2.5d → 3d | 0% → 100% | 178.5d → none |  |  |
| 1365909LOEX | FY09 Mngmnt Effort for Dump | 2008-10-01 A | 2008-12-24 A |  | 0% → 100% | 20d → none |  |  |
| 12165030 | Compile Dump Sys Elect Prcrmnt Packages++ | 2009-01-05 → 2009-01-30 A (+25d) | 2009-07-01 → 2009-09-15 A (+76d) | 125d → 159d | 0% → 100% | 63d → none |  | resources ELEC ENG [560 h]; ELEC TECH [200 h] → ELEC TECH [200 h]; ELEC ENG [560 h] |
| 12165035 | Compile Dump Systen Mech Prcrmnt Packages++ | 2009-02-18 → 2009-01-30 A (-19d) | 2009-05-19 → 2009-09-15 A (+119d) | 65d → 159d | 0% → 100% | 93d → none | 9-090M FS+90d, 12165027 → 12165027 FS-250d, 9-090M | resources ELEC TECH [120 h]; ELEC ENG [440 h]; SUPPLIES & MATERIALS → ELEC ENG [440 h]; ELEC TECH [120 h]; SUPPLIES & MATERIALS |
| 12165040 | Re-Baseline Actuals Adjustment | 2013-08-30 A | 2013-08-30 A |  | 0% → 100% | 20d → none | 9-130M FS+227d → none |  |
| 12166007LOE | FY07 Management Effort for Vacuum (VAC CONT) | 2006-10-02 A | 2007-09-28 A |  | 0% → 100% | 20d → none |  |  |
| 12166010 | Design Top Level System Layout (VAC CONT) | 2006-12-05 → 2006-11-01 A (-34d) | 2007-01-12 → 2007-05-18 A (+126d) | 22.5d → 132.5d | 0% → 100% | 351.5d → none |  | resources ELEC TECH [17.6 h]; ELEC ENG [87 h] → ELEC ENG [87 h]; ELEC TECH [17.6 h] |
| 12166015 | Define Vacuum System Interface Requirements (VAC CONT) | 2006-12-05 → 2007-02-26 A (+83d) | 2007-01-12 → 2007-05-18 A (+126d) | 22.5d → 59.5d | 0% → 100% | 317.5d → none |  |  |
| 12166020 | Preliminary Design & Safety Review (VAC CONT) | 2007-03-02 → 2007-04-23 A (+52d) | 2007-03-05 → 2007-06-15 A (+102d) | 1d → 38d | 0% → 100% | 317.5d → none |  |  |
| 12166020M | Complete Preliminary Design & Safety Review Vauum Controls (VAC CONT) | 2007-03-05 → 2007-06-15 A (+102d) | 2007-03-05 → 2007-06-15 A (+102d) |  | 0% → 100% | 317.5d → none |  |  |
| 12166025M | Ready to baseline Vauum Controls (VAC CONT) | 2007-03-05 → 2007-06-15 A (+102d) | 2007-03-05 → 2007-06-15 A (+102d) |  | 0% → 100% | 317.5d → none |  |  |
| 12166908LOE | FY08 Mngmnt Effort for Vac (VAC CONT) | 2007-10-01 A | 2008-09-30 A |  | 0% → 100% | 20d → none |  |  |
| 12166026 | FY08 Comp Sys Dsgn (VAC CONT) | 2007-10-01 → 2007-11-01 A (+31d) | 2007-11-02 → 2008-08-14 A (+286d) | 25d → 193d | 0% → 100% | 171d → none |  |  |
| 12166027 | Pre-Constrctn Final Dsgn Review for Vac Controls | 2007-11-05 → 2008-08-15 A (+284d) | 2007-11-16 → 2008-08-28 A (+286d) |  | 0% → 100% | 171d → none |  |  |
| 1366909LOEX | FY09 Mngmnt Effort for SRFand ARC Vac Controls | 2008-10-01 A | 2008-12-24 A |  | 0% → 100% | 20d → none |  |  |
| 12166035 | Compile Vac Controls Sys Elect Procurements Packages++ | 2009-01-05 → 2009-05-15 A (+130d) | 2009-07-09 → 2009-09-15 A (+68d) | 130d → 85d | 0% → 100% | 58d → none |  | resources PROCUREMENT<$50K 60; ELEC TECH [120 h]; SUPPLIES & MATERIALS; ELEC ENG [240 h] → ELEC TECH [120 h]; SUPPLIES & MATERIALS; PROCUREMENT<$50K 60; ELEC ENG [240 h] |
| 12166040 | Re-Baseline Actuals Adjustment | 2013-08-30 A | 2013-08-30 A |  | 0% → 100% | 20d → none | 9-130M FS+227d → none |  |
| 12167007LOE | FY07 Management Effort for Magnet Controls (MAG INSTR) | 2006-10-02 A | 2007-09-28 A |  | 0% → 100% | 20d → none |  |  |
| 12167010 | Design Top-Level Magnet Control System Layout (MAG INSTR) | 2006-12-05 → 2006-11-01 A (-34d) | 2007-01-12 → 2007-02-28 A (+47d) | 22.5d → 75.5d | 0% → 100% | 344d → none |  | resources ELEC ENG [34.8 h]; ELEC DES [34.8 h] → ELEC DES [34.8 h]; ELEC ENG [34.8 h] |
| 12167015 | Preliminary Design & Safety Review (MAG INSTR) | 2007-02-02 → 2007-02-20 A (+18d) | 2007-02-05 → 2007-06-15 A (+130d) | 1d → 82d | 0% → 100% | 344d → none |  |  |
| 12167015M | Complete Preliminary Design & Safety Review Magnet Controls (MAG INSTR) | 2007-02-05 → 2007-06-15 A (+130d) | 2007-02-05 → 2007-06-15 A (+130d) |  | 0% → 100% | 344d → none |  |  |
| 12167020M | Ready to Baseline Magnet Controls WBS (MAG INSTR) | 2007-02-05 → 2007-06-15 A (+130d) | 2007-02-05 → 2007-06-15 A (+130d) |  | 0% → 100% | 344d → none |  |  |
| 12167026 | FY08 Comp Sys Dsgn (MAG INSTR) | 2007-10-01 → 2007-12-03 A (+63d) | 2007-11-02 → 2008-01-15 A (+74d) |  | 0% → 100% | 178.5d → none |  |  |
| 12167027 | Pre-Constrctn Final Dsgn Review for Mag Instrmenttn | 2007-11-05 → 2008-02-04 A (+91d) | 2007-11-07 → 2008-02-06 A (+91d) |  | 0% → 100% | 178.5d → none |  |  |
| 12167028 | Compile Mag Control Sys Elect Prcrmnt Package+ | 2009-01-05 → 2009-05-15 A (+130d) | 2009-02-04 → 2009-09-15 A (+223d) | 21.5d → 84.5d | 0% → 100% | 166.5d → none |  |  |
| 12167030 | Re-Baseline Actuals Adjustment | 2013-08-30 A | 2013-08-30 A |  | 0% → 100% | 20d → none | 9-130M FS+227d → none |  |
| 122030M | Monthly Safety Inspection Completed | 2006-10-31 A | 2006-10-31 A |  | 0% → 100% | 475d → none |  |  |
| 122031M | Monthly Safety Inspection Completed | 2006-11-30 A | 2006-11-30 A |  | 0% → 100% | 475d → none |  |  |
| 122005M | Quarterly Safety Meeting Complete | 2006-12-22 A | 2006-12-22 A |  | 0% → 100% | 475d → none |  |  |

| ID | Task | Start | Finish | Duration | Complete | Total float | Predecessors | Other |
| --- | --- | --- | --- | --- | --- | --- | --- | --- |
| 122032M | Monthly Safety Inspection Completed | 2006-12-22 A | 2006-12-22 A |  | 0% → 100% | 475d → none |  |  |
| 122033M | Monthly Safety Inspection Completed | 2007-01-31 A | 2007-01-31 A |  | 0% → 100% | 475d → none |  |  |
| 122034M | Monthly Safety Inspection Completed | 2007-02-28 A | 2007-02-28 A |  | 0% → 100% | 475d → none |  |  |
| 122010M | Quarterly Safety Meeting Complete | 2007-03-30 → 2007-03-27 A (-3d) | 2007-03-30 → 2007-03-27 A (-3d) |  | 0% → 100% | 475d → none |  |  |
| 122035M | Monthly Safety Inspection Completed | 2007-03-30 → 2007-03-27 A (-3d) | 2007-03-30 → 2007-03-27 A (-3d) |  | 0% → 100% | 475d → none |  |  |
| 122036M | Monthly Safety Inspection Completed | 2007-04-30 → 2007-04-25 A (-5d) | 2007-04-30 → 2007-04-25 A (-5d) |  | 0% → 100% | 475d → none |  |  |
| 122037M | Monthly Safety Inspection Completed | 2007-05-31 A | 2007-05-31 A |  | 0% → 100% | 475d → none |  |  |
| 122015M | Quarterly Safety Meeting Complete | 2007-06-29 → 2007-06-12 A (-17d) | 2007-06-29 → 2007-06-12 A (-17d) |  | 0% → 100% | 475d → none |  |  |
| 122038M | Monthly Safety Inspection Completed | 2007-06-29 A | 2007-06-29 A |  | 0% → 100% | 475d → none |  |  |
| 122039M | Monthly Safety Inspection Completed | 2007-07-31 → 2007-07-27 A (-4d) | 2007-07-31 → 2007-07-27 A (-4d) |  | 0% → 100% | 475d → none |  |  |
| 122040M | Monthly Safety Inspection Completed | 2007-08-31 A | 2007-08-31 A |  | 0% → 100% | 475d → none |  |  |
| 122041M | Monthly Sfty Inspection Comptd | 2007-09-28 → 2007-10-01 A (+3d) | 2007-09-28 → 2007-10-01 A (+3d) |  | 0% → 100% | 475d → none |  |  |
| 122020M | Quarterly Sfty Meet Comp | 2007-09-28 → 2007-10-16 A (+18d) | 2007-09-28 → 2007-10-16 A (+18d) |  | 0% → 100% | 475d → none |  |  |
| 1 | **1.2.2.1 HALL A** | 2006-10-02 → 2006-10-16 (+14d) |  |  |  |  |  |  |
| 3 | **1.2.2.1.3 COMPUTING** | 2006-10-02 → 2007-04-18 (+198d) |  |  |  |  |  |  |
| 2 | **1.2.2.1.3.2 DAQ UPGRADES FOR HRS** | 2006-10-02 → 2007-04-18 (+198d) |  |  |  |  |  |  |
| 122132005M | Start PED DAQ upgrade for one HRS (DAQ UPGRD) | 2006-10-02 → 2007-04-18 A (+198d) | 2006-10-02 → 2007-04-18 A (+198d) |  | 0% → 100% | 637d → none |  |  |
| 122132010 | Specify readout modules & busses trigger changes. Design power dist changes. Engineer DAQ driver changes (DAQ UPGRD) | 2006-10-02 → 2007-04-18 A (+198d) | 2007-02-08 → 2007-09-25 A (+229d) | 85d → 112d | 0% → 100% | 637d → none |  | resources ELEC ENG [40 h]; ELEC DES [40 h]; PROCUREMENT<$50K 60; SCIENTIST [416 h] → ELEC DES [40 h]; PROCUREMENT<$50K 60; SCIENTIST [416 h]; ELEC ENG [40 h] |
| 122132908LOE | FY08 Proj Admin H-A | 2007-10-01 A | 2008-09-30 A |  | 0% → 100% | 20d → none |  |  |
| 122132015 | Re-Baseline Actuals Adjustment | 2013-08-30 A | 2013-08-30 A |  | 0% → 100% | 20d → none | 9-130M FS+227d → none |  |
| 5 | **1.2.2.1.5 BEAMLINE** | 2006-10-02 → 2006-10-16 (+14d) |  |  |  |  |  |  |
| 1 | **1.2.2.1.5.1 MOLLER POLARIMETER UPGRADE** | 2006-10-02 → 2006-10-16 (+14d) |  |  |  |  |  |  |
| 122151005M | Start PED Moller (MLLR PLRMTR UPGRD) | 2006-10-02 → 2006-10-16 A (+14d) | 2006-10-02 → 2006-10-16 A (+14d) |  | 0% → 100% | 637d → none |  |  |
| 122151010 | Design dipole/detector stands beamline changes dipole insert (MLLR PLRMTR UPGRD) | 2006-10-02 → 2006-10-16 A (+14d) | 2007-02-08 → 2007-02-28 A (+20d) | 85d → 88d | 0% → 100% | 637d → none |  | resources VISTNG USERS [160 h]; MECH DES [240 h]; ELEC DES [40 h]; PLABOR; SCIENTIST [160 h] → ELEC DES [40 h]; PLABOR; SCIENTIST [160 h]; VISTNG USERS [160 h]; MECH DES [240 h] |
| 122151015 | Re-Baseline Actuals Adjustment | 2013-08-30 A | 2013-08-30 A |  | 0% → 100% | 20d → none | 9-130M FS+227d → none |  |
| 2 | **1.2.2.1.5.2 COMPTON POLARIMETER UPGRADE** | 2007-03-01 → 2006-10-16 (-136d) |  |  |  |  |  |  |
| 122152005M | Start FY07 PED Compton - 1st phase | 2007-03-01 → 2006-10-16 A (-136d) | 2007-03-01 → 2006-10-16 A (-136d) |  | 0% → 100% | 539d → none |  |  |
| 122152010 | FY07 Design magnets / cavity stands. Engineer detector mods (COMPT PLRMTR UPGRD) | 2007-03-01 → 2006-10-16 A (-136d) | 2007-06-28 → 2007-09-25 A (+89d) | 85d → 234d | 0% → 100% | 539d → none |  | resources MECH ENG [80 h]; MECH DES [120 h]; SCIENTIST [160 h]; PD UNIV STUDNT [400 h] → SCIENTIST [160 h]; PD UNIV STUDNT [400 h]; MECH ENG [80 h]; MECH DES [120 h] |
| 122152015M | Start FY08 Milestone P-#2 (COMPT PLRMTR UPGRD) | 2008-07-02 → 2007-11-01 A (-244d) | 2008-07-02 → 2007-11-01 A (-244d) |  | 0% → 100% | 290d → none |  |  |
| 122152020 | FY08 Dsgn Vac Pipe & Detector motion Sys (COMPT PLRMTR UPGRD)+ | 2008-07-02 → 2007-11-01 A (-244d) | 2008-07-31 → 2009-11-02 A (+459d) | 21d → 496d | 0% → 100% | 290d → none |  | resources PD UNIV STUDNT [400 h]; MECH ENG [80 h]; SCIENTIST [160 h]; MECH DES [120 h] → MECH ENG [80 h]; MECH DES [120 h]; SCIENTIST [160 h]; PD UNIV STUDNT [400 h] |
| 122152025 | Re-Baseline Actuals Adjustment | 2013-08-30 A | 2013-08-30 A |  | 0% → 100% | 20d → none | 9-130M FS+227d → none |  |
| 3 | **1.2.2.1.5.3 MAPPING-ARC ENERGY MEASUREMENT** | 2006-10-02 → 2007-09-04 (+337d) |  |  |  |  |  |  |
| 122153000M | Start FY07 PED 9th dipole mapper 1ST Phase | 2006-10-02 → 2007-09-04 A (+337d) | 2006-10-02 → 2007-09-04 A (+337d) |  | 0% → 100% | 543d → none |  |  |
| 122153005 | FY07 PED Engineer & analysis of mapping coil 1st Phase | 2006-10-02 → 2007-09-04 A (+337d) | 2006-11-03 → 2007-09-25 A (+326d) | 25d → 16d | 0% → 100% | 543d → none |  | resources MECH ENG [77.6 h]; ELEC DES [19.2 h]; SUPPLIES & MATERIALS; SCIENTIST [96.8 h]; MECH DES [155.2 h]; ELEC ENG [19.2 h]; TRAVEL → SUPPLIES & MATERIALS; SCIENTIST [96.8 h]; MECH ENG [77.6 h]; ELEC ENG [19.2 h]; TRAVEL; ELEC DES [19.2 h]; MECH DES [155.2 h] |
| 122153009M | Start FY09 PED 9th Dipole Mapper P-#2 | 2008-10-01 → 2008-07-07 A (-86d) | 2008-10-01 → 2008-07-07 A (-86d) |  | 0% → 100% | 73d → none |  | was named Start FY08 PED 9th Dipole Mapper P-#2 |
| 122153010 | FY08 PED Mech & Elect Sys Dsgn P-2+ | 2009-03-11 → 2008-07-07 A (-247d) | 2009-06-17 → 2008-07-14 A (-338d) | 70d → 6d | 0% → 100% | 73d → none |  | was named PED Mech & Elect Sys Dsgn P-2+ |
| 122153015 | Re-Baseline Actuals Adjustment | 2013-08-30 A | 2013-08-30 A |  | 0% → 100% | 20d → none | 9-130M FS+227d → none |  |
| 122211007LOE | FY07 Project Management for all Hall B | 2006-10-02 A | 2007-09-28 A |  | 0% → 100% | 20d → none |  |  |
| 122211015M | Torus- Completion of ACD technical review and summary report | 2007-04-26 A | 2007-04-26 A |  | 0% → 100% | 127d → none |  |  |
| 122212015M | Sol- Completion of ACD technical review and progress report | 2007-04-26 A | 2007-04-26 A |  | 0% → 100% | 24.08d → none |  |  |
| 122211020 | Torus- First phase of the design (TOROIDAL MAG) | 2007-06-04 → 2007-04-27 A (-38d) | 2007-09-04 → 2007-08-15 A (-20d) | 65d → 77d | 0% → 100% | 127d → none |  | resources PROCUREMENT>$50K 69; MECH DES [252 h]; MECH ENG [160 h]; PROCUREMENT<$50K 60 → MECH DES [252 h]; PROCUREMENT<$50K 60; PROCUREMENT>$50K 69; MECH ENG [160 h] |
| 122212017 | Sol- Initial Payment for the design (SACLAY) | 2007-04-27 A | 2007-06-01 → 2008-05-30 A (+364d) | 25d → 271d | 0% → 100% | 24.08d → none |  | resources PROCUREMENT>$50K 69; PROCUREMENT<$50K 60 → PROCUREMENT<$50K 60; PROCUREMENT>$50K 69 |
| 122212020 | Sol- First phase of the design (SOLENOID) | 2007-06-04 → 2007-04-27 A (-38d) | 2007-09-04 → 2007-08-15 A (-20d) | 65d → 77d | 0% → 100% | 24.08d → none |  | resources MECH DES [44 h]; PROCUREMENT<$50K 60; MECH ENG [28.4 h]; PROCUREMENT>$50K 69 → PROCUREMENT<$50K 60; MECH ENG [28.4 h]; MECH DES [44 h]; PROCUREMENT>$50K 69 |
| 122211025M | Torus- Safety Assessment (TOROIDAL MAG) | 2007-09-04 → 2007-08-15 A (-20d) | 2007-09-04 → 2007-08-15 A (-20d) |  | 0% → 100% | 127d → none |  |  |
| 122212025M | Sol- Safety Assessment (SOLENOID) | 2007-09-04 → 2007-08-15 A (-20d) | 2007-09-04 → 2007-08-15 A (-20d) |  | 0% → 100% | 24.08d → none |  |  |
| 12221040 | **Torus Labor Reference Dsgn | 2007-10-31 → 2007-11-01 A (+1d) | 2008-03-12 → 2008-05-19 A (+68d) | 85d → 131.5d | 0% → 100% | 99d → none | 122211036M FS-1d → 122211036M FS-10d | resources MECH DES [40 h]; SR STAFF [100 h]; TRAVEL; MECH ENG [40 h] → MECH ENG [40 h]; SR STAFF [100 h]; TRAVEL; MECH DES [40 h] |
| 122211017 | Torus- Initial Payment for the design (TOROIDAL MAG) | 2007-04-27 → 2007-11-01 A (+188d) | 2007-06-01 → 2007-11-01 A (+153d) | 25d → 1d | 0% → 100% | 127d → none |  |  |
| 122211035 | **Torus-FY07-Contract for Design (1st & part 2nd prog pymnt) | 2007-09-05 → 2007-11-01 A (+57d) | 2007-10-30 → 2008-01-15 A (+77d) | 40d → 44d | 0% → 100% | 127d → none | 122211025M, 1131005 → 1131005, 122211036M | was named **Torus-FY07-Second phase of the design (1st & part of 2nd prog pymnt); resources MECH ENG [92 h]; MECH DES [184 h]; PROCUREMENT<$50K 60 NO ESCALATION FY08; PROCUREMENT>$50K 69 NO ESCALATION FY08 → MECH ENG [92 h]; PROCUREMENT<$50K 60 NO ESCALATION FY08; PROCUREMENT>$50K 69 NO ESCALATION FY08; MECH DES [184 h] |
| 122211036M | Torus- Contract Award | 2007-11-01 A | 2007-11-01 A |  | 0% → 100% | 99d → none |  |  |
| 122211037S | **Torus- Contract for Design (balance of 2nd & 3rd progress pymnts) | 2007-11-01 A | 2008-01-31 → 2008-04-30 A (+90d) | 56d → 119d | 0% → 100% | 127d → none |  | resources PROCUREMENT<$50K 60; PROCUREMENT>$50K 69 → PROCUREMENT>$50K 69; PROCUREMENT<$50K 60 |
| 122212035 | **Solenoid- FY07 Contract for Design (1st & part 2nd prog pymnt) | 2007-09-05 → 2007-11-01 A (+57d) | 2007-10-01 → 2008-03-14 A (+165d) | 19d → 86d | 0% → 100% | 24.08d → none | 122212020, 122212025M → 122212036M | was named **Solenoid- FY07 Contract for Design (1st & part of 2nd prog pymnt); resources MECH ENG [12 h]; MECH DES [28 h]; PROCUREMENT>$50K 69 NO ESCALATION FY08; PROCUREMENT<$50K 60 NO ESCALATION FY08 → MECH DES [28 h]; MECH ENG [12 h]; PROCUREMENT<$50K 60 NO ESCALATION FY08; PROCUREMENT>$50K 69 NO ESCALATION FY08 |
| 122212036M | Solenoid- Contract Award | 2007-11-01 A | 2007-11-01 A |  | 0% → 100% | 25d → none |  |  |
| 122212037S | **Solenoid- Contract for Design (balance of 2nd & 3rd progress pymnts) | 2007-11-01 A | 2008-03-31 → 2008-04-30 A (+30d) | 97d → 118.38d | 0% → 100% | 86d → none |  |  |
| 12221055 | **Solenoid Labor Reference Dsgn | 2007-10-17 → 2007-11-01 A (+15d) | 2008-02-13 → 2009-03-02 A (+383d) | 75d → 322.08d | 0% → 100% | 24.08d → none | 12221050M, 122212036M FS-11d → 122212036M FS-11d | resources SR STAFF [100 h]; MECH ENG [40 h]; MECH DES [40 h] → MECH ENG [40 h]; SR STAFF [100 h]; MECH DES [40 h] |
| 122211038M | Torus- 1st Progress Payment Completed | 2007-11-29 → 2007-12-14 A (+15d) | 2007-11-29 → 2007-12-14 A (+15d) |  | 0% → 100% | 148d → none | 122211036M FS+19d, 122211035 → 122211036M FS+19d, 122211035 FS-5d |  |
| 122211035M | Torus- FY07 Techncl Dsgn Report & Sfty Assessmnt | 2007-10-30 → 2007-12-14 A (+45d) | 2007-10-30 → 2007-12-14 A (+45d) |  | 0% → 100% | 127d → none |  |  |
| 122211039M | Torus- 2nd Progress Payment Completed | 2007-12-21 → 2008-01-15 A (+25d) | 2007-12-21 → 2008-01-15 A (+25d) |  | 0% → 100% | 148d → none |  |  |
| 122212038M | Solenoid- 1st Progress Payment Completed | 2008-01-04 → 2008-01-15 A (+11d) | 2008-01-04 → 2008-01-15 A (+11d) |  | 0% → 100% | 107d → none |  |  |
| 12221050M | Solenoid- FY07 Techncl Dsgn Report & Sfty Assessmnt | 2007-10-17 → 2008-02-01 A (+107d) | 2007-10-17 → 2008-02-01 A (+107d) |  | 0% → 100% | 24.08d → none |  |  |
| 122212039M | Solenoid- 2nd Progress Payment Completed | 2008-02-29 → 2008-03-17 A (+17d) | 2008-02-29 → 2008-03-17 A (+17d) |  | 0% → 100% | 107d → none |  |  |
| 12221045M | Torus- Reference Dsgn Comptd++ | 2008-03-12 → 2008-04-04 A (+23d) | 2008-03-12 → 2008-04-04 A (+23d) |  | 0% → 100% | 99d → none | 12221040, 122211040M → 122211040M, 12221040, 122211025M |  |
| 12221050 | **Solenoid- FY08 Contract for Design (part 2nd prog pymnt) | 2007-10-02 → 2008-04-30 A (+211d) | 2007-10-17 → 2008-04-30 A (+196d) | 11.92d → 0.92d | 0% → 100% | 24.08d → none |  | was named **Solenoid- FY08 Contract for Design (part of 2nd prog pymnt); resources MECH ENG [28 h]; PROCUREMENT<$50K 60; MECH DES [12 h] → MECH DES [12 h]; MECH ENG [28 h]; PROCUREMENT<$50K 60 |
| 12221060M | Solenoid- Reference Dsgn Comptd++ | 2008-03-31 → 2008-04-30 A (+30d) | 2008-03-31 → 2008-04-30 A (+30d) |  | 0% → 100% | 86d → none | 122212040M, 12221055 → 122212025M, 122212040M, 12221055 |  |
| 122212040M | Solenoid- 3rd Progress Payment Completed | 2008-03-31 → 2008-04-30 A (+30d) | 2008-03-31 → 2008-04-30 A (+30d) |  | 0% → 100% | 86d → none |  |  |
| 122211040M | Torus- 3rd Progress Payment Completed | 2008-01-31 → 2008-04-30 A (+90d) | 2008-01-31 → 2008-04-30 A (+90d) |  | 0% → 100% | 127d → none |  |  |
| 12221045 | Torus Labor Procurement Prep | 2008-03-13 → 2008-06-02 A (+81d) | 2008-09-29 → 2008-08-29 A (-31d) | 140d → 64d | 0% → 100% | 831d → none |  | resources SR STAFF [100 h]; TRAVEL; MECH ENG [40 h]; MSHOP; MECH DES [40 h] → MECH DES [40 h]; SR STAFF [100 h]; MSHOP; TRAVEL; MECH ENG [40 h] |
| 12221060 | Solenoid Labor Procurement Prep | 2008-02-13 → 2008-06-02 A (+110d) | 2008-09-23 → 2008-08-29 A (-25d) | 155d → 64d | 0% → 100% | 24.08d → none |  | resources MECH DES [40 h]; MSHOP; MECH ENG [40 h]; SR STAFF [100 h] → MECH ENG [40 h]; MECH DES [40 h]; SR STAFF [100 h]; MSHOP |
| 14211000MX | Torus Start 2nd Phase of Proc Prep | 2008-10-01 A | 2008-10-01 A |  | 0% → 100% | 830d → none | 9-090M, 12221045 → 12221045M, 9-090M, 12221045 |  |
| 14212000MX | Solenoid Start 2nd Phase of Proc Prep | 2008-10-01 A | 2008-10-01 A |  | 0% → 100% | 19d → none |  |  |
| 14211002X | Torus Prcrmnt Prep | 2008-10-01 → 2008-11-03 A (+33d) | 2008-12-24 → 2009-09-04 A (+254d) | 59d → 208d | 0% → 100% | 830d → none |  | resources OFFICE [80 h]; ELEC TECH [80 h]; SCIENTIST [280 h]; MECH ENG [360 h]; MECH TECH [800 h]; ELEC DES [280 h]; ELEC ENG [200 h]; MECH DES [240 h] → MECH TECH [800 h]; ELEC ENG [200 h]; ELEC TECH [80 h]; SCIENTIST [280 h]; OFFICE [80 h]; ELEC DES [280 h]; MECH ENG [360 h]; MECH DES [240 h] |

| ID | Task | Start | Finish | Duration | Complete | Total float | Predecessors | Other |
| --- | --- | --- | --- | --- | --- | --- | --- | --- |
| 14211009EX | Torus FY09 Travel | 2008-10-01 → 2008-12-01 A (+61d) | 2008-12-24 → 2008-12-22 A (-2d) | 59d → 16d | 0% → 100% | 0d → none |  |  |
| 14212002X | Solenoid Prcrmnt Prep for Dsgn & Prcrmnt | 2008-10-01 → 2008-12-01 A (+61d) | 2008-12-24 → 2009-10-12 A (+292d) | 59d → 215d | 0% → 100% | 19d → none |  | resources OFFICE [80 h]; MECH TECH [800 h]; MECH DES [200 h]; MECH ENG [200 h]; ELEC TECH [60 h]; ELEC ENG [20 h]; VISTNG USERS [160 h]; SCIENTIST [40 h] → ELEC ENG [20 h]; ELEC TECH [60 h]; VISTNG USERS [160 h]; SCIENTIST [40 h]; OFFICE [80 h]; MECH ENG [200 h]; MECH DES [200 h]; MECH TECH [800 h] |
| 14212009EX | Solenoid FY09 Travel | 2008-10-01 → 2008-12-01 A (+61d) | 2008-12-24 → 2008-12-22 A (-2d) | 59d → 16d | 0% → 100% | 19d → none |  |  |
| 122212050 | Re-Baseline Actuals Adjustment | 2013-08-30 A | 2013-08-30 A |  | 0% → 100% | 20d → none | 9-130M FS+227d → none |  |
| 2 | **1.2.2.2.2 DETECTORS** | 2006-10-02 → 2006-11-01 (+30d) |  |  |  |  |  |  |
| 1222211005 | SVT-Design overall layout (SILICON DTCTR) | 2006-10-02 → 2006-11-01 A (+30d) | 2007-05-11 → 2007-06-15 A (+35d) | 150d → 152d | 0% → 100% | 228d → none |  |  |
| 1222213005 | DC- Design of the chamber & Stringing Fixture : Phase 1 (F DRFT CHAMB) | 2006-10-02 → 2006-11-01 A (+30d) | 2007-03-30 → 2007-04-13 A (+14d) | 120d → 108d | 0% → 100% | 251d → none |  | resources MECH DES [245.48 h]; CONTRB UNIV LBR [214.79 h]; MECH ENG [92 h]; MECH TECH [245.48 h] → MECH TECH [245.48 h]; MECH DES [245.48 h]; CONTRB UNIV LBR [214.79 h]; MECH ENG [92 h] |
| 1222213010 | DC-Design On-chamber Electronics: Phase 1 (F DRFT CHAMB) | 2006-10-02 → 2006-11-01 A (+30d) | 2007-03-30 → 2007-03-15 A (-15d) | 120d → 87d | 0% → 100% | 251d → none |  | resources OFFICE [214.79 h]; ELEC ENG [122.74 h]; ELEC DES [337.54 h]; ELEC TECH [122.74 h] → ELEC TECH [122.74 h]; OFFICE [214.79 h]; ELEC ENG [122.74 h]; ELEC DES [337.54 h] |
| 1222223005 | Designing the mounting (FCAL) | 2006-10-02 → 2006-11-01 A (+30d) | 2007-03-02 → 2007-09-28 A (+210d) | 100d → 225d | 0% → 100% | 419d → none |  | resources MECH ENG [97.47 h]; MECH DES [123 h] → MECH DES [123 h]; MECH ENG [97.47 h] |
| 1222223010 | Design Box with end plates (FCAL) | 2006-10-02 → 2006-11-01 A (+30d) | 2007-03-02 → 2007-09-28 A (+210d) | 100d → 225d | 0% → 100% | 419d → none |  |  |
| 1222231005 | Design of Light Guides (CTOF) | 2006-10-02 → 2006-11-01 A (+30d) | 2007-03-30 → 2007-09-28 A (+182d) | 120d → 225d | 0% → 100% | 383d → none |  | resources SCIENTIST [122.74 h]; MECH ENG [90.25 h]; MECH DES [158.8 h] → MECH DES [158.8 h]; SCIENTIST [122.74 h]; MECH ENG [90.25 h] |
| 1222232010 | Design of the light guides (FTOF) | 2006-10-02 → 2006-11-01 A (+30d) | 2007-04-06 → 2007-09-28 A (+175d) | 125d → 225d | 0% → 100% | 493d → none |  | resources MECH DES [122.74 h]; SCIENTIST [122.74 h]; MECH ENG [61.37 h] → MECH ENG [61.37 h]; MECH DES [122.74 h]; SCIENTIST [122.74 h] |
| 1222232015 | Magnetic shielding design (FTOF) | 2007-01-02 → 2006-11-01 A (-62d) | 2007-06-28 → 2007-09-28 A (+92d) | 125d → 225d | 0% → 100% | 435d → none |  | resources SCIENTIST [122.74 h]; MECH ENG [61.37 h]; MECH DES [122.74 h] → MECH DES [122.74 h]; SCIENTIST [122.74 h]; MECH ENG [61.37 h] |
| 1222241005 | Design of the mirror 6 sectors (HTCC) | 2007-01-04 → 2006-11-01 A (-64d) | 2007-06-25 → 2007-08-14 A (+50d) | 120d → 193d | 0% → 100% | 363d → none |  |  |
| 1222241010 | Design of the Module (HTCC) | 2007-01-24 → 2006-11-01 A (-84d) | 2007-06-14 → 2007-08-14 A (+61d) | 100d → 193d | 0% → 100% | 296d → none |  | resources SCIENTIST [61.37 h]; MECH DES [521.64 h]; MECH ENG [30.8 h]; ELEC DES [30.8 h] → MECH DES [521.64 h]; ELEC DES [30.8 h]; SCIENTIST [61.37 h]; MECH ENG [30.8 h] |
| 1222241015 | Design of the Mounting Frames (HTCC) | 2007-06-15 → 2006-11-01 A (-226d) | 2007-09-28 A | 74d → 225d | 0% → 100% | 296d → none |  |  |
| 1222242005 | Design modification to the mirrors (LTCC) | 2007-01-04 → 2006-11-01 A (-64d) | 2007-06-11 → 2007-12-17 A (+189d) | 110d → 279d | 0% → 100% | 411d → none |  |  |
| 1222211010 | SVT-Design support structure (SILICON DTCTR) | 2007-05-14 → 2006-12-01 A (-164d) | 2007-11-27 → 2007-09-28 A (-60d) | 137d → 205d | 0% → 100% | 228d → none |  | resources MECH DES [337.54 h]; MECH ENG [153.43 h] → MECH ENG [153.43 h]; MECH DES [337.54 h] |
| 1222211015 | SVT- Design of the VME Board (SILICON DTCTR) | 2006-10-02 → 2006-12-01 A (+60d) | 2007-04-06 → 2007-09-28 A (+175d) | 125d → 205d | 0% → 100% | 268d → none |  | resources ELEC ENG [153.43 h]; ELEC DES [577.6 h] → ELEC DES [577.6 h]; ELEC ENG [153.43 h] |
| 1222231010 | Design of tools for the LG bending technique (CTOF) | 2007-01-02 → 2006-12-01 A (-32d) | 2007-06-21 → 2007-09-28 A (+99d) | 120d → 205d | 0% → 100% | 325d → none |  | resources MECH ENG [90.25 h]; SCIENTIST [122.74 h]; MECH DES [158.84 h] → SCIENTIST [122.74 h]; MECH ENG [90.25 h]; MECH DES [158.84 h] |
| 1222232005 | Design of the backing structure for scintillators (FTOF) | 2006-10-02 → 2006-12-01 A (+60d) | 2007-04-06 → 2007-09-28 A (+175d) | 125d → 205d | 0% → 100% | 493d → none |  | resources SCIENTIST [122.74 h]; MECH ENG [61.37 h]; MECH DES [122.74 h] → MECH DES [122.74 h]; SCIENTIST [122.74 h]; MECH ENG [61.37 h] |
| 1222211020 | SVT- Design readout software (SILICON DTCTR) | 2007-04-09 → 2007-01-02 A (-97d) | 2007-09-28 A | 122d → 189d | 0% → 100% | 268d → none |  |  |
| 1222223015 | Design scintillator holders (FCAL) | 2006-12-22 → 2007-01-02 A (+11d) | 2007-03-27 → 2007-09-28 A (+185d) | 60d → 189d | 0% → 100% | 419d → none |  |  |
| 1222223020 | Design lead sheets (FCAL) | 2007-03-26 → 2007-01-02 A (-83d) | 2007-04-20 → 2007-09-28 A (+161d) | 20d → 189d | 0% → 100% | 419d → none | 1222223015 FS-2d → 1222223015 FS-19d | resources MECH DES [18.05 h]; MECH ENG [46.8 h] → MECH ENG [46.8 h]; MECH DES [18.05 h] |
| 1222223025 | Design pmt holders fiber routing and light guides (FCAL) | 2006-10-02 → 2007-01-02 A (+92d) | 2007-03-02 → 2007-09-28 A (+210d) | 100d → 189d | 0% → 100% | 454d → none |  |  |
| 1222223030 | Design lifting plan and hardware (FCAL) | 2006-11-15 → 2007-01-02 A (+48d) | 2007-01-22 → 2007-09-28 A (+249d) | 40d → 189d | 0% → 100% | 482d → none |  |  |
| 1222213020 | DC-Design On-chamber Electronics: Phase 2 (F DRFT CHAMB) | 2007-04-02 → 2007-03-16 A (-17d) | 2007-09-28 A | 127d → 138d | 0% → 100% | 251d → none |  | resources CONTRB UNIV LBR [245.48 h]; ELEC DES [337.6 h]; ELEC ENG [122.74 h]; ELEC TECH [122.74 h] → ELEC ENG [122.74 h]; ELEC DES [337.6 h]; ELEC TECH [122.74 h]; CONTRB UNIV LBR [245.48 h] |
| 1222213015 | DC- Design of the chamber & Stringing Fixture : Phase 2 (F DRFT CHAMB) | 2007-04-02 → 2007-04-13 A (+11d) | 2007-09-28 A | 127d → 118d | 0% → 100% | 251d → none |  |  |
| 1222232020 | PMT housing and grounding design (FTOF) | 2007-02-15 → 2007-05-01 A (+75d) | 2007-09-28 A | 158d → 106d | 0% → 100% | 371d → none |  | resources SCIENTIST [122.74 h]; MECH ENG [61.2 h]; MECH DES [122.74 h] → MECH ENG [61.2 h]; MECH DES [122.74 h]; SCIENTIST [122.74 h] |
| 1222242010 | Design of the support structure (LTCC) | 2007-03-21 → 2007-05-01 A (+41d) | 2007-08-23 → 2007-12-17 A (+116d) | 110d → 160d | 0% → 100% | 411d → none |  | resources MECH DES [306.85 h]; MECH ENG [31.6 h] → MECH ENG [31.6 h]; MECH DES [306.85 h] |
| 1222231015 | Design the support for the triplet with 1 m long bend LG's (CTOF) | 2007-02-15 → 2007-06-15 A (+120d) | 2007-06-14 → 2007-09-28 A (+106d) | 84d → 74d | 0% → 100% | 330d → none |  | resources SCIENTIST [122.74 h]; MECH ENG [61.37 h]; MECH DES [194.94 h] → MECH ENG [61.37 h]; MECH DES [194.94 h]; SCIENTIST [122.74 h] |
| 1222213025M | FDC- FY07 Techncl Dsgn Report & Sfty Assessmnt (DETCTR) | 2007-09-28 A | 2007-09-28 A |  | 0% → 100% | 251d → none |  |  |
| 1222223030M | EC-FY07 technical design report and safety assessment (FCAL) | 2007-04-20 → 2007-09-28 A (+161d) | 2007-04-20 → 2007-09-28 A (+161d) |  | 0% → 100% | 419d → none |  |  |
| 1222231020M | CTOF-FY07 Techncl Dsgn Report & Sfty Assessmnt (DETCTR) | 2007-06-21 → 2007-09-28 A (+99d) | 2007-06-21 → 2007-09-28 A (+99d) |  | 0% → 100% | 325d → none |  |  |
| 1222232020M | FTOF- FY07 technical design report and safety assessment | 2007-09-28 A | 2007-09-28 A |  | 0% → 100% | 371d → none |  |  |
| 1222241025M | FY07 technical design report and safety assessment (HTCC) | 2007-09-28 A | 2007-09-28 A |  | 0% → 100% | 296d → none |  |  |
| 12222005 | SVT- Dsgn Supprt Struct Optimztn Comptd (DETCTR) | 2007-11-28 → 2007-10-01 A (-58d) | 2008-05-12 → 2009-03-27 A (+319d) | 110d → 366d | 0% → 100% | 228d → none |  | resources MECH DES [440 h]; PROCUREMENT<$50K 60 → PROCUREMENT<$50K 60; MECH DES [440 h] |
| 12222025 | FDC- Comp Dsgn of Chamb & Stringing Fixture (DETCTR) | 2007-10-01 A | 2008-09-25 → 2008-09-26 A (+1d) | 245d → 246d | 0% → 100% | 251d → none |  | resources MECH ENG [240 h]; MECH TECH [640 h]; MECH DES [640 h]; SCIENTIST [40 h]; CONTRB UNIV LBR [1920 h] → MECH DES [640 h]; MECH TECH [640 h]; CONTRB UNIV LBR [1920 h]; MECH ENG [240 h]; SCIENTIST [40 h] |
| 12222030 | FDC- Comp Dsgn of Chambers Electrnc's (DETCTR) | 2007-10-01 A | 2008-09-25 → 2009-04-20 A (+207d) | 245d → 382d | 0% → 100% | 251d → none |  | resources ELEC TECH [600 h]; SCIENTIST [80 h]; CONTRB UNIV LBR [1920 h]; ELEC DES [1200 h]; ELEC ENG [400 h] → ELEC DES [1200 h]; ELEC ENG [400 h]; ELEC TECH [600 h]; SCIENTIST [80 h]; CONTRB UNIV LBR [1920 h] |
| 12222045 | CTOF- Compltn of Light Guides Dsgn (DETCTR) | 2007-06-22 → 2007-10-01 A (+101d) | 2007-12-12 → 2009-01-20 A (+405d) | 120d → 319d | 0% → 100% | 445d → none |  | resources ELEC DES [200 h]; MECH DES [40 h]; SCIENTIST [40 h]; MECH ENG [120 h] → MECH DES [40 h]; SCIENTIST [40 h]; MECH ENG [120 h]; ELEC DES [200 h] |
| 12222050 | CTOF- Compltn of Dsgn LG bending (DETCTR) | 2007-06-22 → 2007-10-01 A (+101d) | 2007-12-12 → 2008-08-29 A (+261d) | 120d → 227d | 0% → 100% | 325d → none |  |  |
| 12222055 | PROC CTOF- Comp Dsgn Supprt for Triplet with 1 m long bend LG's (DETCTR)+ | 2008-09-30 → 2007-10-01 A (-365d) | 2009-03-30 → 2009-02-20 A (-38d) | 120d → 341d | 0% → 100% | 129d → none |  |  |
| 12222055a | FY08 LAB/EXP CTOF- Comp Dsgn Supprt for Triplet with 1 m long bend LG's (DETCTR)+ | 2008-09-30 → 2007-10-01 A (-365d) | 2008-09-30 → 2007-10-02 A (-364d) | 1d → 2d | 0% → 100% | 129d → none |  | was named FY08 Exp CTOF- Comp Dsgn Supprt for Triplet with 1 m long bend LG's (DETCTR)+; resources MECH ENG [1 h]; SCIENTIST [0.33 h]; MECH DES [1 h] → SCIENTIST [0.33 h]; MECH ENG [1 h]; MECH DES [1 h] |
| 12222060 | FTOF- Comp Dsgn of Backing Struct for Scintillators (DETCTR) + | 2007-10-01 A | 2008-04-07 → 2008-10-24 A (+200d) | 125d → 266d | 0% → 100% | 371d → none |  | resources MECH DES [40 h]; SCIENTIST [40 h]; MECH ENG [120 h] → MECH ENG [120 h]; SCIENTIST [40 h]; MECH DES [40 h] |
| 12222065 | FTOF- Comp Magnetic Shielding Dsgn (DETCTR) + | 2007-10-01 A | 2008-04-07 → 2008-08-29 A (+144d) | 125d → 227d | 0% → 100% | 371d → none |  | resources MECH ENG [120 h]; SCIENTIST [40 h]; MECH DES [80 h] → MECH ENG [120 h]; MECH DES [80 h]; SCIENTIST [40 h] |
| 12222070 | FTOF- Comp PMT Housing & Grounding Dsgn (DETCTR)+ | 2007-10-01 A | 2008-04-07 → 2008-10-24 A (+200d) | 125d → 266d | 0% → 100% | 371d → none |  | was named FTOF- Comp PMT Housing & Grounding Dsgn (DETCTR) +; resources ELEC DES [200 h]; MECH ENG [120 h]; MECH DES [40 h]; SCIENTIST [40 h] → MECH ENG [120 h]; MECH DES [40 h]; SCIENTIST [40 h]; ELEC DES [200 h] |
| 12222075 | PROC HTCC- Dsgn of Whole Module (DETCTR) | 2008-09-30 → 2007-10-01 A (-365d) | 2009-07-22 → 2009-01-20 A (-183d) | 200d → 319d | 0% → 100% | 49d → none |  |  |
| 12222075a | FY08 LAB/EXP HTCC- Dsgn of Whole Module (DETCTR) | 2008-09-30 → 2007-10-01 A (-365d) | 2008-09-30 → 2007-10-02 A (-364d) | 1d → 2d | 0% → 100% | 49d → none |  | was named FY08 Exp HTCC- Dsgn of Whole Module (DETCTR); resources ELEC DES [2.2 h]; SCIENTIST [0.4 h]; MECH DES [2.2 h]; MECH ENG [0.8 h] → MECH DES [2.2 h]; ELEC DES [2.2 h]; SCIENTIST [0.4 h]; MECH ENG [0.8 h] |
| 1222232030 | FTOF- Comp Dsgn of Light Guides (DETCTR) (FY-08) | 2007-04-09 → 2007-10-01 A (+175d) | 2007-10-03 → 2008-08-29 A (+331d) | 125d → 227d | 0% → 100% | 493d → none |  | was named FTOF- Comp Dsgn of Light Guides (DETCTR) (FY-07) Notebook; resources MECH ENG [120 h]; MECH DES [40 h]; SCIENTIST [40 h] → SCIENTIST [40 h]; MECH ENG [120 h]; MECH DES [40 h] |
| 12222055b | FY09 LAB/EXP CTOF- Comp Dsgn Supprt for Triplet with 1 m long bend LG's (DETCTR)+ | 2008-10-01 → 2007-10-03 A (-364d) | 2009-03-30 → 2009-04-20 A (+21d) | 119d → 380d | 0% → 100% | 129d → none |  | was named FY09 Exp CTOF- Comp Dsgn Supprt for Triplet with 1 m long bend LG's (DETCTR)+; resources MECH DES [119 h]; SCIENTIST [39.67 h]; MECH ENG [119 h] → MECH ENG [119 h]; MECH DES [119 h]; SCIENTIST [39.67 h] |
| 12222075b | FY09 LAB/EXP HTCC- Dsgn of Whole Module (DETCTR) | 2008-10-01 → 2007-10-03 A (-364d) | 2009-07-22 → 2009-02-20 A (-152d) | 199d → 339d | 0% → 100% | 49d → none |  | was named FY09 Exp HTCC- Dsgn of Whole Module (DETCTR); resources MECH ENG [159.2 h]; ELEC DES [437.8 h]; SCIENTIST [79.6 h]; MECH DES [437.8 h] → SCIENTIST [79.6 h]; MECH DES [437.8 h]; MECH ENG [159.2 h]; ELEC DES [437.8 h] |
| 12222000 | FY08 SVT- Comp Dsgn Layout (DETCTR)+ | 2008-05-13 → 2007-10-16 A (-210d) | 2008-09-30 → 2008-09-16 A (-14d) | 98d → 226d | 0% → 100% | 236d → none |  |  |
| 12222020M | FDC- Resource Loaded Schedule for Fab (DETCTR) | 2007-10-01 → 2007-10-22 A (+21d) | 2007-10-01 → 2007-10-22 A (+21d) |  | 0% → 100% | 251d → none |  |  |
| 12222010 | SVT- Dsgn of VME Board Comptd (DETCTR) | 2008-03-31 → 2007-11-01 A (-151d) | 2008-09-24 → 2008-08-29 A (-26d) | 125d → 204d | 0% → 100% | 252d → none |  | resources ELEC ENG [880 h]; ELEC DES [880 h] → ELEC DES [880 h]; ELEC ENG [880 h] |
| 12222015 | FY08 SVT- Dsgn Readout Software Comptd (DETCTR) | 2008-03-31 → 2007-11-01 A (-151d) | 2008-09-30 → 2008-10-15 A (+15d) | 129d → 235.21d | 0% → 100% | 228d → none |  | resources COMP SCIENT [190.47 h]; SCIENTIST [10.39 h]; ELEC ENG [761.88 h]; CONTRB UNIV LBR [761.88 h]; ELEC TECH [380.94 h]; OFFICE [17.32 h] → COMP SCIENT [190.47 h]; ELEC ENG [761.88 h]; OFFICE [17.32 h]; CONTRB UNIV LBR [761.88 h]; ELEC TECH [380.94 h]; SCIENTIST [10.39 h] |
| 12222040 | FY08 EC- Comp Dsgn of Assy (DETCTR) | 2008-09-30 → 2007-11-01 A (-334d) | 2008-09-30 → 2007-11-02 A (-333d) | 1d → 1.02d | 0% → 100% | 60d → none |  | was named FY08 Exp EC- Comp Dsgn of Assy (DETCTR); resources MECH DES [2.4 h]; SCIENTIST [0.27 h]; MECH ENG [0.93 h] → SCIENTIST [0.27 h]; MECH ENG [0.93 h]; MECH DES [2.4 h] |
| 12222080 | LTCC- Dsgn Extended Working Volume (DETCTR) | 2007-08-24 → 2007-11-01 A (+69d) | 2008-02-08 → 2009-07-27 A (+535d) | 110d → 427d | 0% → 100% | 411d → none |  |  |
| 12222040a | FY09 EC- Comp Dsgn of Assy (DETCTR) | 2008-10-01 → 2007-11-05 A (-331d) | 2009-05-11 → 2009-01-20 A (-111d) | 149d → 294d | 0% → 100% | 60d → none |  | was named FY09 Exp EC- Comp Dsgn of Assy (DETCTR) |
| 1222242015M | LTCC- FY07 Techncl Dsgn Report & Sfty Assessmnt (DETCTR) | 2007-08-23 → 2007-12-17 A (+116d) | 2007-08-23 → 2007-12-17 A (+116d) |  | 0% → 100% | 411d → none |  |  |
| 12222000a | FY09 SVT- Comp Dsgn Layout (DETCTR)+ | 2008-10-01 → 2008-09-17 A (-14d) | 2008-10-16 → 2009-03-27 A (+162d) | 12d → 128d | 0% → 100% | 236d → none |  |  |
| 12222015a | FY09 SVT- Dsgn Readout Software Comptd (DETCTR) | 2008-10-01 A | 2008-10-28 → 2009-05-25 A (+209d) | 20d → 158d | 0% → 100% | 228d → none |  | resources OFFICE [2.68 h]; COMP SCIENT [29.53 h]; ELEC ENG [118.12 h]; SCIENTIST [1.61 h]; CONTRB UNIV LBR [118.12 h]; ELEC TECH [59.06 h] → SCIENTIST [1.61 h]; CONTRB UNIV LBR [118.12 h]; ELEC TECH [59.06 h]; OFFICE [2.68 h]; COMP SCIENT [29.53 h]; ELEC ENG [118.12 h] |
| 142213009EX | FY09 Travel (FWD Chambers) | 2008-10-01 → 2008-12-02 A (+62d) | 2008-12-24 → 2008-12-22 A (-2d) | 59d → 15d | 0% → 100% | 248d → none |  |  |
| 1222223040 | EC- Dsgn of Lifting & Mounting Hardware (DETCTR)+ | 2009-01-30 → 2008-12-10 A (-51d) | 2009-07-07 → 2009-05-25 A (-43d) |  | 0% → 100% | 60d → none |  | resources SCIENTIST [52 h]; MECH DES [320 h]; MECH ENG [200 h] → MECH DES [320 h]; SCIENTIST [52 h]; MECH ENG [200 h] |
| 1222223041M | EC- Final Techncl Dsgn Report & Sfty Assessmnt (DETCTR)+ | 2009-05-11 → 2009-03-27 A (-45d) | 2009-05-11 → 2009-03-27 A (-45d) |  | 0% → 100% | 99d → none | 12222040a → 12222040a FS+47d |  |
| 1222241035M | HTCC- Techncl Dsgn Report (DETCTR)+ | 2009-07-22 → 2009-04-01 A (-112d) | 2009-07-22 → 2009-04-01 A (-112d) |  | 0% → 100% | 49d → none | 12222075, 12222075b → 12222075b FS+50d, 12222075 |  |
| 12222035M | FDC-Compltn of PED (DETCTR)+ | 2008-09-29 → 2009-04-20 A (+203d) | 2008-09-29 → 2009-04-20 A (+203d) |  | 0% → 100% | 249d → none |  |  |
| 12222015M | SVT- Techncl Dsgn Report & drawings (DETCTR)+ | 2008-10-28 → 2009-05-25 A (+209d) | 2008-10-28 → 2009-05-25 A (+209d) |  | 0% → 100% | 228d → none |  |  |
| 1222242020 | Re-Baseline Actuals Adjustment | 2013-08-30 A | 2013-08-30 A |  | 0% → 100% | 20d → none | 9-130M FS+227d → none |  |
| 3 | **1.2.2.2.3 COMPUTING** | 2006-10-02 → 2006-12-01 (+60d) |  |  |  |  |  |  |
| 122231005 | Trigger- Level 1 design (TRGR SYS) | 2006-10-02 → 2006-12-01 A (+60d) | 2007-03-16 → 2007-09-28 A (+196d) | 110d → 205d | 0% → 100% | 387d → none |  |  |

| ID | Task | Start | Finish | Duration | Complete | Total float | Predecessors | Other |
| --- | --- | --- | --- | --- | --- | --- | --- | --- |
| 122231010 | Trigger- Level 2 design (TRGR SYS) | 2006-12-21 → 2006-12-01 A (-20d) | 2007-06-26 → 2007-10-29 A (+125d) | 125d → 226d | 0% → 100% | 316d → none |  |  |
| 122231015 | Trigger- Electronic design (TRGR SYS) | 2007-06-27 → 2007-04-13 A (-75d) | 2007-09-28 → 2007-10-29 A (+31d) | 66d → 139d | 0% → 100% | 316d → none | 122231010, 122231005 → 122231005, 122231010 FS-11d | resources ELEC ENG [337.54 h]; SCIENTIST [158.84 h] → SCIENTIST [158.84 h]; ELEC ENG [337.54 h] |
| 12223025 | Trigger- Compltn of L-1 Dsgn Scheme (COMPUTNG) | 2007-10-01 A | 2008-01-03 → 2009-01-20 A (+383d) | 60d → 319d | 0% → 100% | 316d → none |  |  |
| 122231020M | Trigger- Design Report (TRGR SYS) | 2007-09-28 → 2007-10-29 A (+31d) | 2007-09-28 → 2007-10-29 A (+31d) |  | 0% → 100% | 316d → none |  |  |
| 12223030 | Trigger- Compltn of L-2 Dsgn Scheme (COMPUTNG) | 2008-01-04 → 2007-11-01 A (-64d) | 2008-03-31 → 2009-04-20 A (+385d) | 60d → 359d | 0% → 100% | 316d → none |  |  |
| 12223035 | Trigger- Compltn of Electronic Dsgn (COMPUTNG) | 2008-04-01 → 2007-11-01 A (-152d) | 2008-06-24 → 2009-06-15 A (+356d) | 60d → 398d | 0% → 100% | 316d → none |  |  |
| 12223040M | CLAS12 Trigger Techncl Dsgn Report (COMPUTNG)+ | 2008-06-24 → 2008-05-01 A (-54d) | 2008-06-24 → 2008-05-01 A (-54d) |  | 0% → 100% | 316d → none |  |  |
| 12223045 | CLAS12 Slow Control Dsgn Sys (COMPUTNG)++ | 2009-04-01 → 2009-06-01 A (+61d) | 2009-09-03 → 2009-09-28 A (+25d) | 110d → 84d | 0% → 100% | 18d → none |  | resources SCIENTIST [400 h]; PD UNIV STUDNT [440 h] → PD UNIV STUDNT [440 h]; SCIENTIST [400 h] |
| 122231025 | Re-Baseline Actuals Adjustment | 2013-08-30 A | 2013-08-30 A |  | 0% → 100% | 20d → none | 9-130M FS+227d → none |  |
| 4 | **1.2.2.2.4 ELECTRONICS** | 2008-01-04 → 2007-11-01 (-64d) |  |  |  |  |  |  |
| 12224005 | FADC Analysis (ADC) (ELECTRNC'S)++ | 2008-01-04 → 2007-11-01 A (-64d) | 2008-06-24 → 2009-04-20 A (+300d) | 120d → 359d | 0% → 100% | 26d → none |  |  |
| 12224010 | Re-Baseline Actuals Adjustment | 2013-08-30 A | 2013-08-30 A |  | 0% → 100% | 20d → none | 9-130M FS+227d → none |  |
| 5 | **1.2.2.2.5 BEAMLINE** | 2006-10-02 → 2006-12-01 (+60d) |  |  |  |  |  |  |
| 122253000 | Target- Design of Longitudinal polarized target (TARGETS) | 2007-01-04 → 2006-12-01 A (-34d) | 2007-08-07 → 2007-09-28 A (+52d) | 150d → 205d | 0% → 100% | 288d → none |  |  |
| 122254005 | BL-Shielding design for central detector (BL COMPON) | 2006-10-02 → 2007-01-02 A (+92d) | 2007-03-16 → 2007-06-15 A (+91d) | 110d → 116d | 0% → 100% | 251d → none |  |  |
| 122254010 | BL-Forward detector shielding (BL COMPON) | 2007-03-19 → 2007-01-02 A (-76d) | 2007-09-28 A | 137d → 189d | 0% → 100% | 251d → none |  | resources MECH DES [122.74 h]; MECH ENG [30.8 h]; VISTNG USERS [398.9 h] → MECH ENG [30.8 h]; VISTNG USERS [398.9 h]; MECH DES [122.74 h] |
| 122253005M | Target- Design Report (TARGETS) | 2007-08-07 → 2007-09-28 A (+52d) | 2007-08-07 → 2007-09-28 A (+52d) |  | 0% → 100% | 288d → none |  |  |
| 122254015M | BL-Design Report (BL COMPON) | 2007-09-28 A | 2007-09-28 A |  | 0% → 100% | 251d → none |  |  |
| 12225050 | BL COMPON- Dsgn of BL Shielding (BL)+ | 2008-06-30 → 2008-03-05 A (-117d) | 2008-09-23 → 2009-09-28 A (+370d) | 60d → 393d | 0% → 100% | 253d → none | 12225045, 1135025 → 1135025 FS-20d, 12225045 FS-63d | resources MECH DES [80 h]; SCIENTIST [80 h]; MECH ENG [40 h] → SCIENTIST [80 h]; MECH ENG [40 h]; MECH DES [80 h] |
| 12225015 | Moller Polarimter Optic Dsgn (BL) | 2008-10-01 → 2008-08-11 A (-51d) | 2008-11-25 → 2009-09-28 A (+307d) | 40d → 282d | 0% → 100% | 168d → none |  |  |
| 12225045 | BL COMPON- Beam Vac Sys (BL) | 2008-01-04 → 2008-10-01 A (+271d) | 2008-03-31 → 2009-09-28 A (+546d) | 60d → 246d | 0% → 100% | 86d → none |  | resources MECH DES [80 h]; SCIENTIST [4 h]; MECH ENG [40 h] → SCIENTIST [4 h]; MECH ENG [40 h]; MECH DES [80 h] |
| 12225025 | Target- Layout (BL) | 2008-10-06 A | 2008-12-23 → 2009-03-20 A (+87d) | 55d → 110d | 0% → 100% | 0d → none |  | resources MECH DES [160 h]; SCIENTIST [40 h]; CONTRB UNIV LBR [120 h]; MECH ENG [80 h] → SCIENTIST [40 h]; MECH ENG [80 h]; MECH DES [160 h]; CONTRB UNIV LBR [120 h] |
| 12225035 | Target- Dsgn of Cryogenic Sys (BL) | 2009-05-18 → 2009-01-05 A (-133d) | 2009-08-04 → 2009-05-25 A (-71d) | 55d → 98d | 0% → 100% | 0d → none | 12225030 → 12225030 FS-15d | resources CONTRB UNIV LBR [80 h]; MECH ENG [80 h]; MECH DES [160 h]; SCIENTIST [40 h] → MECH DES [160 h]; CONTRB UNIV LBR [80 h]; MECH ENG [80 h]; SCIENTIST [40 h] |
| 12225030 | Target- Vac Sys Dsgn & Mech Supprt (BL) | 2008-12-24 → 2009-01-12 A (+19d) | 2009-05-15 → 2009-05-25 A (+10d) | 95d → 93d | 0% → 100% | 0d → none | 12225025 → 12225025 FS-25d | resources MECH DES [220 h]; SCIENTIST [100 h]; CONTRB UNIV LBR [160 h]; MECH ENG [120 h] → MECH ENG [120 h]; MECH DES [220 h]; SCIENTIST [100 h]; CONTRB UNIV LBR [160 h] |
| 12225040 | Target- Dsgn Control Sys (BL)+ | 2009-08-05 → 2009-01-12 A (-205d) | 2009-09-30 → 2009-05-25 A (-128d) | 40d → 93d | 0% → 100% | 0d → none | 12225035 → 12225035 FS-5d | resources CONTRB UNIV LBR [80 h]; SCIENTIST [44 h]; MECH ENG [80 h]; MECH DES [160 h] → SCIENTIST [44 h]; CONTRB UNIV LBR [80 h]; MECH ENG [80 h]; MECH DES [160 h] |
| 12225020 | Moller Polarimter Mech Supprt (BL)+ | 2008-11-26 → 2009-02-23 A (+89d) | 2009-02-02 → 2009-09-28 A (+238d) | 40d → 153d | 0% → 100% | 168d → none | 12225015 → 12225015 FS-500d |  |
| 122254020 | Re-Baseline Actuals Adjustment | 2013-08-30 A | 2013-08-30 A |  | 0% → 100% | 20d → none | 9-130M FS+227d → none |  |
| 12226010 | FY08 Utilities Dsgn of Connections to Cryogenic systems (Utilities) (INFSTRCTR)+ | 2008-04-01 A | 2008-09-30 → 2008-09-15 A (-15d) | 128d → 117d | 0% → 100% | 116d → none |  | was named FY08 Exp Utilities Dsgn of Connections to Cryogenic systems (Utilities) (INFSTRCTR)+ |
| 12226015 | FY08 Dsgn Mech Supprt Frames for HTCC (INFSTRCTR)+ | 2008-04-01 A | 2008-09-30 → 2008-09-15 A (-15d) | 128d → 117d | 0% → 100% | 56d → none |  | was named FY08 Exp Dsgn Mech Supprt Frames for HTCC (INFSTRCTR)+; resources MECH TECH [96 h]; SCIENTIST [32 h]; MECH ENG [352 h]; MECH DES [416 h] → MECH DES [416 h]; MECH TECH [96 h]; SCIENTIST [32 h]; MECH ENG [352 h] |
| 12226020 | FY08 Dsgn Mech Supprt Frames for Central Detector (INFSTRCTR)+ | 2008-04-01 A | 2008-09-30 → 2008-09-15 A (-15d) | 128d → 117d | 0% → 100% | 56d → none |  | was named FY08 Exp Dsgn Mech Supprt Frames for Central Detector (INFSTRCTR)+; resources MECH ENG [352 h]; SCIENTIST [32 h]; MECH DES [416 h]; MECH TECH [96 h] → MECH ENG [352 h]; MECH TECH [96 h]; MECH DES [416 h]; SCIENTIST [32 h] |
| 12226010a | FY09 Utilities Dsgn of Connections to Cryogenic systems (Utilities) (INFSTRCTR)+ | 2008-10-01 → 2008-09-16 A (-15d) | 2009-04-16 → 2009-09-28 A (+165d) | 132d → 257d | 0% → 100% | 116d → none |  | was named FY09 Exp Utilities Dsgn of Connections to Cryogenic systems (Utilities) (INFSTRCTR)+; resources MECH ENG [243.69 h]; MECH DES [446.77 h] → MECH DES [446.77 h]; MECH ENG [243.69 h] |
| 12226015a | FY09 Dsgn Mech Supprt Frames for HTCC (INFSTRCTR)+ | 2008-10-01 → 2008-09-16 A (-15d) | 2009-07-13 → 2009-09-28 A (+77d) | 192d → 257d | 0% → 100% | 56d → none |  | was named FY09 Exp Dsgn Mech Supprt Frames for HTCC (INFSTRCTR)+; resources SCIENTIST [48 h]; MECH ENG [528 h]; MECH DES [624 h]; MECH TECH [144 h] → MECH ENG [528 h]; MECH DES [624 h]; MECH TECH [144 h]; SCIENTIST [48 h] |
| 12226020a | FY09 Dsgn Mech Supprt Frames for Central Detector (INFSTRCTR)+ | 2008-10-01 → 2008-09-16 A (-15d) | 2009-07-13 → 2009-09-28 A (+77d) | 192d → 257d | 0% → 100% | 56d → none |  | was named FY09 Exp Dsgn Mech Supprt Frames for Central Detector (INFSTRCTR)+; resources MECH DES [624 h]; MECH TECH [144 h]; SCIENTIST [48 h]; MECH ENG [528 h] → MECH TECH [144 h]; SCIENTIST [48 h]; MECH ENG [528 h]; MECH DES [624 h] |
| 12226025 | Re-Baseline Actuals Adjustment | 2013-08-30 A | 2013-08-30 A |  | 0% → 100% | 20d → none | 9-130M FS+227d → none |  |
| 122311007LOE | FY07 Overview entire PED project Q1-QUAD | 2006-10-02 A | 2007-09-28 A |  | 0% → 100% | 0d → none |  |  |
| 122311010 | Perform magnetic analysis and analyze tolerances Q1-QUAD | 2006-10-02 A | 2007-04-13 → 2007-09-28 A (+168d) | 130d → 247d | 0% → 100% | 68d → none |  |  |
| 122311020 | Design LN2 shield Q1-QUAD | 2006-10-02 → 2006-11-01 A (+30d) | 2007-01-03 → 2008-02-14 A (+407d) | 60d → 314d | 0% → 100% | 17d → none |  | resources MECH ENG [40 h]; MECH DES [280 h] → MECH DES [280 h]; MECH ENG [40 h] |
| 122311030 | Design control system Q1-QUAD | 2006-10-02 → 2007-01-02 A (+92d) | 2006-11-28 → 2007-10-29 A (+335d) | 40d → 210d | 0% → 100% | 78d → none |  |  |
| 122311045 | P-1 Prepare reference design Q1-QUAD | 2007-03-06 → 2007-01-02 A (-63d) | 2007-11-28 → 2007-10-19 A (-40d) | 187d → 204d | 0% → 100% | 17d → none | 122311020, 122311035 FS-68d, 122311030, 122311010 FS-80d → 122311010 FS-80d, 122311020, 122311030 | resources SCIENTIST [476 h]; MECH ENG [193.6 h]; MECH DES [96.8 h] → MECH DES [96.8 h]; MECH ENG [193.6 h]; SCIENTIST [476 h] |
| 122311047 | Dsgn Vac Vessel Q1-QUAD | 2007-10-01 → 2007-08-01 A (-61d) | 2008-01-10 → 2008-02-26 A (+47d) | 65d → 138d | 0% → 100% | 60d → none |  |  |
| 122311035 | Trial Winding of Q1 Coil Q1-QUAD | 2007-01-04 → 2007-10-01 A (+270d) | 2007-06-08 → 2008-11-26 A (+537d) | 109d → 288d | 0% → 100% | 17d → none | 122311020 → 122311010 |  |
| 122311908LOE | FY08 Overview Entire PED Proj Q1-QUAD | 2007-10-01 A | 2008-09-30 A |  | 0% → 100% | 0d → none |  |  |
| 122311045b | P-2 Prep reference Dsgn Q1-QUAD | 2007-11-29 → 2007-10-22 A (-38d) | 2008-05-30 → 2008-07-31 A (+62d) | 122d → 191d | 0% → 100% | 17d → none |  | resources MECH ENG [120 h]; MECH DES [40 h] → MECH DES [40 h]; MECH ENG [120 h] |
| 122311049 | Dsgn Mag Supprt & Stand Q1-QUAD | 2008-01-11 → 2007-11-01 A (-71d) | 2008-03-31 → 2008-08-29 A (+151d) | 55d → 204d | 0% → 100% | 60d → none | 9-080M, 122311047 → 122311047 FS-40d, 9-080M | was named Dsgn Mag SupprtStand Q1-QUAD; resources MECH DES [360 h]; MECH ENG [40 h] → MECH ENG [40 h]; MECH DES [360 h] |
| 122311050M | Start Bid Process Q1-QUAD | 2008-06-02 → 2008-06-23 A (+21d) | 2008-06-02 → 2008-06-23 A (+21d) |  | 0% → 100% | 17d → none |  |  |
| 122311055 | FY08 Bid Process P-#1 Q1-QUAD | 2008-06-02 → 2008-06-23 A (+21d) | 2008-09-30 → 2008-11-26 A (+57d) | 85d → 110d | 0% → 100% | 17d → none | 122311050M, 122311049 → 122311049 FS-40d, 122311050M | was named FY08 Exp Bid Process P-#1 Q1-QUAD; resources TRAVEL; MECH DES [215.87 h]; MECH ENG [539.68 h]; SUPPLIES & MATERIALS → MECH DES [215.87 h]; TRAVEL; SUPPLIES & MATERIALS; MECH ENG [539.68 h] |
| 122311045M | Reference Dsgn Comptd Q1-QUAD | 2008-05-30 → 2008-07-31 A (+62d) | 2008-05-30 → 2008-07-31 A (+62d) |  | 0% → 100% | 17d → none |  |  |
| 14312909LOEX | Q1- FY09 Proj Mngmnt H-C upgrade | 2008-10-01 A | 2008-12-24 A |  | 0% → 100% | 20d → none |  |  |
| 122311056 | Determine Best Offer P-#2 Q1-QUAD+ | 2008-12-01 → 2008-11-20 A (-11d) | 2009-02-18 → 2009-05-29 A (+100d) | 50d → 126d | 0% → 100% | 17d → none | 122311055a → 122311035 FS+20d, 122311055a FS-26d |  |
| 122311055a | FY09 Bid Process P-#1 Q1-QUAD | 2008-10-01 → 2008-11-26 A (+56d) | 2008-11-26 → 2009-05-29 A (+184d) | 41d → 122d | 0% → 100% | 17d → none |  | was named FY09 Exp Bid Process P-#1 Q1-QUAD; resources MECH DES [104.13 h]; MECH ENG [260.32 h]; SUPPLIES & MATERIALS; TRAVEL → MECH ENG [260.32 h]; TRAVEL; SUPPLIES & MATERIALS; MECH DES [104.13 h] |
| 122311060 | Re-Baseline Actuals Adjustment | 2013-08-30 A | 2013-08-30 A |  | 0% → 100% | 20d → none | 9-130M FS+227d → none |  |
| 122312015 | Optimise coil design & analyze tolerances Q2-3/Dipole | 2006-10-02 A | 2007-03-30 → 2007-09-28 A (+182d) | 120d → 247d | 0% → 100% | 105d → none |  | was named Optimise coil design analyze tolerances HB/Q2-3/Dipole; resources MECH DES [667.2 h]; MECH ENG [194.68 h] → MECH ENG [194.68 h]; MECH DES [667.2 h] |
| 122312060 | Optimize Coil Design for HB Magnet | 2006-10-02 A | 2007-02-07 → 2007-11-30 A (+296d) | 84d → 289d | 0% → 100% | 251d → none |  | was named Optimize Coil Design for HB Magnet (HB) |
| 122312050 | Prepare reference design Q2-3/Dipole | 2006-10-02 → 2006-11-01 A (+30d) | 2007-08-01 → 2008-11-21 A (+478d) | 206d → 511d | 0% → 100% | 57d → none |  | resources MECH ENG [320 h]; MECH DES [160 h]; SUPPLIES & MATERIALS → MECH DES [160 h]; SUPPLIES & MATERIALS; MECH ENG [320 h] |
| 122312030 | Design helium vessel Q2-3/Dipole | 2007-04-02 → 2007-01-02 A (-90d) | 2007-05-24 → 2008-11-21 A (+547d) | 39d → 475d | 0% → 100% | 105d → none |  | was named Design helium vessel (HB/Q2-3/Dipole) |
| 122312035 | Design LN2 shield Q2-3/Dipole | 2007-03-30 → 2007-05-01 A (+32d) | 2007-06-21 → 2008-07-31 A (+406d) | 59d → 312d | 0% → 100% | 105d → none |  | was named Design LN2 shield HB/Q2-3/Dipole; resources MECH DES [480 h]; MECH ENG [40 h] → MECH ENG [40 h]; MECH DES [480 h] |
| 122312045 | P-1 Dsgn Mag Supprt & Stand Q2-3/Dipole | 2007-08-02 → 2007-05-01 A (-93d) | 2007-09-12 → 2007-12-17 A (+96d) | 29d → 160d | 0% → 100% | 57d → none | 122312035 FS-20d, 122312050M → 122312035 FS-20d | resources MECH DES [192 h]; PROCUREMENT<$50K 60; MECH ENG [16 h] → MECH ENG [16 h]; MECH DES [192 h]; PROCUREMENT<$50K 60 |
| 122312074 | Dsgn Cryostat for Horiz Bender HB | 2007-10-01 → 2007-08-01 A (-61d) | 2008-01-03 → 2009-02-11 A (+405d) | 60d → 377d | 0% → 100% | 366d → none |  | was named Dsgn Cryostat for Horiz Bender (HB); resources MECH DES [200 h]; MECH ENG [40 h] → MECH ENG [40 h]; MECH DES [200 h] |
| 122312076 | Dsgn quench Detection Sys for Horiz Bender | 2007-10-01 → 2007-08-01 A (-61d) | 2007-11-26 → 2008-03-24 A (+119d) | 39d → 157d | 0% → 100% | 387d → none |  | was named Dsgn quench Detection Sys for Horiz Bender (HB) |
| 122312078 | Dsgn Supprt & Stand for Horiz Bender | 2007-10-01 → 2007-08-01 A (-61d) | 2008-01-03 → 2009-07-21 A (+565d) | 60d → 488d | 0% → 100% | 366d → none |  | was named Dsgn Supprt & Stand for Horiz Bender (HB) |
| 122312080 | Prepare Preliminary Design for HB | 2007-10-01 → 2007-08-01 A (-61d) | 2008-03-26 → 2008-05-30 A (+65d) | 117d → 205d | 0% → 100% | 89d → none |  | was named Prepare Preliminary Dsgn for HB; resources MECH ENG [120 h]; MECH DES [40 h]; SUPPLIES & MATERIALS → SUPPLIES & MATERIALS; MECH ENG [120 h]; MECH DES [40 h] |
| 122312079 | CR 07-005 Procurements P-1 Dipole | 2007-10-01 → 2008-01-01 A (+92d) | 2008-03-03 A | 100d → 42d | 0% → 100% | 276d → none | 9-080M → 9-080M FS+75d |  |
| 122312045b | P-2 Dsgn Mag Supprt & Stand Q2-3/Dipole | 2007-09-13 → 2008-01-15 A (+124d) | 2007-11-12 → 2009-06-19 A (+585d) | 43d → 358d | 0% → 100% | 57d → none | 122312045 → 122312045 FS-120d |  |
| 122312084 | CR 07-005 P-2 Dipole | 2008-03-04 → 2008-03-10 A (+6d) | 2008-07-23 → 2008-11-21 A (+121d) | 100d → 182d | 0% → 100% | 276d → none |  | was named CR 07-005 Procurements P-2 Dipole |
| 122312080a | Prepare Reference Design for HB | 2008-05-01 → 2008-05-30 A (+29d) | 2008-11-14 → 2009-02-11 A (+89d) | 139d → 173d | 0% → 100% | 145d → none | 9-080M FS+142d → 9-080M | was named Prepare Reference Dsgn for HB |
| 122312050M | Reference design completed Q2-3/Dipole | 2007-08-01 → 2008-11-21 A (+478d) | 2007-08-01 → 2008-11-21 A (+478d) |  | 0% → 100% | 57d → none |  |  |
| 122312062M | Start Bid Process Q2-3/Dipole | 2007-10-01 → 2008-11-24 A (+420d) | 2007-10-01 → 2008-11-24 A (+420d) |  | 0% → 100% | 88d → none | 1141010, 1141015, 9-080M, 1141020, 122312060 → 1141015, 9-080M, 122312060, 1141020, 122312050M |  |
| 122312065 | Bid Process P-#1 Q2-3/Dipole | 2007-11-13 → 2008-11-24 A (+377d) | 2008-06-11 → 2009-09-21 A (+467d) | 140d → 203d | 0% → 100% | 57d → none | 122312045b, 122312062M → 122312062M | resources SUPPLIES & MATERIALS; MECH ENG [120 h]; MECH DES [320 h]; TRAVEL → MECH DES [320 h]; SUPPLIES & MATERIALS; MECH ENG [120 h]; TRAVEL |
| 14315050x | Design Cryo Reservoirs for All Mag | 2008-12-01 A | 2009-04-01 → 2009-04-30 A (+29d) | 80d → 101d | 0% → 100% | 346d → none |  |  |
| 14315055x | Design Iron Yoke for Q2/3 and Dipole | 2008-12-01 A | 2009-03-04 → 2009-06-17 A (+105d) | 60d → 134d | 0% → 100% | 692d → none |  |  |

| ID | Task | Start | Finish | Duration | Complete | Total float | Predecessors | Other |
| --- | --- | --- | --- | --- | --- | --- | --- | --- |
| 122312090 | Bid Process for Horiz Bender P-#1 (HB) | 2008-11-17 → 2009-02-02 A (+77d) | 2009-02-05 → 2009-11-30 A (+298d) | 50d → 210d | 0% → 100% | 145d → none | 122312078, 122312074, 122312080M → 122312074, 122312078 FS-40d, 122312080M | resources MECH DES [120 h]; MECH ENG [280 h] → MECH ENG [280 h]; MECH DES [120 h] |
| 122312080M | Reference Dsgn for Horiz Bender Comptd | 2008-11-14 → 2009-02-11 A (+89d) | 2008-11-14 → 2009-02-11 A (+89d) |  | 0% → 100% | 145d → none |  | was named Reference Dsgn for Horiz Bender Comptd (HB) |
| 122312070 | Determine Best Offer P-#2 Q2-3/Dipole | 2008-06-12 → 2009-11-30 A (+536d) | 2008-09-05 → 2009-11-30 A (+451d) | 60d → 1d | 0% → 100% | 57d → none | 1141011, 122312065 → 122312084 FS+40d, 1141011, 122312065 |  |
| 122312095 | Determine Best Offer for Horiz Bender P-#2 | 2009-02-06 → 2009-11-30 A (+297d) | 2009-03-06 → 2009-11-30 A (+269d) | 20d → 1d | 0% → 100% | 145d → none |  | was named Determine Best Offer for Horiz Bender P-#2 (HB) |
| 122312100 | Re-Baseline Actuals Adjustment | 2013-08-30 A | 2013-08-30 A |  | 0% → 100% | 20d → none | 9-130M FS+227d → none |  |
| 2 | **1.2.2.3.2 DETECTOR** | 2007-01-04 → 2007-01-02 (-2d) |  |  |  |  |  |  |
| 122321005 | P-1 Update and rescale existing drawings (WIRE CHAMB) | 2007-01-04 → 2007-01-02 A (-2d) | 2007-09-28 → 2008-03-28 A (+182d) | 187d → 308d | 0% → 100% | 248d → none |  |  |
| 122322005 | Update drawings for scintillator (HODO) | 2007-01-04 → 2007-01-02 A (-2d) | 2007-07-10 → 2008-07-21 A (+377d) | 130d → 387d | 0% → 100% | 333d → none |  |  |
| 122325005 | Prepare drawings for final block arrangements (SHWR CNTR) | 2007-01-04 → 2007-02-23 A (+50d) | 2007-03-30 → 2008-07-30 A (+488d) | 60d → 358d | 0% → 100% | 603d → none |  | resources TRAVEL; SCIENTIST [63.2 h]; VISTNG USERS [366.8 h] → VISTNG USERS [366.8 h]; SCIENTIST [63.2 h]; TRAVEL |
| 122323005 | P-1 Update existing drawings for Cerenkov (HIPRESS CRNKV) | 2007-06-18 → 2007-03-01 A (-109d) | 2007-09-28 → 2008-03-28 A (+182d) | 73d → 268d | 0% → 100% | 275d → none |  |  |
| 122322015 | P-1 Prep Drawings for Quartz hodoscope (HODO) | 2007-05-14 → 2007-04-02 A (-42d) | 2007-08-02 → 2008-03-28 A (+239d) | 57d → 245d | 0% → 100% | 333d → none |  | was named P-1 Prep Drawings for Quartz hosdoscope (HODO); resources TRAVEL; SCIENTIST [28 h]; PLABOR; VISTNG USERS [184 h] → VISTNG USERS [184 h]; TRAVEL; PLABOR; SCIENTIST [28 h] |
| 122324005 | P-1 Prepare Drawings for Heavy Gas Cerenkove (LOPRESS CRNKV) | 2009-01-05 → 2007-06-15 A (-570d) | 2009-03-19 → 2008-03-28 A (-356d) | 52d → 193d | 0% → 100% | 65d → none | 1142020, 9-090M FS+60d → 9-070M | was named P-1 Prepare drawings for heavy gas Cerenkove (LOPRESS CRNKV) |
| 122325020 | Dsgn Detector Frame (SHWR CNTR)++ | 2009-05-01 → 2007-12-12 A (-506d) | 2009-09-29 → 2009-09-30 A (+1d) | 105d → 446d | 0% → 100% | 1d → none | 122325015 → 122325015 FS-125d |  |
| 12232015 | P-2 Update & Rescale Eisting Drawings (Wire CHAMB)+ | 2008-10-01 → 2008-06-16 A (-107d) | 2009-09-01 → 2009-06-24 A (-69d) | 228d → 255d | 0% → 100% | 0d → none | 122321005, 9-090M → 9-090M FS-100d, 122321005 | was named P-2 Update & Rescale Existing Drawings (Wire CHAMB)+ |
| 122322015b | P-2 Prep Drawings for Quartz Hodoscope (HODO)+ | 2008-10-01 → 2008-06-16 A (-107d) | 2009-07-28 → 2009-08-27 A (+30d) | 203d → 300d | 0% → 100% | 45d → none | 9-090M, 122322015 → 9-090M FS-100d, 122322015 FS-60d | resources TRAVEL; SCIENTIST [92 h]; PLABOR; VISTNG USERS [644 h] → VISTNG USERS [644 h]; TRAVEL; SCIENTIST [92 h]; PLABOR |
| 122324005b | P-2 Prep Drawings for Heavy Gas Cerenkove (LOPRESS CRNKV) | 2009-03-20 → 2008-07-14 A (-249d) | 2009-04-03 → 2008-11-04 A (-150d) | 11d → 81d | 0% → 100% | 65d → none |  |  |
| 122323005b | P-2 Update Existing Drawings for Cerenkov (HIPRESS CRNKV) | 2008-10-01 → 2008-11-03 A (+33d) | 2008-10-15 → 2008-11-04 A (+20d) | 11d → 2d | 0% → 100% | 27d → none | 122323005, 9-090M → 122323005 |  |
| 122325015 | Prep Drawings for PM & Cable Arrangement (SHWR CNTR) | 2008-10-20 → 2009-05-25 A (+217d) | 2009-04-30 → 2009-07-24 A (+85d) | 129d → 43d | 0% → 100% | 1d → none | 9-090M FS+13d → 1142020, 9-090M FS+13d | resources TRAVEL; PLABOR; SCIENTIST [48 h]; VISTNG USERS [240 h] → VISTNG USERS [240 h]; TRAVEL; PLABOR; SCIENTIST [48 h] |
| 122323015 | Update Existing Drawers for Cerenkov (HIPRESS CRNKV)+ | 2009-02-19 → 2009-05-29 A (+99d) | 2009-08-21 → 2009-08-05 A (-16d) | 130d → 48d | 0% → 100% | 27d → none | 122323005b FS+80d → 122323005b |  |
| 122324015 | Prep Drawings for Heavy Gas Cerenkove (LOPRESS CRNKV)+ | 2009-04-06 → 2009-05-29 A (+53d) | 2009-06-29 → 2009-08-14 A (+46d) | 60d → 55d | 0% → 100% | 65d → none | 122324005b → 122324005b FS+1d |  |
| 12232020 | P-3 Update & Rescale Existing Drawings (Wire CHAMB)+ | 2009-09-02 → 2009-07-01 A (-63d) | 2009-09-30 → 2009-09-18 A (-12d) | 20d → 56d | 0% → 100% | 0d → none | 122325005, 12232015 → 12232015 FS-100d, 122325005 FS-15d | was named P-3 Update & Rescale Existing Drawings (Wire CHAMB) + |
| 122325025 | Re-Baseline Actuals Adjustment | 2013-08-30 A | 2013-08-30 A |  | 0% → 100% | 20d → none | 9-130M FS+227d → none |  |
| 6 | **1.2.2.3.6 INFRASTRUCTURE** | 2006-10-02 → 2006-11-01 (+30d) |  |  |  |  |  |  |
| 122363010 | Prepare preliminary drawings (SHLD HOUSE) | 2006-10-02 → 2006-11-01 A (+30d) | 2007-02-05 → 2007-04-27 A (+81d) | 82d → 118d | 0% → 100% | 160d → none |  |  |
| 122362010 | Hire subcontructor to prepare preliminmary design (SUP STRUCT) | 2006-10-02 → 2007-01-02 A (+92d) | 2007-02-14 → 2007-04-27 A (+72d) | 89d → 82d | 0% → 100% | 154d → none |  |  |
| 122361010 | P-1 Dsgn Vac Sys (ENG&DES)+ | 2007-04-16 → 2007-04-13 A (-3d) | 2007-09-28 → 2007-11-30 A (+63d) | 117d → 160d | 0% → 100% | 386d → none |  | resources MECH DES [220 h]; SUPPLIES & MATERIALS; MECH ENG [110 h] → MECH DES [220 h]; MECH ENG [110 h]; SUPPLIES & MATERIALS |
| 122361015 | P-1 Dsgn Cryogenic Sys (ENG&DES)+ | 2007-04-16 → 2007-04-13 A (-3d) | 2007-09-28 → 2007-11-30 A (+63d) | 117d → 161d | 0% → 100% | 486d → none |  | resources MECH DES [148 h]; SUPPLIES & MATERIALS; MECH ENG [72 h] → SUPPLIES & MATERIALS; MECH ENG [72 h]; MECH DES [148 h] |
| 122362015 | Approve preliminary design (SUP STRUCT) | 2007-02-15 → 2007-04-27 A (+71d) | 2007-02-22 → 2007-06-15 A (+113d) | 5d → 35d | 0% → 100% | 154d → none |  | resources MECH ENG [40 h]; TRAVEL; MECH DES [40 h] → MECH ENG [40 h]; MECH DES [40 h]; TRAVEL |
| 122363015 | Approve preliminary design (SHLD HOUSE) | 2007-02-06 → 2007-04-27 A (+80d) | 2007-02-12 → 2007-06-15 A (+123d) | 5d → 35d | 0% → 100% | 160d → none |  | resources MECH DES [40 h]; MECH ENG [40 h]; TRAVEL → TRAVEL; MECH ENG [40 h]; MECH DES [40 h] |
| 12236020 | Dsgn Scattering Chamb (ENG&DES)+ | 2008-10-01 → 2007-12-10 A (-296d) | 2008-10-28 → 2009-05-29 A (+213d) | 20d → 362d | 0% → 100% | 128d → none |  |  |
| 12236025 | Dsgn Beam Pipe & Stands (ENG&DES)+ | 2008-10-01 → 2007-12-11 A (-295d) | 2009-01-02 → 2009-09-28 A (+269d) | 60d → 445d | 0% → 100% | 88d → none |  | resources SUPPLIES & MATERIALS; MECH ENG [80 h]; MECH DES [160 h] → MECH ENG [80 h]; MECH DES [160 h]; SUPPLIES & MATERIALS |
| 122362020 | Produce detailed design and drawings (SUP STRUCT) | 2007-10-01 → 2008-01-15 A (+106d) | 2008-03-17 → 2008-09-30 A (+197d) | 110d → 181d | 0% → 100% | 1d → none | 9-080M, 122362015 → 9-080M FS+62.5d, 122362015 | resources MECH ENG [113.6 h]; MECH DES [280.4 h]; PROCUREMENT<$50K 60 → PROCUREMENT<$50K 60; MECH ENG [113.6 h]; MECH DES [280.4 h] |
| 122363020 | Prepare detailed design and drawings (SHLD HOUSE) | 2007-10-01 → 2008-01-15 A (+106d) | 2008-03-31 → 2008-09-30 A (+183d) | 120d → 181d | 0% → 100% | 0d → none | 122363015, 9-080M → 122363015, 9-080M FS+63d | resources PROCUREMENT<$50K 60; MECH ENG [80 h]; MECH DES [80 h] → MECH ENG [80 h]; MECH DES [80 h]; PROCUREMENT<$50K 60 |
| 12236030 | PROC Continue Reference Dsgn & Drawings (SUP STRUCT) | 2008-03-18 → 2008-07-14 A (+118d) | 2009-03-05 → 2008-11-21 A (-104d) | 240d → 94d | 0% → 100% | 1d → none | 122362020 → 122362020 FS-160d |  |
| 12236030a | FY08 LAB/EXP Continue Reference Dsgn & Drawings (SUP STRUCT) | 2008-03-18 → 2008-07-14 A (+118d) | 2008-09-30 → 2008-10-20 A (+20d) | 138d → 70d | 0% → 100% | 1d → none |  | was named FY08 Exp Continue Reference Dsgn & Drawings (SUP STRUCT); resources TRAVEL; MECH DES [115 h]; MECH ENG [50.6 h] → MECH DES [115 h]; MECH ENG [50.6 h]; TRAVEL |
| 12236830LOE | FY09 Coordinate All SHMS Compnts with Supprt Struct (ENG&DES)+ | 2008-10-01 A | 2009-07-08 A |  | 0% → 100% | 59d → none |  | resources TRAVEL; PLABOR; PROCUREMENT<$50K 60; MECH ENG [80 h]; MECH DES [160 h] → MECH ENG [80 h]; MECH DES [160 h]; TRAVEL; PLABOR; PROCUREMENT<$50K 60 |
| 12236045 | PROC Continue Reference Dsgn & Drawings (SHLD HOUSE) | 2008-04-01 → 2008-10-20 A (+202d) | 2009-03-19 → 2009-06-24 A (+97d) | 240d → 167d | 0% → 100% | 0d → none | 122363020 → 122363020 FS-103d |  |
| 12236045a | FY08 LAB/EXP Continue Reference Dsgn & Drawings (SHLD HOUSE) | 2008-04-01 → 2008-10-20 A (+202d) | 2008-09-30 → 2009-04-30 A (+212d) | 128d → 129d | 0% → 100% | 0d → none |  | was named FY08 Exp Continue Reference Dsgn & Drawings (SHLD HOUSE); resources MECH ENG [42.67 h]; TRAVEL; MECH DES [42.67 h] → MECH DES [42.67 h]; MECH ENG [42.67 h]; TRAVEL |
| 12236045b | FY09 LAB/EXP Continue Reference Dsgn & Drawings (SHLD HOUSE) | 2008-10-01 → 2008-10-20 A (+19d) | 2009-03-19 → 2009-04-30 A (+42d) | 112d → 129d | 0% → 100% | 0d → none | 12236045a → 12236045a FS-15d | was named FY09 Exp Continue Reference Dsgn & Drawings (SHLD HOUSE) |
| 12236030b | FY09 LAB/EXP Continue Reference Dsgn & Drawings (SUP STRUCT) | 2008-10-01 → 2008-10-31 A (+30d) | 2009-03-05 → 2008-11-21 A (-104d) | 102d → 16d | 0% → 100% | 1d → none |  | was named FY09 Exp Continue Reference Dsgn & Drawings (SUP STRUCT) |
| 12236010b | P-2 Dsgn Vac Sys (ENG&DES)+ | 2008-10-01 → 2008-12-01 A (+61d) | 2008-10-14 → 2009-07-30 A (+289d) | 10d → 163d | 0% → 100% | 138d → none | 122361010, 9-090M → 122361010, 9-090M FS-100d |  |
| 12236015b | P-2 Dsgn Cryogenic Sys (ENG&DES)+ | 2008-10-01 → 2008-12-01 A (+61d) | 2008-10-14 → 2009-09-29 A (+350d) | 10d → 206d | 0% → 100% | 238d → none | 9-090M, 122361015 → 9-090M FS-100d, 122361015 | resources SUPPLIES & MATERIALS; MECH ENG [8 h]; MECH DES [12 h] → MECH DES [12 h]; SUPPLIES & MATERIALS; MECH ENG [8 h] |
| 12236035 | Prep Bid Packages (SUP STRUCT) | 2009-03-06 → 2009-06-15 A (+101d) | 2009-06-26 → 2009-09-22 A (+88d) | 80d → 70d | 0% → 100% | 1d → none |  | resources SUPPLIES & MATERIALS; MECH ENG [80 h]; MECH DES [160 h] → MECH DES [160 h]; SUPPLIES & MATERIALS; MECH ENG [80 h] |
| 12236050 | Prep Bid Packages (SHLD HOUSE) | 2009-03-20 → 2009-07-01 A (+103d) | 2009-07-13 → 2009-09-22 A (+71d) | 80d → 58d | 0% → 100% | 0d → none | 12236045b, 12236045 → 12236045 FS-200d, 12236045b FS-200d |  |
| 12236035M | Start Bid Process (SUP STRUCT) | 2009-06-29 → 2009-11-02 A (+126d) | 2009-06-29 → 2009-11-02 A (+126d) |  | 0% → 100% | 1d → none | 12236035 → 12236035 FS+40d |  |
| 12236055M | Start Bid Process (SHLD HOUSE) | 2009-07-14 → 2009-11-02 A (+111d) | 2009-07-14 → 2009-11-02 A (+111d) |  | 0% → 100% | 0d → none | 12236050 → 12236050 FS+40d |  |
| 12236040 | Determine Best Offer (SUP STRUCT)+ | 2009-06-29 → 2009-12-14 A (+168d) | 2009-09-29 → 2009-12-21 A (+83d) | 65d → 5d | 0% → 100% | 1d → none |  | resources MECH DES [40 h]; TRAVEL; MECH ENG [40 h] → MECH ENG [40 h]; MECH DES [40 h]; TRAVEL |
| 12236060 | Determine Best Offer (SHLD HOUSE)+ | 2009-07-14 → 2009-12-14 A (+153d) | 2009-09-30 → 2009-12-21 A (+82d) | 56d → 5d | 0% → 100% | 0d → none |  | resources MECH DES [40 h]; TRAVEL; MECH ENG [40 h] → MECH ENG [40 h]; MECH DES [40 h]; TRAVEL |
| 122363025 | Re-Baseline Actuals Adjustment | 2013-08-30 A | 2013-08-30 A |  | 0% → 100% | 20d → none | 9-130M FS+227d → none |  |
| 1 | **1.2.3.1 SOLENOID** | 2008-10-01 → 2008-12-02 (+62d) |  |  |  |  |  |  |
| 151009E5 | FY09 Travel (SOLENOID) | 2008-10-01 → 2008-12-02 A (+62d) | 2008-12-24 → 2008-12-22 A (-2d) | 59d → 15d | 0% → 100% | 431d → none |  |  |
| 1231000 | Re-Baseline Actuals Adjustment | 2013-08-30 A | 2013-08-30 A |  | 0% → 100% | 20d → none | 9-130M FS+227d → none |  |
| 123211010 | Fall Progress updates including safety assessment at Hall D collaboration meeting | 2006-11-15 → 2006-10-16 A (-30d) | 2006-11-30 → 2006-10-31 A (-30d) | 10d → 12d | 0% → 100% | 568d → none |  |  |
| 123211010M | Fall Design updates based on collaboration assessment | 2006-12-15 → 2006-10-31 A (-45d) | 2006-12-15 → 2006-10-31 A (-45d) |  | 0% → 100% | 568d → none |  |  |
| 123211020 | Spring Progress updates including safety assessment at Hall D collaboration meeting | 2007-04-30 → 2007-03-02 A (-59d) | 2007-05-11 → 2007-03-13 A (-59d) | 10d → 8d | 0% → 100% | 568d → none |  |  |
| 123211020M | Spring Safety Design Report updates based on collaboration assessment | 2007-05-15 → 2007-03-13 A (-63d) | 2007-05-15 → 2007-03-13 A (-63d) |  | 0% → 100% | 568d → none |  |  |
| 123211015 | Interim Design and Safety Assessment of drift chambers | 2007-03-15 → 2007-03-01 A (-14d) | 2007-03-28 → 2007-03-13 A (-15d) | 10d → 9d | 0% → 100% | 454d → none |  |  |
| 123211015M | Interim Drift chamber design requirements updated | 2007-04-16 → 2007-04-27 A (+11d) | 2007-04-16 → 2007-04-27 A (+11d) |  | 0% → 100% | 454d → none |  |  |
| 12321017 | Final Dsgn & Safty Assessmnt of Drift Chambs | 2008-09-16 → 2009-01-05 A (+111d) | 2008-09-29 → 2009-03-16 A (+168d) | 10d → 49d | 0% → 100% | 236d → none | 123211020M, 123213010, 123212035, 123211055 → 123213010, 123211020M, 123212035 FS-40d, 123211055 FS-40d |  |
| 12321018M | Drift Chamb Dsgn Rquirmnts Finalized++ | 2008-10-16 → 2009-03-16 A (+151d) | 2008-10-16 → 2009-03-16 A (+151d) |  | 0% → 100% | 236d → none | 12321017 FS+13d → 12321017 |  |
| 1 | **1.2.3.2.1.1 FORWARD CHAMBERS** | 2006-10-02 → 2006-11-01 (+30d) |  |  |  |  |  |  |
| 123211005 | Develop FDC design (FWD CHAMB) | 2006-10-02 → 2006-11-01 A (+30d) | 2007-02-01 A | 79d → 57d | 0% → 100% | 339d → none |  | resources MECH TECH [252.2 h]; CONTRB UNIV LBR [461.2 h] → CONTRB UNIV LBR [461.2 h]; MECH TECH [252.2 h] |
| 12321105A | Develop FDC design (FWD CHAMB) | 2007-02-02 → 2007-02-01 A (-1d) | 2007-09-28 A | 167d → 168d | 0% → 100% | 338d → none |  |  |
| 123211025 | Specify All FDC Chamb Matrl's | 2007-10-01 → 2007-11-01 A (+31d) | 2007-12-04 → 2008-03-14 A (+101d) | 45d → 86d | 0% → 100% | 338d → none |  |  |
| 123211035 | Comp FDC Layout & Dsgn of on-board Electrnc's | 2007-10-01 → 2007-11-01 A (+31d) | 2007-12-04 → 2008-07-15 A (+224d) | 45d → 171d | 0% → 100% | 338d → none |  |  |
| 123211045 | Finalize FDC Cable Spec's, Connectors, Routing, & Packing Decisions | 2007-10-01 → 2007-11-01 A (+31d) | 2007-12-04 → 2008-07-14 A (+223d) | 45d → 170d | 0% → 100% | 338d → none |  |  |
| 123211030 | Detail FDC Final Procedure for Chamb Wire Stringing, Constrctn, & Assy | 2007-10-01 → 2007-12-03 A (+63d) | 2007-12-04 → 2008-09-12 A (+283d) | 45d → 193d | 0% → 100% | 338d → none |  |  |
| 123211050 | Comp Final FDC Drawings | 2007-12-05 → 2008-01-07 A (+33d) | 2008-02-15 → 2008-09-30 A (+228d) | 45d → 187d | 0% → 100% | 338d → none |  |  |
| 123211040 | Dsgn FDC Gas Handling Sys | 2007-10-01 → 2008-02-29 A (+151d) | 2007-12-04 → 2008-12-03 A (+365d) | 45d → 194d | 0% → 100% | 338d → none |  |  |
| 123211055 | Detail FDC Final Procedures for Component Quality Control & Acceptance | 2008-02-19 → 2008-07-28 A (+160d) | 2008-04-21 → 2009-05-25 A (+399d) | 45d → 204d | 0% → 100% | 338d → none |  |  |

| ID | Task | Start | Finish | Duration | Complete | Total float | Predecessors | Other |
| --- | --- | --- | --- | --- | --- | --- | --- | --- |
| 15211009EX | FY09 Travel (FWD Chambers) | 2008-10-01 → 2008-12-01 A (+61d) | 2008-12-24 → 2008-12-22 A (-2d) | 59d → 16d | 0% → 100% | 64d → none |  |  |
| 123211060 | Re-Baseline Actuals Adjustment | 2013-08-30 A | 2013-08-30 A |  | 0% → 100% | 20d → none | 9-130M FS+227d → none |  |
| 2 | **1.2.3.2.1.2 CENTRAL CHAMBERS** | 2006-10-02 → 2007-09-04 (+337d) |  |  |  |  |  |  |
| 123212005 | Develop Preamp design (CENT CHAMB) | 2006-10-02 → 2007-09-04 A (+337d) | 2007-02-01 → 2007-09-28 A (+239d) | 80d → 19d | 0% → 100% | 245d → none |  |  |
| 123212005A | Develop Preamp design (CENT CHAMB) | 2007-02-02 → 2007-10-01 A (+241d) | 2007-12-21 → 2008-08-29 A (+252d) | 225d → 227d | 0% → 100% | 245d → none |  |  |
| 123212010 | Specify CDC Chamb Matrl's | 2008-01-02 → 2008-01-14 A (+12d) | 2008-04-24 → 2008-10-22 A (+181d) | 80d → 198d | 0% → 100% | 245d → none |  |  |
| 123212025 | Finalize CDC Cable Spec's, Connectors, Routing & Packing | 2008-01-02 → 2008-01-14 A (+12d) | 2008-04-24 → 2008-08-25 A (+123d) | 80d → 157d | 0% → 100% | 245d → none |  |  |
| 123212030 | Comp CDC Final Drawings | 2008-05-08 → 2008-01-14 A (-115d) | 2008-08-29 → 2009-06-23 A (+298d) | 80d → 361d | 0% → 100% | 236d → none | 123212008, 123212015, 123212020, 1152035 FS-100d, 1152030 FS-100d, 123212010, 123212025 → 1152035 FS-200d, 123212015 FS-100d, 123212020, 123212008 FS-100d, 123212010, 1152030 FS-200d, 123212025 |  |
| 123212020 | Dsgn CDC Gas Handling Sys | 2008-01-02 → 2008-04-30 A (+119d) | 2008-04-24 → 2008-12-22 A (+242d) | 80d → 164d | 0% → 100% | 245d → none |  |  |
| 123212008 | Preamp Dsgn | 2008-01-02 → 2008-06-09 A (+159d) | 2008-04-24 → 2009-10-19 A (+543d) | 80d → 341d | 0% → 100% | 245d → none |  |  |
| 123212015 | Detail CDC Final Procedure for Chamb Tube Mounting,/Wire Stringing,/Constrctn/Assy | 2008-01-02 → 2008-07-28 A (+208d) | 2008-04-24 → 2009-06-22 A (+424d) | 80d → 224d | 0% → 100% | 245d → none |  |  |
| 123212035 | Detail CDC Final Procedures for Component Quality Control & Acceptance | 2008-07-21 → 2008-07-28 A (+7d) | 2008-09-15 → 2009-06-24 A (+282d) | 40d → 226d | 0% → 100% | 236d → none | 123212030 FS-30d → 123212030 |  |
| 15212009EX | FY09 Travel (CENT CHAMB) | 2008-10-01 → 2008-12-01 A (+61d) | 2008-12-24 → 2008-12-22 A (-2d) | 59d → 16d | 0% → 100% | 119d → none |  |  |
| 123212040 | Re-Baseline Actuals Adjustment | 2013-08-30 A | 2013-08-30 A |  | 0% → 100% | 20d → none | 9-130M FS+227d → none |  |
| 123213005LOE | Start counter design (START CNTR) | 2006-10-02 A | 2007-09-28 A |  | 0% → 100% | 373d → none |  |  |
| 123213010 | Evaluate H-B Start Counter Use in H-D 08 | 2007-10-01 → 2007-11-01 A (+31d) | 2008-03-03 → 2008-09-04 A (+185d) | 100d → 207d | 0% → 100% | 373d → none |  |  |
| 123213015 | Re-Baseline Actuals Adjustment | 2013-08-30 A | 2013-08-30 A |  | 0% → 100% | 20d → none | 9-130M FS+227d → none |  |
| 12322017 | Final Dsgn & Safty Assessmnt of Calorimeters | 2008-08-01 → 2008-09-24 A (+54d) | 2008-08-14 → 2008-10-31 A (+78d) | 10d → 28d | 0% → 100% | 267d → none | 123221804bLOE, 123223010, 123223015, 123222025, 123221025, 123223020, 123222020 FS+20d, 123222030 → 123222020, 123221804bLOE, 123223010, 123222025, 123223020, 123221025, 123223015, 123222030 |  |
| 12322018M | Calorimeter Dsgn Rquirmnts Finalized++ | 2008-09-03 → 2008-10-31 A (+58d) | 2008-09-03 → 2008-10-31 A (+58d) |  | 0% → 100% | 267d → none | 12322017 FS+13d → 12322017 |  |
| 123221007LOE | FY07 Hall D project administration (BCAL) | 2006-10-02 A | 2007-02-01 A |  | 0% → 100% | 59d → none |  |  |
| 123221002 | Develop BCAL design (BCAL) | 2006-10-02 → 2006-11-01 A (+30d) | 2007-02-01 A | 80d → 58d | 0% → 100% | 47d → none |  |  |
| 123221000 | Assessment of SiPM progress toward use with BCAL | 2007-01-02 → 2006-12-01 A (-32d) | 2007-01-30 → 2007-04-27 A (+87d) | 20d → 98d | 0% → 100% | 494d → none |  |  |
| 123221007ALOE | FY07 Hall D project administration (BCAL) | 2007-02-02 → 2007-02-01 A (-1d) | 2007-09-28 A | 167d → 168d | 0% → 100% | 58d → none |  |  |
| 123221002A | Develop BCAL design (BCAL) | 2007-02-02 A | 2007-09-28 A |  | 0% → 100% | 47d → none |  |  |
| 123221004 | FY07 BCAL postdoc for design (BCAL) | 2007-04-16 A | 2007-09-28 → 2008-04-30 A (+215d) | 117d → 259d | 0% → 100% | 463d → none |  |  |
| 123221000M | Decision on readout for BCAL | 2007-03-01 → 2007-05-31 A (+91d) | 2007-03-01 → 2007-05-31 A (+91d) |  | 0% → 100% | 494d → none |  |  |
| 123221004LOE | FY07 BCAL postdoc for design (BCAL) | 2006-10-02 → 2007-09-04 A (+337d) | 2006-10-02 → 2007-09-04 A (+337d) |  | 0% → 100% | 709d → none |  |  |
| 123221908LOE | FY08 H-D Proj Admin (BCAL) | 2007-02-01 → 2007-10-01 A (+242d) | 2008-02-04 → 2008-03-04 A (+29d) | 248d → 101d | 0% → 100% | 126d → none | 123221007LOE → 123221007LOE, 123221007ALOE |  |
| 123221804bLOE | FY08 BCAL postdoc for Dsgn (BCAL) | 2007-10-02 A | 2007-10-15 A |  | 0% → 100% | 462d → none |  |  |
| 123221020 | Drawings of Supprt in Solenoid (BCAL) | 2007-10-01 → 2007-11-01 A (+31d) | 2008-03-17 → 2009-06-22 A (+462d) | 110d → 403d | 0% → 100% | 47d → none |  | resources CONTRB UNIV LBR [1196 h]; PD UNIV STAFF [440 h] → PD UNIV STAFF [440 h]; CONTRB UNIV LBR [1196 h] |
| 123221025 | Assy Drawings (BCAL) | 2008-03-25 → 2008-01-14 A (-71d) | 2008-07-31 → 2009-04-20 A (+263d) | 91d → 316d | 0% → 100% | 42d → none | 1152040, 123221020 → 123221020 FS-60d, 1152040 FS-40d | resources CONTRB UNIV LBR [1240 h]; PD UNIV STAFF [364 h]; PROCUREMENT<$50K 60; MECH ENG [648 h] → MECH ENG [648 h]; PROCUREMENT<$50K 60; CONTRB UNIV LBR [1240 h]; PD UNIV STAFF [364 h] |
| 15221009EX | FY09 Travel (BarCal) | 2008-10-01 → 2008-12-01 A (+61d) | 2008-12-24 → 2008-12-22 A (-2d) | 59d → 16d | 0% → 100% | 496d → none | 9-090M → 123221908LOE, 9-090M |  |
| 123221030 | Re-Baseline Actuals Adjustment | 2013-08-30 A | 2013-08-30 A |  | 0% → 100% | 20d → none | 9-130M FS+227d → none |  |
| 2 | **1.2.3.2.2.2 FORWARD CALORIMETER** | 2006-10-02 → 2007-03-01 (+150d) |  |  |  |  |  |  |
| 123222005 | Develop FCAL modifications for use in Hall D (FCAL) | 2006-10-02 → 2007-03-01 A (+150d) | 2007-09-28 → 2007-05-31 A (-120d) | 247d → 65d | 0% → 100% | 283d → none |  |  |
| 123222010 | Drawings of Glass Supprt to circular geometry (FCAL) | 2007-10-01 → 2007-11-01 A (+31d) | 2008-01-03 → 2009-08-24 A (+599d) | 60d → 447d | 0% → 100% | 353d → none |  |  |
| 123222015 | Drawings of Cellular Wall (FCAL) | 2007-10-01 → 2007-11-01 A (+31d) | 2008-04-14 → 2009-08-24 A (+497d) | 130d → 447d | 0% → 100% | 283d → none |  |  |
| 123222025 | Drawings for attaching PMTs to Glass (FCAL) | 2007-10-01 → 2008-02-29 A (+151d) | 2008-01-25 → 2009-08-24 A (+577d) | 75d → 372d | 0% → 100% | 398d → none |  |  |
| 123222030 | Drawings for Light Guides (FCAL) | 2007-10-01 → 2008-02-29 A (+151d) | 2008-01-25 → 2009-08-24 A (+577d) | 75d → 372d | 0% → 100% | 398d → none |  |  |
| 123222020 | Assy Plans for stacking Glass (FCAL) | 2008-04-15 → 2008-09-25 A (+163d) | 2008-06-10 → 2009-08-24 A (+440d) | 40d → 226d | 0% → 100% | 283d → none | 123222010, 123222015, 123222005 → 123222010 FS-125d, 123222005 FS-125d, 123222015 FS-125d | resources CONTRB UNIV LBR [359.88 h]; PD UNIV STUDNT [856.12 h] → PD UNIV STUDNT [856.12 h]; CONTRB UNIV LBR [359.88 h] |
| 15222009EX | FY09 Travel (FWD CAL) | 2008-10-01 → 2008-12-01 A (+61d) | 2008-12-24 → 2008-12-22 A (-2d) | 59d → 16d | 0% → 100% | 317d → none |  |  |
| 123222035 | Re-Baseline Actuals Adjustment | 2013-08-30 A | 2013-08-30 A |  | 0% → 100% | 20d → none | 9-130M FS+227d → none |  |
| 3 | **1.2.3.2.2.3 UPSTREAM PHOTON VETO** |  | 2008-07-09 → 2008-03-21 (-110d) |  |  |  |  |  |
| 123223005LOE | Develop Upstream Photon Veto Design (CAL TOF) | 2006-10-02 A | 2007-02-01 A |  | 0% → 100% | 283d → none |  |  |
| 123223005ALOE | Develop Upstream Photon Veto Design (CAL TOF) | 2007-02-02 A | 2007-09-28 → 2007-05-31 A (-120d) | 167d → 83d | 0% → 100% | 283d → none |  |  |
| 123223010 | Drawings for UPV Frame (CAL TOF) | 2007-10-01 → 2008-03-03 A (+154d) | 2008-01-03 → 2008-03-07 A (+64d) | 60d → 5d | 0% → 100% | 353d → none |  |  |
| 123223015 | Drawings for individual Compnts (CAL TOF) | 2007-10-01 → 2008-03-10 A (+161d) | 2008-04-14 → 2008-03-14 A (-31d) | 130d → 5d | 0% → 100% | 283d → none |  |  |
| 123223020 | Dsgn Supprt Frame & method for maintenance (CAL TOF) | 2008-04-15 → 2008-03-17 A (-29d) | 2008-07-09 → 2008-03-21 A (-110d) | 60d → 5d | 0% → 100% | 283d → none |  |  |
| 12323039 | Final Dsgn & Safty Assessmnt of Particle ID | 2009-06-04 → 2009-01-05 A (-150d) | 2009-06-17 → 2009-04-20 A (-58d) | 10d → 74d | 0% → 100% | 73d → none | 123232010, 123231030, 123232035, 123232015, 123232025, 123232030, 123232020 → 123232035, 123232010, 123232015, 123232020, 123231030 FS-250d, 123232025, 123232030 |  |
| 12323040M | Particle ID Dsgn Rquirmnts Finalized++ | 2009-06-17 → 2009-04-20 A (-58d) | 2009-06-17 → 2009-04-20 A (-58d) |  | 0% → 100% | 73d → none |  |  |
| 1 | **1.2.3.2.3.1 TIME OF FLIGHT** |  | 2008-09-16 → 2009-07-27 (+314d) |  |  |  |  |  |
| 123231005LOE | Develop TOF integration (PART ID TOF) | 2006-10-02 A | 2007-02-01 A |  | 0% → 100% | 248d → none |  |  |
| 123231005ALOE | Develop TOF integration (PART ID TOF) | 2007-02-02 A | 2007-09-28 → 2007-05-31 A (-120d) | 167d → 83d | 0% → 100% | 248d → none |  |  |
| 123231010 | Drawings of Scintillator Counters (PART ID TOF) | 2007-10-01 → 2008-03-31 A (+182d) | 2007-12-04 → 2009-06-22 A (+566d) | 45d → 307d | 0% → 100% | 248d → none | 123231005ALOE → 123231005ALOE FS+260d |  |
| 123231015 | Drawings of PMT Housing Assy (PART ID TOF) | 2007-12-05 → 2008-03-31 A (+117d) | 2008-02-15 → 2009-06-24 A (+495d) | 45d → 309d | 0% → 100% | 248d → none |  |  |
| 123231020 | Dsgn Voltage Divider for PMT (PART ID TOF) | 2008-02-19 → 2008-03-31 A (+41d) | 2008-04-21 → 2009-07-27 A (+462d) | 45d → 331d | 0% → 100% | 248d → none |  |  |
| 123231025 | Dsgn Signal Splitting Between ADC & Discriminator/TDC (PART ID TOF) | 2008-04-22 → 2008-03-31 A (-22d) | 2008-06-23 → 2009-07-27 A (+399d) | 44d → 330d | 0% → 100% | 248d → none |  |  |
| 123231030 | Dsgn Mounting Frame for Counters (PART ID TOF) | 2008-06-24 → 2008-03-31 A (-85d) | 2008-09-16 → 2009-06-29 A (+286d) | 59d → 312d | 0% → 100% | 248d → none |  |  |
| 2 | **1.2.3.2.3.2 CERENKOV COUNTER** | 2006-10-02 → 2007-03-01 (+150d) |  |  |  |  |  |  |
| 123232005A | Develop CER design (CERENKOV CNTR) | 2007-02-02 → 2007-03-01 A (+27d) | 2007-09-28 A | 167d → 149d | 0% → 100% | 261d → none |  | resources SCIENTIST [332 h]; PD UNIV STUDNT [416 h]; VISTNG USERS [600 h] → SCIENTIST [332 h]; VISTNG USERS [600 h]; PD UNIV STUDNT [416 h] |
| 123232005 | Develop CER design (CERENKOV CNTR) | 2006-10-02 → 2008-01-03 A (+458d) | 2007-02-01 → 2008-01-03 A (+336d) | 80d → 1d | 0% → 100% | 261d → none |  |  |
| 123232010 | Comp Spec's for Mirrors (CERENKOV CNTR) | 2009-04-01 → 2008-01-03 A (-454d) | 2009-06-03 → 2008-01-03 A (-517d) | 45d → 1d | 0% → 100% | 73d → none |  |  |
| 123232015 | Comp Drawings for Mirrors & Fab (CERENKOV CNTR) | 2009-01-05 → 2008-01-03 A (-368d) | 2009-04-07 → 2008-01-03 A (-460d) | 65d → 1d | 0% → 100% | 113d → none |  |  |
| 123232020 | Drawings for PMT Assy (CERENKOV CNTR) | 2009-04-01 → 2008-01-03 A (-454d) | 2009-06-03 → 2008-01-03 A (-517d) | 45d → 1d | 0% → 100% | 73d → none |  |  |
| 123232025 | Develop Matrl Spec's for Gas Windows (CERENKOV CNTR) | 2009-01-05 → 2008-01-03 A (-368d) | 2009-02-02 → 2008-01-03 A (-396d) | 20d → 1d | 0% → 100% | 158d → none |  |  |
| 123232030 | Dsgn Supprt Frame for Cerenkov Detector (CERENKOV CNTR) | 2009-01-05 → 2008-01-03 A (-368d) | 2009-04-07 → 2008-01-03 A (-460d) | 65d → 1d | 0% → 100% | 113d → none |  |  |
| 123232035 | Dsgn Alignment Procedure for Mirrors (CERENKOV CNTR) | 2009-01-05 → 2008-01-03 A (-368d) | 2009-04-07 → 2008-01-03 A (-460d) | 65d → 1d | 0% → 100% | 113d → none |  |  |
| 123232040 | Re-Baseline Actuals Adjustment | 2013-08-30 A | 2013-08-30 A |  | 0% → 100% | 20d → none | 9-130M FS+227d → none |  |
| 1233039 | Final Dsgn & Safty Assessmnt of Computing | 2009-03-20 → 2009-01-05 A (-74d) | 2009-04-02 → 2009-06-26 A (+85d) | 10d → 122d | 0% → 100% | 126d → none | 12333020, 12332015, 12331010, 12333015a, 12332025a → 12331010, 12332025a FS-250d, 12333020, 12333015a FS-250d, 12332015 FS-250d |  |
| 1233040M | Computing Dsgn Rquirmnts Finalized+ | 2009-04-02 → 2009-06-26 A (+85d) | 2009-04-02 → 2009-06-26 A (+85d) |  | 0% → 100% | 126d → none |  | was named Computing Dsgn Rquirmnts Finalized++ |

| ID | Task | Start | Finish | Duration | Complete | Total float | Predecessors | Other |
| --- | --- | --- | --- | --- | --- | --- | --- | --- |
| 1 | **1.2.3.3.1 DAQ** | 2006-10-02 → 2007-01-16 (+106d) |  |  |  |  |  |  |
| 12331005 | Procure architechture and high speed links (DAQ) | 2006-10-02 → 2007-01-16 A (+106d) | 2007-09-28 A | 247d → 180d | 0% → 100% | 246d → none |  |  |
| 12331010 | Proto parallel Event builder (DAQ) (IPL) | 2008-03-18 → 2008-01-15 A (-63d) | 2008-09-18 → 2008-10-17 A (+29d) | 130d → 194d | 0% → 100% | 246d → none |  |  |
| 12331015 | Re-Baseline Actuals Adjustment | 2013-08-30 A | 2013-08-30 A |  | 0% → 100% | 20d → none | 9-130M FS+227d → none |  |
| 12332005LOE | Conduct planning for online system (ONLINE COMP) | 2006-10-02 A | 2007-02-01 A |  | 0% → 100% | 186d → none |  |  |
| 12332005ALOE | Conduct planning for online system (ONLINE COMP) | 2007-02-02 A | 2007-09-28 → 2007-05-31 A (-120d) | 167d → 83d | 0% → 100% | 186d → none |  |  |
| 12332020 | Dsgn Experiment Controls Sys (ONLINE COMP) | 2008-01-04 → 2008-02-01 A (+28d) | 2008-09-04 → 2009-03-23 A (+200d) | 170d → 283d | 0% → 100% | 126d → none |  |  |
| 12332010 | Dsgn Monitoring Sys (ONLINE COMP) | 2008-04-01 A | 2008-07-01 → 2009-03-23 A (+265d) | 65d → 242d | 0% → 100% | 251d → none |  |  |
| 12332015 | Dsgn Alarm Sys (ONLINE COMP) | 2008-07-02 → 2008-04-01 A (-92d) | 2008-09-11 → 2009-03-23 A (+193d) | 50d → 242d | 0% → 100% | 251d → none |  | resources SCIENTIST [408 h]; PROCUREMENT<$50K 60 → PROCUREMENT<$50K 60; SCIENTIST [408 h] |
| 12332025 | FY08 Dsgn Event Display (ONLINE COMP) | 2008-09-05 → 2008-11-03 A (+59d) | 2008-09-30 → 2009-05-29 A (+241d) | 18d → 139d | 0% → 100% | 126d → none | 12332020 → 12332020 FS-200d | was named FY08 Exp Dsgn Event Display (ONLINE COMP) |
| 12332025a | FY09 Dsgn Event Display (ONLINE COMP) | 2008-10-01 → 2008-12-02 A (+62d) | 2009-03-19 → 2009-05-29 A (+71d) | 112d → 120d | 0% → 100% | 126d → none | 12332025 → 12332025 FS-200d | was named FY09 Exp Dsgn Event Display (ONLINE COMP); resources CONTRB UNIV LBR [310.15 h]; SCIENTIST [654.77 h] → SCIENTIST [654.77 h]; CONTRB UNIV LBR [310.15 h] |
| 12332030 | Re-Baseline Actuals Adjustment | 2013-08-30 A | 2013-08-30 A |  | 0% → 100% | 20d → none | 9-130M FS+227d → none |  |
| 12333005LOE | Conduct planning for offline computing (OFFLINE COMP) | 2006-10-02 A | 2007-02-01 A |  | 0% → 100% | 155d → none |  |  |
| 12333005ALOE | Conduct planning for offline computing (OFFLINE COMP) | 2007-02-02 A | 2007-09-28 → 2007-05-31 A (-120d) | 167d → 83d | 0% → 100% | 155d → none |  |  |
| 12333010 | Dsgn Reconstruction Framework (OFFLINE COMP) | 2007-10-01 A | 2008-04-14 → 2008-08-29 A (+137d) | 130d → 227d | 0% → 100% | 155d → none |  |  |
| 12333020 | Dsgn Interface Between Analysis Framework & Simulation (OFFLINE COMP) | 2008-07-25 → 2008-01-03 A (-204d) | 2009-02-05 → 2008-05-30 A (-251d) | 130d → 104d | 0% → 100% | 155d → none |  |  |
| 12333015 | FY08 Dsgn Calibration Databases (OFFLINE COMP) | 2008-07-25 → 2008-10-01 A (+68d) | 2008-09-30 → 2009-05-29 A (+241d) | 47d → 162d | 0% → 100% | 155d → none |  | was named FY08 Exp Dsgn Calibration Databases (OFFLINE COMP); resources SCIENTIST [477.23 h]; CONTRB UNIV LBR [361.54 h] → CONTRB UNIV LBR [361.54 h]; SCIENTIST [477.23 h] |
| 12333015a | FY09 Dsgn Calibration Databases (OFFLINE COMP) | 2008-10-01 → 2008-12-02 A (+62d) | 2009-02-05 → 2009-05-29 A (+113d) | 83d → 120d | 0% → 100% | 155d → none | 12333015 → 12333015 FS-250d | was named FY09 Exp Dsgn Calibration Databases (OFFLINE COMP); resources CONTRB UNIV LBR [638.46 h]; SCIENTIST [842.77 h] → SCIENTIST [842.77 h]; CONTRB UNIV LBR [638.46 h] |
| 12333025 | Re-Baseline Actuals Adjustment | 2013-08-30 A | 2013-08-30 A |  | 0% → 100% | 20d → none | 9-130M FS+227d → none |  |
| 12341005 | Conduct FADC development (FADC) | 2006-10-02 A | 2007-02-01 A |  | 0% → 100% | 114d → none |  | resources PROCUREMENT<$50K 60; CONTRB UNIV LBR [541.2 h] → CONTRB UNIV LBR [541.2 h]; PROCUREMENT<$50K 60 |
| 12342010 | Develop clock distribution and synchronization (TDC) | 2007-02-01 → 2006-11-01 A (-92d) | 2007-09-28 → 2007-02-01 A (-239d) | 167d → 57d | 0% → 100% | 114d → none | 12342010A → 9-070M | resources none → ELEC DES [86.4 h] |
| 12343005 | Develop plans for trigger integration (TRGR) | 2006-10-02 → 2006-11-01 A (+30d) | 2007-02-01 A | 79d → 57d | 0% → 100% | 114d → none |  |  |
| 12345005 | Integrate electronics subsystems (HV) | 2006-10-02 → 2006-11-01 A (+30d) | 2007-02-01 A | 79d → 57d | 0% → 100% | 454d → none |  |  |
| 12341005A | Conduct FADC development (FADC) | 2007-02-01 A | 2007-09-28 A | 167d → 168d | 0% → 100% | 114d → none |  | resources ELEC ENG [421.2 h]; PROCUREMENT<$50K 60 → PROCUREMENT<$50K 60; ELEC ENG [421.2 h] |
| 12342010A | Develop clock distribution and synchronization (TDC) (IPL) | 2006-10-02 → 2007-02-01 A (+122d) | 2007-02-01 → 2007-11-30 A (+302d) | 79d → 211d | 0% → 100% | 114d → none | 9-070M → 12342010 | resources ELEC DES [86.4 h] → none |
| 12343005A | Develop plans for trigger integration (TRGR) | 2007-02-01 A | 2007-09-28 → 2007-11-30 A (+63d) | 167d → 211d | 0% → 100% | 114d → none |  |  |
| 12345005A | Integrate electronics subsystems (HV) | 2007-02-01 A | 2007-09-28 → 2007-12-05 A (+68d) | 167d → 214d | 0% → 100% | 454d → none |  |  |
| 12342005 | Develop DAQ trigger and electronics integration (TDC) | 2006-10-02 → 2007-03-02 A (+151d) | 2007-02-01 → 2007-11-30 A (+302d) | 79d → 191d | 0% → 100% | 199d → none |  |  |
| 12342005A | Develop DAQ trigger and electronics integration (TDC) | 2007-02-01 → 2007-12-03 A (+305d) | 2007-09-28 → 2008-08-29 A (+336d) | 167d → 184d | 0% → 100% | 199d → none |  |  |
| 1234085 | Specification of Crates Backplane, Pwr Supply, remote sensing (Electrnc's) | 2008-10-01 → 2008-01-03 A (-272d) | 2008-10-28 → 2008-08-29 A (-60d) | 20d → 168d | 0% → 100% | 205d → none |  |  |
| 1234090 | Dsgn Layout of Crates on Detector & Racks (Electrnc's) | 2008-09-05 → 2008-01-03 A (-246d) | 2008-09-30 → 2008-07-28 A (-64d) | 18d → 144d | 0% → 100% | 155d → none |  |  |
| 1234030 | Dsgn Energy Sum Board (Electrnc's) (IPL) | 2008-10-01 → 2008-01-14 A (-261d) | 2008-11-11 → 2008-12-09 A (+28d) | 30d → 230d | 0% → 100% | 85d → none |  | resources PROCUREMENT<$50K 60; ELEC ENG [1668 h]; ELEC DES [480 h] → ELEC DES [480 h]; PROCUREMENT<$50K 60; ELEC ENG [1668 h] |
| 1234045 | Programing of FADCs for Testing (Electrnc's) | 2009-03-04 → 2008-01-14 A (-415d) | 2009-04-28 → 2008-07-28 A (-274d) | 40d → 137d | 0% → 100% | 85d → none |  |  |
| 1234070 | Dsgn Energy Sum collections into Trigger (Electrnc's) | 2008-06-11 → 2008-01-14 A (-149d) | 2008-07-23 → 2008-09-04 A (+43d) | 30d → 164d | 0% → 100% | 113d → none | 1234065 → 1234065 FS-20d |  |
| 1234075 | Dsgn Track Count Collection into Trigger (Electrnc's) (IPL) | 2008-07-24 → 2008-01-14 A (-192d) | 2008-09-04 A | 30d → 164d | 0% → 100% | 113d → none |  |  |
| 1234080 | PROC Dsgn Master Trigger (Electrnc's) | 2008-09-26 → 2008-01-14 A (-256d) | 2009-04-09 → 2008-09-25 A (-196d) | 130d → 179d | 0% → 100% | 98d → none |  |  |
| 1234080a | FY08 LAB/EXP Dsgn Master Trigger (Electrnc's) | 2008-09-26 → 2008-01-14 A (-256d) | 2008-09-30 → 2008-01-16 A (-258d) |  | 0% → 100% | 98d → none |  | was named FY08 Exp Dsgn Master Trigger (Electrnc's) |
| 1234110 | Specify HV & Low Voltage Supplies (Electrnc's) | 2008-10-01 → 2008-01-14 A (-261d) | 2008-10-14 → 2008-07-28 A (-78d) | 10d → 137d | 0% → 100% | 215d → none |  |  |
| 1234080b | FY09 LAB/EXP Dsgn Master Trigger (Electrnc's) | 2008-10-01 → 2008-01-17 A (-258d) | 2009-04-09 → 2008-09-25 A (-196d) | 127d → 176d | 0% → 100% | 98d → none |  | was named FY09 Exp Dsgn Master Trigger (Electrnc's) |
| 1234095 | Dsgn Grounding Scheme of Crates & Racks (Electrnc's) | 2008-10-01 → 2008-04-01 A (-183d) | 2008-10-28 → 2008-12-22 A (+55d) | 20d → 185d | 0% → 100% | 155d → none |  |  |
| 1234100 | Dsgn networking of Crates (Electrnc's) | 2008-10-29 → 2008-04-01 A (-211d) | 2008-11-25 → 2009-06-22 A (+209d) | 20d → 306d | 0% → 100% | 155d → none |  |  |
| 1234105 | Dsgn Global Signal Distrbtn Interface to FADCs & TDCs (Electrnc's) | 2008-11-26 → 2008-04-01 A (-239d) | 2009-01-16 → 2009-03-23 A (+66d) | 30d → 242d | 0% → 100% | 155d → none |  |  |
| 1234035 | Dsgn Crate Clock Distrbtn for FADCs (Electrnc's) | 2008-11-12 → 2008-09-25 A (-48d) | 2009-01-16 → 2009-01-14 A (-2d) | 40d → 72d | 0% → 100% | 85d → none |  |  |
| 1234040 | Dsgn Cabling & Layout for FADCs (Electrnc's) | 2009-01-20 → 2008-09-25 A (-117d) | 2009-03-03 → 2008-12-22 A (-71d) | 30d → 61d | 0% → 100% | 85d → none |  |  |
| 1234115 | FY08 Specify Discriminators & Logic for DAQ/Trigger Integration (Electrnc's) | 2008-09-26 → 2008-12-01 A (+66d) | 2008-09-30 → 2009-04-27 A (+209d) | 3d → 98d | 0% → 100% | 208d → none |  | was named FY08 Exp Specify Discriminators & Logic for DAQ/Trigger Integration (Electrnc's) |
| 1545009EX | FY09 Travel (LOGIC, HV) | 2008-10-01 → 2008-12-01 A (+61d) | 2008-12-24 → 2008-12-22 A (-2d) | 59d → 16d | 0% → 100% | 310d → none |  |  |
| 1234115a | FY09 Specify Discriminators & Logic for DAQ/Trigger Integration (Electrnc's) | 2008-10-01 → 2008-12-02 A (+62d) | 2008-10-23 → 2009-04-20 A (+179d) | 17d → 92d | 0% → 100% | 208d → none | 1154060, 1234115 → 1154060, 1234115 FS-250d | was named FY09 Exp Specify Discriminators & Logic for DAQ/Trigger Integration (Electrnc's) |
| 1234050 | TDC Version II: Dsgn & Proto (Electrnc's) | 2007-10-01 → 2009-01-05 A (+462d) | 2007-11-27 → 2009-04-20 A (+510d) | 40d → 73d | 0% → 100% | 113d → none | 12342005A FS-85d, 12343005A, 12341005A, 12342010, 1154005A → 12342005A FS-85d, 12343005A, 12342010A, 12341005A, 1154005A |  |
| 1234060 | Dsgn Clock Distrbtn for TDC Sys (Electrnc's) | 2008-02-04 → 2009-01-05 A (+336d) | 2008-04-28 → 2009-04-27 A (+364d) | 60d → 79d | 0% → 100% | 113d → none | 1234055 → 1234055 FS-250d |  |
| 1234065 | Dsgn Cabling & Layout for TDC Sys (Electrnc's) | 2008-04-29 → 2009-01-05 A (+251d) | 2008-06-10 → 2009-03-23 A (+286d) | 30d → 53d | 0% → 100% | 113d → none | 1234060 → 1234060 FS-250d | was named Dsgn Cabling & Layout for TDC Sys (Electrnc's) (IPL) |
| 1234159 | Final Dsgn & Safty Assessmnt of Electrnc's | 2009-04-29 → 2009-01-05 A (-114d) | 2009-05-12 → 2009-03-23 A (-50d) | 10d → 54d | 0% → 100% | 85d → none | 1234075, 1234040, 1234110, 1234080b, 1234045, 1234105, 1234080, 1234085, 1234115a → 1234075, 1234110 FS-250d, 1234105 FS-250d, 1234045, 1234080, 1234040, 1234085, 1234115a FS-250d, 1234080b |  |
| 1234180M | Electrnc's Dsgn Rquirmnts Finalized++ | 2009-06-01 → 2009-03-23 A (-70d) | 2009-06-01 → 2009-03-23 A (-70d) |  | 0% → 100% | 85d → none |  |  |
| 1234055 | TDC Version II: Test, Evaluate (Electrnc's) | 2007-11-28 → 2009-04-01 A (+490d) | 2008-02-01 → 2009-04-20 A (+444d) | 40d → 14d | 0% → 100% | 113d → none |  |  |
| 12345010 | Re-Baseline Actuals Adjustment | 2013-08-30 A | 2013-08-30 A |  | 0% → 100% | 20d → none | 9-130M FS+227d → none |  |
| 12351054 | Final Dsgn & Safty Assessmnt of Tagger | 2009-03-20 → 2008-11-03 A (-137d) | 2009-04-02 → 2008-12-22 A (-101d) | 10d → 34d | 0% → 100% | 113d → none | 123511050, 123512050, 123511045, 123511050b → 123511045, 123512050, 123511050, 123512040, 123512035, 123512045, 123511050b |  |
| 12351055M | Tagger Dsgn Rquirmnts Finalized++ | 2009-04-21 → 2008-12-22 A (-120d) | 2009-04-21 → 2008-12-22 A (-120d) |  | 0% → 100% | 113d → none | 12351054 FS+13d → 12351054 |  |
| 123511005LOE | Develop design and procurement strategies (TAGMAG) | 2006-10-02 A | 2007-02-01 A |  | 0% → 100% | 189d → none |  |  |
| 123511005ALOE | Develop design and procurement strategies (TAGMAG) | 2007-02-02 → 2007-02-01 A (-1d) | 2007-09-28 → 2008-03-31 A (+185d) | 167d → 288d | 0% → 100% | 188d → none |  |  |
| 123511005 | Develop design and procurement strategies (TAGMAG) | 2006-10-02 → 2007-04-02 A (+182d) | 2007-09-28 A | 247d → 127d | 0% → 100% | 188d → none |  |  |
| 123511010 | Top Level Drawings of Quad, Two Dipoles & Vac Sys (TAG MAG) | 2007-04-11 → 2007-11-01 A (+204d) | 2007-06-13 → 2009-02-27 A (+625d) | 45d → 323d | 0% → 100% | 188d → none |  |  |
| 123511020 | Top view of a Dipole Showing bolt locations (TAG MAG) | 2007-08-17 → 2007-11-01 A (+76d) | 2007-10-19 → 2009-02-27 A (+497d) | 45d → 323d | 0% → 100% | 188d → none |  | resources VISTNG USERS [160 h]; PD UNIV STAFF [440 h] → PD UNIV STAFF [440 h]; VISTNG USERS [160 h] |
| 123511025 | Individual Drawings for Poleshoes (TAG MAG) | 2007-10-22 → 2007-11-01 A (+10d) | 2008-01-03 → 2009-02-27 A (+421d) | 45d → 323d | 0% → 100% | 188d → none | 123511020 → 123511020 FS-10d | resources PD UNIV STAFF [440 h]; VISTNG USERS [160 h] → VISTNG USERS [160 h]; PD UNIV STAFF [440 h] |
| 123511030 | Drawings Showing All Different Types of Brackets (TAG MAG) | 2008-01-04 → 2007-11-01 A (-64d) | 2008-03-10 → 2009-02-27 A (+354d) | 45d → 323d | 0% → 100% | 188d → none | 123511025 → 123511025 FS-10d |  |
| 123511035 | Layout of Vac Chamb (TAG MAG) | 2008-03-11 → 2007-11-01 A (-131d) | 2008-05-12 → 2009-02-27 A (+291d) | 45d → 323d | 0% → 100% | 188d → none | 123511030 → 123511030 FS-10d |  |
| 123511015 | Vertical Section through a Dipole Showing how Poleshoes & Yoke (TAG MAG) | 2007-06-14 → 2008-01-16 A (+216d) | 2007-08-16 → 2009-02-27 A (+561d) | 45d → 278d | 0% → 100% | 188d → none |  | resources VISTNG USERS [160 h]; PD UNIV STAFF [440 h] → PD UNIV STAFF [440 h]; VISTNG USERS [160 h] |
| 123511040 | Drawings of Top & Bottom Lids, & Back-Wall of Vac Chamb (TAG MAG) | 2008-05-13 → 2008-04-01 A (-42d) | 2008-07-16 → 2009-07-27 A (+376d) | 45d → 330d | 0% → 100% | 188d → none | 123511035 → 123511035 FS-10d | resources VISTNG USERS [160 h]; PD UNIV STAFF [440 h] → PD UNIV STAFF [440 h]; VISTNG USERS [160 h] |
| 123511045 | Drawings Showing Assy & Dis-assy of Mag (TAG MAG) | 2008-07-17 → 2008-04-01 A (-107d) | 2008-09-18 → 2009-07-27 A (+312d) | 45d → 330d | 0% → 100% | 188d → none | 123511040 → 123511040 FS-125d | resources VISTNG USERS [440 h]; PROCUREMENT<$50K 60 → PROCUREMENT<$50K 60; VISTNG USERS [440 h] |
| 123511050 | PROC Production of Drawings for Strong Back Supprt for Dipole Magnets. (TAG MAG) | 2008-09-19 → 2008-04-01 A (-171d) | 2008-11-20 → 2009-07-27 A (+249d) | 45d → 330d | 0% → 100% | 188d → none | 123511045 → 123511045 FS-125d |  |
| 123511050a | FY08 LAB/EXP Production of Drawings for Strong Back Supprt for Dipole Magnets. (TAG MAG) | 2008-09-19 → 2008-04-01 A (-171d) | 2008-09-30 → 2008-04-10 A (-173d) |  | 0% → 100% | 188d → none | 123511045 → 123511045 FS-125d | was named FY08 Exp Production of Drawings for Strong Back Supprt for Dipole Magnets. (TAG MAG) |
| 123511050b | FY09 LAB/EXP Production of Drawings for Strong Back Supprt for Dipole Magnets. (TAG MAG) | 2008-10-01 → 2008-04-11 A (-173d) | 2008-11-20 → 2009-07-27 A (+249d) | 37d → 322d | 0% → 100% | 188d → none | 123511050a → 123511050a FS-125d | was named FY09 Exp Production of Drawings for Strong Back Supprt for Dipole Magnets. (TAG MAG) |

| ID | Task | Start | Finish | Duration | Complete | Total float | Predecessors | Other |
| --- | --- | --- | --- | --- | --- | --- | --- | --- |
| 123511055 | Re-Baseline Actuals Adjustment | 2013-08-30 A | 2013-08-30 A |  | 0% → 100% | 20d → none | 9-130M FS+227d → none |  |
| 2 | **1.2.3.5.1.2 HODOSCOPE** | 2006-10-02 → 2006-11-01 (+30d) | 2009-03-19 → 2009-02-23 (-24d) |  |  |  |  |  |
| 123512005 | Develop design for the spectrometer hodoscope (HODO) | 2006-10-02 → 2006-11-01 A (+30d) | 2007-02-01 A | 80d → 58d | 0% → 100% | 113d → none |  |  |
| 123512005A | Develop design for the spectrometer hodoscope (HODO) | 2007-02-02 A | 2007-09-28 → 2008-01-31 A (+125d) | 167d → 246d | 0% → 100% | 113d → none |  |  |
| 123512010 | Dsgn Light Guides for Microscope (HODO) | 2007-10-01 → 2008-09-22 A (+357d) | 2007-11-27 → 2009-02-23 A (+454d) | 40d → 101d | 0% → 100% | 113d → none |  |  |
| 123512015 | Dsgn Frame for Microscope (HODO) | 2007-11-28 → 2008-09-22 A (+299d) | 2008-02-01 → 2009-02-23 A (+388d) | 40d → 101d | 0% → 100% | 113d → none | 123512010 → 1155005A FS-60d, 123512005A |  |
| 123512040 | Dsgn Alignment for Microscope (HODO) | 2008-09-19 → 2008-09-24 A (+5d) | 2008-11-13 → 2009-02-23 A (+102d) | 40d → 99d | 0% → 100% | 113d → none | 123512035 → 123512010, 123512015 |  |
| 123512045 | Dsgn Cable Layout for Microscope (HODO) | 2008-11-14 → 2008-09-24 A (-51d) | 2009-01-21 → 2009-02-23 A (+33d) | 40d → 99d | 0% → 100% | 113d → none | 123512040 → 123512015, 123512010 |  |
| 123512020 | Dsgn Frame for Fixed Array (HODO) | 2008-02-04 → 2008-11-03 A (+273d) | 2008-03-31 → 2009-02-23 A (+329d) | 40d → 71d | 0% → 100% | 113d → none | 123512015 → 123512005A, 1155005A FS-60d |  |
| 123512025 | Dsgn Voltage Divider for Fixed Array PMT (HODO) | 2008-04-01 → 2008-11-03 A (+216d) | 2008-05-27 → 2009-02-23 A (+272d) | 40d → 71d | 0% → 100% | 113d → none | 123512020 → 1155005A FS-60d, 123512005A |  |
| 123512030 | Dsgn Light Guides for Fixed Array (HODO) | 2008-05-28 → 2008-11-03 A (+159d) | 2008-07-23 → 2009-02-23 A (+215d) | 40d → 71d | 0% → 100% | 113d → none | 123512025 → 1155005A FS-60d, 123512005A |  |
| 123512035 | Determine Assy Procedure for Fixed Array (HODO) | 2008-07-24 → 2008-11-03 A (+102d) | 2008-09-18 → 2009-02-23 A (+158d) | 40d → 71d | 0% → 100% | 113d → none | 123512030 → 123512020, 123512030, 123512025 |  |
| 123512050 | Dsgn Cable Layout for Fixed Array (HODO) | 2009-01-22 → 2008-11-03 A (-80d) | 2009-03-19 → 2009-02-23 A (-24d) | 40d → 71d | 0% → 100% | 113d → none | 123512045 → 123512010, 123512015 |  |
| 3 | **1.2.3.5.3 BEAMLINE COMPONENTS** | 2006-10-02 → 2006-11-01 (+30d) |  |  |  |  |  |  |
| 12353005 | Develop design for active collimator (BL COMPONENTS) | 2006-10-02 → 2006-11-01 A (+30d) | 2007-02-01 A | 79d → 57d | 0% → 100% | 93d → none |  |  |
| 12353005A | Develop design for active collimator (BL COMPONENTS) | 2007-02-02 → 2007-02-01 A (-1d) | 2008-03-04 → 2008-01-31 A (-33d) | 268d → 247d | 0% → 100% | 92d → none |  |  |
| 12353030 | Dsgn BL Configuration (BL Compnts) | 2008-10-20 → 2008-06-09 A (-133d) | 2009-01-22 → 2008-10-27 A (-87d) | 60d → 99d | 0% → 100% | 92d → none | 12353025a → 1155010A FS-80d, 12353005A FS-120d, 12353025a FS-120d |  |
| 12353010 | Dsgn Active Collimator (BL Compnts) | 2007-09-04 → 2008-07-28 A (+328d) | 2007-11-28 → 2009-01-27 A (+426d) | 60d → 122d | 0% → 100% | 92d → none | 1155010A FS-60d, 12353005A FS-120d → 1155010A FS-80d, 12353005A FS-120d |  |
| 12353015 | Dsgn Photon Monitor (BL Compnts) | 2007-11-29 → 2008-07-28 A (+242d) | 2008-03-04 → 2008-12-22 A (+293d) | 60d → 103d | 0% → 100% | 92d → none | 12353010 → 12353005A FS-120d, 1155010A FS-80d |  |
| 12353020 | Dsgn Feedback Mechanism (BL Compnts) | 2008-03-05 → 2008-07-28 A (+145d) | 2008-08-07 → 2009-06-22 A (+319d) | 110d → 224d | 0% → 100% | 92d → none | 12353015 → 12353010, 12353015 |  |
| 12353025 | FY08 Dsgn Display of Beam Position (BL Compnts) | 2008-05-14 → 2008-10-01 A (+140d) | 2008-09-30 → 2009-01-26 A (+118d) | 97d → 75d | 0% → 100% | 92d → none | 12353020 FS-60d → 1155010A FS-80d, 12353005A FS-120d | was named FY08 Exp Dsgn Display of Beam Position (BL Compnts) |
| 12353035 | Integrate Goniometer into BL (BL Compnts) | 2009-01-23 → 2008-10-01 A (-114d) | 2009-04-17 → 2009-03-23 A (-25d) | 60d → 114d | 0% → 100% | 92d → none |  |  |
| 12353040 | Final Dsgn & Safty Assessmnt of Beam Line Compnts | 2009-04-20 → 2008-11-03 A (-168d) | 2009-05-01 → 2009-01-15 A (-106d) | 10d → 46d | 0% → 100% | 92d → none | 12353035 → 12353035, 12353020 |  |
| 12353045M | Beam Line Components Dsgn Rquirmnts Finalized | 2009-05-20 → 2009-01-15 A (-125d) | 2009-05-20 → 2009-01-15 A (-125d) |  | 0% → 100% | 92d → none |  |  |
| 12353025a | FY09 Dsgn Display of Beam Position (BL Compnts) | 2008-10-01 → 2009-05-29 A (+240d) | 2008-10-17 → 2009-06-22 A (+248d) | 13d → 17d | 0% → 100% | 92d → none |  | was named FY09 Exp Dsgn Display of Beam Position (BL Compnts) |
| 12353050 | Re-Baseline Actuals Adjustment | 2013-08-30 A | 2013-08-30 A |  | 0% → 100% | 20d → none | 9-130M FS+227d → none |  |
| 12361000M | Starting Milestone for FY09 (Assy) | 2008-10-01 A | 2008-10-01 A |  | 0% → 100% | 58d → none |  |  |
| 12361005 | Develop Alignment of DCs (Assy)+ | 2008-10-01 A | 2009-02-17 → 2009-03-16 A (+27d) | 90d → 109d | 0% → 100% | 158d → none |  |  |
| 12361010 | Develop Installtn of Bcal (Assy)+ | 2009-03-04 → 2008-10-01 A (-154d) | 2009-07-09 → 2009-03-16 A (-115d) | 90d → 109d | 0% → 100% | 58d → none | 12361000M FS+100d → 12361000M |  |
| 12361015 | Re-Baseline Actuals Adjustment | 2013-08-30 A | 2013-08-30 A |  | 0% → 100% | 20d → none | 9-130M FS+227d → none |  |
| 1241000M | Begin Design N&S Access Building Additions | 2006-10-02 A | 2006-10-02 A |  | 0% → 100% | 140d → none |  |  |
| 1241005 | Develop N&S Addition Preliminary Design (ACCEL) | 2006-10-02 → 2006-10-10 A (+8d) | 2006-11-10 → 2006-11-21 A (+11d) | 30d → 31d | 0% → 100% | 140d → none |  |  |
| 1241010 | Conduct N&S Addition Prelim Design & Safety Review | 2006-11-13 → 2006-11-22 A (+9d) | 2006-12-12 → 2007-01-16 A (+35d) | 20d → 31d | 0% → 100% | 140d → none |  |  |
| 1241040M | Begin Design N&S Access Building Utilities (ACCEL) | 2006-12-13 → 2006-12-11 A (-2d) | 2006-12-13 → 2006-12-11 A (-2d) |  | 0% → 100% | 140d → none |  |  |
| 1241045 | Develop N&S Utilities 35% Design (ACCEL) | 2006-12-13 → 2006-12-11 A (-2d) | 2007-02-15 → 2007-04-20 A (+64d) | 40d → 87d | 0% → 100% | 140d → none |  | resources OFFICE [120 h]; MECH DES [40 h]; PLANT ENG [240 h] → PLANT ENG [240 h]; OFFICE [120 h]; MECH DES [40 h] |
| 1241160M | Begin Design N&S Linac Power (ACCEL) | 2007-02-16 → 2006-12-11 A (-67d) | 2007-02-16 → 2006-12-11 A (-67d) |  | 0% → 100% | 165d → none |  |  |
| 1241165 | Develop N&S Linac 35% Design (ACCEL) | 2007-02-16 → 2006-12-11 A (-67d) | 2007-03-30 → 2007-03-27 A (-3d) | 30d → 69d | 0% → 100% | 165d → none |  |  |
| 1241080M | Begin Design Beam Switch Yard Addition (ACCEL) | 2006-11-13 → 2007-02-20 A (+99d) | 2006-11-13 → 2007-02-20 A (+99d) |  | 0% → 100% | 155d → none |  |  |
| 1241085 | Develop BSY Addition 35% Design (ACCEL) | 2006-11-13 → 2007-02-20 A (+99d) | 2007-03-16 → 2007-04-06 A (+21d) | 80d → 34d | 0% → 100% | 155d → none |  |  |
| 1241170 | Conduct N&S Linac 35% Design & Safety Review | 2007-04-02 → 2007-04-03 A (+1d) | 2007-04-13 → 2007-05-18 A (+35d) | 10d → 34d | 0% → 100% | 165d → none |  |  |
| 1241090 | Conduct BSY Addition 35% Design & Safety Review | 2007-03-19 → 2007-04-11 A (+23d) | 2007-04-13 → 2007-05-11 A (+28d) | 20d → 23d | 0% → 100% | 155d → none |  |  |
| 1241120M | Begin Design Tunnel A/C (ACCEL) | 2007-02-16 → 2007-04-16 A (+59d) | 2007-02-16 → 2007-04-16 A (+59d) |  | 0% → 100% | 140d → none |  |  |
| 1241125 | Develop Tunnel A/C 35% Design (ACCEL) | 2007-02-16 → 2007-04-16 A (+59d) | 2007-04-20 → 2007-05-25 A (+35d) | 45d → 30d | 0% → 100% | 140d → none |  | resources PLANT ENG [160 h]; MECH DES [40 h] → MECH DES [40 h]; PLANT ENG [160 h] |
| 1241050 | Conduct N&S Utilities 35% Design & Safety Review | 2007-02-16 → 2007-04-24 A (+67d) | 2007-04-13 → 2007-05-04 A (+21d) | 40d → 9d | 0% → 100% | 155d → none |  |  |
| 1241130 | Conduct Tunnel A/C 35% Design & Safety Review | 2007-04-23 → 2007-05-29 A (+36d) | 2007-05-18 → 2007-06-06 A (+19d) | 20d → 7d | 0% → 100% | 140d → none |  |  |
| 1241015 | Conduct N&S Addition Cost Validation (ACCEL) | 2006-12-13 → 2007-06-20 A (+189d) | 2007-01-03 → 2007-08-02 A (+211d) | 10d → 31d | 0% → 100% | 245d → none |  |  |
| 1241055 | Conduct N&S Utilities Cost Validation (ACCEL) | 2007-04-16 → 2007-06-20 A (+65d) | 2007-05-11 → 2007-08-02 A (+83d) | 20d → 31d | 0% → 100% | 155d → none |  |  |
| 1241095 | Conduct BSY Addition Cost Validation (ACCEL) | 2007-04-16 → 2007-06-20 A (+65d) | 2007-05-11 → 2007-08-02 A (+83d) | 20d → 31d | 0% → 100% | 155d → none |  |  |
| 1241135 | Conduct Tunnel A/C Cost Validation (ACCEL) | 2007-05-21 → 2007-06-20 A (+30d) | 2007-06-04 → 2007-08-02 A (+59d) | 10d → 31d | 0% → 100% | 140d → none |  |  |
| 1241175 | Conduct N&S Linac Cost Validation (ACCEL) | 2007-04-16 → 2007-06-20 A (+65d) | 2007-04-27 → 2007-08-02 A (+97d) | 10d → 31d | 0% → 100% | 165d → none |  |  |
| 1241020 | Develop N&S Addition 100% Dsgn (ACCEL) | 2007-10-01 → 2007-08-01 A (-61d) | 2008-01-03 → 2007-12-06 A (-28d) | 60d → 89d | 0% → 100% | 26d → none |  | was named Develop N&S ADDITION 100% Dsgn (ACCEL); resources MECH ENG [80 h]; MECH DES [40 h]; OFFICE [120 h]; PLABOR; PLANT ENG [280 h]; ELEC ENG [80 h] → PLABOR; PLANT ENG [280 h]; ELEC ENG [80 h]; MECH ENG [80 h]; MECH DES [40 h]; OFFICE [120 h] |
| 1241016M | N&S Access Building Preliminary Design Complete | 2007-01-03 → 2007-08-02 A (+211d) | 2007-01-03 → 2007-08-02 A (+211d) |  | 0% → 100% | 245d → none |  |  |
| 1241056M | N&S Utilities Building Preliminary Design Complete | 2007-05-11 → 2007-08-02 A (+83d) | 2007-05-11 → 2007-08-02 A (+83d) |  | 0% → 100% | 155d → none |  |  |
| 1241096M | BSY Addition Preliminary Design Complete (ACCEL) | 2007-05-11 → 2007-08-02 A (+83d) | 2007-05-11 → 2007-08-02 A (+83d) |  | 0% → 100% | 155d → none |  |  |
| 1241136M | Tunnel A/C Preliminary Design Complete (ACCEL) | 2007-06-04 → 2007-08-02 A (+59d) | 2007-06-04 → 2007-08-02 A (+59d) |  | 0% → 100% | 140d → none |  |  |
| 1241176M | N&S Linac Preliminary Design Complete | 2007-04-27 → 2007-08-02 A (+97d) | 2007-04-27 → 2007-08-02 A (+97d) |  | 0% → 100% | 165d → none |  |  |
| 1241100 | Develop BSY Addition 100% Dsgn (ACCEL) | 2008-02-04 → 2007-08-08 A (-180d) | 2008-04-28 → 2008-01-17 A (-102d) | 60d → 107d | 0% → 100% | 26d → none |  | was named Develop BSY ADDITION 100% Dsgn (ACCEL); resources PLANT ENG [280 h]; PLABOR; ELEC ENG [80 h]; OFFICE [120 h]; MECH ENG [40 h]; MECH DES [40 h] → ELEC ENG [80 h]; MECH ENG [40 h]; MECH DES [40 h]; PLANT ENG [280 h]; PLABOR; OFFICE [120 h] |
| 1241060 | Develop N&S Utilities 100% Dsgn (ACCEL) | 2007-10-01 → 2007-09-04 A (-27d) | 2008-01-03 → 2008-03-07 A (+64d) | 60d → 123d | 0% → 100% | 16d → none |  | was named Develop N&S UTILITIES 100% Dsgn (ACCEL); resources MECH DES [40 h]; PLABOR; ELEC ENG [80 h]; MECH ENG [360 h]; OFFICE [80 h] → OFFICE [80 h]; MECH DES [40 h]; PLABOR; MECH ENG [360 h]; ELEC ENG [80 h] |
| 1241025 | Conduct N&S Addition 100% Dsgn & Safty Review | 2008-01-04 → 2007-12-19 A (-16d) | 2008-02-01 → 2008-01-08 A (-24d) | 20d → 8d | 0% → 100% | 26d → none |  | was named Conduct N&S ADDITION 100% Dsgn & Safty Review |
| 1241030 | Develop N&S Addition Final Dsgn (ACCEL) | 2008-02-04 → 2008-01-29 A (-6d) | 2008-03-03 → 2008-08-29 A (+179d) | 20d → 151d | 0% → 100% | 106d → none |  | was named Develop N&S ADDITION Final Dsgn (ACCEL) |
| 1241105 | Conduct BSY Addition 100% Dsgn & Safty Review | 2008-04-29 → 2008-02-01 A (-88d) | 2008-05-27 → 2008-02-13 A (-104d) | 20d → 9d | 0% → 100% | 26d → none |  | was named Conduct BSY ADDITION 100% Dsgn & Safty Review |
| 1241110 | Develop BSY Addition Final Dsgn (ACCEL) | 2008-05-28 → 2008-02-14 A (-104d) | 2008-06-24 → 2008-09-19 A (+87d) | 20d → 153d | 0% → 100% | 26d → none |  | was named Develop BSY ADDITION Final Dsgn (ACCEL) |
| 1241065 | Conduct N&S Utilities100% Dsgn & Safty Review | 2008-01-04 → 2008-03-10 A (+66d) | 2008-02-01 → 2008-04-22 A (+81d) | 20d → 32d | 0% → 100% | 116d → none |  | was named Conduct N&S UTILITIES100% Dsgn & Safty Review |
| 1241140 | Develop Tunnel A/C 100% Dsgn (ACCEL) | 2008-01-04 → 2008-03-17 A (+73d) | 2008-03-31 → 2008-07-18 A (+109d) | 60d → 87d | 0% → 100% | 16d → none | 9-080M, 1241060 → 9-080M, 1241060 FS-5d | was named Develop TUNNEL A/C 100% Dsgn (ACCEL); resources OFFICE [40 h]; ELEC ENG [80 h]; MECH ENG [200 h]; PLABOR → MECH ENG [200 h]; OFFICE [40 h]; PLABOR; ELEC ENG [80 h] |
| 1241180 | Develop N&S Linac 100% Dsgn (ACCEL) | 2007-11-28 → 2008-03-17 A (+110d) | 2008-03-03 → 2008-05-30 A (+88d) | 60d → 54d | 0% → 100% | 26d → none | 9-080M FS+40d → 9-080M FS+80d | was named Develop N&S LINAC 100% Dsgn (ACCEL); resources ELEC ENG [240 h]; MECH DES [40 h]; OFFICE [40 h]; PLABOR → PLABOR; ELEC ENG [240 h]; OFFICE [40 h]; MECH DES [40 h] |
| 1241070 | Develop N&S Utilities Final Dsgn (ACCEL) | 2008-02-04 → 2008-05-12 A (+98d) | 2008-02-15 → 2008-09-26 A (+224d) | 10d → 97d | 0% → 100% | 116d → none |  | was named Develop N&S UTILITIES Final Dsgn (ACCEL) |
| 1241185 | Conduct N&S Linac 100% Dsgn & Safty Review | 2008-03-04 → 2008-06-05 A (+93d) | 2008-04-28 → 2008-07-01 A (+64d) | 40d → 18d | 0% → 100% | 26d → none |  | was named Conduct N&S LINAC 100% Dsgn & Safty Review |
| 1241190 | Develop N&S Linac Final Dsgn (ACCEL) | 2008-04-29 → 2008-07-02 A (+64d) | 2008-06-24 → 2008-08-20 A (+57d) | 40d → 35d | 0% → 100% | 26d → none |  | was named Develop N&S LINAC Final Dsgn (ACCEL) |
| 1241145 | Conduct Tunnel A/C 100% Dsgn & Safty Review | 2008-04-01 → 2008-08-04 A (+125d) | 2008-05-27 → 2008-08-19 A (+84d) | 40d → 12d | 0% → 100% | 16d → none |  | was named Conduct TUNNEL A/C 100% Dsgn & Safty Review |
| 1241150 | Develop Tunnel A/C Final Dsgn (ACCEL) | 2008-05-28 → 2008-08-20 A (+84d) | 2008-07-09 → 2008-09-17 A (+70d) | 30d → 20d | 0% → 100% | 16d → none |  | was named Develop TUNNEL A/C Final Dsgn (ACCEL) |

| ID | Task | Start | Finish | Duration | Complete | Total float | Predecessors | Other |
| --- | --- | --- | --- | --- | --- | --- | --- | --- |
| 1241195M | Comp Dsgn N&S Linac Pwr (ACCEL)++ | 2008-06-24 → 2008-08-20 A (+57d) | 2008-06-24 → 2008-08-20 A (+57d) |  | 0% → 100% | 68d → none |  | was named Comp Dsgn N&S LINAC Pwr (ACCEL)++ |
| 1241035M | Comp Dsgn N&S Access Bldng Addition+ | 2008-03-03 → 2008-08-29 A (+179d) | 2008-03-03 → 2008-08-29 A (+179d) |  | 0% → 100% | 396d → none |  | was named Comp Dsgn N&S Access Bldng ADDITION+ |
| 1241155M | Comp Dsgn Tunnel A/C (ACCEL)+ | 2008-07-09 → 2008-09-17 A (+70d) | 2008-07-09 → 2008-09-17 A (+70d) |  | 0% → 100% | 58d → none |  | was named Comp Dsgn TUNNEL A/C (ACCEL)+ |
| 1241115M | Comp Dsgn Beam Switch Yard Addition | 2008-06-24 → 2008-09-19 A (+87d) | 2008-06-24 → 2008-09-19 A (+87d) |  | 0% → 100% | 68d → none |  | was named Comp Dsgn Beam Switch Yard (BSY) ADDITION |
| 1241075M | Comp Dsgn N&S Utilities (ACCEL)+ | 2008-02-15 → 2008-09-26 A (+224d) | 2008-02-15 → 2008-09-26 A (+224d) |  | 0% → 100% | 158d → none |  | was named Comp Dsgn N&S UTILITIES (ACCEL)+ |
| 1241200 | Re-Baseline Actuals Adjustment | 2013-08-30 A | 2013-08-30 A |  | 0% → 100% | 20d → none | 9-130M FS+227d → none |  |
| 1242005M | Begin Design CHL Addition (CHL) | 2006-10-02 A | 2006-10-02 A |  | 0% → 100% | 313d → none |  |  |
| 1242010 | Develop CHL 60% Design (CHL) | 2006-10-02 A | 2006-11-28 → 2006-11-27 A (-1d) | 40d → 39d | 0% → 100% | 313d → none |  |  |
| 1242015 | Conduct CHL 60% Design & Safety Review | 2006-11-29 → 2006-11-28 A (-1d) | 2006-12-19 → 2007-01-19 A (+31d) | 15d → 32d | 0% → 100% | 313d → none |  |  |
| 1242015M | 60% Design CHL Complete | 2006-12-19 A | 2006-12-19 A |  | 0% → 100% | 313d → none |  |  |
| 1242020 | Develop CHL 100% Design (CHL) | 2006-12-20 → 2007-02-20 A (+62d) | 2007-03-02 → 2007-05-10 A (+69d) | 45d → 58d | 0% → 100% | 313d → none |  |  |
| 1242025 | Conduct CHL 100% Design & Safety Review | 2007-03-05 → 2007-06-18 A (+105d) | 2007-03-30 → 2007-08-03 A (+126d) | 20d → 34d | 0% → 100% | 313d → none |  |  |
| 1242025M | 100% Design CHL Complete | 2007-03-30 → 2007-08-03 A (+126d) | 2007-03-30 → 2007-08-03 A (+126d) |  | 0% → 100% | 313d → none |  |  |
| 1242030 | Develop CHL Final Design (CHL) | 2007-04-02 → 2007-09-10 A (+161d) | 2007-04-13 → 2007-10-23 A (+193d) | 10d → 32d | 0% → 100% | 313d → none |  |  |
| 1242035 | Conduct CHL Final Design & Safety Review | 2007-04-16 → 2007-11-26 A (+224d) | 2007-04-27 → 2007-12-05 A (+222d) | 10d → 8d | 0% → 100% | 313d → none |  | resources OFFICE [40 h]; PLANT ENG [80 h] → PLANT ENG [80 h]; OFFICE [40 h] |
| 1242040M | Complete Design CHL Addition (CHL) | 2007-04-27 → 2008-04-25 A (+364d) | 2007-04-27 → 2008-04-25 A (+364d) |  | 0% → 100% | 313d → none | 1242035 → 1242035 FS+95d |  |
| 1621000MX | CHL Addition Begin Proc Prep | 2008-10-01 A | 2008-10-01 A |  | 0% → 100% | 72d → none |  |  |
| 1621005X | Prcrmnt Prep for CHL Addition to Award Contract | 2008-10-01 A | 2008-12-24 → 2008-12-12 A (-12d) | 59d → 51d | 0% → 100% | 72d → none |  |  |
| 1242045 | Re-Baseline Actuals Adjustment | 2013-08-30 A | 2013-08-30 A |  | 0% → 100% | 20d → none | 9-130M FS+227d → none |  |
| 1243005M | Begin Definitive Design Hall D Complex | 2006-10-02 A | 2006-10-02 A |  | 0% → 100% | 15d → none |  |  |
| 1243010 | Develop Hall D 60% Design (HALL D) | 2006-10-02 → 2006-10-13 A (+11d) | 2006-12-05 → 2006-12-15 A (+10d) | 45d → 44d | 0% → 100% | 15d → none |  | resources PROCUREMENT<$50K 60; PROCUREMENT>$50K 69 → PROCUREMENT>$50K 69; PROCUREMENT<$50K 60 |
| 1243015 | Conduct Hall D 60% Design & Safety Review | 2006-12-06 → 2006-12-21 A (+15d) | 2007-01-18 → 2007-02-15 A (+28d) | 25d → 34d | 0% → 100% | 15d → none |  | resources OFFICE [120 h]; PLANT ENG [1000 h] → PLANT ENG [1000 h]; OFFICE [120 h] |
| 1243015M | 60% Design Hall D Complete | 2007-01-18 → 2007-02-15 A (+28d) | 2007-01-18 → 2007-02-15 A (+28d) |  | 0% → 100% | 15d → none |  |  |
| 1243018 | Independent Cost Validation | 2007-04-23 → 2007-04-24 A (+1d) | 2007-06-20 → 2007-06-18 A (-2d) | 42d → 39d | 0% → 100% | 93d → none |  |  |
| 1243021 | Develop Hall D Civil Commissioning Plan | 2007-05-21 → 2007-05-14 A (-7d) | 2007-08-14 → 2008-05-22 A (+282d) | 60d → 255d | 0% → 100% | 15d → none |  |  |
| 1243020 | Develop Hall D 100% Design (HALL D) | 2007-05-21 → 2007-06-18 A (+28d) | 2007-08-14 → 2007-10-05 A (+52d) | 60d → 78d | 0% → 100% | 15d → none |  |  |
| 1243025 | Conduct Hall D 100% Design & Safety Review | 2007-08-15 → 2007-10-11 A (+57d) | 2007-10-10 → 2007-11-21 A (+42d) | 40d → 30d | 0% → 100% | 15d → none |  |  |
| 1243025M | 100% Design Hall D Complete | 2007-10-10 → 2007-11-21 A (+42d) | 2007-10-10 → 2007-11-21 A (+42d) |  | 0% → 100% | 15d → none |  |  |
| 1243030 | Develop Hall D Final Design (HALL D) | 2007-10-11 → 2008-01-02 A (+83d) | 2007-11-07 → 2008-02-01 A (+86d) | 20d → 22d | 0% → 100% | 15d → none |  |  |
| 1243035 | Conduct Hall D Final Design & Safety Review | 2007-11-08 → 2008-02-05 A (+89d) | 2007-11-30 → 2008-03-05 A (+96d) | 15d → 21d | 0% → 100% | 15d → none | 1243030 → 1243030 FS-5d |  |
| 1243040M | Complete Design Hall D Complete (HALL D) | 2007-11-30 → 2008-03-05 A (+96d) | 2007-11-30 → 2008-03-05 A (+96d) |  | 0% → 100% | 15d → none | 1243035 → 1243035 FS+10d |  |
| 1243050 | PROC Procurement Prep to Award Hall D Contract | 2008-01-02 → 2008-03-06 A (+64d) | 2008-10-07 → 2009-01-08 A (+93d) | 195d → 210d | 0% → 100% | 136d → none |  |  |
| 1243050a | FY08 LAB/EXP Procurement Prep to Award Hall D Contract | 2008-01-02 → 2008-03-06 A (+64d) | 2008-09-30 → 2008-11-26 A (+57d) | 190d → 187d | 0% → 100% | 136d → none |  | was named FY08 Exp Procurement Prep to Award Hall D Contract |
| 1243055 | Hall D Survey Network | 2008-08-04 → 2008-05-19 A (-77d) | 2008-08-29 → 2008-09-23 A (+25d) | 20d → 89d | 0% → 100% | 162d → none | 1243040M FS+164d → 1243040M | resources MECH TECH [200 h]; MECH ENG [80 h]; PROCUREMENT<$50K 60 → MECH ENG [80 h]; MECH TECH [200 h]; PROCUREMENT<$50K 60 |
| 1243045 | Obtain Permit to Dispose of Dewater Effleuent (HALL D)+ | 2007-12-03 → 2008-05-28 A (+177d) | 2008-04-17 → 2009-02-13 A (+302d) | 90d → 177d | 0% → 100% | 256d → none | 1243035 → 1243035 FS+55d | resources PROCUREMENT<$50K 60; PLANT ENG [160 h] → PLANT ENG [160 h]; PROCUREMENT<$50K 60 |
| 1243050b | FY09 LAB/EXP Procurement Prep to Award Hall D Contract | 2008-10-01 → 2008-12-01 A (+61d) | 2008-10-07 → 2009-01-08 A (+93d) | 5d → 23d | 0% → 100% | 136d → none |  | was named FY09 Exp Procurement Prep to Award Hall D Contract; resources MECH ENG [7.18 h]; PLANT ENG [1.03 h]; ELEC ENG [6.15 h] → PLANT ENG [1.03 h]; ELEC ENG [6.15 h]; MECH ENG [7.18 h] |
| 1243060 | Re-Baseline Actuals Adjustment | 2013-08-30 A | 2013-08-30 A |  | 0% → 100% | 20d → none | 9-130M FS+227d → none |  |
| 1251006RKC | FY06 Obligations RKC | 2006-10-02 A | 2007-03-30 → 2007-01-31 A (-58d) | 120d → 79d | 0% → 100% | 333d → none |  |  |
| 1251007LOE | FY07 Project Management Project Office | 2006-10-02 A | 2007-09-28 A |  | 0% → 100% | 1d → none |  | resources DIRECTORATE [720 h]; SCIENTIST [880 h]; ELEC ENG [2640 h]; SR STAFF [4400 h]; ADMIN [880 h]; SUPPLIES & MATERIALS → SR STAFF [4400 h]; ADMIN [880 h]; DIRECTORATE [720 h]; SCIENTIST [880 h]; ELEC ENG [2640 h]; SUPPLIES & MATERIALS |
| 1251908LOE | FY08 PED Proj Office Proj Mngmnt P-1 | 2007-10-01 A | 2008-04-30 A |  | 0% → 100% | 1d → none |  | resources DIRECTORATE [412.26 h]; SCIENTIST [366.45 h]; ADMIN [503.87 h]; SR STAFF [3728.65 h]; OFFICE [503.87 h]; ELEC ENG [664.19 h]; SUPPLIES & MATERIALS; MECH ENG [297.74 h] → SR STAFF [3728.8 h]; DIRECTORATE [412.4 h]; OFFICE [504 h]; ELEC ENG [664 h]; SUPPLIES & MATERIALS; SCIENTIST [366.4 h]; MECH ENG [297.6 h]; ADMIN [504 h] |
| 1251908LOEB | FY08 PED Proj Office Proj Mngmnt P-2 | 2008-05-01 A | 2008-09-30 A |  | 0% → 100% | 1d → none |  | resources ELEC ENG [495.81 h]; MECH ENG [222.26 h]; SCIENTIST [273.55 h]; ADMIN [376.13 h]; OFFICE [376.13 h]; SR STAFF [1745.16 h]; SUPPLIES & MATERIALS → SCIENTIST [273.55 h]; ADMIN [376.13 h]; SR STAFF [1745.16 h]; OFFICE [376.13 h]; ELEC ENG [495.81 h]; SUPPLIES & MATERIALS; MECH ENG [222.26 h] |
| 171909LOEX | FY09 Constrctn Proj Office Proj Mngmnt | 2008-10-01 A | 2008-12-24 A |  | 0% → 100% | 20d → none |  | resources OFFICE [418.71 h]; SUPPLIES & MATERIALS; DIRECTORATE [171.29 h]; ELEC ENG [837.42 h]; SCIENTIST [209.35 h]; SR STAFF [1674.84 h]; ADMIN [418.71 h] → SUPPLIES & MATERIALS; DIRECTORATE [171.29 h]; SCIENTIST [209.35 h]; SR STAFF [1674.84 h]; ADMIN [418.71 h]; ELEC ENG [837.42 h]; OFFICE [418.71 h] |
| 1251910 | Re-Baseline Actuals Adjustment | 2013-08-30 A | 2013-08-30 A |  | 0% → 100% | 20d → none | 9-130M FS+227d → none |  |
| 1252007LOE | FY07 Project Management Project Office | 2006-10-02 A | 2007-09-28 A |  | 0% → 100% | 20d → none |  | resources SR STAFF [528 h]; ADMIN [1056 h]; MECH ENG [1056 h]; SUPPLIES & MATERIALS → SR STAFF [528 h]; ADMIN [1056 h]; SUPPLIES & MATERIALS; MECH ENG [1056 h] |
| 1252010 | PREP for OECM EVMS Contractor Certification Review | 2007-09-17 → 2007-10-01 A (+14d) | 2007-11-09 → 2007-11-30 A (+21d) | 40d → 43d | 0% → 100% | 31d → none |  |  |
| 1252908LOE | FY08 PED OPM Proj Mngmnt P-1 | 2007-10-01 A | 2008-04-15 A | 131d → 130d | 0% → 100% | 20d → none |  | resources OFFICE [380.32 h]; ADMIN [1115.61 h]; DIRECTORATE [278.9 h]; SUPPLIES & MATERIALS; MECH ENG [1394.52 h] → ADMIN [1115.6 h]; SUPPLIES & MATERIALS; OFFICE [380.4 h]; DIRECTORATE [278.8 h]; MECH ENG [1394.4 h] |
| 1252015 | OECM EVMS Contractor Certification REVIEW | 2007-12-03 A | 2007-12-07 A |  | 0% → 100% | 31d → none | 1252010 FS+13d → 1252010 FS+3d |  |
| 1252908LOEB | FY08 PED OPM Proj Mngmnt P-2 | 2008-04-16 A | 2008-09-30 A |  | 0% → 100% | 20d → none |  |  |
| 1252910 | Re-Baseline Actuals Adjustment | 2013-08-30 A | 2013-08-30 A |  | 0% → 100% | 20d → none | 9-130M FS+227d → none |  |
| 6 | **1.2.6 ACCELERATOR SYSTEMS COMMISSIONING PLANNING** | 2006-11-01 → 2007-02-23 (+114d) |  |  |  |  |  |  |
| 126000M | Start Milestone for Commissioning PED (ACC SYS COMMIS PLNNG) | 2006-11-01 → 2007-02-23 A (+114d) | 2006-11-01 → 2007-02-23 A (+114d) |  | 0% → 100% | 278d → none |  |  |
| 126005 | Develop draft commissioning plan for EIR (ACC SYS COMMIS PLNNG) | 2006-11-01 → 2007-02-23 A (+114d) | 2007-05-15 → 2007-05-17 A (+2d) | 130d → 60d | 0% → 100% | 278d → none |  |  |
| 126010 | Preliminary Design & Safety Review for Commissioning Plan (ACC SYS COMMIS PLNNG) | 2007-05-16 → 2007-05-18 A (+2d) | 2007-05-16 → 2007-05-18 A (+2d) |  | 0% → 100% | 278d → none |  |  |
| 126015 | Post-review development of Commissioning Plan (ACC SYS COMMIS PLNNG) | 2007-05-17 → 2007-07-23 A (+67d) | 2007-05-31 → 2007-09-25 A (+117d) | 10d → 46d | 0% → 100% | 278d → none |  |  |
| 126020M | Draft commissioning plan ready for EIR (ACC SYS COMMIS PLNNG) | 2007-05-31 → 2007-09-25 A (+117d) | 2007-05-31 → 2007-09-25 A (+117d) |  | 0% → 100% | 278d → none |  |  |
| 126025M | Start of FY08 Commssng Planning (ACC SYS COMMIS PLNNG) | 2008-03-27 → 2008-02-01 A (-55d) | 2008-03-27 → 2008-02-01 A (-55d) |  | 0% → 100% | 77d → none |  |  |
| 126030 | Development of Sys's Cmmssng Milestones (ACC SYS COMMIS PLNNG) | 2008-03-27 → 2008-02-01 A (-55d) | 2008-09-29 → 2009-05-15 A (+228d) | 130d → 322d | 0% → 100% | 77d → none |  |  |
| 126060 | Development of Beam-Based Cmmssng Plan (ACC SYS COMMIS PLNNG) | 2008-10-29 → 2009-03-03 A (+125d) | 2009-05-12 → 2009-09-21 A (+132d) | 130d → 142d | 0% → 100% | 77d → none | 126045 → 126045 FS-10d |  |
| 126040 | Review of Sys Milestones with Sys owners (ACC SYS COMMIS PLNNG) | 2008-09-30 → 2009-05-11 A (+223d) | 2008-09-30 → 2009-06-29 A (+272d) | 1d → 35d | 0% → 100% | 77d → none |  | resources MECH ENG [20 h]; ADMIN [20 h]; SCIENTIST [20 h]; ELEC ENG [20 h] → SCIENTIST [20 h]; MECH ENG [20 h]; ELEC ENG [20 h]; ADMIN [20 h] |
| 126035M | Comp Draft Sys's Cmmssng Milestones (ACC SYS COMMIS PLNNG) | 2008-09-29 → 2009-05-15 A (+228d) | 2008-09-29 → 2009-05-15 A (+228d) |  | 0% → 100% | 77d → none |  |  |
| 126045 | Incorporate Changes from Review of Sys's Milestones (ACC SYS COMMIS PLNNG) | 2008-10-01 → 2009-06-02 A (+244d) | 2008-10-28 → 2009-07-27 A (+272d) | 20d → 39d | 0% → 100% | 77d → none |  | resources SCIENTIST [120 h]; ADMIN [40 h] → ADMIN [40 h]; SCIENTIST [120 h] |
| 126065M | Comp Draft Beam-Based Commssng Plan (ACC SYS COMMIS PLNNG) | 2009-05-12 → 2009-09-21 A (+132d) | 2009-05-12 → 2009-09-21 A (+132d) |  | 0% → 100% | 77d → none |  |  |
| 126070 | Review of Beam-Based Cmmssng Plan (ACC SYS COMMIS PLNNG) | 2009-05-13 → 2009-09-22 A (+132d) | 2009-05-13 → 2009-09-22 A (+132d) |  | 0% → 100% | 77d → none |  | resources ELEC ENG [4 h]; SCIENTIST [20 h]; MECH ENG [4 h]; ADMIN [4 h] → SCIENTIST [20 h]; MECH ENG [4 h]; ADMIN [4 h]; ELEC ENG [4 h] |
| 126075 | Incorporate Changes from Review of Beam-Based Plan (ACC SYS COMMIS PLNNG) | 2009-05-14 → 2009-09-23 A (+132d) | 2009-06-11 → 2009-09-29 A (+110d) | 20d → 5d | 0% → 100% | 77d → none |  |  |
| 126080M | Comp Commssng Plan (ACC SYS COMMIS PLNNG) | 2009-06-11 → 2009-09-29 A (+110d) | 2009-06-11 → 2009-09-29 A (+110d) |  | 0% → 100% | 77d → none |  |  |
| 126085 | Re-Baseline Actuals Adjustment | 2013-08-30 A | 2013-08-30 A |  | 0% → 100% | 20d → none | 9-130M FS+227d → none |  |
| 3 | **1.3 CONSTRUCTION ACCELERATOR SYSTEMS** |  | 2014-10-31 → 2014-10-30 (-1d) |  |  |  |  |  |
| 1 | **1.3.1 CRYOMODULES** | 2009-01-02 → 2009-01-26 (+24d) |  |  |  |  |  |  |
| 1 | **1.3.1.1 PROCUREMENTS** | 2009-01-02 → 2009-01-26 (+24d) |  |  |  |  |  |  |
| 1 | **1.3.1.1.1 CAVITY STRING PROCUREMENTS** | 2009-01-05 → 2009-01-26 (+21d) |  |  |  |  |  |  |

| ID | Task | Start | Finish | Duration | Complete | Total float | Predecessors | Other |
| --- | --- | --- | --- | --- | --- | --- | --- | --- |
| 1 | **1.3.1.1.1.1 NIOBIUM** | 2009-01-05 → 2009-01-26 (+21d) |  |  |  |  |  |  |
| 131111010 | Proc Niobium | 2009-01-05 → 2009-01-26 A (+21d) | 2009-01-05 → 2009-07-03 A (+179d) | 1d → 112d | 0% → 100% | 527d → none |  |  |
| 131111011 | Niobium Labor and Expenses Initial | 2009-01-06 → 2009-05-01 A (+115d) | 2009-05-29 → 2009-08-24 A (+87d) | 101d → 80d | 0% → 100% | 527d → none |  | resources TRAVEL; MECH DES [100 h]; ELEC ENG [60 h]; MECH ENG [100 h]; SR STAFF [100 h]; SCIENTIST [24 h]; SUPPLIES & MATERIALS → ELEC ENG [60 h]; MECH ENG [100 h]; SR STAFF [100 h]; SCIENTIST [24 h]; SUPPLIES & MATERIALS; MECH DES [100 h]; TRAVEL |
| 131111012 | Expenses Niobium Batch 1 | 2009-01-06 → 2009-07-01 A (+176d) | 2009-05-29 → 2009-11-30 A (+185d) | 101d → 105d | 0% → 100% | 713d → none |  |  |
| 131111012A | Vend Fab - Order Niobium | 2009-07-15 → 2009-07-01 A (-14d) | 2009-08-10 → 2009-08-24 A (+14d) | 19d → 38d | 0% → 100% | 663d → none |  |  |
| 131111012B | Vend Fab - Niobium Batch 1 | 2009-07-15 → 2009-07-01 A (-14d) | 2009-11-11 → 2009-11-30 A (+19d) | 85d → 105d | 0% → 100% | 577d → none |  |  |
| 131111013 | Expenses Niobium Batch 2 | 2009-01-06 → 2009-07-01 A (+176d) | 2009-05-29 → 2010-07-29 A (+426d) | 101d → 268d | 0% → 100% | 713d → none |  |  |
| 131111013A | Vend Fab - Niobium Batch 2 | 2009-07-15 → 2009-07-01 A (-14d) | 2010-02-11 → 2010-03-01 A (+18d) | 142d → 162d | 0% → 100% | 530d → none |  |  |
| 131111011LOE | Niobium Labor and Expenses Final FY09 | 2009-07-15 → 2009-07-14 A (-1d) | 2009-09-30 A | 55d → 56d | 0% → 100% | 527d → none | 131111011 FS+31d → 131111011 FS-200d | resources MECH DES [8.52 h]; TRAVEL; ELEC ENG [5.68 h]; MECH ENG [8.52 h]; SR STAFF [7.81 h]; SCIENTIST [3.55 h]; SUPPLIES & MATERIALS → SUPPLIES & MATERIALS; MECH DES [8.52 h]; TRAVEL; ELEC ENG [5.68 h]; MECH ENG [8.52 h]; SR STAFF [7.81 h]; SCIENTIST [3.55 h] |
| 131111011LOEb | Niobium Labor and Expenses Final FY10 | 2009-10-01 A | 2010-03-03 A |  | 0% → 100% | 527d → none |  | resources TRAVEL; SR STAFF [14.19 h]; SCIENTIST [6.45 h]; ELEC ENG [10.32 h]; MECH ENG [15.48 h]; SUPPLIES & MATERIALS; MECH DES [15.48 h] → MECH DES [15.48 h]; TRAVEL; ELEC ENG [10.32 h]; MECH ENG [15.48 h]; SR STAFF [14.19 h]; SCIENTIST [6.45 h]; SUPPLIES & MATERIALS |
| 131111015 | Receive & Insp Niobium Batch 1 | 2009-11-12 → 2009-11-02 A (-10d) | 2009-12-11 → 2009-12-21 A (+10d) | 20d → 33d | 0% → 100% | 577d → none |  | resources SUPPLIES & MATERIALS; MECH TECH [240 h]; ELEC ENG [80 h]; COMP SCIENT [120 h]; MECH DES [80 h]; MECH ENG [80 h]; SCIENTIST [40 h]; SR STAFF [200 h] → MECH DES [80 h]; MECH ENG [80 h]; SCIENTIST [40 h]; SR STAFF [200 h]; SUPPLIES & MATERIALS; MECH TECH [240 h]; ELEC ENG [80 h]; COMP SCIENT [120 h] |
| 131111013B | Vend Fab - Niobium Batch 2 Reverse Entry per CR 10-043 | 2010-03-01 A | 2010-03-01 A |  | 0% → 100% | 528d → none |  |  |
| 131111013C | Vend Fab - Niobium Batch 2 Revised Delivery per CR 10-043 | 2010-03-01 A | 2010-09-30 → 2010-07-30 A (-62d) | 151d → 108d | 0% → 100% | 379d → none |  |  |
| 131111020 | Receive & Insp Niobium Batch 2 (Original History) | 2010-02-12 → 2010-03-01 A (+17d) | 2010-02-26 → 2010-03-01 A (+3d) | 10d → 1d | 0% → 100% | 530d → none |  | resources SUPPLIES & MATERIALS; ELEC ENG [80 h]; MECH DES [20 h]; MECH TECH [240 h]; MECH ENG [40 h] → MECH DES [20 h]; MECH TECH [240 h]; MECH ENG [40 h]; ELEC ENG [80 h]; SUPPLIES & MATERIALS |
| 131111020A | Receive & Insp Niobium Batch 2 Reverse Entry per CR 10-043 | 2010-03-02 → 2010-03-01 A (-1d) | 2010-03-02 → 2010-03-01 A (-1d) |  | 0% → 100% | 528d → none |  | resources MECH TECH [-240 h]; MECH ENG [-40 h]; SUPPLIES & MATERIALS; ELEC ENG [-80 h]; MECH DES [-20 h] → MECH DES [-20 h]; MECH TECH [-240 h]; MECH ENG [-40 h]; SUPPLIES & MATERIALS; ELEC ENG [-80 h] |
| 131111020B | Receive & Insp Niobium Batch 2 Revised Delivery per CR 10-043 | 2010-09-17 → 2010-06-01 A (-108d) | 2010-09-30 → 2010-07-30 A (-62d) | 10d → 43d | 0% → 100% | 379d → none |  | resources ELEC ENG [160 h]; MECH DES [40 h]; MECH TECH [480 h]; MECH ENG [80 h]; SUPPLIES & MATERIALS → MECH TECH [480 h]; MECH ENG [80 h]; SUPPLIES & MATERIALS; ELEC ENG [160 h]; MECH DES [40 h] |
| 131111025 | Re-Baseline Actuals Adjustment | 2013-08-30 A | 2013-08-30 A |  | 0% → 100% | 20d → none | 9-130M FS+227d → none |  |
| 2 | **1.3.1.1.1.2 CAVITY FABRICATION** | 2009-01-05 → 2009-01-26 (+21d) |  |  |  |  |  |  |
| 131112000 | Re-Baseline Actuals Adjustment | 2013-08-30 A | 2013-08-30 A |  | 0% → 100% | 20d → none | 9-130M FS+227d → none |  |
| 1 | **1.3.1.1.1.2.1 VEND FAB CAVITIES** | 2009-01-05 → 2009-01-26 (+21d) |  |  |  |  |  |  |
| 1311121010 | Proc Cavity Fab | 2009-01-05 → 2009-01-26 A (+21d) | 2009-01-09 → 2009-07-03 A (+175d) | 5d → 112d | 0% → 100% | 169d → none |  |  |
| 1311121015 | Cavities Labor Initial | 2009-01-12 → 2009-05-01 A (+109d) | 2009-05-29 → 2009-06-30 A (+32d) | 97d → 42d | 0% → 100% | 169d → none |  | resources ELEC ENG [61.6 h]; MECH ENG [70 h]; SCIENTIST [50 h]; SR STAFF [50 h]; MECH DES [70.4 h] → MECH ENG [70 h]; SCIENTIST [50 h]; SR STAFF [50 h]; MECH DES [70.4 h]; ELEC ENG [61.6 h] |
| 1311121015LOE | Cavities Labor Final FY09 | 2009-07-15 → 2009-07-14 A (-1d) | 2009-09-30 A | 55d → 56d | 0% → 100% | 169d → none | 1311121015 FS+31d → 1311121015 | resources MECH DES [9.53 h]; ELEC ENG [2.02 h]; MECH ENG [9.69 h]; SCIENTIST [3.26 h]; SR STAFF [7.46 h] → SR STAFF [7.46 h]; MECH DES [9.53 h]; ELEC ENG [2.02 h]; MECH ENG [9.69 h]; SCIENTIST [3.26 h] |
| 1311121016 | Vend Fab Cavities 1 & 2 | 2009-07-15 → 2009-09-14 A (+61d) | 2010-06-30 → 2010-07-30 A (+30d) | 239d → 218d | 0% → 100% | 53d → none |  |  |
| 1311121020 | Vend Fab Cavities 3 thru 8 | 2009-07-15 → 2009-09-14 A (+61d) | 2010-07-30 → 2010-09-29 A (+61d) |  | 0% → 100% | 40d → none | 9-090M FS+193d → 1311121016 FS-191d |  |
| 1311121025 | Vend Fab Cavities 9 thru 14 | 2009-07-15 → 2009-09-14 A (+61d) | 2010-07-30 → 2010-10-18 A (+80d) | 260d → 273d | 0% → 100% | 80d → none | 9-090M FS+193d → 1311121020 FS-214d |  |
| 1311121030 | Vend Fab Cavities 15 thru 20 | 2009-07-15 → 2009-09-14 A (+61d) | 2010-08-31 → 2010-10-25 A (+55d) | 282d → 278d | 0% → 100% | 73d → none | 9-090M FS+193d → 1311121025 FS-233d |  |
| 1311121035 | Vend Fab Cavities 21 thru 26 | 2009-07-15 → 2009-09-14 A (+61d) | 2010-09-30 → 2010-10-25 A (+25d) | 303d → 278d | 0% → 100% | 138d → none | 9-090M FS+193d → 1311121030 FS-287.88d |  |
| 1311121040 | Vend Fab Cavities 27 thru 32 | 2009-07-15 → 2009-09-14 A (+61d) | 2010-10-29 → 2010-10-25 A (-4d) | 324d → 278d | 0% → 100% | 134d → none | 9-090M FS+193d → 1311121035 FS-274d |  |
| 1311121045 | Vend Fab Cavities 33 thru 38 | 2009-07-15 → 2009-09-14 A (+61d) | 2010-12-30 → 2010-11-30 A (-30d) | 361d → 302d | 0% → 100% | 130d → none | 9-090M FS+193d → 1311121040 FS-293d |  |
| 1311121050 | Vend Fab Cavities 39 thru 44 | 2009-07-15 → 2009-09-14 A (+61d) | 2011-01-31 → 2010-11-30 A (-62d) | 381d → 302d | 0% → 100% | 129d → none | 9-090M FS+193d → 1311121045 FS-335d |  |
| 1311121055 | Vend Fab Cavities 45 thru 50 | 2009-07-15 → 2009-09-14 A (+61d) | 2011-02-28 → 2010-11-30 A (-90d) | 400d → 302d | 0% → 100% | 109d → none | 9-090M FS+193d → 1311121050 FS-350d |  |
| 1311121060 | Vend Fab Cavities 51 thru 56 | 2009-07-15 → 2009-09-14 A (+61d) | 2011-03-31 → 2010-11-30 A (-121d) | 423d → 302d | 0% → 100% | 111d → none | 9-090M FS+193d → 1311121055 FS-370d |  |
| 1311121065 | Vend Fab Cavities 57 thru 62 | 2009-07-15 → 2009-09-14 A (+61d) | 2011-04-29 → 2010-11-30 A (-150d) | 444d → 302d | 0% → 100% | 110d → none | 9-090M FS+193d → 1311121060 FS-387d |  |
| 1311121070 | Vend Fab Cavities 63 thru 68 | 2009-07-15 → 2009-09-14 A (+61d) | 2011-05-31 → 2010-11-30 A (-182d) | 465d → 302d | 0% → 100% | 105d → none | 9-090M FS+193d → 1311121065 FS-407d |  |
| 1311121075 | Vend Fab Cavities 69 thru 74 | 2009-07-15 → 2009-09-14 A (+61d) | 2011-06-30 → 2010-12-17 A (-195d) | 487d → 315d | 0% → 100% | 123d → none | 9-090M FS+193d → 1311121070 FS-427d |  |
| 1311121080 | Vend Fab Cavities 75 thru 80 | 2009-07-15 → 2009-09-14 A (+61d) | 2011-07-29 → 2010-12-21 A (-220d) | 507d → 316d | 0% → 100% | 119d → none | 9-090M FS+193d → 1311121075 FS-448d |  |
| 1311121085 | Vend Fab Cavities 81 thru 86 | 2009-07-15 → 2009-09-14 A (+61d) | 2011-08-31 → 2011-03-25 A (-159d) | 530d → 377d | 0% → 100% | 111d → none | 9-090M FS+193d → 1311121080 FS-467d |  |
| 1311121015LOEb | Cavities Labor Final FY10 | 2009-10-01 A | 2010-09-30 → 2011-08-08 A (+312d) | 248d → 457d | 0% → 100% | 169d → none |  | resources MECH ENG [43.7 h]; MECH DES [42.98 h]; SCIENTIST [14.7 h]; SR STAFF [33.65 h]; ELEC ENG [9.09 h] → MECH ENG [43.7 h]; SCIENTIST [14.7 h]; SR STAFF [33.65 h]; MECH DES [42.98 h]; ELEC ENG [9.09 h] |
| 1311121015LOEc | Cavities Labor Final FY11 | 2010-10-01 → 2009-10-01 A (-365d) | 2011-08-08 A | 210d → 457d | 0% → 100% | 169d → none | 1311121015LOEb → 1311121015LOE | resources ELEC ENG [7.69 h]; MECH ENG [37.01 h]; SCIENTIST [12.44 h]; SR STAFF [28.49 h]; MECH DES [36.39 h] → MECH ENG [37.01 h]; SCIENTIST [12.44 h]; SR STAFF [28.49 h]; MECH DES [36.39 h]; ELEC ENG [7.69 h] |
| 1311121017 | Vend Fab Chemistry & Tuning Cavities 1 & 2 | 2010-01-04 A | 2010-06-30 → 2010-07-30 A (+30d) | 125d → 146d | 0% → 100% | 53d → none | 9-100M FS+59d → 9-100M FS+22d |  |
| 1311121021 | Vend Fab Chemistry & Tuning Cavities 3 thru 8 | 2010-01-04 A | 2010-07-30 → 2010-09-29 A (+61d) | 146d → 188d | 0% → 100% | 40d → none | 9-100M FS+59d → 9-100M FS+22d |  |
| 1311121026 | Vend Fab Chemistry & Tuning Cavities 9 thru 14 | 2010-01-04 A | 2010-07-30 → 2010-10-25 A (+87d) | 146d → 206d | 0% → 100% | 80d → none | 9-100M FS+59d → 9-100M FS+22d |  |
| 1311121031 | Vend Fab Chemistry & Tuning Cavities 15 thru 20 | 2010-01-04 A | 2010-08-31 → 2010-10-25 A (+55d) | 168d → 206d | 0% → 100% | 73d → none | 9-100M FS+59d → 9-100M FS+22d |  |
| 1311121036 | Vend Fab Chemistry & Tuning Cavities 21 thru 26 | 2010-01-04 A | 2010-09-30 → 2010-10-25 A (+25d) | 189d → 206d | 0% → 100% | 138d → none | 9-100M FS+59d → 9-100M FS+22d |  |
| 1311121041 | Vend Fab Chemistry & Tuning Cavities 27 thru 32 | 2010-01-04 A | 2010-10-29 → 2010-10-25 A (-4d) | 210d → 206d | 0% → 100% | 134d → none | 9-100M FS+59d → 9-100M FS+22d |  |
| 1311121046 | Vend Fab Chemistry & Tuning Cavities 33 thru 38 | 2010-01-04 A | 2010-12-30 → 2010-11-30 A (-30d) | 247d → 230d | 0% → 100% | 130d → none | 9-100M FS+59d → 9-100M FS+22d |  |
| 1311121051 | Vend Fab Chemistry & Tuning Cavities 39 thru 44 | 2010-01-04 A | 2011-01-31 → 2010-11-30 A (-62d) | 267d → 230d | 0% → 100% | 129d → none | 9-100M FS+59d → 9-100M FS+22d |  |
| 1311121056 | Vend Fab Chemistry & Tuning Cavities 45 thru 50 | 2010-01-04 A | 2011-02-28 → 2010-11-30 A (-90d) | 286d → 230d | 0% → 100% | 109d → none | 9-100M FS+59d → 9-100M FS+22d |  |
| 1311121061 | Vend Fab Chemistry & Tuning Cavities 51 thru 56 | 2010-01-04 A | 2011-03-31 → 2010-11-30 A (-121d) | 309d → 230d | 0% → 100% | 111d → none | 9-100M FS+59d → 9-100M FS+22d |  |
| 1311121066 | Vend Fab Chemistry & Tuning Cavities 57 thru 62 | 2010-01-04 A | 2011-04-29 → 2010-11-30 A (-150d) | 330d → 230d | 0% → 100% | 110d → none | 9-100M FS+59d → 9-100M FS+22d |  |
| 1311121071 | Vend Fab Chemistry & Tuning Cavities 63 thru 68 | 2010-01-04 A | 2011-05-31 → 2010-11-30 A (-182d) | 351d → 230d | 0% → 100% | 105d → none | 9-100M FS+59d → 9-100M FS+22d |  |
| 1311121076 | Vend Fab Chemistry & Tuning Cavities 69 thru 74 | 2010-01-04 A | 2011-06-30 → 2010-12-17 A (-195d) | 373d → 243d | 0% → 100% | 123d → none | 9-100M FS+59d → 9-100M FS+22d |  |
| 1311121081 | Vend Fab Chemistry & Tuning Cavities 75 thru 80 | 2010-01-04 A | 2011-07-29 → 2010-12-21 A (-220d) | 393d → 245d | 0% → 100% | 119d → none | 9-100M FS+59d → 9-100M FS+22d |  |
| 1311121086 | Vend Fab Chemistry & Tuning Cavities 81 thru 86 | 2010-01-04 A | 2011-08-31 → 2011-03-25 A (-159d) | 416d → 305d | 0% → 100% | 111d → none | 9-100M FS+59d → 9-100M FS+22d |  |
| 1311121091 | Cavities Custom Duty Adjustment | 2010-07-01 A | 2011-08-31 → 2011-03-25 A (-159d) | 291d → 180d | 0% → 100% | 105d → none |  |  |
| 1311121096LOE | SOTR Oversight FY10 | 2010-07-01 A | 2010-09-30 A |  | 0% → 100% | 137d → none |  |  |
| 1311121101LOE | SOTR Oversight FY11 | 2010-10-01 A | 2011-09-22 A |  | 0% → 100% | 137d → none |  |  |
| 2 | **1.3.1.1.1.2.2 RECEIVE AND INSPECT CAVITIES** | 2010-06-11 → 2010-07-19 (+38d) | 2011-10-03 → 2011-08-22 (-42d) |  |  |  |  |  |
| 1311122005 | Receive and Inspect Cavities 1 & 2 | 2010-06-11 → 2010-07-19 A (+38d) | 2010-06-24 → 2010-08-23 A (+60d) | 10d → 26d | 0% → 100% | 53d → none |  | resources MECH ENG [46.7 h]; SR STAFF [15 h]; SUPPLIES & MATERIALS; COMP SCIENT [30 h]; ELEC TECH [30 h]; ELEC ENG [40 h]; MECH DES [30 h]; MECH TECH [60.13 h]; SCIENTIST [20 h] → MECH ENG [46.7 h]; MECH TECH [60.13 h]; SCIENTIST [20 h]; SR STAFF [15 h]; SUPPLIES & MATERIALS; COMP SCIENT [30 h]; ELEC ENG [40 h]; ELEC TECH [30 h]; MECH DES [30 h] |
| 1311122010 | Receive and Inspect Cavities 3 Thru 8 | 2010-07-15 → 2010-09-01 A (+48d) | 2010-08-04 → 2010-09-22 A (+49d) |  | 0% → 100% | 40d → none | 1311121021 FS-12d, 1311121020 FS-12d, 1311122005 → 1311121021 FS-45d, 1311122005 FS-10d, 1311121020 FS-45d | resources MECH DES [60 h]; MECH ENG [120 h]; SCIENTIST [48 h]; SUPPLIES & MATERIALS; ELEC TECH [60 h]; MECH TECH [240 h]; SR STAFF [30 h]; COMP SCIENT [60 h]; ELEC ENG [120 h] → MECH DES [60 h]; ELEC ENG [120 h]; MECH ENG [120 h]; SCIENTIST [48 h]; SR STAFF [30 h]; ELEC TECH [60 h]; MECH TECH [240 h]; SUPPLIES & MATERIALS; COMP SCIENT [60 h] |
| 1311122015 | Receive and Inspect Cavities 9 Thru 14 | 2010-09-10 → 2010-10-01 A (+21d) | 2010-09-30 → 2010-10-18 A (+18d) | 15d → 12d | 0% → 100% | 37d → none |  | resources ELEC TECH [30 h]; SUPPLIES & MATERIALS; MECH DES [30 h]; MECH ENG [90 h]; SCIENTIST [48 h]; COMP SCIENT [30 h]; ELEC ENG [120 h]; SR STAFF [30 h]; MECH TECH [240 h] → COMP SCIENT [30 h]; ELEC ENG [120 h]; MECH ENG [90 h]; SR STAFF [30 h]; SUPPLIES & MATERIALS; ELEC TECH [30 h]; MECH TECH [240 h]; MECH DES [30 h]; SCIENTIST [48 h] |
| 1311122020 | Receive and Inspect Cavities 15 and 16 | 2010-10-01 → 2010-11-01 A (+31d) | 2010-10-07 → 2010-11-30 A (+54d) | 5d → 20d | 0% → 100% | 37d → none |  |  |
| 1311122022 | Receive and Inspect Cavities 17 Thru 20 | 2010-10-08 → 2010-11-01 A (+24d) | 2010-10-21 → 2010-11-30 A (+40d) | 10d → 20d | 0% → 100% | 107d → none |  | resources MECH ENG [60 h]; SCIENTIST [32 h]; SR STAFF [20 h]; SUPPLIES & MATERIALS; ELEC TECH [40 h]; MECH TECH [160 h]; ELEC ENG [80 h]; MECH DES [20 h] → SUPPLIES & MATERIALS; ELEC TECH [40 h]; MECH TECH [160 h]; ELEC ENG [80 h]; MECH DES [20 h]; MECH ENG [60 h]; SCIENTIST [32 h]; SR STAFF [20 h] |
| 1311122025 | Receive and Inspect Cavities 21 Thru 24 | 2010-10-22 → 2010-11-01 A (+10d) | 2010-11-04 → 2010-11-30 A (+26d) | 10d → 20d | 0% → 100% | 107d → none |  | resources MECH DES [20 h]; MECH TECH [160 h]; ELEC ENG [80 h]; MECH ENG [60 h]; SCIENTIST [32 h]; SUPPLIES & MATERIALS; ELEC TECH [40 h] → MECH DES [20 h]; SCIENTIST [32 h]; ELEC ENG [80 h]; MECH ENG [60 h]; SUPPLIES & MATERIALS; ELEC TECH [40 h]; MECH TECH [160 h] |
| 1311122027 | Receive and Inspect Cavities 25 and 26 | 2010-11-05 → 2010-11-01 A (-4d) | 2010-11-11 → 2010-11-30 A (+19d) | 5d → 20d | 0% → 100% | 108d → none |  | resources ELEC ENG [40 h]; SUPPLIES & MATERIALS; ELEC TECH [10 h]; MECH TECH [80 h]; MECH DES [10 h]; SR STAFF [10 h]; MECH ENG [13 h]; SCIENTIST [16 h] → MECH ENG [13 h]; SCIENTIST [16 h]; SUPPLIES & MATERIALS; ELEC TECH [10 h]; MECH TECH [80 h]; SR STAFF [10 h]; ELEC ENG [40 h]; MECH DES [10 h] |
| 1311122030 | Receive and Inspect Cavities 27 Thru 32 | 2010-11-12 → 2010-11-01 A (-11d) | 2010-12-06 → 2010-11-30 A (-6d) | 15d → 20d | 0% → 100% | 108d → none |  | resources ELEC ENG [120 h]; SR STAFF [30 h]; SUPPLIES & MATERIALS; ELEC TECH [30 h]; MECH DES [30 h]; MECH ENG [39 h]; MECH TECH [240 h]; SCIENTIST [48 h] → ELEC TECH [30 h]; MECH DES [30 h]; MECH ENG [39 h]; MECH TECH [240 h]; SCIENTIST [48 h]; SR STAFF [30 h]; SUPPLIES & MATERIALS; ELEC ENG [120 h] |
| 1311122035 | Receive and Inspect Cavities 33 Thru 38 | 2011-01-18 → 2010-12-01 A (-48d) | 2011-02-07 → 2010-12-17 A (-52d) | 15d → 13d | 0% → 100% | 108d → none |  | resources ELEC ENG [120 h]; SCIENTIST [48 h]; SUPPLIES & MATERIALS; ELEC TECH [30 h]; SR STAFF [30 h]; MECH TECH [240 h]; MECH DES [15 h]; MECH ENG [39 h] → MECH DES [15 h]; ELEC ENG [120 h]; SR STAFF [30 h]; MECH ENG [39 h]; SCIENTIST [48 h]; SUPPLIES & MATERIALS; ELEC TECH [30 h]; MECH TECH [240 h] |
| 1311122065 | Receive and Inspect Cavities 39 and 40 | 2011-02-08 → 2010-12-01 A (-69d) | 2011-02-14 → 2010-12-17 A (-59d) | 5d → 13d | 0% → 100% | 108d → none |  | resources SR STAFF [10 h]; SCIENTIST [16 h]; SUPPLIES & MATERIALS; ELEC TECH [10 h]; MECH TECH [80 h]; MECH ENG [13 h]; ELEC ENG [40 h]; MECH DES [5 h] → ELEC ENG [40 h]; SUPPLIES & MATERIALS; SR STAFF [10 h]; MECH ENG [13 h]; SCIENTIST [16 h]; MECH TECH [80 h]; MECH DES [5 h]; ELEC TECH [10 h] |
| 1311122067 | Receive and Inspect Cavities 41 Thru 44 | 2011-02-15 → 2010-12-01 A (-76d) | 2011-03-01 → 2010-12-17 A (-74d) | 10d → 13d | 0% → 100% | 112d → none |  | resources SUPPLIES & MATERIALS; ELEC TECH [20 h]; ELEC ENG [80 h]; MECH DES [10 h]; SR STAFF [20 h]; MECH ENG [26 h]; SCIENTIST [32 h]; MECH TECH [160 h] → SUPPLIES & MATERIALS; ELEC TECH [20 h]; MECH TECH [160 h]; MECH DES [10 h]; SR STAFF [20 h]; MECH ENG [26 h]; SCIENTIST [32 h]; ELEC ENG [80 h] |

| ID | Task | Start | Finish | Duration | Complete | Total float | Predecessors | Other |
| --- | --- | --- | --- | --- | --- | --- | --- | --- |
| 1311122070 | Receive and Inspect Cavities 45 Thru 48 | 2011-03-07 → 2011-01-03 A (-63d) | 2011-03-18 → 2011-01-14 A (-63d) | 10d → 9d | 0% → 100% | 109d → none |  | resources SR STAFF [20 h]; MECH ENG [26 h]; ELEC ENG [80 h]; ELEC TECH [20 h]; MECH TECH [160 h]; MECH DES [10 h]; SUPPLIES & MATERIALS; SCIENTIST [32 h] → ELEC TECH [20 h]; MECH DES [10 h]; ELEC ENG [80 h]; MECH TECH [160 h]; SR STAFF [20 h]; MECH ENG [26 h]; SCIENTIST [32 h]; SUPPLIES & MATERIALS |
| 1311122072 | Receive and Inspect Cavities 49 and 50 | 2011-03-21 → 2011-01-14 A (-66d) | 2011-03-25 → 2011-01-21 A (-63d) |  | 0% → 100% | 113d → none |  | resources SR STAFF [10 h]; ELEC ENG [40 h]; MECH ENG [13 h]; SCIENTIST [16 h]; SUPPLIES & MATERIALS; ELEC TECH [10 h]; MECH TECH [80 h]; MECH DES [5 h] → MECH ENG [13 h]; SCIENTIST [16 h]; SUPPLIES & MATERIALS; ELEC TECH [10 h]; ELEC ENG [40 h]; MECH TECH [80 h]; MECH DES [5 h]; SR STAFF [10 h] |
| 1311122075 | Receive and Inspect Cavities 51 Thru 56 | 2011-03-30 → 2011-01-24 A (-65d) | 2011-04-19 → 2011-01-31 A (-78d) | 15d → 6d | 0% → 100% | 111d → none |  | resources SR STAFF [30 h]; MECH ENG [39 h]; SCIENTIST [48 h]; SUPPLIES & MATERIALS; ELEC TECH [30 h]; ELEC ENG [120 h]; MECH TECH [240 h]; MECH DES [15 h] → SUPPLIES & MATERIALS; ELEC TECH [30 h]; ELEC ENG [120 h]; MECH TECH [240 h]; MECH DES [15 h]; SR STAFF [30 h]; MECH ENG [39 h]; SCIENTIST [48 h] |
| 1311122080 | Receive and Inspect Cavities 57 Thru 62 | 2011-04-27 → 2011-03-01 A (-57d) | 2011-05-17 → 2011-03-21 A (-57d) |  | 0% → 100% | 110d → none |  | resources MECH ENG [39 h]; SCIENTIST [48 h]; SUPPLIES & MATERIALS; ELEC TECH [30 h]; MECH TECH [240 h]; MECH DES [15 h]; ELEC ENG [120 h] → MECH TECH [240 h]; MECH DES [15 h]; MECH ENG [39 h]; SCIENTIST [48 h]; SUPPLIES & MATERIALS; ELEC ENG [120 h]; ELEC TECH [30 h] |
| 1311122085 | Receive and Inspect Cavities 63 and 64 | 2011-05-25 → 2011-04-01 A (-54d) | 2011-06-01 → 2011-04-18 A (-44d) | 5d → 12d | 0% → 100% | 105d → none |  | resources ELEC TECH [10 h]; MECH TECH [80 h]; MECH DES [5 h]; MECH ENG [13 h]; SCIENTIST [16 h]; SUPPLIES & MATERIALS; ELEC ENG [40 h] → MECH ENG [13 h]; SCIENTIST [16 h]; SUPPLIES & MATERIALS; ELEC TECH [10 h]; MECH TECH [80 h]; MECH DES [5 h]; ELEC ENG [40 h] |
| 1311122087 | Receive and Inspect Cavities 65 thru 68 | 2011-06-02 → 2011-05-02 A (-31d) | 2011-06-15 → 2011-05-16 A (-30d) | 10d → 11d | 0% → 100% | 109d → none |  | resources MECH ENG [26 h]; ELEC TECH [20 h]; MECH TECH [160 h]; ELEC ENG [80 h]; SCIENTIST [32 h]; SUPPLIES & MATERIALS → ELEC TECH [20 h]; MECH TECH [160 h]; ELEC ENG [80 h]; SCIENTIST [32 h]; SUPPLIES & MATERIALS; MECH ENG [26 h] |
| 1311122090 | Receive and Inspect Cavities 69 Thru 72 | 2011-08-01 → 2011-06-01 A (-61d) | 2011-08-12 → 2011-06-15 A (-58d) | 10d → 11d | 0% → 100% | 98d → none | 1311122087, 1311121075 FS-5d, 1311121076 FS-5d, 1317010 → 1311122087, 1311121075 FS-5d, 1311121076 FS-5d | resources ELEC ENG [80 h]; SCIENTIST [32 h]; MECH ENG [26 h]; ELEC TECH [20 h]; MECH TECH [160 h]; SUPPLIES & MATERIALS → MECH TECH [160 h]; SCIENTIST [32 h]; ELEC ENG [80 h]; SUPPLIES & MATERIALS; MECH ENG [26 h]; ELEC TECH [20 h] |
| 1311122092 | Receive and Inspect Cavities 73 and 74 | 2011-08-15 → 2011-06-18 A (-58d) | 2011-08-19 → 2011-06-22 A (-58d) | 5d → 3d | 0% → 100% | 98d → none |  | resources MECH ENG [13 h]; MECH TECH [80 h]; SCIENTIST [16 h]; SUPPLIES & MATERIALS; ELEC TECH [10 h]; ELEC ENG [40 h] → SUPPLIES & MATERIALS; MECH ENG [13 h]; ELEC TECH [10 h]; MECH TECH [80 h]; ELEC ENG [40 h]; SCIENTIST [16 h] |
| 1311122095 | Receive and Inspect Cavities 75 Thru 80 | 2011-08-22 → 2011-07-01 A (-52d) | 2011-09-12 → 2011-07-19 A (-55d) | 15d → 12d | 0% → 100% | 98d → none |  | resources SCIENTIST [48 h]; SUPPLIES & MATERIALS; MECH ENG [39 h]; ELEC TECH [30 h]; MECH TECH [240 h]; ELEC ENG [120 h] → SUPPLIES & MATERIALS; MECH ENG [39 h]; ELEC TECH [30 h]; MECH TECH [240 h]; ELEC ENG [120 h]; SCIENTIST [48 h] |
| 1311122100 | Receive and Inspect Cavities 81 Thru 86 FY11 | 2011-09-13 → 2011-07-11 A (-64d) | 2011-09-30 → 2011-08-22 A (-39d) | 14d → 31d | 0% → 100% | 98d → none |  | resources SCIENTIST [44.8 h]; MECH ENG [48.53 h]; ELEC TECH [37.33 h]; MECH TECH [224 h]; SUPPLIES & MATERIALS; ELEC ENG [112 h] → SUPPLIES & MATERIALS; MECH ENG [48.53 h]; ELEC TECH [37.33 h]; MECH TECH [224 h]; SCIENTIST [44.8 h]; ELEC ENG [112 h] |
| 1311122100a | Receive and Inspect Cavities 81 Thru 86 FY12 | 2011-10-03 → 2011-07-11 A (-84d) | 2011-10-03 → 2011-08-22 A (-42d) | 1d → 31d | 0% → 100% | 98d → none |  | resources ELEC ENG [8 h]; SCIENTIST [3.2 h]; MECH ENG [3.47 h]; ELEC TECH [2.67 h]; MECH TECH [16 h]; SUPPLIES & MATERIALS → ELEC ENG [8 h]; MECH ENG [3.47 h]; ELEC TECH [2.67 h]; MECH TECH [16 h]; SUPPLIES & MATERIALS; SCIENTIST [3.2 h] |
| 1311122105M | All Cavities Recieved and Inspected | 2011-10-03 → 2011-08-22 A (-42d) | 2011-10-03 → 2011-08-22 A (-42d) |  | 0% → 100% | 130d → none | 1311122092, 1311122070, 1311122027, 131111020B, 1311121101LOE, 1311122080, 131111012A, 1311122087, 1311122065, 1311122100a, 131111013A, 1311122005, 1311122015, 1311122030, 1311122090, 1311122020, 1311122010, 1311122022, 131111015, 131111020, 131111020A, 1311121015LOEc, 1311122025, 1311122067, 131111013, 131111012, 1311122075, 1311122035, 1311122072, 1311122085, 1311122095, 131111011LOEb → 1311122100, 1311122027, 1311122072, 1311122025, 1311122085, 1311122095, 1311122087, 131111013, 131111015, 131111020A, 1311122092, 1311122070, 1311122022, 1311122030, 131111011LOEb FF, 1311122015, 1311122090, 1311122100a, 1311121101LOE FS-30d, 131111020B, 1311122035 FF, 1311122065, 1311121015LOEb, 1311121015LOEc, 131111012 FF, 131111013A, 131111020, 1311122020, 1311122075 FF, 131111012A, 1311122010, 1311122005, 1311122080, 1311122067 |  |
| 3 | **1.3.1.1.1.3 WAVEGUIDES** | 2009-01-05 → 2009-01-26 (+21d) |  |  |  |  |  |  |
| 131113000 | Re-Baseline Actuals Adjustment | 2013-08-30 A | 2013-08-30 A |  | 0% → 100% | 20d → none | 9-130M FS+227d → none |  |
| 1311131010 | Proc Waveguides | 2009-01-05 → 2009-01-26 A (+21d) | 2009-01-05 → 2009-04-30 A (+115d) | 1d → 68d | 0% → 100% | 363d → none | 9-090M FS+60d, 11115005 → 11115005 FS-250d, 9-090M FS+60d | resources MECH ENG [40 h]; MECH DES [80 h] → MECH DES [80 h]; MECH ENG [40 h] |
| 1311131015 | Waveguides Labor Initial | 2009-01-06 → 2009-05-01 A (+115d) | 2009-05-29 → 2009-09-15 A (+109d) | 101d → 95d | 0% → 100% | 379d → none |  | resources TRAVEL; ELEC ENG [60 h]; MECH DES [80 h]; MECH ENG [100 h]; SR STAFF [40 h]; SUPPLIES & MATERIALS → MECH ENG [100 h]; SR STAFF [40 h]; SUPPLIES & MATERIALS; TRAVEL; ELEC ENG [60 h]; MECH DES [80 h] |
| 1311131020 | Vend Fab Waveguides 1 thru 10 | 2009-06-01 → 2009-05-01 A (-31d) | 2009-12-15 → 2010-01-18 A (+34d) | 138d → 175d | 0% → 100% | 234d → none |  |  |
| 1311131025 | Vend Fab Waveguides 11 thru 30 | 2009-06-01 → 2009-05-01 A (-31d) | 2010-02-22 → 2010-05-24 A (+91d) | 179d → 264d | 0% → 100% | 213d → none | 9-090M FS+162d → 1311131020 FS-73d |  |
| 1311131030 | Vend Fab Waveguides 31 thru 40 | 2009-06-01 → 2009-05-01 A (-31d) | 2010-05-03 → 2010-07-30 A (+88d) | 229d → 311d | 0% → 100% | 342d → none | 9-090M FS+162d → 1311131025 FS-114d |  |
| 1311131035 | Vend Fab Waveguides 41 thru 50 | 2009-06-01 → 2009-05-01 A (-31d) | 2010-06-01 → 2010-08-23 A (+83d) | 249d → 327d | 0% → 100% | 368d → none | 9-090M FS+162d → 1311131030 FS-164d | resources PROCUREMENT>$50K 69 NO ESCALATION; PROCUREMENT<$50K 60 NO ESCALATION → PROCUREMENT<$50K 60 NO ESCALATION; PROCUREMENT>$50K 69 NO ESCALATION |
| 1311131040 | Vend Fab Waveguides 51 thru 60 | 2009-06-01 → 2009-05-01 A (-31d) | 2010-07-01 → 2010-11-30 A (+152d) | 271d → 395d | 0% → 100% | 366d → none | 9-090M FS+162d → 1311131035 FS-184d |  |
| 1311131045 | Vend Fab Waveguides 61 thru 70 | 2009-06-01 → 2009-05-01 A (-31d) | 2010-08-02 → 2011-02-28 A (+210d) | 292d → 451d | 0% → 100% | 365.5d → none | 9-090M FS+162d → 1311131040 FS-206d |  |
| 1311131050 | Vend Fab Waveguides 71 thru 80 | 2009-06-01 → 2009-05-01 A (-31d) | 2010-09-01 → 2011-04-25 A (+236d) | 314d → 491d | 0% → 100% | 364d → none | 9-090M FS+162d → 1311131045 FS-227d | resources PROCUREMENT<$50K 60 NO ESCALATION; PROCUREMENT>$50K 69 NO ESCALATION → PROCUREMENT>$50K 69 NO ESCALATION; PROCUREMENT<$50K 60 NO ESCALATION |
| 1311131055 | Vend Fab Waveguides 81 thru 88 | 2009-06-01 → 2009-05-01 A (-31d) | 2010-10-01 → 2011-06-20 A (+262d) | 335d → 530d | 0% → 100% | 363d → none | 9-090M FS+162d → 1311131050 FS-249d | resources PROCUREMENT>$50K 69 NO ESCALATION; PROCUREMENT<$50K 60 NO ESCALATION → PROCUREMENT<$50K 60 NO ESCALATION; PROCUREMENT>$50K 69 NO ESCALATION |
| 1311131015LOE | Waveguides Labor Final FY09 | 2009-06-01 → 2009-07-01 A (+30d) | 2009-09-30 A | 86d → 64d | 0% → 100% | 379d → none | 1311131015 → 1311131015 FS-200d | resources SR STAFF [10.3 h]; TRAVEL; ELEC ENG [15.45 h]; MECH DES [20.6 h]; MECH ENG [25.75 h] → ELEC ENG [15.45 h]; MECH DES [20.6 h]; MECH ENG [25.75 h]; SR STAFF [10.3 h]; TRAVEL |
| 1311131015LOEb | Waveguides Labor Final FY10 | 2009-10-01 A | 2010-09-30 A |  | 0% → 100% | 379d → none |  |  |
| 1311131060 | Exchange Rate | 2010-06-30 → 2010-07-01 A (+1d) | 2010-10-01 → 2011-09-11 A (+345d) | 66d → 297d | 0% → 100% | 363d → none | 1311131010 FS+370d → 1311131010 |  |
| 2 | **1.3.1.1.1.3.2 WAVEGUIDES RECEIVE AND INSPECT** | 2009-12-16 → 2010-01-18 (+33d) | 2010-10-22 → 2011-09-30 (+343d) |  |  |  |  |  |
| 1311132010 | Receive & Insp Waveguides 1 thru 8 | 2009-12-16 → 2010-01-18 A (+33d) | 2010-01-13 → 2010-02-19 A (+37d) | 15d → 23d | 0% → 100% | 234d → none |  | resources MECH DES [96 h]; SR STAFF [64 h]; MECH ENG [64 h]; COMP SCIENT [32 h]; ELEC ENG [96 h]; SUPPLIES & MATERIALS; ELEC TECH [32 h]; MECH TECH [128 h] → MECH DES [96 h]; MECH ENG [64 h]; COMP SCIENT [32 h]; ELEC ENG [96 h]; SR STAFF [64 h]; SUPPLIES & MATERIALS; ELEC TECH [32 h]; MECH TECH [128 h] |
| 1311132015 | Receive & Insp Waveguides 9 & 10 | 2010-01-14 → 2010-02-01 A (+18d) | 2010-01-21 → 2010-02-26 A (+36d) | 5d → 19d | 0% → 100% | 234d → none |  | resources SR STAFF [16 h]; SUPPLIES & MATERIALS; MECH DES [24 h]; MECH ENG [16 h]; MECH TECH [32 h]; COMP SCIENT [8 h]; ELEC ENG [24 h]; ELEC TECH [8 h] → COMP SCIENT [8 h]; ELEC ENG [24 h]; SUPPLIES & MATERIALS; MECH DES [24 h]; MECH ENG [16 h]; ELEC TECH [8 h]; MECH TECH [32 h]; SR STAFF [16 h] |
| 1311132020 | Receive & Insp Waveguides 11 thru 16 | 2010-02-23 → 2010-02-18 A (-5d) | 2010-03-15 → 2010-04-21 A (+37d) | 15d → 45d | 0% → 100% | 213d → none | 1311132015, 1311131025 → 1311131025 FS-15d, 1311132015 |  |
| 1311132025 | Receive & Insp Waveguides 17 Thru 20 | 2010-03-16 → 2010-04-05 A (+20d) | 2010-03-29 → 2010-04-27 A (+29d) | 10d → 17d | 0% → 100% | 342d → none |  | resources MECH ENG [32 h]; ELEC TECH [16 h]; MECH TECH [64 h]; ELEC ENG [32 h]; SR STAFF [32 h]; SUPPLIES & MATERIALS; MECH DES [16 h]; COMP SCIENT [16 h] → MECH TECH [64 h]; COMP SCIENT [16 h]; ELEC ENG [32 h]; SR STAFF [32 h]; SUPPLIES & MATERIALS; MECH DES [16 h]; MECH ENG [32 h]; ELEC TECH [16 h] |
| 1311132030 | Receive & Insp Waveguides 21 thru 24 | 2010-03-30 → 2010-04-26 A (+27d) | 2010-04-12 → 2010-06-21 A (+70d) | 10d → 40d | 0% → 100% | 342d → none |  | resources MECH TECH [64 h]; MECH ENG [32 h]; COMP SCIENT [14.4 h]; ELEC ENG [32 h]; SUPPLIES & MATERIALS; MECH DES [16 h]; ELEC TECH [16 h] → MECH DES [16 h]; ELEC TECH [16 h]; MECH TECH [64 h]; MECH ENG [32 h]; COMP SCIENT [14.4 h]; ELEC ENG [32 h]; SUPPLIES & MATERIALS |
| 1311132035 | Receive & Insp Waveguides 25 thru 30 | 2010-04-13 → 2010-06-15 A (+63d) | 2010-05-03 → 2010-07-30 A (+88d) | 15d → 33d | 0% → 100% | 342d → none |  |  |
| 1311132040 | Receive & Insp Waveguides 31 and 32 | 2010-05-04 → 2010-08-02 A (+90d) | 2010-05-10 → 2010-08-09 A (+91d) | 5d → 6d | 0% → 100% | 342d → none |  | resources ELEC TECH [8 h]; MECH ENG [16 h]; MECH TECH [32 h]; MECH DES [3.2 h]; SUPPLIES & MATERIALS → MECH TECH [32 h]; SUPPLIES & MATERIALS; MECH DES [3.2 h]; MECH ENG [16 h]; ELEC TECH [8 h] |
| 1311132045 | Receive & Insp Waveguides 33 thru 40 | 2010-05-11 → 2010-08-09 A (+90d) | 2010-06-01 → 2010-08-16 A (+76d) | 15d → 6d | 0% → 100% | 357d → none |  | resources MECH TECH [128 h]; SUPPLIES & MATERIALS; MECH DES [12.8 h]; MECH ENG [64 h]; ELEC TECH [32 h] → MECH DES [12.8 h]; MECH ENG [64 h]; ELEC TECH [32 h]; MECH TECH [128 h]; SUPPLIES & MATERIALS |
| 1311132050 | Receive & Insp Waveguides 41 thru 48 | 2010-06-02 → 2010-08-23 A (+82d) | 2010-06-22 → 2010-08-25 A (+64d) | 15d → 3d | 0% → 100% | 368d → none |  | resources MECH ENG [25.6 h]; ELEC TECH [32 h]; MECH TECH [128 h]; SUPPLIES & MATERIALS; MECH DES [12.8 h] → MECH DES [12.8 h]; MECH ENG [25.6 h]; ELEC TECH [32 h]; MECH TECH [128 h]; SUPPLIES & MATERIALS |
| 1311132055 | Receive & Insp Waveguides 49 and 50 | 2010-06-23 → 2010-09-01 A (+70d) | 2010-06-29 → 2010-09-08 A (+71d) |  | 0% → 100% | 368d → none |  | resources ELEC TECH [8 h]; MECH TECH [32 h]; SUPPLIES & MATERIALS; MECH DES [3.2 h]; MECH ENG [6.4 h] → SUPPLIES & MATERIALS; MECH DES [3.2 h]; MECH ENG [6.4 h]; ELEC TECH [8 h]; MECH TECH [32 h] |
| 1311132060 | Receive & Insp Waveguides 51 thru 56 | 2010-07-02 → 2010-09-09 A (+69d) | 2010-07-21 → 2010-09-27 A (+68d) |  | 0% → 100% | 366d → none |  | resources ELEC TECH [24 h]; MECH TECH [96 h]; SUPPLIES & MATERIALS; MECH DES [9.6 h]; MECH ENG [19.2 h] → MECH DES [9.6 h]; MECH ENG [19.2 h]; ELEC TECH [24 h]; MECH TECH [96 h]; SUPPLIES & MATERIALS |
| 1311132065 | Receive & Insp Waveguides 57 thru 60 | 2010-07-22 → 2010-12-10 A (+141d) | 2010-08-02 → 2010-12-23 A (+143d) | 7.5d → 8d | 0% → 100% | 366d → none |  | resources MECH ENG [12.8 h]; ELEC TECH [16 h]; MECH TECH [64 h]; SUPPLIES & MATERIALS; MECH DES [6.4 h] → ELEC TECH [16 h]; MECH TECH [64 h]; SUPPLIES & MATERIALS; MECH DES [6.4 h]; MECH ENG [12.8 h] |
| 1311132070 | Receive & Insp Waveguides 61 thru 64 | 2010-08-03 → 2011-01-10 A (+160d) | 2010-08-12 → 2011-01-17 A (+158d) | 8d → 5d | 0% → 100% | 365.5d → none |  | resources MECH ENG [12.8 h]; ELEC TECH [16 h]; MECH TECH [64 h]; SUPPLIES & MATERIALS; MECH DES [6.4 h] → MECH DES [6.4 h]; MECH ENG [12.8 h]; ELEC TECH [16 h]; MECH TECH [64 h]; SUPPLIES & MATERIALS |
| 1311132075 | Receive & Insp Waveguides 65 thru 70 | 2010-08-13 → 2011-02-01 A (+172d) | 2010-08-31 → 2011-02-28 A (+181d) | 12.5d → 18.5d | 0% → 100% | 365.5d → none |  | resources ELEC TECH [24 h]; MECH TECH [96 h]; SUPPLIES & MATERIALS; MECH DES [9.6 h]; MECH ENG [19.2 h] → MECH TECH [96 h]; SUPPLIES & MATERIALS; MECH ENG [19.2 h]; MECH DES [9.6 h]; ELEC TECH [24 h] |
| 1311132080 | Receive & Insp Waveguides 71 and 72 | 2010-09-02 → 2011-04-20 A (+230d) | 2010-09-09 → 2011-05-07 A (+240d) | 5d → 13d | 0% → 100% | 364d → none |  |  |
| 1311132085 | Receive & Insp Waveguides 73 thru 80 | 2010-09-10 → 2011-05-16 A (+248d) | 2010-09-30 → 2011-05-28 A (+240d) | 15d → 10d | 0% → 100% | 364d → none |  |  |
| 1311132090 | Receive & Insp Waveguides 81 thru 88 | 2010-10-04 → 2011-09-12 A (+343d) | 2010-10-22 → 2011-09-30 A (+343d) |  | 0% → 100% | 363d → none |  |  |
| 1311132100M | All Waveguides Received and Inspected | 2010-10-22 → 2011-09-30 A (+343d) | 2010-10-22 → 2011-09-30 A (+343d) |  | 0% → 100% | 363d → none |  |  |
| 131114010 | Proc Helium Vessels | 2009-03-02 A | 2009-05-29 → 2009-11-09 A (+164d) | 64d → 178d | 0% → 100% | 227d → none |  | resources MECH DES [40 h]; MECH ENG [20 h] → MECH ENG [20 h]; MECH DES [40 h] |
| 131114015LOE | Helium Vessels Labor Final FY09 | 2009-06-02 → 2009-07-01 A (+29d) | 2009-09-30 A | 85d → 63d | 0% → 100% | 266d → none |  |  |
| 131114015 | Helium Vessels Labor Initial | 2009-05-29 → 2009-09-21 A (+115d) | 2009-06-01 → 2009-09-24 A (+115d) | 2d → 4d | 0% → 100% | 266d → none | 131114010 FS-1d → 131114010 FS-125d |  |
| 131114015LOEb | Helium Vessels Labor Final FY10 | 2009-10-01 A | 2010-08-11 A |  | 0% → 100% | 266d → none |  |  |
| 131114016 | Vend Fab - Helium Vessels 1 & 2 | 2009-06-01 → 2009-11-23 A (+175d) | 2009-08-10 → 2010-07-30 A (+354d) | 50d → 168d | 0% → 100% | 286d → none |  |  |
| 131114017 | Vend Fab - Helium Vessels 3 Thru 8 | 2009-06-01 → 2009-11-23 A (+175d) | 2009-08-31 → 2010-07-30 A (+333d) | 65d → 168d | 0% → 100% | 281d → none |  |  |
| 131114020 | Vend Fab - Helium Vessels 9 Thru 16 | 2009-06-01 → 2009-11-23 A (+175d) | 2009-09-22 → 2010-10-18 A (+391d) | 80d → 223d | 0% → 100% | 291d → none | 131114010 → 131114017 FS-500d, 131114010 |  |
| 131114025 | Vend Fab - Helium Vessels 17 Thru 24 | 2009-06-01 → 2009-11-23 A (+175d) | 2009-10-13 → 2010-12-23 A (+436d) | 95d → 267d | 0% → 100% | 366d → none | 131114010 → 131114010, 131114020 FS-500d |  |
| 131114030 | Vend Fab - Helium Vessels 25 Thru 32 | 2009-06-01 → 2009-11-23 A (+175d) | 2009-11-03 → 2011-01-14 A (+437d) | 110d → 279d | 0% → 100% | 389d → none | 131114010 → 131114025 FS-500d, 131114010 |  |
| 131114035 | Vend Fab - Helium Vessels 33 Thru 40 | 2009-06-01 → 2009-11-23 A (+175d) | 2009-11-24 → 2011-02-28 A (+461d) | 125d → 308d | 0% → 100% | 400d → none | 131114010 → 131114030 FS-500d, 131114010 | resources PROCUREMENT<$50K 60 NO ESCALATION FY10; PROCUREMENT>$50K 69 NO ESCALATION FY10 → PROCUREMENT>$50K 69 NO ESCALATION FY10; PROCUREMENT<$50K 60 NO ESCALATION FY10 |
| 131114040 | Vend Fab - Helium Vessels 41 Thru 48 | 2009-06-01 → 2009-11-23 A (+175d) | 2009-12-17 → 2011-02-28 A (+438d) | 140d → 308d | 0% → 100% | 409d → none | 131114010 → 131114010, 131114035 FS-500d | resources PROCUREMENT>$50K 69 NO ESCALATION FY10; PROCUREMENT<$50K 60 NO ESCALATION FY10 → PROCUREMENT<$50K 60 NO ESCALATION FY10; PROCUREMENT>$50K 69 NO ESCALATION FY10 |
| 131114045 | Vend Fab - Helium Vessels 49 Thru 56 | 2009-06-01 → 2009-11-23 A (+175d) | 2010-02-16 → 2011-03-28 A (+405d) | 175d → 328d | 0% → 100% | 398d → none | 131114010 → 131114010, 131114040 FS-500d | resources PROCUREMENT<$50K 60 NO ESCALATION FY10; PROCUREMENT>$50K 69 NO ESCALATION FY10 → PROCUREMENT>$50K 69 NO ESCALATION FY10; PROCUREMENT<$50K 60 NO ESCALATION FY10 |
| 131114050 | Vend Fab - Helium Vessels 57 Thru 64 | 2009-06-01 → 2009-11-23 A (+175d) | 2010-03-09 → 2011-04-25 A (+412d) | 190d → 348d | 0% → 100% | 407d → none | 131114010 → 131114010, 131114045 FS-500d | resources PROCUREMENT>$50K 69 NO ESCALATION FY10; PROCUREMENT<$50K 60 NO ESCALATION FY10 → PROCUREMENT<$50K 60 NO ESCALATION FY10; PROCUREMENT>$50K 69 NO ESCALATION FY10 |
| 131114055 | Vend Fab - Helium Vessels 65 Thru 72 | 2009-06-01 → 2009-11-23 A (+175d) | 2010-03-30 → 2011-04-25 A (+391d) | 205d → 348d | 0% → 100% | 447d → none | 131114010 → 131114050 FS-500d, 131114010 | resources PROCUREMENT>$50K 69 NO ESCALATION FY10; PROCUREMENT<$50K 60 NO ESCALATION FY10 → PROCUREMENT<$50K 60 NO ESCALATION FY10; PROCUREMENT>$50K 69 NO ESCALATION FY10 |
| 131114060 | Vend Fab - Helium Vessels 73 Thru 80 | 2009-06-01 → 2009-11-23 A (+175d) | 2010-04-20 → 2011-05-23 A (+398d) | 220d → 368d | 0% → 100% | 451d → none | 131114010 → 131114055 FS-500d, 131114010 | resources PROCUREMENT<$50K 60 NO ESCALATION FY10; PROCUREMENT>$50K 69 NO ESCALATION FY10 → PROCUREMENT>$50K 69 NO ESCALATION FY10; PROCUREMENT<$50K 60 NO ESCALATION FY10 |
| 131114065 | Vend Fab - Helium Vessels 81 Thru 90 | 2009-06-01 → 2009-11-23 A (+175d) | 2010-05-11 → 2011-06-20 A (+405d) | 235d → 387d | 0% → 100% | 441d → none | 131114010 → 131114010, 131114060 FS-500d |  |
| 131114070 | Receive & Insp Helium Vessels 1 & 2 | 2009-08-11 → 2010-06-15 A (+308d) | 2009-08-24 → 2010-07-26 A (+336d) | 10d → 29d | 0% → 100% | 286d → none |  | resources MECH TECH [12 h]; MECH DES [8 h]; SUPPLIES & MATERIALS; MECH ENG [8 h] → MECH ENG [8 h]; MECH TECH [12 h]; MECH DES [8 h]; SUPPLIES & MATERIALS |
| 131114130 | Vend Fab 10 CFR 851 Compliance | 2010-07-01 A | 2011-03-31 → 2011-07-05 A (+96d) | 184d → 250d | 0% → 100% | 227d → none | 131114010 FS+270d → 131114010 FS+120d |  |
| 131114075 | Receive & Insp Helium Vessels 3 Thru 8 | 2009-09-01 → 2010-07-19 A (+321d) | 2009-09-08 → 2010-07-30 A (+325d) | 5d → 10d | 0% → 100% | 281d → none |  |  |
| 131114015LOEc | SOTR Oversight FY11 | 2010-10-01 A | 2011-03-25 A |  | 0% → 100% | 231d → none |  |  |
| 131114080 | Receive & Insp Helium Vessels 9 Thru 16 | 2009-09-23 → 2010-10-01 A (+373d) | 2009-09-29 → 2010-10-18 A (+384d) | 5d → 12d | 0% → 100% | 291d → none |  | resources MECH DES [17.6 h]; MECH TECH [48 h]; MECH ENG [32 h]; SUPPLIES & MATERIALS → SUPPLIES & MATERIALS; MECH DES [17.6 h]; MECH ENG [32 h]; MECH TECH [48 h] |
| 131114085 | Receive & Insp Helium Vessels 17 thru 24 | 2009-10-14 → 2011-01-04 A (+447d) | 2009-10-20 → 2011-01-11 A (+448d) | 5d → 6d | 0% → 100% | 366d → none |  | resources SUPPLIES & MATERIALS; MECH DES [12.8 h]; MECH TECH [48 h]; MECH ENG [20.8 h] → MECH ENG [20.8 h]; SUPPLIES & MATERIALS; MECH DES [12.8 h]; MECH TECH [48 h] |
| 131114090 | Receive & Insp Helium Vessels 25 Thru 32 | 2009-11-04 → 2011-02-01 A (+454d) | 2009-11-10 → 2011-02-28 A (+475d) | 5d → 19d | 0% → 100% | 389d → none |  | resources SUPPLIES & MATERIALS; MECH DES [12.8 h]; MECH TECH [48 h]; MECH ENG [21.81 h] → MECH ENG [21.81 h]; SUPPLIES & MATERIALS; MECH DES [12.8 h]; MECH TECH [48 h] |
| 131114095 | Receive & Insp Helium Vessels 33 Thru 40 | 2009-11-25 → 2011-02-01 A (+433d) | 2009-12-03 → 2011-02-28 A (+452d) | 5d → 19d | 0% → 100% | 400d → none |  | resources MECH TECH [48 h]; MECH DES [12.8 h]; MECH ENG [9.6 h]; SUPPLIES & MATERIALS → MECH DES [12.8 h]; MECH ENG [9.6 h]; SUPPLIES & MATERIALS; MECH TECH [48 h] |

| ID | Task | Start | Finish | Duration | Complete | Total float | Predecessors | Other |
| --- | --- | --- | --- | --- | --- | --- | --- | --- |
| 131114100 | Receive & Insp Helium Vessels 41 thru 48 | 2009-12-18 → 2011-03-01 A (+438d) | 2009-12-31 → 2011-03-21 A (+445d) | 5d → 15d | 0% → 100% | 409d → none |  | resources MECH DES [12.8 h]; MECH ENG [9.6 h]; SUPPLIES & MATERIALS; MECH TECH [48 h] → SUPPLIES & MATERIALS; MECH TECH [48 h]; MECH DES [12.8 h]; MECH ENG [9.6 h] |
| 131114105 | Receive & Insp Helium Vessels 49 Thru 56 | 2010-02-17 → 2011-03-01 A (+377d) | 2010-02-23 → 2011-03-21 A (+391d) | 5d → 15d | 0% → 100% | 398d → none |  | resources MECH TECH [48 h]; MECH ENG [9.6 h]; SUPPLIES & MATERIALS; MECH DES [12.8 h] → MECH DES [12.8 h]; MECH ENG [9.6 h]; SUPPLIES & MATERIALS; MECH TECH [48 h] |
| 131114110 | Receive & Insp Helium Vessels 57 Thru 64 | 2010-03-10 → 2011-04-01 A (+387d) | 2010-03-16 → 2011-04-18 A (+398d) | 5d → 12d | 0% → 100% | 407d → none |  | resources MECH TECH [48 h]; MECH ENG [9.6 h]; SUPPLIES & MATERIALS; MECH DES [12.8 h] → SUPPLIES & MATERIALS; MECH DES [12.8 h]; MECH TECH [48 h]; MECH ENG [9.6 h] |
| 131114115 | Receive & Insp Helium Vessels 65 thru 72 | 2010-03-31 → 2011-05-02 A (+397d) | 2010-04-06 → 2011-05-07 A (+396d) |  | 0% → 100% | 447d → none |  | resources MECH ENG [9.6 h]; SUPPLIES & MATERIALS; MECH TECH [48 h]; MECH DES [12.8 h] → MECH DES [12.8 h]; MECH ENG [9.6 h]; SUPPLIES & MATERIALS; MECH TECH [48 h] |
| 131114120 | Receive & Insp Helium Vessels 73 thru 80 | 2010-04-21 → 2011-05-08 A (+382d) | 2010-04-27 → 2011-05-16 A (+384d) | 5d → 6d | 0% → 100% | 451d → none |  | resources MECH ENG [9.6 h]; SUPPLIES & MATERIALS; MECH TECH [48 h]; MECH DES [12.8 h] → MECH DES [12.8 h]; MECH ENG [9.6 h]; SUPPLIES & MATERIALS; MECH TECH [48 h] |
| 131114125 | Receive & Insp Helium Vessels 81 Thru 90 | 2010-05-12 → 2011-07-01 A (+415d) | 2010-05-18 → 2011-07-05 A (+413d) | 5d → 2d | 0% → 100% | 441d → none |  | resources MECH ENG [9.6 h]; SUPPLIES & MATERIALS; MECH TECH [48 h]; MECH DES [12.8 h] → MECH TECH [48 h]; MECH DES [12.8 h]; MECH ENG [9.6 h]; SUPPLIES & MATERIALS |
| 131114130M | All Helium Vessels Received and Inspected | 2011-03-31 → 2011-07-05 A (+96d) | 2011-03-31 → 2011-07-05 A (+96d) |  | 0% → 100% | 227d → none |  |  |
| 131114135 | Re-Baseline Actuals Adjustment | 2013-08-30 A | 2013-08-30 A |  | 0% → 100% | 20d → none | 9-130M FS+227d → none |  |
| 5 | **1.3.1.1.1.5 HARDWARE** | 2009-03-02 → 2009-09-01 (+183d) |  |  |  |  |  |  |
| 131115010 | Proc Hardware | 2009-03-02 → 2009-09-01 A (+183d) | 2009-05-01 → 2010-09-24 A (+511d) | 45d → 265d | 0% → 100% | 356d → none |  | resources MECH ENG [40 h]; MECH DES [40 h] → MECH DES [40 h]; MECH ENG [40 h] |
| 131115012 | Vend Fab - Hardware (Phase 1) | 2009-05-01 → 2009-12-28 A (+241d) | 2009-06-12 → 2010-02-15 A (+248d) | 30d → 33d | 0% → 100% | 356d → none | 131115010 FS-1d → 131115010 FS-250d | resources MECH TECH [20 h]; MECH ENG [20 h]; PROCUREMENT<$50K 60; MECH DES [20 h] → PROCUREMENT<$50K 60; MECH DES [20 h]; MECH ENG [20 h]; MECH TECH [20 h] |
| 131115013 | Vend Fab - Hardware (Phase 2) | 2009-06-15 → 2010-02-08 A (+238d) | 2009-07-28 → 2010-09-24 A (+423d) | 31d → 161d | 0% → 100% | 539d → none |  | resources PROCUREMENT<$50K 60; MECH DES [20 h]; MECH TECH [20 h]; MECH ENG [20 h] → PROCUREMENT<$50K 60; MECH DES [20 h]; MECH ENG [20 h]; MECH TECH [20 h] |
| 131115015 | Receive & Insp Hardware (Phase 1) | 2009-06-29 → 2010-05-24 A (+329d) | 2009-07-21 → 2010-05-26 A (+309d) | 16d → 3d | 0% → 100% | 356d → none |  | resources MECH TECH [40 h]; MECH ENG [20 h]; MECH DES [20 h] → MECH ENG [20 h]; MECH TECH [40 h]; MECH DES [20 h] |
| 131115016 | Receive & Insp Hardware (Phase 2) | 2009-08-12 → 2010-09-13 A (+397d) | 2009-09-02 → 2010-09-28 A (+391d) | 16d → 12d | 0% → 100% | 539d → none | 131115013 FS+10d → 131115013 | resources MECH TECH [40 h]; MECH ENG [20 h]; MECH DES [20 h] → MECH DES [20 h]; MECH ENG [20 h]; MECH TECH [40 h] |
| 131115020 | Re-Baseline Actuals Adjustment | 2013-08-30 A | 2013-08-30 A |  | 0% → 100% | 20d → none | 9-130M FS+227d → none |  |
| 6 | **1.3.1.1.1.6 MISC** | 2009-03-16 → 2009-09-01 (+169d) |  |  |  |  |  |  |
| 131116010 | Proc Misc | 2009-03-16 → 2009-09-01 A (+169d) | 2009-06-01 → 2010-09-30 A (+486d) | 55d → 269d | 0% → 100% | 324d → none |  |  |
| 131116012 | Vend Fab - Misc (Phase 1) | 2009-06-01 → 2009-12-21 A (+203d) | 2009-08-11 → 2010-01-18 A (+160d) | 51d → 14d | 0% → 100% | 324d → none | 131116010 FS-1d → 131116010 FS-200d | resources PROCUREMENT<$50K 60; MECH DES [20 h]; MECH ENG [20 h]; SUPPLIES & MATERIALS; MECH TECH [20 h] → SUPPLIES & MATERIALS; MECH TECH [20 h]; MECH DES [20 h]; MECH ENG [20 h]; PROCUREMENT<$50K 60 |
| 131116013 | Vend Fab - Misc (Phase 2) Labor FY09 | 2009-08-12 → 2009-12-21 A (+131d) | 2009-09-30 → 2010-09-30 A (+365d) | 35d → 193d | 0% → 100% | 487d → none | 131116012 → 131116012 FS-200d | resources MECH ENG [13.73 h]; SUPPLIES & MATERIALS; MECH TECH [13.73 h]; MECH DES [13.73 h] → MECH DES [13.73 h]; MECH ENG [13.73 h]; SUPPLIES & MATERIALS; MECH TECH [13.73 h] |
| 131116013b | Vend Fab - Misc (Phase 2) Labor FY10 | 2009-10-01 → 2009-12-21 A (+81d) | 2009-10-22 → 2010-09-30 A (+343d) | 16d → 193d | 0% → 100% | 487d → none | 131116013 → 131116013 FS-200d | resources MECH ENG [6.27 h]; SUPPLIES & MATERIALS; MECH TECH [6.27 h]; MECH DES [6.27 h] → SUPPLIES & MATERIALS; MECH TECH [6.27 h]; MECH DES [6.27 h]; MECH ENG [6.27 h] |
| 131116013c | Vend Fab - Misc (Phase 2) Procurement | 2009-08-12 → 2010-02-08 A (+180d) | 2009-10-22 → 2010-09-30 A (+343d) | 51d → 165d | 0% → 100% | 487d → none |  |  |
| 131116020 | QC Traveler FY10 | 2010-04-01 A | 2010-09-30 A |  | 0% → 100% | 126d → none |  |  |
| 131116015 | Receive & Insp Misc (Phase 1) | 2009-08-12 → 2010-05-24 A (+285d) | 2009-09-03 → 2010-05-27 A (+266d) | 17d → 4d | 0% → 100% | 324d → none |  | resources MECH TECH [40 h]; MECH ENG [20 h]; MECH DES [20 h] → MECH ENG [20 h]; MECH TECH [40 h]; MECH DES [20 h] |
| 131116016 | Receive & Insp Misc (Phase 2) | 2009-10-23 → 2010-09-15 A (+327d) | 2009-11-16 → 2011-02-28 A (+469d) | 17d → 109d | 0% → 100% | 487d → none |  | resources MECH DES [20 h]; MECH ENG [20 h]; MECH TECH [40 h] → MECH TECH [40 h]; MECH DES [20 h]; MECH ENG [20 h] |
| 131116025 | QC Traveler FY11 | 2010-10-01 A | 2010-12-30 A |  | 0% → 100% | 126d → none |  |  |
| 131116030 | Re-Baseline Actuals Adjustment | 2013-08-30 A | 2013-08-30 A |  | 0% → 100% | 20d → none | 9-130M FS+227d → none |  |
| 131121010 | Proc Space Frames | 2009-02-02 A | 2009-08-03 → 2009-08-31 A (+28d) | 128d → 148d | 0% → 100% | 19d → none | 9-090M, 1211020M5 FS-168d → 1211020M5 FS-168d, 9-090M FS+79d |  |
| 131121010ALOE | Vendor Fab Space Frames Labor FY09 | 2009-08-27 A | 2009-09-30 A |  | 0% → 100% | 476d → none |  | resources SR STAFF [2.5 h]; SUPPLIES & MATERIALS; TRAVEL; MECH DES [5 h]; MECH ENG [7.5 h] → MECH DES [5 h]; MECH ENG [7.5 h]; SR STAFF [2.5 h]; SUPPLIES & MATERIALS; TRAVEL |
| 131121011 | Vend Fab Space Frames 10% of Material Costs | 2009-08-27 A | 2010-01-29 → 2010-02-25 A (+27d) | 102d → 120d | 0% → 100% | 274d → none | 9-090M FS+224d, 131121010 FS-45d → 131121010 FS-45d |  |
| 131121015 | Vend Fab Space Frames 50% of Cost (Fab/Ship) 1st Article | 2009-08-27 A | 2010-03-29 → 2010-05-17 A (+49d) | 142d → 177d | 0% → 100% | 234d → none | 9-090M FS+224d, 131121010 FS-1d → 131121011 FS-99d, 131121010 FS-1d | was named Vend Fab Space Frames 50% OF Cost (Fab/Ship) 1st Article |
| 131121016 | Vend Fab Space Frames 50% of Cost (Fab/Ship) Upon Receipt of 1st Article | 2009-08-27 A | 2010-04-30 → 2010-05-24 A (+24d) | 166d → 182d | 0% → 100% | 210d → none | 9-090M FS+224d → 131121015 FS-139d | was named Vend Fab Space Frames 50% OF Cost (Fab/Ship) Upon Receipt of 1st Article; resources PROCUREMENT>$50K 69 NO ESCALATION; PROCUREMENT<$50K 60 NO ESCALATION → PROCUREMENT<$50K 60 NO ESCALATION; PROCUREMENT>$50K 69 NO ESCALATION |
| 131121016A | Vend Fab Space Frames Production 90% of Material | 2009-08-27 A | 2010-03-31 → 2010-05-24 A (+54d) | 144d → 182d | 0% → 100% | 345d → none | 9-090M FS+224d → 131121016 FS-163d |  |
| 131121016B | Vend Fab Space Frames Deliver Space Frame #2 | 2009-08-27 A | 2010-06-30 → 2010-11-30 A (+153d) | 208d → 313d | 0% → 100% | 195.5d → none | 9-090M FS+224d → 131121016A FS-141d |  |
| 131121016C | Vend Fab Space Frames Deliver Space Frame #3 | 2009-08-27 A | 2010-07-30 → 2010-11-30 A (+123d) | 229d → 313d | 0% → 100% | 260d → none | 9-090M FS+224d → 131121016B FS-205d |  |
| 131121016D | Vend Fab Space Frames Deliver Space Frame #4 | 2009-08-27 A | 2010-08-31 → 2011-01-13 A (+135d) | 251d → 339d | 0% → 100% | 279d → none | 9-090M FS+224d → 131121016C FS-226d |  |
| 131121016F | Vend Fab Space Frames Deliver Space Frame #5 | 2009-08-27 A | 2010-09-30 → 2011-03-07 A (+158d) | 272d → 374d | 0% → 100% | 313d → none | 9-090M FS+224d → 131121016D FS-248d |  |
| 131121016G | Vend Fab Space Frames Deliver Space Frame #6 | 2009-08-27 A | 2010-10-29 → 2011-05-16 A (+199d) | 293d → 424d | 0% → 100% | 345d → none | 9-090M FS+224d → 131121016F FS-269d |  |
| 131121016H | Vend Fab Space Frames Deliver Space Frame #7 | 2009-08-27 A | 2010-11-30 → 2011-07-18 A (+230d) | 313d → 467d | 0% → 100% | 429d → none | 9-090M FS+224d → 131121016G FS-290d |  |
| 131121016J | Vend Fab Space Frames Deliver Space Frame #8 | 2009-08-27 A | 2011-01-31 → 2011-08-15 A (+196d) | 350d → 487d | 0% → 100% | 451d → none | 9-090M FS+224d → 131121016H FS-310d |  |
| 131121016K | Vend Fab Space Frames Deliver Space Frame #9 | 2009-08-27 A | 2011-01-31 → 2011-10-12 A (+254d) | 350d → 528d | 0% → 100% | 496.5d → none | 9-090M FS+224d → 131121016J FS-347d |  |
| 131121016L | Vend Fab Space Frames Deliver Space Frame #10 | 2009-08-27 A | 2011-02-28 → 2011-11-14 A (+259d) | 369d → 551d | 0% → 100% | 500d → none | 9-090M FS+224d → 131121016K FS-347d |  |
| 131121010BLOE | Vendor Fab Space Frames Labor FY10 | 2009-10-01 A | 2010-09-30 A |  | 0% → 100% | 476d → none |  | resources SR STAFF [26.5 h]; SUPPLIES & MATERIALS; TRAVEL; MECH DES [53 h]; MECH ENG [79.6 h] → TRAVEL; MECH DES [53 h]; MECH ENG [79.6 h]; SR STAFF [26.5 h]; SUPPLIES & MATERIALS |
| 131121020 | Receive & Insp Space Frame First Article (Lab Labor) | 2010-05-03 → 2010-05-17 A (+14d) | 2010-05-28 → 2010-06-15 A (+18d) | 20d → 21d | 0% → 100% | 210d → none |  | resources MECH ENG [22.8 h]; MECH TECH [24 h]; SUPPLIES & MATERIALS; MECH DES [15.6 h] → SUPPLIES & MATERIALS; MECH DES [15.6 h]; MECH ENG [22.8 h]; MECH TECH [24 h] |
| 131121040LOE | SOTR Oversight FY10 | 2010-07-01 A | 2010-09-30 A |  | 0% → 100% | 479d → none |  |  |
| 131121010CLOE | Vendor Fab Space Frames Labor FY11 | 2010-10-01 A | 2011-04-29 A |  | 0% → 100% | 476d → none |  | resources SUPPLIES & MATERIALS; TRAVEL; MECH DES [22 h]; MECH ENG [32.9 h]; SR STAFF [11 h] → MECH DES [22 h]; MECH ENG [32.9 h]; SR STAFF [11 h]; SUPPLIES & MATERIALS; TRAVEL |
| 131121045LOE | SOTR Oversight FY11 | 2010-10-01 A | 2011-04-26 A |  | 0% → 100% | 479d → none |  |  |
| 131121021 | Receive & Insp Space Frame #2 | 2010-07-01 → 2010-12-06 A (+158d) | 2010-07-29 → 2011-01-05 A (+160d) | 20d → 17d | 0% → 100% | 195.5d → none |  | resources MECH DES [12.48 h]; MECH ENG [18.24 h]; MECH TECH [19.2 h]; SUPPLIES & MATERIALS → MECH ENG [18.24 h]; MECH TECH [19.2 h]; SUPPLIES & MATERIALS; MECH DES [12.48 h] |
| 131121022 | Receive & Insp Space Frame #3 | 2010-08-02 → 2010-12-06 A (+126d) | 2010-08-27 → 2011-01-06 A (+132d) | 20d → 18d | 0% → 100% | 260d → none |  | resources MECH TECH [16 h]; SUPPLIES & MATERIALS; MECH DES [10.4 h]; MECH ENG [15.2 h] → MECH ENG [15.2 h]; MECH TECH [16 h]; SUPPLIES & MATERIALS; MECH DES [10.4 h] |
| 131121025 | Receive & Insp Space Frame #4 | 2010-09-01 → 2011-01-10 A (+131d) | 2010-09-29 → 2011-02-28 A (+152d) | 20d → 34d | 0% → 100% | 279d → none |  | resources MECH TECH [14.4 h]; MECH DES [9.36 h]; SUPPLIES & MATERIALS; MECH ENG [13.68 h] → MECH TECH [14.4 h]; SUPPLIES & MATERIALS; MECH ENG [13.68 h]; MECH DES [9.36 h] |
| 131121026 | Receive & Insp Space Frame #5 | 2010-10-01 → 2011-03-25 A (+175d) | 2010-10-28 → 2011-04-27 A (+181d) | 20d → 24d | 0% → 100% | 313d → none |  | resources MECH ENG [13.68 h]; MECH TECH [14.4 h]; MECH DES [9.36 h]; SUPPLIES & MATERIALS → MECH DES [9.36 h]; MECH ENG [13.68 h]; MECH TECH [14.4 h]; SUPPLIES & MATERIALS |
| 131121027 | Receive & Insp Space Frame #6 | 2010-11-01 → 2011-05-16 A (+196d) | 2010-11-30 → 2011-05-31 A (+182d) | 20d → 11d | 0% → 100% | 345d → none |  |  |
| 131121028 | Receive & Insp Space Frame #7 | 2010-12-01 → 2011-07-19 A (+230d) | 2011-01-05 → 2011-07-25 A (+201d) | 20d → 5d | 0% → 100% | 429d → none |  | resources SUPPLIES & MATERIALS; MECH ENG [13.68 h]; MECH TECH [14.4 h]; MECH DES [9.36 h] → MECH ENG [13.68 h]; MECH TECH [14.4 h]; MECH DES [9.36 h]; SUPPLIES & MATERIALS |
| 131121029 | Receive & Insp Space Frame #8 | 2011-02-01 → 2011-08-16 A (+196d) | 2011-03-01 → 2011-10-17 A (+230d) | 20d → 44d | 0% → 100% | 451d → none |  | resources MECH ENG [13.68 h]; MECH TECH [14.4 h]; SUPPLIES & MATERIALS; MECH DES [9.36 h] → MECH ENG [13.68 h]; MECH TECH [14.4 h]; MECH DES [9.36 h]; SUPPLIES & MATERIALS |
| 131121030 | Receive & Insp Space Frame #9 | 2011-03-02 → 2011-10-18 A (+230d) | 2011-03-29 → 2011-10-24 A (+209d) | 20d → 5d | 0% → 100% | 476.5d → none |  | resources SUPPLIES & MATERIALS; MECH TECH [14.4 h]; MECH DES [9.36 h]; MECH ENG [13.68 h] → MECH ENG [13.68 h]; SUPPLIES & MATERIALS; MECH DES [9.36 h]; MECH TECH [14.4 h] |
| 131121035 | Receive & Insp Space Frame #10 | 2011-03-30 → 2011-11-14 A (+229d) | 2011-04-26 → 2011-12-19 A (+237d) | 20d → 24d | 0% → 100% | 479d → none |  | resources MECH ENG [13.68 h]; SUPPLIES & MATERIALS; MECH TECH [14.4 h]; MECH DES [9.36 h] → MECH DES [9.36 h]; MECH ENG [13.68 h]; SUPPLIES & MATERIALS; MECH TECH [14.4 h] |
| 131121050 | Re-Baseline Actuals Adjustment | 2013-08-30 A | 2013-08-30 A |  | 0% → 100% | 20d → none | 9-130M FS+227d → none |  |
| 2 | **1.3.1.1.2.2 TUNERS** | 2009-05-01 → 2009-02-09 (-81d) |  |  |  |  |  |  |
| 131122010 | Proc Tuners | 2009-05-01 → 2009-02-09 A (-81d) | 2009-09-01 A | 86d → 144d | 0% → 100% | 274d → none | 9-090M FS+142d → 9-090M | resources MECH DES [32 h]; MECH ENG [16 h] → MECH ENG [16 h]; MECH DES [32 h] |
| 131122015 | Vend Fab - Cold Tuners Lot #1 (Phase 1) FY09 Original Labor | 2009-09-01 → 2009-09-09 A (+8d) | 2009-09-30 → 2009-09-29 A (-1d) | 21d → 15d | 0% → 100% | 318d → none | 131122010 FS-1d → 131122010 FS-66d | resources TRAVEL; MECH DES [3.36 h]; MECH ENG [6.72 h]; SR STAFF [3.36 h]; SUPPLIES & MATERIALS → SR STAFF [3.36 h]; SUPPLIES & MATERIALS; TRAVEL; MECH DES [3.36 h]; MECH ENG [6.72 h] |
| 131122016A | Vend Fab - Cold Tuners - Materials | 2009-09-09 A | 2009-09-30 → 2009-11-30 A (+61d) | 16d → 57d | 0% → 100% | 274d → none | 131122010 FS+4d → 131122010 FS-61d |  |
| 131122016B | Vend Fab - Cold Tuners - First Article | 2009-09-09 A | 2009-10-30 → 2010-02-18 A (+111d) | 38d → 107d | 0% → 100% | 274d → none |  |  |
| 131122016C | Vend Fab - Cold Tuners - 2 thru 10 | 2009-09-09 A | 2010-01-29 → 2010-03-22 A (+52d) | 94d → 129d | 0% → 100% | 274d → none |  |  |
| 131122016D | Vend Fab - Cold Tuners - 11 thru 20 | 2009-09-09 A | 2010-02-26 → 2010-03-29 A (+31d) | 113d → 134d | 0% → 100% | 280d → none |  |  |
| 131122016F | Vend Fab - Cold Tuners - 21 thru 30 | 2009-09-09 A | 2010-03-31 → 2010-08-16 A (+138d) | 136d → 232d | 0% → 100% | 345d → none |  |  |
| 131122016G | Vend Fab - Cold Tuners - 31 thru 40 | 2009-09-09 A | 2010-04-30 → 2010-08-23 A (+115d) | 158d → 237d | 0% → 100% | 354d → none |  |  |
| 131122016H | Vend Fab - Cold Tuners - 41 thru 50 | 2009-09-09 A | 2010-05-28 → 2010-09-20 A (+115d) | 178d → 256d | 0% → 100% | 389d → none |  |  |
| 131122016J | Vend Fab - Cold Tuners - 51 thru 60 | 2009-09-09 A | 2010-06-30 → 2010-09-14 A (+76d) | 200d → 252d | 0% → 100% | 425d → none |  |  |
| 131122016K | Vend Fab - Cold Tuners - 61 thru 70 | 2009-09-09 A | 2010-07-30 → 2010-10-25 A (+87d) | 221d → 281d | 0% → 100% | 513d → none |  |  |
| 131122016L | Vend Fab - Cold Tuners - 71 thru 80 | 2009-09-09 A | 2010-08-31 → 2010-10-25 A (+55d) | 243d → 281d | 0% → 100% | 570d → none |  |  |
| 131122016N | Vend Fab - Cold Tuners - 81 thru 84 | 2009-09-09 A | 2010-09-30 → 2010-10-25 A (+25d) | 264d → 281d | 0% → 100% | 572d → none |  |  |

| ID | Task | Start | Finish | Duration | Complete | Total float | Predecessors | Other |
| --- | --- | --- | --- | --- | --- | --- | --- | --- |
| 131122015A | Vend Fab - Cold Tuners Lot #1 (Phase 1) FY10 Original Labor | 2009-10-01 → 2009-11-02 A (+32d) | 2010-02-01 → 2009-11-30 A (-63d) | 79d → 19d | 0% → 100% | 318d → none |  | resources SR STAFF [12.64 h]; SUPPLIES & MATERIALS; TRAVEL; MECH DES [12.64 h]; MECH ENG [25.28 h] → MECH ENG [25.28 h]; SR STAFF [12.64 h]; SUPPLIES & MATERIALS; MECH DES [12.64 h]; TRAVEL |
| 131122016 | Vend Fab - Cold Tuners Lot #2 & 3 (Phase 2) Original Labor | 2010-02-02 → 2010-02-01 A (-1d) | 2010-07-22 A | 120d → 121d | 0% → 100% | 397d → none | 131122015, 131122015A → 131122015, 131122015A FS+38d | resources TRAVEL; MECH DES [24 h]; MECH ENG [48 h]; SR STAFF [24 h]; SUPPLIES & MATERIALS → SR STAFF [24 h]; SUPPLIES & MATERIALS; TRAVEL; MECH DES [24 h]; MECH ENG [48 h] |
| 131122017 | Receive & Insp First Article Tuner | 2009-11-02 → 2010-02-08 A (+98d) | 2009-11-13 → 2010-03-29 A (+136d) | 10d → 35d | 0% → 100% | 335d → none |  | resources MECH ENG [8 h]; MECH TECH [8 h]; SUPPLIES & MATERIALS; MECH DES [8 h] → MECH DES [8 h]; MECH ENG [8 h]; MECH TECH [8 h]; SUPPLIES & MATERIALS |
| 131122020 | Receive & Insp Tuners Lot #1 2-10 | 2010-02-01 → 2010-03-22 A (+49d) | 2010-02-22 → 2010-03-29 A (+35d) | 15d → 6d | 0% → 100% | 274d → none |  | resources MECH TECH [32 h]; SUPPLIES & MATERIALS; MECH DES [32 h]; MECH ENG [32 h] → SUPPLIES & MATERIALS; MECH DES [32 h]; MECH ENG [32 h]; MECH TECH [32 h] |
| 131122025 | Receive & Insp Tuners Lot #2 11-20 | 2010-03-01 → 2010-03-29 A (+28d) | 2010-03-26 → 2010-04-28 A (+33d) | 20d → 23d | 0% → 100% | 280d → none |  | resources MECH TECH [40 h]; MECH DES [8 h]; SUPPLIES & MATERIALS; MECH ENG [40 h] → MECH DES [8 h]; SUPPLIES & MATERIALS; MECH ENG [40 h]; MECH TECH [40 h] |
| 131122065 | Vend Fab - Warm Tuners Lot # 1(FROZEN) | 2009-10-01 → 2010-04-26 A (+207d) | 2010-06-24 → 2010-07-30 A (+36d) | 180d → 68d | 0% → 100% | 168d → none |  | was named Vend Fab - Warm Tuners Lot # 1; resources PROCUREMENT>$50K 69; PROCUREMENT<$50K 60 → PROCUREMENT<$50K 60; PROCUREMENT>$50K 69 |
| 131122065B | Vend Fab - Warm Tuners Peg Point #1 Receipt of Materials | 2010-05-25 → 2010-05-03 A (-22d) | 2010-07-30 A | 47d → 63d | 0% → 100% | 103d → none | 9-100M FS+158d → 9-100M FS+162d | resources PROCUREMENT>$50K 69 NO ESCALATION; PROCUREMENT<$50K 60 NO ESCALATION → PROCUREMENT<$50K 60 NO ESCALATION; PROCUREMENT>$50K 69 NO ESCALATION |
| 131122065C | Vend Fab - Warm Tuners Peg Point #2 Receipt of Balance of Materials | 2010-05-25 → 2010-05-03 A (-22d) | 2010-08-31 → 2010-08-09 A (-22d) |  | 0% → 100% | 103d → none |  |  |
| 131122065D | Vend Fab - Warm Tuners Peg Point #3 Receipt of R100 Materials | 2010-05-25 → 2010-05-03 A (-22d) | 2010-08-31 → 2010-08-16 A (-15d) | 69d → 74d | 0% → 100% | 103d → none |  |  |
| 131122065F | Vend Fab - Warm Tuners Peg Point #4 Receipt of First Article | 2010-05-25 → 2010-05-03 A (-22d) | 2010-09-30 A | 90d → 106d | 0% → 100% | 103d → none |  |  |
| 131122065G | Vend Fab - Warm Tuners Peg Point #5 Receipt of 1st Production Set | 2010-05-25 → 2010-05-03 A (-22d) | 2010-10-29 → 2010-12-20 A (+52d) | 111d → 161d | 0% → 100% | 103d → none |  |  |
| 131122065H | Vend Fab - Warm Tuners Peg Point #6 Receipt of 2nd Production Set | 2010-05-25 → 2010-05-03 A (-22d) | 2010-11-30 → 2011-01-06 A (+37d) | 131d → 168d | 0% → 100% | 113d → none |  |  |
| 131122065J | Vend Fab - Warm Tuners Peg Point #7 Receipt of 3rd Production Set | 2010-05-25 → 2010-05-03 A (-22d) | 2010-12-30 → 2011-01-21 A (+22d) | 148d → 178d | 0% → 100% | 166d → none |  |  |
| 131122065K | Vend Fab - Warm Tuners Peg Point #8 Receipt of 4th Production Set | 2010-05-25 → 2010-05-03 A (-22d) | 2011-02-28 A | 187d → 203d | 0% → 100% | 166d → none |  |  |
| 131122065L | Vend Fab - Warm Tuners Peg Point #9 Receipt of 5th Production Set | 2010-05-25 → 2010-05-03 A (-22d) | 2011-03-31 → 2011-02-28 A (-31d) | 210d → 203d | 0% → 100% | 203d → none |  |  |
| 131122065N | Vend Fab - Warm Tuners Peg Point #10 Receipt of 6th Production Set | 2010-05-25 → 2010-05-03 A (-22d) | 2011-04-29 → 2011-04-25 A (-4d) | 231d → 243d | 0% → 100% | 255d → none |  |  |
| 131122065P | Vend Fab - Warm Tuners Peg Point #11 Receipt of 7th Production Set | 2010-05-25 → 2010-05-03 A (-22d) | 2011-06-30 → 2011-04-25 A (-66d) | 274d → 243d | 0% → 100% | 310d → none |  |  |
| 131122065Q | Vend Fab - Warm Tuners Peg Point #12 Receipt of 8th Production Set | 2010-05-25 → 2010-05-03 A (-22d) | 2011-07-29 → 2011-05-15 A (-75d) | 294d → 257d | 0% → 100% | 358d → none |  |  |
| 131122065R | Vend Fab - Warm Tuners Peg Point #13 Receipt of R100 Production Set | 2010-05-25 → 2010-05-03 A (-22d) | 2011-08-31 → 2011-04-25 A (-128d) | 317d → 243d | 0% → 100% | 429d → none |  |  |
| 131122065A | Vend Fab - Warm Tuners Lot # 1 Reverse Entry Per CR 10-064 | 2010-07-01 → 2010-07-26 A (+25d) | 2010-07-01 → 2010-07-29 A (+28d) | 1d → 4d | 0% → 100% | 217d → none | 9-100M FS+184d → 9-100M FS+120d |  |
| 131122030 | Receive & Insp Tuners Lot #3 21-30 | 2010-04-01 → 2010-08-16 A (+137d) | 2010-04-28 → 2010-08-23 A (+117d) | 20d → 6d | 0% → 100% | 345d → none |  | resources MECH ENG [12 h]; SUPPLIES & MATERIALS; MECH TECH [40 h]; MECH DES [8 h] → MECH TECH [40 h]; MECH DES [8 h]; MECH ENG [12 h]; SUPPLIES & MATERIALS |
| 131122035 | Receive & Insp Tuners Lot #4 31-40 | 2010-05-03 → 2010-08-23 A (+112d) | 2010-05-28 → 2010-08-30 A (+94d) | 20d → 6d | 0% → 100% | 354d → none |  | resources MECH DES [8 h]; MECH ENG [12 h]; SUPPLIES & MATERIALS; MECH TECH [40 h] → SUPPLIES & MATERIALS; MECH TECH [40 h]; MECH DES [8 h]; MECH ENG [12 h] |
| 131122070 | Recieve & Inspect Warm Tuners - First Article | 2010-10-01 → 2010-09-10 A (-21d) | 2010-10-28 → 2010-09-23 A (-35d) | 20d → 10d | 0% → 100% | 104d → none | 131122065F, 131122065 FS+4d → 131122065F FS-26d, 131122065 FS+4d | resources MECH ENG [40 h]; MECH TECH [80 h] → MECH TECH [80 h]; MECH ENG [40 h] |
| 131122040 | Receive & Insp Tuners Lot #5 41-50 | 2010-06-01 → 2010-09-20 A (+111d) | 2010-06-28 → 2010-10-25 A (+119d) | 20d → 26d | 0% → 100% | 389d → none |  | resources SUPPLIES & MATERIALS; MECH ENG [12 h]; MECH TECH [40 h]; MECH DES [8 h] → MECH DES [8 h]; SUPPLIES & MATERIALS; MECH ENG [12 h]; MECH TECH [40 h] |
| 131122045 | Receive & Insp Tuners Lot #6 51-60 | 2010-07-01 → 2010-09-20 A (+81d) | 2010-07-29 → 2010-10-25 A (+88d) | 20d → 26d | 0% → 100% | 425d → none |  | resources MECH TECH [40 h]; SUPPLIES & MATERIALS; MECH DES [8 h]; MECH ENG [12 h] → SUPPLIES & MATERIALS; MECH DES [8 h]; MECH ENG [12 h]; MECH TECH [40 h] |
| 131122050 | Receive & Insp Tuners Lot #7 61-70 | 2010-08-02 → 2010-11-15 A (+105d) | 2010-08-27 → 2010-11-30 A (+95d) | 20d → 10d | 0% → 100% | 513d → none |  | resources MECH DES [8 h]; MECH ENG [12 h]; SUPPLIES & MATERIALS; MECH TECH [40 h] → MECH DES [8 h]; SUPPLIES & MATERIALS; MECH TECH [40 h]; MECH ENG [12 h] |
| 131122055 | Receive & Insp Tuners Lot #8 71-80 | 2010-09-01 → 2010-12-03 A (+93d) | 2010-09-29 → 2010-12-14 A (+76d) | 20d → 8d | 0% → 100% | 570d → none |  | resources MECH DES [8 h]; MECH ENG [12 h]; SUPPLIES & MATERIALS; MECH TECH [40 h] → SUPPLIES & MATERIALS; MECH TECH [40 h]; MECH DES [8 h]; MECH ENG [12 h] |
| 131122075 | Recieve & Inspect Warm Tuners - 1st Production Set | 2010-11-01 → 2010-12-06 A (+35d) | 2010-11-30 → 2011-01-05 A (+36d) | 20d → 17d | 0% → 100% | 103d → none | 131122065G, 131122070 → 131122070, 131122065G FS-26d |  |
| 131122060 | Receive & Insp Tuners Lot #9 81-84 | 2010-10-01 → 2010-12-15 A (+75d) | 2010-10-28 → 2010-12-23 A (+56d) | 20d → 5d | 0% → 100% | 572d → none |  |  |
| 131122080 | Recieve & Inspect Warm Tuners - 2nd Production Set | 2010-12-01 → 2011-01-06 A (+36d) | 2011-01-05 → 2011-01-28 A (+23d) | 20d → 16d | 0% → 100% | 113d → none | 131122065H, 131122065A → 131122065H FS-26d, 131122065A |  |
| 131122085 | Recieve & Inspect Warm Tuners - 3rd Production Set | 2011-01-06 → 2011-01-31 A (+25d) | 2011-02-03 → 2011-02-28 A (+25d) |  | 0% → 100% | 186d → none | 131122080, 131122065J → 131122080, 131122065J FS-26d |  |
| 131122090 | Recieve & Inspect Warm Tuners - 4th Production Set | 2011-03-01 → 2011-02-01 A (-28d) | 2011-03-28 → 2011-02-28 A (-28d) | 20d → 19d | 0% → 100% | 166d → none | 131122065B, 131122065K → 131122065K FS-26d, 131122065B | resources MECH TECH [40 h]; MECH ENG [24 h] → MECH ENG [24 h]; MECH TECH [40 h] |
| 131122095 | Recieve & Inspect Warm Tuners - 5th Production Set | 2011-04-01 → 2011-02-01 A (-59d) | 2011-04-28 → 2011-03-28 A (-31d) | 20d → 39d | 0% → 100% | 203d → none | 131122065L, 131122090 → 131122065L FS-26d, 131122090 |  |
| 131122100 | Recieve & Inspect Warm Tuners - 6th Production Set | 2011-05-02 → 2011-04-02 A (-30d) | 2011-05-27 → 2011-04-25 A (-32d) | 20d → 16d | 0% → 100% | 255d → none |  |  |
| 131122105 | Recieve & Inspect Warm Tuners - 7th Production Set | 2011-07-01 → 2011-04-20 A (-72d) | 2011-07-29 → 2011-05-28 A (-62d) | 20d → 28d | 0% → 100% | 310d → none |  |  |
| 131122110 | Recieve & Inspect Warm Tuners - 8th Production Set | 2011-08-01 → 2011-05-16 A (-77d) | 2011-08-26 → 2011-05-30 A (-88d) | 20d → 10d | 0% → 100% | 358d → none |  |  |
| 131122115 | Re-Baseline Actuals Adjustment | 2013-08-30 A | 2013-08-30 A |  | 0% → 100% | 20d → none | 9-130M FS+227d → none |  |
| 3 | **1.3.1.1.2.3 HELIUM HEADERS** | 2009-04-01 → 2009-03-25 (-7d) |  |  |  |  |  |  |
| 131123010 | Proc Helium Headers | 2009-04-01 → 2009-03-25 A (-7d) | 2009-07-01 → 2009-09-30 A (+91d) | 65d → 133d | 0% → 100% | 311d → none |  |  |
| 131123015 | Vend Fab - Helium Headers Lot #1, 2 & 3 (Phase 1) | 2009-07-01 → 2009-09-14 A (+75d) | 2009-08-07 → 2010-02-25 A (+202d) | 27d → 109d | 0% → 100% | 345d → none |  | resources TRAVEL; MECH DES [10 h]; MECH ENG [10 h]; PROCUREMENT>$50K 69; SR STAFF [10 h]; PROCUREMENT<$50K 60; SUPPLIES & MATERIALS → MECH DES [10 h]; MECH ENG [10 h]; PROCUREMENT>$50K 69; SR STAFF [10 h]; PROCUREMENT<$50K 60; SUPPLIES & MATERIALS; TRAVEL |
| 131123016 | Vend Fab - Helium Headers Lot #1, 2 & 3 (Phase 2) FY09 Labor | 2009-08-10 → 2010-02-01 A (+175d) | 2009-09-30 → 2010-02-25 A (+148d) | 37d → 18d | 0% → 100% | 458d → none |  | resources SR STAFF [13.88 h]; TRAVEL; MECH DES [13.88 h]; SUPPLIES & MATERIALS; MECH ENG [13.88 h] → SUPPLIES & MATERIALS; TRAVEL; MECH DES [13.88 h]; MECH ENG [13.88 h]; SR STAFF [13.88 h] |
| 131123016b | Vend Fab - Helium Headers Lot #1, 2 & 3 (Phase 2) FY10 Labor | 2009-10-01 → 2010-02-01 A (+123d) | 2009-12-02 → 2010-02-25 A (+85d) | 43d → 18d | 0% → 100% | 458d → none |  | resources MECH DES [16.12 h]; SUPPLIES & MATERIALS; MECH ENG [16.12 h]; SR STAFF [16.12 h]; TRAVEL → SUPPLIES & MATERIALS; TRAVEL; MECH DES [16.12 h]; MECH ENG [16.12 h]; SR STAFF [16.12 h] |
| 131123016c | Vend Fab - Helium Headers Lot #1, 2 & 3 (Phase 2) Procurement | 2009-08-10 → 2010-03-01 A (+203d) | 2009-12-02 → 2010-03-29 A (+117d) | 80d → 21d | 0% → 100% | 458d → none |  |  |
| 131123020 | Receive & Insp Helium Headers Lot #1 1-3 | 2009-10-05 → 2010-03-29 A (+175d) | 2009-10-30 → 2010-04-28 A (+180d) | 20d → 23d | 0% → 100% | 345d → none | 131123010, 131123015 FS+39d → 131123015, 131123010 | resources SUPPLIES & MATERIALS; MECH TECH [40 h]; MECH ENG [12 h]; MECH DES [8 h] → MECH ENG [12 h]; SUPPLIES & MATERIALS; MECH TECH [40 h]; MECH DES [8 h] |
| 131123025 | Receive & Insp Helium Headers Lot #2 4-7 | 2009-11-02 → 2010-05-24 A (+203d) | 2009-12-01 → 2010-06-28 A (+209d) | 20d → 25d | 0% → 100% | 474d → none |  | resources MECH DES [8 h]; MECH ENG [12 h]; SUPPLIES & MATERIALS; MECH TECH [40 h] → SUPPLIES & MATERIALS; MECH TECH [40 h]; MECH DES [8 h]; MECH ENG [12 h] |
| 131123030 | Receive & Insp Helium Headers Lot #3 8-10 | 2009-12-02 → 2010-05-24 A (+173d) | 2010-01-06 → 2010-06-30 A (+175d) | 20d → 27d | 0% → 100% | 755d → none |  | resources MECH DES [8 h]; MECH ENG [12 h]; SUPPLIES & MATERIALS → MECH ENG [12 h]; SUPPLIES & MATERIALS; MECH DES [8 h] |
| 131123016d | Vend Fab 10 CFR 851 Compliance | 2010-07-02 → 2010-07-01 A (-1d) | 2010-07-09 → 2010-07-01 A (-8d) | 5d → 1d | 0% → 100% | 311d → none |  |  |
| 131123035 | Re-Baseline Actuals Adjustment | 2013-08-30 A | 2013-08-30 A |  | 0% → 100% | 20d → none | 9-130M FS+227d → none |  |
| 3 | **1.3.1.1.3 CRYOMODULE PROCUREMENTS** | 2009-01-02 → 2009-02-02 (+31d) |  |  |  |  |  |  |
| 1 | **1.3.1.1.3.1 MLI** | 2009-03-02 → 2009-07-03 (+123d) |  |  |  |  |  |  |
| 131131010 | Proc MLI | 2009-03-02 → 2009-07-03 A (+123d) | 2009-06-01 → 2010-02-25 A (+269d) | 65d → 158d | 0% → 100% | 390d → none |  | resources MECH ENG [20 h]; MECH DES [20 h] → MECH DES [20 h]; MECH ENG [20 h] |
| 131131015 | Vend Fab - MLI (Phase 1) | 2009-06-01 → 2009-09-14 A (+105d) | 2009-06-26 → 2010-02-25 A (+244d) | 20d → 109d | 0% → 100% | 390d → none | 131131010 FS-1d → 131131010 FS-500d | resources SR STAFF [10 h]; MECH DES [10 h]; MECH ENG [10 h]; MECH TECH [10 h]; PROCUREMENT<$50K 60; PROCUREMENT>$50K 69; SUPPLIES & MATERIALS → MECH ENG [10 h]; PROCUREMENT>$50K 69; SUPPLIES & MATERIALS; SR STAFF [10 h]; MECH DES [10 h]; MECH TECH [10 h]; PROCUREMENT<$50K 60 |
| 131131020 | Receive & Insp MLI (Phase 1) | 2009-06-29 → 2009-12-14 A (+168d) | 2009-08-06 → 2009-12-21 A (+137d) | 28d → 5d | 0% → 100% | 390d → none |  | resources MECH ENG [5 h]; SUPPLIES & MATERIALS; MECH TECH [10 h]; MECH DES [5 h] → SUPPLIES & MATERIALS; MECH TECH [10 h]; MECH DES [5 h]; MECH ENG [5 h] |
| 131131016 | Vend Fab - MLI (Phase 2) | 2009-06-29 → 2010-08-16 A (+413d) | 2009-09-16 → 2011-01-14 A (+485d) | 56d → 101d | 0% → 100% | 543d → none |  | resources PROCUREMENT>$50K 69; SUPPLIES & MATERIALS; SR STAFF [30 h]; MECH DES [30 h]; MECH ENG [30 h]; MECH TECH [30 h]; PROCUREMENT<$50K 60 → MECH DES [30 h]; MECH TECH [30 h]; PROCUREMENT<$50K 60; MECH ENG [30 h]; PROCUREMENT>$50K 69; SUPPLIES & MATERIALS; SR STAFF [30 h] |
| 131131021 | Receive & Insp MLI (Phase 2) FY09 | 2009-09-17 → 2011-01-03 A (+473d) | 2009-09-30 → 2011-01-28 A (+485d) | 10d → 18d | 0% → 100% | 543d → none |  | resources MECH TECH [10.71 h]; MECH DES [5.36 h]; MECH ENG [5.36 h]; SUPPLIES & MATERIALS → MECH DES [5.36 h]; MECH ENG [5.36 h]; SUPPLIES & MATERIALS; MECH TECH [10.71 h] |
| 131131021b | Receive & Insp MLI (Phase 2) FY10 | 2009-10-01 → 2011-01-03 A (+459d) | 2009-10-26 → 2011-01-28 A (+459d) |  | 0% → 100% | 543d → none |  |  |
| 131131025 | Re-Baseline Actuals Adjustment | 2013-08-30 A | 2013-08-30 A |  | 0% → 100% | 20d → none | 9-130M FS+227d → none |  |
| 2 | **1.3.1.1.3.2 THERMAL SHIELD** | 2009-02-02 → 2009-03-25 (+51d) |  |  |  |  |  |  |
| 131132010 | Proc Thermal Shield | 2009-02-02 → 2009-03-25 A (+51d) | 2009-09-01 → 2009-09-21 A (+20d) | 149d → 126d | 0% → 100% | 243d → none |  | resources MECH ENG [20 h]; MECH DES [20 h] → MECH DES [20 h]; MECH ENG [20 h] |
| 131132015 | Vend Fab - Thermal Shield Lot #1 (Phase 1) Labor FY09 | 2009-09-01 → 2009-09-14 A (+13d) | 2009-09-30 → 2010-06-28 A (+271d) | 21d → 194d | 0% → 100% | 243d → none |  | resources SR STAFF [2.1 h]; MECH DES [4.2 h]; MECH ENG [4.2 h]; TRAVEL; SUPPLIES & MATERIALS → MECH ENG [4.2 h]; SR STAFF [2.1 h]; SUPPLIES & MATERIALS; TRAVEL; MECH DES [4.2 h] |
| 131132015c | Vend Fab - Thermal Shield Lot #1 (Phase 1) Procurement | 2009-09-01 → 2009-09-14 A (+13d) | 2010-03-02 → 2010-06-28 A (+118d) | 120d → 195d | 0% → 100% | 243d → none |  | resources PROCUREMENT<$50K 60 NO ESCALATION FY10; PROCUREMENT>$50K 69 NO ESCALATION FY10 → PROCUREMENT>$50K 69 NO ESCALATION FY10; PROCUREMENT<$50K 60 NO ESCALATION FY10 |
| 131132016 | Vend Fab - Thermal Shield Lot #2 & 3 (Phase 2) | 2010-03-03 → 2010-01-04 A (-58d) | 2010-08-19 → 2011-01-04 A (+138d) | 120d → 249d | 0% → 100% | 337d → none | 131132015b, 131132015c → 131132015c FS-100d, 131132015b FS-100d | resources PROCUREMENT>$50K 69; MECH ENG [56 h]; TRAVEL; MECH DES [56 h]; SUPPLIES & MATERIALS; SR STAFF [28 h]; PROCUREMENT<$50K 60 → PROCUREMENT>$50K 69; SUPPLIES & MATERIALS; TRAVEL; MECH DES [56 h]; MECH ENG [56 h]; SR STAFF [28 h]; PROCUREMENT<$50K 60 |
| 131132015b | Vend Fab - Thermal Shield Lot #1 (Phase 1) Labor FY10 | 2009-10-01 → 2010-02-01 A (+123d) | 2010-03-02 → 2010-06-28 A (+118d) | 99d → 104d | 0% → 100% | 243d → none | 131132015 → 131132015 FS-25d | resources MECH DES [19.8 h]; SUPPLIES & MATERIALS; SR STAFF [9.9 h]; MECH ENG [19.8 h]; TRAVEL → MECH DES [19.8 h]; MECH ENG [19.8 h]; SR STAFF [9.9 h]; SUPPLIES & MATERIALS; TRAVEL |
| 131132020 | Receive & Insp Thermal Shield Lot #1 1-3 | 2010-03-03 → 2010-02-15 A (-16d) | 2010-04-13 → 2010-06-30 A (+78d) | 30d → 96d | 0% → 100% | 243d → none | 131132015b, 131132015c → 131132015b FS-25d, 131132015c FS-45d | resources SUPPLIES & MATERIALS; MECH DES [40 h]; MECH TECH [40 h]; MECH ENG [40 h] → MECH TECH [40 h]; SUPPLIES & MATERIALS; MECH DES [40 h]; MECH ENG [40 h] |
| 131132025 | Receive & Insp Thermal Shield Lot #2 4-7 | 2010-05-26 → 2010-08-23 A (+89d) | 2010-07-08 → 2010-11-29 A (+144d) | 30d → 68d | 0% → 100% | 337d → none |  | resources MECH ENG [20 h]; MECH TECH [40 h]; MECH DES [20 h]; SUPPLIES & MATERIALS → MECH TECH [40 h]; MECH DES [20 h]; MECH ENG [20 h]; SUPPLIES & MATERIALS |
| 131132030 | Receive & Insp Thermal Shield Lot #3 8-10 FY10 | 2010-08-20 → 2011-01-14 A (+147d) | 2010-09-30 → 2011-01-25 A (+117d) | 29d → 7d | 0% → 100% | 548d → none |  | resources MECH ENG [19.33 h]; SUPPLIES & MATERIALS; MECH DES [19.33 h]; MECH TECH [38.67 h] → MECH TECH [38.67 h]; MECH DES [19.33 h]; SUPPLIES & MATERIALS; MECH ENG [19.33 h] |
| 131132030a | Receive & Insp Thermal Shield Lot #3 8-10 FY11 | 2010-10-01 → 2011-02-01 A (+123d) | 2010-10-01 → 2011-02-28 A (+150d) | 1d → 19d | 0% → 100% | 548d → none |  | resources MECH ENG [0.67 h]; SUPPLIES & MATERIALS; MECH DES [0.67 h]; MECH TECH [1.33 h] → MECH TECH [1.33 h]; MECH DES [0.67 h]; MECH ENG [0.67 h]; SUPPLIES & MATERIALS |
| 131132035 | Re-Baseline Actuals Adjustment | 2013-08-30 A | 2013-08-30 A |  | 0% → 100% | 20d → none | 9-130M FS+227d → none |  |
| 3 | **1.3.1.1.3.3 MAGNETIC SHIELD** | 2009-01-02 → 2009-06-22 (+171d) |  |  |  |  |  |  |
| 131133010 | Prcrmnt Prep for Magnetic Shield | 2009-01-02 → 2009-06-22 A (+171d) | 2009-02-11 → 2010-06-30 A (+504d) | 28d → 255d | 0% → 100% | 101d → none |  | resources MECH DES [6.44 h]; MECH ENG [6.44 h] → MECH ENG [6.44 h]; MECH DES [6.44 h] |

| ID | Task | Start | Finish | Duration | Complete | Total float | Predecessors | Other |
| --- | --- | --- | --- | --- | --- | --- | --- | --- |
| 131133015 | Vend Fab - Magnetic Shield Lot #1 (Phase 1) (FROZEN) | 2009-02-11 → 2010-06-01 A (+475d) | 2009-09-14 → 2010-07-19 A (+308d) | 150d → 34d | 0% → 100% | 101d → none |  | was named Vend Fab - Magnetic Shield Lot #1 (Phase 1); resources SUPPLIES & MATERIALS; TRAVEL; MECH DES [12 h]; SR STAFF [12 h]; PROCUREMENT>$50K 69; MECH ENG [12 h]; PROCUREMENT<$50K 60 → PROCUREMENT<$50K 60; SR STAFF [12 h]; PROCUREMENT>$50K 69; MECH ENG [12 h]; SUPPLIES & MATERIALS; TRAVEL; MECH DES [12 h] |
| 131133016 | Vend Fab - Magnetic Shield Lot #2 & 3 (Phase 2) Labor FY09 | 2009-09-15 → 2010-06-01 A (+259d) | 2009-09-30 → 2010-07-14 A (+287d) | 12d → 31d | 0% → 100% | 242d → none | 131133015 → 131133015 FS-53d | resources SR STAFF [2.8 h]; MECH ENG [2.8 h]; SUPPLIES & MATERIALS; TRAVEL; MECH DES [2.8 h] → MECH DES [2.8 h]; SR STAFF [2.8 h]; MECH ENG [2.8 h]; SUPPLIES & MATERIALS; TRAVEL |
| 131133016b | Vend Fab - Magnetic Shield Lot #2 & 3 (Phase 2) Labor FY10 | 2009-10-01 → 2010-06-01 A (+243d) | 2010-03-15 → 2010-07-19 A (+126d) | 108d → 34d | 0% → 100% | 242d → none |  | resources TRAVEL; MECH DES [25.2 h]; SR STAFF [25.2 h]; MECH ENG [25.2 h]; SUPPLIES & MATERIALS → MECH ENG [25.2 h]; SUPPLIES & MATERIALS; TRAVEL; MECH DES [25.2 h]; SR STAFF [25.2 h] |
| 131133016c | Vend Fab - Inner Magnetic Shield- First Article Set | 2010-07-01 A | 2010-08-31 → 2010-07-30 A (-32d) | 43d → 21d | 0% → 100% | 119d → none | 131133015 FS+196d → 131133015 FS-54d |  |
| 131133016c1 | Vend Fab - Inner Magnetic Shield Set #2 | 2010-07-01 A | 2010-09-30 A |  | 0% → 100% | 119d → none |  |  |
| 131133017 | Vend Fab - Inner Magnetic Shield Set #3 | 2010-07-01 A | 2010-11-30 → 2010-10-25 A (-36d) | 105d → 81d | 0% → 100% | 176d → none |  |  |
| 131133017A | Vend Fab - Inner Magnetic Shield Set #4 | 2010-07-01 A | 2010-11-30 → 2010-10-25 A (-36d) | 105d → 81d | 0% → 100% | 192d → none |  |  |
| 131133017B | Vend Fab - Inner Magnetic Shield Set #5 | 2010-07-01 A | 2010-12-30 → 2010-11-30 A (-30d) | 122d → 105d | 0% → 100% | 235d → none |  |  |
| 131133017C | Vend Fab - Inner Magnetic Shield Set #6 | 2010-07-01 A | 2011-01-31 A |  | 0% → 100% | 278d → none |  |  |
| 131133017D | Vend Fab - Inner Magnetic Shield Set #7 | 2010-07-01 A | 2011-02-28 → 2011-03-25 A (+25d) | 161d → 180d | 0% → 100% | 373d → none |  |  |
| 131133017F | Vend Fab - Inner Magnetic Shield Set #8 | 2010-07-01 A | 2011-03-31 → 2011-03-25 A (-6d) | 184d → 180d | 0% → 100% | 409d → none |  |  |
| 131133017G | Vend Fab - Inner Magnetic Shield Set #9 | 2010-07-01 A | 2011-04-29 → 2011-04-25 A (-4d) | 205d → 201d | 0% → 100% | 421d → none |  |  |
| 131133017H | Vend Fab - Inner Magnetic Shield Set #10 | 2010-07-01 A | 2011-05-31 → 2011-06-20 A (+20d) | 226d → 240d | 0% → 100% | 435d → none |  |  |
| 131133018 | Vend Fab - Outer Magnetic Shield First Article Set | 2010-07-01 A | 2010-10-29 → 2010-09-30 A (-29d) | 85d → 64d | 0% → 100% | 101d → none | 131133015 FS+196d → 131133015 FS-54d |  |
| 131133018A | Vend Fab - Outer Magnetic Shield Receipt of Materials | 2010-07-01 A | 2010-12-30 → 2011-05-15 A (+136d) | 122d → 215d | 0% → 100% | 101d → none |  |  |
| 131133018B | Vend Fab - Outer Magnetic Shield Set #2 | 2010-07-01 A | 2010-12-30 → 2011-05-16 A (+137d) | 122d → 216d | 0% → 100% | 101d → none |  |  |
| 131133018C | Vend Fab - Outer Magnetic Shield Set #3 | 2010-07-01 A | 2011-02-28 → 2011-06-18 A (+110d) | 161d → 239d | 0% → 100% | 143d → none |  |  |
| 131133018D | Vend Fab - Outer Magnetic Shield Set #4 | 2010-07-01 A | 2011-03-31 → 2011-08-09 A (+131d) | 184d → 275d | 0% → 100% | 143d → none |  |  |
| 131133018F | Vend Fab - Outer Magnetic Shield Set #5 | 2010-07-01 A | 2011-04-29 → 2011-09-12 A (+136d) | 205d → 298d | 0% → 100% | 182d → none |  |  |
| 131133018G | Vend Fab - Outer Magnetic Shield Set #6 | 2010-07-01 A | 2011-05-31 → 2012-01-23 A (+237d) | 226d → 384d | 0% → 100% | 234d → none |  |  |
| 131133018H | Vend Fab - Outer Magnetic Shield Set #7 | 2010-07-01 A | 2011-06-30 → 2012-02-21 A (+236d) | 248d → 404d | 0% → 100% | 310d → none |  |  |
| 131133018J | Vend Fab - Outer Magnetic Shield Set #8 | 2010-07-01 A | 2011-07-29 → 2012-02-20 A (+206d) | 268d → 403d | 0% → 100% | 358d → none |  |  |
| 131133018K | Vend Fab - Outer Magnetic Shield Set #9 | 2010-07-01 A | 2011-08-31 → 2012-06-18 A (+292d) | 291d → 486d | 0% → 100% | 379d → none |  |  |
| 131133018L | Vend Fab - Outer Magnetic Shield Set #10 | 2010-07-01 A | 2011-09-26 → 2012-07-16 A (+294d) | 308d → 505d | 0% → 100% | 392d → none |  |  |
| 131133120LOE | SOTR Oversight FY10 | 2010-07-01 A | 2010-09-30 A |  | 0% → 100% | 392d → none |  |  |
| 131133015a | Vend Fab - Magnetic Shield Lot #1 (Phase 1) Reverse Entry Per CR10-064 ETC | 2010-07-01 → 2010-07-12 A (+11d) | 2010-07-01 → 2010-07-19 A (+18d) | 1d → 6d | 0% → 100% | 182d → none |  | resources TRAVEL; MECH DES [-12 h]; SR STAFF [-12 h]; PROCUREMENT>$50K 69; MECH ENG [-12 h]; PROCUREMENT<$50K 60; SUPPLIES & MATERIALS → MECH DES [-12 h]; SR STAFF [-12 h]; PROCUREMENT>$50K 69; MECH ENG [-12 h]; PROCUREMENT<$50K 60; SUPPLIES & MATERIALS; TRAVEL |
| 131133020 | Receive & Insp Inner Magnetic Shield First Article Set | 2010-01-12 → 2010-08-02 A (+202d) | 2010-02-09 → 2010-08-09 A (+181d) | 20d → 6d | 0% → 100% | 282d → none | 131133016c FS-162d, 131133015 FS+77d, 131133010 → 131133015 FS-54d, 131133016c FS-162d, 131133010 | resources MECH DES [20 h]; MECH ENG [20 h]; SUPPLIES & MATERIALS; MECH TECH [40 h] → MECH ENG [20 h]; SUPPLIES & MATERIALS; MECH TECH [40 h]; MECH DES [20 h] |
| 131133025 | Receive & Insp Inner Magnetic Shield Set #2 | 2010-10-01 → 2010-09-01 A (-30d) | 2010-10-28 → 2010-09-30 A (-28d) | 20d → 21d | 0% → 100% | 119d → none | 131133016c1, 131133015a, 131133016b FS+17d → 131133016b FS-40d, 131133015a, 131133016c1 | resources MECH ENG [8 h]; MECH TECH [40 h]; MECH DES [8 h] → MECH DES [8 h]; MECH TECH [40 h]; MECH ENG [8 h] |
| 131133070 | Receive & Insp Outer Magnetic Shield First Article Set | 2010-11-01 → 2010-09-24 A (-38d) | 2010-11-30 → 2011-04-25 A (+146d) | 20d → 142d | 0% → 100% | 103d → none |  |  |
| 131133125LOE | SOTR Oversight FY11 | 2010-10-01 A | 2011-09-30 A |  | 0% → 100% | 392d → none |  |  |
| 131133030 | Receive & Insp Inner Magnetic Shield Set #3 | 2010-12-01 → 2010-10-07 A (-55d) | 2011-01-05 → 2010-10-25 A (-72d) | 20d → 13d | 0% → 100% | 176d → none | 131133017, 131133016b FS+77d → 131133016b, 131133017 | resources MECH TECH [40 h]; MECH ENG [8 h]; MECH DES [8 h] → MECH DES [8 h]; MECH ENG [8 h]; MECH TECH [40 h] |
| 131133035 | Receive & Insp Inner Magnetic Shield Set #4 | 2010-12-01 → 2010-10-07 A (-55d) | 2011-01-05 → 2010-10-25 A (-72d) | 20d → 13d | 0% → 100% | 192d → none |  |  |
| 131133040 | Receive & Insp Inner Magnetic Shield Set #5 | 2010-12-31 → 2011-01-04 A (+4d) | 2011-01-31 → 2011-01-14 A (-17d) | 20d → 9d | 0% → 100% | 235d → none |  | resources MECH ENG [8 h]; MECH TECH [40 h]; MECH DES [8 h] → MECH DES [8 h]; MECH ENG [8 h]; MECH TECH [40 h] |
| 131133045 | Receive & Insp Inner Magnetic Shield Set #6 | 2011-02-01 → 2011-01-17 A (-15d) | 2011-03-01 → 2011-01-28 A (-32d) | 20d → 9d | 0% → 100% | 278d → none |  | resources MECH TECH [40 h]; MECH DES [8 h]; MECH ENG [8 h] → MECH ENG [8 h]; MECH TECH [40 h]; MECH DES [8 h] |
| 131133050 | Receive & Insp Inner Magnetic Shield Set #7 | 2011-03-01 → 2011-03-02 A (+1d) | 2011-03-28 → 2011-03-25 A (-3d) | 20d → 18d | 0% → 100% | 373d → none |  |  |
| 131133055 | Receive & Insp Inner Magnetic Shield Set #8 | 2011-04-01 → 2011-03-02 A (-30d) | 2011-04-28 → 2011-03-25 A (-34d) | 20d → 18d | 0% → 100% | 409d → none |  | resources MECH TECH [40 h]; MECH DES [8 h]; MECH ENG [8 h] → MECH DES [8 h]; MECH ENG [8 h]; MECH TECH [40 h] |
| 131133060 | Receive & Insp Inner Magnetic Shield Set #9 | 2011-05-02 → 2011-04-01 A (-31d) | 2011-05-27 → 2011-04-25 A (-32d) | 20d → 17d | 0% → 100% | 421d → none |  | resources MECH TECH [40 h]; MECH DES [8 h]; MECH ENG [8 h] → MECH DES [8 h]; MECH ENG [8 h]; MECH TECH [40 h] |
| 131133075 | Receive & Insp Outer Magnetic Shield Set #2 | 2010-12-17 → 2011-05-11 A (+145d) | 2011-01-24 → 2011-05-23 A (+119d) | 20d → 9d | 0% → 100% | 101d → none |  | resources MECH DES [8 h]; MECH ENG [8 h]; MECH TECH [40 h] → MECH ENG [8 h]; MECH TECH [40 h]; MECH DES [8 h] |
| 131133065 | Receive & Insp Inner Magnetic Shield Set #10 | 2011-06-01 → 2011-06-19 A (+18d) | 2011-06-28 → 2011-06-20 A (-8d) | 20d → 1d | 0% → 100% | 435d → none |  | resources MECH ENG [8 h]; MECH TECH [40 h]; MECH DES [8 h] → MECH DES [8 h]; MECH ENG [8 h]; MECH TECH [40 h] |
| 131133080 | Receive & Insp Outer Magnetic Shield Set #3 | 2011-03-01 → 2011-06-19 A (+110d) | 2011-03-28 → 2011-06-27 A (+91d) | 20d → 6d | 0% → 100% | 150d → none |  |  |
| 131133085 | Receive & Insp Outer Magnetic Shield Set #4 | 2011-04-01 → 2011-09-01 A (+153d) | 2011-04-28 → 2011-09-12 A (+137d) | 20d → 7d | 0% → 100% | 143d → none |  | resources MECH TECH [40 h]; MECH DES [8 h]; MECH ENG [8 h] → MECH DES [8 h]; MECH ENG [8 h]; MECH TECH [40 h] |
| 131133090 | Receive & Insp Outer Magnetic Shield Set #5 | 2011-05-02 → 2011-09-13 A (+134d) | 2011-05-27 → 2011-09-30 A (+126d) | 20d → 14d | 0% → 100% | 182d → none |  |  |
| 131133130LOE | SOTR Oversight FY12 | 2011-10-03 A | 2011-10-24 A |  | 0% → 100% | 392d → none |  |  |
| 131133095 | Receive & Insp Outer Magnetic Shield Set #6 | 2011-06-01 → 2012-01-23 A (+236d) | 2011-06-28 → 2012-01-30 A (+216d) | 20d → 6d | 0% → 100% | 234d → none |  |  |
| 131133100 | Receive & Insp Outer Magnetic Shield Set #7 | 2011-07-01 → 2012-02-13 A (+227d) | 2011-07-29 → 2012-02-20 A (+206d) | 20d → 5d | 0% → 100% | 310d → none |  | resources MECH DES [8 h]; MECH TECH [40 h]; MECH ENG [8 h] → MECH DES [8 h]; MECH ENG [8 h]; MECH TECH [40 h] |
| 131133105 | Receive & Insp Outer Magnetic Shield Set #8 | 2011-08-01 → 2012-03-02 A (+214d) | 2011-08-26 → 2012-03-19 A (+206d) | 20d → 12d | 0% → 100% | 358d → none |  | resources MECH ENG [8 h]; MECH TECH [40 h]; MECH DES [8 h] → MECH DES [8 h]; MECH ENG [8 h]; MECH TECH [40 h] |
| 131133110 | Receive & Insp Outer Magnetic Shield Set #9 | 2011-09-01 → 2012-06-19 A (+292d) | 2011-09-29 → 2012-06-25 A (+270d) | 20d → 5d | 0% → 100% | 379d → none |  | resources MECH TECH [40 h]; MECH DES [8 h]; MECH ENG [8 h] → MECH DES [8 h]; MECH ENG [8 h]; MECH TECH [40 h] |
| 131133115 | Receive & Insp Outer Magnetic Shield Set #10 FY11 | 2011-09-27 → 2012-07-02 A (+279d) | 2011-09-30 → 2012-07-09 A (+283d) | 4d → 5d | 0% → 100% | 392d → none |  | resources MECH TECH [8 h]; MECH DES [1.6 h]; MECH ENG [1.6 h] → MECH ENG [1.6 h]; MECH TECH [8 h]; MECH DES [1.6 h] |
| 131133115a | Receive & Insp Outer Magnetic Shield Set #10 FY12 | 2011-10-03 → 2012-07-10 A (+281d) | 2011-10-24 → 2012-07-23 A (+273d) | 16d → 9d | 0% → 100% | 392d → none |  | resources MECH DES [6.4 h]; MECH ENG [6.4 h]; MECH TECH [32 h] → MECH DES [6.4 h]; MECH TECH [32 h]; MECH ENG [6.4 h] |
| 131133135 | Re-Baseline Actuals Adjustment | 2013-08-30 A | 2013-08-30 A |  | 0% → 100% | 20d → none | 9-130M FS+227d → none |  |
| 4 | **1.3.1.1.3.4 INSTRUMENTATION** | 2009-04-01 → 2009-06-22 (+82d) |  |  |  |  |  |  |
| 131134010 | Proc Instrmenttn | 2009-04-01 → 2009-06-22 A (+82d) | 2009-07-01 → 2010-05-24 A (+327d) | 65d → 229d | 0% → 100% | 276d → none |  |  |
| 131134012 | Vend Fab - Instrmenttn (Phase 1) Labor FY09 | 2009-07-01 → 2009-11-09 A (+131d) | 2009-09-30 → 2010-02-19 A (+142d) | 64d → 65d | 0% → 100% | 276d → none | 131134010 FS-1d → 131134010 FS-250d | resources ELEC TECH [12.8 h]; MECH ENG [6.4 h]; SR STAFF [6.4 h]; ELEC ENG [6.4 h]; MECH DES [6.4 h] → SR STAFF [6.4 h]; ELEC ENG [6.4 h]; ELEC TECH [12.8 h]; MECH DES [6.4 h]; MECH ENG [6.4 h] |
| 131134012b | Vend Fab - Instrmenttn (Phase 1) Labor FY10 | 2009-10-01 → 2009-11-09 A (+39d) | 2009-12-28 → 2010-02-19 A (+53d) | 56d → 65d | 0% → 100% | 276d → none | 131134012 → 131134012 FS-200d | resources MECH ENG [5.6 h]; SR STAFF [5.6 h]; ELEC ENG [5.6 h]; MECH DES [5.6 h]; ELEC TECH [11.2 h] → SR STAFF [5.6 h]; ELEC ENG [5.6 h]; ELEC TECH [11.2 h]; MECH DES [5.6 h]; MECH ENG [5.6 h] |
| 131134012c | Vend Fab - Instrmenttn (Phase 1) Procurement | 2009-07-01 → 2009-11-09 A (+131d) | 2009-12-28 → 2010-02-19 A (+53d) | 120d → 65d | 0% → 100% | 276d → none | 131134010 FS-1d → 131134010 FS-200d |  |
| 131134015 | Receive & Insp Instrmenttn (Phase 1) | 2009-12-29 → 2010-02-15 A (+48d) | 2010-01-27 → 2010-02-25 A (+29d) | 20d → 8d | 0% → 100% | 276d → none |  | resources ELEC ENG [12 h]; ELEC TECH [24 h]; MECH DES [6 h]; SUPPLIES & MATERIALS → ELEC TECH [24 h]; MECH DES [6 h]; ELEC ENG [12 h]; SUPPLIES & MATERIALS |
| 131134013 | Vend Fab - Instrmenttn (Phase 2) | 2009-12-29 → 2010-02-22 A (+55d) | 2010-06-18 → 2011-04-25 A (+311d) | 120d → 293d | 0% → 100% | 313d → none |  | resources ELEC TECH [56 h]; MECH ENG [28 h]; MECH DES [28 h]; SR STAFF [28 h]; PROCUREMENT>$50K 69; ELEC ENG [28 h] → ELEC TECH [56 h]; MECH DES [28 h]; MECH ENG [28 h]; SR STAFF [28 h]; PROCUREMENT>$50K 69; ELEC ENG [28 h] |
| 131134016 | Receive & Insp Instrmenttn (Phase 2) | 2010-06-21 → 2010-02-22 A (-119d) | 2010-07-19 → 2010-08-30 A (+42d) | 20d → 134d | 0% → 100% | 313d → none | 131134013 → 131134013 FS-60d | resources ELEC TECH [56 h]; MECH DES [14 h]; SUPPLIES & MATERIALS; ELEC ENG [28 h] → ELEC ENG [28 h]; ELEC TECH [56 h]; MECH DES [14 h]; SUPPLIES & MATERIALS |
| 131134021LOE | SOTR Oversight | 2010-07-01 A | 2010-09-30 A |  | 0% → 100% | 343d → none |  | resources ELEC ENG [200 h]; ELEC TECH [320 h]; MECH DES [80 h] → MECH DES [80 h]; ELEC ENG [200 h]; ELEC TECH [320 h] |
| 131134018 | Receive & Insp Instrmenttn (Phase 2) Additional Hardware | 2010-07-20 → 2010-08-23 A (+34d) | 2010-09-30 → 2011-04-25 A (+207d) | 52d → 165d | 0% → 100% | 313d → none | 131134016 → 131134016 FS-60d | was named Receive & Insp Instrmenttn (Phase 2) Additinal Hardware; resources MECH DES [14 h]; SUPPLIES & MATERIALS; ELEC ENG [28 h]; ELEC TECH [56 h] → ELEC TECH [56 h]; MECH DES [14 h]; SUPPLIES & MATERIALS; ELEC ENG [28 h] |
| 131134025 | Re-Baseline Actuals Adjustment | 2013-08-30 A | 2013-08-30 A |  | 0% → 100% | 20d → none | 9-130M FS+227d → none |  |
| 5 | **1.3.1.1.3.5 END CANS** | 2009-10-01 → 2009-06-22 (-101d) |  |  |  |  |  |  |
| 131135010 | Proc End Cans | 2009-10-01 → 2009-06-22 A (-101d) | 2010-02-02 → 2009-12-23 A (-41d) | 80d → 126d | 0% → 100% | -25d → none | 1211020M10, 9-100M → 1211020M10 FS-100d | resources MECH ENG [20 h]; MECH DES [20 h] → MECH DES [20 h]; MECH ENG [20 h] |
| 131135015B | Vend Fab End Cans - Submittal of Project Q.A. Plan | 2010-01-04 A | 2010-01-29 → 2010-02-15 A (+17d) | 19d → 29d | 0% → 100% | 114d → none |  | resources PROCUREMENT<$50K 60 NO ESCALATION; PROCUREMENT>$50K 69 NO ESCALATION → PROCUREMENT>$50K 69 NO ESCALATION; PROCUREMENT<$50K 60 NO ESCALATION |
| 131135015C | Vend Fab End Cans - Material P.O. for End Can sets 1-3 | 2010-01-04 A | 2010-04-30 → 2010-03-29 A (-32d) | 83d → 59d | 0% → 100% | 114d → none |  |  |
| 131135015D | Vend Fab End Cans - Material Receipt for End Can sets 4-6 | 2010-01-04 A | 2010-08-31 → 2010-08-30 A (-1d) | 168d → 167d | 0% → 100% | 114d → none |  |  |
| 131135015F | Vend Fab End Cans - Material P.O. for End Can sets 7-8 | 2010-01-04 A | 2010-10-29 → 2010-11-29 A (+31d) | 210d → 229d | 0% → 100% | 114d → none |  |  |
| 131135015G | Vend Fab End Cans - Material Receipt for End Can sets 9-10 | 2010-01-04 A | 2010-12-30 → 2010-12-16 A (-14d) | 247d → 242d | 0% → 100% | 114d → none |  |  |
| 131135015H | Vend Fab End Cans - Delivery of Set #1 | 2010-01-04 A | 2010-07-30 → 2010-08-30 A (+31d) | 146d → 167d | 0% → 100% | 114d → none |  |  |
| 131135015J | Vend Fab End Cans - Delivery of Set #2 | 2010-01-04 A | 2010-09-30 → 2010-10-25 A (+25d) | 189d → 206d | 0% → 100% | 114d → none |  |  |

| ID | Task | Start | Finish | Duration | Complete | Total float | Predecessors | Other |
| --- | --- | --- | --- | --- | --- | --- | --- | --- |
| 131135015K | Vend Fab End Cans - Delivery of Set #3 | 2010-01-04 A | 2010-09-30 → 2010-10-25 A (+25d) | 189d → 206d | 0% → 100% | 182d → none |  |  |
| 131135015N | Vend Fab End Cans - Delivery of Set #4 | 2010-01-04 A | 2010-11-30 → 2010-12-23 A (+23d) | 230d → 245d | 0% → 100% | 182d → none |  |  |
| 131135015O | Vend Fab End Cans - Delivery of Set #5 | 2010-01-04 A | 2010-11-30 → 2011-02-14 A (+76d) | 230d → 277d | 0% → 100% | 242d → none |  |  |
| 131135015P | Vend Fab End Cans - Delivery of Set #6 | 2010-01-04 A | 2010-12-31 → 2011-02-21 A (+52d) | 248d → 281d | 0% → 100% | 297d → none |  |  |
| 131135015Q | Vend Fab End Cans - Delivery of Set #7 | 2010-01-05 → 2010-01-04 A (-1d) | 2011-02-01 → 2011-03-25 A (+52d) | 267d → 305d | 0% → 100% | 375d → none |  |  |
| 131135015R | Vend Fab End Cans - Delivery of Set #8 | 2010-01-05 → 2010-01-04 A (-1d) | 2011-02-01 → 2011-05-23 A (+111d) | 267d → 346d | 0% → 100% | 443d → none |  |  |
| 131135015S | Vend Fab End Cans - Delivery of Set #9 | 2010-01-05 → 2010-01-04 A (-1d) | 2011-04-01 → 2011-07-15 A (+105d) | 309d → 383d | 0% → 100% | 445d → none |  |  |
| 131135015T | Vend Fab End Cans - Delivery of Set #10 | 2010-01-05 → 2010-01-04 A (-1d) | 2011-05-02 → 2011-07-26 A (+85d) | 330d → 390d | 0% → 100% | 454d → none |  |  |
| 131135015 | Technical Oversight End Cans Procurement FY10 | 2010-01-04 → 2010-02-01 A (+28d) | 2010-09-30 A | 189d → 170d | 0% → 100% | 515d → none |  | resources MECH DES [45.82 h]; SUPPLIES & MATERIALS; TRAVEL; MECH ENG [45.82 h] → MECH ENG [45.82 h]; TRAVEL; MECH DES [45.82 h]; SUPPLIES & MATERIALS |
| 131135016 | Electronic Valve Actuators | 2010-07-01 → 2010-07-02 A (+1d) | 2010-07-08 → 2010-07-19 A (+11d) | 5d → 11d | 0% → 100% | 655d → none |  |  |
| 131135017 | Additional End Can Hardware | 2010-07-01 → 2010-07-02 A (+1d) | 2010-07-08 → 2010-07-19 A (+11d) | 5d → 11d | 0% → 100% | 655d → none |  |  |
| 131135020 | Receive & Insp End Cans Set #1 FY10 | 2010-08-02 → 2010-08-31 A (+29d) | 2010-09-30 → 2010-09-24 A (-6d) | 43d → 18d | 0% → 100% | 127d → none |  | resources MECH ENG [14.33 h]; MECH TECH [57.33 h]; SUPPLIES & MATERIALS; MECH DES [5.73 h] → SUPPLIES & MATERIALS; MECH DES [5.73 h]; MECH ENG [14.33 h]; MECH TECH [57.33 h] |
| 131135020a | Receive & Insp End Cans Set #1 FY11 | 2010-10-01 → 2010-08-31 A (-31d) | 2010-10-25 → 2010-09-24 A (-31d) | 17d → 18d | 0% → 100% | 127d → none |  | resources MECH TECH [22.67 h]; SUPPLIES & MATERIALS; MECH DES [2.27 h]; MECH ENG [5.67 h] → SUPPLIES & MATERIALS; MECH DES [2.27 h]; MECH ENG [5.67 h]; MECH TECH [22.67 h] |
| 131135015A | Technical Oversight End Cans Procurement FY11 | 2010-10-01 A | 2011-04-29 A |  | 0% → 100% | 515d → none |  | resources MECH ENG [120 h]; MECH DES [34.18 h]; SUPPLIES & MATERIALS; TRAVEL → SUPPLIES & MATERIALS; TRAVEL; MECH DES [34.18 h]; MECH ENG [120 h] |
| 131135025 | Receive & Insp End Cans Set #2 | 2010-10-01 → 2010-10-18 A (+17d) | 2011-01-04 → 2010-10-26 A (-70d) | 60d → 7d | 0% → 100% | 114d → none |  | resources SUPPLIES & MATERIALS; MECH TECH [80 h]; MECH DES [8 h]; MECH ENG [20 h] → MECH TECH [80 h]; MECH DES [8 h]; MECH ENG [20 h]; SUPPLIES & MATERIALS |
| 131135030 | Receive & Insp End Cans Set #3 | 2010-10-01 → 2010-11-01 A (+31d) | 2011-01-04 → 2010-11-29 A (-36d) | 60d → 19d | 0% → 100% | 207d → none |  | resources SUPPLIES & MATERIALS; MECH TECH [80 h]; MECH DES [8 h]; MECH ENG [20 h] → MECH DES [8 h]; MECH ENG [20 h]; SUPPLIES & MATERIALS; MECH TECH [80 h] |
| 131135035 | Receive & Insp End Cans Set #4 | 2010-12-01 A | 2011-03-04 → 2011-01-21 A (-42d) | 60d → 31d | 0% → 100% | 182d → none |  | resources MECH DES [8 h]; MECH ENG [20 h]; SUPPLIES & MATERIALS; MECH TECH [80 h] → MECH TECH [80 h]; MECH DES [8 h]; MECH ENG [20 h]; SUPPLIES & MATERIALS |
| 131135040 | Receive & Insp End Cans Set #5 | 2010-12-01 → 2011-02-01 A (+62d) | 2011-03-04 → 2011-03-28 A (+24d) | 60d → 39d | 0% → 100% | 242d → none |  | resources MECH DES [8 h]; MECH ENG [20 h]; SUPPLIES & MATERIALS; MECH TECH [80 h] → SUPPLIES & MATERIALS; MECH TECH [80 h]; MECH DES [8 h]; MECH ENG [20 h] |
| 131135045 | Receive & Insp End Cans Set #6 | 2011-01-04 → 2011-02-01 A (+28d) | 2011-03-30 → 2011-03-28 A (-2d) | 60d → 39d | 0% → 100% | 297d → none |  | resources MECH ENG [20 h]; SUPPLIES & MATERIALS; MECH TECH [80 h]; MECH DES [8 h] → SUPPLIES & MATERIALS; MECH TECH [80 h]; MECH DES [8 h]; MECH ENG [20 h] |
| 131135050 | Receive & Insp End Cans Set #7 | 2011-02-02 → 2011-03-22 A (+48d) | 2011-04-27 → 2011-04-25 A (-2d) | 60d → 25d | 0% → 100% | 375d → none |  | resources MECH ENG [20 h]; SUPPLIES & MATERIALS; MECH TECH [80 h]; MECH DES [8 h] → SUPPLIES & MATERIALS; MECH TECH [80 h]; MECH DES [8 h]; MECH ENG [20 h] |
| 131135055 | Receive & Insp End Cans Set #8 | 2011-02-02 → 2011-05-16 A (+103d) | 2011-04-27 → 2011-07-23 A (+87d) | 60d → 48d | 0% → 100% | 443d → none |  | resources MECH TECH [80 h]; MECH DES [8 h]; MECH ENG [20 h]; SUPPLIES & MATERIALS → MECH DES [8 h]; MECH ENG [20 h]; SUPPLIES & MATERIALS; MECH TECH [80 h] |
| 131135060 | Receive & Insp End Cans Set #9 | 2011-04-04 → 2011-07-01 A (+88d) | 2011-06-27 → 2011-08-23 A (+57d) | 60d → 37d | 0% → 100% | 445d → none |  | resources MECH DES [8 h]; MECH ENG [20 h]; SUPPLIES & MATERIALS; MECH TECH [80 h] → MECH TECH [80 h]; MECH DES [8 h]; MECH ENG [20 h]; SUPPLIES & MATERIALS |
| 131135065 | Receive & Insp End Cans Set #10 | 2011-05-03 → 2011-07-18 A (+76d) | 2011-07-27 → 2011-08-29 A (+33d) | 60d → 31d | 0% → 100% | 454d → none |  |  |
| 131135070 | Re-Baseline Actuals Adjustment | 2013-08-30 A | 2013-08-30 A |  | 0% → 100% | 20d → none | 9-130M FS+227d → none |  |
| 6 | **1.3.1.1.3.6 VACUUM VESSELS** | 2009-11-02 → 2009-02-02 (-273d) |  |  |  |  |  |  |
| 131136010 | Proc Vac Vessels | 2009-11-02 → 2009-02-02 A (-273d) | 2009-11-02 → 2009-11-09 A (+7d) | 1d → 197d | 0% → 100% | 17d → none | 9-100M FS+22d → 9-100M FS-500d |  |
| 131136016 | Vend Fab - Vac Vessels Peg Point #1 Materials | 2009-11-25 A | 2010-01-29 → 2010-02-01 A (+3d) | 39d → 40d | 0% → 100% | 174d → none |  |  |
| 131136016a | Vend Fab - Vac Vessels Peg Point #2 Acceptance of First Article | 2009-11-25 A | 2010-04-30 → 2010-04-26 A (-4d) | 103d → 99d | 0% → 100% | 174d → none |  |  |
| 131136016b | Vend Fab - Vac Vessels Peg Point #4 Completion of Production components prior to Welding | 2009-11-25 A | 2010-04-30 → 2010-04-26 A (-4d) | 103d → 99d | 0% → 100% | 174d → none |  |  |
| 131136016c | Vend Fab - Vac Vessels Peg Point #3 First Article Shipped | 2009-11-25 A | 2010-06-30 A |  | 0% → 100% | 174d → none |  |  |
| 131136016d | Vend Fab - Vac Vessels Peg Point #5 Vacuum Vessel Assembly #2 Shipped | 2009-11-25 A | 2010-08-31 → 2010-10-25 A (+55d) | 188d → 226d | 0% → 100% | 174d → none |  |  |
| 131136016f | Vend Fab - Vac Vessels Peg Point #6 Vacuum Vessel Assembly #3 Shipped | 2009-11-25 A | 2010-09-30 → 2010-11-29 A (+60d) | 209d → 249d | 0% → 100% | 242d → none |  |  |
| 131136016g | Vend Fab - Vac Vessels Peg Point #7 Vacuum Vessel Assembly #4 Shipped | 2009-11-25 A | 2010-10-29 → 2011-01-10 A (+73d) | 230d → 273d | 0% → 100% | 242d → none |  |  |
| 131136016h | Vend Fab - Vac Vessels Peg Point #8 Vacuum Vessel Assembly #5 Shipped | 2009-11-25 A | 2010-11-30 → 2011-02-28 A (+90d) | 250d → 306d | 0% → 100% | 279d → none |  |  |
| 131136016j | Vend Fab - Vac Vessels Peg Point #9 Vacuum Vessel Assembly #6 Shipped | 2009-11-25 A | 2011-01-31 → 2011-03-28 A (+56d) | 287d → 326d | 0% → 100% | 319d → none |  |  |
| 131136016k | Vend Fab - Vac Vessels Peg Point #10 Vacuum Vessel Assembly #7 Shipped | 2009-11-25 A | 2011-02-28 → 2011-11-14 A (+259d) | 306d → 488d | 0% → 100% | 394d → none |  |  |
| 131136016n | Vend Fab - Vac Vessels Peg Point #11 Vacuum Vessel Assembly #8 Shipped | 2009-11-25 A | 2011-03-31 → 2012-01-09 A (+284d) | 329d → 520d | 0% → 100% | 441d → none |  |  |
| 131136016o | Vend Fab - Vac Vessels Peg Point #12 Vacuum Vessel Assembly #9 Shipped | 2009-11-25 A | 2011-04-29 → 2012-01-16 A (+262d) | 350d → 524d | 0% → 100% | 464d → none |  |  |
| 131136016p | Vend Fab - Vac Vessels Peg Point #13 Vacuum Vessel Assembly #10 Shipped | 2009-11-25 A | 2011-05-31 → 2012-01-23 A (+237d) | 371d → 529d | 0% → 100% | 472d → none |  |  |
| 131136015 | Vend Fab - Vac Vessels Lot #1 Original Labor FY10 | 2010-03-08 A | 2010-09-30 A | 146d → 145d | 0% → 100% | 197d → none |  | resources SUPPLIES & MATERIALS; MECH ENG [77.87 h]; TRAVEL; SR STAFF [38.93 h]; MECH DES [77.87 h] → MECH ENG [77.87 h]; SR STAFF [38.93 h]; MECH DES [77.87 h]; SUPPLIES & MATERIALS; TRAVEL |
| 131136020 | Receive & Insp Vac Vessels First Article | 2010-07-01 → 2010-06-30 A (-1d) | 2010-07-30 → 2010-08-30 A (+31d) | 21d → 43d | 0% → 100% | 196d → none | 131136016c, 131136015a FS-69d → 131136015a, 131136016c |  |
| 131136017 | Vend Fab Insulating Vac Components and Hardware | 2010-07-01 → 2010-08-09 A (+39d) | 2010-07-08 → 2011-06-18 A (+345d) | 5d → 213d | 0% → 100% | 693d → none |  |  |
| 131136015a | Vend Fab - Vac Vessels Lot #1 Original Labor FY11 | 2010-10-01 → 2010-11-01 A (+31d) | 2010-10-06 → 2010-11-22 A (+47d) | 4d → 16d | 0% → 100% | 197d → none |  | resources SUPPLIES & MATERIALS; MECH ENG [2.13 h]; TRAVEL; SR STAFF [1.07 h]; MECH DES [2.13 h] → SR STAFF [1.07 h]; MECH DES [2.13 h]; SUPPLIES & MATERIALS; TRAVEL; MECH ENG [2.13 h] |
| 131136025 | Receive & Insp Vac Vessel Assembly #2 | 2010-09-01 → 2010-11-15 A (+75d) | 2010-09-30 → 2010-11-29 A (+60d) | 21d → 9d | 0% → 100% | 174d → none |  |  |
| 131136030 | Receive & Insp Vac Vessels Assembly #3 | 2010-10-01 → 2010-11-15 A (+45d) | 2010-10-29 → 2010-11-29 A (+31d) | 21d → 9d | 0% → 100% | 242d → none |  | resources MECH DES [8 h]; MECH TECH [40 h]; MECH ENG [8 h]; SUPPLIES & MATERIALS → MECH ENG [8 h]; SUPPLIES & MATERIALS; MECH DES [8 h]; MECH TECH [40 h] |
| 131136035 | Receive & Insp Vac Vessels Assembly #4 | 2010-11-01 → 2011-01-11 A (+71d) | 2010-11-30 → 2011-02-28 A (+90d) | 20d → 33d | 0% → 100% | 242d → none |  | resources MECH DES [8 h]; MECH TECH [40 h]; MECH ENG [8 h]; SUPPLIES & MATERIALS → MECH ENG [8 h]; SUPPLIES & MATERIALS; MECH DES [8 h]; MECH TECH [40 h] |
| 131136040 | Receive & Insp Vac Vessels Assembly #5 | 2010-12-01 → 2011-02-28 A (+89d) | 2011-01-10 → 2011-03-28 A (+77d) | 23d → 21d | 0% → 100% | 279d → none |  | resources MECH DES [4 h]; MECH TECH [40 h]; MECH ENG [4 h]; SUPPLIES & MATERIALS → SUPPLIES & MATERIALS; MECH DES [4 h]; MECH TECH [40 h]; MECH ENG [4 h] |
| 131136045 | Receive & Insp Vac Vessels Assembly #6 | 2011-02-01 → 2011-03-28 A (+55d) | 2011-02-28 → 2011-04-25 A (+56d) | 19d → 21d | 0% → 100% | 319d → none |  | resources MECH ENG [4 h]; SUPPLIES & MATERIALS; MECH DES [4 h]; MECH TECH [40 h] → SUPPLIES & MATERIALS; MECH DES [4 h]; MECH TECH [40 h]; MECH ENG [4 h] |
| 131136050 | Receive & Insp Vac Vessels Assembly #7 | 2011-03-01 → 2011-11-15 A (+259d) | 2011-03-31 → 2011-12-19 A (+263d) |  | 0% → 100% | 394d → none |  | resources MECH TECH [40 h]; SUPPLIES & MATERIALS; MECH DES [4 h]; MECH ENG [4 h] → SUPPLIES & MATERIALS; MECH DES [4 h]; MECH TECH [40 h]; MECH ENG [4 h] |
| 131136055 | Receive & Insp Vac Vessels Assembly #8 | 2011-04-01 → 2012-01-09 A (+283d) | 2011-04-29 → 2012-01-16 A (+262d) | 21d → 5d | 0% → 100% | 441d → none |  | resources MECH DES [4 h]; MECH TECH [40 h]; MECH ENG [4 h]; SUPPLIES & MATERIALS → MECH ENG [4 h]; SUPPLIES & MATERIALS; MECH DES [4 h]; MECH TECH [40 h] |
| 131136060 | Receive & Insp Vac Vessels Assembly #9 | 2011-05-02 → 2012-01-16 A (+259d) | 2011-05-31 → 2012-02-20 A (+265d) | 21d → 24d | 0% → 100% | 464d → none |  | resources MECH DES [4 h]; MECH TECH [40 h]; SUPPLIES & MATERIALS; MECH ENG [4 h] → MECH DES [4 h]; MECH TECH [40 h]; MECH ENG [4 h]; SUPPLIES & MATERIALS |
| 131136065 | Receive & Insp Vac Vessels Assembly #10 | 2011-06-01 → 2012-01-23 A (+236d) | 2011-06-30 → 2012-04-16 A (+291d) | 22d → 60d | 0% → 100% | 472d → none | 131136060, 131136016p, 131136017 → 131136017, 131136060 FS-20d, 131136016p | resources SUPPLIES & MATERIALS; MECH DES [4 h]; MECH TECH [40 h]; MECH ENG [4 h] → MECH ENG [4 h]; SUPPLIES & MATERIALS; MECH DES [4 h]; MECH TECH [40 h] |
| 131136070 | Re-Baseline Actuals Adjustment | 2013-08-30 A | 2013-08-30 A |  | 0% → 100% | 20d → none | 9-130M FS+227d → none |  |
| 131137010 | Proc Beam Pipes Labor FY09 | 2009-09-25 A | 2009-09-30 → 2010-01-25 A (+117d) | 4d → 77d | 0% → 100% | 176d → none |  | resources MECH DES [0.63 h]; MECH ENG [0.79 h] → MECH ENG [0.79 h]; MECH DES [0.63 h] |
| 131137012 | Vend Fab - Cold Valves 1-4 | 2009-09-25 A | 2010-02-26 A |  | 0% → 100% | 144d → none |  |  |
| 131137013 | Vend Fab - Cold Valves 5-8 | 2009-09-25 A | 2010-03-31 A |  | 0% → 100% | 144d → none |  |  |
| 131137014 | Vend Fab - Cold Valves 9-12 | 2009-09-25 A | 2010-03-31 A |  | 0% → 100% | 144d → none |  |  |
| 131137015 | Vend Fab - Cold Valves 13-16 | 2009-09-25 A | 2010-04-30 → 2010-04-26 A (-4d) | 146d → 142d | 0% → 100% | 144d → none |  |  |
| 131137016 | Vend Fab - Cold Valves 17-20 | 2009-09-25 A | 2010-04-30 → 2010-04-26 A (-4d) | 146d → 142d | 0% → 100% | 144d → none |  |  |
| 131137017 | Vend Fab - Cold Valves 21-22 | 2009-09-25 A | 2010-05-28 A |  | 0% → 100% | 144d → none |  |  |
| 131137010b | Proc Beam Pipes Labor FY10 | 2009-10-01 → 2009-09-30 A (-1d) | 2010-02-26 → 2010-01-25 A (-32d) | 97d → 74d | 0% → 100% | 176d → none | 131137010 → 131137010 FS-300d | resources MECH DES [15.37 h]; MECH ENG [19.21 h] → MECH ENG [19.21 h]; MECH DES [15.37 h] |
| 131137011 | Vendor Fab Cold Valves - Oversight | 2009-10-01 A | 2010-01-04 → 2009-12-23 A (-12d) | 60d → 55d | 0% → 100% | 172d → none |  | resources MECH DES [10 h]; MECH ENG [10 h]; SUPPLIES & MATERIALS → SUPPLIES & MATERIALS; MECH DES [10 h]; MECH ENG [10 h] |
| 131137025 | Vendor Fab Burst Disc | 2009-10-01 → 2009-11-02 A (+32d) | 2010-02-26 → 2009-11-26 A (-92d) | 97d → 18d | 0% → 100% | 272d → none |  | resources MECH ENG [10 h]; SUPPLIES & MATERIALS; PROCUREMENT<$50K 60; MECH DES [10 h] → MECH DES [10 h]; MECH ENG [10 h]; SUPPLIES & MATERIALS; PROCUREMENT<$50K 60 |
| 131137030 | Receive & Inspect Burst Disc | 2010-03-01 → 2009-11-23 A (-98d) | 2010-03-31 → 2009-12-21 A (-100d) | 23d → 18d | 0% → 100% | 272d → none |  |  |
| 131137020 | Receive & Inspect Cold Valves | 2010-02-16 A | 2010-05-28 A |  | 0% → 100% | 144d → none |  |  |
| 131137045 | Vendor Fab Warm Valves | 2009-12-04 → 2010-04-05 A (+122d) | 2010-08-27 → 2010-05-28 A (-91d) | 181d → 40d | 0% → 100% | 165d → none |  | resources SUPPLIES & MATERIALS; PROCUREMENT<$50K 60; MECH DES [10 h]; MECH ENG [10 h] → MECH DES [10 h]; MECH ENG [10 h]; PROCUREMENT<$50K 60; SUPPLIES & MATERIALS |
| 131137050 | Receive & Inspect Warm Valves | 2010-03-24 → 2010-05-28 A (+65d) | 2010-08-31 → 2010-06-30 A (-62d) | 113d → 23d | 0% → 100% | 165d → none |  | resources SUPPLIES & MATERIALS; MECH TECH [16 h]; MECH ENG [2 h]; MECH DES [1.6 h] → MECH DES [1.6 h]; SUPPLIES & MATERIALS; MECH TECH [16 h]; MECH ENG [2 h] |
| 131137034 | Vendor Fab Warm to Cold Beam Pipe - Oversight | 2010-01-05 → 2010-09-01 A (+239d) | 2010-08-27 → 2011-09-17 A (+386d) | 165d → 259d | 0% → 100% | 165d → none | 9-100M FS+60d → 9-100M FS+140d | resources MECH DES [10 h]; SUPPLIES & MATERIALS; MECH ENG [10 h] → MECH DES [10 h]; MECH ENG [10 h]; SUPPLIES & MATERIALS |
| 131137035 | Vendor Fab Warm to Cold Beam Pipe | 2010-07-01 → 2010-10-01 A (+92d) | 2010-12-30 → 2011-09-17 A (+261d) | 122d → 238d | 0% → 100% | 165d → none | 9-100M FS+184d → 9-100M FS+140d | resources PROCUREMENT>$50K 69 NO ESCALATION FY11; PROCUREMENT<$50K 60 NO ESCALATION FY11 → PROCUREMENT<$50K 60 NO ESCALATION FY11; PROCUREMENT>$50K 69 NO ESCALATION FY11 |
| 131137040 | Receive & Inspect Warm to Cold Beam Pipe | 2010-04-05 → 2010-12-01 A (+240d) | 2010-08-31 → 2011-09-30 A (+395d) | 105d → 207d | 0% → 100% | 165d → none | 131137035 FS-184d, 131137034 FS-103d → 131137035 FS-103d, 131137034 FS-103d | resources MECH TECH [32 h]; MECH ENG [4 h]; MECH DES [3.2 h]; SUPPLIES & MATERIALS → SUPPLIES & MATERIALS; MECH TECH [32 h]; MECH ENG [4 h]; MECH DES [3.2 h] |

| ID | Task | Start | Finish | Duration | Complete | Total float | Predecessors | Other |
| --- | --- | --- | --- | --- | --- | --- | --- | --- |
| 131137055 | Re-Baseline Actuals Adjustment | 2013-08-30 A | 2013-08-30 A |  | 0% → 100% | 20d → none | 9-130M FS+227d → none |  |
| 8 | **1.3.1.1.3.8 TOP HATS** | 2009-05-13 → 2009-07-03 (+51d) |  |  |  |  |  |  |
| 131138010 | Proc Top Hats Air Side FPC Components | 2009-05-13 → 2009-07-03 A (+51d) | 2009-08-06 → 2010-07-26 A (+354d) | 60d → 263d | 0% → 100% | 135d → none |  |  |
| 131138025 | Vendor Fab Vacuum Components Labor Initial | 2009-10-05 → 2009-12-01 A (+57d) | 2009-11-30 → 2010-02-05 A (+67d) | 39d → 42d | 0% → 100% | 144d → none | 131138010 FS+40d → 131138010 FS-200d | resources MECH ENG [26 h]; MECH TECH [26 h]; MECH DES [10.4 h]; TRAVEL; SUPPLIES & MATERIALS; ELEC ENG [13.2 h] → MECH ENG [26 h]; MECH TECH [26 h]; MECH DES [10.4 h]; SUPPLIES & MATERIALS; ELEC ENG [13.2 h]; TRAVEL |
| 131138025a5 | Vendor Fab Vacuum Components Procurement | 2009-10-05 → 2009-12-01 A (+57d) | 2010-08-31 → 2011-09-20 A (+385d) | 225d → 447d | 0% → 100% | 144d → none | 131138010 FS+40d → 131138010 FS-500d | was named Vendor Fab Vacuum Components Labor Procurement |
| 131138030 | Receive & Insp Vacuum Components | 2010-02-05 A | 2010-09-30 → 2011-12-19 A (+445d) | 166d → 468d | 0% → 100% | 144d → none |  | resources SUPPLIES & MATERIALS; ELEC TECH [40 h]; MECH TECH [120 h]; MECH DES [16 h]; MECH ENG [20 h] → MECH DES [16 h]; MECH ENG [20 h]; SUPPLIES & MATERIALS; ELEC TECH [40 h]; MECH TECH [120 h] |
| 131138025a | Vendor Fab Vacuum Components Labor Final | 2009-12-01 → 2010-02-08 A (+69d) | 2010-08-31 → 2011-09-19 A (+384d) | 186d → 404d | 0% → 100% | 144d → none |  | resources SUPPLIES & MATERIALS; ELEC ENG [7.2 h]; MECH ENG [14 h]; MECH TECH [14 h]; MECH DES [5.6 h]; TRAVEL → MECH TECH [14 h]; MECH DES [5.6 h]; SUPPLIES & MATERIALS; ELEC ENG [7.2 h]; TRAVEL; MECH ENG [14 h] |
| 131138037 | Diagnostic Components Procurement Lots 1 thru 4 | 2010-01-04 → 2010-04-26 A (+112d) | 2010-08-31 → 2011-09-20 A (+385d) | 168d → 351d | 0% → 100% | 78d → none | 131138010 FS+40d, 9-100M FS+59d → 131138010 FS-40d, 9-100M |  |
| 131138015c | Vend Fab - Warm Windows Lot 1 and 2 | 2009-08-07 → 2010-05-24 A (+290d) | 2010-05-28 → 2011-01-18 A (+235d) | 200d → 160d | 0% → 100% | 223d → none | 131138010 → 131138010 FS-500d | resources PROCUREMENT<$50K 60 NO ESCALATION FY10; PROCUREMENT>$50K 69 NO ESCALATION FY10 → PROCUREMENT>$50K 69 NO ESCALATION FY10; PROCUREMENT<$50K 60 NO ESCALATION FY10 |
| 131138035 | Support for Diagnostic Components Procurement | 2009-10-05 → 2010-05-24 A (+231d) | 2010-01-06 → 2011-09-19 A (+621d) | 60d → 330d | 0% → 100% | 223d → none | 131138010 FS+40d → 131138010 FS-70d | resources MECH DES [40 h]; MECH TECH [20 h]; SUPPLIES & MATERIALS; ELEC ENG [20 h]; TRAVEL; MECH ENG [40 h]; ELEC TECH [20 h] → MECH TECH [20 h]; SUPPLIES & MATERIALS; TRAVEL; MECH ENG [40 h]; MECH DES [40 h]; ELEC ENG [20 h]; ELEC TECH [20 h] |
| 131138015 | Vend Fab - Warm Windows Labor FY09 | 2009-08-07 → 2010-07-01 A (+328d) | 2009-09-30 → 2011-01-24 A (+481d) | 38d → 137d | 0% → 100% | 287d → none |  | resources SUPPLIES & MATERIALS; MECH TECH [10.13 h]; MECH ENG [25.33 h]; MECH DES [15.2 h]; TRAVEL; ELEC ENG [5.07 h] → MECH ENG [25.33 h]; ELEC ENG [5.07 h]; SUPPLIES & MATERIALS; TRAVEL; MECH DES [15.2 h]; MECH TECH [10.13 h] |
| 131138015b | Vend Fab - Warm Windows Labor FY10 Initial | 2009-10-01 → 2010-07-01 A (+273d) | 2009-11-30 → 2011-01-24 A (+420d) | 41d → 137d | 0% → 100% | 287d → none | 131138015 → 131138015 FS-230d | resources SUPPLIES & MATERIALS; MECH TECH [10.93 h]; MECH ENG [27.33 h]; MECH DES [16.4 h]; ELEC ENG [5.47 h]; TRAVEL → MECH ENG [27.33 h]; ELEC ENG [5.47 h]; SUPPLIES & MATERIALS; TRAVEL; MECH DES [16.4 h]; MECH TECH [10.93 h] |
| 131138015ba | Vend Fab - Warm Windows Labor FY10 Final | 2009-12-01 → 2010-07-01 A (+212d) | 2010-09-30 → 2011-01-24 A (+116d) | 207d → 137d | 0% → 100% | 287d → none | 131138015b → 131138015b FS-230d | resources ELEC ENG [9.46 h]; TRAVEL; SUPPLIES & MATERIALS; MECH TECH [18.94 h]; MECH ENG [47.34 h]; MECH DES [28.4 h] → MECH DES [28.4 h]; MECH TECH [18.94 h]; MECH ENG [47.34 h]; ELEC ENG [9.46 h]; SUPPLIES & MATERIALS; TRAVEL |
| 131138060LOE | SOTR Oversight FY10 | 2010-07-01 A | 2010-09-30 A |  | 0% → 100% | 435d → none |  |  |
| 131138040 | Receive & Insp Diagnostic Components Lot 1 | 2010-08-04 → 2010-07-12 A (-23d) | 2010-09-01 → 2010-09-17 A (+16d) | 21d → 49d | 0% → 100% | 78d → none | 131138010, 131138037 FS-20d, 131138035 → 131138037 FS-110d, 131138035 FS-110d, 131138010 | resources MECH ENG [20 h]; SUPPLIES & MATERIALS; ELEC ENG [20 h]; ELEC TECH [20 h]; MECH TECH [20 h]; MECH DES [20 h] → ELEC TECH [20 h]; MECH TECH [20 h]; SUPPLIES & MATERIALS; MECH ENG [20 h]; MECH DES [20 h]; ELEC ENG [20 h] |
| 131138015d | Vend Fab - Warm Windows Lot 3 and 4 | 2010-07-30 → 2010-08-02 A (+3d) | 2011-07-29 → 2012-03-12 A (+227d) | 248d → 397d | 0% → 100% | 398d → none |  |  |
| 131138015f | Vend Fab - Warm Windows Coatings | 2010-07-30 → 2010-08-02 A (+3d) | 2011-07-29 → 2012-03-12 A (+227d) | 248d → 397d | 0% → 100% | 398d → none |  |  |
| 131138020 | Receive & Insp Warm Windows Lot 1 | 2010-06-01 → 2010-08-09 A (+69d) | 2010-06-30 → 2010-10-25 A (+117d) | 22d → 55d | 0% → 100% | 223d → none | 131138015ba FS-150d, 131138015c → 131138015c FS-80d, 131138015ba FS-250d | resources MECH ENG [20 h]; MECH TECH [30 h]; SUPPLIES & MATERIALS; ELEC TECH [10 h]; ELEC ENG [10 h]; MECH DES [10 h] → MECH DES [10 h]; MECH ENG [20 h]; MECH TECH [30 h]; SUPPLIES & MATERIALS; ELEC ENG [10 h]; ELEC TECH [10 h] |
| 131138045 | Receive & Insp Diagnostic Components Lot 2 FY10 | 2010-09-02 → 2010-08-23 A (-10d) | 2010-09-30 → 2011-01-20 A (+112d) | 20d → 99d | 0% → 100% | 237d → none | 131138040 → 131138040 FS-50d | resources ELEC TECH [16 h]; MECH TECH [16 h]; MECH DES [16 h]; MECH ENG [16 h]; SUPPLIES & MATERIALS; ELEC ENG [16 h] → SUPPLIES & MATERIALS; ELEC ENG [16 h]; ELEC TECH [16 h]; MECH TECH [16 h]; MECH DES [16 h]; MECH ENG [16 h] |
| 131138045a | Receive & Insp Diagnostic Components Lot 2 FY11 | 2010-10-01 → 2010-08-23 A (-39d) | 2010-10-07 → 2011-01-20 A (+105d) | 5d → 99d | 0% → 100% | 237d → none | 131138045 → 131138045 FS-70d | resources ELEC TECH [4 h]; MECH DES [4 h]; MECH ENG [4 h]; SUPPLIES & MATERIALS; ELEC ENG [4 h]; MECH TECH [4 h] → SUPPLIES & MATERIALS; ELEC ENG [4 h]; ELEC TECH [4 h]; MECH TECH [4 h]; MECH DES [4 h]; MECH ENG [4 h] |
| 131138020b | Receive & Insp Warm Windows Lot 2 FY10 | 2010-07-01 → 2010-09-02 A (+63d) | 2010-09-30 → 2011-01-27 A (+119d) | 64d → 96d | 0% → 100% | 317d → none | 131138020, 131138015c, 131138020a → 131138020 FS-45d, 131138015c FS-75d, 131138020a FS-45d | resources ELEC TECH [7.11 h]; ELEC ENG [7.11 h]; MECH DES [7.11 h]; MECH ENG [14.22 h]; MECH TECH [21.33 h]; SUPPLIES & MATERIALS → MECH ENG [14.22 h]; MECH TECH [21.33 h]; ELEC ENG [7.11 h]; ELEC TECH [7.11 h]; MECH DES [7.11 h]; SUPPLIES & MATERIALS |
| 131138020ba | Receive & Insp Warm Windows Lot 2 FY11 | 2010-10-01 → 2010-09-02 A (-29d) | 2010-11-05 → 2011-01-27 A (+83d) | 26d → 96d | 0% → 100% | 317d → none | 131138020b → 131138020b FS-75d | resources ELEC TECH [2.89 h]; ELEC ENG [2.89 h]; MECH DES [2.89 h]; MECH ENG [5.78 h]; MECH TECH [8.67 h]; SUPPLIES & MATERIALS → SUPPLIES & MATERIALS; ELEC ENG [2.89 h]; MECH DES [2.89 h]; ELEC TECH [2.89 h]; MECH ENG [5.78 h]; MECH TECH [8.67 h] |
| 131138065LOE | SOTR Oversight FY11 | 2010-10-01 A | 2011-08-23 A |  | 0% → 100% | 435d → none |  |  |
| 131138020a | Acceptance Warm Windows Phase 1 | 2010-06-30 → 2010-10-18 A (+110d) | 2010-06-30 → 2010-11-29 A (+152d) | 1d → 29d | 0% → 100% | 317d → none |  |  |
| 131138020d | Receive & Insp Warm Windows Lot 3 | 2010-11-08 → 2011-03-01 A (+113d) | 2011-03-25 → 2011-09-30 A (+189d) | 90d → 151d | 0% → 100% | 398d → none |  | resources ELEC TECH [10 h]; ELEC ENG [10 h]; MECH DES [10 h]; MECH ENG [20 h]; MECH TECH [30 h]; SUPPLIES & MATERIALS → MECH TECH [30 h]; SUPPLIES & MATERIALS; ELEC ENG [10 h]; ELEC TECH [10 h]; MECH DES [10 h]; MECH ENG [20 h] |
| 131138020g | Receive & Insp Warm Windows Lot 4 | 2011-04-18 → 2011-03-02 A (-47d) | 2011-08-23 → 2012-03-12 A (+202d) | 90d → 256d | 0% → 100% | 405d → none | 131138015f FS-73d, 131138015d FS-73d → 131138015f FS-90d, 131138015d FS-90d | resources ELEC TECH [10 h]; ELEC ENG [10 h]; MECH DES [10 h]; MECH ENG [20 h]; MECH TECH [30 h]; SUPPLIES & MATERIALS → MECH DES [10 h]; MECH ENG [20 h]; MECH TECH [30 h]; SUPPLIES & MATERIALS; ELEC ENG [10 h]; ELEC TECH [10 h] |
| 131138050 | Receive & Insp Diagnostic Components Lot 3 | 2010-10-08 → 2011-04-11 A (+185d) | 2010-11-11 → 2011-08-16 A (+278d) | 25d → 90d | 0% → 100% | 308d → none |  | resources MECH TECH [20 h]; MECH DES [20 h]; MECH ENG [20 h]; SUPPLIES & MATERIALS; ELEC ENG [20 h]; ELEC TECH [20 h] → MECH ENG [20 h]; SUPPLIES & MATERIALS; ELEC ENG [20 h]; ELEC TECH [20 h]; MECH TECH [20 h]; MECH DES [20 h] |
| 131138055 | Receive & Insp Diagnostic Components Lot 4 | 2010-11-12 → 2011-04-20 A (+159d) | 2010-12-20 → 2011-11-15 A (+330d) | 25d → 147d | 0% → 100% | 334d → none | 131138050 → 131138050 FS-40d |  |
| 131138070 | Re-Baseline Actuals Adjustment | 2013-08-30 A | 2013-08-30 A |  | 0% → 100% | 20d → none | 9-130M FS+227d → none |  |
| 9 | **1.3.1.1.3.9 SUPPORTS** | 2009-10-01 → 2009-07-01 (-92d) |  |  |  |  |  |  |
| 131139010 | Proc Supprts | 2009-10-01 → 2009-07-01 A (-92d) | 2009-12-11 → 2009-11-23 A (-18d) | 50d → 102d | 0% → 100% | 261d → none | 9-100M → 9-100M FS-500d | resources MECH ENG [20 h]; MECH DES [16 h] → MECH DES [16 h]; MECH ENG [20 h] |
| 131139015 | Vend Fab - Supprts | 2009-12-14 → 2009-11-23 A (-21d) | 2010-03-24 → 2010-03-29 A (+5d) | 65d → 81d | 0% → 100% | 261d → none |  |  |
| 131139025 | Receive & Insp Supprts | 2010-03-25 → 2009-11-24 A (-121d) | 2010-04-15 → 2010-03-29 A (-17d) | 16d → 80d | 0% → 100% | 261d → none |  | resources SUPPLIES & MATERIALS; MECH TECH [40 h] → MECH TECH [40 h]; SUPPLIES & MATERIALS |
| 131139020 | Additional Support Baseplates | 2010-07-12 → 2010-07-02 A (-10d) | 2010-07-16 → 2010-07-19 A (+3d) | 5d → 11d | 0% → 100% | 261d → none |  |  |
| 131139030 | Re-Baseline Actuals Adjustment | 2013-08-30 A | 2013-08-30 A |  | 0% → 100% | 20d → none | 9-130M FS+227d → none |  |
| 4 | **1.3.1.1.4 INSTALLATION AND ASSEMBLY TOOLING PROCUREMENTS** | 2009-10-01 → 2010-02-01 (+123d) |  |  |  |  |  |  |
| 13114010 | Vend Fab - Installtn & Assy Tooling | 2009-10-01 → 2010-02-01 A (+123d) | 2010-03-31 → 2010-08-30 A (+152d) | 120d → 148d | 0% → 100% | 212d → none |  |  |
| 13114015 | Receive & Insp Installtn & Assy Tooling | 2010-04-01 → 2010-02-15 A (-45d) | 2010-04-28 → 2010-08-31 A (+125d) | 20d → 139d | 0% → 100% | 212d → none |  | resources MECH DES [320 h]; MECH ENG [160 h]; SUPPLIES & MATERIALS → MECH ENG [160 h]; SUPPLIES & MATERIALS; MECH DES [320 h] |
| 13114012 | Vend Fab - Installtn & Assy Tooling Phase 2 | 2010-07-01 A | 2010-09-30 → 2011-03-18 A (+169d) | 64d → 175d | 0% → 100% | 79d → none |  |  |
| 13114020 | Receive & Insp Installtn & Assy Tooling Phase 2 FY10 | 2010-09-10 → 2010-08-23 A (-18d) | 2010-09-30 → 2010-11-22 A (+53d) | 15d → 65d | 0% → 100% | 79d → none | 13114012 FS-15d → 13114012 FS-50d |  |
| 13114020a | Receive & Insp Installtn & Assy Tooling Phase 2 FY11 | 2010-10-01 → 2010-08-23 A (-39d) | 2010-11-04 → 2011-04-26 A (+173d) | 25d → 165.37d | 0% → 100% | 79d → none | 13114020 → 13114012 FS-50d | resources MECH ENG [550 h]; MECH TECH [750 h]; SUPPLIES & MATERIALS; MECH DES [1250 h] → SUPPLIES & MATERIALS; MECH DES [1250 h]; MECH ENG [550 h]; MECH TECH [750 h] |
| 13114025 | Re-Baseline Actuals Adjustment | 2013-08-30 A | 2013-08-30 A |  | 0% → 100% | 20d → none | 9-130M FS+227d → none |  |
| 5 | **1.3.1.1.5 CRYOMODULE TEST INSTRUMENTATION & INTERLOCKS PROCUREMENT** | 2009-10-01 → 2010-02-01 (+123d) | 2010-02-02 → 2010-02-01 (-1d) |  |  |  |  |  |
| 13115010 | Vend Fab - Instrmenttn & Interlocks | 2009-10-01 → 2010-02-01 A (+123d) | 2010-01-04 → 2010-02-01 A (+28d) | 60d → 1d | 0% → 100% | 312d → none |  |  |
| 13115015 | Receive & Insp Instrmenttn & Interlocks | 2010-01-05 → 2010-02-01 A (+27d) | 2010-02-02 → 2010-02-01 A (-1d) | 20d → 1d | 0% → 100% | 312d → none |  |  |
| 2 | **1.3.1.2 CAVITY STRING ASSEMBLY** | 2010-08-05 → 2010-10-25 (+81d) |  |  |  |  |  |  |
| 1312000 | Re-Baseline Actuals Adjustment | 2013-08-30 A | 2013-08-30 A |  | 0% → 100% | 20d → none | 9-130M FS+227d → none |  |
| 1 | **1.3.1.2.1 CAVITY PREPARATION** | 2010-08-05 → 2010-11-01 (+88d) | 2011-11-16 → 2012-02-07 (+83d) |  |  |  |  |  |
| 01 | **1.3.1.2.1.01 CAVITY STRING #1 PREPERATION** | 2010-08-05 → 2010-11-01 (+88d) | 2010-11-05 → 2010-12-28 (+53d) |  |  |  |  |  |
| 1312101005 | Cavity String #1 Helium Vessel Welding | 2010-08-05 → 2010-11-01 A (+88d) | 2010-08-25 → 2010-12-10 A (+107d) | 15d → 28d | 0% → 100% | 57d → none |  | resources ELEC TECH [8 h]; MECH DES [4 h]; MECH ENG [8 h]; MECH TECH [120 h]; SUPPLIES & MATERIALS → MECH DES [4 h]; MECH ENG [8 h]; MECH TECH [120 h]; SUPPLIES & MATERIALS; ELEC TECH [8 h] |
| 1312101030 | Cavity #1 VTA Run | 2010-09-10 → 2010-11-08 A (+59d) | 2010-09-16 → 2010-11-22 A (+67d) | 5d → 11d | 0% → 100% | 37d → none |  | resources SCIENTIST [8 h]; SR STAFF [8 h]; COMP SCIENT [8 h]; ELEC ENG [8 h]; ELEC TECH [8 h]; MECH DES [8 h]; MECH ENG [8 h]; MECH TECH [8 h] → MECH TECH [8 h]; SCIENTIST [8 h]; SR STAFF [8 h]; COMP SCIENT [8 h]; ELEC ENG [8 h]; ELEC TECH [8 h]; MECH DES [8 h]; MECH ENG [8 h] |
| 1312101002 | Cavity String #1 Cavity Processing | 2010-11-01 → 2010-12-01 A (+30d) | 2010-11-05 → 2010-12-06 A (+31d) | 5d → 4d | 0% → 100% | 101d → none |  |  |
| 1312101035 | Cavity #2 VTA Run | 2010-09-15 → 2010-12-13 A (+89d) | 2010-09-21 → 2010-12-14 A (+84d) | 5d → 2d | 0% → 100% | 37d → none |  | resources SCIENTIST [8 h]; SR STAFF [8 h]; COMP SCIENT [8 h]; ELEC ENG [8 h]; MECH ENG [8 h]; ELEC TECH [8 h]; MECH DES [8 h]; MECH TECH [8 h] → MECH TECH [8 h]; SCIENTIST [8 h]; SR STAFF [8 h]; COMP SCIENT [8 h]; ELEC ENG [8 h]; ELEC TECH [8 h]; MECH DES [8 h]; MECH ENG [8 h] |
| 1312101040 | Cavity #3 VTA Run | 2010-09-20 → 2010-12-15 A (+86d) | 2010-09-24 → 2010-12-16 A (+83d) | 5d → 2d | 0% → 100% | 37d → none |  | resources COMP SCIENT [8 h]; ELEC ENG [8 h]; ELEC TECH [8 h]; MECH DES [8 h]; MECH ENG [8 h]; MECH TECH [8 h]; SCIENTIST [8 h]; SR STAFF [8 h] → ELEC TECH [8 h]; MECH DES [8 h]; MECH ENG [8 h]; MECH TECH [8 h]; SCIENTIST [8 h]; SR STAFF [8 h]; COMP SCIENT [8 h]; ELEC ENG [8 h] |
| 1312101045 | Cavity #4 VTA Run | 2010-09-23 → 2010-12-17 A (+85d) | 2010-09-29 → 2010-12-20 A (+82d) | 5d → 2d | 0% → 100% | 37d → none |  | resources MECH DES [8 h]; MECH ENG [8 h]; MECH TECH [8 h]; SCIENTIST [8 h]; SR STAFF [8 h]; COMP SCIENT [8 h]; ELEC ENG [8 h]; ELEC TECH [8 h] → MECH DES [8 h]; MECH TECH [8 h]; SCIENTIST [8 h]; SR STAFF [8 h]; COMP SCIENT [8 h]; ELEC ENG [8 h]; ELEC TECH [8 h]; MECH ENG [8 h] |
| 1312101050 | Cavity #5 VTA Run FY10 | 2010-09-28 → 2010-12-20 A (+83d) | 2010-09-30 → 2010-12-21 A (+82d) | 3d → 2d | 0% → 100% | 37d → none |  | resources MECH DES [4.8 h]; MECH ENG [4.8 h]; MECH TECH [4.8 h]; SCIENTIST [4.8 h]; SR STAFF [4.8 h]; COMP SCIENT [4.8 h]; ELEC ENG [4.8 h]; ELEC TECH [4.8 h] → SR STAFF [4.8 h]; COMP SCIENT [4.8 h]; ELEC ENG [4.8 h]; ELEC TECH [4.8 h]; MECH DES [4.8 h]; MECH ENG [4.8 h]; MECH TECH [4.8 h]; SCIENTIST [4.8 h] |
| 1312101050a | Cavity #5 VTA Run FY11 | 2010-10-01 → 2010-12-20 A (+80d) | 2010-10-04 → 2010-12-21 A (+78d) |  | 0% → 100% | 37d → none | 1312101050 → 1312101045 FS-2d, 1312101050 | resources ELEC TECH [3.2 h]; MECH DES [3.2 h]; MECH ENG [3.2 h]; MECH TECH [3.2 h]; SCIENTIST [3.2 h]; SR STAFF [3.2 h]; COMP SCIENT [3.2 h]; ELEC ENG [3.2 h] → MECH ENG [3.2 h]; MECH TECH [3.2 h]; SCIENTIST [3.2 h]; SR STAFF [3.2 h]; COMP SCIENT [3.2 h]; ELEC ENG [3.2 h]; ELEC TECH [3.2 h]; MECH DES [3.2 h] |
| 1312101055 | Cavity #6 VTA Run | 2010-10-01 → 2010-12-21 A (+81d) | 2010-10-07 → 2010-12-22 A (+76d) | 5d → 1d | 0% → 100% | 37d → none | 1312101050a FS-2d → 1312101050 FS-2d, 1312101050a FS-2d | resources ELEC TECH [8 h]; MECH DES [8 h]; MECH ENG [8 h]; MECH TECH [8 h]; SCIENTIST [8 h]; SR STAFF [8 h]; COMP SCIENT [8 h]; ELEC ENG [8 h] → MECH TECH [8 h]; SCIENTIST [8 h]; SR STAFF [8 h]; COMP SCIENT [8 h]; ELEC ENG [8 h]; ELEC TECH [8 h]; MECH DES [8 h]; MECH ENG [8 h] |
| 1312101060 | Cavity #7 VTA Run | 2010-10-06 → 2010-12-22 A (+77d) | 2010-10-12 → 2010-12-23 A (+72d) |  | 0% → 100% | 37d → none |  | resources SCIENTIST [8 h]; SR STAFF [8 h]; COMP SCIENT [8 h]; ELEC ENG [8 h]; ELEC TECH [8 h]; MECH DES [8 h]; MECH ENG [8 h]; MECH TECH [8 h] → MECH DES [8 h]; MECH ENG [8 h]; MECH TECH [8 h]; SCIENTIST [8 h]; SR STAFF [8 h]; COMP SCIENT [8 h]; ELEC ENG [8 h]; ELEC TECH [8 h] |
| 1312101065 | Cavity #8 VTA Run | 2010-10-11 → 2010-12-27 A (+77d) | 2010-10-15 → 2010-12-28 A (+74d) |  | 0% → 100% | 37d → none |  | resources MECH TECH [8 h]; SCIENTIST [8 h]; SR STAFF [8 h]; COMP SCIENT [8 h]; ELEC ENG [8 h]; ELEC TECH [8 h]; MECH DES [8 h]; MECH ENG [8 h] → MECH TECH [8 h]; COMP SCIENT [8 h]; ELEC ENG [8 h]; ELEC TECH [8 h]; MECH DES [8 h]; MECH ENG [8 h]; SCIENTIST [8 h]; SR STAFF [8 h] |
| 02 | **1.3.1.2.1.02 CAVITY STRING #2 PREPARATION** | 2010-10-08 → 2011-01-12 (+96d) | 2010-11-19 → 2011-03-07 (+108d) |  |  |  |  |  |
| 1312102002 | Cavity String #2 Cavity Processing | 2010-11-08 → 2011-01-12 A (+65d) | 2010-11-12 → 2011-02-28 A (+108d) | 5d → 32d | 0% → 100% | 101d → none | 1311122020, 1312101002, 1311122015 → 1311122015, 1312101002 FS+20d, 1311122020 | resources MECH ENG [12.4 h]; MECH TECH [178 h]; SUPPLIES & MATERIALS → SUPPLIES & MATERIALS; MECH ENG [12.4 h]; MECH TECH [178 h] |
| 1312102005 | Cavity String #2 Helium Vessel Welding | 2010-10-08 → 2011-01-12 A (+96d) | 2010-10-28 → 2011-02-21 A (+116d) | 15d → 27d | 0% → 100% | 37d → none |  |  |
| 1312102030 | Cavity #9 VTA Run | 2010-10-15 → 2011-01-17 A (+94d) | 2010-10-21 → 2011-01-21 A (+92d) | 5d → 4d | 0% → 100% | 37d → none |  | resources SCIENTIST [8 h]; ELEC TECH [8 h]; MECH DES [8 h]; MECH ENG [8 h]; MECH TECH [8 h]; SR STAFF [8 h]; COMP SCIENT [8 h]; ELEC ENG [8 h] → COMP SCIENT [8 h]; ELEC ENG [8 h]; ELEC TECH [8 h]; MECH DES [8 h]; MECH ENG [8 h]; MECH TECH [8 h]; SCIENTIST [8 h]; SR STAFF [8 h] |
| 1312102035 | Cavity #10 VTA Run | 2010-10-20 → 2011-01-24 A (+96d) | 2010-10-26 → 2011-01-28 A (+94d) |  | 0% → 100% | 37d → none |  | resources MECH ENG [8 h]; MECH TECH [8 h]; SCIENTIST [8 h]; SR STAFF [8 h]; COMP SCIENT [8 h]; ELEC ENG [8 h]; ELEC TECH [8 h]; MECH DES [8 h] → MECH TECH [8 h]; SCIENTIST [8 h]; SR STAFF [8 h]; COMP SCIENT [8 h]; ELEC ENG [8 h]; ELEC TECH [8 h]; MECH ENG [8 h]; MECH DES [8 h] |
| 1312102040 | Cavity #11 VTA Run | 2010-10-25 → 2011-01-31 A (+98d) | 2010-10-29 → 2011-02-21 A (+115d) | 5d → 15d | 0% → 100% | 37d → none |  | resources ELEC ENG [8 h]; ELEC TECH [8 h]; MECH DES [8 h]; MECH ENG [8 h]; MECH TECH [8 h]; SCIENTIST [8 h]; SR STAFF [8 h]; COMP SCIENT [8 h] → ELEC ENG [8 h]; COMP SCIENT [8 h]; ELEC TECH [8 h]; MECH DES [8 h]; MECH ENG [8 h]; MECH TECH [8 h]; SCIENTIST [8 h]; SR STAFF [8 h] |
| 1312102045 | Cavity #12 VTA Run | 2010-10-28 → 2011-02-01 A (+96d) | 2010-11-03 → 2011-02-21 A (+110d) | 5d → 14d | 0% → 100% | 37d → none |  | resources SR STAFF [8 h]; COMP SCIENT [8 h]; ELEC ENG [8 h]; ELEC TECH [8 h]; MECH DES [8 h]; MECH ENG [8 h]; MECH TECH [8 h]; SCIENTIST [8 h] → SCIENTIST [8 h]; SR STAFF [8 h]; COMP SCIENT [8 h]; ELEC ENG [8 h]; ELEC TECH [8 h]; MECH DES [8 h]; MECH ENG [8 h]; MECH TECH [8 h] |
| 1312102050 | Cavity #13 VTA Run | 2010-11-02 → 2011-02-01 A (+91d) | 2010-11-08 → 2011-02-28 A (+112d) | 5d → 19d | 0% → 100% | 37d → none |  | resources MECH DES [8 h]; MECH ENG [8 h]; MECH TECH [8 h]; SCIENTIST [8 h]; SR STAFF [8 h]; COMP SCIENT [8 h]; ELEC ENG [8 h]; ELEC TECH [8 h] → SR STAFF [8 h]; COMP SCIENT [8 h]; ELEC ENG [8 h]; ELEC TECH [8 h]; MECH DES [8 h]; MECH ENG [8 h]; MECH TECH [8 h]; SCIENTIST [8 h] |
| 1312102055 | Cavity #14 VTA Run | 2010-11-05 → 2011-02-01 A (+88d) | 2010-11-11 → 2011-02-28 A (+109d) | 5d → 19d | 0% → 100% | 37d → none |  | resources MECH ENG [8 h]; MECH TECH [8 h]; SCIENTIST [8 h]; SR STAFF [8 h]; COMP SCIENT [8 h]; ELEC ENG [8 h]; ELEC TECH [8 h]; MECH DES [8 h] → MECH DES [8 h]; MECH ENG [8 h]; MECH TECH [8 h]; SCIENTIST [8 h]; SR STAFF [8 h]; COMP SCIENT [8 h]; ELEC ENG [8 h]; ELEC TECH [8 h] |
| 1312102060 | Cavity #15 VTA Run | 2010-11-10 → 2011-02-01 A (+83d) | 2010-11-16 → 2011-02-28 A (+104d) | 5d → 19d | 0% → 100% | 37d → none |  | resources MECH ENG [8 h]; MECH TECH [8 h]; SCIENTIST [8 h]; SR STAFF [8 h]; COMP SCIENT [8 h]; ELEC ENG [8 h]; ELEC TECH [8 h]; MECH DES [8 h] → ELEC TECH [8 h]; MECH DES [8 h]; MECH ENG [8 h]; MECH TECH [8 h]; SCIENTIST [8 h]; SR STAFF [8 h]; COMP SCIENT [8 h]; ELEC ENG [8 h] |

| ID | Task | Start | Finish | Duration | Complete | Total float | Other |
| --- | --- | --- | --- | --- | --- | --- | --- |
| 1312102065 | Cavity #16 VTA Run | 2010-11-15 → 2011-02-01 A (+78d) | 2010-11-19 → 2011-03-07 A (+108d) | 5d → 24d | 0% → 100% | 37d → none | resources MECH DES [8 h]; MECH ENG [8 h]; MECH TECH [8 h]; SCIENTIST [8 h]; SR STAFF [8 h]; COMP SCIENT [8 h]; ELEC ENG [8 h]; ELEC TECH [8 h] → COMP SCIENT [8 h]; ELEC ENG [8 h]; ELEC TECH [8 h]; MECH DES [8 h]; MECH ENG [8 h]; MECH TECH [8 h]; SCIENTIST [8 h]; SR STAFF [8 h] |
| 03 | **1.3.1.2.1.03 CAVITY STRING #3 PREPARATION** | 2010-11-15 → 2011-02-01 (+78d) | 2011-02-01 → 2011-04-25 (+83d) |  |  |  |  |
| 1312103005 | Cavity String #3 Cavity Process & He Vs Weld | 2010-11-15 → 2011-02-01 A (+78d) | 2010-12-08 → 2011-03-21 A (+103d) | 16d → 34d | 0% → 100% | 101d → none | resources ELEC TECH [8 h]; MECH DES [4 h]; MECH ENG [20.4 h]; MECH TECH [298 h]; SUPPLIES & MATERIALS → MECH DES [4 h]; MECH ENG [20.4 h]; MECH TECH [298 h]; SUPPLIES & MATERIALS; ELEC TECH [8 h] |
| 1312103030 | Cavity #17 VTA Run | 2010-11-23 → 2011-03-02 A (+99d) | 2010-12-01 → 2011-03-28 A (+117d) | 5d → 19d | 0% → 100% | 101d → none | resources SR STAFF [8 h]; COMP SCIENT [8 h]; ELEC ENG [8 h]; ELEC TECH [8 h]; MECH DES [8 h]; MECH ENG [8 h]; MECH TECH [8 h]; SCIENTIST [8 h] → MECH DES [8 h]; MECH ENG [8 h]; MECH TECH [8 h]; SCIENTIST [8 h]; SR STAFF [8 h]; COMP SCIENT [8 h]; ELEC ENG [8 h]; ELEC TECH [8 h] |
| 1312103035 | Cavity #18 VTA Run | 2010-11-30 → 2011-03-02 A (+92d) | 2010-12-06 → 2011-03-28 A (+112d) | 5d → 19d | 0% → 100% | 101d → none | resources MECH DES [8 h]; MECH TECH [8 h]; MECH ENG [8 h]; SR STAFF [8 h]; SCIENTIST [8 h]; COMP SCIENT [8 h]; ELEC ENG [8 h]; ELEC TECH [8 h] → MECH ENG [8 h]; MECH TECH [8 h]; SCIENTIST [8 h]; SR STAFF [8 h]; COMP SCIENT [8 h]; ELEC ENG [8 h]; ELEC TECH [8 h]; MECH DES [8 h] |
| 1312103040 | Cavity #19 VTA Run | 2010-12-03 → 2011-03-02 A (+89d) | 2010-12-09 → 2011-03-28 A (+109d) | 5d → 19d | 0% → 100% | 101d → none | resources SR STAFF [8 h]; COMP SCIENT [8 h]; ELEC ENG [8 h]; ELEC TECH [8 h]; MECH DES [8 h]; MECH ENG [8 h]; MECH TECH [8 h]; SCIENTIST [8 h] → ELEC TECH [8 h]; MECH DES [8 h]; MECH ENG [8 h]; SR STAFF [8 h]; SCIENTIST [8 h]; MECH TECH [8 h]; COMP SCIENT [8 h]; ELEC ENG [8 h] |
| 1312103045 | Cavity #20 VTA Run | 2010-12-08 → 2011-03-02 A (+84d) | 2010-12-14 → 2011-03-28 A (+104d) | 5d → 19d | 0% → 100% | 101d → none | resources SCIENTIST [8 h]; SR STAFF [8 h]; COMP SCIENT [8 h]; ELEC ENG [8 h]; ELEC TECH [8 h]; MECH DES [8 h]; MECH TECH [8 h]; MECH ENG [8 h] → MECH ENG [8 h]; MECH TECH [8 h]; SCIENTIST [8 h]; SR STAFF [8 h]; COMP SCIENT [8 h]; ELEC ENG [8 h]; ELEC TECH [8 h]; MECH DES [8 h] |
| 1312103050 | Cavity #21 VTA Run | 2010-12-13 → 2011-03-02 A (+79d) | 2010-12-17 → 2011-03-28 A (+101d) | 5d → 19d | 0% → 100% | 101d → none | resources MECH DES [8 h]; MECH ENG [8 h]; MECH TECH [8 h]; SCIENTIST [8 h]; SR STAFF [8 h]; COMP SCIENT [8 h]; ELEC ENG [8 h]; ELEC TECH [8 h] → SCIENTIST [8 h]; SR STAFF [8 h]; COMP SCIENT [8 h]; ELEC ENG [8 h]; ELEC TECH [8 h]; MECH DES [8 h]; MECH ENG [8 h]; MECH TECH [8 h] |
| 1312103055 | Cavity #22 VTA Run | 2011-01-18 → 2011-03-02 A (+43d) | 2011-01-24 → 2011-03-28 A (+63d) | 5d → 19d | 0% → 100% | 99d → none | resources MECH TECH [8 h]; SCIENTIST [8 h]; SR STAFF [8 h]; COMP SCIENT [8 h]; ELEC ENG [8 h]; ELEC TECH [8 h]; MECH DES [8 h]; MECH ENG [8 h] → SR STAFF [8 h]; COMP SCIENT [8 h]; ELEC ENG [8 h]; ELEC TECH [8 h]; MECH DES [8 h]; MECH ENG [8 h]; MECH TECH [8 h]; SCIENTIST [8 h] |
| 1312103060 | Cavity #23 VTA Run | 2011-01-21 → 2011-04-02 A (+71d) | 2011-01-27 → 2011-04-25 A (+88d) | 5d → 16d | 0% → 100% | 99d → none | resources MECH DES [8 h]; MECH ENG [8 h]; SCIENTIST [8 h]; SR STAFF [8 h]; COMP SCIENT [8 h]; ELEC ENG [8 h]; MECH TECH [8 h]; ELEC TECH [8 h] → ELEC ENG [8 h]; ELEC TECH [8 h]; MECH DES [8 h]; MECH ENG [8 h]; MECH TECH [8 h]; SCIENTIST [8 h]; SR STAFF [8 h]; COMP SCIENT [8 h] |
| 1312103065 | Cavity #24 VTA Run | 2011-01-26 → 2011-04-05 A (+69d) | 2011-02-01 → 2011-04-25 A (+83d) | 5d → 15d | 0% → 100% | 99d → none | resources ELEC ENG [8 h]; ELEC TECH [8 h]; MECH DES [8 h]; MECH ENG [8 h]; MECH TECH [8 h]; SCIENTIST [8 h]; SR STAFF [8 h]; COMP SCIENT [8 h] → ELEC ENG [8 h]; ELEC TECH [8 h]; MECH DES [8 h]; MECH TECH [8 h]; MECH ENG [8 h]; SCIENTIST [8 h]; SR STAFF [8 h]; COMP SCIENT [8 h] |
| 04 | **1.3.1.2.1.04 CAVITY STRING #4 PREPARATION** | 2010-12-09 → 2011-03-02 (+83d) | 2011-03-08 → 2011-06-08 (+92d) |  |  |  |  |
| 1312104005 | Cavity String #4 Cavity Process & He Vs Weld | 2010-12-09 → 2011-03-02 A (+83d) | 2011-01-07 → 2011-05-23 A (+136d) | 16d → 59d | 0% → 100% | 123d → none | resources MECH ENG [20.4 h]; MECH TECH [298 h]; SUPPLIES & MATERIALS; ELEC TECH [8 h]; MECH DES [4 h] → MECH DES [4 h]; MECH ENG [20.4 h]; MECH TECH [298 h]; SUPPLIES & MATERIALS; ELEC TECH [8 h] |
| 1312104030 | Cavity#25 VTA Run | 2011-01-31 → 2011-04-04 A (+63d) | 2011-02-04 → 2011-04-25 A (+80d) | 5d → 16d | 0% → 100% | 99d → none | resources ELEC TECH [8 h]; MECH DES [8 h]; MECH ENG [8 h]; MECH TECH [8 h]; SR STAFF [8 h]; SCIENTIST [8 h]; COMP SCIENT [8 h]; ELEC ENG [8 h] → COMP SCIENT [8 h]; ELEC ENG [8 h]; ELEC TECH [8 h]; MECH DES [8 h]; MECH ENG [8 h]; MECH TECH [8 h]; SR STAFF [8 h]; SCIENTIST [8 h] |
| 1312104035 | Cavity#26 VTA Run | 2011-02-03 → 2011-04-13 A (+69d) | 2011-02-09 → 2011-04-19 A (+69d) |  | 0% → 100% | 99d → none | resources COMP SCIENT [8 h]; MECH TECH [8 h]; ELEC ENG [8 h]; MECH DES [8 h]; MECH ENG [8 h]; SR STAFF [8 h]; SCIENTIST [8 h]; ELEC TECH [8 h] → MECH TECH [8 h]; SR STAFF [8 h]; SCIENTIST [8 h]; COMP SCIENT [8 h]; ELEC ENG [8 h]; ELEC TECH [8 h]; MECH DES [8 h]; MECH ENG [8 h] |
| 1312104040 | Cavity#27 VTA Run | 2011-02-08 → 2011-05-08 A (+89d) | 2011-02-14 → 2011-05-14 A (+89d) |  | 0% → 100% | 99d → none | resources SR STAFF [8 h]; SCIENTIST [8 h]; ELEC ENG [8 h]; ELEC TECH [8 h]; MECH DES [8 h]; MECH ENG [8 h]; MECH TECH [8 h]; COMP SCIENT [8 h] → MECH TECH [8 h]; SR STAFF [8 h]; SCIENTIST [8 h]; COMP SCIENT [8 h]; ELEC ENG [8 h]; ELEC TECH [8 h]; MECH DES [8 h]; MECH ENG [8 h] |
| 1312104045 | Cavity#28 VTA Run | 2011-02-11 → 2011-05-13 A (+91d) | 2011-02-17 → 2011-05-17 A (+89d) | 5d → 3d | 0% → 100% | 99d → none | resources SCIENTIST [8 h]; COMP SCIENT [8 h]; ELEC ENG [8 h]; ELEC TECH [8 h]; MECH DES [8 h]; MECH ENG [8 h]; MECH TECH [8 h]; SR STAFF [8 h] → COMP SCIENT [8 h]; ELEC ENG [8 h]; ELEC TECH [8 h]; MECH DES [8 h]; MECH TECH [8 h]; SR STAFF [8 h]; SCIENTIST [8 h]; MECH ENG [8 h] |
| 1312104050 | Cavity#29 VTA Run | 2011-02-16 → 2011-05-16 A (+89d) | 2011-02-23 → 2011-05-22 A (+88d) |  | 0% → 100% | 99d → none | resources SCIENTIST [8 h]; SR STAFF [8 h]; COMP SCIENT [8 h]; ELEC ENG [8 h]; ELEC TECH [8 h]; MECH DES [8 h]; MECH ENG [8 h]; MECH TECH [8 h] → COMP SCIENT [8 h]; ELEC ENG [8 h]; ELEC TECH [8 h]; MECH DES [8 h]; MECH ENG [8 h]; MECH TECH [8 h]; SR STAFF [8 h]; SCIENTIST [8 h] |
| 1312104055 | Cavity#30 VTA Run | 2011-02-22 → 2011-05-21 A (+88d) | 2011-02-28 → 2011-05-27 A (+88d) |  | 0% → 100% | 99d → none | resources ELEC ENG [8 h]; ELEC TECH [8 h]; MECH DES [8 h]; MECH ENG [8 h]; MECH TECH [8 h]; SR STAFF [8 h]; SCIENTIST [8 h]; COMP SCIENT [8 h] → COMP SCIENT [8 h]; ELEC ENG [8 h]; ELEC TECH [8 h]; MECH DES [8 h]; MECH ENG [8 h]; MECH TECH [8 h]; SR STAFF [8 h]; SCIENTIST [8 h] |
| 1312104060 | Cavity#31 VTA Run | 2011-02-25 → 2011-05-24 A (+88d) | 2011-03-03 → 2011-05-30 A (+88d) | 5d → 4d | 0% → 100% | 99d → none | resources COMP SCIENT [8 h]; ELEC ENG [8 h]; ELEC TECH [8 h]; MECH DES [8 h]; MECH ENG [8 h]; MECH TECH [8 h]; SR STAFF [8 h]; SCIENTIST [8 h] → SCIENTIST [8 h]; COMP SCIENT [8 h]; ELEC ENG [8 h]; ELEC TECH [8 h]; MECH DES [8 h]; MECH ENG [8 h]; MECH TECH [8 h]; SR STAFF [8 h] |
| 1312104065 | Cavity#32 VTA Run | 2011-03-02 → 2011-06-01 A (+91d) | 2011-03-08 → 2011-06-08 A (+92d) | 5d → 6d | 0% → 100% | 99d → none | resources MECH ENG [8 h]; MECH TECH [8 h]; SCIENTIST [8 h]; COMP SCIENT [8 h]; ELEC ENG [8 h]; ELEC TECH [8 h]; MECH DES [8 h]; SR STAFF [8 h] → ELEC TECH [8 h]; SCIENTIST [8 h]; COMP SCIENT [8 h]; ELEC ENG [8 h]; MECH DES [8 h]; MECH ENG [8 h]; MECH TECH [8 h]; SR STAFF [8 h] |
| 05 | **1.3.1.2.1.05 CAVITY STRING #5 PREPARATION** | 2011-02-15 → 2011-08-01 (+167d) | 2011-04-13 → 2011-09-28 (+168d) |  |  |  |  |
| 1312105005 | Cavity String #5 Cavity Process & He Vs Weld | 2011-02-15 → 2011-08-01 A (+167d) | 2011-03-09 → 2011-08-15 A (+159d) | 16d → 11d | 0% → 100% | 108d → none | resources MECH ENG [20.4 h]; MECH TECH [298 h]; SUPPLIES & MATERIALS; ELEC TECH [8 h]; MECH DES [4 h] → MECH TECH [298 h]; SUPPLIES & MATERIALS; ELEC TECH [8 h]; MECH DES [4 h]; MECH ENG [20.4 h] |
| 1312105030 | Cavity #33 VTA Run | 2011-03-09 → 2011-08-12 A (+156d) | 2011-03-15 → 2011-08-22 A (+160d) | 5d → 7d | 0% → 100% | 99d → none |  |
| 1312105035 | Cavity #34 VTA Run | 2011-03-14 → 2011-08-15 A (+154d) | 2011-03-18 → 2011-08-21 A (+156d) |  | 0% → 100% | 99d → none | resources ELEC ENG [8 h]; ELEC TECH [8 h]; MECH DES [8 h]; MECH ENG [8 h]; MECH TECH [8 h]; SCIENTIST [8 h]; SR STAFF [8 h]; COMP SCIENT [8 h] → MECH TECH [8 h]; SCIENTIST [8 h]; SR STAFF [8 h]; COMP SCIENT [8 h]; ELEC ENG [8 h]; ELEC TECH [8 h]; MECH DES [8 h]; MECH ENG [8 h] |
| 1312105040 | Cavity #35 VTA Run | 2011-03-17 → 2011-09-03 A (+170d) | 2011-03-23 → 2011-09-07 A (+168d) | 5d → 2d | 0% → 100% | 99d → none | resources SCIENTIST [8 h]; SR STAFF [8 h]; COMP SCIENT [8 h]; ELEC ENG [8 h]; ELEC TECH [8 h]; MECH DES [8 h]; MECH ENG [8 h]; MECH TECH [8 h] → MECH DES [8 h]; MECH ENG [8 h]; MECH TECH [8 h]; SCIENTIST [8 h]; COMP SCIENT [8 h]; ELEC ENG [8 h]; ELEC TECH [8 h]; SR STAFF [8 h] |
| 1312105045 | Cavity #36 VTA Run | 2011-03-22 → 2011-09-06 A (+168d) | 2011-03-28 → 2011-09-12 A (+168d) |  | 0% → 100% | 99d → none | resources MECH DES [8 h]; MECH ENG [8 h]; MECH TECH [8 h]; SCIENTIST [8 h]; SR STAFF [8 h]; COMP SCIENT [8 h]; ELEC ENG [8 h]; ELEC TECH [8 h] → COMP SCIENT [8 h]; ELEC ENG [8 h]; MECH ENG [8 h]; ELEC TECH [8 h]; MECH DES [8 h]; MECH TECH [8 h]; SCIENTIST [8 h]; SR STAFF [8 h] |
| 1312105050 | Cavity #37 VTA Run | 2011-03-25 → 2011-09-11 A (+170d) | 2011-03-31 → 2011-09-17 A (+170d) |  | 0% → 100% | 99d → none | resources MECH ENG [8 h]; MECH TECH [8 h]; SR STAFF [8 h]; COMP SCIENT [8 h]; ELEC ENG [8 h]; ELEC TECH [8 h]; MECH DES [8 h]; SCIENTIST [8 h] → MECH DES [8 h]; MECH ENG [8 h]; MECH TECH [8 h]; SCIENTIST [8 h]; SR STAFF [8 h]; COMP SCIENT [8 h]; ELEC ENG [8 h]; ELEC TECH [8 h] |
| 1312105055 | Cavity #38 VTA Run | 2011-03-30 → 2011-09-14 A (+168d) | 2011-04-05 → 2011-09-20 A (+168d) |  | 0% → 100% | 99d → none | resources ELEC ENG [8 h]; SR STAFF [8 h]; SCIENTIST [8 h]; COMP SCIENT [8 h]; ELEC TECH [8 h]; MECH DES [8 h]; MECH ENG [8 h]; MECH TECH [8 h] → MECH ENG [8 h]; MECH TECH [8 h]; SCIENTIST [8 h]; SR STAFF [8 h]; COMP SCIENT [8 h]; ELEC ENG [8 h]; ELEC TECH [8 h]; MECH DES [8 h] |
| 1312105060 | Cavity #39 VTA Run | 2011-04-04 → 2011-09-19 A (+168d) | 2011-04-08 → 2011-09-25 A (+170d) |  | 0% → 100% | 99d → none | resources MECH ENG [8 h]; MECH TECH [8 h]; SR STAFF [8 h]; COMP SCIENT [8 h]; ELEC ENG [8 h]; ELEC TECH [8 h]; MECH DES [8 h]; SCIENTIST [8 h] → MECH DES [8 h]; MECH ENG [8 h]; MECH TECH [8 h]; SCIENTIST [8 h]; SR STAFF [8 h]; COMP SCIENT [8 h]; ELEC ENG [8 h]; ELEC TECH [8 h] |
| 1312105065 | Cavity #40 VTA Run | 2011-04-07 → 2011-09-24 A (+170d) | 2011-04-13 → 2011-09-28 A (+168d) | 5d → 3d | 0% → 100% | 99d → none | resources SR STAFF [8 h]; COMP SCIENT [8 h]; ELEC ENG [8 h]; ELEC TECH [8 h]; MECH DES [8 h]; MECH ENG [8 h]; MECH TECH [8 h]; SCIENTIST [8 h] → MECH ENG [8 h]; MECH TECH [8 h]; SR STAFF [8 h]; COMP SCIENT [8 h]; ELEC ENG [8 h]; ELEC TECH [8 h]; MECH DES [8 h]; SCIENTIST [8 h] |
| 06 | **1.3.1.2.1.06 CAVITY STRING #6 PREPARATION** | 2011-03-21 → 2011-08-29 (+161d) | 2011-05-17 → 2011-10-30 (+166d) |  |  |  |  |
| 1312106005 | Cavity String #6 Cavity Process & He Vs Weld | 2011-03-21 → 2011-08-29 A (+161d) | 2011-04-11 → 2011-09-24 A (+166d) | 16d → 19d | 0% → 100% | 109d → none | resources MECH ENG [20.4 h]; MECH TECH [298 h]; SUPPLIES & MATERIALS; ELEC TECH [8 h]; MECH DES [4 h] → MECH DES [4 h]; MECH ENG [20.4 h]; MECH TECH [298 h]; SUPPLIES & MATERIALS; ELEC TECH [8 h] |
| 1312106030 | Cavity #41 VTA Run | 2011-04-12 → 2011-09-19 A (+160d) | 2011-04-18 → 2011-09-28 A (+163d) | 5d → 8d | 0% → 100% | 99d → none | resources ELEC TECH [8 h]; MECH DES [8 h]; MECH ENG [8 h]; MECH TECH [8 h]; SCIENTIST [8 h]; SR STAFF [8 h]; COMP SCIENT [8 h]; ELEC ENG [8 h] → MECH ENG [8 h]; MECH TECH [8 h]; SCIENTIST [8 h]; SR STAFF [8 h]; COMP SCIENT [8 h]; ELEC ENG [8 h]; ELEC TECH [8 h]; MECH DES [8 h] |
| 1312106035 | Cavity #42 VTA Run | 2011-04-15 → 2011-09-26 A (+164d) | 2011-04-21 → 2011-09-29 A (+161d) | 5d → 4d | 0% → 100% | 99d → none | resources SR STAFF [8 h]; COMP SCIENT [8 h]; ELEC ENG [8 h]; ELEC TECH [8 h]; MECH DES [8 h]; MECH ENG [8 h]; MECH TECH [8 h]; SCIENTIST [8 h] → ELEC TECH [8 h]; SR STAFF [8 h]; MECH TECH [8 h]; SCIENTIST [8 h]; MECH DES [8 h]; MECH ENG [8 h]; COMP SCIENT [8 h]; ELEC ENG [8 h] |
| 1312106040 | Cavity #43 VTA Run | 2011-04-20 → 2011-10-03 A (+166d) | 2011-04-26 → 2011-10-07 A (+164d) |  | 0% → 100% | 99d → none | resources ELEC ENG [8 h]; ELEC TECH [8 h]; MECH DES [8 h]; MECH ENG [8 h]; MECH TECH [8 h]; SCIENTIST [8 h]; SR STAFF [8 h]; COMP SCIENT [8 h] → COMP SCIENT [8 h]; ELEC ENG [8 h]; ELEC TECH [8 h]; MECH DES [8 h]; MECH ENG [8 h]; SCIENTIST [8 h]; MECH TECH [8 h]; SR STAFF [8 h] |
| 1312106045 | Cavity #44 VTA Run | 2011-04-25 → 2011-10-04 A (+162d) | 2011-04-29 → 2011-10-10 A (+164d) |  | 0% → 100% | 99d → none | resources SCIENTIST [8 h]; SR STAFF [8 h]; COMP SCIENT [8 h]; ELEC ENG [8 h]; ELEC TECH [8 h]; MECH DES [8 h]; MECH ENG [8 h]; MECH TECH [8 h] → MECH DES [8 h]; MECH ENG [8 h]; MECH TECH [8 h]; SCIENTIST [8 h]; SR STAFF [8 h]; COMP SCIENT [8 h]; ELEC ENG [8 h]; ELEC TECH [8 h] |
| 1312106050 | Cavity #45 VTA Run | 2011-04-28 → 2011-10-09 A (+164d) | 2011-05-04 → 2011-10-15 A (+164d) |  | 0% → 100% | 99d → none | resources MECH DES [8 h]; MECH ENG [8 h]; MECH TECH [8 h]; SCIENTIST [8 h]; SR STAFF [8 h]; COMP SCIENT [8 h]; ELEC ENG [8 h]; ELEC TECH [8 h] → MECH ENG [8 h]; MECH TECH [8 h]; SCIENTIST [8 h]; SR STAFF [8 h]; COMP SCIENT [8 h]; ELEC ENG [8 h]; ELEC TECH [8 h]; MECH DES [8 h] |
| 1312106055 | Cavity #46 VTA Run | 2011-05-03 → 2011-10-14 A (+164d) | 2011-05-09 → 2011-10-18 A (+162d) | 5d → 3d | 0% → 100% | 99d → none | resources MECH TECH [8 h]; SCIENTIST [8 h]; SR STAFF [8 h]; COMP SCIENT [8 h]; ELEC ENG [8 h]; ELEC TECH [8 h]; MECH DES [8 h]; MECH ENG [8 h] → SR STAFF [8 h]; COMP SCIENT [8 h]; ELEC ENG [8 h]; ELEC TECH [8 h]; SCIENTIST [8 h]; MECH DES [8 h]; MECH ENG [8 h]; MECH TECH [8 h] |
| 1312106060 | Cavity #47 VTA Run | 2011-05-06 → 2011-10-17 A (+164d) | 2011-05-12 → 2011-10-23 A (+164d) |  | 0% → 100% | 99d → none | resources SCIENTIST [8 h]; SR STAFF [8 h]; COMP SCIENT [8 h]; ELEC ENG [8 h]; ELEC TECH [8 h]; MECH DES [8 h]; MECH ENG [8 h]; MECH TECH [8 h] → ELEC TECH [8 h]; MECH DES [8 h]; MECH ENG [8 h]; MECH TECH [8 h]; SCIENTIST [8 h]; SR STAFF [8 h]; COMP SCIENT [8 h]; ELEC ENG [8 h] |
| 1312106065 | Cavity #48 VTA Run | 2011-05-11 → 2011-10-22 A (+164d) | 2011-05-17 → 2011-10-30 A (+166d) |  | 0% → 100% | 99d → none | resources SR STAFF [8 h]; ELEC ENG [8 h]; ELEC TECH [8 h]; COMP SCIENT [8 h]; MECH DES [8 h]; MECH ENG [8 h]; MECH TECH [8 h]; SCIENTIST [8 h] → MECH DES [8 h]; MECH ENG [8 h]; MECH TECH [8 h]; SCIENTIST [8 h]; SR STAFF [8 h]; COMP SCIENT [8 h]; ELEC ENG [8 h]; ELEC TECH [8 h] |
| 07 | **1.3.1.2.1.07 CAVITY STRING #7 PREPARATION** | 2011-04-20 → 2011-09-26 (+159d) | 2011-06-21 → 2011-11-20 (+152d) |  |  |  |  |
| 1312107005 | Cavity String #7 Cavity Process & He Vs Weld | 2011-04-20 → 2011-09-26 A (+159d) | 2011-05-11 → 2011-10-22 A (+164d) | 16d → 20d | 0% → 100% | 111d → none | resources MECH DES [4 h]; MECH ENG [20.4 h]; MECH TECH [298 h]; SUPPLIES & MATERIALS; ELEC TECH [8 h] → MECH ENG [20.4 h]; MECH TECH [298 h]; SUPPLIES & MATERIALS; ELEC TECH [8 h]; MECH DES [4 h] |
| 1312107030 | Cavity #49 VTA Run | 2011-05-16 → 2011-10-17 A (+154d) | 2011-05-20 → 2011-10-24 A (+157d) | 5d → 6d | 0% → 100% | 99d → none | resources MECH ENG [8 h]; MECH TECH [8 h]; SCIENTIST [8 h]; SR STAFF [8 h]; COMP SCIENT [8 h]; ELEC ENG [8 h]; ELEC TECH [8 h]; MECH DES [8 h] → ELEC TECH [8 h]; MECH DES [8 h]; MECH ENG [8 h]; MECH TECH [8 h]; SCIENTIST [8 h]; SR STAFF [8 h]; COMP SCIENT [8 h]; ELEC ENG [8 h] |
| 1312107035 | Cavity #50 VTA Run | 2011-05-19 → 2011-10-17 A (+151d) | 2011-05-25 → 2011-10-24 A (+152d) | 5d → 6d | 0% → 100% | 99d → none | resources MECH TECH [8 h]; SCIENTIST [8 h]; SR STAFF [8 h]; COMP SCIENT [8 h]; ELEC ENG [8 h]; ELEC TECH [8 h]; MECH DES [8 h]; MECH ENG [8 h] → MECH DES [8 h]; MECH ENG [8 h]; MECH TECH [8 h]; SCIENTIST [8 h]; COMP SCIENT [8 h]; ELEC ENG [8 h]; ELEC TECH [8 h]; SR STAFF [8 h] |
| 1312107040 | Cavity #51 VTA Run | 2011-05-24 → 2011-10-17 A (+146d) | 2011-05-31 → 2011-10-24 A (+146d) | 5d → 6d | 0% → 100% | 99d → none | resources MECH ENG [8 h]; MECH TECH [8 h]; SCIENTIST [8 h]; SR STAFF [8 h]; COMP SCIENT [8 h]; ELEC ENG [8 h]; ELEC TECH [8 h]; MECH DES [8 h] → MECH DES [8 h]; MECH ENG [8 h]; MECH TECH [8 h]; SCIENTIST [8 h]; SR STAFF [8 h]; COMP SCIENT [8 h]; ELEC ENG [8 h]; ELEC TECH [8 h] |
| 1312107045 | Cavity #52 VTA Run | 2011-05-27 → 2011-10-24 A (+150d) | 2011-06-03 → 2011-10-31 A (+150d) | 5d → 6d | 0% → 100% | 99d → none | resources SR STAFF [8 h]; COMP SCIENT [8 h]; ELEC ENG [8 h]; ELEC TECH [8 h]; MECH DES [8 h]; MECH TECH [8 h]; MECH ENG [8 h]; SCIENTIST [8 h] → SR STAFF [8 h]; COMP SCIENT [8 h]; ELEC ENG [8 h]; ELEC TECH [8 h]; MECH DES [8 h]; MECH ENG [8 h]; MECH TECH [8 h]; SCIENTIST [8 h] |
| 1312107050 | Cavity #53 VTA Run | 2011-06-02 → 2011-11-01 A (+152d) | 2011-06-08 → 2011-11-07 A (+152d) |  | 0% → 100% | 99d → none | resources SCIENTIST [8 h]; SR STAFF [8 h]; COMP SCIENT [8 h]; ELEC ENG [8 h]; ELEC TECH [8 h]; MECH DES [8 h]; MECH ENG [8 h]; MECH TECH [8 h] → MECH TECH [8 h]; SCIENTIST [8 h]; SR STAFF [8 h]; COMP SCIENT [8 h]; ELEC ENG [8 h]; ELEC TECH [8 h]; MECH DES [8 h]; MECH ENG [8 h] |
| 1312107055 | Cavity #54 VTA Run | 2011-06-07 → 2011-11-06 A (+152d) | 2011-06-13 → 2011-11-12 A (+152d) |  | 0% → 100% | 99d → none | resources MECH DES [8 h]; MECH ENG [8 h]; MECH TECH [8 h]; ELEC ENG [8 h]; SCIENTIST [8 h]; SR STAFF [8 h]; COMP SCIENT [8 h]; ELEC TECH [8 h] → MECH DES [8 h]; MECH ENG [8 h]; MECH TECH [8 h]; SCIENTIST [8 h]; SR STAFF [8 h]; COMP SCIENT [8 h]; ELEC ENG [8 h]; ELEC TECH [8 h] |
| 1312107060 | Cavity #55 VTA Run | 2011-06-10 → 2011-11-09 A (+152d) | 2011-06-16 → 2011-11-15 A (+152d) |  | 0% → 100% | 99d → none | resources COMP SCIENT [8 h]; ELEC ENG [8 h]; ELEC TECH [8 h]; SR STAFF [8 h]; MECH DES [8 h]; MECH ENG [8 h]; MECH TECH [8 h]; SCIENTIST [8 h] → ELEC TECH [8 h]; SR STAFF [8 h]; MECH DES [8 h]; MECH ENG [8 h]; MECH TECH [8 h]; SCIENTIST [8 h]; COMP SCIENT [8 h]; ELEC ENG [8 h] |
| 1312107065 | Cavity #56 VTA Run | 2011-06-15 → 2011-11-14 A (+152d) | 2011-06-21 → 2011-11-20 A (+152d) |  | 0% → 100% | 99d → none | resources MECH DES [8 h]; MECH ENG [8 h]; MECH TECH [8 h]; SCIENTIST [8 h]; SR STAFF [8 h]; COMP SCIENT [8 h]; ELEC ENG [8 h]; ELEC TECH [8 h] → MECH TECH [8 h]; SCIENTIST [8 h]; SR STAFF [8 h]; COMP SCIENT [8 h]; ELEC ENG [8 h]; ELEC TECH [8 h]; MECH DES [8 h]; MECH ENG [8 h] |
| 08 | **1.3.1.2.1.08 CAVITY STRING #8 PREPARATION** | 2011-06-02 → 2011-10-17 (+137d) | 2011-08-26 → 2011-11-25 (+91d) |  |  |  |  |
| 1312108005 | Cavity String #8 Cavity Process & He Vs Weld | 2011-06-02 → 2011-10-17 A (+137d) | 2011-06-23 → 2011-11-07 A (+137d) |  | 0% → 100% | 105d → none | resources SUPPLIES & MATERIALS; ELEC TECH [8 h]; MECH DES [4 h]; MECH ENG [20.4 h]; MECH TECH [298 h] → MECH DES [4 h]; MECH ENG [20.4 h]; MECH TECH [298 h]; SUPPLIES & MATERIALS; ELEC TECH [8 h] |
| 1312108030 | Cavity #57 VTA Run | 2011-06-20 → 2011-11-08 A (+141d) | 2011-06-24 → 2011-11-10 A (+139d) | 5d → 3d | 0% → 100% | 99d → none | resources COMP SCIENT [8 h]; ELEC ENG [8 h]; ELEC TECH [8 h]; MECH DES [8 h]; MECH ENG [8 h]; MECH TECH [8 h]; SCIENTIST [8 h]; SR STAFF [8 h] → MECH DES [8 h]; MECH ENG [8 h]; MECH TECH [8 h]; SCIENTIST [8 h]; SR STAFF [8 h]; COMP SCIENT [8 h]; ELEC ENG [8 h]; ELEC TECH [8 h] |
| 1312108035 | Cavity #58 VTA Run | 2011-06-23 → 2011-11-10 A (+140d) | 2011-06-29 → 2011-11-14 A (+138d) | 5d → 3d | 0% → 100% | 99d → none | resources MECH TECH [8 h]; SCIENTIST [8 h]; SR STAFF [8 h]; COMP SCIENT [8 h]; ELEC ENG [8 h]; ELEC TECH [8 h]; MECH DES [8 h]; MECH ENG [8 h] → MECH DES [8 h]; MECH ENG [8 h]; MECH TECH [8 h]; SCIENTIST [8 h]; SR STAFF [8 h]; COMP SCIENT [8 h]; ELEC ENG [8 h]; ELEC TECH [8 h] |
| 1312108040 | Cavity #59 VTA Run | 2011-08-01 → 2011-11-14 A (+105d) | 2011-08-05 → 2011-11-17 A (+104d) | 5d → 4d | 0% → 100% | 107d → none | resources SR STAFF [8 h]; COMP SCIENT [8 h]; ELEC ENG [8 h]; ELEC TECH [8 h]; MECH DES [8 h]; MECH ENG [8 h]; MECH TECH [8 h]; SCIENTIST [8 h] → MECH ENG [8 h]; MECH TECH [8 h]; SCIENTIST [8 h]; SR STAFF [8 h]; COMP SCIENT [8 h]; ELEC ENG [8 h]; ELEC TECH [8 h]; MECH DES [8 h] |
| 1312108045 | Cavity #60 VTA Run | 2011-08-04 → 2011-11-14 A (+102d) | 2011-08-10 → 2011-11-17 A (+99d) | 5d → 4d | 0% → 100% | 107d → none | resources SCIENTIST [8 h]; SR STAFF [8 h]; COMP SCIENT [8 h]; ELEC ENG [8 h]; ELEC TECH [8 h]; MECH DES [8 h]; MECH ENG [8 h]; MECH TECH [8 h] → MECH DES [8 h]; MECH ENG [8 h]; MECH TECH [8 h]; SCIENTIST [8 h]; SR STAFF [8 h]; COMP SCIENT [8 h]; ELEC ENG [8 h]; ELEC TECH [8 h] |
| 1312108050 | Cavity #61 VTA Run | 2011-08-09 → 2011-11-14 A (+97d) | 2011-08-15 → 2011-11-18 A (+95d) |  | 0% → 100% | 107d → none | resources COMP SCIENT [8 h]; ELEC ENG [8 h]; ELEC TECH [8 h]; MECH DES [8 h]; MECH ENG [8 h]; MECH TECH [8 h]; SCIENTIST [8 h]; SR STAFF [8 h] → MECH DES [8 h]; MECH ENG [8 h]; MECH TECH [8 h]; SCIENTIST [8 h]; SR STAFF [8 h]; COMP SCIENT [8 h]; ELEC ENG [8 h]; ELEC TECH [8 h] |
| 1312108055 | Cavity #62 VTA Run | 2011-08-12 → 2011-11-16 A (+96d) | 2011-08-18 → 2011-11-21 A (+95d) | 5d → 4d | 0% → 100% | 107d → none | resources MECH ENG [8 h]; MECH TECH [8 h]; SCIENTIST [8 h]; SR STAFF [8 h]; COMP SCIENT [8 h]; ELEC TECH [8 h]; MECH DES [8 h]; ELEC ENG [8 h] → SCIENTIST [8 h]; COMP SCIENT [8 h]; ELEC ENG [8 h]; ELEC TECH [8 h]; SR STAFF [8 h]; MECH DES [8 h]; MECH ENG [8 h]; MECH TECH [8 h] |
| 1312108060 | Cavity #63 VTA Run | 2011-08-17 → 2011-11-17 A (+92d) | 2011-08-23 → 2011-11-24 A (+93d) |  | 0% → 100% | 107d → none | resources COMP SCIENT [8 h]; ELEC ENG [8 h]; ELEC TECH [8 h]; MECH DES [8 h]; MECH ENG [8 h]; MECH TECH [8 h]; SCIENTIST [8 h]; SR STAFF [8 h] → MECH TECH [8 h]; SCIENTIST [8 h]; SR STAFF [8 h]; COMP SCIENT [8 h]; ELEC ENG [8 h]; ELEC TECH [8 h]; MECH DES [8 h]; MECH ENG [8 h] |
| 1312108065 | Cavity #64 VTA Run | 2011-08-22 → 2011-11-21 A (+91d) | 2011-08-26 → 2011-11-25 A (+91d) | 5d → 3d | 0% → 100% | 107d → none | resources MECH DES [8 h]; MECH ENG [8 h]; MECH TECH [8 h]; SCIENTIST [8 h]; SR STAFF [8 h]; COMP SCIENT [8 h]; ELEC ENG [8 h]; ELEC TECH [8 h] → ELEC TECH [8 h]; MECH DES [8 h]; MECH ENG [8 h]; MECH TECH [8 h]; SCIENTIST [8 h]; SR STAFF [8 h]; COMP SCIENT [8 h]; ELEC ENG [8 h] |
| 09 | **1.3.1.2.1.09 CAVITY STRING #9 PREPARATION** | 2011-08-15 → 2011-11-14 (+91d) | 2011-09-30 → 2011-12-09 (+70d) |  |  |  |  |
| 1312109005 | Cavity String #9 Cavity Process & He Vs Weld | 2011-08-15 → 2011-11-14 A (+91d) | 2011-09-06 → 2011-11-21 A (+76d) | 16d → 6d | 0% → 100% | 109d → none |  |
| 1312109030 | Cavity #65 VTA Run | 2011-08-25 → 2011-11-23 A (+90d) | 2011-08-31 → 2011-11-28 A (+89d) | 5d → 2d | 0% → 100% | 107d → none | resources SCIENTIST [8 h]; SR STAFF [8 h]; COMP SCIENT [8 h]; ELEC ENG [8 h]; ELEC TECH [8 h]; MECH DES [8 h]; MECH ENG [8 h]; MECH TECH [8 h] → COMP SCIENT [8 h]; ELEC ENG [8 h]; ELEC TECH [8 h]; MECH DES [8 h]; MECH ENG [8 h]; MECH TECH [8 h]; SCIENTIST [8 h]; SR STAFF [8 h] |
| 1312109035 | Cavity #66 VTA Run | 2011-08-30 → 2011-11-25 A (+87d) | 2011-09-06 → 2011-11-30 A (+85d) | 5d → 3d | 0% → 100% | 107d → none | resources SCIENTIST [8 h]; SR STAFF [8 h]; COMP SCIENT [8 h]; ELEC ENG [8 h]; ELEC TECH [8 h]; MECH DES [8 h]; MECH ENG [8 h]; MECH TECH [8 h] → COMP SCIENT [8 h]; ELEC ENG [8 h]; ELEC TECH [8 h]; MECH DES [8 h]; MECH ENG [8 h]; MECH TECH [8 h]; SCIENTIST [8 h]; SR STAFF [8 h] |
| 1312109040 | Cavity #67 VTA Run | 2011-09-02 → 2011-12-01 A (+90d) | 2011-09-09 → 2011-12-05 A (+87d) | 5d → 3d | 0% → 100% | 107d → none | resources MECH ENG [8 h]; MECH TECH [8 h]; SCIENTIST [8 h]; SR STAFF [8 h]; COMP SCIENT [8 h]; ELEC ENG [8 h]; ELEC TECH [8 h]; MECH DES [8 h] → COMP SCIENT [8 h]; ELEC ENG [8 h]; ELEC TECH [8 h]; MECH DES [8 h]; MECH ENG [8 h]; MECH TECH [8 h]; SCIENTIST [8 h]; SR STAFF [8 h] |
| 1312109045 | Cavity #68 VTA Run | 2011-09-08 → 2011-12-02 A (+85d) | 2011-09-14 → 2011-12-05 A (+82d) | 5d → 2d | 0% → 100% | 107d → none | resources ELEC ENG [8 h]; ELEC TECH [8 h]; MECH DES [8 h]; MECH ENG [8 h]; MECH TECH [8 h]; SCIENTIST [8 h]; SR STAFF [8 h]; COMP SCIENT [8 h] → ELEC TECH [8 h]; MECH DES [8 h]; MECH ENG [8 h]; MECH TECH [8 h]; SCIENTIST [8 h]; COMP SCIENT [8 h]; ELEC ENG [8 h]; SR STAFF [8 h] |
| 1312109050 | Cavity #69 VTA Run | 2011-09-13 → 2011-12-05 A (+83d) | 2011-09-19 → 2011-12-07 A (+79d) | 5d → 3d | 0% → 100% | 107d → none | resources MECH ENG [8 h]; MECH TECH [8 h]; SCIENTIST [8 h]; SR STAFF [8 h]; ELEC ENG [8 h]; COMP SCIENT [8 h]; ELEC TECH [8 h]; MECH DES [8 h] → ELEC TECH [8 h]; MECH DES [8 h]; MECH ENG [8 h]; MECH TECH [8 h]; SCIENTIST [8 h]; SR STAFF [8 h]; COMP SCIENT [8 h]; ELEC ENG [8 h] |
| 1312109055 | Cavity #70 VTA Run | 2011-09-16 → 2011-12-05 A (+80d) | 2011-09-22 → 2011-12-08 A (+77d) | 5d → 4d | 0% → 100% | 107d → none | resources MECH DES [8 h]; MECH ENG [8 h]; MECH TECH [8 h]; SCIENTIST [8 h]; SR STAFF [8 h]; COMP SCIENT [8 h]; ELEC ENG [8 h]; ELEC TECH [8 h] → ELEC ENG [8 h]; ELEC TECH [8 h]; MECH DES [8 h]; MECH ENG [8 h]; MECH TECH [8 h]; SCIENTIST [8 h]; COMP SCIENT [8 h]; SR STAFF [8 h] |
| 1312109060 | Cavity #71 VTA Run | 2011-09-21 → 2011-12-06 A (+76d) | 2011-09-27 → 2011-12-08 A (+72d) | 5d → 3d | 0% → 100% | 107d → none | resources ELEC TECH [8 h]; MECH DES [8 h]; MECH ENG [8 h]; SCIENTIST [8 h]; SR STAFF [8 h]; COMP SCIENT [8 h]; MECH TECH [8 h]; ELEC ENG [8 h] → MECH DES [8 h]; MECH ENG [8 h]; MECH TECH [8 h]; SCIENTIST [8 h]; SR STAFF [8 h]; COMP SCIENT [8 h]; ELEC ENG [8 h]; ELEC TECH [8 h] |

| ID | Task | Start | Finish | Duration | Complete | Total float | Predecessors | Other |
| --- | --- | --- | --- | --- | --- | --- | --- | --- |
| 1312109065 | Cavity #72 VTA Run | 2011-09-26 → 2011-12-07 A (+72d) | 2011-09-30 → 2011-12-09 A (+70d) | 5d → 3d | 0% → 100% | 107d → none |  | resources MECH ENG [8 h]; MECH TECH [8 h]; SCIENTIST [8 h]; SR STAFF [8 h]; COMP SCIENT [8 h]; ELEC ENG [8 h]; ELEC TECH [8 h]; MECH DES [8 h] → ELEC TECH [8 h]; MECH DES [8 h]; MECH ENG [8 h]; MECH TECH [8 h]; SCIENTIST [8 h]; SR STAFF [8 h]; COMP SCIENT [8 h]; ELEC ENG [8 h] |
| 10 | **1.3.1.2.1.10 CAVITY STRING #10 PREPARATION** | 2011-10-04 → 2011-11-28 (+55d) | 2011-11-16 → 2012-02-07 (+83d) |  |  |  |  |  |
| 1312110005 | Cavity String #10 Cavity Process & He Vs Weld | 2011-10-04 → 2011-11-28 A (+55d) | 2011-10-25 → 2011-12-12 A (+48d) | 16d → 11d | 0% → 100% | 98d → none | 1311122092, 1311122095, 131114130M, 131114125, 1312109005, 131114120, 1311122100a → 131114125, 1311122092, 1311122100a, 1311122095, 131114130M, 131114120, 1311122100, 1312109005 | resources ELEC TECH [8 h]; MECH DES [4 h]; MECH ENG [20.4 h]; MECH TECH [298 h]; SUPPLIES & MATERIALS → MECH DES [4 h]; MECH ENG [20.4 h]; MECH TECH [298 h]; ELEC TECH [8 h]; SUPPLIES & MATERIALS |
| 1312110030 | Cavity #73 VTA Run | 2011-10-12 → 2011-12-12 A (+61d) | 2011-10-18 → 2011-12-15 A (+58d) | 5d → 4d | 0% → 100% | 98d → none |  | resources MECH TECH [8 h]; SCIENTIST [8 h]; SR STAFF [8 h]; COMP SCIENT [8 h]; ELEC ENG [8 h]; ELEC TECH [8 h]; MECH DES [8 h]; MECH ENG [8 h] → ELEC TECH [8 h]; MECH DES [8 h]; MECH ENG [8 h]; MECH TECH [8 h]; SCIENTIST [8 h]; SR STAFF [8 h]; COMP SCIENT [8 h]; ELEC ENG [8 h] |
| 1312110035 | Cavity #74 VTA Run | 2011-10-17 → 2011-12-12 A (+56d) | 2011-10-21 → 2011-12-16 A (+56d) |  | 0% → 100% | 98d → none |  |  |
| 1312110040 | Cavity #75 VTA Run | 2011-10-20 → 2012-01-03 A (+75d) | 2011-10-26 → 2012-01-07 A (+73d) | 5d → 4d | 0% → 100% | 98d → none |  | resources SCIENTIST [8 h]; SR STAFF [8 h]; COMP SCIENT [8 h]; ELEC ENG [8 h]; ELEC TECH [8 h]; MECH DES [8 h]; MECH ENG [8 h]; MECH TECH [8 h] → ELEC TECH [8 h]; MECH DES [8 h]; MECH ENG [8 h]; MECH TECH [8 h]; SCIENTIST [8 h]; SR STAFF [8 h]; COMP SCIENT [8 h]; ELEC ENG [8 h] |
| 1312110045 | Cavity #76 VTA Run | 2011-10-25 → 2012-01-06 A (+73d) | 2011-10-31 → 2012-01-10 A (+71d) | 5d → 3d | 0% → 100% | 98d → none |  | resources MECH DES [8 h]; MECH ENG [8 h]; MECH TECH [8 h]; SCIENTIST [8 h]; SR STAFF [8 h]; COMP SCIENT [8 h]; ELEC ENG [8 h]; ELEC TECH [8 h] → COMP SCIENT [8 h]; ELEC TECH [8 h]; MECH DES [8 h]; MECH ENG [8 h]; MECH TECH [8 h]; SCIENTIST [8 h]; SR STAFF [8 h]; ELEC ENG [8 h] |
| 1312110050 | Cavity #77 VTA Run | 2011-10-28 → 2012-01-09 A (+73d) | 2011-11-03 → 2012-01-15 A (+73d) |  | 0% → 100% | 98d → none |  |  |
| 1312110055 | Cavity #78 VTA Run | 2011-11-02 → 2012-01-14 A (+73d) | 2011-11-08 → 2012-01-21 A (+74d) | 5d → 4d | 0% → 100% | 98d → none |  |  |
| 1312110060 | Cavity #79 VTA Run | 2011-11-07 → 2012-01-17 A (+71d) | 2011-11-11 → 2012-01-24 A (+74d) | 5d → 6d | 0% → 100% | 98d → none |  | resources ELEC ENG [8 h]; ELEC TECH [8 h]; MECH DES [8 h]; MECH ENG [8 h]; MECH TECH [8 h]; SCIENTIST [8 h]; SR STAFF [8 h]; COMP SCIENT [8 h] → SCIENTIST [8 h]; SR STAFF [8 h]; COMP SCIENT [8 h]; ELEC ENG [8 h]; ELEC TECH [8 h]; MECH DES [8 h]; MECH ENG [8 h]; MECH TECH [8 h] |
| 1312110065 | Cavity #80 VTA Run | 2011-11-10 → 2012-02-01 A (+83d) | 2011-11-16 → 2012-02-07 A (+83d) |  | 0% → 100% | 98d → none |  | resources COMP SCIENT [8 h]; ELEC ENG [8 h]; ELEC TECH [8 h]; MECH DES [8 h]; MECH ENG [8 h]; MECH TECH [8 h]; SCIENTIST [8 h]; SR STAFF [8 h] → COMP SCIENT [8 h]; ELEC ENG [8 h]; MECH DES [8 h]; ELEC TECH [8 h]; MECH ENG [8 h]; MECH TECH [8 h]; SCIENTIST [8 h]; SR STAFF [8 h] |
| 4 | **1.3.1.2.4 STRING ASSEMBLY** | 2010-11-01 → 2010-10-25 (-7d) | 2012-02-21 → 2012-02-20 (-1d) |  |  |  |  |  |
| 01 | **1.3.1.2.4.01 CAVITY STRING ASSEMBLY #1** | 2010-11-01 → 2010-10-25 (-7d) | 2010-11-15 → 2011-02-02 (+79d) |  |  |  |  |  |
| 1312401000 | Cavity String Assy #1 | 2010-11-01 → 2010-10-25 A (-7d) | 2010-11-12 → 2010-12-14 A (+32d) | 10d → 35d | 0% → 100% | 37d → none | 1312101030, 1312101035, 131116015, 1312101065 FS+10d, 1312101060, 1312101050a, 131115015, 1312101040, 1312101045, 131137020, 32-03M, 1312101055, 131138040, 1311132010 → 1312101030 FS-15d, 1312101050a FS-30d, 131115015, 131116015, 1312101040 FS-20d, 32-03M, 1312101060 FS-35d, 1311132010, 1312101045 FS-20d, 131138040, 1312101035 FS-15d, 1312101050 FS-20d, 1312101065 FS-45d, 131137020, 1312101055 FS-35d | resources SR STAFF [20 h]; ELEC ENG [200 h]; MECH DES [80 h]; MECH ENG [80 h]; MECH TECH [1200 h]; ELEC TECH [40 h]; COMP SCIENT [40 h]; SUPPLIES & MATERIALS; SCIENTIST [64 h] → MECH DES [80 h]; MECH ENG [80 h]; MECH TECH [1200 h]; ELEC TECH [40 h]; COMP SCIENT [40 h]; SUPPLIES & MATERIALS; SCIENTIST [64 h]; SR STAFF [20 h]; ELEC ENG [200 h] |
| 1312401010 | Transfer to CM #1 Assy | 2010-11-15 → 2011-02-01 A (+78d) | 2010-11-15 → 2011-02-02 A (+79d) | 1d → 2d | 0% → 100% | 37d → none |  |  |
| 02 | **1.3.1.2.4.02 CAVITY STRING ASSEMBLY #2** | 2010-11-22 → 2010-10-25 (-28d) | 2011-03-07 → 2011-04-19 (+43d) |  |  |  |  |  |
| 1312402000 | Cavity String Assy #2 | 2010-11-22 → 2010-10-25 A (-28d) | 2010-12-07 → 2011-04-11 A (+125d) | 10d → 111d | 0% → 100% | 37d → none | 1312102045, 1312102055, 1312102050, 1311132020, 1312102040, 1311132015, 1312102030, 1312102060, 1312102035, 1312102065, 1312401010 FS+4d → 1312401010 FS-70d, 1312102060 FS-60d, 1312102050 FS-50d, 1312102040 FS-40d, 1312102030 FS-40d, 1311132015, 1312102065 FS-70d, 1312102035 FS-40d, 1312102045 FS-50d, 1311132020, 1312102055 FS-60d | resources SUPPLIES & MATERIALS; SCIENTIST [64 h]; SR STAFF [20 h]; ELEC ENG [200 h]; ELEC TECH [40 h]; MECH DES [80 h]; MECH ENG [80 h]; MECH TECH [1000 h] → SCIENTIST [64 h]; MECH TECH [1000 h]; SR STAFF [20 h]; ELEC ENG [200 h]; ELEC TECH [40 h]; MECH DES [80 h]; MECH ENG [80 h]; SUPPLIES & MATERIALS |
| 1312402010 | Transfer to CM #2 Assy | 2011-03-07 → 2011-04-19 A (+43d) | 2011-03-07 → 2011-04-19 A (+43d) |  | 0% → 100% | 37d → none | 1312402000 FS+55d → 1312402000 FS+12d |  |
| 03 | **1.3.1.2.4.03 CAVITY STRING ASSEMBLY #3** | 2011-03-22 → 2010-10-25 (-148d) | 2011-04-05 → 2011-06-22 (+78d) |  |  |  |  |  |
| 1312403000 | Cavity String Assy #3 | 2011-03-22 → 2010-10-25 A (-148d) | 2011-04-04 → 2011-06-21 A (+78d) | 10d → 161d | 0% → 100% | 114d → none | 1312103065, 1312103035, 1312402010 FS+4d, 1311132025, 1312103050, 131302001, 1312103060, 1312103040, 1311132030, 1312103030, 1312103055, 1312103045 → 1312103065 FS-120d, 1312103040 FS-80d, 1312103045 FS-85d, 1312103050 FS-90d, 1312103060 FS-115d, 1311132030, 1312402010 FS-85d, 1312103055 FS-95d, 1312103035 FS-75d, 1311132025, 131302001 FS-140d, 1312103030 FS-70d | resources MECH TECH [800 h]; SUPPLIES & MATERIALS; ELEC TECH [40 h]; MECH DES [40 h]; SCIENTIST [64 h]; ELEC ENG [200 h]; SR STAFF [20 h]; MECH ENG [40 h] → MECH DES [40 h]; SCIENTIST [64 h]; ELEC ENG [200 h]; SR STAFF [20 h]; MECH ENG [40 h]; MECH TECH [800 h]; SUPPLIES & MATERIALS; ELEC TECH [40 h] |
| 1312403010 | Transfer to CM #3 Assy | 2011-04-05 → 2011-06-22 A (+78d) | 2011-04-05 → 2011-06-22 A (+78d) |  | 0% → 100% | 114d → none |  |  |
| 04 | **1.3.1.2.4.04 CAVITY STRING ASSEMBLY #4** | 2011-05-03 → 2010-10-25 (-190d) | 2011-05-17 → 2011-08-12 (+87d) |  |  |  |  |  |
| 1312404000 | Cavity String Assy #4 | 2011-05-03 → 2010-10-25 A (-190d) | 2011-05-16 → 2011-07-25 A (+70d) | 10d → 184d | 0% → 100% | 100d → none | 131138045a, 1312104055, 1312104060, 1312104045, 1311132035, 131302002 FS-30d, 1312104065, 1312403010 FS+4d, 1312104040, 1312104030, 1312104035, 1312104050, 1311132040 → 1312104045 FS-115d, 131302002 FS-160d, 1311132035, 1312403010 FS-140d, 1312104050 FS-115d, 131138045a FS-75d, 1312104055 FS-115d, 1312104060 FS-120d, 1312104030 FS-100d, 1312104035 FS-105d, 1312104065 FS-120d, 1311132040, 1312104040 FS-110d | resources SUPPLIES & MATERIALS; SR STAFF [20 h]; MECH DES [40 h]; ELEC ENG [200 h]; MECH ENG [40 h]; SCIENTIST [64 h]; ELEC TECH [40 h]; MECH TECH [800 h] → ELEC TECH [40 h]; MECH TECH [800 h]; SUPPLIES & MATERIALS; SR STAFF [20 h]; MECH DES [40 h]; ELEC ENG [200 h]; MECH ENG [40 h]; SCIENTIST [64 h] |
| 1312404010 | Transfer to CM #4 Assy | 2011-05-17 → 2011-08-12 A (+87d) | 2011-05-17 → 2011-08-12 A (+87d) |  | 0% → 100% | 100d → none | 131302002 FS-20d, 1312404000 → 1312404000, 131302002 |  |
| 05 | **1.3.1.2.4.05 CAVITY STRING ASSEMBLY #5** | 2011-05-25 → 2010-10-25 (-212d) | 2011-06-09 → 2011-09-28 (+111d) |  |  |  |  |  |
| 1312405000 | Cavity String Assy #5 | 2011-05-25 → 2010-10-25 A (-212d) | 2011-06-08 → 2011-09-27 A (+111d) | 10d → 229d | 0% → 100% | 114d → none | 1312105060, 131115016, 131302003 FS-25d, 1312105050, 1312404010 FS-10d, 131116016, 1312105055, 1311132045, 1312105065, 1312105035, 1312105045, 1312105030, 1312105040 → 1312105055 FS-170d, 131116016 FS-155d, 1312105040 FS-160d, 1312105065 FS-180d, 1311132045, 131115016, 1312105035 FS-160d, 1312404010 FS-180d, 1312105045 FS-165d, 131302003 FS-200d, 1312105030 FS-155d, 1312105050 FS-165d, 1312105060 FS-170d | resources MECH TECH [800 h]; SUPPLIES & MATERIALS; MECH ENG [40 h]; SCIENTIST [64 h]; SR STAFF [20 h]; ELEC ENG [200 h]; ELEC TECH [40 h]; MECH DES [40 h] → MECH DES [40 h]; MECH ENG [40 h]; SCIENTIST [64 h]; SR STAFF [20 h]; ELEC ENG [200 h]; ELEC TECH [40 h]; MECH TECH [800 h]; SUPPLIES & MATERIALS |
| 1312405010 | Transfer to CM #5 Assy | 2011-06-09 → 2011-09-28 A (+111d) | 2011-06-09 → 2011-09-28 A (+111d) |  | 0% → 100% | 144d → none |  |  |
| 06 | **1.3.1.2.4.06 CAVITY STRING ASSEMBLY #6** | 2011-06-17 → 2010-10-25 (-235d) | 2011-11-21 → 2011-11-24 (+3d) |  |  |  |  |  |
| 1312406000 | Cavity String Assy #6 | 2011-06-17 → 2010-10-25 A (-235d) | 2011-06-30 → 2011-11-21 A (+144d) | 10d → 268d | 0% → 100% | 149d → none | 1312106035, 1312106060, 1312106040, 1312106055, 1312405010 FS+4d, 1312106065, 1312106045, 1311132050, 1312106030, 1312106050, 131302004 FS-105d, 1317010 FS-30d → 1312106060 FS-205d, 1311132050, 1312106040 FS-195d, 1312106030 FS-190d, 1312106065 FS-210d, 1312405010 FS-210d, 1312106035 FS-195d, 1312106055 FS-205d, 131302004 FS-265d, 1312106045 FS-200d, 1312106050 FS-200d | resources MECH ENG [40 h]; ELEC ENG [200 h]; ELEC TECH [40 h]; MECH TECH [800 h]; SUPPLIES & MATERIALS; SCIENTIST [64 h]; SR STAFF [20 h]; MECH DES [40 h] → MECH DES [40 h]; MECH ENG [40 h]; SR STAFF [20 h]; ELEC ENG [200 h]; ELEC TECH [40 h]; MECH TECH [800 h]; SUPPLIES & MATERIALS; SCIENTIST [64 h] |
| 1312406010 | Transfer to CM #6 Assy | 2011-11-21 → 2011-11-23 A (+2d) | 2011-11-21 → 2011-11-24 A (+3d) |  | 0% → 100% | 50d → none | 131302004 FS+5d, 1312406000, 1317010 → 1317010, 1312406000, 131302004 FS-55d |  |
| 07 | **1.3.1.2.4.07 CAVITY STRING ASSEMBLY #7** | 2011-11-30 → 2010-10-25 (-401d) | 2011-12-14 → 2011-12-13 (-1d) |  |  |  |  |  |
| 1312407000 | Cavity String Assy #7 | 2011-11-30 → 2010-10-25 A (-401d) | 2011-12-13 A | 10d → 282d | 0% → 100% | 50d → none | 1312107045, 1312107040, 1312107065, 1312107035, 131138050, 1312406010 FS+4d, 1311132055, 1312107050, 1312107055, 1312107060, 1311132060, 1312107030, 131302005 FS-40d → 1311132060, 131302005 FS-300d, 131138050 FS-180d, 1312107030 FS-185d, 1312107055 FS-195d, 1312107045 FS-190d, 1312107050 FS-195d, 1312107040 FS-190d, 1312107035 FS-185d, 1311132055, 1312406010 FS-235d, 1312107065 FS-200d, 1312107060 FS-200d | resources SUPPLIES & MATERIALS; SR STAFF [20 h]; MECH DES [40 h]; ELEC ENG [200 h]; MECH ENG [40 h]; SCIENTIST [64 h]; ELEC TECH [40 h]; MECH TECH [800 h] → ELEC TECH [40 h]; MECH TECH [800 h]; SUPPLIES & MATERIALS; SR STAFF [20 h]; MECH DES [40 h]; MECH ENG [40 h]; SCIENTIST [64 h]; ELEC ENG [200 h] |
| 1312407010 | Transfer to CM #7 Assy | 2011-12-14 → 2011-12-13 A (-1d) | 2011-12-14 → 2011-12-13 A (-1d) |  | 0% → 100% | 50d → none |  |  |
| 08 | **1.3.1.2.4.08 CAVITY STRING ASSEMBLY #8** | 2011-12-21 → 2010-10-25 (-422d) | 2012-01-12 → 2012-01-24 (+12d) |  |  |  |  |  |
| 1312408000 | Cavity String Assy #8 | 2011-12-21 → 2010-10-25 A (-422d) | 2012-01-11 → 2011-12-19 A (-23d) | 10d → 286d | 0% → 100% | 50d → none | 1312407010 FS+4d, 1311132065, 1312108035, 1312108040, 1312108060, 1312108030, 1312108045, 1312108055, 1312108065, 1312108050, 131302006 FS-65d, 1311132070 → 131302006 FS-360d, 1311132070 FS-20d, 1312108035 FS-220d, 1312108065 FS-240d, 1312108055 FS-235d, 1312108040 FS-225d, 1312108045 FS-225d, 1312407010 FS-260d, 1312108060 FS-235d, 1312108030 FS-220d, 1311132065 FS-15d, 1312108050 FS-230d | resources MECH ENG [40 h]; SCIENTIST [64 h]; MECH TECH [800 h]; MECH DES [40 h]; ELEC ENG [200 h]; ELEC TECH [40 h]; SUPPLIES & MATERIALS; SR STAFF [20 h] → ELEC ENG [200 h]; ELEC TECH [40 h]; SUPPLIES & MATERIALS; SR STAFF [20 h]; MECH TECH [800 h]; MECH DES [40 h]; MECH ENG [40 h]; SCIENTIST [64 h] |
| 1312408010 | Transfer to CM #8 Assy | 2012-01-12 → 2012-01-24 A (+12d) | 2012-01-12 → 2012-01-24 A (+12d) |  | 0% → 100% | 50d → none | 1312408000, 131302006 FS-65d → 131302006 FS-110d, 1312408000 |  |
| 09 | **1.3.1.2.4.09 CAVITY STRING ASSEMBLY #9** | 2012-01-20 → 2010-10-25 (-452d) | 2012-02-03 → 2012-01-18 (-16d) |  |  |  |  |  |
| 1312409000 | Cavity String Assy #9 | 2012-01-20 → 2010-10-25 A (-452d) | 2012-02-02 → 2012-01-16 A (-17d) | 10d → 299d | 0% → 100% | 50d → none | 1311132075, 1312109065, 1312109035, 1312109030, 1312109050, 1311132080, 1312109040, 1312109055, 1312109060, 1312408010 FS+4d, 1312109045 → 1312109055 FS-255d, 1311132080 FS-40d, 1312109030 FS-245d, 1312109035 FS-245d, 1312109050 FS-255d, 1312109065 FS-265d, 1312109060 FS-260d, 1312109045 FS-250d, 1311132075 FS-35d, 1312408010 FS-295d, 1312109040 FS-250d | resources ELEC TECH [40 h]; MECH ENG [40 h]; SR STAFF [20 h]; ELEC ENG [200 h]; SCIENTIST [64 h]; SUPPLIES & MATERIALS; MECH TECH [800 h]; MECH DES [40 h] → ELEC ENG [200 h]; SCIENTIST [64 h]; SUPPLIES & MATERIALS; MECH TECH [800 h]; MECH DES [40 h]; ELEC TECH [40 h]; MECH ENG [40 h]; SR STAFF [20 h] |
| 1312409010 | Transfer to CM #9 Assy | 2012-02-03 → 2012-01-17 A (-17d) | 2012-02-03 → 2012-01-18 A (-16d) | 1d → 2d | 0% → 100% | 50d → none |  |  |
| 10 | **1.3.1.2.4.10 CAVITY STRING ASSEMBLY #10** | 2012-02-06 → 2010-10-25 (-469d) | 2012-02-21 → 2012-02-20 (-1d) |  |  |  |  |  |
| 1312410000 | Cavity String Assy #10 | 2012-02-06 → 2010-10-25 A (-469d) | 2012-02-17 → 2012-02-20 A (+3d) | 10d → 323d | 0% → 100% | 50d → none | 1312409010, 1312110055, 1312110030, 1312110065, 1311132085, 1312110060, 1312110040, 1312110050, 1311132100M, 1312110045, 1312110035, 1311122105M, 1311132090 → 1311122105M FS-295d, 1311132090 FS-80d, 1312110035 FS-285d, 1312110040 FS-290d, 1312110045 FS-290d, 1312110030 FS-285d, 1312110060 FS-300d, 1312409010 FS-225d, 1312110065 FS-5d, 1312110055 FS-295d, 1311132100M FS-80d, 1312110050 FS-295d | resources ELEC TECH [40 h]; MECH TECH [800 h]; MECH DES [40 h]; MECH ENG [40 h]; SCIENTIST [64 h]; SR STAFF [20 h]; SUPPLIES & MATERIALS; ELEC ENG [200 h] → SR STAFF [20 h]; SUPPLIES & MATERIALS; ELEC ENG [200 h]; ELEC TECH [40 h]; MECH TECH [800 h]; MECH DES [40 h]; MECH ENG [40 h]; SCIENTIST [64 h] |
| 1312410010 | Transfer to CM #10 Assy | 2012-02-21 → 2012-02-13 A (-8d) | 2012-02-21 → 2012-02-20 A (-1d) | 1d → 5d | 0% → 100% | 50d → none |  |  |
| 3 | **1.3.1.3 CRYOMODULE ASSEMBLY** | 2010-11-16 → 2011-01-21 (+66d) |  |  |  |  |  |  |
| 01 | **1.3.1.3.01 SPACE FRAME ASSEMBLY** | 2010-11-16 → 2011-01-21 (+66d) |  |  |  |  |  |  |
| 131301001 | Space Frame Assy #1 | 2010-11-16 → 2011-01-21 A (+66d) | 2011-01-21 → 2011-04-18 A (+87d) | 40d → 61d | 0% → 100% | 72d → none | 1312401010, 131133020 FS-15d, 131134015, 131121020 FS-20d, 131131020, 131123020 FS-15d, 13114020a, 13114015, 131122017 FS-15d, 131132020 FS-20d, 131122020 FS-15d → 131122017 FS-15d, 131123020 FS-15d, 131132020 FS-20d, 13114020a FS-70d, 131134015, 13114020, 131133020 FS-15d, 1312401010, 131121020 FS-20d, 13114015, 131122020 FS-15d, 131131020 | resources ELEC ENG [80 h]; SR STAFF [80 h]; ELEC TECH [320 h]; MECH DES [160 h]; SCIENTIST [80 h]; SUPPLIES & MATERIALS; COMP SCIENT [80 h]; MECH ENG [160 h]; MECH TECH [1600 h] → SUPPLIES & MATERIALS; MECH DES [160 h]; SCIENTIST [80 h]; COMP SCIENT [80 h]; MECH ENG [160 h]; MECH TECH [1600 h]; ELEC ENG [80 h]; SR STAFF [80 h]; ELEC TECH [320 h] |
| 131301002 | Space Frame Assy #2 | 2011-03-08 → 2011-04-11 A (+34d) | 2011-04-25 → 2011-06-14 A (+50d) | 35d → 46d | 0% → 100% | 37d → none | 131132020 FS-12.5d, 131122020 FS-10d, 131121021 FS-12.5d, 1312402010, 131123020 FS-10d, 131133025, 131122025 FS-10d, 131122017 FS-10d → 131122020 FS-10d, 131122017 FS-10d, 131121021, 131122025 FS-10d, 131133025, 1312402010, 131123020 FS-10d, 131132020 FS-12.5d | resources ELEC TECH [320 h]; SUPPLIES & MATERIALS; MECH DES [80 h]; MECH ENG [80 h]; MECH TECH [1600 h]; SCIENTIST [40 h]; SR STAFF [40 h]; ELEC ENG [40 h] → MECH TECH [1600 h]; SUPPLIES & MATERIALS; SR STAFF [40 h]; ELEC ENG [40 h]; ELEC TECH [320 h]; MECH DES [80 h]; MECH ENG [80 h]; SCIENTIST [40 h] |
| 131301003 | Space Frame Assy #3 | 2011-04-06 → 2011-06-01 A (+56d) | 2011-05-17 → 2011-09-11 A (+117d) | 30d → 71d | 0% → 100% | 114d → none |  | resources MECH DES [40 h]; MECH ENG [40 h]; MECH TECH [1600 h]; SUPPLIES & MATERIALS; SCIENTIST [20 h]; SR STAFF [20 h]; ELEC ENG [40 h]; ELEC TECH [320 h] → SUPPLIES & MATERIALS; SCIENTIST [20 h]; SR STAFF [20 h]; ELEC ENG [40 h]; ELEC TECH [320 h]; MECH DES [40 h]; MECH ENG [40 h]; MECH TECH [1600 h] |
| 131301004 | Space Frame Assy #4 | 2011-06-15 → 2011-08-12 A (+58d) | 2011-07-27 → 2011-12-12 A (+138d) | 30d → 84d | 0% → 100% | 81d → none |  | resources ELEC ENG [16 h]; ELEC TECH [240 h]; MECH DES [4 h]; MECH ENG [40 h]; MECH TECH [1600 h]; SCIENTIST [4 h]; SR STAFF [4 h]; SUPPLIES & MATERIALS → SR STAFF [4 h]; SUPPLIES & MATERIALS; MECH TECH [1600 h]; ELEC ENG [16 h]; ELEC TECH [240 h]; MECH DES [4 h]; MECH ENG [40 h]; SCIENTIST [4 h] |
| 131301005 | Space Frame Assy #5 | 2011-06-30 → 2011-09-20 A (+82d) | 2011-08-11 → 2011-11-28 A (+109d) | 30d → 48d | 0% → 100% | 130d → none | 131132025 FS-20d, 131121026 FS-20d, 131122040 FS-10d, 131302003, 131134016, 131122035 FS-10d, 131133040, 131131021b, 131123025 FS-10d, 1312405010, 131134018 → 131122040 FS-10d, 1312405010 FS-20d, 131121026, 131131021b, 131132025 FS-20d, 131134016, 131122035 FS-10d, 131134018, 131302003 FS-45d, 131123025 FS-10d, 131133040 | resources SUPPLIES & MATERIALS; MECH DES [4 h]; MECH ENG [40 h]; SCIENTIST [4 h]; MECH TECH [1600 h]; ELEC ENG [16 h]; SR STAFF [4 h]; ELEC TECH [240 h] → MECH DES [4 h]; MECH ENG [40 h]; SCIENTIST [4 h]; ELEC ENG [16 h]; SR STAFF [4 h]; MECH TECH [1600 h]; ELEC TECH [240 h]; SUPPLIES & MATERIALS |
| 131301006 | Space Frame Assy #6 | 2011-11-22 → 2012-02-01 A (+71d) | 2012-01-27 → 2012-02-06 A (+10d) | 40d → 4d | 0% → 100% | 92d → none | 131123025 FS-5d, 1312406010, 131121027 FS-10d, 131122040 FS-5d, 131132025 FS-10d, 131133045, 131302004, 131122045 FS-5d, 131301005 FS-15d → 131122045 FS-5d, 131133045, 1312406010 FS+5d, 131132025 FS-10d, 131123025 FS-5d, 131301005, 131121027, 131122040 FS-5d, 131302004 | resources MECH DES [4 h]; MECH ENG [40 h]; SCIENTIST [4 h]; ELEC ENG [16 h]; ELEC TECH [240 h]; SR STAFF [4 h]; MECH TECH [1600 h]; SUPPLIES & MATERIALS → SCIENTIST [4 h]; ELEC ENG [16 h]; ELEC TECH [240 h]; SR STAFF [4 h]; MECH TECH [1600 h]; MECH DES [4 h]; MECH ENG [40 h]; SUPPLIES & MATERIALS |
| 131301006a | Space Frame Assy #6 Reverse entry | 2012-02-01 A | 2012-02-01 → 2012-02-06 A (+5d) | 1d → 4d | 0% → 100% | 153d → none |  | resources SCIENTIST [-4 h]; ELEC ENG [-16 h]; ELEC TECH [-240 h]; SR STAFF [-4 h]; MECH TECH [-1600 h]; SUPPLIES & MATERIALS; MECH DES [-4 h]; MECH ENG [-40 h] → MECH TECH [-1600 h]; SUPPLIES & MATERIALS; MECH DES [-4 h]; MECH ENG [-40 h]; SCIENTIST [-4 h]; ELEC ENG [-16 h]; ELEC TECH [-240 h]; SR STAFF [-4 h] |
| 131301007 | Space Frame Assy #7 | 2012-02-03 → 2012-02-01 A (-2d) | 2012-03-08 → 2012-03-18 A (+10d) | 24d → 32d | 0% → 100% | 162d → none | 131133050, 131132025, 131121028, 131122045, 131122050, 131123025, 131302005, 1312407010 → 131123025, 131122045, 131122050, 131121028, 131132025, 131302005 FS-20d, 131133050, 1312407010 | resources MECH TECH [1600 h]; ELEC ENG [16 h]; SUPPLIES & MATERIALS; MECH DES [4 h]; SR STAFF [4 h]; MECH ENG [40 h]; ELEC TECH [240 h]; SCIENTIST [4 h] → SR STAFF [4 h]; MECH ENG [40 h]; ELEC TECH [240 h]; MECH TECH [1600 h]; ELEC ENG [16 h]; SUPPLIES & MATERIALS; MECH DES [4 h]; SCIENTIST [4 h] |
| 131301006b | Space Frame Assy #6 | 2012-02-27 → 2012-03-03 A (+5d) | 2012-04-06 → 2012-04-27 A (+21d) | 30d → 40d | 0% → 100% | 153d → none |  | resources MECH DES [4 h]; MECH ENG [40 h]; SCIENTIST [4 h]; ELEC ENG [16 h]; MECH TECH [1600 h]; SUPPLIES & MATERIALS; ELEC TECH [240 h]; SR STAFF [4 h] → MECH DES [4 h]; MECH ENG [40 h]; SCIENTIST [4 h]; ELEC ENG [16 h]; ELEC TECH [240 h]; SR STAFF [4 h]; MECH TECH [1600 h]; SUPPLIES & MATERIALS |
| 131301008 | Space Frame Assy #8 | 2012-05-29 → 2012-05-01 A (-28d) | 2012-07-13 → 2012-08-14 A (+32d) | 33d → 74d | 0% → 100% | 141d → none | 131122055 FS-20d, 1312408010, 131123030 FS-20d, 131132030 FS-20d, 131132030a, 131302007, 131122050 FS-20d, 131121029, 1317025, 131133055 → 1312408010, 131122055 FS-20d, 131132030a, 131121029, 131132030 FS-20d, 131122050 FS-20d, 131133055, 131302007 FS-10d, 131123030 FS-20d | resources MECH DES [4 h]; MECH ENG [40 h]; SCIENTIST [4 h]; ELEC ENG [16 h]; ELEC TECH [240 h]; SR STAFF [4 h]; MECH TECH [1600 h]; SUPPLIES & MATERIALS → ELEC ENG [16 h]; ELEC TECH [240 h]; SR STAFF [4 h]; MECH ENG [40 h]; MECH TECH [1600 h]; SUPPLIES & MATERIALS; MECH DES [4 h]; SCIENTIST [4 h] |
| 131301009 | Space Frame Assy #9 | 2012-07-09 → 2012-07-16 A (+7d) | 2012-09-07 → 2012-09-17 A (+10d) | 44d → 45d | 0% → 100% | 146d → none | 131121030 FS-12.5d, 1312409010, 131302006b, 131133060, 131122060 FS-10d, 131122055 FS-10d, 131132030 FS-12.5d, 131132030a, 131123030 FS-10d → 131132030a FS-12.5d, 131133060, 131121030 FS-12.5d, 1317025 FS-40d, 131123030 FS-10d, 131302006b, 131122055 FS-10d, 131122060 FS-10d, 1312409010 | resources MECH DES [4 h]; MECH ENG [40 h]; SR STAFF [4 h]; SCIENTIST [4 h]; ELEC ENG [16 h]; SUPPLIES & MATERIALS; ELEC TECH [240 h]; MECH TECH [1600 h] → MECH DES [4 h]; MECH ENG [40 h]; MECH TECH [1600 h]; SCIENTIST [4 h]; SR STAFF [4 h]; ELEC ENG [16 h]; SUPPLIES & MATERIALS; ELEC TECH [240 h] |
| 131301010 | Space Frame Assy #10 FY12 | 2012-09-04 → 2012-09-10 A (+6d) | 2012-09-28 → 2012-11-19 A (+52d) | 19d → 69d | 0% → 100% | 141d → none |  | resources ELEC ENG [7.79 h]; ELEC TECH [116.92 h]; SUPPLIES & MATERIALS; MECH ENG [19.49 h]; MECH TECH [779.49 h]; SCIENTIST [1.95 h]; MECH DES [1.95 h]; SR STAFF [1.95 h] → MECH TECH [779.49 h]; SCIENTIST [1.95 h]; MECH DES [1.95 h]; SR STAFF [1.95 h]; ELEC ENG [7.79 h]; ELEC TECH [116.92 h]; SUPPLIES & MATERIALS; MECH ENG [19.49 h] |
| 131301010a | Space Frame Assy #10 FY13 | 2012-10-01 → 2012-09-10 A (-21d) | 2012-10-26 → 2012-11-19 A (+24d) | 20d → 69d | 0% → 100% | 141d → none | 131301010 → 131301010 FS-20d | resources MECH ENG [30.48 h]; MECH TECH [1219.28 h]; SCIENTIST [3.05 h]; MECH DES [3.05 h]; SR STAFF [3.05 h]; ELEC ENG [12.2 h]; ELEC TECH [182.9 h]; SUPPLIES & MATERIALS → MECH DES [3.05 h]; SR STAFF [3.05 h]; ELEC ENG [12.2 h]; ELEC TECH [182.9 h]; SUPPLIES & MATERIALS; MECH ENG [30.48 h]; MECH TECH [1219.28 h]; SCIENTIST [3.05 h] |
| 131301015 | Re-Baseline Actuals Adjustment | 2013-08-30 A | 2013-08-30 A |  | 0% → 100% | 20d → none | 9-130M FS+227d → none |  |
| 02 | **1.3.1.3.02 CRYOMODULE ASSEMBLY** | 2011-01-24 → 2011-04-11 (+77d) |  |  |  |  |  |  |
| 131302001 | Cryomodule Assy #1 | 2011-01-24 → 2011-04-11 A (+77d) | 2011-03-21 → 2011-05-21 A (+61d) | 40d → 30d | 0% → 100% | 72d → none | 131137040, 131131020, 131122017 FS-15d, 131136020 FS-15d, 131139025, 131133070, 131123020 FS-15d, 131138020 FS-15d, 131132020 FS-20d, 13114020a, 131137015, 131137030, 131135020a, 13115015, 131138030, 131122075, 131137050, 131138040, 131301001, 13114015, 131134015, 131122020 FS-15d → 131131020, 131138020 FS-15d, 131136020 FS-15d, 131138030 FS-90d, 131137015, 131134015, 131138040, 131123020 FS-15d, 131139025, 131133070, 13114020a, 131137040 FS-45d, 131137030, 131132020 FS-20d, 131122017 FS-15d, 131122075, 13114015, 131135020a, 131301001, 13115015, 131122020 FS-15d, 13114020, 131135020 FS-25d, 131137050 | resources ELEC TECH [320 h]; SCIENTIST [80 h]; COMP SCIENT [80 h]; MECH ENG [160 h]; MECH TECH [1600 h]; ELEC ENG [80 h]; SR STAFF [80 h]; SUPPLIES & MATERIALS; MECH DES [160 h] → SR STAFF [80 h]; SUPPLIES & MATERIALS; ELEC TECH [320 h]; MECH DES [160 h]; SCIENTIST [80 h]; COMP SCIENT [80 h]; MECH ENG [160 h]; MECH TECH [1600 h]; ELEC ENG [80 h] |
| 131302002 | Cryomodule Assy #2 | 2011-04-26 → 2011-06-15 A (+50d) | 2011-06-14 → 2011-08-09 A (+56d) | 35d → 39d | 0% → 100% | 37d → none | 131136025, 131122080, 131132020 FS-12.5d, 131122017 FS-10d, 131302001 FS-15d, 131122025 FS-10d, 131122020 FS-10d, 131133075, 131138020 FS-10d, 131123020 FS-10d, 131301002, 131135025 → 131136025, 131132020 FS-12.5d, 131301002, 131122017 FS-10d, 131122020 FS-10d, 131123020 FS-10d, 131138020 FS-10d, 131122080, 131135025, 131133075 FS-15d, 131302001 FS-15d, 131122025 FS-10d | resources SR STAFF [40 h]; ELEC ENG [40 h]; ELEC TECH [320 h]; MECH DES [80 h]; MECH ENG [80 h]; MECH TECH [1600 h]; SUPPLIES & MATERIALS; SCIENTIST [40 h] → MECH ENG [80 h]; MECH TECH [1600 h]; SUPPLIES & MATERIALS; SCIENTIST [40 h]; SR STAFF [40 h]; ELEC ENG [40 h]; ELEC TECH [320 h]; MECH DES [80 h] |
| 131302003 | Cryomodule Assy #3 | 2011-05-18 → 2011-09-03 A (+108d) | 2011-06-29 → 2011-10-16 A (+109d) | 30d → 29d | 0% → 100% | 114d → none | 131138020, 131135030, 131122030, 131136030, 131122085, 131301003, 131133080, 131122025, 131132020, 131123020 → 131122085, 131135030, 131136030, 131122025, 131133080 FS-15d, 131301003, 131138020, 131122030, 131123020, 131132020 | resources SR STAFF [20 h]; ELEC ENG [40 h]; ELEC TECH [320 h]; MECH DES [40 h]; MECH ENG [40 h]; SUPPLIES & MATERIALS; MECH TECH [1600 h]; SCIENTIST [20 h] → SCIENTIST [20 h]; SR STAFF [20 h]; ELEC ENG [40 h]; ELEC TECH [320 h]; MECH DES [40 h]; MECH ENG [40 h]; MECH TECH [1600 h]; SUPPLIES & MATERIALS |
| 131302005 | Cryomodule Assy #5 | 2012-01-05 → 2011-11-21 A (-45d) | 2012-02-02 → 2012-01-29 A (-4d) | 20d → 41d | 0% → 100% | 35d → none | 131138020ba, 131135040, 131131021b, 131132025 FS-20d, 131122095, 9-120M FS+60d, 131134018, 131123025 FS-10d, 131301005, 131134016, 131136040, 131134021LOE, 131133090, 131122035 FS-10d, 131122040 FS-10d → 131135040, 131134018, 131123025 FS-10d, 131134021LOE, 131122035 FS-10d, 131133090 FS-15d, 131134016, 131136040, 131131021b, 131301005, 131138020ba, 131132025 FS-20d, 131122095, 131122040 FS-10d | resources ELEC TECH [240 h]; ELEC ENG [16 h]; SR STAFF [4 h]; MECH TECH [1600 h]; SUPPLIES & MATERIALS; MECH DES [4 h]; MECH ENG [40 h]; SCIENTIST [4 h] → MECH ENG [40 h]; SR STAFF [4 h]; MECH TECH [1600 h]; ELEC TECH [240 h]; SUPPLIES & MATERIALS; MECH DES [4 h]; SCIENTIST [4 h]; ELEC ENG [16 h] |
| 131302004 | Cryomodule Assy #4 | 2011-10-03 → 2011-12-13 A (+71d) | 2011-11-11 → 2012-03-12 A (+122d) | 30d → 57d | 0% → 100% | 35d → none | 131133085, 131123025 FS-15d, 131132025 FS-25d, 131122035 FS-15d, 131122030 FS-15d, 9-120M, 131301004, 131138020, 131122090, 131135035, 131136035 → 131136035, 9-120M, 131135035, 131123025 FS-15d, 131133085 FS-15d, 131138020, 131132025 FS-25d, 131122090, 131122030 FS-15d, 131301004 FS-20d, 131122035 FS-15d | resources SCIENTIST [4 h]; SR STAFF [4 h]; ELEC TECH [240 h]; MECH DES [4 h]; MECH ENG [40 h]; MECH TECH [1600 h]; SUPPLIES & MATERIALS; ELEC ENG [16 h] → SCIENTIST [4 h]; SR STAFF [4 h]; ELEC ENG [16 h]; ELEC TECH [240 h]; MECH DES [4 h]; MECH ENG [40 h]; MECH TECH [1600 h]; SUPPLIES & MATERIALS |
| 131302006 | Cryomodule Assy #6 | 2012-01-30 → 2012-02-01 A (+2d) | 2012-01-31 → 2012-02-06 A (+6d) | 2d → 4d | 0% → 100% | 92d → none |  | resources SUPPLIES & MATERIALS; MECH DES [0.4 h]; MECH ENG [4 h]; SCIENTIST [0.4 h]; ELEC ENG [1.6 h]; ELEC TECH [24 h]; SR STAFF [0.4 h]; MECH TECH [160 h] → MECH ENG [4 h]; SUPPLIES & MATERIALS; MECH DES [0.4 h]; SCIENTIST [0.4 h]; ELEC ENG [1.6 h]; ELEC TECH [24 h]; SR STAFF [0.4 h]; MECH TECH [160 h] |
| 131302006a | Cryomodule Assy #6 Reverse Entry | 2012-02-01 A | 2012-02-01 → 2012-02-06 A (+5d) | 1d → 4d | 0% → 100% | 199d → none |  | resources SUPPLIES & MATERIALS; MECH DES [-0.4 h]; MECH ENG [-4 h]; SCIENTIST [-0.4 h]; ELEC ENG [-1.6 h]; ELEC TECH [-24 h]; SR STAFF [-0.4 h]; MECH TECH [-160 h] → SR STAFF [-0.4 h]; SUPPLIES & MATERIALS; MECH TECH [-160 h]; MECH DES [-0.4 h]; MECH ENG [-4 h]; SCIENTIST [-0.4 h]; ELEC ENG [-1.6 h]; ELEC TECH [-24 h] |
| 131302007 | Cryomodule Assy #7 | 2012-03-09 → 2012-03-02 A (-7d) | 2012-04-26 → 2012-05-14 A (+18d) | 35d → 52d | 0% → 100% | 162d → none | 131122050, 131301007, 131132025, 131138020d, 131122045, 131122105, 131123025, 131133100, 131135050, 131136050 → 131138020d, 131122105, 131135050, 131122050, 131132025, 131136050, 131133100 FS-15d, 131301007, 131123025, 131122045 | resources ELEC ENG [16 h]; SUPPLIES & MATERIALS; MECH DES [4 h]; SCIENTIST [4 h]; SR STAFF [4 h]; MECH ENG [40 h]; ELEC TECH [240 h]; MECH TECH [1600 h] → SCIENTIST [4 h]; SR STAFF [4 h]; MECH ENG [40 h]; ELEC TECH [240 h]; MECH TECH [1600 h]; ELEC ENG [16 h]; SUPPLIES & MATERIALS; MECH DES [4 h] |
| 131302006b | Cryomodule Assy #6 | 2012-05-29 → 2012-04-09 A (-50d) | 2012-07-06 → 2012-06-27 A (-9d) | 28d → 56d | 0% → 100% | 118d → none | 131302006a, 131132025 FS-10d, 131301006, 131122100, 131135045, 131122045 FS-5d, 131138020ba, 131136045, 131123025 FS-5d, 131301006b, 1317025, 131133095, 131122040 FS-5d → 131301006, 131301006b, 131122040 FS-5d, 131136045, 131302006a, 131122045 FS-5d, 131123025 FS-5d, 131135045, 131133095, 131122100, 131138020ba, 131132025 FS-10d |  |
| 131302008 | Cryomodule Assy #8 | 2012-07-16 → 2012-08-20 A (+35d) | 2012-08-31 → 2012-09-10 A (+10d) | 35d → 15d | 0% → 100% | 141d → none | 131122050 FS-20d, 131138030 FS-20d, 131301008, 131135055, 131122110, 131123030 FS-20d, 131132030a, 131132030 FS-20d, 131138020d, 131136055, 131133105, 131122055 FS-20d → 131136055, 131133105 FS-15d, 131132030a, 131122050 FS-20d, 131123030 FS-20d, 131138030 FS-20d, 1317025 FS-15d, 131122110, 131122055 FS-20d, 131135055, 131132030, 131301008, 131138020d | resources ELEC TECH [240 h]; SR STAFF [4 h]; ELEC ENG [16 h]; MECH TECH [1600 h]; SUPPLIES & MATERIALS; MECH DES [4 h]; MECH ENG [40 h]; SCIENTIST [4 h] → MECH ENG [40 h]; SCIENTIST [4 h]; ELEC ENG [16 h]; ELEC TECH [240 h]; SR STAFF [4 h]; MECH TECH [1600 h]; SUPPLIES & MATERIALS; MECH DES [4 h] |
| 131302009 | Cryomodule Assy #9 FY12 | 2012-09-10 → 2012-09-17 A (+7d) | 2012-09-28 → 2013-01-31 A (+125d) | 15d → 68d | 0% → 100% | 146d → none | 131122055 FS-10d, 131122060 FS-10d, 131123030 FS-10d, 131301009, 131133110, 131138030 FS-10d, 131138020g, 131132030a, 131135060, 131136060, 131132030 FS-12.5d → 131122060 FS-10d, 131123030 FS-10d, 131136060, 131138030 FS-10d, 131133110 FS-15d, 131122055 FS-10d, 131301009, 131132030a FS-20d, 131135060, 131138020g | resources SUPPLIES & MATERIALS; ELEC TECH [120 h]; MECH TECH [800 h]; MECH DES [2 h]; MECH ENG [20 h]; SCIENTIST [2 h]; SR STAFF [2 h]; ELEC ENG [8 h] → ELEC TECH [120 h]; MECH TECH [800 h]; MECH DES [2 h]; MECH ENG [20 h]; SCIENTIST [2 h]; SR STAFF [2 h]; ELEC ENG [8 h]; SUPPLIES & MATERIALS |

| ID | Task | Start | Finish | Duration | Complete | Total float | Predecessors | Other |
| --- | --- | --- | --- | --- | --- | --- | --- | --- |
| 131302009a | Cryomodule Assy #9 FY13 | 2012-10-01 → 2012-09-17 A (-14d) | 2012-10-19 → 2013-01-31 A (+104d) | 15d → 68d | 0% → 100% | 146d → none | 131302009 → 131302009 FS-20d | resources SCIENTIST [3 h]; SR STAFF [3 h]; ELEC ENG [11.99 h]; SUPPLIES & MATERIALS; ELEC TECH [179.81 h]; MECH TECH [1198.77 h]; MECH DES [3 h]; MECH ENG [29.97 h] → SUPPLIES & MATERIALS; ELEC TECH [179.81 h]; MECH TECH [1198.78 h]; MECH DES [3 h]; MECH ENG [29.97 h]; SCIENTIST [3 h]; SR STAFF [3 h]; ELEC ENG [11.99 h] |
| 131302010 | Cryomodule Assy #10 | 2012-10-29 → 2012-12-17 A (+49d) | 2012-12-07 → 2013-03-11 A (+94d) |  | 0% → 100% | 141d → none | 131138065LOE, 131138020g, 131135065, 131132030a, 131122060, 131132030, 131123030, 131133130LOE, 131133115a, 131122065R, 131301010a, 131138030, 131136065 → 131301010 FS-15d, 131135065, 131138065LOE, 131122065R, 131133115a, 131133130LOE, 131132030, 131132030a, 131122060, 131123030, 131138020g, 131138030, 131301010a FS-15d, 131136065 | resources ELEC ENG [23.98 h]; ELEC TECH [359.63 h]; SUPPLIES & MATERIALS; MECH ENG [59.94 h]; MECH TECH [2397.53 h]; SCIENTIST [5.99 h]; MECH DES [5.99 h]; SR STAFF [5.99 h] → SUPPLIES & MATERIALS; MECH ENG [59.94 h]; MECH TECH [2397.53 h]; SCIENTIST [5.99 h]; MECH DES [5.99 h]; SR STAFF [5.99 h]; ELEC ENG [23.98 h]; ELEC TECH [359.63 h] |
| 131302015 | Re-Baseline Actuals Adjustment | 2013-08-30 A | 2013-08-30 A |  | 0% → 100% | 20d → none | 9-130M FS+227d → none |  |
| 4 | **1.3.1.4 CRYOMODULE ACCEPTANCE TEST** | 2011-03-22 → 2011-06-01 (+71d) |  |  |  |  |  |  |
| 1314000 | Re-Baseline Actuals Adjustment | 2013-08-30 A | 2013-08-30 A |  | 0% → 100% | 20d → none | 9-130M FS+227d → none |  |
| 01 | **1.3.1.4.01 CRYOMODULE ACCEPTANCE TEST #1** | 2011-03-22 → 2011-06-01 (+71d) | 2011-04-25 → 2011-08-15 (+112d) |  |  |  |  |  |
| 131401000 | Acceptance Test Cryomodule #1 | 2011-03-22 → 2011-06-01 A (+71d) | 2011-04-25 → 2011-08-15 A (+112d) | 25d → 53d | 0% → 100% | 72d → none |  | resources ELEC ENG [240 h]; MECH TECH [200 h]; SUPPLIES & MATERIALS; COMP SCIENT [80 h]; SCIENTIST [200 h]; SR STAFF [200 h]; ELEC TECH [120 h]; MECH ENG [120 h] → COMP SCIENT [80 h]; ELEC ENG [240 h]; SCIENTIST [200 h]; ELEC TECH [120 h]; MECH ENG [120 h]; MECH TECH [200 h]; SUPPLIES & MATERIALS; SR STAFF [200 h] |
| 02 | **1.3.1.4.02 CRYOMODULE ACCEPTANCE TEST #2** | 2011-06-15 → 2011-08-15 (+61d) | 2011-07-20 → 2011-09-14 (+56d) |  |  |  |  |  |
| 131402000 | Acceptance Test Cryomodule #2 | 2011-06-15 → 2011-08-15 A (+61d) | 2011-07-20 → 2011-09-14 A (+56d) | 25d → 22d | 0% → 100% | 37d → none |  | resources SCIENTIST [120 h]; ELEC ENG [240 h]; SR STAFF [120 h]; COMP SCIENT [60 h]; MECH ENG [80 h]; ELEC TECH [120 h]; MECH TECH [160 h]; SUPPLIES & MATERIALS → SR STAFF [120 h]; ELEC ENG [240 h]; ELEC TECH [120 h]; COMP SCIENT [60 h]; MECH ENG [80 h]; MECH TECH [160 h]; SUPPLIES & MATERIALS; SCIENTIST [120 h] |
| 03 | **1.3.1.4.03 CRYOMODULE ACCEPTANCE TEST #3** | 2011-11-01 → 2011-10-17 (-15d) | 2011-12-07 → 2011-12-19 (+12d) |  |  |  |  |  |
| 131403000 | Acceptance Test Cryomodule #3 | 2011-11-01 → 2011-10-17 A (-15d) | 2011-12-07 → 2011-12-19 A (+12d) | 25d → 44d | 0% → 100% | 49d → none |  | resources ELEC TECH [120 h]; COMP SCIENT [40 h]; MECH ENG [80 h]; MECH TECH [160 h]; SUPPLIES & MATERIALS; SCIENTIST [40 h]; SR STAFF [40 h]; ELEC ENG [240 h] → SCIENTIST [40 h]; ELEC TECH [120 h]; SR STAFF [40 h]; ELEC ENG [240 h]; COMP SCIENT [40 h]; MECH ENG [80 h]; MECH TECH [160 h]; SUPPLIES & MATERIALS |
| 04 | **1.3.1.4.04 CRYOMODULE ACCEPTANCE TEST #4** | 2011-12-08 → 2012-02-01 (+55d) | 2012-03-30 → 2012-05-14 (+45d) |  |  |  |  |  |
| 131404000 | Acceptance Test Cryomodule #4 | 2011-12-08 → 2012-02-01 A (+55d) | 2012-01-12 → 2012-02-06 A (+25d) | 20d → 4d | 0% → 100% | 49d → none |  | resources ELEC TECH [120 h]; COMP SCIENT [40 h]; MECH ENG [80 h]; MECH TECH [160 h]; SUPPLIES & MATERIALS; SCIENTIST [40 h]; SR STAFF [40 h]; ELEC ENG [240 h] → SUPPLIES & MATERIALS; SCIENTIST [40 h]; SR STAFF [40 h]; ELEC ENG [240 h]; ELEC TECH [120 h]; COMP SCIENT [40 h]; MECH ENG [80 h]; MECH TECH [160 h] |
| 131404005 | Acceptance Test Cryomodule #4 Reverse Entry | 2012-02-01 A | 2012-02-01 → 2012-02-06 A (+5d) | 1d → 4d | 0% → 100% | 51d → none |  | resources SR STAFF [-40 h]; ELEC ENG [-240 h]; ELEC TECH [-120 h]; COMP SCIENT [-40 h]; MECH ENG [-80 h]; MECH TECH [-160 h]; SUPPLIES & MATERIALS; SCIENTIST [-40 h] → MECH TECH [-160 h]; SUPPLIES & MATERIALS; SCIENTIST [-40 h]; SR STAFF [-40 h]; ELEC ENG [-240 h]; ELEC TECH [-120 h]; COMP SCIENT [-40 h]; MECH ENG [-80 h] |
| 131404010 | Acceptance Test Cryomodule #4 | 2012-02-27 → 2012-04-09 A (+42d) | 2012-03-30 → 2012-05-14 A (+45d) | 25d → 26d | 0% → 100% | 35d → none | 131405000 FS+1d, 131404005, 131403000, 131302004 FS+65d → 131302004, 131404005, 131405000 FS+1d, 131403000 | resources SR STAFF [40 h]; ELEC TECH [120 h]; COMP SCIENT [40 h]; MECH ENG [80 h]; MECH TECH [160 h]; ELEC ENG [240 h]; SUPPLIES & MATERIALS; SCIENTIST [40 h] → SCIENTIST [40 h]; SR STAFF [40 h]; ELEC ENG [240 h]; ELEC TECH [120 h]; COMP SCIENT [40 h]; MECH ENG [80 h]; MECH TECH [160 h]; SUPPLIES & MATERIALS |
| 05 | **1.3.1.4.05 CRYOMODULE ACCEPTANCE TEST #5** | 2012-02-03 → 2012-01-16 (-18d) |  |  |  |  |  |  |
| 131405000 | Acceptance Test Cryomodule #5 | 2012-02-03 → 2012-01-16 A (-18d) | 2012-02-23 A | 14d → 27d | 0% → 100% | 35d → none | 131404000, 131302005 → 131302005, 131404000 FS-35d | resources MECH ENG [80 h]; MECH TECH [160 h]; SUPPLIES & MATERIALS; SCIENTIST [40 h]; ELEC ENG [240 h]; SR STAFF [40 h]; ELEC TECH [120 h]; COMP SCIENT [40 h] → MECH TECH [160 h]; SUPPLIES & MATERIALS; SCIENTIST [40 h]; SR STAFF [40 h]; ELEC TECH [120 h]; COMP SCIENT [40 h]; ELEC ENG [240 h]; MECH ENG [80 h] |
| 06 | **1.3.1.4.06 CRYOMODULE ACCEPTANCE TEST #6** | 2012-07-16 → 2012-12-03 (+140d) | 2012-08-31 → 2013-02-11 (+164d) |  |  |  |  |  |
| 131406000 | Acceptance Test Cryomodule #6 | 2012-07-16 → 2012-12-03 A (+140d) | 2012-08-31 → 2013-02-11 A (+164d) | 35d → 33d | 0% → 100% | 113d → none |  | resources SUPPLIES & MATERIALS; SCIENTIST [40 h]; COMP SCIENT [40 h]; SR STAFF [40 h]; ELEC ENG [240 h]; ELEC TECH [120 h]; MECH ENG [80 h]; MECH TECH [160 h] → ELEC TECH [120 h]; MECH ENG [80 h]; MECH TECH [160 h]; SUPPLIES & MATERIALS; SCIENTIST [40 h]; COMP SCIENT [40 h]; SR STAFF [40 h]; ELEC ENG [240 h] |
| 07 | **1.3.1.4.07 CRYOMODULE ACCEPTANCE TEST #7** | 2012-09-04 → 2012-05-01 (-126d) | 2012-10-19 → 2012-06-27 (-114d) |  |  |  |  |  |
| 131407000a | Acceptance Test Cryomodule #7 FY13 | 2012-10-01 → 2012-05-01 A (-153d) | 2012-10-19 → 2012-06-27 A (-114d) | 15d → 39d | 0% → 100% | 113d → none |  |  |
| 131407000 | Acceptance Test Cryomodule #7 FY12 | 2012-09-04 → 2012-05-01 A (-126d) | 2012-09-28 → 2012-06-27 A (-93d) | 19d → 40d | 0% → 100% | 113d → none | 131406000, 131302007 → 131406000 FS-90d, 131302007 | resources MECH ENG [44.71 h]; SCIENTIST [22.35 h]; SR STAFF [22.35 h]; COMP SCIENT [22.35 h]; ELEC ENG [134.12 h]; ELEC TECH [67.06 h]; MECH TECH [89.41 h]; SUPPLIES & MATERIALS → SR STAFF [22.35 h]; ELEC ENG [134.12 h]; ELEC TECH [67.06 h]; COMP SCIENT [22.35 h]; MECH ENG [44.71 h]; MECH TECH [89.41 h]; SUPPLIES & MATERIALS; SCIENTIST [22.35 h] |
| 08 | **1.3.1.4.08 CRYOMODULE ACCEPTANCE TEST #8** | 2012-10-22 → 2013-02-12 (+113d) | 2012-12-07 → 2013-03-11 (+94d) |  |  |  |  |  |
| 131408000 | Acceptance Test Cryomodule #8 | 2012-10-22 → 2013-02-12 A (+113d) | 2012-12-07 → 2013-03-11 A (+94d) |  | 0% → 100% | 113d → none | 131302008, 131407000a → 131302008, 131406000, 131407000a | resources SR STAFF [52.86 h]; ELEC ENG [317.15 h]; ELEC TECH [158.58 h]; MECH ENG [105.72 h]; SUPPLIES & MATERIALS; SCIENTIST [52.86 h]; MECH TECH [211.43 h]; COMP SCIENT [52.86 h] → SUPPLIES & MATERIALS; SCIENTIST [52.86 h]; ELEC TECH [158.58 h]; SR STAFF [52.86 h]; ELEC ENG [317.16 h]; COMP SCIENT [52.86 h]; MECH TECH [211.43 h]; MECH ENG [105.72 h] |
| 09 | **1.3.1.4.09 CRYOMODULE ACCEPTANCE TEST #9** | 2012-12-10 → 2013-03-11 (+91d) | 2013-01-25 → 2013-04-16 (+81d) |  |  |  |  |  |
| 131409000 | Acceptance Test Cryomodule #9 | 2012-12-10 → 2013-03-11 A (+91d) | 2013-01-25 → 2013-04-16 A (+81d) | 28d → 34d | 0% → 100% | 113d → none | 131408000, 131302009a → 131302009a, 131408000 FS+9d | resources COMP SCIENT [52.86 h]; MECH ENG [105.72 h]; MECH TECH [211.43 h]; SUPPLIES & MATERIALS; SCIENTIST [52.86 h]; ELEC ENG [317.15 h]; ELEC TECH [158.58 h]; SR STAFF [52.86 h] → SR STAFF [52.86 h]; ELEC ENG [317.16 h]; ELEC TECH [158.58 h]; COMP SCIENT [52.86 h]; MECH ENG [105.72 h]; MECH TECH [211.43 h]; SUPPLIES & MATERIALS; SCIENTIST [52.86 h] |
| 10 | **1.3.1.4.10 CRYOMODULE ACCEPTANCE TEST #10** | 2013-01-28 → 2013-04-20 (+82d) | 2013-03-15 → 2013-06-18 (+95d) |  |  |  |  |  |
| 131410000 | Acceptance Test Cryomodule #10 | 2013-01-28 → 2013-04-20 A (+82d) | 2013-03-15 → 2013-06-18 A (+95d) | 34d → 35d | 0% → 100% | 113d → none | 131302010, 131409000 → 131409000 FS+1d, 131302010 | resources MECH TECH [211.43 h]; SCIENTIST [52.86 h]; SR STAFF [52.86 h]; ELEC TECH [158.58 h]; COMP SCIENT [52.86 h]; ELEC ENG [317.15 h]; MECH ENG [105.72 h]; SUPPLIES & MATERIALS → ELEC TECH [158.58 h]; COMP SCIENT [52.86 h]; MECH ENG [105.72 h]; MECH TECH [211.43 h]; SUPPLIES & MATERIALS; SCIENTIST [52.86 h]; SR STAFF [52.86 h]; ELEC ENG [317.16 h] |
| 5 | **1.3.1.5 CRYOMODULE INSTALLATION AND TEST** | 2011-05-23 → 2011-08-02 (+71d) |  |  |  |  |  |  |
| 1315000 | Re-Baseline Actuals Adjustment | 2013-08-30 A | 2013-08-30 A |  | 0% → 100% | 20d → none | 9-130M FS+227d → none |  |
| 01 | **1.3.1.5.01 CRYOMODULE #1 INSTALLATION AND TEST** | 2011-05-23 → 2011-08-02 (+71d) | 2011-09-07 → 2011-09-29 (+22d) |  |  |  |  |  |
| 131501000 | Installaton Cryomodule #1 | 2011-05-23 → 2011-08-02 A (+71d) | 2011-05-27 → 2011-08-09 A (+74d) | 5d → 6d | 0% → 100% | 60d → none |  |  |
| 131501005 | In-Tunnel Checkout and Commisioning Cryomodule #1 | 2011-08-12 → 2011-08-21 A (+9d) | 2011-09-07 → 2011-09-29 A (+22d) | 18d → 28d | 0% → 100% | 19d → none |  | resources MECH TECH [160 h]; SUPPLIES & MATERIALS; SCIENTIST [40 h]; SR STAFF [40 h]; ELEC TECH [120 h]; COMP SCIENT [40 h]; ELEC ENG [240 h]; MECH ENG [80 h] → SUPPLIES & MATERIALS; SCIENTIST [40 h]; SR STAFF [40 h]; ELEC TECH [120 h]; COMP SCIENT [40 h]; ELEC ENG [240 h]; MECH ENG [80 h]; MECH TECH [160 h] |
| 02 | **1.3.1.5.02 CRYOMODULE #2 INSTALLATION AND TEST** | 2011-07-21 → 2011-09-16 (+57d) | 2011-10-05 → 2011-09-28 (-7d) |  |  |  |  |  |
| 131502000 | Installaton Cryomodule #2 | 2011-07-21 → 2011-09-16 A (+57d) | 2011-07-27 → 2011-09-22 A (+57d) |  | 0% → 100% | 37d → none |  |  |
| 131502005 | In-Tunnel Checkout and Commisioning Cryomodule #2 | 2011-09-12 → 2011-09-23 A (+11d) | 2011-09-30 → 2011-09-28 A (-2d) | 15d → 4d | 0% → 100% | 12d → none |  | was named In-Tunnel Checkout and Commisioning Cryomodule #2 FY11; resources ELEC TECH [100 h]; COMP SCIENT [33.33 h]; MECH ENG [66.67 h]; SUPPLIES & MATERIALS; MECH TECH [133.33 h]; SR STAFF [33.33 h]; SCIENTIST [33.33 h]; ELEC ENG [200 h] → MECH ENG [66.67 h]; SUPPLIES & MATERIALS; MECH TECH [133.33 h]; SR STAFF [33.33 h]; SCIENTIST [33.33 h]; ELEC ENG [200 h]; ELEC TECH [100 h]; COMP SCIENT [33.33 h] |
| 131502005a | In-Tunnel Checkout and Commisioning Cryomodule #2 FY12 | 2011-10-03 → 2011-09-23 A (-10d) | 2011-10-05 → 2011-09-28 A (-7d) | 3d → 4d | 0% → 100% | 12d → none |  | resources SUPPLIES & MATERIALS; MECH TECH [26.67 h]; SR STAFF [6.67 h]; SCIENTIST [6.67 h]; ELEC ENG [40 h]; ELEC TECH [20 h]; COMP SCIENT [6.67 h]; MECH ENG [13.33 h] → MECH TECH [26.67 h]; SR STAFF [6.67 h]; SCIENTIST [6.67 h]; ELEC ENG [40 h]; ELEC TECH [20 h]; COMP SCIENT [6.67 h]; MECH ENG [13.33 h]; SUPPLIES & MATERIALS |
| 03 | **1.3.1.5.03 CRYOMODULE #3 INSTALLATION AND TEST** | 2012-12-21 → 2012-10-15 (-67d) | 2013-01-11 → 2012-12-15 (-27d) |  |  |  |  |  |
| 131503000 | Installaton Cryomodule #3 5th | 2012-12-21 → 2012-10-15 A (-67d) | 2013-01-11 → 2012-12-15 A (-27d) | 10d → 43d | 0% → 100% | 45d → none | 132121065M, 131505000, 131403000, 2-02M, 13436055, 131502005a, 132112085M → 2-02M, 13436055, 131505000, 131403000, 132121065M, 132112085M FS-35d, 131502005a |  |
| 04 | **1.3.1.5.04 CRYOMODULE #4 INSTALLATION AND TEST** | 2012-05-14 → 2012-05-21 (+7d) | 2012-07-13 → 2012-07-30 (+17d) |  |  |  |  |  |
| 131504000 | Installaton Cryomodule #4 3rd | 2012-05-14 → 2012-05-21 A (+7d) | 2012-05-25 → 2012-06-18 A (+24d) | 10d → 19d | 0% → 100% | 35d → none | 131404010 FS+30d, 131404000, 132121063M, 132112083M → 132112083M, 131404000, 132121063M, 131404010 FS+9d |  |
| 131504005 | In-Tunnel Checkout and Commisioning Cryomodule #4 3rd | 2012-06-13 → 2012-06-28 A (+15d) | 2012-07-13 → 2012-07-30 A (+17d) |  | 0% → 100% | 312d → none |  |  |
| 05 | **1.3.1.5.05 CRYOMODULE #5 INSTALLATION AND TEST** | 2012-05-29 → 2012-05-18 (-11d) | 2012-07-27 → 2012-06-29 (-28d) |  |  |  |  |  |
| 131505000 | Installaton Cryomodule #5 4th | 2012-05-29 → 2012-05-18 A (-11d) | 2012-06-08 → 2012-06-29 A (+21d) | 8d → 29d | 0% → 100% | 35d → none | 132112084M, 132113115, 131504000, 132121064M, 13436050, 131405000 → 132113115 FS-85d, 131504000 FS-10d, 132121064M, 13436050 FS-20d, 132112084M, 131405000 |  |
| 131505005 | In-Tunnel Checkout and Commisioning Cryomodule #5 4th | 2012-06-25 → 2012-06-18 A (-7d) | 2012-07-27 → 2012-06-29 A (-28d) | 25d → 10d | 0% → 100% | 35d → none |  | resources COMP SCIENT [16 h]; SUPPLIES & MATERIALS; MECH ENG [80 h]; MECH TECH [160 h]; SCIENTIST [40 h]; ELEC ENG [240 h]; ELEC TECH [120 h]; SR STAFF [40 h] → ELEC TECH [120 h]; SR STAFF [40 h]; COMP SCIENT [16 h]; SUPPLIES & MATERIALS; MECH ENG [80 h]; MECH TECH [160 h]; SCIENTIST [40 h]; ELEC ENG [240 h] |
| 06 | **1.3.1.5.06 CRYOMODULE #6 INSTALLATION AND TEST** | 2013-01-17 → 2013-03-11 (+53d) | 2013-01-30 → 2013-03-25 (+54d) |  |  |  |  |  |
| 131506000 | Installaton Cryomodule #6 | 2013-01-17 → 2013-03-11 A (+53d) | 2013-01-30 → 2013-03-25 A (+54d) | 9d → 30d | 0% → 100% | 57d → none | 132121066M, 131505005, 132112086M, 131406000, 131503000 → 132112086M FS-15d, 131503000, 131505005, 131406000, 132121066M |  |
| 07 | **1.3.1.5.07 CRYOMODULE #7 INSTALLATION AND TEST** | 2013-02-07 → 2012-10-22 (-108d) | 2013-02-21 → 2012-12-17 (-66d) |  |  |  |  |  |
| 131507000 | Installaton Cryomodule #7 | 2013-02-07 → 2012-10-22 A (-108d) | 2013-02-21 → 2012-12-17 A (-66d) | 10d → 43d | 0% → 100% | 66d → none | 132112087M, 131506000, 132121067M, 131407000a → 132121067M FS-40d, 132112087M FS-65d, 131407000a |  |
| 08 | **1.3.1.5.08 CRYOMODULE #8 INSTALLATION AND TEST** | 2013-02-27 → 2013-03-11 (+12d) | 2013-03-12 → 2013-04-15 (+34d) |  |  |  |  |  |
| 131508000 | Installaton Cryomodule #8 | 2013-02-27 → 2013-03-11 A (+12d) | 2013-03-12 → 2013-04-15 A (+34d) | 10d → 13d | 0% → 100% | 78d → none | 131408000, 132121068M, 132112088M, 131507000 → 132112088M FS-60d, 132121068M, 131507000, 131408000 FS-2d |  |
| 09 | **1.3.1.5.09 CRYOMODULE #9 INSTALLATION AND TEST** | 2013-03-18 → 2013-04-16 (+29d) | 2013-03-29 → 2013-05-10 (+42d) |  |  |  |  |  |
| 131509000 | Installaton Cryomodule #9 | 2013-03-18 → 2013-04-16 A (+29d) | 2013-03-29 → 2013-05-10 A (+42d) | 10d → 13d | 0% → 100% | 89d → none | 132112089M, 131508000, 131409000, 132121069M → 132121069M, 132112089M FS-60d, 131508000, 131409000 FS-12d |  |
| 10 | **1.3.1.5.10 CRYOMODULE #10 INSTALLATION AND TEST** | 2013-04-04 → 2013-06-03 (+60d) | 2013-04-17 → 2013-06-14 (+58d) |  |  |  |  |  |
| 131510000 | Installaton Cryomodule #10 | 2013-04-04 → 2013-06-03 A (+60d) | 2013-04-17 → 2013-06-14 A (+58d) | 10d → 12d | 0% → 100% | 100d → none | 132122030M, 131509000, 131410000, 132121070M, 132112090M → 132112090M FS-60d, 132122030M, 131509000, 132121070M, 131410000 |  |
| 1316005 | Initial studies in accelerator tunnel | 2011-06-01 A | 2011-06-30 A |  | 0% → 100% | 22d → none |  |  |
| 1316010 | Analysis and mitigation development | 2011-06-24 → 2011-07-01 A (+7d) | 2011-08-30 → 2011-08-31 A (+1d) | 47d → 43d | 0% → 100% | 22d → none |  | resources MECH TECH [290.23 h]; SCIENTIST [182.67 h]; MECH DES [267.78 h]; ELEC ENG [457 h]; ELEC TECH [292.26 h]; MECH ENG [643.86 h] → ELEC TECH [292.26 h]; MECH ENG [643.86 h]; MECH TECH [290.23 h]; SCIENTIST [182.67 h]; MECH DES [267.78 h]; ELEC ENG [457 h] |
| 1316015 | Re-Baseline Actuals Adjustment | 2013-08-30 A | 2013-08-30 A |  | 0% → 100% | 20d → none | 9-130M FS+227d → none |  |
| 7 | **1.3.1.7 TEDF INTERFACE** | 2010-08-10 → 2010-08-09 (-1d) | 2012-07-13 → 2012-11-30 (+140d) |  |  |  |  |  |
| 1317000 | TEDF Summer Down 2010 | 2010-08-10 → 2010-08-09 A (-1d) | 2010-09-09 A | 22d → 23d | 0% → 100% | 37d → none | 9-100M FS+211d, 1311122010 → 9-100M FS+211d, 1311122010 FS-35d |  |
| 1317005 | TEDF Winter Down 2010 | 2010-12-20 A | 2011-01-14 A |  | 0% → 100% | 99d → none | 1312103050 FS-2d, 1311122030, 9-110M FS+54d → 9-110M FS+54d, 1311122030, 1312103050 FS-60d |  |
| 1317010 | TEDF Summer Down 2011 | 2011-07-01 A | 2011-07-29 A |  | 0% → 100% | 98d → none | 1311122087, 9-110M FS+184d, 1312108035, 1312405000 → 9-110M FS+184d, 1312405000 FS-43d, 1311122087, 1312108030 FS-52d |  |
| 1317020 | Transition - Planning and Coordination | 2011-10-03 A | 2012-04-13 → 2012-04-16 A (+3d) | 130d → 131d | 0% → 100% | 0d → none |  |  |
| 1317015 | TEDF Winter Down 2011 | 2011-12-19 → 2011-12-03 A (-16d) | 2012-01-20 → 2012-02-01 A (+12d) | 18d → 36d | 0% → 100% | 79d → none |  |  |
| 1317025 | Transition - Cryomodule Work Center | 2012-04-02 → 2012-06-29 A (+88d) | 2012-05-25 → 2012-08-20 A (+87d) | 40d → 37d | 0% → 100% | 0d → none | 1317020 FS-10d → 1317020 FS+50d | constraint mandatory start 2012-04-02 → mandatory start 2012-06-18 |
| 1317035 | CMTF Down - TL Renovation | 2012-05-29 → 2012-06-29 A (+31d) | 2012-07-13 → 2012-11-30 A (+140d) | 33d → 108d | 0% → 100% | 0d → none | 1317025 → 1317025 FS-35d | constraint mandatory finish 2012-07-13 → none |
| 2 | **1.3.2 POWER SYSTEMS** | 2009-01-02 → 2009-01-22 (+20d) |  |  |  |  |  |  |
| 1 | **1.3.2.1 RF** |  | 2013-11-06 → 2013-12-13 (+37d) |  |  |  |  |  |
| 132111025M | Klystron Contract Awarded (KLYSTRONS) | 2009-04-21 A | 2009-04-21 A |  | 0% → 100% | -37d → none |  |  |
| 132111030 | Vend Fab Dsgn Period (Klystrons) | 2009-04-21 A | 2009-08-07 → 2009-08-18 A (+11d) | 77d → 84d | 0% → 100% | 154d → none |  | was named Vend Dsgn Period (Klystrons); resources PROCUREMENT<$50K 60 NO ESCALATION; PROCUREMENT>$50K 69 NO ESCALATION → PROCUREMENT>$50K 69 NO ESCALATION; PROCUREMENT<$50K 60 NO ESCALATION |

| ID | Task | Start | Finish | Duration | Complete | Total float | Predecessors | Other |
| --- | --- | --- | --- | --- | --- | --- | --- | --- |
| 132111035 | Klystron Dsgn Review & Approval for Production (Klystrons) | 2009-08-10 → 2009-08-11 A (+1d) | 2009-08-14 → 2009-08-18 A (+4d) | 5d → 6d | 0% → 100% | 154d → none |  |  |
| 132111040 | Vend Manufacture First article Klystron (Order and Recieve Parts) | 2009-08-17 → 2009-08-18 A (+1d) | 2009-11-20 → 2010-03-29 A (+129d) | 69d → 149d | 0% → 100% | 347d → none |  | resources PROCUREMENT<$50K 60 NO ESCALATION; PROCUREMENT>$50K 69 NO ESCALATION → PROCUREMENT>$50K 69 NO ESCALATION; PROCUREMENT<$50K 60 NO ESCALATION |
| 132111040A | Vend Manufacture First article Klystron (First Article Testing) | 2009-08-17 → 2009-08-18 A (+1d) | 2010-04-21 → 2010-08-30 A (+131d) | 167d → 257d | 0% → 100% | 206d → none | 132111035 → 132111040 FS-58d | resources PROCUREMENT<$50K 60 NO ESCALATION; PROCUREMENT>$50K 69 NO ESCALATION → PROCUREMENT>$50K 69 NO ESCALATION; PROCUREMENT<$50K 60 NO ESCALATION |
| 132111040B | Vend Manufacture First article Klystron (Delivery of FA Report) | 2009-08-17 → 2009-08-18 A (+1d) | 2010-07-06 → 2011-01-28 A (+206d) | 219d → 356d | 0% → 100% | 154d → none | 132111035 → 132111040A FS-156d | resources PROCUREMENT<$50K 60 NO ESCALATION; PROCUREMENT>$50K 69 NO ESCALATION → PROCUREMENT>$50K 69 NO ESCALATION; PROCUREMENT<$50K 60 NO ESCALATION |
| 132111042 | Vend Manufacture First article Klystron (Klystrons) LABOR/EXPS FY09 | 2009-08-17 → 2009-08-18 A (+1d) | 2009-09-30 → 2010-08-23 A (+327d) | 32d → 252d | 0% → 100% | 154d → none | 132111035 → 132111035, 132111040B FS-208d |  |
| 132111042b | Vend Manufacture First article Klystron (Klystrons) LABOR/EXPS FY10 | 2009-10-01 → 2009-09-30 A (-1d) | 2010-07-06 → 2010-10-25 A (+111d) | 187d → 266d | 0% → 100% | 154d → none | 132111042 → 132111042 FS-400d |  |
| 132111911LOE | Proj Admin (2011) ongoing (Klystrons) | 2009-10-01 A | 2010-09-30 A |  | 0% → 100% | 20d → none |  |  |
| 132111049M | Start of Klystron Production | 2010-07-14 → 2010-09-01 A (+49d) | 2010-07-14 → 2010-09-01 A (+49d) |  | 0% → 100% | 154d → none | 132111049 → 132111049 FS-30d |  |
| 132111050 | Vend Klystron Production (Klystron 1&2) | 2010-07-14 → 2010-09-01 A (+49d) | 2011-03-31 → 2011-04-11 A (+11d) | 176d → 148d | 0% → 100% | 262d → none | 2-01M, 132111049M → 132111049M FS-10d, 2-01M FS-30d |  |
| 132111050A | Vend Klystron Production (Klystrons 3-6) | 2010-07-14 → 2010-09-01 A (+49d) | 2011-04-29 → 2011-05-23 A (+24d) | 197d → 178d | 0% → 100% | 612d → none | 2-01M, 132111049M → 132111050 FS-107d, 132111049M, 2-01M FS-30d |  |
| 132111050B | Vend Klystron Production (Klystrons 7-10) | 2010-07-14 → 2010-09-01 A (+49d) | 2011-05-27 → 2011-06-30 A (+34d) | 217d → 205d | 0% → 100% | 592d → none | 2-01M, 132111049M → 132111049M, 2-01M FS-30d, 132111050A FS-124d |  |
| 132111050C | Vend Klystron Production (Klystrons 11-14) | 2010-07-14 → 2010-09-01 A (+49d) | 2011-06-30 → 2011-07-05 A (+5d) | 240d → 207d | 0% → 100% | 569d → none | 2-01M, 132111049M → 132111049M, 2-01M FS-30d, 132111050B FS-144d |  |
| 132111050D | Vend Klystron Production (Klystrons 15&16) | 2010-07-14 → 2010-09-01 A (+49d) | 2011-07-29 → 2011-07-26 A (-3d) | 260d → 222d | 0% → 100% | 549d → none | 2-01M, 132111049M → 2-01M FS-30d, 132111050C FS-163d, 132111049M |  |
| 132111050F | Vend Klystron Production (Klystrons 17-19) | 2010-07-14 → 2010-09-01 A (+49d) | 2011-07-29 → 2011-08-20 A (+22d) | 260d → 240d | 0% → 100% | 549d → none | 2-01M, 132111049M → 132111049M, 2-01M FS-30d, 132111050D FS-186d |  |
| 132111050G | Vend Klystron Production (Klystrons 20-24) | 2010-07-14 → 2010-09-01 A (+49d) | 2011-08-31 → 2011-09-14 A (+14d) | 283d → 257d | 0% → 100% | 526d → none | 2-01M, 132111049M → 132111049M, 2-01M FS-30d, 132111050F FS-207d |  |
| 132111050H | Vend Klystron Production (Klystrons 25-30) | 2010-07-14 → 2010-09-01 A (+49d) | 2011-09-30 → 2011-10-24 A (+24d) | 304d → 285d | 0% → 100% | 505d → none | 2-01M, 132111049M → 132111049M, 2-01M FS-30d, 132111050G FS-228d |  |
| 132111050J | Vend Klystron Production (Klystrons 37-42) | 2010-07-14 → 2010-09-01 A (+49d) | 2011-11-30 → 2012-01-16 A (+47d) | 345d → 336d | 0% → 100% | 154d → none | 132111049M, 2-01M → 132111049M, 2-01M FS-30d, 132111050i FS-271d |  |
| 132111050K | Vend Klystron Production (Klystrons 43-48) | 2010-07-14 → 2010-09-01 A (+49d) | 2011-12-30 → 2012-03-02 A (+63d) | 362d → 369d | 0% → 100% | 447d → none | 132111049M, 2-01M → 2-01M FS-30d, 132111049M, 132111050J FS-314d |  |
| 132111050L | Vend Klystron Production (Klystrons 49-54) | 2010-07-14 → 2010-09-01 A (+49d) | 2012-01-31 → 2012-03-17 A (+46d) | 382d → 379d | 0% → 100% | 427d → none | 2-01M, 132111049M → 132111050K FS-314d, 132111049M, 2-01M FS-30d |  |
| 132111050N | Vend Klystron Production (Klystrons 55-60) | 2010-07-14 → 2010-09-01 A (+49d) | 2012-02-29 → 2012-03-19 A (+19d) | 402d → 380d | 0% → 100% | 407d → none | 2-01M, 132111049M → 2-01M FS-30d, 132111050L FS-335d, 132111049M |  |
| 132111050P | Vend Klystron Production (Klystrons 67-72) | 2010-07-14 → 2010-09-01 A (+49d) | 2012-04-30 → 2012-05-14 A (+14d) | 445d → 419d | 0% → 100% | 364d → none | 2-01M, 132111049M → 132111049M, 132111050o FS-392d, 2-01M FS-30d |  |
| 132111050Q | Vend Klystron Production (Klystrons 73-78) | 2010-07-14 → 2010-09-01 A (+49d) | 2012-05-31 → 2012-06-11 A (+11d) | 467d → 438d | 0% → 100% | 342d → none | 2-01M, 132111049M → 132111049M, 2-01M FS-30d, 132111050P FS-392d |  |
| 132111050R | Vend Klystron Production (Klystrons 79-83) | 2010-07-14 → 2010-09-01 A (+49d) | 2012-06-29 → 2012-08-13 A (+45d) | 487d → 483d | 0% → 100% | 322d → none | 2-01M, 132111049M → 2-01M FS-30d, 132111049M |  |
| 132111050i | Vend Klystron Production (Klystrons 31-36) | 2010-07-14 → 2010-09-01 A (+49d) | 2011-10-31 → 2011-11-28 A (+28d) | 325d → 308d | 0% → 100% | 484d → none | 2-01M, 132111049M → 132111049M, 2-01M FS-30d, 132111050H FS-249d |  |
| 132111050o | Vend Klystron Production (Klystrons 61-66) | 2010-07-14 → 2010-09-01 A (+49d) | 2012-03-30 → 2012-05-14 A (+45d) | 424d → 419d | 0% → 100% | 272d → none | 132111049M, 2-01M → 2-01M FS-30d, 132111049M |  |
| 132111052 | Vend Klystron Production LABOR/EXP FY10 | 2010-07-14 → 2010-09-01 A (+49d) | 2010-09-30 → 2012-08-13 A (+683d) | 56d → 482.89d | 0% → 100% | 354d → none |  | resources SUPPLIES & MATERIALS; ELEC ENG [1.97 h] → ELEC ENG [1.97 h]; SUPPLIES & MATERIALS |
| 132111052a | Vend Klystron Production LABOR/EXP FY11 | 2010-10-01 → 2010-09-01 A (-30d) | 2011-09-30 → 2012-08-13 A (+318d) | 248d → 483d | 0% → 100% | 354d → none | 132111052 → 132111052 FS-419d | resources SUPPLIES & MATERIALS; ELEC ENG [8.72 h] → ELEC ENG [8.72 h]; SUPPLIES & MATERIALS |
| 132111052ab | Vend Klystron Production LABOR/EXP FY12 | 2011-10-03 → 2010-09-01 A (-397d) | 2012-05-14 → 2012-08-13 A (+91d) | 151d → 483d | 0% → 100% | 354d → none | 132111052a → 132111052a FS-160d |  |
| 132111045 | Test First article Klystron (Klystrons) | 2010-04-21 → 2010-10-01 A (+163d) | 2010-05-04 → 2011-02-21 A (+293d) | 10d → 92d | 0% → 100% | 197d → none | 132111040 FS-53d, 132111040A FS-53d, 132111042b FS-53d, 132111040B FS-53d → 132111040B FS-53d, 132111040 FS-85d, 132111042b FS-32d, 132111040A FS-85d | resources TRAVEL; SUPPLIES & MATERIALS; ELEC TECH [40 h]; ELEC DES [80 h]; ELEC ENG [40 h] → ELEC DES [80 h]; ELEC ENG [40 h]; TRAVEL; SUPPLIES & MATERIALS; ELEC TECH [40 h] |
| 132111912LOE | Proj Admin (2012) ongoing (Klystrons) | 2010-10-01 A | 2011-09-30 A |  | 0% → 100% | 20d → none |  |  |
| 132111049 | Grant Approval for Klystron Production, (Klystrons) | 2010-07-07 → 2010-11-15 A (+131d) | 2010-07-13 → 2011-02-21 A (+223d) | 5d → 61d | 0% → 100% | 154d → none | 132111040A, 132111042b, 9-100M FS+60d, 132111045, 132111040B → 9-100M FS+60d, 132111040A FS-5d, 132111040B FS-29d, 132111042b FS-5d, 132111045 FS-15d |  |
| 132111060 | Release Prcrmnt Package, Driver Amplifer (Klystrons) | 2010-12-07 → 2010-12-13 A (+6d) | 2010-12-13 → 2011-02-28 A (+77d) | 5d → 48d | 0% → 100% | 293d → none | 9-110M FS+45d, 132111049 → 9-110M FS+40d, 132111049 FS-20d |  |
| 132111068 | Bid Driver Amplifer Prcrmnt (Klystrons) | 2011-02-03 → 2011-01-31 A (-3d) | 2011-02-16 → 2011-02-21 A (+5d) | 10d → 15d | 0% → 100% | 293d → none |  |  |
| 132111065 | Receive & Evaluate Driver Amplifer Proposals (Klystrons) | 2010-12-14 → 2011-02-07 A (+55d) | 2011-02-02 → 2011-02-28 A (+26d) | 30d → 15d | 0% → 100% | 293d → none | 132111060 → 132111060 FS+4d |  |
| 132111075 | Dsgn Review for Driver Amplifer (Klystrons) | 2011-03-04 → 2011-02-14 A (-18d) | 2011-04-14 → 2011-02-28 A (-45d) | 30d → 10d | 0% → 100% | 293d → none | 132111070 → 132111070 FS-20d |  |
| 132111069M | Award Driver Amplifer Prcrmnt (KLYSTRONS) | 2011-02-17 → 2011-02-21 A (+4d) | 2011-02-17 → 2011-02-21 A (+4d) |  | 0% → 100% | 293d → none | 9-110M, 132111068 → 132111068 FS+2d, 9-110M |  |
| 132111070 | Vend Fab Driver Amplifer 1st Article (Klystrons) | 2011-02-17 → 2011-02-28 A (+11d) | 2011-03-03 → 2011-03-28 A (+25d) | 10d → 21d | 0% → 100% | 293d → none |  |  |
| 132111080 | Vendor Fab Lot 1 Driver Amplifers (Klystrons) Labor FY11 | 2011-04-15 → 2011-03-01 A (-45d) | 2011-09-30 → 2011-08-15 A (-46d) |  | 0% → 100% | 293d → none | 132111075 → 132111075 FS-20d | resources ELEC TECH [36.31 h]; ELEC ENG [7.26 h] → ELEC ENG [7.26 h]; ELEC TECH [36.31 h] |
| 132111080a | Vendor Fab Lot 1 Driver Amplifers (Klystrons) Labor FY12 | 2011-10-03 → 2011-03-01 A (-216d) | 2011-10-18 → 2011-08-15 A (-64d) | 12d → 118d | 0% → 100% | 293d → none |  |  |
| 132111080b | Vendor Fab Lot 1 Driver Amplifers (Klystrons) Procurement | 2011-04-15 → 2011-03-01 A (-45d) | 2011-10-18 → 2011-08-15 A (-64d) | 130d → 118d | 0% → 100% | 293d → none |  |  |
| 132111115 | Vendor Fab Lot 2 of Driver Amplifers (Klystrons) | 2011-10-19 → 2011-06-30 A (-111d) | 2012-08-09 → 2011-08-15 A (-360d) | 200d → 32d | 0% → 100% | 293d → none | 132111080b, 132111080a, 9-120M → 132111080 FS-30d, 132111080b, 132111080a FS-30d |  |
| 132111055 | Receive & Test Production Klystrons FY11 | 2011-04-01 → 2011-08-01 A (+122d) | 2011-09-30 → 2012-09-14 A (+350d) | 128d → 280.85d | 0% → 100% | 262d → none |  |  |
| 132111055a | Receive & Test Production Klystrons FY12 | 2011-10-03 → 2011-08-01 A (-63d) | 2012-09-24 → 2012-09-14 A (-10d) | 243d → 280.85d | 0% → 100% | 262d → none | 132111055 → 132111055 FS-245d |  |
| 132111115M | Driver amplfier Prcrmnt Comp (KLYSTRONS) | 2012-08-09 → 2011-08-15 A (-360d) | 2012-08-09 → 2011-08-15 A (-360d) |  | 0% → 100% | 293d → none |  |  |
| 132111913LOE | Proj Admin (2013) ongoing (Klystrons) | 2011-10-03 A | 2012-09-28 A |  | 0% → 100% | 20d → none |  |  |
| 132111057M | Production Klystrons Received and Tested | 2012-09-24 → 2012-09-14 A (-10d) | 2012-09-24 → 2012-09-14 A (-10d) |  | 0% → 100% | 262d → none | 132111050, 132111050Q, 132111052ab, 132111050o, 132111055a, 132111050L, 132111050D, 132111050F, 132111050G, 132111050N, 132111050A, 132111050C, 132111050i, 132111050K, 132111050P, 132111050R, 132111050H, 132111050B, 132111050J → 132111050o, 132111050J, 132111052ab, 132111050N, 132111050R, 132111055a, 132111050Q |  |
| 132111914LOE | Proj Admin (2014) ongoing (Klystrons) | 2012-10-01 A | 2013-08-30 A | 228d → 248d | 0% → 100% | 20d → none |  | was named Proj Admin (2014) ongoing (Klystrons) *** Re-Baseline Split |
| 132111950 | Re-Baseline Actuals Adjustment | 2013-08-30 A | 2013-08-30 A |  | 0% → 100% | 20d → none | 9-130M FS+227d → none |  |
| 232111914LOE | Proj Admin ongoing (Klystrons) | 2013-09-03 A | 2013-09-30 A |  | 0% → 100% | 58d → none |  |  |
| 2 | **1.3.2.1.1.2 DC POWER** | 2009-06-18 → 2009-05-22 (-27d) |  |  |  |  |  |  |
| 132112081M | First Zone Installed/Tested (DC Power) | 2011-08-04 → 2011-07-23 A (-12d) | 2011-08-04 → 2011-07-23 A (-12d) |  | 0% → 100% | 19d → none | 4A-03M, 1321122100 → 1321122100, 132121061M FS+5d, 4A-03M |  |
| 132112082M | Second Zone Installed/Tested (DC Power) | 2011-09-01 → 2011-09-23 A (+22d) | 2011-09-01 → 2011-09-23 A (+22d) |  | 0% → 100% | 12d → none | 1321122105 → 132121062M FS+5d, 1321122105 |  |
| 132112083M | Third Zone Installed/Tested (DC Power) | 2011-09-30 → 2012-02-28 A (+151d) | 2011-09-30 → 2012-02-28 A (+151d) |  | 0% → 100% | 185d → none | 1321122110 → 1321122110, 132121063M FS+5d |  |
| 132112084M | Fourth Zone Installed/Tested (DC Power) | 2011-11-30 → 2012-04-16 A (+138d) | 2011-11-30 → 2012-04-16 A (+138d) |  | 0% → 100% | 154d → none | 1321122115a, 132121064M FS+25d, 132111050J, 132112083M → 132112083M, 132111050J, 132121064M FS+5d, 1321122115a |  |
| 132112085M | Fifth Zone Installed/Tested (DC Power) | 2012-12-20 → 2013-01-31 A (+42d) | 2012-12-20 → 2013-01-31 A (+42d) |  | 0% → 100% | 45d → none | 1321122120a FS+264d → 1321122120a, 1321122180, 132121065M FS+5d | was named Fifth Zones Installed/Tested (DC Power) |
| 132112086M | Sixth Zone Installed/Tested (DC Power) | 2013-01-16 → 2013-04-15 A (+89d) | 2013-01-16 → 2013-04-15 A (+89d) |  | 0% → 100% | 51d → none |  |  |
| 132112087M | Seventh Zone Installed/Tested (DC Power) | 2013-02-06 → 2013-05-24 A (+107d) | 2013-02-06 → 2013-05-24 A (+107d) |  | 0% → 100% | 61d → none | 132111050o, 1321122190, 1321122130, 132121067M FS+25d, 132112086M → 132111050o, 132121067M FS-40d, 132112086M FS-50d, 1321122130, 1321122190 |  |
| 132112088M | Eighth Zone Installed/Tested (DC Power) | 2013-02-26 → 2013-06-14 A (+108d) | 2013-02-26 → 2013-06-14 A (+108d) |  | 0% → 100% | 73d → none |  |  |
| 132112089M | Ninth Zone Installed/Tested (DC Power) | 2013-03-15 → 2013-07-29 A (+136d) | 2013-03-15 → 2013-07-29 A (+136d) |  | 0% → 100% | 84d → none |  |  |
| 132112090M | Tenth Zone Installed/Tested (DC Power) | 2013-04-03 → 2013-08-18 A (+137d) | 2013-04-03 → 2013-08-18 A (+137d) |  | 0% → 100% | 95d → none |  |  |
| 1 | **1.3.2.1.1.2.1 High Voltage Power Supply** | 2009-06-18 → 2009-05-22 (-27d) |  |  |  |  |  |  |
| 1321121000 | Bid HVPS | 2009-06-18 → 2009-05-22 A (-27d) | 2009-07-31 → 2009-07-28 A (-3d) | 31d → 46d | 0% → 100% | 81d → none |  |  |
| 1321121005 | Evaluate HVPS | 2009-08-03 → 2009-07-27 A (-7d) | 2009-09-17 → 2009-12-21 A (+95d) | 33d → 102d | 0% → 100% | 81d → none |  |  |
| 1321121010 | Award HVPS Lot 1 (3) | 2009-10-01 → 2009-12-21 A (+81d) | 2009-10-07 → 2010-01-22 A (+107d) | 5d → 18d | 0% → 100% | 72d → none |  |  |
| 1321121015 | Fabricate HVPS Lot 1 (3) Original Expenses | 2009-10-08 → 2010-01-04 A (+88d) | 2010-09-30 → 2010-07-29 A (-63d) | 243d → 145d | 0% → 100% | 77d → none |  |  |
| 1321121020 | Vend Fab HVPS Peg Point #1 Design Review | 2010-01-04 A | 2010-03-31 → 2010-04-29 A (+29d) | 61d → 82d | 0% → 100% | 12d → none |  |  |
| 1321121025 | Vend Fab HVPS Peg Point #2 Special Non Stock parts for 10 Systems | 2010-01-04 A | 2010-07-30 → 2011-04-25 A (+269d) | 146d → 326d | 0% → 100% | 12d → none |  |  |
| 1321121030 | Vend Fab HVPS Peg Point #3 Test 1st Article | 2010-01-04 A | 2010-11-30 → 2011-02-07 A (+69d) | 230d → 272d | 0% → 100% | 12d → none |  |  |
| 1321121035 | Vend Fab HVPS Peg Point #4 Ship and Accept 1st Article | 2010-01-04 A | 2010-12-30 → 2011-03-25 A (+85d) | 247d → 305d | 0% → 100% | 12d → none |  |  |
| 1321121040 | Vend Fab HVPS Peg Point #5 Ship and Accept unit #2 | 2010-01-04 A | 2011-02-28 → 2011-03-25 A (+25d) | 286d → 305d | 0% → 100% | 12d → none |  |  |

| ID | Task | Start | Finish | Duration | Complete | Total float | Predecessors | Other |
| --- | --- | --- | --- | --- | --- | --- | --- | --- |
| 1321121045 | Vend Fab HVPS Peg Point #6 Ship and Accept unit #3 | 2010-01-04 A | 2011-03-31 → 2011-05-03 A (+33d) | 309d → 332d | 0% → 100% | 45d → none |  |  |
| 1321121050 | Vend Fab HVPS Peg Point #7 Ship and Accept unit #4 | 2010-01-04 A | 2011-04-29 → 2011-05-29 A (+30d) | 330d → 350d | 0% → 100% | 45d → none |  |  |
| 1321121055 | Vend Fab HVPS Peg Point #8 Ship and Accept unit #5 | 2010-01-04 A | 2011-05-31 → 2011-07-12 A (+42d) | 351d → 380d | 0% → 100% | 45d → none |  |  |
| 1321121060 | Vend Fab HVPS Peg Point #9 Ship and Accept unit #6 | 2010-01-04 A | 2011-09-30 → 2011-08-26 A (-35d) | 437d → 412d | 0% → 100% | 270d → none |  |  |
| 1321121065 | Vend Fab HVPS Peg Point #10 Ship and Accept unit #7 | 2010-01-04 A | 2011-10-31 → 2011-10-05 A (-26d) | 458d → 440d | 0% → 100% | 294d → none | 1321121060 FS-437d → 1321121060 FS-373d |  |
| 1321121070 | Vend Fab HVPS Peg Point #11 Ship and Accept unit #8 | 2010-01-04 A | 2011-11-30 → 2011-11-07 A (-23d) | 478d → 463d | 0% → 100% | 319d → none | 1321121065 FS-458d → 1321121065 FS-393d |  |
| 1321121075 | Vend Fab HVPS Peg Point #12 Ship and Accept unit #9 | 2010-01-04 A | 2012-01-31 → 2011-12-19 A (-43d) | 515d → 491d | 0% → 100% | 337d → none | 1321121070 FS-478d → 1321121070 FS-416d |  |
| 1321121080 | Vend Fab HVPS Peg Point #13 Ship and Accept unit #10 | 2010-01-04 A | 2012-01-31 → 2012-01-16 A (-15d) | 515d → 504d | 0% → 100% | 361d → none | 1321121075 FS-515d → 1321121075 FS-437d |  |
| 1321121085 | Re-Baseline Actuals Adjustment | 2013-08-30 A | 2013-08-30 A |  | 0% → 100% | 20d → none | 9-130M FS+227d → none |  |
| 2 | **1.3.2.1.1.2.2 High Power Amplifier** | 2009-10-01 → 2009-10-15 (+14d) |  |  |  |  |  |  |
| 1321122035 | Bid HPA Components, Subassemblies | 2009-10-01 → 2009-10-15 A (+14d) | 2009-10-23 → 2010-07-26 A (+276d) | 17d → 191d | 0% → 100% | 86d → none |  | resources MECH TECH [120 h]; ELEC ENG [20 h]; ELEC TECH [80 h] → ELEC TECH [80 h]; MECH TECH [120 h]; ELEC ENG [20 h] |
| 1321122000 | Order/Receive Components: Aux PS, Cabling | 2009-10-01 → 2009-11-30 A (+60d) | 2010-02-08 → 2011-06-30 A (+507d) | 84d → 392d | 0% → 100% | 351d → none |  |  |
| 1321122045LOE | Engineering Oversight FY10 | 2010-04-01 A | 2010-09-30 A |  | 0% → 100% | 434d → none | 9-100M FS+120d, 1321122000M → 1321122000M FS-120d, 9-100M FS+120d |  |
| 1321122035M | Award HPA Components | 2009-12-09 → 2010-07-26 A (+229d) | 2009-12-09 → 2010-07-26 A (+229d) |  | 0% → 100% | 86d → none | 1321122035 FS+30d → 1321122035 |  |
| 1321122041 | Procure AC Power Materials (208 VAC) | 2010-08-02 → 2010-07-30 A (-3d) | 2010-09-27 → 2011-02-14 A (+140d) | 40d → 132d | 0% → 100% | 419d → none |  | was named Procure AC Power Materiala (208 VAC) |
| 1321122042 | Install RF Zone 208 VAC FY10 | 2010-09-28 A | 2010-09-30 → 2011-08-19 A (+323d) | 3d → 221.8d | 0% → 100% | 419d → none | 1321122041 → 1321122041 FS-40d |  |
| 1321122042a | Install RF Zone 208 VAC FY11 | 2010-10-01 → 2010-09-28 A (-3d) | 2010-11-22 → 2011-08-19 A (+270d) | 37d → 221.57d | 0% → 100% | 419d → none | 1321122042 → 1321122041 FS-40d |  |
| 1321122020 | Bid Solenoid PS (10) | 2010-01-05 → 2010-10-01 A (+269d) | 2010-01-26 → 2010-12-20 A (+328d) | 15d → 54.48d | 0% → 100% | 361d → none |  |  |
| 1321122046LOE | Engineering Oversight FY11 | 2010-10-01 A | 2011-09-30 A |  | 0% → 100% | 434d → none |  |  |
| 1321122040 | Fabricate HPA Components | 2010-01-08 → 2010-12-15 A (+341d) | 2010-04-07 → 2012-01-16 A (+649d) | 62d → 264d | 0% → 100% | 70d → none |  |  |
| 1321122020M | Award Solenoid PS | 2010-02-03 → 2011-01-19 A (+350d) | 2010-02-03 → 2011-01-19 A (+350d) |  | 0% → 100% | 361d → none | 1321122020 FS+5d → 1321122020 |  |
| 1321122025 | Fabricate, Receive & Test Solenoid PS (Original Labor) | 2010-02-03 → 2011-02-14 A (+376d) | 2010-05-26 → 2011-10-24 A (+516d) | 80d → 177d | 0% → 100% | 361d → none |  | resources ELEC ENG [20 h]; ELEC TECH [80 h] → ELEC TECH [80 h]; ELEC ENG [20 h] |
| 1321122026 | Fabricate Solenoid PS | 2010-09-07 → 2011-02-14 A (+160d) | 2011-06-30 → 2011-10-24 A (+116d) | 202d → 177d | 0% → 100% | 291d → none | 1321122025, 9-100M FS+230d → 1321122025 FS-44d, 9-100M FS+230d |  |
| 1321122050 | Fabricate HPA #1 | 2010-01-12 → 2011-03-01 A (+413d) | 2010-04-07 → 2011-07-18 A (+467d) | 60d → 98d | 0% → 100% | 70d → none | 1321122040 FS-60d → 1321122040 FS-40d |  |
| 1321122000M | Components: Aux PS, Cabling Received | 2010-02-09 → 2011-06-30 A (+506d) | 2010-02-09 → 2011-06-30 A (+506d) |  | 0% → 100% | 351d → none |  |  |
| 1321122005 | Fabricate: Aux PS, Cabling FY10 | 2010-02-09 → 2011-06-30 A (+506d) | 2010-09-30 → 2011-07-18 A (+291d) | 164d → 12d | 0% → 100% | 351d → none | 1321122000M → 1321122000M FS-23d | resources ELEC TECH [3456.34 h] → ELEC TECH [3456.4 h] |
| 1321122005a | Fabricate: Aux PS, Cabling FY11 | 2010-10-01 → 2011-06-30 A (+272d) | 2010-11-01 → 2011-07-15 A (+256d) | 22d → 11d | 0% → 100% | 351d → none | 1321122005 → 1321122000M |  |
| 1321122015 | Install: Aux PS, Cabling FY11 | 2011-01-05 → 2011-06-30 A (+176d) | 2011-09-30 → 2012-11-12 A (+409d) | 188d → 342.43d | 0% → 100% | 291d → none | 3A-03M, 1321122010a FS-60d, 9-110M FS+60d → 1321122010a FS-140d, 3A-03M, 9-110M, 1321122010 FS-140d |  |
| 1321122015a | Install: Aux PS, Cabling FY12 | 2011-10-03 → 2011-06-30 A (-95d) | 2012-06-18 → 2012-11-12 A (+147d) | 174d → 343d | 0% → 100% | 291d → none | 1321122015 → 1321122015 FS-200d |  |
| 1321122055 | Fabricate HPA #2 FY10 | 2010-09-01 → 2011-06-30 A (+302d) | 2010-09-30 → 2011-07-12 A (+285d) | 21d → 8d | 0% → 100% | 70d → none | 1321122050 FS+102d → 1321122050 FS-40d | resources MECH TECH [168 h]; ELEC DES [7 h]; ELEC TECH [28 h] → ELEC TECH [28 h]; MECH TECH [168 h]; ELEC DES [7 h] |
| 1321122055a | Fabricate HPA #2 FY11 | 2010-10-01 → 2011-06-30 A (+272d) | 2010-11-24 → 2011-07-12 A (+230d) | 39d → 8d | 0% → 100% | 70d → none | 1321122055 → 1321122055 FS-50d, 1321122050 FS-40d | resources MECH TECH [312 h]; ELEC DES [13 h]; ELEC TECH [52 h] → ELEC DES [13 h]; ELEC TECH [52 h]; MECH TECH [312 h] |
| 1321122100 | Install/Test HPA #1 | 2010-12-31 → 2011-06-30 A (+181d) | 2011-08-04 → 2011-07-09 A (-26d) | 150d → 6d | 0% → 100% | 19d → none |  | resources ELEC TECH [292 h]; SUPPLIES & MATERIALS; MECH TECH [100 h] → ELEC TECH [292 h]; MECH TECH [100 h]; SUPPLIES & MATERIALS |
| 1321122105 | Install/Test HPA #2 | 2011-03-01 → 2011-06-30 A (+121d) | 2011-09-01 → 2011-09-30 A (+29d) | 131d → 65d | 0% → 100% | 12d → none | 1321122055a, 1321121040 → 132111050F FS-100d, 1321121040, 1321122055, 1321122055a | resources ELEC TECH [292 h]; MECH TECH [100 h] → MECH TECH [100 h]; ELEC TECH [292 h] |
| 1321122010 | Test: Aux PS, Cabling FY10 | 2010-04-15 → 2011-07-11 A (+452d) | 2010-09-30 → 2011-08-30 A (+334d) | 118d → 37d | 0% → 100% | 351d → none | 1321122005a FS-140d → 1321122005a FS-30d, 1321122005 FS-30d |  |
| 1321122010a | Test: Aux PS, Cabling FY11 | 2010-10-01 → 2011-07-11 A (+283d) | 2011-01-04 → 2011-08-29 A (+237d) | 60d → 36d | 0% → 100% | 351d → none | 1321122010 → 1321122010 FS-40d, 1321122005a FS-160d, 1321122005 FS-160d | resources ELEC ENG [6.74 h]; ELEC TECH [215.73 h] → ELEC TECH [215.6 h]; ELEC ENG [6.8 h] |
| 1321122060 | Fabricate HPA #3 FY10 | 2010-09-30 → 2011-07-11 A (+284d) | 2010-09-30 → 2011-08-19 A (+323d) | 1d → 30d | 0% → 100% | 108d → none | 1321122055a FS-40d → 1321122055 FS-45d, 1321122055a FS-45d | resources ELEC DES [0.33 h]; ELEC TECH [1.33 h]; MECH TECH [8 h] → ELEC TECH [1.33 h]; MECH TECH [8 h]; ELEC DES [0.33 h] |
| 1321122060a | Fabricate HPA #3 FY11 | 2010-10-01 → 2011-07-11 A (+283d) | 2010-12-31 → 2011-08-19 A (+231d) | 59d → 30d | 0% → 100% | 108d → none | 1321122060 → 1321122055a FS-45d, 1321122055 FS-45d, 1321122060 FS-59d | resources MECH TECH [472 h]; ELEC DES [19.67 h]; ELEC TECH [78.67 h] → ELEC TECH [78.67 h]; MECH TECH [472 h]; ELEC DES [19.67 h] |
| 1321122110 | Install/Test HPA #3 | 2011-04-01 → 2011-07-11 A (+101d) | 2011-09-30 → 2012-03-19 A (+171d) | 128d → 170d | 0% → 100% | 185d → none | 1321122060a, 1321121045 → 1321122060 FS-15d, 1321122060a FS-15d, 1321121045 |  |
| 1321122030 | Install Solenoid PS FY11 | 2011-03-10 → 2011-07-18 A (+130d) | 2011-09-30 → 2013-01-24 A (+482d) | 144d → 359d | 0% → 100% | 291d → none | 1321122026 FS-80d, 1321122025, 9-110M FS+60d → 9-110M FS+60d, 1321122025 FS-40d, 1321122026 FS-80d |  |
| 1321122030a | Install Solenoid PS FY12 | 2011-10-03 → 2011-07-18 A (-77d) | 2012-06-18 → 2013-01-24 A (+220d) | 174d → 359d | 0% → 100% | 291d → none | 1321122030 → 1321122030 FS-200d |  |
| 1321122120 | Install/Test HPA #5 FY11 Frozen by CR 12-028 | 2011-06-01 → 2011-07-24 A (+53d) | 2011-09-30 → 2012-03-12 A (+164d) | 86d → 154.19d | 0% → 100% | 45d → none | 1321121055, 1321122070 → 1321121055, 1321122070 FS-225d |  |
| 1321122120a | Install/Test HPA #5 FY12 Frozen by CR 12-028 | 2011-10-03 → 2011-07-24 A (-71d) | 2011-11-29 → 2012-03-12 A (+104d) | 40d → 155d | 0% → 100% | 45d → none | 1321122120 → 1321122120 FS-225d |  |
| 1321122115 | Install/Test HPA #4 FY11 | 2011-05-02 → 2011-07-26 A (+85d) | 2011-09-30 → 2012-03-19 A (+171d) | 107d → 158.98d | 0% → 100% | 175d → none | 1321121050, 1321122065 → 1321121050 FS-20d, 1321122065 FS-20d | resources MECH TECH [84.25 h]; ELEC TECH [246.02 h] → ELEC TECH [246.02 h]; MECH TECH [84.25 h] |
| 1321122115a | Install/Test HPA #4 FY12 | 2011-10-03 → 2011-07-26 A (-69d) | 2011-10-28 → 2012-03-19 A (+143d) | 20d → 159d | 0% → 100% | 175d → none | 1321122115 → 1321122115 FS-80d |  |
| 1321122065 | Fabricate HPA #4 | 2010-10-28 → 2011-08-01 A (+277d) | 2011-02-01 → 2012-02-20 A (+384d) | 60d → 135d | 0% → 100% | 108d → none | 1321122060a FS-40d → 1321122060a FS-10d, 1321122060 FS-10d | resources MECH TECH [480 h]; ELEC TECH [80 h]; ELEC DES [20 h] → ELEC DES [20 h]; ELEC TECH [80 h]; MECH TECH [480 h] |
| 1321122070 | Fabricate HPA #5 Frozen by CR 12-028 | 2010-11-29 → 2011-08-01 A (+245d) | 2011-03-02 → 2012-03-12 A (+376d) | 60d → 150d | 0% → 100% | 108d → none | 1321122065 FS-40d → 1321122065 FS-42.5d | resources ELEC TECH [80 h]; MECH TECH [480 h]; ELEC DES [20 h] → MECH TECH [480 h]; ELEC DES [20 h]; ELEC TECH [80 h] |
| 1321122075 | Fabricate HPA #6 Frozen by CR 12-028 | 2011-01-04 → 2011-08-01 A (+209d) | 2011-03-30 → 2012-03-12 A (+348d) | 60d → 150d | 0% → 100% | 399d → none | 1321122070 FS-40d → 1321122070 FS-200d | resources ELEC DES [20 h]; ELEC TECH [80 h]; MECH TECH [480 h] → ELEC TECH [80 h]; MECH TECH [480 h]; ELEC DES [20 h] |
| 1321122080 | Fabricate HPA #7 Frozen by CR 12-028 | 2011-02-02 → 2011-09-19 A (+229d) | 2011-04-27 → 2012-03-12 A (+320d) | 60d → 116d | 0% → 100% | 424d → none | 1321122075 FS-40d → 1321122075 FS-225d |  |
| 1321122085 | Fabricate HPA #8 Frozen by CR 12-028 | 2011-03-03 → 2011-09-19 A (+200d) | 2011-05-25 → 2012-03-12 A (+292d) | 60d → 116d | 0% → 100% | 449d → none | 1321122080 FS-40d → 1321122080 FS-50d | resources ELEC DES [20 h]; ELEC TECH [80 h]; MECH TECH [480 h] → ELEC TECH [80 h]; MECH TECH [480 h]; ELEC DES [20 h] |
| 1321122090 | Fabricate HPA #9 Frozen by CR 12-028 | 2011-03-31 → 2011-09-19 A (+172d) | 2011-06-23 → 2012-03-12 A (+263d) | 60d → 116d | 0% → 100% | 490d → none | 1321122085 FS-40d → 1321122085 FS-60d | resources MECH TECH [480 h]; ELEC DES [20 h]; ELEC TECH [80 h] → ELEC DES [20 h]; ELEC TECH [80 h]; MECH TECH [480 h] |
| 1321122095 | Fabricate HPA #10 Frozen by CR 12-028 | 2011-04-28 → 2011-09-19 A (+144d) | 2011-07-22 → 2012-03-12 A (+234d) | 60d → 116d | 0% → 100% | 494d → none | 1321122090 FS-40d → 1321122090 FS-65d | resources ELEC DES [20 h]; ELEC TECH [80 h]; MECH TECH [480 h] → MECH TECH [480 h]; ELEC DES [20 h]; ELEC TECH [80 h] |
| 1321122047LOE | Engineering Oversight FY12 | 2011-10-03 A | 2011-11-14 A |  | 0% → 100% | 434d → none |  |  |
| 1321122125 | Install/Test HPA #6 Frozen by CR 12-028 | 2011-10-03 → 2012-03-01 A (+150d) | 2012-02-29 → 2012-03-12 A (+12d) | 98d → 8d | 0% → 100% | 270d → none |  |  |
| 1321122130 | Install/Test HPA #7 Frozen by CR 12-028 | 2011-11-01 → 2012-03-01 A (+121d) | 2012-02-29 → 2012-03-12 A (+12d) | 77d → 8d | 0% → 100% | 294d → none |  | resources MECH TECH [41.85 h]; ELEC TECH [122.2 h] → ELEC TECH [122.2 h]; MECH TECH [41.85 h] |
| 1321122135 | Install/Test HPA #8 Frozen by CR 12-028 | 2011-12-01 → 2012-03-01 A (+91d) | 2012-02-29 → 2012-03-12 A (+12d) | 57d → 8d | 0% → 100% | 319d → none |  | resources ELEC TECH [91.96 h]; MECH TECH [31.49 h] → MECH TECH [31.49 h]; ELEC TECH [91.96 h] |
| 1321122140 | Install/Test HPA #9 Frozen by CR 12-028 | 2012-02-01 → 2012-03-01 A (+29d) | 2012-02-29 → 2012-03-12 A (+12d) | 20d → 8d | 0% → 100% | 343d → none |  | resources MECH TECH [11.11 h]; ELEC TECH [32.44 h] → ELEC TECH [32.44 h]; MECH TECH [11.11 h] |
| 1321122145 | Install/Test HPA #10 Frozen by CR 12-028 | 2012-02-01 → 2012-03-01 A (+29d) | 2012-02-29 → 2012-03-12 A (+12d) | 20d → 8d | 0% → 100% | 367d → none |  |  |
| 1321122210 | Reverse Entry Per CR 12-028 | 2012-03-05 → 2012-03-01 A (-4d) | 2012-03-23 → 2012-03-12 A (-11d) | 15d → 8d | 0% → 100% | 132d → none |  |  |
| 1321122150 | Fabricate HPA #5 Revised per CR 12-028 | 2012-10-01 → 2012-03-12 A (-203d) | 2012-11-02 → 2012-10-22 A (-11d) | 25d → 158d | 0% → 100% | 51d → none | 1321122065 FS-40d, 132127035 FS-99d, 132127030 FS-91d, 9-130M → 132127030 FS-300d, 1321122065, 132127035 FS-300d |  |
| 1321122155 | Fabricate HPA #6 Revised per CR 12-028 | 2012-10-22 → 2012-03-12 A (-224d) | 2012-11-27 → 2012-12-17 A (+20d) | 25d → 195d | 0% → 100% | 55d → none | 1321122150 FS-10d → 1321122150 FS-150d | resources MECH TECH [240 h]; ELEC DES [10 h]; ELEC TECH [40 h] → ELEC TECH [40 h]; MECH TECH [240 h]; ELEC DES [10 h] |
| 1321122160 | Fabricate HPA #7 Revised per CR 12-028 | 2012-11-12 → 2012-10-15 A (-28d) | 2012-12-18 → 2012-12-17 A (-1d) | 25d → 45d | 0% → 100% | 64d → none | 1321122155 FS-10d → 1321122155 FS-30d |  |
| 1321122165 | Fabricate HPA #8 Revised per CR 12-028 | 2012-12-05 → 2012-11-12 A (-23d) | 2013-01-16 → 2013-02-28 A (+43d) | 25d → 40d | 0% → 100% | 74d → none | 1321122160 FS-10d → 1321122160 FS-20d |  |
| 1321122180 | Install/Test HPA #5 Revised per CR 12-028 | 2012-11-13 A | 2012-12-20 → 2013-01-31 A (+42d) | 26d → 18d | 0% → 100% | 51d → none | 1321122150 FS+6d, 1321121055 → 1321121055, 1321122150 |  |
| 1321122170 | Fabricate HPA #9 Revised per CR 12-028 | 2012-12-19 → 2012-11-19 A (-30d) | 2013-01-31 → 2013-03-11 A (+39d) | 25d → 45d | 0% → 100% | 88d → none | 1321122165 FS-15d → 1321122165 FS-30d |  |
| 1321122185 | Install/Test HPA #6 Revised per CR 12-028 | 2012-12-04 → 2012-11-19 A (-15d) | 2013-01-16 → 2013-04-15 A (+89d) | 26d → 31d | 0% → 100% | 51d → none | 1321122155, 1321122180 FS-13d, 1321121060 → 1321122155 FS-20d, 1321122180 FS-26d, 1321121060 |  |
| 1321122190 | Install/Test HPA #7 Revised per CR 12-028 | 2012-12-31 → 2012-11-21 A (-40d) | 2013-02-06 → 2013-05-24 A (+107d) | 26d → 44d | 0% → 100% | 61d → none | 1321122185 FS-12d, 1321121065, 1321122160 → 1321122185 FS-40d, 1321121065, 1321122160 FS-30d | resources ELEC TECH [292 h]; MECH TECH [100 h] → MECH TECH [100 h]; ELEC TECH [292 h] |
| 1321122195 | Install/Test HPA #8 Revised per CR 12-028 | 2013-01-18 → 2012-11-23 A (-56d) | 2013-02-26 → 2013-06-14 A (+108d) | 26d → 58d | 0% → 100% | 73d → none | 1321121070, 1321122190 FS-13d, 1321122165 → 1321122165 FS-30d, 1321121070, 1321122190 FS-40d |  |
| 1321122175 | Fabricate HPA #10 Revised per CR 12-028 | 2013-01-10 → 2012-11-26 A (-45d) | 2013-02-14 → 2013-03-18 A (+32d) | 25d → 52d | 0% → 100% | 102d → none | 1321122170 FS-15d → 1321122170 FS-45d | resources ELEC TECH [40 h]; MECH TECH [240 h]; ELEC DES [10 h] → ELEC DES [10 h]; ELEC TECH [40 h]; MECH TECH [240 h] |
| 1321122200 | Install/Test HPA #9 Revised per CR 12-028 | 2013-02-07 → 2012-11-26 A (-73d) | 2013-03-15 → 2013-07-15 A (+122d) | 26d → 71d | 0% → 100% | 84d → none | 1321122195 FS-13d, 1321122170, 1321121075 → 1321122195 FS-60d, 1321121075, 1321122170 FS-40d |  |
| 1321122205 | Install/Test HPA #10 Revised per CR 12-028 | 2013-02-27 → 2012-11-27 A (-92d) | 2013-04-03 → 2013-08-12 A (+131d) | 26d → 83d | 0% → 100% | 95d → none | 1321122200 FS-13d, 1321122175, 1321121080 → 1321121080, 1321122175 FS-60d, 1321122200 FS-85d |  |

| ID | Task | Start | Finish | Duration | Complete | Total float | Predecessors | Other |
| --- | --- | --- | --- | --- | --- | --- | --- | --- |
| 1321122215 | Re-Baseline Actuals Adjustment | 2013-08-30 A | 2013-08-30 A |  | 0% → 100% | 20d → none | 9-130M FS+227d → none |  |
| 3 | **1.3.2.1.1.3 WAVEGUIDE COMPONENTS** | 2009-08-19 → 2009-06-01 (-79d) |  |  |  |  |  |  |
| 132113010 | Release Prcrmnt: HOM Filter (WVGUIDE COMPON) | 2009-10-15 → 2009-06-01 A (-136d) | 2009-10-28 → 2009-06-29 A (-121d) | 10d → 21d | 0% → 100% | 188d → none |  |  |
| 132113030 | Receive Responses, Evaluate, Award: HOM Filters (WVGUIDE COMPON) | 2009-10-29 → 2009-06-01 A (-150d) | 2009-12-11 → 2009-06-30 A (-164d) | 30d → 22d | 0% → 100% | 188d → none |  |  |
| 132113050 | Receive First HOMs (manufacturing delay) (WVGUIDE COMPON) | 2009-12-14 → 2009-06-01 A (-196d) | 2010-03-17 → 2009-06-15 A (-275d) | 60d → 11d | 0% → 100% | 188d → none |  |  |
| 132113000 | Final Tweaking of Waveguide Layout (Klystron specific) (WVGUIDE COMPON) | 2009-08-19 → 2009-07-27 A (-23d) | 2009-10-14 → 2009-08-24 A (-51d) | 40d → 21d | 0% → 100% | 188d → none |  | was named Final Tweaking of Waveguide Layout (Klystron specific) (WVGUIDE COMPON) FY09; resources SUPPLIES & MATERIALS; ELEC ENG [80 h]; MECH DES [80 h] → ELEC ENG [80 h]; SUPPLIES & MATERIALS; MECH DES [80 h] |
| 132113005 | Release Prcrmnt: Circulators (WVGUIDE COMPON) | 2009-10-15 → 2009-07-27 A (-80d) | 2009-10-28 → 2009-08-11 A (-78d) | 10d → 12d | 0% → 100% | 237d → none |  |  |
| 132113025 | Receive Responses, Evaluate, Award: Circulators (WVGUIDE COMPON) | 2009-10-29 → 2009-09-14 A (-45d) | 2009-12-11 → 2010-01-04 A (+24d) | 30d → 73d | 0% → 100% | 237d → none |  |  |
| 132113020 | Release Prcrmnt: Special Waveguide (WVGUIDE COMPON) | 2009-10-15 A | 2009-10-28 → 2010-02-08 A (+103d) | 10d → 74d | 0% → 100% | 188d → none |  |  |
| 132113045 | Vend Fab Circulators Peg Point #1 Design Review | 2010-01-04 A | 2010-02-19 → 2010-04-26 A (+66d) | 33d → 79d | 0% → 100% | 228d → none |  |  |
| 132113045A | Vend Fab Circulators Peg Point #2 1st Article Testing | 2010-01-04 A | 2010-04-20 → 2010-10-25 A (+188d) | 75d → 206d | 0% → 100% | 228d → none |  |  |
| 132113045B | Vend Fab Circulators Peg Point #3 1st Article Delivery and Acceptance | 2010-01-04 A | 2010-05-28 → 2010-09-27 A (+122d) | 103d → 186d | 0% → 100% | 228d → none |  |  |
| 132113045C | Vend Fab Circulators Peg Point #4 Units 2-20 Delivery and Acceptance | 2010-01-04 A | 2010-06-30 → 2010-10-25 A (+117d) | 125d → 206d | 0% → 100% | 228d → none |  |  |
| 132113045D | Vend Fab Circulators Peg Point #5 Units 21-40 Delivery and Acceptance | 2010-01-04 A | 2010-07-30 → 2010-11-15 A (+108d) | 146d → 221d | 0% → 100% | 228d → none |  |  |
| 132113045F | Vend Fab Circulators Peg Point #6 Units 41-60 Delivery and Acceptance | 2010-01-04 A | 2010-08-31 → 2010-12-21 A (+112d) | 168d → 245d | 0% → 100% | 228d → none |  |  |
| 132113045G | Vend Fab Circulators Peg Point #7 Units 61-84 Delivery and Acceptance | 2010-01-04 A | 2010-09-30 → 2011-01-27 A (+119d) | 189d → 265d | 0% → 100% | 228d → none |  |  |
| 132113015 | Release Prcrmnt: Waveguide Parts (WVGUIDE COMPON) | 2009-10-15 → 2010-02-08 A (+116d) | 2009-10-28 → 2010-02-15 A (+110d) | 10d → 5d | 0% → 100% | 188d → none |  |  |
| 132113035 | Receive Responses, Evaluate, Award: Special Waveguide (WVGUIDE COMPON) | 2009-10-29 → 2010-02-08 A (+102d) | 2009-12-11 → 2010-02-15 A (+66d) | 30d → 5d | 0% → 100% | 188d → none |  |  |
| 132113040 | Receive Responses, Evaluate, Award: Waveguide Parts (WVGUIDE COMPON) | 2009-10-29 → 2010-02-08 A (+102d) | 2009-12-11 → 2010-02-15 A (+66d) | 30d → 5d | 0% → 100% | 188d → none |  |  |
| 132113065 | Receive,Test,Install Waveguide Compnts (P-#1, 4 zones) (WVGUIDE COMPON) Labor FY10 | 2010-03-18 → 2010-02-08 A (-38d) | 2010-09-30 → 2011-09-26 A (+361d) | 138d → 409d | 0% → 100% | 188d → none | 132113060, 132113050, 32-03M, 132113055 → 32-03M, 132113045, 132113050, 132113060, 132113055 |  |
| 132113065a | Receive,Test,Install Waveguide Compnts (P-#1, 4 zones) (WVGUIDE COMPON) Labor FY11 | 2010-10-01 → 2010-02-08 A (-235d) | 2010-11-29 → 2011-09-26 A (+301d) | 40d → 409d | 0% → 100% | 188d → none | 132113065 → 132113065 FS-178d | resources ELEC ENG [3.6 h]; ELEC TECH [161.8 h]; ELEC DES [44.94 h]; SUPPLIES & MATERIALS; MECH TECH [161.8 h] → SUPPLIES & MATERIALS; MECH TECH [161.8 h]; ELEC ENG [3.6 h]; ELEC TECH [161.8 h]; ELEC DES [44.94 h] |
| 132113065b | Receive,Test,Install Waveguide Compnts (P-#1, 4 zones) (WVGUIDE COMPON) Procurement | 2010-03-18 → 2010-02-08 A (-38d) | 2010-11-29 → 2011-09-26 A (+301d) | 178d → 409d | 0% → 100% | 188d → none | 132113060, 132113055, 32-03M, 132113050 → 132113055, 132113045, 132113050, 132113060, 32-03M |  |
| 132113055 | Receive First Special Waveguide (mfr delay) (WVGUIDE COMPON) | 2009-12-14 → 2010-04-01 A (+108d) | 2010-03-17 → 2010-04-01 A (+15d) | 60d → 1d | 0% → 100% | 188d → none |  |  |
| 132113060 | Receive First Waveguide Parts (mfr delay) (WVGUIDE COMPON) | 2009-12-14 → 2010-04-01 A (+108d) | 2010-03-17 → 2010-04-01 A (+15d) | 60d → 1d | 0% → 100% | 188d → none |  |  |
| 132113100 | Develop and Release Bid Package (40) HOM Filter (WVGUIDE COMPON) | 2010-05-04 → 2010-04-26 A (-8d) | 2010-06-01 → 2011-01-31 A (+244d) | 20d → 189d | 0% → 100% | 207d → none |  |  |
| 132113105 | Receive Responses, Evaluate, Award: (40) HOM Filters (WVGUIDE COMPON) | 2010-06-02 → 2011-01-31 A (+243d) | 2010-08-11 → 2011-03-25 A (+226d) | 50d → 39d | 0% → 100% | 207d → none | 132113100 → 132113100 FS+10d |  |
| 132113075 | Receive,Test,Install Waveguide Compnts (P-#2, 4 zones) (WVGUIDE COMPON) Labor FY11 | 2011-01-05 → 2011-03-01 A (+55d) | 2011-09-30 → 2013-05-13 A (+591d) | 188d → 467d | 0% → 100% | 168d → none | 132113070M, 9-110M FS+60d, 132113045G → 9-110M FS+60d, 132113070M FS-100d, 132113045G | resources ELEC DES [153.47 h]; MECH TECH [552.49 h]; SUPPLIES & MATERIALS; ELEC TECH [552.49 h] → MECH TECH [552.49 h]; ELEC TECH [552.49 h]; SUPPLIES & MATERIALS; ELEC DES [153.47 h] |
| 132113075a | Receive,Test,Install Waveguide Compnts (P-#2, 4 zones) (WVGUIDE COMPON) Labor FY12 | 2011-10-03 → 2011-03-01 A (-216d) | 2011-12-29 → 2013-05-13 A (+501d) | 57d → 467d | 0% → 100% | 168d → none | 132113075 → 132113075 FS-235d |  |
| 132113075b | Receive,Test,Install Waveguide Compnts (P-#2, 4 zones) (WVGUIDE COMPON) Procurement | 2011-01-05 → 2011-03-01 A (+55d) | 2011-12-29 → 2013-05-13 A (+501d) | 245d → 467d | 0% → 100% | 168d → none | 9-110M FS+60d, 132113045G, 132113070M → 132113045G, 9-110M FS+60d, 132113070M FS-100d | resources PROCUREMENT>$50K 69 NO ESCALATION FY12; PROCUREMENT<$50K 60 NO ESCALATION FY12 → PROCUREMENT<$50K 60 NO ESCALATION FY12; PROCUREMENT>$50K 69 NO ESCALATION FY12 |
| 132113110 | Vend Fab (40) HOMs (manufacturing delay) (WVGUIDE COMPON) | 2010-11-05 → 2011-03-01 A (+116d) | 2011-08-25 → 2013-04-15 A (+599d) | 198d → 489d | 0% → 100% | 207d → none | 132113105 FS+60d → 132113105 | resources PROCUREMENT>$50K 69; PROCUREMENT<$50K 60 → PROCUREMENT<$50K 60; PROCUREMENT>$50K 69 |
| 132113085a | Receive,Test,Install Waveguide Compnts (P-#3, 2 zones) (WVGUIDE COMPON) FY13 | 2012-10-01 → 2011-09-12 A (-385d) | 2013-02-14 → 2013-07-15 A (+151d) | 90d → 352d | 0% → 100% | 168d → none | 132113085 → 132113085 FS-120d |  |
| 132113085b | Receive,Test,Install Waveguide Compnts (P-#3, 2 zones) (WVGUIDE COMPON) Procurement | 2012-04-25 → 2011-09-12 A (-226d) | 2013-02-14 → 2013-07-15 A (+151d) | 200d → 352d | 0% → 100% | 168d → none | 132113080M → 132113080M FS-240d |  |
| 132113085 | FAB Receive,Test,Install Waveguide Compnts (P-#3, 2 zones) (WVGUIDE COMPON) | 2012-04-25 → 2011-09-12 A (-226d) | 2012-09-28 → 2013-07-15 A (+290d) | 110d → 352d | 0% → 100% | 168d → none | 132113080M → 132113080M FS-240d | was named Receive,Test,Install Waveguide Compnts (P-#3, 2 zones) (WVGUIDE COMPON) FY12; resources ELEC DES [66 h]; ELEC TECH [198 h]; MECH TECH [198 h]; SUPPLIES & MATERIALS → ELEC DES [66 h]; MECH TECH [198 h]; SUPPLIES & MATERIALS; ELEC TECH [198 h] |
| 132113070M | End P-#1 Waveguide Installtn (WVGUIDE COMPON) | 2010-11-29 → 2011-09-26 A (+301d) | 2010-11-29 → 2011-09-26 A (+301d) |  | 0% → 100% | 188d → none |  |  |
| 132113115 | Receive and Inspect: (40) HOM Filters (WVGUIDE COMPON) | 2011-02-15 → 2011-11-14 A (+272d) | 2011-09-14 → 2013-04-15 A (+579d) | 148d → 316d | 0% → 100% | 207d → none | 132113110 FS-135d → 132113110 FS-85d |  |
| 132113130 | Klystron:Modify 20 tubes for body current problems | 2012-11-05 → 2012-11-19 A (+14d) | 2012-11-21 → 2012-12-17 A (+26d) | 13d → 21d | 0% → 100% | 52d → none |  |  |
| 132113135 | Klystrons: Retune 20 tubes after Mods | 2013-03-18 → 2012-12-03 A (-105d) | 2013-07-01 → 2012-12-17 A (-196d) | 75d → 57d | 0% → 100% | 52d → none |  |  |
| 132113120 | Remove SL Circulators for Repair | 2013-01-14 → 2013-03-04 A (+49d) | 2013-04-05 → 2013-04-15 A (+10d) | 58d → 26d | 0% → 100% | 73d → none |  |  |
| 132113125 | Test and Reinstall SL Circulators | 2013-03-18 → 2013-03-11 A (-7d) | 2013-07-01 → 2013-08-30 A (+60d) | 75d → 62d | 0% → 100% | 73d → none | 132113120 FS-15d → 132113120 FS-20d |  |
| 132113080M | End P-#2 Waveguide Installtn (WVGUIDE COMPON) | 2012-04-24 → 2013-05-13 A (+384d) | 2012-04-24 → 2013-05-13 A (+384d) |  | 0% → 100% | 168d → none | 132113075a FS+80d, 132113075b FS+80d → 132113075a, 132113075b |  |
| 132113140 | Re-Baseline Actuals Adjustment | 2013-08-30 A | 2013-08-30 A |  | 0% → 100% | 20d → none | 9-130M FS+227d → none |  |
| 132113090M | Waveguide Installtn Comp (WVGUIDE COMPON) | 2013-02-14 → 2013-08-30 A (+197d) | 2013-02-14 → 2013-08-30 A (+197d) |  | 0% → 100% | 168d → none | 132113085a, 132113085b → 132113085b, 132113125, 132113085, 132113085a |  |
| 232113125 | Test and Reinstall SL Circulators | 2013-09-03 A | 2013-09-06 A |  | 0% → 100% | 71d → none |  |  |
| 2 | **1.3.2.1.2 CONTROL** | 2009-10-01 → 2009-07-24 (-69d) |  |  |  |  |  |  |
| 132121000 | RF & Digital Bd Bid & Award (FIELD Control) | 2009-10-01 A | 2010-01-04 → 2009-11-30 A (-35d) | 60d → 41d | 0% → 100% | 74d → none |  | resources TRAVEL; ELEC ENG [200 h]; ELEC DES [160 h]; OFFICE [40 h] → ELEC ENG [200 h]; ELEC DES [160 h]; OFFICE [40 h]; TRAVEL |
| 132121001 | RF & Digital Bd Vendor Fab (FIELD Control) | 2010-01-05 → 2009-11-30 A (-36d) | 2010-08-16 → 2010-09-17 A (+32d) | 156d → 199d | 0% → 100% | 74d → none | 9-100M FS+60d, 132121000 → 9-100M, 132121000 | resources PROCUREMENT<$50K 60; PROCUREMENT>$50K 69 → PROCUREMENT>$50K 69; PROCUREMENT<$50K 60 |
| 132121005 | First Article (RF and Digital) Inspection and Test (IPL 521215020M) | 2010-02-01 → 2009-12-21 A (-42d) | 2010-03-29 A | 40d → 63d | 0% → 100% | 74d → none | 132121001 FS-138d, 1212125025M → 1212125025M, 132121001 FS-200d | resources ELEC DES [80 h]; ELEC TECH [80 h]; COMP SCIENT [320 h]; OFFICE [40 h]; SUPPLIES & MATERIALS; ELEC ENG [400 h] → ELEC ENG [400 h]; ELEC DES [80 h]; ELEC TECH [80 h]; COMP SCIENT [320 h]; OFFICE [40 h]; SUPPLIES & MATERIALS |
| 132121020M | Comp First Article Board Testing (FIELD CONTROL) | 2010-03-29 A | 2010-03-29 A |  | 0% → 100% | 74d → none |  |  |
| 132121045 | First FC Chassis Tested (FIELD Control) Labor FY10 | 2010-07-28 → 2010-03-29 A (-121d) | 2010-09-30 → 2010-07-26 A (-66d) | 46d → 84d | 0% → 100% | 74d → none | 132121035M FS-32d, 132121010 FS-23d → 132121010 FS-500d, 132121035M FS-500d | resources ELEC TECH [86.59 h]; COMP SCIENT [173.18 h]; OFFICE [21.65 h]; ELEC ENG [216.47 h]; ELEC DES [86.59 h] → ELEC ENG [216.47 h]; ELEC DES [86.59 h]; ELEC TECH [86.59 h]; OFFICE [21.65 h]; COMP SCIENT [173.18 h] |
| 132121045a | First FC Chassis Tested (FIELD Control) Labor FY11 | 2010-10-01 → 2010-03-29 A (-186d) | 2010-11-24 → 2010-07-26 A (-121d) | 39d → 84d | 0% → 100% | 74d → none | 132121045 → 132121035M FS-500d, 132121010 FS-500d | resources ELEC DES [73.41 h]; ELEC TECH [73.41 h]; COMP SCIENT [146.82 h]; OFFICE [18.35 h]; ELEC ENG [183.53 h] → OFFICE [18.35 h]; COMP SCIENT [146.82 h]; ELEC ENG [183.53 h]; ELEC DES [73.41 h]; ELEC TECH [73.41 h] |
| 132121045b | First FC Chassis Tested (FIELD Control) Procurement | 2010-07-28 → 2010-03-29 A (-121d) | 2010-11-24 → 2010-07-26 A (-121d) | 85d → 84d | 0% → 100% | 74d → none | 132121035M FS-32d, 132121010 FS-23d → 132121035M FS-500d, 132121010 FS-500d |  |
| 132121010 | RF Boards Inspection and Testing | 2010-04-12 → 2010-05-03 A (+21d) | 2010-08-27 → 2011-04-29 A (+245d) | 98d → 247d | 0% → 100% | 74d → none |  |  |
| 132121025 | Digital Boards Inspection and Testing | 2010-04-12 → 2010-05-03 A (+21d) | 2010-08-27 → 2011-03-25 A (+210d) | 98d → 222d | 0% → 100% | 74d → none |  | resources ELEC TECH [240 h]; COMP SCIENT [240 h]; ELEC ENG [400 h]; ELEC DES [80 h] → ELEC DES [80 h]; COMP SCIENT [240 h]; ELEC ENG [400 h]; ELEC TECH [240 h] |
| 132121040 | FC Chassis Procure and Fabricate Labor FY10 | 2010-06-29 → 2010-05-17 A (-43d) | 2010-09-30 → 2011-03-25 A (+176d) | 66d → 211.51d | 0% → 100% | 268d → none | 132121010 FS-46d, 9-110M FS-66d → 9-110M FS-120d, 132121010 FS-85d | resources OFFICE [18.21 h]; COMP SCIENT [36.41 h]; ELEC ENG [36.41 h]; ELEC TECH [728.28 h]; ELEC DES [72.83 h] → OFFICE [18.21 h]; COMP SCIENT [36.41 h]; ELEC ENG [36.41 h]; ELEC DES [72.83 h]; ELEC TECH [728.28 h] |
| 132121040a | FC Chassis Procure and Fabricate Labor FY11 | 2010-10-01 → 2010-05-17 A (-137d) | 2011-02-01 → 2011-03-25 A (+52d) | 79d → 212d | 0% → 100% | 268d → none | 132121040 → 132121010 FS-85d, 9-110M FS-120d | resources ELEC DES [87.17 h]; OFFICE [21.79 h]; COMP SCIENT [43.59 h]; ELEC ENG [43.59 h]; ELEC TECH [871.72 h] → COMP SCIENT [43.59 h]; ELEC ENG [43.59 h]; ELEC DES [87.17 h]; OFFICE [21.79 h]; ELEC TECH [871.72 h] |
| 132121040b | FC Chassis Procure and Fabricate Procurement | 2010-06-29 → 2010-05-17 A (-43d) | 2011-02-01 → 2011-03-25 A (+52d) | 145d → 212d | 0% → 100% | 268d → none | 132121010 FS-46d, 9-110M FS-66d → 9-110M FS-120d, 132121010 FS-85d |  |
| 132121055 | FC Chassis Bench Testing (FIELD Control) Labor FY11 | 2011-01-25 → 2010-11-22 A (-64d) | 2011-09-30 → 2012-03-19 A (+171d) | 175d → 322.77d | 0% → 100% | 74d → none | 3A-02M FS-120d, 132121040b FS-200d, 132125020, 32-03M, 132121040a FS-200d → 132121040 FS-200d, 132121040b FS-200d, 3A-02M FS-120d, 132125020 FS-120d, 132121040a FS-200d, 32-03M | resources ELEC ENG [242.21 h]; COMP SCIENT [48.44 h]; ELEC DES [193.77 h]; ELEC TECH [484.43 h]; OFFICE [48.44 h] → ELEC DES [193.77 h]; ELEC TECH [484.43 h]; OFFICE [48.44 h]; ELEC ENG [242.21 h]; COMP SCIENT [48.44 h] |
| 132121055a | FC Chassis Bench Testing (FIELD Control) Labor FY12 | 2011-10-03 → 2010-11-22 A (-315d) | 2012-03-22 → 2012-03-19 A (-3d) | 114d → 323d | 0% → 100% | 74d → none | 132121055 → 132121055 FS-120d |  |
| 132121055b | FC Chassis Bench Testing (FIELD Control) Procurement | 2011-01-25 → 2010-11-22 A (-64d) | 2012-03-22 → 2012-03-19 A (-3d) | 289d → 323d | 0% → 100% | 74d → none | 3A-02M FS-120d, 32-03M, 132121040a FS-200d, 132121040b FS-200d, 132125020 → 132121040b FS-200d, 132121040 FS-200d, 132125020 FS-120d, 132121040a FS-200d, 3A-02M FS-120d, 32-03M |  |
| 132121030M | 1/2 Production Boards Tested (FIELD CONTROL) | 2010-06-29 → 2010-11-23 A (+147d) | 2010-06-29 → 2010-11-23 A (+147d) |  | 0% → 100% | 126d → none | 132121005, 132121025 FS-43d → 132121025 FS-22d, 132121005 |  |
| 132121035M | Comp Production Board Testing (FIELD CONTROL) | 2010-09-10 → 2011-04-29 A (+231d) | 2010-09-10 → 2011-04-29 A (+231d) |  | 0% → 100% | 74d → none | 132121025 FS+9d, 132121030M → 132121030M, 132121025 |  |
| 132121060 | Zone Test & Check (FIELD Control) Labor FY11 Frozen Per CR12-028 | 2011-06-08 → 2011-05-23 A (-16d) | 2011-09-30 → 2012-03-12 A (+164d) | 81d → 197.71d | 0% → 100% | 95d → none | 132121045b, 132121055a FS-195d, 132121055b FS-195d, 132121045a → 132121055b FS-205d, 132121055 FS-205d, 132121045a, 132121055a FS-205d, 132121045b, 132121045 | resources ELEC ENG [133.88 h]; SUPPLIES & MATERIALS; ELEC TECH [147.27 h]; COMP SCIENT [133.88 h]; SCIENTIST [40.17 h]; ELEC DES [133.88 h] → SUPPLIES & MATERIALS; ELEC TECH [147.27 h]; COMP SCIENT [133.88 h]; SCIENTIST [40.17 h]; ELEC DES [133.88 h]; ELEC ENG [133.88 h] |
| 132121060a | Zone Test & Check (FIELD Control) Labor FY12 Frozen Per CR12-028 | 2011-10-03 → 2011-05-23 A (-133d) | 2012-02-29 → 2012-03-12 A (+12d) | 98d → 198d | 0% → 100% | 95d → none | 132121060 → 132121060 FS-160d |  |
| 132121060b | Zone Test & Check (FIELD Control) Procurement Frozen Per CR12-028 | 2011-06-08 → 2011-05-23 A (-16d) | 2012-03-29 → 2012-03-12 A (-17d) | 200d → 198d | 0% → 100% | 74d → none | 132121055b FS-195d, 132121045a, 132121055a FS-195d, 132121045b → 132121055b FS-205d, 132121045, 132121045b, 132121055 FS-205d, 132121045a, 132121055a FS-205d |  |
| 132121061M | First Zone Installed/Tested (FIELD CONTROL) | 2011-05-02 → 2011-06-30 A (+59d) | 2011-05-02 → 2011-06-30 A (+59d) |  | 0% → 100% | 74d → none |  |  |
| 132121062M | Second Zone Installed/Tested (FIELD CONTROL) | 2011-05-27 → 2011-07-18 A (+52d) | 2011-05-27 → 2011-07-18 A (+52d) |  | 0% → 100% | 74d → none |  |  |
| 132121063M | Third Zone Installed/Tested (FIELD CONTROL) | 2011-06-27 → 2011-09-15 A (+80d) | 2011-06-27 → 2011-09-15 A (+80d) |  | 0% → 100% | 217d → none | 132121062M FS+20d → 132121062M FS+62d |  |
| 132121064M | Fourth Zone Installed/Tested (FIELD CONTROL) | 2011-07-26 → 2012-01-16 A (+174d) | 2011-07-26 → 2012-01-16 A (+174d) |  | 0% → 100% | 217d → none | 132121063M FS+20d → 132121063M |  |
| 132121060f | Reverse Entry Per CR12-028 | 2012-03-05 → 2012-03-01 A (-4d) | 2012-03-23 → 2012-03-12 A (-11d) | 15d → 8d | 0% → 100% | 132d → none |  | resources ELEC ENG [-114 h]; SUPPLIES & MATERIALS; ELEC TECH [-125 h]; COMP SCIENT [-114 h]; SCIENTIST [-33 h]; ELEC DES [-114 h] → ELEC TECH [-125 h]; COMP SCIENT [-114 h]; SCIENTIST [-33 h]; ELEC DES [-114 h]; ELEC ENG [-114 h]; SUPPLIES & MATERIALS |
| 132121050M | Comp FC Bench Testing (FIELD CONTROL) | 2012-04-02 → 2012-03-27 A (-6d) | 2012-04-02 → 2012-03-27 A (-6d) |  | 0% → 100% | 344d → none | 132121055a FS+7d, 132121055b FS+7d → 132121055b FS+7d, 132121055 FS+7d, 132121055a FS+7d |  |

| ID | Task | Start | Finish | Duration | Complete | Total float | Predecessors | Other |
| --- | --- | --- | --- | --- | --- | --- | --- | --- |
| 132121060c | Zone Test & Check (FIELD Control) Labor Revised Per CR12-028 | 2012-10-01 A | 2013-02-15 → 2013-07-15 A (+150d) |  | 0% → 100% | 67d → none |  | resources ELEC TECH [241.27 h]; COMP SCIENT [219.33 h]; SCIENTIST [65.8 h]; ELEC DES [219.33 h]; ELEC ENG [219.33 h]; SUPPLIES & MATERIALS → SCIENTIST [65.8 h]; ELEC DES [219.33 h]; ELEC ENG [219.33 h]; SUPPLIES & MATERIALS; ELEC TECH [241.27 h]; COMP SCIENT [219.33 h] |
| 132121060d | Zone Test & Check (FIELD Control) Procurement Revised Per CR12-028 | 2012-10-01 A | 2013-02-28 → 2013-07-15 A (+137d) |  | 0% → 100% | 129d → none |  |  |
| 132121065M | Fifth Zone Installed/Tested (FIELD CONTROL) | 2012-10-30 A | 2012-10-30 A |  | 0% → 100% | 67d → none | 132121060c FS-70d, 132121064M FS+20d, 132123020M → 132121060c FS-70d, 132121064M FS+17d, 132123020M |  |
| 132121066M | Sixth Zone Installed/Tested (FIELD CONTROL) | 2012-11-30 → 2013-01-28 A (+59d) | 2012-11-30 → 2013-01-28 A (+59d) |  | 0% → 100% | 67d → none |  |  |
| 132121067M | Seventh Zone Installed/Tested (FIELD CONTROL) | 2012-12-14 → 2013-01-28 A (+45d) | 2012-12-14 → 2013-01-28 A (+45d) |  | 0% → 100% | 67d → none |  |  |
| 132121068M | Eighth Zone Installed/Tested (FIELD CONTROL) | 2013-01-15 → 2013-02-20 A (+36d) | 2013-01-15 → 2013-02-20 A (+36d) |  | 0% → 100% | 101d → none |  |  |
| 132121069M | Ninth Zone Installed/Tested (FIELD CONTROL) | 2013-02-01 → 2013-03-07 A (+34d) | 2013-02-01 → 2013-03-07 A (+34d) |  | 0% → 100% | 113d → none |  |  |
| 132121070M | Tenth Zone Installed/Tested (FIELD CONTROL) | 2013-02-15 → 2013-04-15 A (+59d) | 2013-02-15 → 2013-04-15 A (+59d) |  | 0% → 100% | 127d → none |  |  |
| 132121075 | Re-Baseline Actuals Adjustment | 2013-08-30 A | 2013-08-30 A |  | 0% → 100% | 20d → none | 9-130M FS+227d → none |  |
| 2 | **1.3.2.1.2.2 RESONANCE CONTROL & INTERLOCKS (Interlocks,Tuner Controls)** | 2010-06-02 → 2009-07-24 (-313d) |  |  |  |  |  |  |
| 132122000 | Bid & Award Matrl & Parts (RESON CTRL) FY10 | 2010-09-03 → 2009-07-24 A (-406d) | 2010-09-30 → 2010-10-25 A (+25d) | 19d → 313d | 0% → 100% | 555d → none | 9-110M FS-19d, 1212122170, 1212122110M → 1212122110M, 1212122170 | resources TRAVEL; ELEC DES [76 h]; OFFICE [25.33 h]; ELEC ENG [38 h] → ELEC ENG [38 h]; TRAVEL; ELEC DES [76 h]; OFFICE [25.33 h] |
| 132122000a | Bid & Award Matrl & Parts (RESON CTRL) FY11 | 2010-10-01 → 2009-07-24 A (-434d) | 2010-11-30 → 2010-12-15 A (+15d) | 41d → 347.2d | 0% → 100% | 555d → none | 132122000 → 132122000 FS-60d | resources ELEC DES [164 h]; OFFICE [54.67 h]; ELEC ENG [82 h]; TRAVEL → TRAVEL; ELEC DES [164 h]; OFFICE [54.67 h]; ELEC ENG [82 h] |
| 132122001 | Vend Fab Matrl & Parts (RESON CTRL) | 2011-01-05 → 2009-10-26 A (-436d) | 2011-03-17 → 2010-12-15 A (-92d) | 50d → 283d | 0% → 100% | 536d → none | 132122000a, 9-110M FS+60d → 132122000a FS-1000d | resources PROCUREMENT>$50K 69; PROCUREMENT<$50K 60 → PROCUREMENT<$50K 60; PROCUREMENT>$50K 69 |
| 132122005 | Fab & Test Stepper Chassis (RESON CTRL) | 2011-03-18 → 2009-11-23 A (-480d) | 2011-08-17 → 2010-05-31 A (-443d) | 107d → 125d | 0% → 100% | 536d → none | 132122001, 9-120M FS-170d → 9-120M FS-500d, 132122001 FS-500d | resources ELEC TECH [920 h]; COMP SCIENT [80 h]; PROCUREMENT<$50K 60; ELEC ENG [200 h]; ELEC DES [240 h] → ELEC ENG [200 h]; ELEC DES [240 h]; ELEC TECH [920 h]; COMP SCIENT [80 h]; PROCUREMENT<$50K 60 |
| 132122010 | Fab & Test PZT Chassis (RESON CTRL) Phase 1 | 2010-07-01 → 2010-01-25 A (-157d) | 2010-07-01 → 2010-08-30 A (+60d) | 1d → 152.19d | 0% → 100% | 154d → none | 9-100M FS+184d → 9-120M FS-500d | resources PROCUREMENT<$50K 60; ELEC DES [96 h]; ELEC TECH [368 h]; COMP SCIENT [32 h]; ELEC ENG [96 h] → ELEC ENG [96 h]; ELEC DES [96 h]; ELEC TECH [368 h]; COMP SCIENT [32 h]; PROCUREMENT<$50K 60 |
| 132122015 | Fab & Test Heater & Interlock (RESON CTRL) Labor FY10 | 2010-06-02 → 2010-05-24 A (-9d) | 2010-09-30 → 2011-06-30 A (+273d) | 85d → 274.44d | 0% → 100% | 124d → none |  | resources ELEC DES [148.63 h]; ELEC TECH [427.32 h]; ELEC ENG [130.05 h] → ELEC ENG [130.05 h]; ELEC DES [148.63 h]; ELEC TECH [427.32 h] |
| 132122015a | Fab & Test Heater & Interlock (RESON CTRL) Labor FY11 | 2010-10-01 → 2010-05-24 A (-130d) | 2011-03-01 → 2011-06-30 A (+121d) | 98d → 274.22d | 0% → 100% | 124d → none | 132122015 → 9-100M FS+163d | resources ELEC DES [171.37 h]; ELEC TECH [492.68 h]; ELEC ENG [149.95 h] → ELEC ENG [149.95 h]; ELEC DES [171.37 h]; ELEC TECH [492.68 h] |
| 132122015b | Fab & Test Heater & Interlock (RESON CTRL) Procurement | 2010-06-02 → 2010-05-24 A (-9d) | 2011-03-01 → 2011-06-30 A (+121d) | 183d → 275d | 0% → 100% | 124d → none |  |  |
| 132122010a | Fab & Test PZT Chassis (RESON CTRL) Phase 2 Labor FY10 | 2010-07-02 → 2010-08-30 A (+59d) | 2010-09-30 → 2010-09-17 A (-13d) | 63d → 14d | 0% → 100% | 154d → none |  | resources ELEC ENG [69.25 h]; ELEC DES [69.25 h]; ELEC TECH [265.47 h]; COMP SCIENT [23.08 h] → ELEC DES [69.25 h]; ELEC TECH [265.47 h]; COMP SCIENT [23.08 h]; ELEC ENG [69.25 h] |
| 132122010b | Fab & Test PZT Chassis (RESON CTRL) Phase 2 Labor FY11 | 2010-10-01 → 2010-08-30 A (-32d) | 2011-01-14 → 2010-09-17 A (-119d) | 68d → 14d | 0% → 100% | 154d → none | 132122010a → 132122010 | resources ELEC DES [74.75 h]; ELEC TECH [286.53 h]; COMP SCIENT [24.92 h]; ELEC ENG [74.75 h] → ELEC TECH [286.53 h]; COMP SCIENT [24.92 h]; ELEC ENG [74.75 h]; ELEC DES [74.75 h] |
| 132122010c | Fab & Test PZT Chassis (RESON CTRL) Phase 2 Procurement | 2010-07-02 → 2010-08-30 A (+59d) | 2011-01-14 → 2010-09-17 A (-119d) | 131d → 14d | 0% → 100% | 154d → none |  |  |
| 132122020 | Zone Test and Check (Reson Ctrl) Labor FY11 Frozen Per CR12-028 | 2011-03-16 → 2011-05-16 A (+61d) | 2011-09-30 → 2012-03-12 A (+164d) | 140d → 203d | 0% → 100% | 376d → none | 132122015b FS+10d, 132122015a FS+10d → 132122015 FS-25d, 132122015a FS-25d, 132122015b FS-25d | resources ELEC ENG [66.93 h]; ELEC DES [89.24 h]; ELEC TECH [223.11 h]; COMP SCIENT [89.24 h]; SUPPLIES & MATERIALS → SUPPLIES & MATERIALS; ELEC TECH [223.11 h]; COMP SCIENT [89.24 h]; ELEC ENG [66.93 h]; ELEC DES [89.24 h] |
| 132122020a | Zone Test and Check (Reson Ctrl) Labor FY12 Frozen Per CR12-028 | 2011-10-03 → 2011-05-16 A (-140d) | 2012-02-29 → 2012-03-12 A (+12d) | 98d → 203d | 0% → 100% | 376d → none | 132122020 → 132122020 FS-120d |  |
| 132122020b | Zone Test and Check (Reson Ctrl) Procurement Frozen Per CR12-028 | 2011-03-16 → 2011-05-16 A (+61d) | 2012-03-19 → 2012-03-12 A (-7d) | 251d → 203d | 0% → 100% | 363d → none | 132122015a FS+10d, 132122015b FS+10d → 132122015b FS-25d, 132122015a FS-25d, 132122015 FS-25d |  |
| 132122021M | First Zone Installed/Tested (RESON CTRL) | 2011-06-03 → 2011-08-15 A (+73d) | 2011-06-03 → 2011-08-15 A (+73d) |  | 0% → 100% | 363d → none |  |  |
| 132122022M | Second Zone Installed/Tested (RESON CTRL) | 2011-06-30 → 2011-09-19 A (+81d) | 2011-06-30 → 2011-09-19 A (+81d) |  | 0% → 100% | 363d → none | 132122021M FS+20d → 132122021M FS+35d |  |
| 132122023M | Third Zone Installed/Tested (RESON CTRL) | 2011-07-29 → 2011-11-01 A (+95d) | 2011-07-29 → 2011-11-01 A (+95d) |  | 0% → 100% | 363d → none | 132122022M FS+20d → 132122022M FS+40d |  |
| 132122024M | Fourth Zone Installed/Tested (RESON CTRL) | 2011-08-26 → 2012-01-16 A (+143d) | 2011-08-26 → 2012-01-16 A (+143d) |  | 0% → 100% | 363d → none | 132122023M FS+20d → 132122023M FS+40d |  |
| 132122020f | Reverse Entry Per CR12-028 | 2012-03-05 → 2012-03-01 A (-4d) | 2012-03-23 → 2012-03-12 A (-11d) | 15d → 8d | 0% → 100% | 132d → none |  |  |
| 132122020c | Zone Test and Check (Reson Ctrl) Labor Revised Per CR12-028 | 2012-10-01 A | 2013-02-15 → 2013-07-15 A (+150d) |  | 0% → 100% | 91d → none |  | resources ELEC DES [70.76 h]; ELEC TECH [176.89 h]; COMP SCIENT [70.76 h]; SUPPLIES & MATERIALS; ELEC ENG [53.07 h] → COMP SCIENT [70.76 h]; SUPPLIES & MATERIALS; ELEC ENG [53.07 h]; ELEC DES [70.76 h]; ELEC TECH [176.89 h] |
| 132122020d | Zone Test and Check (Reson Ctrl) Procurement Revised Per CR12-028 | 2012-10-01 A | 2013-02-28 → 2013-07-15 A (+137d) |  | 0% → 100% | 133d → none |  |  |
| 132122025M | Fifth Zone Installed/Tested (RESON CTRL) | 2012-10-30 A | 2012-10-30 A |  | 0% → 100% | 91d → none |  |  |
| 132122026M | Sixth Zone Installed/Tested (RESON CTRL) | 2012-11-30 → 2013-01-28 A (+59d) | 2012-11-30 → 2013-01-28 A (+59d) |  | 0% → 100% | 142d → none |  |  |
| 132122027M | Seventh Zone Installed/Tested (RESON CTRL) | 2012-12-14 → 2013-01-28 A (+45d) | 2012-12-14 → 2013-01-28 A (+45d) |  | 0% → 100% | 142d → none |  |  |
| 132122028M | Eighth Zone Installed/Tested (RESON CTRL) | 2013-01-15 → 2013-02-20 A (+36d) | 2013-01-15 → 2013-02-20 A (+36d) |  | 0% → 100% | 142d → none |  |  |
| 132122029M | Ninth Zone Installed/Tested (RESON CTRL) | 2013-02-01 → 2013-03-07 A (+34d) | 2013-02-01 → 2013-03-07 A (+34d) |  | 0% → 100% | 142d → none |  |  |
| 132122030M | Tenth Zone Installed/Tested (RESON CTRL) | 2013-02-15 → 2013-04-19 A (+63d) | 2013-02-15 → 2013-04-19 A (+63d) |  | 0% → 100% | 133d → none |  |  |
| 132122035 | Re-Baseline Actuals Adjustment | 2013-08-30 A | 2013-08-30 A |  | 0% → 100% | 20d → none | 9-130M FS+227d → none |  |
| 3 | **1.3.2.1.2.3 PACKAGING/INTERFACE (Racks, Crates)** | 2010-05-20 → 2009-10-30 (-202d) |  |  |  |  |  |  |
| 132123000 | Bid & Award Racks & Cabling FY10 | 2010-09-01 → 2009-10-30 A (-306d) | 2010-09-30 → 2010-05-31 A (-122d) | 21d → 141d | 0% → 100% | 474d → none | 1212123170, 9-110M FS-21d → 1212123170 | resources ELEC DES [84 h]; ELEC TECH [14 h]; OFFICE [56 h]; ELEC ENG [14 h] → ELEC ENG [14 h]; ELEC DES [84 h]; ELEC TECH [14 h]; OFFICE [56 h] |
| 132123000a | Bid & Award Racks & Cabling FY11 | 2010-10-01 → 2009-10-30 A (-336d) | 2010-11-24 → 2010-05-31 A (-177d) | 39d → 141d | 0% → 100% | 474d → none | 132123000 → 1212123170 | was named Bid & Award Racks & Cabling Fy11; resources OFFICE [104 h]; ELEC ENG [26 h]; ELEC DES [156 h]; ELEC TECH [26 h] → ELEC DES [156 h]; ELEC TECH [26 h]; OFFICE [104 h]; ELEC ENG [26 h] |
| 132123001 | Vend Fab Racks & Cabling | 2011-01-05 → 2009-11-30 A (-401d) | 2011-03-31 → 2010-12-15 A (-106d) | 60d → 260d | 0% → 100% | 453d → none | 132123000a, 9-110M FS+60d → 9-110M FS-500d, 132123000 FS-200d, 132123000a FS-200d |  |
| 132123005 | Production Pwr Supply Delivered & Tested | 2010-05-20 A | 2010-09-30 → 2010-06-30 A (-92d) | 93d → 29d | 0% → 100% | 454d → none |  | resources ELEC TECH [160 h]; OFFICE [80 h]; PROCUREMENT<$50K 60; ELEC ENG [40 h]; ELEC DES [160 h] → OFFICE [80 h]; PROCUREMENT<$50K 60; ELEC ENG [40 h]; ELEC DES [160 h]; ELEC TECH [160 h] |
| 132123010 | Fab Chassis & Cable Harnesses Labor FY10 | 2010-06-30 → 2010-05-24 A (-37d) | 2010-09-30 → 2011-06-30 A (+273d) | 65d → 275d | 0% → 100% | 454d → none | 132123005 FS-65d → 132123005 FS-85d | resources SUPPLIES & MATERIALS; ELEC DES [144.44 h]; ELEC TECH [609.88 h]; OFFICE [32.1 h] → ELEC DES [144.44 h]; ELEC TECH [609.88 h]; OFFICE [32.1 h]; SUPPLIES & MATERIALS |
| 132123010a | Fab Chassis & Cable Harnesses Labor FY11 | 2010-10-01 → 2010-05-24 A (-130d) | 2011-02-28 → 2011-06-30 A (+122d) | 97d → 275d | 0% → 100% | 454d → none | 132123010 → 132123010 FS-162d | resources ELEC DES [215.56 h]; ELEC TECH [910.12 h]; OFFICE [47.9 h]; SUPPLIES & MATERIALS → SUPPLIES & MATERIALS; ELEC DES [215.56 h]; ELEC TECH [910.12 h]; OFFICE [47.9 h] |
| 132123010b | Fab Chassis & Cable Harnesses Procurement | 2010-06-30 → 2010-05-24 A (-37d) | 2011-02-28 → 2011-06-30 A (+122d) | 162d → 275d | 0% → 100% | 454d → none | 132123005 FS-65d → 132123005 FS-85d |  |
| 132123012 | Install Rack Supports & Conduit | 2010-07-02 → 2010-07-01 A (-1d) | 2010-09-27 → 2010-08-30 A (-28d) | 60d → 42d | 0% → 100% | 459d → none |  |  |
| 132123015 | Install Chassis, Racks & Cabling Labor FY11 | 2010-11-23 → 2010-11-15 A (-8d) | 2011-09-30 → 2012-03-19 A (+171d) | 211d → 327.1d | 0% → 100% | 419d → none | 132123001 FS-117d, 132123012, 132123010a FS-95d, 132123010b FS-95d, 1321122042a → 132123001 FS-117d, 132123010b FS-95d, 132123012, 132123010a FS-95d, 1321122042a FS-85d, 1321122042 FS-85d | resources ELEC ENG [836.04 h]; SKLLD TRADE [159.25 h]; SUPPLIES & MATERIALS; ELEC DES [318.49 h]; ELEC TECH [1154.53 h]; OFFICE [79.62 h] → SKLLD TRADE [159.25 h]; SUPPLIES & MATERIALS; ELEC DES [318.49 h]; ELEC TECH [1154.53 h]; OFFICE [79.62 h]; ELEC ENG [836.04 h] |
| 132123015a | Install Chassis, Racks & Cabling Labor FY12 | 2011-10-03 → 2010-11-15 A (-322d) | 2011-10-03 → 2012-03-19 A (+168d) | 1d → 328d | 0% → 100% | 419d → none | 132123015 → 132123015 FS-50d | resources OFFICE [0.38 h]; ELEC ENG [3.96 h]; SKLLD TRADE [0.75 h]; SUPPLIES & MATERIALS; ELEC DES [1.51 h]; ELEC TECH [5.47 h] → SUPPLIES & MATERIALS; ELEC ENG [3.96 h]; SKLLD TRADE [0.75 h]; ELEC DES [1.51 h]; ELEC TECH [5.47 h]; OFFICE [0.38 h] |
| 132123015b | Install Chassis, Racks & Cabling Labor Procurement | 2010-11-23 → 2010-11-15 A (-8d) | 2011-10-03 → 2012-03-19 A (+168d) | 212d → 328d | 0% → 100% | 419d → none | 132123012, 1321122042a, 132123010a FS-95d, 132123010b FS-95d, 132123001 FS-117d → 1321122042a FS-85d, 1321122042 FS-85d, 132123010a FS-95d, 132123010b FS-95d, 132123012, 132123001 FS-117d |  |
| 132123020M | 5 Racks Installed (PACKAGING) | 2011-06-03 → 2011-06-30 A (+27d) | 2011-06-03 → 2011-06-30 A (+27d) |  | 0% → 100% | 419d → none | 132123015a FS-85d, 132123015b FS-85d → 132123015 FS-85d, 132123015a FS-85d, 132123015b FS-85d |  |
| 132123025M | All Racks Installed (PACKAGING) | 2011-10-03 → 2011-09-26 A (-7d) | 2011-10-03 → 2011-09-26 A (-7d) |  | 0% → 100% | 464d → none | 132123015b, 132123015a → 132123015b FS+78d, 132123015 FS+78d, 132123015a FS+78d |  |
| 132123030 | Re-Baseline Actuals Adjustment | 2013-08-30 A | 2013-08-30 A |  | 0% → 100% | 20d → none | 9-130M FS+227d → none |  |
| 4 | **1.3.2.1.2.4 CPU & SOFTWARE** | 2010-05-03 → 2010-02-08 (-84d) |  |  |  |  |  |  |
| 132124000 | Bid & Award PC104 & Test (CPU) | 2010-05-03 → 2010-02-08 A (-84d) | 2010-07-27 → 2010-06-30 A (-27d) | 60d → 101d | 0% → 100% | 126d → none | 9-100M FS+142d → 9-100M FS+100d | resources SUPPLIES & MATERIALS; ELEC DES [80 h]; COMP SCIENT [80 h]; ELEC TECH [80 h] → ELEC DES [80 h]; COMP SCIENT [80 h]; SUPPLIES & MATERIALS; ELEC TECH [80 h] |
| 132124001 | Vend Fab PC104 & Test (CPU) | 2010-06-02 → 2010-04-26 A (-37d) | 2010-10-01 → 2010-07-26 A (-67d) | 86d → 64d | 0% → 100% | 126d → none | 9-100M FS+60d, 132124000 FS-39d → 9-100M FS+60d, 132124000 FS-60d | resources PROCUREMENT<$50K 60 NO ESCALATION FY11; PROCUREMENT>$50K 69 NO ESCALATION FY11 → PROCUREMENT>$50K 69 NO ESCALATION FY11; PROCUREMENT<$50K 60 NO ESCALATION FY11 |
| 132124005 | EPICS Interface (CPU) | 2010-10-04 → 2010-08-16 A (-49d) | 2011-01-10 → 2012-03-29 A (+444d) | 63d → 400d | 0% → 100% | 283d → none |  | resources PROCUREMENT<$50K 60; ELEC DES [80 h]; COMP SCIENT [80 h]; SUPPLIES & MATERIALS → SUPPLIES & MATERIALS; ELEC DES [80 h]; PROCUREMENT<$50K 60; COMP SCIENT [80 h] |
| 132124010 | Test Software (CPU) | 2010-11-01 → 2010-09-01 A (-61d) | 2011-02-25 → 2011-04-29 A (+63d) | 75d → 162d | 0% → 100% | 126d → none |  | resources ELEC DES [80 h]; COMP SCIENT [80 h] → COMP SCIENT [80 h]; ELEC DES [80 h] |
| 132124015 | Re-Baseline Actuals Adjustment | 2013-08-30 A | 2013-08-30 A |  | 0% → 100% | 20d → none | 9-130M FS+227d → none |  |
| 5 | **1.3.2.1.2.5 TEST STAND** | 2009-11-04 → 2010-01-29 (+86d) |  |  |  |  |  |  |
| 132125000 | Bid & Award Test Equipment (Test STAND) | 2009-11-04 → 2010-01-29 A (+86d) | 2010-02-08 → 2010-08-30 A (+203d) | 60d → 149d | 0% → 100% | 74d → none |  | resources ELEC DES [80 h]; ELEC ENG [80 h] → ELEC ENG [80 h]; ELEC DES [80 h] |
| 132125010 | Automation Software FY10 | 2010-06-28 → 2010-01-29 A (-150d) | 2010-09-30 → 2011-05-23 A (+235d) | 67d → 328d | 0% → 100% | 74d → none | 132125005 FS-65d → 132125005 FS-200d | resources ELEC ENG [49.17 h]; ELEC DES [98.35 h]; COMP SCIENT [245.87 h] → ELEC DES [98.35 h]; COMP SCIENT [245.87 h]; ELEC ENG [49.17 h] |
| 132125010a | Automation Software FY11 | 2010-10-01 → 2010-01-29 A (-245d) | 2010-12-01 → 2011-05-23 A (+173d) | 42d → 327.42d | 0% → 100% | 74d → none | 132125010 → 132125005 FS-200d | resources COMP SCIENT [154.13 h]; ELEC ENG [30.83 h]; ELEC DES [61.65 h] → ELEC ENG [30.83 h]; ELEC DES [61.65 h]; COMP SCIENT [154.13 h] |
| 132125001 | Vend Fab Test Equipment (Test STAND) | 2010-02-09 → 2010-02-15 A (+6d) | 2010-05-04 → 2010-09-14 A (+133d) | 60d → 148d | 0% → 100% | 74d → none | 9-100M FS+60d, 132125000 → 132125000 FS-41d, 9-100M |  |
| 132125005 | Assemble Test Stand (Test STAND) | 2010-07-01 → 2010-05-24 A (-38d) | 2010-09-28 → 2010-12-15 A (+78d) | 62d → 143d | 0% → 100% | 74d → none | 132125001 FS+40d → 132125001 FS-55d | resources SUPPLIES & MATERIALS; ELEC ENG [80 h]; ELEC DES [160 h]; ELEC TECH [480 h]; PROCUREMENT<$50K 60 → SUPPLIES & MATERIALS; ELEC DES [160 h]; ELEC TECH [480 h]; PROCUREMENT<$50K 60; ELEC ENG [80 h] |
| 132125015 | Program Cavity Simulator (Test STAND) FY10 | 2010-07-07 → 2010-05-24 A (-44d) | 2010-09-30 → 2011-02-21 A (+144d) | 61d → 183d | 0% → 100% | 89d → none | 132125001 FS+43d → 132125001 FS-55d |  |
| 132125015a | Program Cavity Simulator (Test STAND) FY11 | 2010-10-01 → 2010-05-24 A (-130d) | 2010-10-04 → 2011-02-21 A (+140d) | 2d → 183d | 0% → 100% | 89d → none | 132125015 → 132125001 FS-55d | resources ELEC ENG [15.24 h]; ELEC DES [7.62 h] → ELEC DES [7.62 h]; ELEC ENG [15.24 h] |
| 132125020 | Test Automation (Test STAND) | 2010-10-05 → 2010-12-15 A (+71d) | 2011-01-24 → 2011-08-30 A (+218d) | 71d → 175d | 0% → 100% | 74d → none | 132125005, 132125015a FS-15d, 132125010a FS-40d → 132125015 FS-75d, 132125015a FS-65d, 132125005, 132125010 FS-55d, 132125010a FS-40d | resources ELEC TECH [400 h]; SUPPLIES & MATERIALS; ELEC ENG [160 h]; ELEC DES [160 h]; COMP SCIENT [160 h]; PROCUREMENT<$50K 60 → SUPPLIES & MATERIALS; ELEC ENG [160 h]; ELEC DES [160 h]; ELEC TECH [400 h]; COMP SCIENT [160 h]; PROCUREMENT<$50K 60 |
| 132125025 | Re-Baseline Actuals Adjustment | 2013-08-30 A | 2013-08-30 A |  | 0% → 100% | 20d → none | 9-130M FS+227d → none |  |
| 7 | **1.3.2.1.2.7 HPA CONTROLS** | 2010-10-01 → 2009-08-24 (-403d) |  |  |  |  |  |  |

| ID | Task | Start | Finish | Duration | Complete | Total float | Predecessors | Other |
| --- | --- | --- | --- | --- | --- | --- | --- | --- |
| 132127000 | Bid & Award HPA Board (HPA CNTLS) | 2010-10-01 → 2009-08-24 A (-403d) | 2011-01-04 → 2009-10-19 A (-442d) | 60d → 40d | 0% → 100% | 22d → none | 9-110M, 1212127065M, 1212127170 → 1212127065M FS-500d, 1212127170 FS-500d, 9-110M FS-500d | resources ELEC DES [80 h]; OFFICE [40 h]; ELEC ENG [40 h] → OFFICE [40 h]; ELEC ENG [40 h]; ELEC DES [80 h] |
| 132127001 | Vend Fab HPA Board (HPA CNTLS) | 2011-01-05 → 2009-10-26 A (-436d) | 2011-04-01 → 2010-04-26 A (-340d) | 61d → 121d | 0% → 100% | 22d → none | 9-110M FS+60d, 132127000 → 132127000 FS-500d |  |
| 132127005 | First Article Test (HPA CNTLS) | 2010-12-02 → 2009-11-30 A (-367d) | 2011-02-02 → 2009-12-21 A (-408d) | 38d → 15d | 0% → 100% | 63d → none | 9-110M FS+42d → 9-110M FS-500d | resources ELEC ENG [80 h]; ELEC DES [80 h]; ELEC TECH [160 h] → ELEC DES [80 h]; ELEC TECH [160 h]; ELEC ENG [80 h] |
| 132127015 | Chassis Fab & Test (HPA CNTLS) | 2011-05-02 → 2010-01-29 A (-458d) | 2011-09-01 → 2010-11-22 A (-283d) | 87d → 208d | 0% → 100% | 22d → none | 132127005, 132127010M FS+20d → 132127005 FS-500d, 132127010M FS-500d | resources PROCUREMENT<$50K 60; SUPPLIES & MATERIALS; ELEC DES [520 h]; ELEC ENG [80 h]; ELEC TECH [800 h]; COMP SCIENT [80 h]; OFFICE [80 h] → ELEC TECH [800 h]; COMP SCIENT [80 h]; OFFICE [80 h]; PROCUREMENT<$50K 60; SUPPLIES & MATERIALS; ELEC DES [520 h]; ELEC ENG [80 h] |
| 132127010M | Final Board Delivered (HPA CNTLS) | 2011-04-01 → 2010-04-26 A (-340d) | 2011-04-01 → 2010-04-26 A (-340d) |  | 0% → 100% | 22d → none |  |  |
| 132127020M | Final Bench Test (HPA CNTLS) | 2011-02-15 → 2010-11-22 A (-85d) | 2011-02-15 → 2010-11-22 A (-85d) |  | 0% → 100% | 22d → none | 132127010M FS-40d, 132127015 FS-140d → 132127015 FS-140d, 132127010M FS-33d |  |
| 132127025 | Installtn (HPA CNTLS) Labor FY11 Frozen per CR 12-028 | 2011-02-15 → 2011-04-02 A (+46d) | 2011-09-30 → 2012-03-12 A (+164d) | 160d → 232.04d | 0% → 100% | 22d → none | 132127020M → 132127020M FS+60d | resources SUPPLIES & MATERIALS; OFFICE [25.91 h]; ELEC TECH [285.02 h]; ELEC DES [103.64 h]; ELEC ENG [51.82 h] → OFFICE [25.91 h]; ELEC ENG [51.82 h]; ELEC TECH [285.02 h]; ELEC DES [103.64 h]; SUPPLIES & MATERIALS |
| 132127025a | Installtn (HPA CNTLS) Labor FY12 Frozen per CR 12-028 | 2011-10-03 → 2011-04-02 A (-184d) | 2012-02-13 → 2012-03-12 A (+28d) | 87d → 233d | 0% → 100% | 22d → none | 132127025 → 132127025 FS-90d | resources ELEC ENG [28.18 h]; SUPPLIES & MATERIALS; OFFICE [14.09 h]; ELEC TECH [154.98 h]; ELEC DES [56.36 h] → SUPPLIES & MATERIALS; OFFICE [14.09 h]; ELEC TECH [154.98 h]; ELEC DES [56.36 h]; ELEC ENG [28.18 h] |
| 132127025b | Installtn (HPA CNTLS) Procurement Frozen per CR 12-028 | 2011-02-15 → 2011-04-02 A (+46d) | 2012-02-13 → 2012-03-12 A (+28d) | 247d → 233d | 0% → 100% | 22d → none | 132127020M → 132127020M FS+60d |  |
| 132127040 | Reverse Entry per CR12-028 | 2012-03-05 → 2012-03-01 A (-4d) | 2012-03-23 → 2012-03-12 A (-11d) | 15d → 8d | 0% → 100% | 132d → none |  |  |
| 132127030 | Installtn (HPA CNTLS) Labor Revised per CR12-028 | 2012-10-01 A | 2013-02-15 → 2013-06-17 A (+122d) |  | 0% → 100% | 51d → none |  |  |
| 132127035 | Installtn (HPA CNTLS) Procurement Revised per CR12-028 | 2012-10-01 A | 2013-02-28 → 2013-06-17 A (+109d) |  | 0% → 100% | 51d → none |  |  |
| 132127045 | Re-Baseline Actuals Adjustment | 2013-08-30 A | 2013-08-30 A |  | 0% → 100% | 20d → none | 9-130M FS+227d → none |  |
| 3 | **1.3.2.1.3 INSTALLATION & SYSTEM COMMISSIONING (Test Equipment, System Integration Labor)** |  | 2013-11-06 → 2013-12-13 (+37d) |  |  |  |  |  |
| 13213000 | BId & Award Test Equipment (Install & SYS COMMIS) | 2010-10-01 A | 2011-01-04 → 2011-03-25 A (+80d) | 60d → 116d | 0% → 100% | 73d → none | 9-110M, 132121045a FS-40d, 132121045b FS-40d → 132121045a FS-40d, 132121045b FS-40d, 132121045 FS-40d, 9-110M |  |
| 13213001 | Vend Fab Test Equipment (Install & SYS COMMIS) | 2011-01-05 → 2011-03-01 A (+55d) | 2011-03-31 → 2011-07-25 A (+116d) | 60d → 103d | 0% → 100% | 73d → none |  |  |
| 13213005 | Fab & Program RF Test Stand (Install & SYS COMMIS) | 2011-03-03 → 2011-04-04 A (+32d) | 2011-05-25 → 2011-09-14 A (+112d) | 60d → 115d | 0% → 100% | 73d → none | 13213001 FS-21d, 1212125025M → 13213001 FS-35d, 1212125025M | resources ELEC TECH [200 h]; ELEC DES [200 h]; SUPPLIES & MATERIALS; COMP SCIENT [400 h]; ELEC ENG [320 h] → SUPPLIES & MATERIALS; ELEC ENG [320 h]; ELEC DES [200 h]; ELEC TECH [200 h]; COMP SCIENT [400 h] |
| 13213010 | RF Sys Tests #1 (Install & SYS COMMIS) | 2011-07-29 → 2011-07-11 A (-18d) | 2011-08-11 A | 10d → 24d | 0% → 100% | 19d → none | 132122010b, 132127020M, 132121061M, 132112081M FS-5d, 132122010c, 13213005 FS-10d, 132122015a, 132122015b, 132124010, 131501000 FS-5d → 132121061M, 132122015a, 132122015b, 132122010a, 132122015, 132122010b, 132127020M, 131501000 FS-40d, 132122010c, 132124010, 132112081M FS-30d, 13213005 FS-40d | resources COMP SCIENT [16 h]; OFFICE [8 h]; SUPPLIES & MATERIALS; ELEC DES [56 h]; ELEC ENG [16 h]; ELEC TECH [100 h] → ELEC DES [56 h]; ELEC TECH [100 h]; COMP SCIENT [16 h]; OFFICE [8 h]; SUPPLIES & MATERIALS; ELEC ENG [16 h] |
| 13213010a | RF Sys Tests #2 (Install & SYS COMMIS) | 2011-08-26 → 2011-07-18 A (-39d) | 2011-09-09 → 2011-09-10 A (+1d) | 10d → 39d | 0% → 100% | 12d → none | 132121062M, 132112082M FS-5d, 131502000 FS-5d → 132121062M, 131502000 FS-60d, 132112082M FS-40d | resources ELEC DES [56 h]; ELEC ENG [16 h]; ELEC TECH [100 h]; COMP SCIENT [16 h]; OFFICE [8 h]; SUPPLIES & MATERIALS → COMP SCIENT [16 h]; OFFICE [8 h]; SUPPLIES & MATERIALS; ELEC DES [56 h]; ELEC ENG [16 h]; ELEC TECH [100 h] |
| 13213015 | RF Cavity Tests Cryomodule #1 (Install & SYS COMMIS) | 2011-08-12 → 2011-08-01 A (-11d) | 2011-09-07 → 2011-09-19 A (+12d) | 18d → 35d | 0% → 100% | 522d → none | 13213010, 131501005 FS-18d → 13213010, 131501005 FS-40d | resources SUPPLIES & MATERIALS; ELEC ENG [16 h]; ELEC DES [64 h]; ELEC TECH [60 h]; SCIENTIST [16 h]; OFFICE [8 h] → ELEC ENG [16 h]; ELEC DES [64 h]; ELEC TECH [60 h]; SCIENTIST [16 h]; OFFICE [8 h]; SUPPLIES & MATERIALS |
| 13213010b | RF Sys Tests #3 (Install & SYS COMMIS) | 2012-05-29 → 2011-09-26 A (-246d) | 2012-06-12 → 2012-02-13 A (-120d) | 10d → 92d | 0% → 100% | 312d → none |  | resources ELEC ENG [16 h]; ELEC TECH [100 h]; COMP SCIENT [16 h]; OFFICE [8 h]; SUPPLIES & MATERIALS; ELEC DES [56 h] → ELEC TECH [100 h]; COMP SCIENT [16 h]; OFFICE [8 h]; SUPPLIES & MATERIALS; ELEC DES [56 h]; ELEC ENG [16 h] |
| 13213015a | RF Cavity Tests Cryomodule #2 (Install & SYS COMMIS) FY11 | 2011-09-12 → 2011-10-03 A (+21d) | 2011-09-30 → 2011-10-17 A (+17d) | 15d → 11d | 0% → 100% | 502d → none |  | resources SUPPLIES & MATERIALS; ELEC ENG [13.33 h]; ELEC DES [53.33 h]; ELEC TECH [50 h]; SCIENTIST [13.33 h]; OFFICE [6.67 h] → SCIENTIST [13.33 h]; OFFICE [6.67 h]; SUPPLIES & MATERIALS; ELEC ENG [13.33 h]; ELEC DES [53.33 h]; ELEC TECH [50 h] |
| 13213015ab | RF Cavity Tests Cryomodule #2 (Install & SYS COMMIS) FY12 | 2011-10-03 A | 2011-10-05 → 2011-10-17 A (+12d) | 3d → 11d | 0% → 100% | 502d → none |  | resources ELEC DES [10.67 h]; ELEC TECH [10 h]; SCIENTIST [2.67 h]; OFFICE [1.33 h]; SUPPLIES & MATERIALS; ELEC ENG [2.67 h] → SUPPLIES & MATERIALS; ELEC ENG [2.67 h]; ELEC DES [10.67 h]; ELEC TECH [10 h]; SCIENTIST [2.67 h]; OFFICE [1.33 h] |
| 13213010c | RF Sys Tests #4 (Install & SYS COMMIS) | 2012-06-11 → 2011-11-01 A (-223d) | 2012-06-22 → 2012-05-21 A (-32d) | 10d → 135d | 0% → 100% | 35d → none | 131505000, 132121064M, 132112084M FS-5d → 132121064M FS-60d, 131505000 FS-70d, 132112084M FS-20d | resources ELEC DES [56 h]; ELEC ENG [16 h]; ELEC TECH [100 h]; COMP SCIENT [16 h]; OFFICE [8 h]; SUPPLIES & MATERIALS → ELEC TECH [100 h]; COMP SCIENT [16 h]; OFFICE [8 h]; SUPPLIES & MATERIALS; ELEC DES [56 h]; ELEC ENG [16 h] |
| 13213015c | RF Cavity Tests Cryomodule #4 (Install & SYS COMMIS) | 2012-06-25 A | 2012-07-18 → 2012-07-17 A (-1d) | 18d → 17d | 0% → 100% | 309d → none | 131504005 FS-18d, 13213010c → 131504005 FS-30d, 13213010c | resources ELEC DES [64 h]; ELEC TECH [60 h]; SCIENTIST [16 h]; OFFICE [8 h]; SUPPLIES & MATERIALS; ELEC ENG [16 h] → SCIENTIST [16 h]; OFFICE [8 h]; SUPPLIES & MATERIALS; ELEC ENG [16 h]; ELEC DES [64 h]; ELEC TECH [60 h] |
| 13213015d | RF Cavity Tests Cryomodule #5 (Install & SYS COMMIS) | 2012-07-04 → 2012-07-16 A (+12d) | 2012-07-27 → 2012-07-24 A (-3d) | 18d → 7d | 0% → 100% | 302d → none | 13213010b, 131505005 FS-18d → 131505005 FS-8d, 13213010b | resources ELEC ENG [16 h]; ELEC DES [64 h]; ELEC TECH [60 h]; SCIENTIST [16 h]; OFFICE [8 h]; SUPPLIES & MATERIALS → SCIENTIST [16 h]; OFFICE [8 h]; SUPPLIES & MATERIALS; ELEC ENG [16 h]; ELEC DES [64 h]; ELEC TECH [60 h] |
| 13213025 | Re-Baseline Actuals Adjustment | 2013-08-30 A | 2013-08-30 A |  | 0% → 100% | 20d → none | 9-130M FS+227d → none |  |
| 13213020M | Comp Cavity Tests (INSTALL & SYS COMMIS) | 2013-08-23 → 2013-08-30 A (+7d) | 2013-08-23 → 2013-08-30 A (+7d) |  | 0% → 100% | 35d → none |  |  |
| 23213020M | Comp Cavity Tests (INSTALL & SYS COMMIS) | 2013-11-06 → 2013-12-13 (+37d) | 2013-11-06 → 2013-12-13 (+37d) |  |  | 28d → 78d |  |  |
| 2 | **1.3.2.2 MAGNET POWER** | 2009-01-02 → 2009-01-22 (+20d) |  |  |  |  |  |  |
| 1 | **1.3.2.2.1 BOX SUPPLIES** | 2009-01-02 → 2009-01-22 (+20d) |  |  |  |  |  |  |
| 13221028 | Prcrmnt Prep for Box 600/500kW PS - Arc & Septa (Box SUPPLIES) | 2009-01-02 → 2009-01-22 A (+20d) | 2009-03-30 → 2009-07-28 A (+120d) | 60d → 131d | 0% → 100% | 971d → none |  | resources ELEC ENG [160 h]; ELEC DES [80 h] → ELEC DES [80 h]; ELEC ENG [160 h] |
| 13221053 | Bid/Award Box Low Power PS - Transport (Box SUPPLIES) | 2010-07-08 → 2009-07-08 A (-365d) | 2010-09-30 → 2010-02-26 A (-216d) | 60d → 157d | 0% → 100% | -129d → none | 9-110M FS-60d → 9-100M | resources ELEC DES [80 h]; ELEC ENG [160 h] → ELEC ENG [160 h]; ELEC DES [80 h] |
| 13221003 | Bid/Award Box 1000kW PS - Arc (Box SUPPLIES) | 2010-07-08 → 2009-07-28 A (-345d) | 2010-09-30 → 2010-02-26 A (-216d) | 60d → 143d | 0% → 100% | -129d → none | 9-110M FS-60d → 9-090M | was named Bid/Award Box 1000 kW PS - Arc (Box SUPPLIES); resources ELEC DES [80 h]; ELEC ENG [160 h] → ELEC ENG [160 h]; ELEC DES [80 h] |
| 13221030 | Vend Fab Box 600/500 kW PS - Original Travel Expenses | 2010-01-05 → 2010-03-01 A (+55d) | 2010-02-26 → 2010-03-01 A (+3d) | 37d → 1d | 0% → 100% | 878d → none |  |  |
| 13221035 | Monitor Contract Vend Progress- 600/500kW Box PS Original Labor | 2010-01-05 → 2010-03-01 A (+55d) | 2010-02-26 → 2010-03-01 A (+3d) | 37d → 1d | 0% → 100% | 782d → none | 9-100M FS+60d, 13221029M → 13221029M |  |
| 13221010N | Vend Fab Magnet System Box Power Supplies Peg Point #12 Delivery and Accp of Prod PS (QTY 2) (Frozen Per CR11-055) | 2010-03-18 A | 2011-08-31 → 2011-08-22 A (-9d) | 365d → 358d | 0% → 100% | 1024d → none |  |  |
| 13221010P | Vend Fab Magnet System Box Power Supplies Peg Point #13 Delivery and Accp of Spare Parts (Frozen Per CR11-055) | 2010-03-18 A | 2011-08-31 → 2011-08-22 A (-9d) | 365d → 358d | 0% → 100% | 1024d → none |  |  |
| 13221004M | Award Magnet System Box Power Supplies | 2010-10-01 → 2010-03-19 A (-196d) | 2010-10-01 → 2010-03-19 A (-196d) |  | 0% → 100% | -129d → none |  |  |
| 13221005 | Vend Fab Magnet System Box Power Supplies Oversight FY10 | 2010-03-19 A | 2010-09-30 A |  | 0% → 100% | 768d → none |  |  |
| 13221010 | Vend Fab Magnet System Box Power Supplies Peg Point #1 Preliminary Design Report | 2010-03-19 A | 2010-05-28 → 2010-05-17 A (-11d) | 51d → 41d | 0% → 100% | 542d → none |  |  |
| 13221010A | Vend Fab Magnet System Box Power Supplies Peg Point #2 Design Review and Approval | 2010-03-19 A | 2010-06-30 → 2010-07-30 A (+30d) | 73d → 94d | 0% → 100% | 542d → none |  |  |
| 13221010B | Vend Fab Magnet System Box Power Supplies Peg Point #3 First Article Testing - First Topology (Frozen Per CR11-055) | 2010-03-19 A | 2010-12-30 → 2011-08-01 A (+214d) | 195d → 342d | 0% → 100% | 542d → none |  |  |
| 13221010C | Vend Fab Magnet System Box Power Supplies Peg Point #4 First Article Testing - All Topologies (Frozen Per CR11-055) | 2010-03-19 A | 2011-02-28 → 2011-08-01 A (+154d) | 234d → 342d | 0% → 100% | 542d → none |  |  |
| 13221010D | Vend Fab Magnet System Box Power Supplies Peg Point #5 Delivery and Accp of Prod Power Supplies (Frozen Per CR11-055) | 2010-03-19 A | 2011-03-31 → 2011-08-01 A (+123d) | 257d → 342d | 0% → 100% | 542d → none |  |  |
| 13221010H | Vend Fab Magnet System Box Power Supplies Peg Point #8 Delivery and Accp of Prod Power Supplies (Frozen Per CR11-055) | 2010-03-19 A | 2011-06-30 → 2011-08-01 A (+32d) | 321d → 342d | 0% → 100% | 542d → none |  |  |
| 13221029M | Award Box 600/500 KW PS (BOX SUPPLIES) | 2010-01-05 → 2010-03-19 A (+73d) | 2010-01-05 → 2010-03-19 A (+73d) |  | 0% → 100% | 782d → none |  |  |
| 13221098 | Procure Extraction YA PS & Shunt Sub assemblies | 2010-12-07 → 2010-03-29 A (-253d) | 2011-02-24 → 2010-10-25 A (-122d) | 50d → 148d | 0% → 100% | 300d → none | 9-110M FS+45d → 9-100M | resources ELEC ENG [80 h]; PROCUREMENT<$50K 60; ELEC TECH [120 h] → PROCUREMENT<$50K 60; ELEC TECH [120 h]; ELEC ENG [80 h] |
| 13221100 | Assemble YA PS and Shunt subassemblies | 2011-02-25 → 2010-03-29 A (-333d) | 2011-07-18 → 2010-08-23 A (-329d) | 100d → 104d | 0% → 100% | 300d → none | 13221099M → 13221099M FS-400d | resources SUPPLIES & MATERIALS; ELEC DES [160 h]; ELEC TECH [480 h] → ELEC DES [160 h]; ELEC TECH [480 h]; SUPPLIES & MATERIALS |
| 13221054M | Award Box Low Power PS (BOX SUPPLIES) | 2010-10-01 → 2010-04-01 A (-183d) | 2010-10-01 → 2010-04-01 A (-183d) |  | 0% → 100% | -129d → none | 9-110M, 13221053 → 13221053 |  |
| 13221077 | Dummy Load Design Re-work / Documentation | 2010-05-04 → 2010-04-26 A (-8d) | 2010-07-01 → 2010-07-26 A (+25d) | 42d → 64d | 0% → 100% | 772d → none |  |  |
| 13221095 | Engineering Oversight - Develop/Conduct Procedures, Q.A. and Training FY10 | 2010-05-13 → 2010-04-26 A (-17d) | 2010-09-30 A | 98d → 111d | 0% → 100% | 227d → none |  | resources ELEC TECH [12.56 h]; ELEC ENG [119 h]; ELEC DES [12.56 h] → ELEC ENG [119 h]; ELEC DES [12.56 h]; ELEC TECH [12.56 h] |
| 13221099M | Award H-D & Lambertson (2) PS (BOX SUPPLIES) | 2011-02-25 → 2010-04-26 A (-305d) | 2011-02-25 → 2010-04-26 A (-305d) |  | 0% → 100% | 300d → none |  |  |
| 13221078 | Order Dummy Load Parts | 2010-07-02 → 2010-07-26 A (+24d) | 2010-08-02 → 2010-08-09 A (+7d) | 21d → 11d | 0% → 100% | 772d → none |  | resources ELEC DES [40 h]; ELEC ENG [40 h] → ELEC ENG [40 h]; ELEC DES [40 h] |
| 13221080 | Dummy Load Procurement | 2010-08-03 → 2010-09-01 A (+29d) | 2010-10-04 → 2011-01-20 A (+108d) | 44d → 92d | 0% → 100% | 772d → none |  |  |
| 13221005A | Vend Fab Magnet System Box Power Supplies Oversight FY11 | 2010-10-01 A | 2011-09-30 A |  | 0% → 100% | 768d → none |  |  |
| 13221095LOE | Engineering Oversight - Develop/Conduct Procedures, Q.A. and Training FY11 | 2010-10-01 A | 2011-09-30 A |  | 0% → 100% | 227d → none |  | resources ELEC ENG [302.2 h]; ELEC DES [31.79 h]; ELEC TECH [31.79 h] → ELEC TECH [31.79 h]; ELEC ENG [302.2 h]; ELEC DES [31.79 h] |
| 13221105 | Install and Check-out YA & Shunt hardware | 2011-02-25 → 2010-11-15 A (-102d) | 2011-04-07 → 2011-06-15 A (+69d) | 30d → 142d | 0% → 100% | 370d → none |  |  |
| 13221085 | Dummy Load - Fabricate Sub Assemblies | 2010-10-05 → 2010-11-22 A (+48d) | 2010-12-15 → 2011-04-29 A (+135d) | 50d → 105d | 0% → 100% | 772d → none | 13221080 → 13221080 FS-30d |  |
| 13221118 | Bid Compnts to Refurb 5 PS (Box SUPPLIES) | 2010-10-01 → 2011-01-04 A (+95d) | 2011-02-02 → 2012-02-21 A (+384d) | 80d → 281d | 0% → 100% | 459d → none |  | resources ELEC ENG [80 h]; ELEC DES [40 h] → ELEC DES [40 h]; ELEC ENG [80 h] |
| 13221090 | Dummy Load Assemble Unit #1 | 2010-12-16 → 2011-02-14 A (+60d) | 2011-02-28 → 2011-03-28 A (+28d) | 45d → 30d | 0% → 100% | 772d → none | 13221085 → 13221085 FS-60d | resources ELEC TECH [280 h]; ELEC ENG [40 h]; ELEC DES [40 h] → ELEC TECH [280 h]; ELEC DES [40 h]; ELEC ENG [40 h] |
| 13221092 | Dummy Load Assemble Unit #2 | 2011-03-01 → 2011-02-14 A (-15d) | 2011-05-02 → 2011-04-25 A (-7d) | 45d → 50d | 0% → 100% | 772d → none | 13221090 → 13221090 FS-30d | resources ELEC TECH [280 h]; ELEC ENG [40 h]; ELEC DES [40 h] → ELEC DES [40 h]; ELEC TECH [280 h]; ELEC ENG [40 h] |
| 13221093 | Rental for Dummy Load Water Skid FY11 | 2011-04-15 → 2011-04-01 A (-14d) | 2011-09-30 → 2011-09-13 A (-17d) | 118d → 115d | 0% → 100% | 1d → none |  | resources ELEC ENG [32.11 h]; SUPPLIES & MATERIALS → SUPPLIES & MATERIALS; ELEC ENG [32.11 h] |
| 13221093a | Rental for Dummy Load Water Skid FY12 | 2011-10-03 → 2011-04-01 A (-185d) | 2011-11-10 → 2011-09-13 A (-58d) | 29d → 115d | 0% → 100% | 1d → none |  |  |
| 13221010J | Reverse Entry Per CR 11-055 | 2011-08-01 A | 2011-08-05 A |  | 0% → 100% | 39d → none |  | resources COMP SCIENT [-16.08 h]; SUPPLIES & MATERIALS; PROCUREMENT>$50K 69 NO ESCALATION; ELEC TECH [-160.02 h]; ELEC DES [-40.19 h]; ELEC ENG [-40.19 h] → PROCUREMENT>$50K 69 NO ESCALATION; ELEC TECH [-160.02 h]; ELEC DES [-40.19 h]; ELEC ENG [-40.19 h]; COMP SCIENT [-16.08 h]; SUPPLIES & MATERIALS |
| 13221010K | Revised Schedule per CR11-055 Vend Fab Magnet Box Power Supplies 1st Article M1 Topology (T&M PS) | 2011-08-01 A | 2011-10-31 → 2011-11-22 A (+22d) | 65d → 81d | 0% → 100% | 542d → none |  |  |
| 13221010L | Revised Schedule per CR11-055 Vend Fab Magnet Box Power Supplies Delivery of LAM1C Frozen Per CR12-029 | 2011-08-01 A | 2012-01-31 → 2012-03-12 A (+41d) | 122d → 150d | 0% → 100% | 542d → none |  | was named Revised Schedule per CR11-055 Vend Fab Magnet Box Power Supplies Delivery of LAM1C |
| 13221010Na | Revised Schedule per CR11-055 Vend Fab Magnet Box Power Supplies Delivery of LAM3C Frozen Per CR12-029 | 2011-08-01 A | 2012-02-29 → 2012-03-12 A (+12d) | 142d → 150d | 0% → 100% | 542d → none |  | was named Revised Schedule per CR11-055 Vend Fab Magnet Box Power Supplies Delivery of LAM3C |
| 13221010Pa | Revised Schedule per CR11-055 Vend Fab Magnet Box Power Supplies Delivery of XSEP10 Frozen Per CR12-029 | 2011-08-01 A | 2012-03-30 → 2012-03-12 A (-18d) | 164d → 150d | 0% → 100% | 542d → none |  | was named Revised Schedule per CR11-055 Vend Fab Magnet Box Power Supplies Delivery of XSEP10 |
| 13221010Q | Revised Schedule per CR11-055 Vend Fab Magnet Box Power Supplies Delivery of XSEP8 Frozen Per CR12-029 | 2011-08-01 A | 2012-03-30 → 2012-03-12 A (-18d) | 164d → 150d | 0% → 100% | 542d → none |  | was named Revised Schedule per CR11-055 Vend Fab Magnet Box Power Supplies Delivery of XSEP8 |

| ID | Task | Start | Finish | Duration | Complete | Total float | Predecessors | Other |
| --- | --- | --- | --- | --- | --- | --- | --- | --- |
| 13221010R | Revised Schedule per CR11-055 Vend Fab Magnet Box Power Supplies Delivery of RSEP9A Frozen Per CR12-029 | 2011-08-01 A | 2012-03-30 → 2012-03-12 A (-18d) | 164d → 150d | 0% → 100% | 542d → none |  | was named Revised Schedule per CR11-055 Vend Fab Magnet Box Power Supplies Delivery of RSEP9A |
| 13221010S | Revised Schedule per CR11-055 Vend Fab Magnet Box Power Supplies Delivery of RSEP8A Frozen Per CR12-029 | 2011-08-01 A | 2012-03-30 → 2012-03-12 A (-18d) | 164d → 150d | 0% → 100% | 542d → none | 13221010R FS-164d → 13221010R FS-185d | was named Revised Schedule per CR11-055 Vend Fab Magnet Box Power Supplies Delivery of RSEP8A |
| 13221010T | Revised Schedule per CR11-055 Vend Fab Magnet Box Power Supplies Delivery of ARC2 Frozen Per CR12-029 | 2011-08-01 A | 2012-03-30 → 2012-03-12 A (-18d) | 164d → 150d | 0% → 100% | 542d → none | 13221010S FS-164d → 13221010S FS-185d | was named Revised Schedule per CR11-055 Vend Fab Magnet Box Power Supplies Delivery of ARC2 |
| 13221010U | Revised Schedule per CR11-055 Vend Fab Magnet Box Power Supplies Delivery of ARC4 Frozen Per CR12-029 | 2011-08-01 A | 2012-03-30 → 2012-03-12 A (-18d) | 164d → 150d | 0% → 100% | 542d → none | 13221010T FS-164d → 13221010T FS-207d | was named Revised Schedule per CR11-055 Vend Fab Magnet Box Power Supplies Delivery of ARC4 |
| 13221010V | Revised Schedule per CR11-055 Vend Fab Magnet Box Power Supplies Delivery of ARC5 Frozen Per CR12-029 | 2011-08-01 A | 2012-03-30 → 2012-03-12 A (-18d) | 164d → 150d | 0% → 100% | 542d → none | 13221010U FS-164d → 13221010U FS-207d | was named Revised Schedule per CR11-055 Vend Fab Magnet Box Power Supplies Delivery of ARC5 |
| 13221010W | Revised Schedule per CR11-055 Vend Fab Magnet Box Power Supplies Delivery of ARC7 Frozen Per CR12-029 | 2011-08-01 A | 2012-03-30 → 2012-03-12 A (-18d) | 164d → 150d | 0% → 100% | 542d → none | 13221010V FS-164d → 13221010V FS-227d | was named Revised Schedule per CR11-055 Vend Fab Magnet Box Power Supplies Delivery of ARC7 |
| 13221010X | Revised Schedule per CR11-055 Vend Fab Magnet Box Power Supplies Delivery of ARC3 Frozen Per CR12-029 | 2011-08-01 A | 2012-03-30 → 2012-03-12 A (-18d) | 164d → 150d | 0% → 100% | 542d → none | 13221010W FS-164d → 13221010W FS-227d | was named Revised Schedule per CR11-055 Vend Fab Magnet Box Power Supplies Delivery of ARC3 |
| 13221010Y | Revised Schedule per CR11-055 Vend Fab Magnet Box Power Supplies Delivery of ARC6 Frozen Per CR12-029 | 2011-08-01 A | 2012-03-30 → 2012-03-12 A (-18d) | 164d → 150d | 0% → 100% | 542d → none | 13221010X FS-164d → 13221010X FS-249d | was named Revised Schedule per CR11-055 Vend Fab Magnet Box Power Supplies Delivery of ARC6 |
| 13221010Z | Revised Schedule per CR11-055 Vend Fab Magnet Box Power Supplies Delivery of ARC10 Frozen Per CR12-029 | 2011-08-01 A | 2012-03-30 → 2012-03-12 A (-18d) | 164d → 150d | 0% → 100% | 542d → none | 13221010Y FS-164d → 13221010Y FS-249d | was named Revised Schedule per CR11-055 Vend Fab Magnet Box Power Supplies Delivery of ARC10 |
| 13221010Za | Revised Schedule per CR11-055 Vend Fab Magnet Box Power Supplies Delivery of ARC8 Frozen Per CR12-029 | 2011-08-01 A | 2012-03-30 → 2012-03-12 A (-18d) | 164d → 150d | 0% → 100% | 542d → none | 13221010Z FS-164d → 13221010Z FS-249d | was named Revised Schedule per CR11-055 Vend Fab Magnet Box Power Supplies Delivery of ARC8 |
| 13221010Zb | Revised Schedule per CR11-055 Vend Fab Magnet Box Power Supplies Delivery of ARC9 Frozen Per CR12-029 | 2011-08-01 A | 2012-03-30 → 2012-03-12 A (-18d) | 164d → 150d | 0% → 100% | 542d → none | 13221010Za FS-164d → 13221010Za FS-272d | was named Revised Schedule per CR11-055 Vend Fab Magnet Box Power Supplies Delivery of ARC9 |
| 13221010Zc | Revised Schedule per CR11-055 Vend Fab Magnet Box Power Supplies Delivery of Final Documentation and Spare Parts | 2011-08-01 A | 2012-03-30 → 2012-03-12 A (-18d) | 164d → 150d | 0% → 100% | 542d → none | 13221010Zb FS-164d → 13221010Zb FS-272d |  |
| 13221015 | Receive & Inpect Magnet System Box Power Supplies (Frozen per CR11-055) | 2011-03-01 → 2011-08-01 A (+153d) | 2011-07-29 → 2011-08-09 A (+11d) | 107d → 7d | 0% → 100% | 833d → none |  |  |
| 13221020 | Place/Connect/Check-out Magnet System Box Power Supplies (Frozen per CR11-055) | 2011-07-13 → 2011-08-01 A (+19d) | 2011-07-29 → 2011-08-17 A (+19d) |  | 0% → 100% | 890d → none |  |  |
| 13221115 | Test Extraction PS Systems | 2011-07-19 → 2011-08-01 A (+13d) | 2011-08-15 → 2013-05-13 A (+637d) | 20d → 361d | 0% → 100% | 300d → none |  | resources COMP SCIENT [40 h]; ELEC ENG [40 h]; ELEC TECH [40 h] → ELEC ENG [40 h]; ELEC TECH [40 h]; COMP SCIENT [40 h] |
| 13221005B | Vend Fab Magnet System Box Power Supplies Oversight FY12 | 2011-10-03 A | 2011-10-31 A |  | 0% → 100% | 768d → none |  |  |
| 13221096LOE | Engineering Oversight - Develop/Conduct Procedures, Q.A. and Training FY12 | 2011-10-03 A | 2012-09-28 A |  | 0% → 100% | 227d → none |  | resources ELEC TECH [31.67 h]; ELEC ENG [301 h]; ELEC DES [31.67 h] → ELEC ENG [301 h]; ELEC DES [31.67 h]; ELEC TECH [31.67 h] |
| 13221015a | Receive & Inpect Magnet System Box Power Supplies (Revised by CR11-055) Frozen Per CR12-029 | 2012-01-27 → 2011-11-01 A (-87d) | 2012-02-29 → 2012-03-12 A (+12d) | 23d → 84.73d | 0% → 100% | 542d → none | 13221010Zc FS-45d, 13221005B FS-172d, 13221010C → 13221005B FS-232d, 13221010C, 13221010Zc FS-250d | was named Receive & Inpect Magnet System Box Power Supplies (Revised by CR11-055) |
| 13221020a | Place/Connect/Check-out Magnet System Box Power Supplies (Revised by CR11-055) Frozen Per CR12-029 | 2012-02-29 → 2011-11-01 A (-120d) | 2012-03-16 → 2012-03-12 A (-4d) | 12.42d → 84.24d | 0% → 100% | 542d → none | 13221015 FS-150d, 13221015a FS-1d, 13224040 → 13221015a FS-200d, 13221015 FS-175d, 13224040 | was named Place/Connect/Check-out Magnet System Box Power Supplies (Revised by CR11-055); resources ELEC ENG [38.4 h]; ELEC DES [38.4 h]; ELEC TECH [76.8 h]; COMP SCIENT [15.36 h]; SUPPLIES & MATERIALS → ELEC ENG [38.4 h]; ELEC DES [38.4 h]; SUPPLIES & MATERIALS; ELEC TECH [76.8 h]; COMP SCIENT [15.36 h] |
| 13221119M | Award Components to Refurb 6 PS (BOX SUPPLIES) Frozen Per CR 12-028 | 2011-02-03 → 2012-02-28 A (+390d) | 2011-02-03 → 2012-02-28 A (+390d) |  | 0% → 100% | 459d → none |  |  |
| 13221021 | Reverse Entry Per CR12-029 | 2012-03-02 → 2012-03-01 A (-1d) | 2012-03-15 → 2012-03-12 A (-3d) | 10d → 8d | 0% → 100% | 138d → none |  |  |
| 13221022 | Procurement Prep for Magnet Box Power Supplies Revised per CR12-029 | 2012-03-01 A | 2012-05-21 → 2012-08-20 A (+91d) | 58d → 121d | 0% → 100% | 20d → none |  |  |
| 13221025A | Test T&M PS | 2012-03-05 → 2012-03-01 A (-4d) | 2012-06-01 → 2012-05-14 A (-18d) | 64d → 53d | 0% → 100% | 512d → none |  |  |
| 13221120 | Vend Fab Compnts to Refurb 6 PS (Box SUPPLIES) Frozen Per CR 12-028 | 2011-02-03 → 2012-03-01 A (+392d) | 2011-05-26 → 2012-03-12 A (+291d) | 80d → 8d | 0% → 100% | 459d → none |  |  |
| 13221125 | Monitor Delivery & Receive PS Compnts (Box SUPPLIES) Frozen Per CR 12-028 | 2011-02-03 → 2012-03-01 A (+392d) | 2011-05-26 → 2012-03-12 A (+291d) | 80d → 8d | 0% → 100% | 459d → none |  | resources ELEC TECH [40 h]; ELEC ENG [40 h] → ELEC ENG [40 h]; ELEC TECH [40 h] |
| 13221125A | Reverse Entry Per CR 12-028 | 2012-03-05 → 2012-03-01 A (-4d) | 2012-03-23 → 2012-03-12 A (-11d) | 15d → 8d | 0% → 100% | 132d → none |  |  |
| 13221021A | Additional Reverse Entry Per CR12-029A | 2012-04-03 → 2012-04-02 A (-1d) | 2012-04-16 → 2012-04-09 A (-7d) | 10d → 6d | 0% → 100% | 116d → none |  |  |
| 13221126M | Award Arc 1 and Hall A PS | 2012-04-02 A | 2012-04-02 A |  | 0% → 100% | 162d → none |  |  |
| 13221127 | Production & Delivery of Arc 1 and Hall A PS | 2012-04-02 → 2012-04-16 A (+14d) | 2012-10-31 → 2013-08-30 A (+303d) | 150d → 233d | 0% → 100% | 162d → none |  |  |
| 13221128 | Monitor Production of Arc 1 and Hall A PS FY12 | 2012-04-02 → 2012-04-16 A (+14d) | 2012-09-28 A | 127d → 116d | 0% → 100% | 221d → none |  |  |
| 13221026 | Magnet Box Power Supply Original Vendor Refund | 2012-04-02 → 2012-05-01 A (+29d) | 2012-04-20 → 2012-05-22 A (+32d) | 15d → 16d | 0% → 100% | 112d → none |  |  |
| 13221022a | Magnet Box Power Supply Contract Oversight FY12 | 2012-05-22 → 2012-05-21 A (-1d) | 2012-09-28 A | 91d → 92d | 0% → 100% | 20d → none | 13221022 → 13221022 FS-30d | resources TRAVEL; ELEC ENG [200 h] → ELEC ENG [200 h]; TRAVEL |
| 13221130 | Remove and Shuffle Box PS | 2012-05-14 → 2012-05-21 A (+7d) | 2012-09-28 → 2013-05-13 A (+227d) | 97d → 173d | 0% → 100% | 221d → none | 2-02M, 13221125, 13221127 FS-120d, 13221128a FS-120d, 13221120 → 2-02M, 13221128a FS-120d, 13221120, 13221127 FS-210d, 13221125 | resources ELEC TECH [160 h]; SKLLD TRADE [80 h] → SKLLD TRADE [80 h]; ELEC TECH [160 h] |
| 13221022D | Vend Fab Magnet Box Power Supplies Peg Point #1 - Design Review (Kick-off Meeting) | 2012-08-24 A | 2013-01-31 → 2013-02-08 A (+8d) | 105d → 21d | 0% → 100% | 20d → none |  |  |
| 13221023 | Vend Fab Magnet Box Power Supplies Peg Point #1A - Receipt of Materials | 2012-08-24 A | 2013-04-30 → 2013-07-15 A (+76d) |  | 0% → 100% | 20d → none |  |  |
| 13221023A | Vend Fab Magnet Box Power Supplies Peg Point #2 - First Power Supply (ARC 2) Delivered to JLab | 2012-08-24 A | 2013-07-31 → 2013-07-15 A (-16d) |  | 0% → 100% | 20d → none |  |  |
| 13221023B | Vend Fab Magnet Box Power Supplies Peg Point #3 - First Power Supply (ARC 2) Accepted, Tested and Production Start | 2012-08-24 A | 2013-08-30 A |  | 0% → 100% | 20d → none |  |  |
| 13221022b | Magnet Box Power Supply Contract Oversight FY13 | 2012-10-01 A | 2013-08-30 A | 228d → 248d | 0% → 100% | 20d → none |  | was named Magnet Box Power Supply Contract Oversight FY13 *** Re-Baseline Split; resources ELEC ENG [257.42 h]; TRAVEL → ELEC ENG [280 h]; TRAVEL |
| 13221097LOE | Engineering Oversight - Develop/Conduct Procedures, Q.A. and Training FY13 | 2012-10-01 A | 2012-11-12 A |  | 0% → 100% | 227d → none |  |  |
| 13221128a | Monitor Production of Arc 1 and Hall A PS FY13 | 2012-10-01 A | 2012-10-31 A |  | 0% → 100% | 221d → none | 13221128 → 13221128 FS-50d |  |
| 13221024 | Receive & Inpect Magnet System Box Power Supplies (Revised by CR12-029) | 2013-08-01 → 2013-07-15 A (-17d) | 2013-08-30 A | 22d → 215d | 0% → 100% | 203d → none |  | was named Receive & Inpect Magnet System Box Power Supplies (Revised by CR12-029) *** Re-Baseline Split |
| 13221133 | Receive, Inspect and Install Arc 1 and Hall A PS | 2012-11-01 → 2013-07-15 A (+256d) | 2012-12-31 → 2013-08-30 A (+242d) | 36d → 9d | 0% → 100% | 162d → none | 13221127 → 13221127 FS-15d | resources SKLLD TRADE [80 h]; ELEC TECH [160 h] → ELEC TECH [160 h]; SKLLD TRADE [80 h] |
| 13221024a | Place/Connect/Check-out Magnet System Box Power Supplies (Revised by CR12-029) | 2013-08-08 → 2013-08-12 A (+4d) | 2013-08-30 A | 17d → 215d | 0% → 100% | 203d → none | 13221024 FS-17d → 13221024 FS-210d | was named Place/Connect/Check-out Magnet System Box Power Supplies (Revised by CR12-029) *** Re-Baseline Split |
| 13221025 | Test Magnet System Box Power Supplies w/Dummy Load | 2013-08-15 → 2013-08-30 A (+15d) | 2013-08-30 A | 12d → 215d | 0% → 100% | 203d → none | 13221092, 13221020a FS+14.58d, 3A-23M, 13221020 FS-180d, 13221024a FS-12d → 13221092, 13221024a FS-210d, 3A-23M, 13221020 FS-180d, 13221020a FS+14.6d | was named Test Magnet System Box Power Supplies w/Dummy Load *** Re-Baseline Split; resources ELEC TECH [71.44 h]; ELEC ENG [35.72 h]; ELEC DES [35.72 h] → ELEC TECH [71.64 h]; ELEC ENG [35.62 h]; ELEC DES [35.62 h] |
| 13221135 | Test Arc 1 and Hall A PS w/ Dummy Load | 2013-01-02 → 2013-08-30 A (+240d) | 2013-01-31 → 2013-08-30 A (+211d) | 21d → 10d | 0% → 100% | 162d → none | 13221130, 13221133 → 13221133, 13221130 FS-20d |  |
| 13221140 | Re-Baseline Actuals Adjustment | 2013-08-30 A | 2013-08-30 A |  | 0% → 100% | 20d → none | 9-130M FS+227d → none |  |
| 23221022b | Magnet Box Power Supply Contract Oversight FY13 | 2013-09-03 A | 2013-09-30 A |  | 0% → 100% | 17d → none |  |  |
| 23221023C | Vend Fab Magnet Box Power Supplies Peg Point #4 - ARC 3, 4, 5, 6 and LAM 1 Delivered and accepted at JLab | 2013-09-03 A |  |  | 0% → 40% | 154d → 293d |  |  |
| 23221023D | Vend Fab Magnet Box Power Supplies Peg Point #4 *** Delivery Incentive Bonus****** | 2013-09-03 A |  |  |  | 154d → 250d |  |  |
| 23221023F | Vend Fab Magnet Box Power Supplies Peg Point #5 - ARC 7, 8, 9, 10, RSEP 8 and XSEP 10 Delivered and accepted at JLab | 2013-09-03 A |  |  |  | 154d → 207d |  |  |
| 23221023G | Vend Fab Magnet Box Power Supplies Peg Point #5 *** Delivery Incentive Bonus****** | 2013-09-03 A |  |  |  | 154d → 164d |  |  |
| 23221023H | Vend Fab Magnet Box Power Supplies Peg Point #6 - LAM 3, XSEP 8 and RSEP 9 Delivered and accepted at JLab | 2013-09-03 A |  |  |  | 154d → 283d |  |  |
| 23221023J | Vend Fab Magnet Box Power Supplies Peg Point #6 *** Delivery Incentive Bonus****** | 2013-09-03 A |  |  |  | 154d → 240d |  |  |
| 23221023K | Vend Fab Magnet Box Power Supplies Peg Point #7 Acceptance Test at JLab | 2013-09-03 A |  |  |  | 154d → 197d |  |  |
| 23221023L | Vend Fab Magnet Box Power Supplies Peg Point #8 Delivery of Spares | 2013-09-03 A |  |  |  |  |  |  |
| 23221024 | Receive & Inpect Magnet System Box Power Supplies Part A FY13 (FY14 @ 23221029) | 2013-09-03 A | 2013-09-30 → 2013-11-27 (+58d) |  | 0% → 40% | 0d → 82d |  |  |
| 23221024b | Place/Connect Magnet System Box Power Supplies Part A Procurement | 2013-09-03 A |  |  | 0% → 20% | 0d → 39d |  | resources ELEC TECH; COMP SCIENT; SUPPLIES & MATERIALS; ELEC ENG; ELEC DES; PROCUREMENT<$50K 60 NO ESCALATION FY14 → ELEC TECH; COMP SCIENT; SUPPLIES & MATERIALS; ELEC ENG; ELEC DES; PROCUREMENT<$50K 60 [1584 unit] |
| 23221024c | Place/Connect Magnet System Box Power Supplies Part A Labor/Expenses FY13 | 2013-09-03 A | 2013-09-30 → 2013-11-27 (+58d) |  | 0% → 20% | 0d → 39d |  |  |
| 23221024d | Place/Connect Magnet System Box Power Supplies Part A Labor/Expenses FY14 | 2013-10-01 → 2013-09-03 A (-28d) |  |  | 0% → 20% | 0d → 39d | 23221024a FS-193d, 23221024c → 23221024c FS-62d, 23221024a FS-193d |  |
| 23221029 | Receive & Inpect Magnet System Box Power Supplies Part A FY14 (FY13 @ 23221024) | 2013-10-01 → 2013-09-03 A (-28d) |  |  | 0% → 40% | 0d → 82d | 9-130M FS+228d, 23221024 → 23221024 FS-62d |  |
| 23221127 | Production & Delivery of Arc 1 and Hall A PS | 2013-09-03 A | 2013-10-18 → 2013-10-21 A (+3d) |  | 0% → 100% | 62d → none |  | resources PROCUREMENT<$50K 60 NO ESCALATION; PROCUREMENT>$50K 69 NO ESCALATION → PROCUREMENT>$50K 69 NO ESCALATION |
| 23221133 | Receive, Inspect and Install Arc 1 and Hall A PS FY13 | 2013-09-03 A | 2013-09-30 → 2013-11-22 (+53d) | 20d → 59d | 0% → 50% | 62d → 149d |  |  |
| 23221133a | Receive, Inspect and Install Arc 1 and Hall A PS FY14 | 2013-10-01 → 2013-09-03 A (-28d) |  |  | 0% → 50% | 62d → 149d | 23221127 FS-34d, 23221133 → 23221127 FS-34d, 23221133 FS-59d |  |
| 23221022c | Magnet Box Power Supply Contract Oversight FY14 | 2013-10-01 A |  |  | 0% → 14% |  |  |  |
| 23221140LOE | Proj Admin ongoing FY14 Part A | 2013-10-01 A |  |  | 0% → 55% |  |  |  |
| 2 | **1.3.2.2.2 SHUNTS** | 2010-05-13 → 2010-04-26 (-17d) | 2014-02-03 → 2014-04-18 (+74d) |  |  |  |  |  |
| 13222000M | Start Shunt Work | 2010-05-13 → 2010-04-26 A (-17d) | 2010-05-13 → 2010-04-26 A (-17d) |  | 0% → 100% | 815d → none |  |  |
| 13222005 | Engineering, Drafting and Software - Single Channel Shunt Chassis | 2010-07-06 → 2010-04-26 A (-71d) | 2010-08-02 → 2010-10-25 A (+84d) | 20d → 128d | 0% → 100% | 779d → none | 9-100M FS+186d, 13222000M → 9-100M FS+95d, 13222000M |  |
| 13222015 | Labor and Expenses - Single Channel Shunt Chassis | 2010-07-20 → 2010-04-26 A (-85d) | 2010-09-30 → 2010-11-15 A (+46d) | 52d → 143d | 0% → 100% | 779d → none | 13222005 FS-10d → 13222005 FS-65d | resources MSHOP; ELEC TECH [16 h] → ELEC TECH [16 h]; MSHOP |
| 13222020 | Procurements Parts and Boards - Single Channel Shunt Chassis | 2010-07-15 → 2010-04-26 A (-80d) | 2010-09-23 → 2010-11-15 A (+53d) | 50d → 143d | 0% → 100% | 779d → none | 13222015 FS-55d → 13222015 FS-65d |  |

| ID | Task | Start | Finish | Duration | Complete | Total float | Predecessors | Other |
| --- | --- | --- | --- | --- | --- | --- | --- | --- |
| 13222040 | Engineering and Drafting - Shunt Resistor Plates | 2010-08-02 → 2010-04-26 A (-98d) | 2010-08-11 → 2010-05-17 A (-86d) | 8d → 16d | 0% → 100% | 806d → none | 9-100M FS+205d → 9-100M FS+95d | resources ELEC DES [24 h]; ELEC ENG [40 h] → ELEC ENG [40 h]; ELEC DES [24 h] |
| 13222045 | Labor and Expenses - Shunt Resistor Plates FY10 | 2010-08-12 → 2010-04-26 A (-108d) | 2010-09-30 → 2010-05-24 A (-129d) | 35d → 21d | 0% → 100% | 806d → none | 13222040 → 13222040 FS-10d | resources ELEC TECH [23.33 h]; MSHOP → MSHOP; ELEC TECH [23.33 h] |
| 13222045a | Labor and Expenses - Shunt Resistor Plates FY11 | 2010-10-01 → 2010-04-26 A (-158d) | 2010-11-04 → 2010-05-24 A (-164d) | 25d → 21d | 0% → 100% | 806d → none | 13222045 → 13222045 FS-60d | resources ELEC TECH [16.67 h]; MSHOP → MSHOP; ELEC TECH [16.67 h] |
| 13222050 | Procurement (Parts) - Shunt Resistor Plates | 2010-08-19 → 2010-04-26 A (-115d) | 2010-11-04 → 2010-09-20 A (-45d) | 55d → 103d | 0% → 100% | 806d → none | 13222045a FS-55d → 13222045a FS-65d |  |
| 13222055 | Assembly and Testing - Shunt Resistor Plates | 2010-11-05 → 2010-05-24 A (-165d) | 2011-02-24 → 2010-12-20 A (-66d) | 70d → 146d | 0% → 100% | 806d → none | 13222045a, 13222050 → 13222050 FS-30d, 13222045a FS-50d |  |
| 13222105 | Engineering, Drafting and Software - 75 Amp Shunt Upgrade | 2011-08-23 → 2010-05-24 A (-456d) | 2011-08-29 → 2010-10-25 A (-308d) | 5d → 108d | 0% → 100% | 604d → none | 9-110M FS+220d → 9-110M FS-80d |  |
| 13222025 | Assembly and Testing - Single Channel Shunt Chassis FY10 | 2010-09-24 → 2010-07-26 A (-60d) | 2010-09-30 → 2010-09-10 A (-20d) | 5d → 34d | 0% → 100% | 779d → none | 13222020 → 13222020 FS-55d |  |
| 13222025a | Assembly and Testing - Single Channel Shunt Chassis FY11 | 2010-10-01 → 2010-07-26 A (-67d) | 2011-01-11 → 2010-09-10 A (-123d) | 65d → 34d | 0% → 100% | 779d → none | 13222025 → 13222020 FS-55d |  |
| 13222115 | Procurement (Parts) - 75 Amp Shunt Upgrade | 2011-09-07 → 2010-08-06 A (-397d) | 2011-09-20 → 2010-08-30 A (-386d) | 10d → 17d | 0% → 100% | 604d → none | 13222110 FS-10d → 13222110 FS-120d |  |
| 13222070 | Engineering, Drafting and Software - Track Regulator and 30/80 Frozen per CR12-028 | 2011-01-25 → 2010-11-15 A (-71d) | 2011-04-05 → 2012-03-12 A (+342d) | 50d → 323d | 0% → 100% | 681d → none | 9-110M FS+73d → 9-110M | was named Engineering, Drafting and Software - Track Regulator and 30/80 Frozen Per CR 12-028; resources COMP SCIENT [40 h]; ELEC ENG [160 h]; ELEC DES [160 h] → ELEC ENG [160 h]; ELEC DES [160 h]; COMP SCIENT [40 h] |
| 13222165 | Engineering and Drafting - 12GEV Shunt Shuffle | 2012-03-12 → 2010-12-01 A (-467d) | 2012-05-04 → 2012-10-22 A (+171d) | 40d → 470d | 0% → 100% | 385d → none | 9-120M FS+105d → 9-120M FS-300d |  |
| 13222080 | Procurement (Parts) - Track Regulator and 30/80 Frozen per CR12-028 | 2011-03-30 → 2011-04-11 A (+12d) | 2011-05-17 → 2012-03-12 A (+300d) | 35d → 228d | 0% → 100% | 681d → none | 13222075 FS-35d → 13222075 FS-115d | was named Procurement (Parts) - Track Regulator and 30/80 Frozen Per CR 12-028 |
| 13222075 | Oversight (Labor) - Track Regulator and 30/80 Frozen per CR12-028 | 2011-03-23 → 2011-04-14 A (+22d) | 2011-05-17 → 2012-03-12 A (+300d) | 40d → 225d | 0% → 100% | 681d → none | 13222070 FS-10d → 13222070 FS-90d | was named Oversight (Labor) - Track Regulator and 30/80 Frozen Per CR 12-028 |
| 13222110 | Oversight (Labor) - 75 Amp Shunt Upgrade | 2011-08-30 → 2011-05-09 A (-113d) | 2011-09-20 → 2011-07-25 A (-57d) | 15d → 54d | 0% → 100% | 604d → none |  |  |
| 13222120 | Modifications and Testing - 75 Amp Shunt Upgrade FY11 | 2011-09-21 → 2011-05-23 A (-121d) | 2011-09-30 → 2011-06-15 A (-107d) | 8d → 17d | 0% → 100% | 604d → none |  |  |
| 13222120a | Modifications and Testing - 75 Amp Shunt Upgrade FY12 | 2011-10-03 → 2011-05-23 A (-133d) | 2011-10-19 → 2011-06-15 A (-126d) | 13d → 17d | 0% → 100% | 604d → none |  |  |
| 13222140 | Update Machine Documentation - 75 Amp Shunt Upgrade Part A | 2011-11-03 → 2011-05-23 A (-164d) | 2011-11-04 → 2012-11-12 A (+374d) | 2d → 370d | 0% → 100% | 651d → none | 13222125 → 13222125 FS-295d | resources ELEC DES [8 h]; ELEC TECH [8 h] → ELEC TECH [8 h]; ELEC DES [8 h] |
| 13222125 | Installation and Testing - 75 Amp Shunt Upgrade Part A | 2011-10-20 → 2011-08-03 A (-78d) | 2011-11-02 → 2012-10-22 A (+355d) | 10d → 305d | 0% → 100% | 651d → none | 13222120a → 9-120M FS-21d, 13222120a |  |
| 13222060 | Installation - Shunt Resistor Plates Frozen per CR12-028 | 2011-05-13 → 2012-03-01 A (+293d) | 2011-06-10 → 2012-03-12 A (+276d) | 20d → 8d | 0% → 100% | 751d → none |  |  |
| 13222061 | Reverse Entry per CR12-028 | 2012-03-05 → 2012-03-01 A (-4d) | 2012-03-23 → 2012-03-12 A (-11d) | 15d → 8d | 0% → 100% | 132d → none |  | resources ELEC ENG [-80 h]; PROCUREMENT<$50K 60; ELEC DES [-80 h]; ELEC TECH [-492 h]; COMP SCIENT [-20 h] → ELEC TECH [-492 h]; COMP SCIENT [-20 h]; ELEC ENG [-80 h]; PROCUREMENT<$50K 60; ELEC DES [-80 h] |
| 13222065 | Update Machine Documentation - Shunt Resistor Plates Frozen per CR12-028 | 2011-06-13 → 2012-03-01 A (+262d) | 2011-06-15 → 2012-03-12 A (+271d) | 3d → 8d | 0% → 100% | 751d → none |  | was named Update Machine Documentation - Shunt Resistor Plates Frozen Per CR 12-028 |
| 13222085 | Assembly and Testing - Track Regulator and 30/80 Frozen per CR12-028 | 2011-05-18 → 2012-03-01 A (+288d) | 2011-08-23 → 2012-03-12 A (+202d) | 68d → 8d | 0% → 100% | 681d → none |  | was named Assembly and Testing - Track Regulator and 30/80 Frozen Per CR 12-028 |
| 13222090 | Installation and Testing - Track Regulator and 30/80 Frozen per CR12-028 | 2011-08-24 → 2012-03-01 A (+190d) | 2011-09-21 → 2012-03-12 A (+173d) | 20d → 8d | 0% → 100% | 681d → none |  | was named Installation and Testing - Track Regulator and 30/80 Frozen Per CR 12-028 |
| 13222100 | Data Entry/Paperwork - Track Regulator and 30/80 Frozen per CR12-028 | 2011-09-22 → 2012-03-01 A (+161d) | 2011-09-23 → 2012-03-12 A (+171d) | 2d → 8d | 0% → 100% | 681d → none |  | was named Data Entry/Paperwork - Track Regulator and 30/80 Frozen Per CR 12-028 |
| 13222070A | Engineering, Drafting and Software - Track Regulator and 30/80 Revised Per CR 12-028 | 2012-03-05 → 2012-03-13 A (+8d) | 2012-09-28 → 2013-08-30 A (+336d) | 147d → 261d | 0% → 100% | 259d → none |  |  |
| 13222145 | Engineering (Design) - Shunt Adder System Removal | 2011-06-06 → 2012-05-01 A (+330d) | 2011-06-08 → 2012-05-14 A (+341d) | 3d → 10d | 0% → 100% | 725d → none | 9-110M FS+165d → 9-110M FS+165d, 2-02M |  |
| 13222150 | Component Removal - Shunt Adder System Removal | 2012-06-05 → 2012-05-11 A (-25d) | 2012-06-13 → 2012-05-19 A (-25d) | 7d → 6d | 0% → 100% | 481d → none |  |  |
| 13222155 | Reconfiguration and Testing - Shunt Adder System Removal | 2012-06-14 → 2012-05-20 A (-25d) | 2012-06-22 → 2012-05-31 A (-22d) | 7d → 8d | 0% → 100% | 481d → none |  |  |
| 13222170 | Pull and Modify - 12GEV Shunt Shuffle | 2012-06-06 → 2012-06-05 A (-1d) | 2012-08-27 → 2013-08-30 A (+368d) | 59d → 151d | 0% → 100% | 385d → none | 13222165 FS+20d → 13222165 FS-70d | resources ELEC TECH [200 h]; ELEC ENG [20 h] → ELEC ENG [20 h]; ELEC TECH [200 h] |
| 13222200 | Engineering, Drafting and Software - 25 Amp Shunts | 2012-03-26 → 2012-07-02 A (+98d) | 2012-06-29 → 2012-08-20 A (+52d) | 68d → 36d | 0% → 100% | 330d → none | 9-120M FS+115d → 9-120M FS+205d |  |
| 13222205 | Procurement Labor - 25 Amp Shunts FY12 | 2012-07-02 A | 2012-09-28 → 2012-08-20 A (-39d) | 64d → 36d | 0% → 100% | 330d → none | 13222200 → 13222200 FS-70d |  |
| 13222205a | Procurement Labor - 25 Amp Shunts FY13 | 2012-10-01 → 2012-07-02 A (-91d) | 2012-10-31 → 2012-08-20 A (-72d) | 23d → 36d | 0% → 100% | 330d → none |  |  |
| 13222210 | Procurements - 25 Amp Shunts | 2012-07-02 → 2012-08-06 A (+35d) | 2012-10-31 → 2012-08-20 A (-72d) | 87d → 11d | 0% → 100% | 330d → none |  |  |
| 13222160 | Update Machine Documentation - Shunt Adder System RemovalNew Activity | 2012-07-16 → 2012-09-10 A (+56d) | 2012-07-17 → 2012-09-17 A (+62d) | 2d → 6d | 0% → 100% | 481d → none |  |  |
| 13222175 | Clean and Modify Racks - 12GEV Shunts | 2012-08-28 → 2012-09-10 A (+13d) | 2012-09-10 → 2013-08-30 A (+354d) | 9d → 114d | 0% → 100% | 385d → none | 13222170 → 13222170 FS-30d |  |
| 13222215 | Modification - 25 Amp Shunt Upgrade | 2012-10-25 → 2012-09-10 A (-45d) | 2012-11-30 → 2012-12-15 A (+15d) | 25d → 68d | 0% → 100% | 330d → none |  | resources ELEC TECH [160 h]; ELEC ENG [40 h] → ELEC ENG [40 h]; ELEC TECH [160 h] |
| 13222195 | Update Machine Documentation - 12GEV Shunts | 2013-04-02 → 2012-09-17 A (-197d) | 2013-04-11 → 2013-08-30 A (+141d) | 8d → 150d | 0% → 100% | 300d → none | 13222190 → 13222190 FS-250d | resources ELEC DES [40 h]; ELEC ENG [20 h] → ELEC ENG [20 h]; ELEC DES [40 h] |
| 13222030 | Installation and Testing - Single Channel Shunt Chassis | 2012-10-01 → 2012-10-08 A (+7d) | 2013-01-31 → 2013-08-30 A (+211d) | 80d → 75d | 0% → 100% | 349d → none |  |  |
| 13222035 | Data Entry / Paperwork - Single Channel Shunt Chassis | 2012-11-01 → 2012-10-08 A (-24d) | 2013-01-31 → 2013-08-30 A (+211d) | 57d → 75d | 0% → 100% | 349d → none | 13222030 FS-57d → 13222030 FS-80d |  |
| 13222063 | Installation - Shunt Resistor Plates Part A | 2012-05-04 → 2012-11-12 A (+192d) | 2012-09-28 → 2012-12-17 A (+80d) | 103d → 53d | 0% → 100% | 284d → none | 9-120M FS+144d → 9-130M, 13417030 FS-15d |  |
| 13222180 | Reinstall Chassis' in 12 GEV Shunts | 2012-09-11 → 2012-11-12 A (+62d) | 2012-09-24 → 2013-08-30 A (+340d) | 10d → 69d | 0% → 100% | 385d → none | 13222175, 13222170 → 13222170 FS-30d, 13222175 FS-60d | was named Reinstall Chassis' in Racks - 12GEV Shunts |
| 13222064 | Installation - Shunt Resistor Plates Part B | 2012-10-01 → 2012-12-03 A (+63d) | 2013-04-30 → 2013-08-30 A (+122d) | 142d → 64d | 0% → 100% | 284d → none |  |  |
| 13222067 | Update Machine Documentation - Shunt Resistor Plates Revised Per CR 12-028 | 2013-05-01 → 2012-12-03 A (-149d) | 2013-05-03 → 2013-08-30 A (+119d) | 3d → 86d | 0% → 100% | 284d → none | 13222064 → 13222064 FS-95d |  |
| 13222220 | Installation and Testing - 25 Amp Shunt Upgrade | 2012-12-03 → 2013-01-07 A (+35d) | 2013-01-31 → 2013-08-30 A (+211d) | 37d → 59d | 0% → 100% | 330d → none |  | resources ELEC TECH [40 h]; ELEC ENG [40 h] → ELEC ENG [40 h]; ELEC TECH [40 h] |
| 13222075A | Oversight (Labor) - Track Regulator and 30/80 Revised Per CR 12-028 | 2012-10-01 → 2013-01-28 A (+119d) | 2012-12-31 → 2013-08-30 A (+242d) |  | 0% → 100% | 259d → none | 13222070A → 13222070A FS-50d |  |
| 13222080A | Procurement (Parts) - Track Regulator and 30/80 Revised Per CR 12-028 | 2012-10-01 → 2013-04-01 A (+182d) | 2012-12-31 → 2013-08-30 A (+242d) |  | 0% → 100% | 259d → none |  |  |
| 13222085A | Assembly and Testing - Track Regulator and 30/80 Revised Per CR 12-028 | 2013-01-02 → 2013-06-03 A (+152d) | 2013-04-09 → 2013-08-30 A (+143d) | 68d → 59d | 0% → 100% | 259d → none | 13222080A → 13222080A FS-40d |  |
| 13222130 | Installation and Testing - 75 Amp Shunt Upgrade Part B | 2012-10-01 → 2013-07-08 A (+280d) | 2012-11-30 → 2013-08-30 A (+273d) | 43d → 73d | 0% → 100% | 370d → none |  |  |
| 13222095 | Installation and Testing - Track Regulator and 30/80 Revised Per CR 12-028 | 2013-04-10 → 2013-08-30 A (+142d) | 2013-05-07 → 2013-08-30 A (+115d) | 20d → 14d | 0% → 100% | 259d → none |  | resources ELEC TECH [40 h]; ELEC ENG [40 h] → ELEC ENG [40 h]; ELEC TECH [40 h] |
| 13222100A | Data Entry/Paperwork - Track Regulator and 30/80 Revised Per CR 12-028 | 2013-05-08 → 2013-08-30 A (+114d) | 2013-06-10 → 2013-08-30 A (+81d) | 23d → 12d | 0% → 100% | 259d → none |  |  |
| 13222142 | Update Machine Documentation - 75 Amp Shunt Upgrade Part B | 2012-12-03 → 2013-08-30 A (+270d) | 2012-12-31 → 2013-08-30 A (+242d) | 16d → 12d | 0% → 100% | 370d → none |  |  |
| 13222185 | New Screens for 12 GEV Shunts | 2012-05-07 → 2013-08-30 A (+480d) | 2012-05-11 → 2013-08-30 A (+476d) |  | 0% → 100% | 478d → none | 13222165 → 9-130M FS+220d, 13222165 |  |
| 13222190 | Reconfiguration and Testing - 12GEV Shunts | 2013-02-04 → 2013-08-30 A (+207d) | 2013-04-01 → 2013-08-30 A (+151d) |  | 0% → 100% | 300d → none | 13224085C, 13222185, 13222180, 13224087 → 13224087, 13224085B, 13222180, 13222185, 13224085C |  |
| 13222230 | Drafting (Update Machine Drawings) | 2013-02-01 → 2013-08-30 A (+210d) | 2013-02-28 → 2013-08-30 A (+183d) | 19d → 44d | 0% → 100% | 330d → none |  | resources ELEC DES [80 h]; ELEC ENG [8 h] → ELEC ENG [8 h]; ELEC DES [80 h] |
| 13222240 | Re-Baseline Actuals Adjustment | 2013-08-30 A | 2013-08-30 A |  | 0% → 100% | 20d → none | 9-130M FS+227d → none |  |
| 23222030 | Installation and Testing - Single Channel Shunt Chassis FY13 | 2013-09-03 A | 2013-09-30 → 2013-09-23 A (-7d) | 20d → 44d | 0% → 100% | 156d → none |  |  |
| 23222030a | Installation and Testing - Single Channel Shunt Chassis FY14 | 2013-10-01 → 2013-09-03 A (-28d) | 2013-11-01 → 2013-09-23 A (-39d) |  | 0% → 100% | 156d → none | 23222030, 9-130M FS+228d → 23222030 |  |
| 23222035 | Data Entry / Paperwork - Single Channel Shunt Chassis FY13 | 2013-09-03 A | 2013-09-30 → 2013-09-23 A (-7d) | 20d → 44d | 0% → 100% | 156d → none | 23222030a FS-44d, 23222030 FS-44d → 23222030 FS-44d, 23222030a |  |
| 23222035a | Data Entry / Paperwork - Single Channel Shunt Chassis FY14 | 2013-10-01 → 2013-09-03 A (-28d) | 2013-11-01 → 2013-09-23 A (-39d) |  | 0% → 100% | 156d → none | 23222030a FS-44d, 23222035, 23222030 FS-44d → 23222030a FS-44d, 23222035 |  |
| 23222064 | Installation - Shunt Resistor Plates Part A FY13 | 2013-09-03 A | 2013-09-30 → 2013-09-23 A (-7d) | 20d → 62d | 0% → 100% | 102d → none |  |  |
| 23222065 | Installation - Shunt Resistor Plates Part A FY14 | 2013-10-01 → 2013-09-03 A (-28d) | 2013-11-27 → 2013-09-23 A (-65d) |  | 0% → 100% | 102d → none | 9-130M FS+228d, 23222064 → 23222064 |  |
| 23222067 | Update Machine Documentation - Shunt Resistor Plates Part A FY13 | 2013-09-03 A | 2013-09-30 → 2013-09-23 A (-7d) | 20d → 62d | 0% → 100% | 102d → none |  |  |
| 23222068 | Update Machine Documentation - Shunt Resistor Plates Part A FY14 | 2013-10-01 → 2013-09-03 A (-28d) | 2013-11-27 → 2013-09-23 A (-65d) |  | 0% → 100% | 102d → none | 23222067, 23222064a FS-98d → 23222067 |  |
| 23222080A | Procurement (Parts) - Track Regulator and 30/80 Part A - Procurement | 2013-09-03 A | 2013-11-27 → 2013-10-21 A (-37d) |  | 0% → 100% | 101d → none |  | was named Procurement (Parts) - Track Regulator and 30/80 Part A Procurement; resources SUPPLIES & MATERIALS; PROCUREMENT<$50K 60 NO ESCALATION FY14 → SUPPLIES & MATERIALS; PROCUREMENT<$50K 60 |
| 23222080Ab | Procurement (Parts) - Track Regulator and 30/80 Part A Expenses FY13 | 2013-09-03 A | 2013-09-30 → 2013-11-27 (+58d) |  | 0% → 50% | 101d → 190d | 23222075Aa FS-99d → 23222075Aa FS-120d |  |
| 23222080Ac | Procurement (Parts) - Track Regulator and 30/80 Part A Expenses FY14 | 2013-10-01 → 2013-09-03 A (-28d) |  |  | 0% → 50% | 101d → 144d | 23222080Ab, 23222075Aa FS-99d → 23222080Ab FS-65d |  |
| 23222085A | Assembly and Testing - Track Regulator and 30/80 Part A FY13 | 2013-09-03 A | 2013-09-30 → 2013-11-27 (+58d) | 20d → 62d | 0% → 50% |  |  |  |
| 23222085Ab | Assembly and Testing - Track Regulator and 30/80 Part A FY14 | 2013-10-01 → 2013-09-03 A (-28d) | 2013-11-27 → 2013-11-25 (-2d) |  | 0% → 50% | 101d → 103d | 23222080Aa FS-99d, 23222085A → 23222085A FS-40d |  |
| 23222170 | Pull and Modify - 12GEV Shunt Shuffle FY13 | 2013-09-03 A | 2013-09-30 → 2013-12-06 (+67d) | 20d → 44d | 0% → 85% | 156d → 173d |  |  |
| 23222170a | Pull and Modify - 12GEV Shunt Shuffle FY14 | 2013-10-01 → 2013-09-03 A (-28d) | 2013-11-01 → 2013-12-06 (+35d) |  | 0% → 85% | 156d → 173d | 9-130M FS+228d, 23222170 → 23222170 FS-25d |  |

| ID | Task | Start | Finish | Duration | Complete | Total float | Predecessors | Other |
| --- | --- | --- | --- | --- | --- | --- | --- | --- |
| 23222175 | Clean and Modify Racks - 12GEV Shunts FY13 | 2013-09-03 A | 2013-09-30 → 2013-12-06 (+67d) | 20d → 44d | 0% → 89% | 156d → 173d |  |  |
| 23222175a | Clean and Modify Racks - 12GEV Shunts FY14 | 2013-10-01 → 2013-09-03 A (-28d) | 2013-11-01 → 2013-12-06 (+35d) |  | 0% → 89% | 156d → 173d | 23222170 FS-44d, 23222175, 23222170a FS-44d → 23222170a FS-44d |  |
| 23222180 | Reinstall Chassis' in Racks - 12GEV Shunts FY13 | 2013-09-03 A | 2013-09-30 → 2013-10-21 A (+21d) | 20d → 44d | 0% → 100% | 156d → none |  |  |
| 23222180a | Reinstall Chassis' in Racks - 12GEV Shunts FY14 | 2013-10-01 → 2013-09-03 A (-28d) | 2013-11-01 → 2013-10-21 A (-11d) |  | 0% → 100% | 156d → none | 23222180, 23222170 FS-44d, 23222170a FS-44d, 23222175 FS-44d, 23222175a FS-44d → 23222180 FS-25d, 23222170a FS-44d, 23222175a FS-44d |  |
| 23222185 | New Screens for 12 GEV Shunts FY13 | 2013-09-03 A | 2013-09-30 → 2013-12-06 (+67d) | 20d → 44d | 0% → 50% | 156d → 173d |  |  |
| 23222185a | New Screens for 12 GEV Shunts FY14 | 2013-10-01 → 2013-09-03 A (-28d) | 2013-11-01 → 2013-12-06 (+35d) |  | 0% → 50% | 156d → 173d | 9-130M FS+228d, 23222185 → 23222185 FS-25d |  |
| 23222190 | Reconfiguration and Testing - 12GEV Shunts FY13 | 2013-09-03 A | 2013-09-30 → 2013-12-06 (+67d) | 20d → 44d | 0% → 20% | 156d → 153d |  |  |
| 23222190a | Reconfiguration and Testing - 12GEV Shunts FY14 | 2013-10-01 → 2013-09-03 A (-28d) | 2013-11-01 → 2013-12-06 (+35d) |  | 0% → 20% | 156d → 153d | 23222190, 23222185a FS-44d, 23222180 FS-44d, 23222180a FS-44d, 23222185 FS-44d → 23222180a FS-44d, 23222185a FS-44d |  |
| 23222195 | Update Machine Documentation - 12GEV Shunts FY13 | 2013-09-03 A | 2013-09-30 → 2013-12-06 (+67d) | 20d → 44d | 0% → 50% | 156d → 133d |  |  |
| 23222195a | Update Machine Documentation - 12GEV Shunts FY14 | 2013-10-01 → 2013-09-03 A (-28d) | 2013-11-01 → 2013-12-06 (+35d) |  | 0% → 50% | 156d → 133d | 23222190 FS-44d, 23222195, 23222190a FS-44d → 23222190a FS-44d, 23222195 FS-25d |  |
| 23222230 | Drafting (Update Machine Drawings) FY13 | 2013-09-03 A | 2013-09-30 → 2013-12-06 (+67d) | 20d → 44d | 0% → 50% | 156d → 133d |  |  |
| 23222230a | Drafting (Update Machine Drawings) FY14 | 2013-10-01 → 2013-09-03 A (-28d) | 2013-11-01 → 2013-12-06 (+35d) |  | 0% → 50% | 156d → 133d | 23222230, 23222220a FS-44d, 23222220 FS-44d → 23222230 FS-25d, 23222220a FS-44d |  |
| 23222075Ab | Oversight (Labor) - Track Regulator and 30/80 FY14 | 2013-10-01 A |  |  | 0% → 55% | 101d → 947d | 23222075A, 23222070Aa FS-99d → none |  |
| 23222220 | Installation and Testing - 25 Amp Shunt Upgrade FY13 | 2013-09-03 → 2013-10-01 A (+28d) | 2013-09-30 → 2013-12-06 (+67d) | 20d → 24d | 0% → 46% | 156d → 153d |  |  |
| 23222220a | Installation and Testing - 25 Amp Shunt Upgrade FY14 | 2013-10-01 A | 2013-11-01 → 2013-12-06 (+35d) |  | 0% → 46% | 156d → 153d | 9-130M FS+228d, 23222220 → none |  |
| 23222064a | Installation - Shunt Resistor Plates Part B |  |  |  |  | 102d → 145d | 23222064, 23222065 → 23222064 FS+47d, 23222065 FS+47d |  |
| 23222067a | Update Machine Documentation - Shunt Resistor Plates Part B |  |  |  |  |  | 23222067, 23222068 → 23222068 FS+47d, 23222067 FS+47d |  |
| 23222080Aa | Procurement (Parts) - Track Regulator and 30/80 Part B |  |  |  |  | 101d → 144d | 23222080Ab, 23222080A, 23222080Ac → 23222080A, 23222080Ac |  |
| 23222085Aa | Assembly and Testing - Track Regulator and 30/80 Part B |  |  |  |  |  |  | was named Assembly and Testing - Track Regulator and 30/80 Part A |
| 23222070A | Engineering, Drafting and Software - Track Regulator and 30/80 Part A FY13 | 2013-09-03 → 2013-12-05 (+93d) | 2013-09-30 → 2014-01-13 (+105d) |  |  | 101d → 152d | 9-130M FS+228d → 9-130M FS+228d, 9-140M FS+45d | resources ELEC DES [3.23 h]; COMP SCIENT [1.62 h]; ELEC ENG [4.85 h] → COMP SCIENT [1.62 h]; ELEC ENG [4.85 h]; ELEC DES [3.23 h] |
| 23222075A | Oversight (Labor) - Track Regulator and 30/80 | 2013-09-03 → 2013-12-18 (+106d) | 2013-09-30 → 2014-02-26 (+149d) | 20d → 42d |  | 101d → 152d | 23222070Aa FS-99d → 23222070Aa FS-70d | was named Oversight (Labor) - Track Regulator and 30/80 FY13 |
| 23222070Ab | Engineering, Drafting and Software - Track Regulator and 30/80 Part A FY14 | 2013-10-01 → 2014-01-14 (+105d) | 2013-11-27 → 2014-02-13 (+78d) | 42d → 22d |  | 101d → 152d | 9-130M FS+228d, 23222070A → 23222070A |  |
| 23222070Aa | Engineering, Drafting and Software - Track Regulator and 30/80 Part B | 2013-12-02 → 2014-02-14 (+74d) | 2014-02-03 → 2014-04-07 (+63d) |  |  | 101d → 152d |  |  |
| 23222075Aa | Oversight (Labor) - Track Regulator and 30/80 | 2013-12-02 → 2014-02-27 (+87d) | 2014-02-03 → 2014-04-18 (+74d) |  |  | 101d → 152d | 23222075A, 23222075Ab → 23222075A |  |
| 3 | **1.3.2.2.3 TRIMS** | 2010-04-07 → 2010-04-26 (+19d) | 2014-02-03 → 2014-03-05 (+30d) |  |  |  |  |  |
| 13223038 | Bid 20 amp Trim PS (20 A Trims) | 2010-04-07 → 2010-04-26 A (+19d) | 2010-09-24 → 2011-06-15 A (+264d) | 120d → 284d | 0% → 100% | 534d → none |  |  |
| 13223030 | Proc Rack Hardware for 20 amp Trim PS/Wait for Delivery (20 A TRIMS) | 2011-01-05 → 2010-07-26 A (-163d) | 2011-04-28 → 2012-04-09 A (+347d) | 80d → 422d | 0% → 100% | 423d → none | 121223060a, 9-110M FS+60d → 121223060a, 9-110M FS-45d | resources PROCUREMENT<$50K 60; ELEC ENG [80 h] → ELEC ENG [80 h]; PROCUREMENT<$50K 60 |
| 13223045 | Monitor Design & Development &Test of First Article (20 A Trims) | 2011-01-05 → 2011-06-01 A (+147d) | 2011-04-28 → 2012-01-23 A (+270d) | 80d → 158d | 0% → 100% | 470d → none | 13223039M → 13223039M FS-35d | resources ELEC ENG [80 h]; TRAVEL → TRAVEL; ELEC ENG [80 h] |
| 13223039M | Award 20 amp Trim PS (20 A Trims) | 2011-01-05 → 2011-06-27 A (+173d) | 2011-01-05 → 2011-06-27 A (+173d) |  | 0% → 100% | 470d → none |  |  |
| 13223051A | Vend Fab 20 Amp Trim Power Supplies - Peg Point #1 NRE | 2011-06-27 A | 2011-08-31 → 2011-12-19 A (+110d) | 47d → 122d | 0% → 100% | 372d → none |  |  |
| 13223051B | Vend Fab 20 Amp Trim Power Supplies - Peg Point #2 Approval of 1st Article Test | 2011-06-27 A | 2011-10-31 → 2013-03-11 A (+497d) | 89d → 364d | 0% → 100% | 372d → none |  |  |
| 13223051C | Vend Fab 20 Amp Trim Power Supplies - Peg Point #3 First Delivery and Acceptance of 30 units | 2011-06-27 A | 2012-01-31 → 2013-05-13 A (+468d) | 146d → 388d | 0% → 100% | 372d → none |  |  |
| 13223051D | Vend Fab 20 Amp Trim Power Supplies - Peg Point #4 Second Delivery and Acceptance of 30 units | 2011-06-27 A | 2012-02-29 → 2013-06-17 A (+474d) | 166d → 388d | 0% → 100% | 372d → none |  |  |
| 13223051F | Vend Fab 20 Amp Trim Power Supplies - Peg Point #5 Third Delivery and Acceptance of 30 units | 2012-01-03 A | 2012-03-30 → 2013-07-15 A (+472d) | 62d → 287d | 0% → 100% | 381d → none | 13223051D FS-40d → 13223051D FS-120d |  |
| 13223051G | Vend Fab 20 Amp Trim Power Supplies - Peg Point #6 Fourth Delivery and Acceptance of 30 units | 2012-01-03 A | 2012-04-30 → 2013-07-15 A (+441d) | 83d → 287d | 0% → 100% | 381d → none | 13223051F FS-62d → 13223051F FS-115d |  |
| 13223051H | Vend Fab 20 Amp Trim Power Supplies - Peg Point #7 Fifth Delivery and Acceptance of 30 units | 2012-01-03 A | 2012-05-31 → 2013-08-30 A (+456d) | 105d → 305d | 0% → 100% | 381d → none | 13223051G FS-83d → 13223051G FS-135d |  |
| 13223051J | Vend Fab 20 Amp Trim Power Supplies - Peg Point #8 Sixth Delivery and Acceptance of 30 units | 2012-01-03 A | 2012-06-29 → 2013-08-30 A (+427d) | 125d → 327d | 0% → 100% | 381d → none | 13223051H FS-105d → 13223051H FS-160d |  |
| 13223051K | Vend Fab 20 Amp Trim Power Supplies - Peg Point #9 Seventh Delivery and Acceptance of 30 units | 2012-01-03 A | 2012-07-31 → 2013-08-30 A (+395d) | 147d → 327d | 0% → 100% | 381d → none | 13223051J FS-125d → 13223051J FS-179d |  |
| 13223051N | Vend Fab 20 Amp Trim Power Supplies - Peg Point #10 Eighth Delivery and Acceptance of 30 units | 2012-01-03 A | 2012-08-31 → 2013-08-30 A (+364d) | 170d → 384d | 0% → 100% | 381d → none | 13223051K FS-147d → 13223051K FS-204d |  |
| 13223051P | Vend Fab 20 Amp Trim Power Supplies - Peg Point #11 Final Delivery and Acceptance of 20 units | 2012-01-03 A | 2012-09-28 → 2013-08-30 A (+336d) | 189d → 384d | 0% → 100% | 381d → none | 13223051N FS-170d → 13223051N FS-242d |  |
| 13223035 | Assemble Racks for 20 amp Trim PS (20 A TRIMS) Frozen per CR12-028 | 2011-04-29 → 2012-03-01 A (+307d) | 2011-09-30 → 2012-03-12 A (+164d) | 108d → 8d | 0% → 100% | 474d → none | 13223030 → 13223030 FS-10d | resources ELEC TECH [500 h]; SUPPLIES & MATERIALS → SUPPLIES & MATERIALS; ELEC TECH [500 h] |
| 13223035A | Reverse Entry Per CR12-028 | 2012-03-05 → 2012-03-01 A (-4d) | 2012-03-23 → 2012-03-12 A (-11d) | 15d → 8d | 0% → 100% | 132d → none | 9-120M FS+100d → 9-120M |  |
| 13223052 | Receive , Inspect, Test PS (20 A Trims) P1 Frozen Per CR 12-028 | 2011-11-10 → 2012-03-01 A (+112d) | 2012-03-29 → 2012-03-12 A (-17d) | 91d → 8d | 0% → 100% | 384d → none |  | resources TRAVEL; ELEC TECH [120 h] → ELEC TECH [120 h]; TRAVEL |
| 13223036 | Assemble Racks for 20 amp Trims Part A | 2012-04-02 A | 2012-07-09 → 2012-09-17 A (+70d) | 69d → 118d | 0% → 100% | 195d → none |  |  |
| 13223050 | Monitor Production and Delvery of PS (20 A Trims) P1 (original Labor and Expenses) | 2011-04-29 → 2012-04-02 A (+339d) | 2011-09-30 → 2012-09-17 A (+353d) | 108d → 118d | 0% → 100% | 470d → none |  | was named Monitor Production and Delvery of PS (20 A Trims) P1(original Labor and Expenses); resources ELEC ENG [20 h]; ELEC DES [30 h]; TRAVEL → ELEC ENG [20 h]; TRAVEL; ELEC DES [30 h] |
| 13223110 | SRCC 20 Amp PS PS Procurement | 2012-07-03 → 2012-05-01 A (-63d) | 2012-10-31 → 2013-08-30 A (+303d) | 86d → 173d | 0% → 100% | 132d → none | 9-120M FS+184d → 9-120M |  |
| 13223010 | Relocate and Reuse Trim Hardware for Hall D | 2012-05-14 A | 2012-08-07 → 2013-05-13 A (+279d) | 60d → 177d | 0% → 100% | 359d → none |  | resources ELEC TECH [120 h]; SUPPLIES & MATERIALS; ELEC ENG [20 h]; SKLLD TRADE [40 h] → ELEC ENG [20 h]; SKLLD TRADE [40 h]; SUPPLIES & MATERIALS; ELEC TECH [120 h] |
| 13223051Q | ** Option** Vend Fab 20 Amp Trim Power Supplies - Peg Point #12 Delivery and Acceptance of 10 units | 2012-01-03 → 2012-09-17 A (+258d) | 2012-09-28 → 2013-08-30 A (+336d) | 189d → 205d | 0% → 100% | 381d → none | 13223051P FS-189d → 13223051P FS-200d, 9-130M |  |
| 13223036A | Assemble Racks for 20 amp Trims Part B | 2012-10-01 A | 2013-02-14 → 2013-07-15 A (+151d) |  | 0% → 100% | 137d → none |  |  |
| 13223051 | Monitor Production and Delvery of PS (20 A Trims) P2 (original Labor and Expenses) | 2011-10-03 → 2012-10-01 A (+364d) | 2012-05-11 → 2013-08-30 A (+476d) | 150d → 198d | 0% → 100% | 578d → none |  | resources TRAVEL; ELEC ENG [20 h]; ELEC DES [30 h] → ELEC ENG [20 h]; ELEC DES [30 h]; TRAVEL |
| 13223100 | SRCC Engineering Design, Planning and Oversight | 2012-10-01 → 2012-11-12 A (+42d) | 2012-11-30 → 2013-04-08 A (+129d) | 43d → 36d | 0% → 100% | 75d → none |  |  |
| 13223105 | SRCC Drafting | 2012-12-03 → 2012-11-12 A (-21d) | 2012-12-31 → 2013-08-12 A (+224d) | 16d → 29d | 0% → 100% | 75d → none | 13223100 → 13223100 FS-40d |  |
| 13223112 | SRCC Cable & Misc Procurement | 2012-10-01 → 2012-12-03 A (+63d) | 2013-01-31 → 2012-12-17 A (-45d) | 80d → 60d | 0% → 100% | 75d → none |  |  |
| 13223120 | SRCC Cable Installation, Termination and Hook-up | 2013-03-04 → 2012-12-03 A (-91d) | 2013-04-30 → 2013-08-12 A (+104d) |  | 0% → 100% | 75d → none | 13223112, 13223115, 13223110 → 13223110 FS-35d, 13223112, 13223115 FS-45d |  |
| 13223115 | SRCC PS and Rack installation | 2013-02-01 → 2013-01-07 A (-25d) | 2013-03-01 → 2013-08-13 A (+165d) |  | 0% → 100% | 75d → none | 13223112, 13223110 → 13223112, 13223110 FS-25d |  |
| 13223020 | Reconfigure 10 Amp Trim System (Arc 10 Hall D) (10 A TRIMS) | 2012-10-01 → 2013-04-01 A (+182d) | 2013-05-01 → 2013-07-15 A (+75d) | 143d → 33d | 0% → 100% | 158d → none | 3A-22M, 9-130M → 9-130M FS+120d, 3A-22M |  |
| 13223052A | Receive , Inspect, Test PS (20 A Trims) P1 Revised Per CR 12-028 | 2012-05-04 → 2013-04-01 A (+332d) | 2012-09-28 → 2013-08-30 A (+336d) | 103d → 77d | 0% → 100% | 256d → none | 9-120M FS+144d, 13223050 FS-70d, 13223051D FS-70d → 9-130M FS+43d, 13223051D FS-70d, 13223050 FS-70d, 9-120M FS+144d | resources ELEC TECH [160 h]; ELEC ENG [40 h]; TRAVEL → TRAVEL; ELEC TECH [160 h]; ELEC ENG [40 h] |
| 13223055 | Install PS in Racks (20 A Trims) Part A | 2012-07-04 → 2013-06-03 A (+334d) | 2012-09-28 → 2013-08-30 A (+336d) | 62d → 40d | 0% → 100% | 256d → none | 13223052A FS-225d, 13223053 FS-125d, 13223052 FS-225d → 13223053 FS-125d, 13223052A FS-60d, 13223052 |  |
| 13223015 | Test Trim Rack Hardware (10 ATRIMS) | 2012-10-01 → 2013-08-12 A (+315d) | 2012-11-30 → 2013-08-30 A (+273d) | 43d → 65d | 0% → 100% | 322d → none | 13223010, 9-130M → 13223010, 9-130M FS+120d | resources ELEC TECH [40 h]; ELEC ENG [20 h] → ELEC ENG [20 h]; ELEC TECH [40 h] |
| 13223025 | Assemble & Test 10 amp Trim System (10 A TRIMS) | 2013-05-02 → 2013-08-30 A (+120d) | 2013-08-01 → 2013-08-30 A (+29d) | 64d → 39d | 0% → 100% | 158d → none |  |  |
| 13223053 | Receive , Inspect, Test PS (20 A Trims) P2 | 2012-10-01 → 2013-08-30 A (+333d) | 2013-01-07 → 2013-08-30 A (+235d) | 63d → 64d | 0% → 100% | 256d → none | 13223052, 13223051Q FS-125d, 13223052A, 13223051 FS-225d → 13223052A, 13223051Q FS-189d, 13223051 FS-225d, 13223052 |  |
| 13223055A | Install PS in Racks (20 A Trims) Part B | 2012-10-01 → 2013-08-30 A (+333d) | 2013-03-04 → 2013-08-30 A (+179d) | 101d → 65d | 0% → 100% | 256d → none |  |  |
| 13223060 | Integration Testing of PS (20 A Trims) | 2013-02-15 → 2013-08-30 A (+196d) | 2013-08-30 A | 138d → 75d | 0% → 100% | 137d → none |  | resources ELEC TECH [197.15 h]; COMP SCIENT [118.29 h]; SUPPLIES & MATERIALS; ELEC ENG [23.66 h] → ELEC ENG [23.66 h]; ELEC TECH [197.15 h]; COMP SCIENT [118.29 h]; SUPPLIES & MATERIALS |
| 13223125 | SRCC System Q.A., Testing and Documentation | 2013-05-01 → 2013-08-30 A (+121d) | 2013-05-29 → 2013-08-30 A (+93d) |  | 0% → 100% | 75d → none |  | resources ELEC TECH [80 h]; COMP SCIENT [40 h]; ELEC ENG [40 h] → ELEC ENG [40 h]; ELEC TECH [80 h]; COMP SCIENT [40 h] |
| 13223130 | Re-Baseline Actuals Adjustment | 2013-08-30 A | 2013-08-30 A |  | 0% → 100% | 20d → none | 9-130M FS+227d → none |  |
| 23223025 | Assemble & Test 10 amp Trim System (10 A TRIMS) FY13 | 2013-09-03 A | 2013-09-30 → 2013-11-27 (+58d) | 20d → 39d | 0% → 10% | 97d → 74d |  |  |
| 23223025a | Assemble & Test 10 amp Trim System (10 A TRIMS) FY14 | 2013-10-01 → 2013-09-03 A (-28d) | 2013-10-25 → 2013-11-27 (+33d) |  | 0% → 10% | 97d → 74d | 23223025, 9-130M FS+228d → 23223025 FS-20d |  |
| 23223051H | Vend Fab 20 Amp Trim Power Supplies - Peg Point #7 Fifth Delivery and Acceptance of 30 units | 2013-09-03 A | 2013-09-30 → 2013-09-23 A (-7d) |  | 0% → 100% | 53d → none |  | resources PROCUREMENT<$50K 60 NO ESCALATION; PROCUREMENT>$50K 69 NO ESCALATION → PROCUREMENT>$50K 69 NO ESCALATION |
| 23223051J | Vend Fab 20 Amp Trim Power Supplies - Peg Point #8 Sixth Delivery and Acceptance of 30 units | 2013-09-03 A | 2013-10-31 → 2013-12-05 (+35d) |  | 0% → 40% | 53d → 110d |  |  |
| 23223051K | Vend Fab 20 Amp Trim Power Supplies - Peg Point #9 Seventh Delivery and Acceptance of 30 units | 2013-09-03 A | 2013-11-27 → 2014-01-13 (+47d) |  |  | 53d → 90d |  |  |

| ID | Task | Start | Finish | Duration | Complete | Total float | Predecessors | Other |
| --- | --- | --- | --- | --- | --- | --- | --- | --- |
| 23223051N | Vend Fab 20 Amp Trim Power Supplies - Peg Point #10 Eighth Delivery and Acceptance of 30 units | 2013-09-03 A | 2013-11-27 → 2014-01-13 (+47d) |  |  | 53d → 70d |  |  |
| 23223051P | Vend Fab 20 Amp Trim Power Supplies - Peg Point #11 Final Delivery and Acceptance of 20 units | 2013-09-03 A | 2013-12-20 → 2014-02-04 (+46d) |  |  | 53d → 50d |  |  |
| 23223051Q | ** Option** Vend Fab 20 Amp Trim Power Supplies - Peg Point #12 Delivery and Acceptance of 10 units | 2013-09-03 A | 2014-01-31 → 2014-03-05 (+33d) |  |  | 53d → 30d |  |  |
| 23223052A | Receive , Inspect, Test PS (20 A Trims) P1 FY13 | 2013-09-03 A | 2013-09-30 A | 20d → 21d | 0% → 100% | 37d → none |  |  |
| 23223052Aa | Receive , Inspect, Test PS (20 A Trims) P1 FY14 | 2013-10-01 → 2013-09-03 A (-28d) | 2013-10-01 → 2013-09-30 A (-1d) |  | 0% → 100% | 37d → none | 23223052A, 9-130M FS+228d → 23223052A |  |
| 23223053 | Receive , Inspect, Test PS (20 A Trims) P2 Procurement | 2013-09-03 A |  |  |  | 52d → 95d | 23223052A FS-21d, 23223052Aa FS-21d → 23223052A FS-21d | resources TRAVEL; ELEC TECH; PROCUREMENT<$50K 60 NO ESCALATION FY14 → TRAVEL; ELEC TECH; PROCUREMENT<$50K 60 |
| 23223054 | Receive , Inspect, Test PS (20 A Trims) P2 Labor/Expenses FY13 | 2013-09-03 A | 2013-09-30 → 2014-01-08 (+100d) |  |  | 52d → 101d | 23223052A FS-21d, 23223052Aa FS-21d → 23223052Aa FS-25d |  |
| 23223054a | Receive , Inspect, Test PS (20 A Trims) P2 Labor/Expenses FY14 | 2013-10-01 → 2013-09-03 A (-28d) | 2013-11-27 → 2014-01-08 (+42d) |  |  | 52d → 75d | 23223052A FS-21d, 23223054, 23223052Aa FS-21d → 23223052Aa FS-50d, 23223054 FS-65d |  |
| 23223055 | Install PS in Racks (20 A Trims) Part A FY13 | 2013-09-03 A | 2013-09-30 → 2013-09-23 A (-7d) | 20d → 31d | 0% → 100% | 37d → none | 23223052A FS-21d, 23223052Aa FS-21d, 23223053a FS-101d → 23223052A FS-21d, 23223053a FS-101d |  |
| 23223055b | Install PS in Racks (20 A Trims) Part A FY14 | 2013-10-01 → 2013-09-03 A (-28d) | 2013-10-15 → 2013-09-23 A (-22d) |  | 0% → 100% | 37d → none | 23223052A FS-21d, 23223053a FS-101d, 23223055, 23223052Aa FS-21d → 23223052Aa FS-21d, 23223055 |  |
| 23223110 | SRCC 20 Amp PS PS Procurement | 2013-09-03 A |  |  |  | 42d → 158d |  | resources PROCUREMENT>$50K 69 NO ESCALATION → PROCUREMENT<$50K 60 NO ESCALATION FY14 |
| 23223015 | Test Trim Rack Hardware (10 ATRIMS) FY13 | 2013-09-03 → 2013-09-23 A (+20d) | 2013-09-30 → 2013-11-27 (+58d) | 20d → 39d | 0% → 50% | 97d → 74d |  |  |
| 23223015a | Test Trim Rack Hardware (10 ATRIMS) FY14 | 2013-10-01 → 2013-09-23 A (-8d) | 2013-10-25 → 2013-11-27 (+33d) |  | 0% → 50% | 97d → 74d | 9-130M FS+228d, 23223015 → 23223015 FS-20d |  |
| 23223060 | Integration Testing of PS (20 A Trims) Part A | 2013-10-02 → 2013-10-01 A (-1d) |  |  | 0% → 15% |  |  |  |
| 23223125 | SRCC System Q.A., Testing and Documentation Part A FY13 | 2013-09-03 → 2013-11-01 (+59d) | 2013-09-30 → 2014-01-13 (+105d) | 20d → 42d |  | 42d → 115d |  |  |
| 23223125b | SRCC System Q.A., Testing and Documentation Part A FY14 | 2013-10-01 → 2013-11-01 (+31d) | 2013-11-27 → 2014-01-13 (+47d) |  |  | 42d → 115d | 23223110 FS-67d, 23223125 → 23223125 FS-45d |  |
| 23223055A | Install PS in Racks (20 A Trims) Part B | 2013-11-20 → 2013-12-20 (+30d) | 2014-01-23 → 2014-02-20 (+28d) |  |  | 96d → 98d |  |  |
| 23223053a | Receive , Inspect, Test PS (20 A Trims) P3 | 2013-12-02 → 2014-01-09 (+38d) | 2014-01-14 → 2014-02-12 (+29d) |  |  | 52d → 75d | 23223053, 23223054a, 23223054 → 23223053, 23223054a |  |
| 23223125a | SRCC System Q.A., Testing and Documentation Part B | 2013-12-02 → 2014-01-14 (+43d) | 2013-12-06 → 2014-01-21 (+46d) |  |  | 42d → 115d |  |  |
| 4 | **1.3.2.2.4 INSTALLATION** |  | 2013-11-06 → 2013-12-09 (+33d) |  |  |  |  |  |
| 13224000LOE | Installation Coordination FY10 | 2010-06-11 A | 2010-09-30 A |  | 0% → 100% | 237d → none |  |  |
| 13224001LOE | Installation Coordination FY11 | 2010-10-01 A | 2011-09-30 A |  | 0% → 100% | 237d → none |  |  |
| 13224005 | Proc Box PS Load Cable/Hardware (Installtn) | 2010-10-01 → 2010-11-15 A (+45d) | 2011-01-04 → 2012-02-20 A (+412d) | 60d → 308d | 0% → 100% | 434d → none |  | resources PROCUREMENT<$50K 60; ELEC DES [40 h] → ELEC DES [40 h]; PROCUREMENT<$50K 60 |
| 13224010 | Proc Trim Mag & Shunt Cable (Installtn) | 2010-10-01 → 2010-11-15 A (+45d) | 2011-01-04 → 2011-01-31 A (+27d) | 60d → 47d | 0% → 100% | 434d → none |  |  |
| 13224015 | Proc Trim Sys AC Pwr, Controls & Interlock Cable (Installtn) | 2010-10-01 → 2010-11-15 A (+45d) | 2011-01-04 → 2012-03-27 A (+448d) | 60d → 334d | 0% → 100% | 434d → none |  | resources PROCUREMENT<$50K 60; ELEC DES [40 h] → ELEC DES [40 h]; PROCUREMENT<$50K 60 |
| 13224020 | Proc Box PS Cable Tray, AC Pwr Matrl's (Installtn) | 2010-10-01 → 2010-11-15 A (+45d) | 2011-01-04 → 2011-07-25 A (+202d) | 60d → 169d | 0% → 100% | 434d → none |  | resources PROCUREMENT<$50K 60; ELEC DES [40 h] → ELEC DES [40 h]; PROCUREMENT<$50K 60 |
| 13224025 | Proc DC Pwr Interconnect Hardware (Installtn) | 2010-10-01 → 2010-11-15 A (+45d) | 2011-01-04 → 2011-02-21 A (+48d) | 60d → 61d | 0% → 100% | 434d → none |  | resources PROCUREMENT<$50K 60; ELEC DES [40 h] → ELEC DES [40 h]; PROCUREMENT<$50K 60 |
| 13224030 | Proc LCW Manifolds/Hose for Arc & Septa PS (Installtn) | 2010-10-01 → 2010-11-15 A (+45d) | 2011-01-04 → 2011-07-24 A (+201d) | 60d → 168d | 0% → 100% | 434d → none |  |  |
| 13224040A | SAB Box Supply Infrastructure Installation Work | 2011-03-21 → 2011-03-01 A (-20d) | 2011-07-12 → 2011-08-23 A (+42d) | 80d → 124d | 0% → 100% | 488d → none |  | resources ELEC ENG [40 h]; SKLLD TRADE [880 h]; SUPPLIES & MATERIALS; ELEC DES [40 h] → SKLLD TRADE [880 h]; SUPPLIES & MATERIALS; ELEC DES [40 h]; ELEC ENG [40 h] |
| 13224040 | NAB Box Supply Infrastructure Installation Work | 2011-03-21 → 2011-04-01 A (+11d) | 2011-07-12 → 2011-08-30 A (+49d) | 80d → 106d | 0% → 100% | 488d → none |  | resources ELEC DES [40 h]; ELEC ENG [40 h]; SKLLD TRADE [880 h]; SUPPLIES & MATERIALS → ELEC ENG [40 h]; ELEC DES [40 h]; SKLLD TRADE [880 h]; SUPPLIES & MATERIALS |
| 13224045 | Pull/Terminate Box PS Load Cable (Installtn) Arc 10/West Arc FY11 (FY12 @ 13224047) | 2011-05-13 A | 2011-09-30 → 2011-08-29 A (-32d) | 98d → 75d | 0% → 100% | 409d → none |  | resources ELEC DES [16.33 h]; ELEC ENG [16.33 h]; SKLLD TRADE [555.33 h] → ELEC ENG [16.33 h]; ELEC DES [16.33 h]; SKLLD TRADE [555.33 h] |
| 13224047 | Pull/Terminate Box PS Load Cable (Installtn) Arc 10/West Arc FY12 (FY11 @ 13224045) | 2011-10-03 → 2011-05-13 A (-143d) | 2011-11-01 → 2011-08-29 A (-64d) | 22d → 75d | 0% → 100% | 409d → none |  |  |
| 13224085 | Pull/Terminate Trim Mag & Shunt Cable (Installtn) | 2011-05-13 A | 2011-08-08 → 2012-08-20 A (+378d) | 60d → 317d | 0% → 100% | 581d → none |  | resources ELEC DES [20 h]; SKLLD TRADE [200 h]; ELEC TECH [80 h]; ELEC ENG [60 h] → ELEC ENG [60 h]; ELEC TECH [80 h]; ELEC DES [20 h]; SKLLD TRADE [200 h] |
| 13224085A | Pull/Terminate Trim Mag (Installtn) East Arc , S/R and BSY | 2012-10-01 → 2011-08-15 A (-413d) | 2013-01-31 → 2013-08-30 A (+211d) | 80d → 361d | 0% → 100% | 216d → none | 2-02M, 9-130M → 2-02M FS-175d |  |
| 13224002LOE | Installation Coordination FY12 | 2011-10-03 A | 2012-09-28 A |  | 0% → 100% | 237d → none |  |  |
| 13224050 | Pull/Terminate Arc & H-D Klixon Cable (Installtn) Frozen Per CR12-028 | 2012-02-06 → 2012-03-01 A (+24d) | 2012-02-29 → 2012-03-12 A (+12d) | 17d → 8d | 0% → 100% | 409d → none | 9-120M FS+81d, 16332030 FS+40d → 16332030 FS+5d, 9-120M FS+120d | resources ELEC TECH [34 h]; SKLLD TRADE [170 h]; ELEC DES [8.5 h]; ELEC ENG [8.5 h] → ELEC ENG [8.5 h]; ELEC TECH [34 h]; SKLLD TRADE [170 h]; ELEC DES [8.5 h] |
| 13224053 | Reverse Entry Per CR12-028 | 2012-03-05 → 2012-03-01 A (-4d) | 2012-03-23 → 2012-03-12 A (-11d) | 15d → 8d | 0% → 100% | 132d → none | 9-120M FS+100d → none | resources ELEC DES [-8.5 h]; ELEC TECH [-34 h]; SKLLD TRADE [-170 h]; ELEC ENG [-8.5 h] → ELEC TECH [-34 h]; SKLLD TRADE [-170 h]; ELEC ENG [-8.5 h]; ELEC DES [-8.5 h] |
| 13224080 | Install Trim Rack AC Pwr (Installtn) Part A | 2012-05-14 → 2012-03-02 A (-73d) | 2012-09-28 → 2013-04-14 A (+198d) | 97d → 201d | 0% → 100% | 216d → none | 13224075 FS-76d → 13224075 FS-104d |  |
| 13224044 | Label, Disconnect Pull Back SR Cables | 2012-05-14 A | 2012-09-28 → 2012-07-16 A (-74d) | 97d → 44d | 0% → 100% | 20d → none |  |  |
| 13224075 | Install Trim Racks (Installtn) | 2012-05-14 A | 2012-08-29 → 2012-10-22 A (+54d) | 76d → 113d | 0% → 100% | 216d → none |  |  |
| 13224085B | Pull & Terminate Shunt Cable (Remove Old Cable)-Part A | 2012-05-14 → 2012-06-05 A (+22d) | 2012-09-28 → 2012-08-20 A (-39d) | 97d → 55d | 0% → 100% | 300d → none |  |  |
| 13224085C | Pull & Terminate Shunt Cable (Remove Old Cable)-Part B | 2012-10-01 → 2012-09-03 A (-28d) | 2013-02-01 → 2013-07-15 A (+164d) | 81d → 100d | 0% → 100% | 300d → none |  |  |
| 13224003LOE | Installation Coordination FY13 | 2012-10-01 A | 2013-08-30 A | 228d → 248d | 0% → 100% | 237d → none |  | was named Installation Coordination FY13 *** Re-Baseline Split |
| 13224050A | Cable Tray Install Hall D Tunnel | 2012-12-03 → 2012-10-01 A (-63d) | 2013-02-05 → 2012-10-22 A (-106d) | 40d → 16d | 0% → 100% | 101d → none |  |  |
| 13224095 | Install Trim Comm/Controls Cable (Installtn) FY12 | 2012-08-30 → 2012-11-05 A (+67d) | 2012-09-28 → 2012-11-19 A (+52d) | 21d → 11d | 0% → 100% | 287d → none | 13224075 → 13224075 FS+61d | resources ELEC TECH [350 h]; ELEC ENG [28 h]; ELEC DES [56 h] → ELEC DES [56 h]; ELEC TECH [350 h]; ELEC ENG [28 h] |
| 13224095a | Install Trim Comm/Controls Cable (Installtn) FY13 | 2012-10-01 → 2012-11-19 A (+49d) | 2012-10-11 → 2012-12-17 A (+67d) | 9d → 73d | 0% → 100% | 287d → none |  |  |
| 13224052 | Pull/Terminate Arc & H-D Klixon Cable (Installtn) Revised Per CR12-028 | 2012-12-03 A | 2013-02-05 → 2013-07-15 A (+160d) |  | 0% → 100% | 177d → none |  |  |
| 13224055 | Connect Arc & Hall Mag Load & Klixon Cables (Installtn) | 2013-06-03 → 2013-01-07 A (-147d) | 2013-08-30 A | 64d → 184d | 0% → 100% | 20d → none | 13224050A, 13221135 FS-58d, 13221115, 13224045A, 13224040, 13224047, 13224040A → 13224050A, 13224050, 13224040A, 13224040, 13221115 FS-10d, 13221135 FS-110d, 13224047, 13224045A FS-110d | was named Connect Arc & Hall Mag Load & Klixon Cables (Installtn) *** Re-Baseline Split; resources SKLLD TRADE [83.48 h]; ELEC TECH [55.65 h] → ELEC TECH [55.65 h]; SKLLD TRADE [83.48 h] |
| 13224045A | Pull/Terminate Box PS Load Cable (Installtn) East Arc, S/R,BSY and Extraction | 2012-10-01 → 2013-01-14 A (+105d) | 2013-05-31 → 2013-04-15 A (-46d) | 164d → 104d | 0% → 100% | 20d → none | 13224044, 2-02M, 9-130M, 13221115 → 2-02M, 13224044, 13221115 FS-50d, 9-130M FS+60d |  |
| 13224100 | Update/Install/Test Mag Controls Software (Installtn) | 2012-10-01 → 2013-03-04 A (+154d) | 2013-05-10 → 2013-08-30 A (+112d) |  | 0% → 100% | 108d → none |  |  |
| 13224090 | Pull/terminate/Connect Trim Mag Load Cable - H-D (Installtn) | 2012-10-01 → 2013-05-03 A (+214d) | 2013-03-28 → 2013-07-15 A (+109d) | 119d → 45d | 0% → 100% | 177d → none |  | resources ELEC ENG [20 h]; ELEC DES [20 h]; SKLLD TRADE [200 h] → ELEC DES [20 h]; SKLLD TRADE [200 h]; ELEC ENG [20 h] |
| 13224080A | Install Trim Rack AC Pwr (Installtn) Part B | 2012-10-01 → 2013-06-01 A (+243d) | 2013-01-31 → 2013-07-15 A (+165d) | 80d → 35d | 0% → 100% | 216d → none |  |  |
| 13224087 | BSY Serv. Bldg Infrastructure Installation- Tray, Power, Water, Controls | 2012-10-01 → 2013-06-01 A (+243d) | 2013-01-07 → 2013-08-30 A (+235d) | 63d → 9d | 0% → 100% | 318d → none | 9-130M → 9-130M FS+184d | resources ELEC TECH [200 h]; ELEC ENG [40 h]; SKLLD TRADE [400 h] → ELEC ENG [40 h]; SKLLD TRADE [400 h]; ELEC TECH [200 h] |
| 13224110 | Intergation , Inspection, Test Trim PS (Installtn) | 2013-03-29 → 2013-08-30 A (+154d) | 2013-07-05 → 2013-08-30 A (+56d) |  | 0% → 100% | 177d → none | 13224095a, 13224080, 13224090, 13224085A, 13224080A, 13224085 → 13224080, 13224080A, 13224095a FS-25d, 13224090, 13224085, 13224085A | resources SUPPLIES & MATERIALS; ELEC ENG [40 h]; ELEC TECH [500 h]; ELEC DES [80 h] → ELEC TECH [500 h]; ELEC DES [80 h]; SUPPLIES & MATERIALS; ELEC ENG [40 h] |
| 13224115 | Re-Baseline Actuals Adjustment | 2013-08-30 A | 2013-08-30 A |  | 0% → 100% | 20d → none | 9-130M FS+227d → none |  |
| 23224003LOE | Installation Coordination FY13 | 2013-09-03 A | 2013-09-30 A |  | 0% → 100% | 216d → none |  |  |
| 23224045A | Pull/Terminate Box PS Load Cable (Installtn) East Arc, S/R,BSY and Extraction - Procurement | 2013-09-03 A | 2013-11-06 → 2013-10-21 A (-16d) |  | 0% → 100% | 18d → none |  | was named Pull/Terminate Box PS Load Cable (Installtn) East Arc, S/R,BSY and Extraction Procurement; resources ELEC TECH; SUPPLIES & MATERIALS; SKLLD TRADE; PROCUREMENT<$50K 60 NO ESCALATION FY14 → ELEC TECH; SUPPLIES & MATERIALS; SKLLD TRADE; PROCUREMENT<$50K 60 |
| 23224045Aa | Pull/Terminate Box PS Load Cable (Installtn) East Arc, S/R,BSY and Extraction Labor/Expenses FY13 | 2013-09-03 A | 2013-09-30 → 2013-11-11 (+42d) |  | 0% → 40% | 18d → 86d |  |  |
| 23224045Ab | Pull/Terminate Box PS Load Cable (Installtn) East Arc, S/R,BSY and Extraction Labor/Expenses FY14 | 2013-10-01 → 2013-09-03 A (-28d) | 2013-11-06 → 2013-11-11 (+5d) |  | 0% → 40% | 18d → 86d | 23224045Aa, 9-130M FS+228d → 23224045Aa FS-30d |  |
| 23224055 | Connect Arc & Hall Mag Load & Klixon Cables (Installtn) FY13 | 2013-09-03 A | 2013-09-30 → 2013-11-11 (+42d) | 20d → 47d | 0% → 40% | 18d → 46d | 23224045Ab FS-47d, 2813221005 FS-110d, 23224045A FS-47d, 2813221005a FS-110d, 23224045Aa FS-47d → 23224045A FS-47d, 2813221005 FS-110d, 2813221005a FS-110d |  |
| 23224055a | Connect Arc & Hall Mag Load & Klixon Cables (Installtn) FY14 | 2013-10-01 → 2013-09-03 A (-28d) | 2013-11-06 → 2013-11-11 (+5d) |  | 0% → 40% | 18d → 46d | 2813221005a FS-110d, 23224045Ab FS-47d, 23224045A FS-47d, 23224045Aa FS-47d, 23224055, 2813221005 FS-110d → 23224055 FS-30d, 23224045Aa FS-47d, 23224045Ab FS-47d |  |
| 23224085A | Pull/Terminate Trim Mag (Installtn) East Arc , S/R and BSY FY13 | 2013-09-03 A | 2013-09-30 → 2013-09-23 A (-7d) | 20d → 42d | 0% → 100% | 36d → none |  |  |
| 23224085Aa | Pull/Terminate Trim Mag (Installtn) East Arc , S/R and BSY FY14 | 2013-10-01 → 2013-09-03 A (-28d) | 2013-10-30 → 2013-09-23 A (-37d) | 22d → 15d | 0% → 100% | 36d → none | 23224085A, 9-130M FS+228d → 23224085A |  |
| 23224087 | BSY Serv. Bldg Infrastructure Installation- Tray, Power, Water, Controls FY13 | 2013-09-03 A | 2013-09-30 → 2013-12-04 (+65d) | 20d → 42d | 0% → 39% | 283d → 260d |  | resources ELEC ENG [9.52 h]; SKLLD TRADE [95.24 h]; SUPPLIES & MATERIALS; ELEC TECH [47.62 h] → ELEC TECH [47.62 h]; ELEC ENG [9.52 h]; SKLLD TRADE [95.24 h]; SUPPLIES & MATERIALS |
| 23224087a | BSY Serv. Bldg Infrastructure Installation- Tray, Power, Water, Controls FY14 | 2013-10-01 → 2013-09-03 A (-28d) | 2013-10-30 → 2013-12-04 (+35d) |  | 0% → 39% | 283d → 260d | 9-130M FS+228d, 23224087 → 23224087 FS-30d |  |
| 23224100 | Update/Install/Test Mag Controls Software (Installtn) FY13 | 2013-09-03 A | 2013-09-30 → 2013-12-09 (+70d) | 20d → 45d | 0% → 65% | 25d → 77d |  |  |
| 23224100a | Update/Install/Test Mag Controls Software (Installtn) FY14 | 2013-10-01 → 2013-09-03 A (-28d) | 2013-11-04 → 2013-12-09 (+35d) |  | 0% → 65% | 25d → 77d | 23224100, 9-130M FS+228d → 23224100 FS-30d |  |
| 3 | **1.3.3 CRYOGENICS** | 2009-01-05 → 2009-04-16 (+101d) |  |  |  |  |  |  |
| 1 | **1.3.3.1 ACCELERATOR** | 2009-01-05 → 2009-07-01 (+177d) |  |  |  |  |  |  |
| 01 | **1.3.3.1.01 COMPRESSORS** | 2010-01-05 → 2010-03-08 (+62d) |  |  |  |  |  |  |

| ID | Task | Start | Finish | Duration | Complete | Total float | Predecessors | Other |
| --- | --- | --- | --- | --- | --- | --- | --- | --- |
| 1331.01000 | Vend Production CHL Helium Compressors (Original Labor) | 2010-01-05 → 2010-03-08 A (+62d) | 2010-02-26 → 2010-03-15 A (+17d) | 37d → 6d | 0% → 100% | 109d → none |  | resources MECH DES [24.16 h]; ELEC ENG [24.16 h]; TRAVEL; ELEC DES [24.16 h]; MECH ENG [24.16 h] → ELEC ENG [24.16 h]; TRAVEL; ELEC DES [24.16 h]; MECH ENG [24.16 h]; MECH DES [24.16 h] |
| 1331.01005 | Vend Production CHL Helium Compressors Oversight FY10 | 2010-03-08 A | 2010-09-30 A | 146d → 145.07d | 0% → 100% | 104d → none |  | resources TRAVEL; ELEC TECH [102.5 h]; ELEC DES [58 h]; ELEC ENG [58 h]; MECH DES [58 h]; MECH ENG [58 h]; MECH TECH [273 h] → MECH TECH [273 h]; TRAVEL; ELEC TECH [102.5 h]; ELEC ENG [58 h]; ELEC DES [58 h]; MECH ENG [58 h]; MECH DES [58 h] |
| 1331.01010 | Vend Fab CHL Helium Compressors Peg Point #1 Complete Preliminary Design Review | 2010-03-08 A | 2010-04-30 → 2010-03-29 A (-32d) | 40d → 16d | 0% → 100% | 31d → none |  |  |
| 1331.01015 | Vend Fab CHL Helium Compressors Peg Point #2 Placement of Order for Coolers | 2010-03-08 A | 2010-04-30 → 2010-04-26 A (-4d) | 40d → 36d | 0% → 100% | 40d → none |  |  |
| 1331.01020 | Vend Fab CHL Helium Compressors Peg Point #3 Placement of Order for Compressors | 2010-03-08 A | 2010-04-30 → 2010-04-26 A (-4d) | 40d → 36d | 0% → 100% | 40d → none |  |  |
| 1331.01025 | Vend Fab CHL Helium Compressors Peg Point #4 Placement of Order for Heat Exchangers | 2010-03-08 A | 2010-05-28 → 2010-04-30 A (-28d) | 60d → 40d | 0% → 100% | 40d → none |  |  |
| 1331.01030 | Vend Fab CHL Helium Compressors Peg Point #5 Placement of Order for Motors | 2010-03-08 A | 2010-05-28 → 2010-04-26 A (-32d) | 60d → 36d | 0% → 100% | 40d → none |  |  |
| 1331.01035 | Vend Fab CHL Helium Compressors Peg Point #6 CDR Complete | 2010-03-08 A | 2010-06-30 → 2010-12-13 A (+166d) | 82d → 196d | 0% → 100% | 40d → none |  |  |
| 1331.01040 | Vend Fab CHL Helium Compressors Peg Point #7 Final Drawing Approval | 2010-03-08 A | 2010-08-31 → 2011-01-24 A (+146d) | 125d → 219d | 0% → 100% | 40d → none |  |  |
| 1331.01045 | Vend Fab CHL Helium Compressors Peg Point #8 Receipt of Compressors | 2010-03-08 A | 2010-09-30 → 2010-10-14 A (+14d) | 146d → 156d | 0% → 100% | 40d → none |  |  |
| 1331.01050 | Vend Fab CHL Helium Compressors Peg Point #9 Receipt of Motors | 2010-03-08 A | 2010-10-29 → 2010-11-15 A (+17d) | 167d → 178d | 0% → 100% | 40d → none |  |  |
| 1331.01055 | Vend Fab CHL Helium Compressors Peg Point #10 Receipt of Heat Exchangers | 2010-03-08 A | 2010-10-29 → 2011-10-15 A (+351d) | 167d → 404d | 0% → 100% | 40d → none |  |  |
| 1331.01060 | Vend Fab CHL Helium Compressors Peg Point #11 Receipt of Coolers | 2010-03-08 A | 2010-12-30 → 2011-11-07 A (+312d) | 204d → 420d | 0% → 100% | 40d → none |  |  |
| 1331.01065 | Vend Fab CHL Helium Compressors Peg Point #12 Complete Installation of Motors | 2010-03-08 A | 2011-01-31 → 2011-03-25 A (+53d) | 224d → 262d | 0% → 100% | 40d → none |  |  |
| 1331.01070 | Vend Fab CHL Helium Compressors Peg Point #13 Complete Installation of Compressors | 2010-03-08 A | 2011-01-31 → 2011-03-25 A (+53d) | 224d → 262d | 0% → 100% | 40d → none |  |  |
| 1331.01075 | Vend Fab CHL Helium Compressors Peg Point #14 Complete Installation of Coolers | 2010-03-08 A | 2011-01-31 → 2011-11-23 A (+296d) | 224d → 432d | 0% → 100% | 40d → none |  |  |
| 1331.01080 | Vend Fab CHL Helium Compressors Peg Point #15 Complete Installation of Heat Exchangers | 2010-03-08 A | 2011-02-28 → 2011-11-23 A (+268d) | 243d → 432d | 0% → 100% | 40d → none |  |  |
| 1331.01085 | Vend Fab CHL Helium Compressors Peg Point #16 System Pressure, Leak Test | 2010-03-08 A | 2011-02-28 → 2011-12-12 A (+287d) | 243d → 443d | 0% → 100% | 40d → none |  |  |
| 1331.01090 | Vend Fab CHL Helium Compressors Peg Point #17 Installation of Electrical Panels, Instruments and Devices | 2010-03-08 A | 2011-02-28 → 2011-04-25 A (+56d) | 243d → 283d | 0% → 100% | 40d → none |  |  |
| 1331.01095 | Vend Fab CHL Helium Compressors Peg Point #18 Spare Parts Received by JLab | 2010-03-08 A | 2011-03-31 → 2011-06-08 A (+69d) | 266d → 314d | 0% → 100% | 40d → none |  |  |
| 1331.01100 | Vend Fab CHL Helium Compressors Peg Point #19 Complete User Rediness Review | 2010-03-08 A | 2011-07-29 → 2012-09-14 A (+413d) | 350d → 631d | 0% → 100% | 40d → none |  |  |
| 1331.01105 | Vend Fab CHL Helium Compressors Peg Point #20 Completion of Compressor System Commissioning | 2010-03-08 A | 2011-07-29 → 2012-09-14 A (+413d) | 350d → 631d | 0% → 100% | 40d → none |  |  |
| 1331.01110 | Vend Fab CHL Helium Compressors Peg Point #21 Completion of System Acceptance Testing and Report | 2010-03-08 A | 2011-09-30 → 2012-09-14 A (+350d) | 394d → 631d | 0% → 100% | 40d → none |  |  |
| 1331.01005A | Vend Production CHL Helium Compressors Oversight FY11 | 2010-10-01 A | 2011-06-30 A |  | 0% → 100% | 104d → none |  | resources ELEC ENG [77.84 h]; MECH DES [77.84 h]; MECH ENG [77.84 h]; MECH TECH [367 h]; TRAVEL; ELEC TECH [137.5 h]; ELEC DES [77.84 h] → MECH DES [77.84 h]; MECH ENG [77.84 h]; MECH TECH [367 h]; TRAVEL; ELEC TECH [137.5 h]; ELEC DES [77.84 h]; ELEC ENG [77.84 h] |
| 1331.01115 | Re-Baseline Actuals Adjustment | 2013-08-30 A | 2013-08-30 A |  | 0% → 100% | 20d → none | 9-130M FS+227d → none |  |
| 02 | **1.3.3.1.02 COLD BOXES** | 2009-01-05 → 2009-09-30 (+268d) |  |  |  |  |  |  |
| 1331.02000 | FY-09 Initial Labor (Planned) Procurement Support | 2009-01-05 → 2009-09-30 A (+268d) | 2009-09-30 A | 188d → 1d | 0% → 100% | 0d → none |  | resources MECH DES [151.61 h]; TRAVEL; SUPPLIES & MATERIALS; ELEC DES [90.97 h]; ELEC TECH [90.97 h]; MECH TECH [272.9 h]; MECH ENG [151.61 h] → MECH ENG [151.61 h]; TRAVEL; MECH DES [151.61 h]; SUPPLIES & MATERIALS; ELEC DES [90.97 h]; ELEC TECH [90.97 h]; MECH TECH [272.9 h] |
| 1331.02015 | Vend Fab- Peg Point 1: Contract Award | 2009-09-30 A | 2009-09-30 A |  | 0% → 100% | 0d → none | 1331.02000 FS-1d → 1331.02000 FS-188d | resources PROCUREMENT<$50K 60 NO ESCALATION; PROCUREMENT>$50K 69 NO ESCALATION → PROCUREMENT>$50K 69 NO ESCALATION; PROCUREMENT<$50K 60 NO ESCALATION |
| 1331.02020 | Vend Fab- Peg Point 3: Issue PO for Platefin Heat Exchangers& Absorbers | 2009-09-30 A | 2010-01-29 → 2010-03-05 A (+35d) | 79d → 103d | 0% → 100% | 0d → none |  |  |
| 1331.02025 | Vend Fab- Peg Point 2: Complete Preliminary Design Review | 2009-09-30 A | 2010-01-29 → 2010-02-10 A (+12d) | 79d → 87d | 0% → 100% | 0d → none |  |  |
| 1331.02030 | Vend Fab- Peg Point 4: Issue PO for Turbines & Cryogenic Valves | 2009-09-30 A | 2010-04-30 → 2010-04-26 A (-4d) | 143d → 139d | 0% → 100% | 40d → none |  |  |
| 1331.02035 | Vend Fab- Peg Point 7: Deliver Platefin Heat Exchangers& Absorbers | 2009-09-30 A | 2010-09-30 → 2010-09-27 A (-3d) | 249d → 246d | 0% → 100% | 40d → none |  |  |
| 1331.02040 | Vend Fab- Peg Point 4: Issue PO for Cold Box Shell | 2009-09-30 A | 2010-09-30 → 2010-11-15 A (+46d) | 249d → 281d | 0% → 100% | 40d → none |  |  |
| 1331.02045 | Vend Fab- Peg Point 8: Deliver Turbine Housing | 2009-09-30 A | 2010-11-30 → 2010-09-27 A (-64d) | 290d → 246d | 0% → 100% | 40d → none |  |  |
| 1331.02050 | Vend Fab- Peg Point 5: Complete Final Design Review | 2009-09-30 A | 2010-12-31 → 2010-09-30 A (-92d) | 308d → 249d | 0% → 100% | 40d → none |  |  |
| 1331.02055 | Vend Fab- Peg Point 10: Complete Internal Piping | 2009-09-30 A | 2011-06-30 → 2011-06-23 A (-7d) | 433d → 428d | 0% → 100% | 40d → none |  |  |
| 1331.02060 | Vend Fab- Peg Point 9: Complete Cold Box Shell | 2009-09-30 A | 2011-06-30 → 2011-05-31 A (-30d) | 433d → 411d | 0% → 100% | 40d → none |  |  |
| 1331.02065 | Vend Fab- Peg Point 11: Ship Cold Box | 2009-09-30 A | 2011-08-31 → 2012-03-09 A (+191d) | 476d → 602d | 0% → 100% | 40d → none |  |  |
| 1331.02070 | Vend Fab- Peg Point 12: Complete Installation | 2009-09-30 A | 2011-09-30 → 2012-08-17 A (+322d) | 497d → 715d | 0% → 100% | 40d → none |  |  |
| 1331.02075 | Vend Fab- Peg Point 14: Deliver Final Operating & Maintenance Manuals | 2009-09-30 A | 2011-10-31 → 2012-09-17 A (+322d) | 518d → 735d | 0% → 100% | 418d → none |  |  |
| 1331.02080 | Vend Fab Peg Point 13: Acceptance Test Complete & Report Delivered | 2009-09-30 A | 2012-03-30 → 2013-08-15 A (+503d) | 617d → 835d | 0% → 100% | 418d → none |  | was named Vend Fab- Peg Point 13: Acceptance Test Complete & Report Delivered |
| 1331.02001 | FY-10 Labor Procurement Support | 2009-10-01 → 2009-10-02 A (+1d) | 2010-09-30 A | 248d → 247d | 0% → 100% | 113d → none | 1331.02000, 9-100M → 1331.02000 FS-188d, 9-100M | resources MECH DES [132.21 h]; SUPPLIES & MATERIALS; ELEC DES [92.21 h]; ELEC TECH [92.21 h]; MECH TECH [276.63 h]; MECH ENG [132.21 h]; TRAVEL → SUPPLIES & MATERIALS; ELEC DES [92.21 h]; ELEC TECH [92.21 h]; MECH TECH [276.63 h]; MECH ENG [132.21 h]; TRAVEL; MECH DES [132.21 h] |
| 1331.02012 | He Dewar Procurement | 2009-10-15 → 2010-03-01 A (+137d) | 2010-05-28 → 2010-11-15 A (+171d) | 152d → 183d | 0% → 100% | 374d → none |  | resources PROCUREMENT>$50K 69 NO ESCALATION; PROCUREMENT<$50K 60 NO ESCALATION → PROCUREMENT<$50K 60 NO ESCALATION; PROCUREMENT>$50K 69 NO ESCALATION |
| 1331.02085 | Additional Funds for Currency Exchange Rate | 2010-03-01 A | 2010-03-12 A |  | 0% → 100% | 40d → none |  |  |
| 1331.02090 | Spare Turbine and Seal Kits | 2010-03-01 → 2010-03-17 A (+16d) | 2010-05-28 A | 65d → 53d | 0% → 100% | 353d → none |  |  |
| 1331.02005 | FY-11 Labor Procurement Support | 2010-10-01 A | 2011-09-30 A |  | 0% → 100% | 295d → none | 9-100M FS+60d, 32-02M, 1331.02000, 1331.02001 → 9-100M FS+60d, 1331.02001, 32-02M FS+125d, 1331.02000 | resources MECH TECH [276.63 h]; ELEC TECH [92.21 h]; SUPPLIES & MATERIALS; MECH ENG [132.21 h]; MECH DES [132.21 h]; ELEC DES [92.21 h]; TRAVEL → TRAVEL; MECH TECH [276.63 h]; ELEC TECH [92.21 h]; SUPPLIES & MATERIALS; MECH ENG [132.21 h]; MECH DES [132.21 h]; ELEC DES [92.21 h] |
| 1331.02052 | Vend Fab- Peg Point 15: Venturi Flow Measurement | 2011-01-04 A | 2011-02-28 → 2011-04-25 A (+56d) | 38d → 78d | 0% → 100% | 40d → none |  |  |
| 1331.02068 | Vend Fab- Peg Point 16: Re-rout Transfer Lines | 2011-01-04 A | 2011-09-30 → 2011-05-31 A (-122d) | 189d → 103d | 0% → 100% | 40d → none | 1331.02052 FS-38d, 1331.02065 FS-168d → 1331.02065 FS-168d, 1331.02052 FS-85d | resources PROCUREMENT<$50K 60 NO ESCALATION; PROCUREMENT>$50K 69 NO ESCALATION → PROCUREMENT>$50K 69 NO ESCALATION; PROCUREMENT<$50K 60 NO ESCALATION |
| 1331.02010 | FY-12 Labor Procurement Support | 2011-10-03 A | 2012-03-30 A |  | 0% → 100% | 295d → none |  | resources MECH DES [63.97 h]; MECH TECH [133.85 h]; SUPPLIES & MATERIALS; ELEC DES [44.62 h]; ELEC TECH [44.62 h]; MECH ENG [63.97 h]; TRAVEL → ELEC DES [44.62 h]; ELEC TECH [44.62 h]; MECH ENG [63.97 h]; TRAVEL; MECH DES [63.97 h]; MECH TECH [133.85 h]; SUPPLIES & MATERIALS |
| 1331.02066 | Vend Fab- Peg Point 17: Cold Box Shipping Costs | 2011-11-01 A | 2011-12-30 → 2012-03-16 A (+77d) | 37d → 89d | 0% → 100% | 480d → none | 1331.02065 FS+42d → 1331.02065 FS-30d | resources PROCUREMENT<$50K 60 NO ESCALATION; PROCUREMENT>$50K 69 NO ESCALATION → PROCUREMENT>$50K 69 NO ESCALATION; PROCUREMENT<$50K 60 NO ESCALATION |
| 1331.02100 | Re-Baseline Actuals Adjustment | 2013-08-30 A | 2013-08-30 A |  | 0% → 100% | 20d → none | 9-130M FS+227d → none |  |
| 03 | **1.3.3.1.03 OIL REMOVAL SKIDS** | 2011-01-05 → 2010-02-08 (-331d) |  |  |  |  |  |  |
| 1331.03000 | Fab Oil Removl Skids | 2011-01-05 → 2010-02-08 A (-331d) | 2011-06-17 → 2010-11-15 A (-214d) | 115d → 197d | 0% → 100% | 113d → none | 32-03M, 9-110M FS+60d → 32-03M FS-60d | resources MECH TECH [400 h]; ELEC ENG [40 h]; ELEC TECH [120 h]; PROCUREMENT<$50K 60; PROCUREMENT>$50K 69; MECH DES [40 h]; MECH ENG [40 h] → ELEC TECH [120 h]; PROCUREMENT>$50K 69; PROCUREMENT<$50K 60; MECH ENG [40 h]; MECH DES [40 h]; MECH TECH [400 h]; ELEC ENG [40 h] |
| 1331.03005 | Re-Baseline Actuals Adjustment | 2013-08-30 A | 2013-08-30 A |  | 0% → 100% | 20d → none | 9-130M FS+227d → none |  |
| 06 | **1.3.3.1.06 CHL GAS MANAGEMENT RACK** | 2011-01-05 → 2009-07-01 (-553d) |  |  |  |  |  |  |
| 1331.06000 | Fab CHL Gas Mngmnt Rack | 2011-01-05 → 2009-07-01 A (-553d) | 2011-05-12 → 2010-09-27 A (-227d) | 90d → 309d | 0% → 100% | 138d → none | 9-110M FS+60d → 9-090M | resources MECH ENG [40 h]; PROCUREMENT<$50K 60; ELEC TECH [240 h]; SUPPLIES & MATERIALS; ELEC ENG [40 h]; MECH TECH [600 h]; MECH DES [40 h] → MECH DES [40 h]; ELEC ENG [40 h]; MECH TECH [600 h]; PROCUREMENT<$50K 60; ELEC TECH [240 h]; SUPPLIES & MATERIALS; MECH ENG [40 h] |
| 1331.06005 | Re-Baseline Actuals Adjustment | 2013-08-30 A | 2013-08-30 A |  | 0% → 100% | 20d → none | 9-130M FS+227d → none |  |
| 07 | **1.3.3.1.07 CHL SYSTEM INSTRUMENTATION & CONTROL** | 2010-01-05 → 2009-08-27 (-131d) |  |  |  |  |  |  |
| 1331.07000 | Fab & Install CHL Instrmenttn & Controls Labor FY10 | 2010-01-05 → 2009-08-27 A (-131d) | 2010-09-30 → 2012-10-15 A (+746d) | 188d → 778d | 0% → 100% | 51d → none | 12131.07015, 9-100M FS+60d, 12131.07015b → 12131.07015 FS-500d, 12131.07015b FS-500d, 9-090M | resources SUPPLIES & MATERIALS; MECH ENG [141.55 h]; MECH TECH [141.55 h]; ELEC ENG [283.11 h]; ELEC TECH [2724.89 h] → MECH ENG [141.55 h]; MECH TECH [141.55 h]; ELEC ENG [283.11 h]; ELEC TECH [2724.89 h]; SUPPLIES & MATERIALS |
| 1331.07000a | Fab & Install CHL Instrmenttn & Controls Labor FY11 | 2010-10-01 → 2009-08-27 A (-400d) | 2011-09-15 → 2012-10-15 A (+396d) | 237d → 778d | 0% → 100% | 51d → none | 1331.07000 → 1331.07000 FS-425d |  |
| 1331.07000b | Fab & Install CHL Instrmenttn & Controls Procurement | 2010-01-05 → 2009-08-27 A (-131d) | 2011-09-15 → 2012-10-15 A (+396d) | 425d → 778d | 0% → 100% | 51d → none | 12131.07015, 12131.07015b, 9-100M FS+60d → 12131.07015b FS-500d, 9-090M, 12131.07015 FS-500d |  |
| 1331.07005 | Re-Baseline Actuals Adjustment | 2013-08-30 A | 2013-08-30 A |  | 0% → 100% | 20d → none | 9-130M FS+227d → none |  |
| 08 | **1.3.3.1.08 INSTRUMENT AIR & SUPPORT EQUIPMENT** | 2011-01-05 → 2009-07-01 (-553d) |  |  |  |  |  |  |
| 1331.08000 | Proc & Install CHL Instrument Air Sys | 2011-01-05 → 2009-07-01 A (-553d) | 2011-09-13 → 2009-08-31 A (-743d) | 175d → 43d | 0% → 100% | 53d → none | 9-110M FS+60d, 12131.08000 → 9-090M, 12131.08000 FS-500d | resources MECH DES [200 h]; ELEC ENG [120 h]; PROCUREMENT<$50K 60; ELEC TECH [240 h]; MECH ENG [120 h]; MECH TECH [560 h] → MECH DES [200 h]; MECH TECH [560 h]; PROCUREMENT<$50K 60; MECH ENG [120 h]; ELEC ENG [120 h]; ELEC TECH [240 h] |
| 1331.08005 | Re-Baseline Actuals Adjustment | 2013-08-30 A | 2013-08-30 A |  | 0% → 100% | 20d → none | 9-130M FS+227d → none |  |
| 09 | **1.3.3.1.09 MOTOR CONTROL CENTERS** | 2010-01-05 → 2009-07-01 (-188d) |  |  |  |  |  |  |
| 1331.09000 | Proc & Install Motor Control Centers | 2010-01-05 → 2009-07-01 A (-188d) | 2010-08-06 → 2010-05-21 A (-77d) | 150d → 221d | 0% → 100% | 266d → none | 9-100M FS+60d, 12131.09000 → 12131.09000 FS-500d, 9-090M | resources PROCUREMENT>$50K 69; ELEC ENG [80 h]; PROCUREMENT<$50K 60; ELEC DES [80 h]; SKLLD TRADE [360 h] → SKLLD TRADE [360 h]; ELEC ENG [80 h]; ELEC DES [80 h]; PROCUREMENT<$50K 60; PROCUREMENT>$50K 69 |
| 1331.09005 | Re-Baseline Actuals Adjustment | 2013-08-30 A | 2013-08-30 A |  | 0% → 100% | 20d → none | 9-130M FS+227d → none |  |
| 10 | **1.3.3.1.10 CHL INSTALLATION & DESIGN** | 2009-12-09 → 2009-12-21 (+12d) |  |  |  |  |  |  |
| 1331.10000 | Proc & Install CHL Piping & Compnts Labor FY10 | 2009-12-09 → 2009-12-21 A (+12d) | 2010-09-30 → 2012-12-17 A (+809d) | 201d → 746d | 0% → 100% | 144d → none | 12131.04025, 12131.10010, 2-15M FS-60d → 12131.04025, 12131.10010, 2-15M FS-250d | resources MECH DES [186.43 h]; SR STAFF [1491.48 h]; MECH TECH [4054.96 h]; ELEC ENG [652.52 h]; ELEC DES [93.22 h]; ELEC TECH [1211.83 h] → ELEC ENG [652.52 h]; ELEC DES [93.22 h]; ELEC TECH [1211.83 h]; MECH DES [186.43 h]; MECH TECH [4054.96 h]; SR STAFF [1491.48 h] |

| ID | Task | Start | Finish | Duration | Complete | Total float | Predecessors | Other |
| --- | --- | --- | --- | --- | --- | --- | --- | --- |
| 1331.1000a | Proc & Install CHL Piping & Compnts Labor FY11 | 2010-10-01 → 2009-12-21 A (-284d) | 2011-05-04 → 2012-12-17 A (+593d) | 144d → 746d | 0% → 100% | 144d → none | 1331.10000 → 12131.10010, 12131.04025, 2-15M FS-250d |  |
| 1331.1000b | Proc & Install CHL Piping & Compnts Labor Procurement | 2009-12-09 → 2009-12-21 A (+12d) | 2011-05-04 → 2012-12-17 A (+593d) | 345d → 746d | 0% → 100% | 144d → none | 12131.04025, 2-15M FS-60d, 12131.10010 → 12131.10010, 12131.04025, 2-15M FS-250d | was named Proc & Install CHL Piping & Compnts Procurement; resources PROCUREMENT<$50K 60 NO ESCALATION FY11; PROCUREMENT>$50K 69 NO ESCALATION FY11 → PROCUREMENT>$50K 69 NO ESCALATION FY11; PROCUREMENT<$50K 60 NO ESCALATION FY11 |
| 1331.1005 | Install CHL Cold Box Transfer Line to Linac Labor | 2013-01-07 → 2013-02-11 A (+35d) | 2013-04-26 → 2013-08-30 A (+126d) | 78d → 18d | 0% → 100% | 151d → none | 1331.1000a, 9-130M FS+62d → 1331.1000a, 9-130M |  |
| 1331.1010 | Re-Baseline Actuals Adjustment | 2013-08-30 A | 2013-08-30 A |  | 0% → 100% | 20d → none | 9-130M FS+227d → none |  |
| 2331.1005 | Install CHL Cold Box Transfer Line to Linac Labor | 2013-09-03 A | 2013-09-30 A |  | 0% → 100% | 43d → none |  |  |
| 1331.11000 | Cmmssn CHL Helium Plant Original | 2011-10-03 A | 2012-04-30 → 2013-02-28 A (+304d) | 141d → 306d | 0% → 100% | 146d → none | 1621025, 3A-04M → 1621025, 12131.11010 | resources MECH TECH [902.4 h]; ELEC ENG [902.4 h]; ELEC TECH [902.4 h]; MECH ENG [1353.6 h] → ELEC ENG [902.4 h]; MECH ENG [1353.6 h]; MECH TECH [902.4 h]; ELEC TECH [902.4 h] |
| 1331.11005 | Re-Baseline Actuals Adjustment | 2013-08-30 A | 2013-08-30 A |  | 0% → 100% | 20d → none | 9-130M FS+227d → none |  |
| 12 | **1.3.3.1.12 LINAC TRANSFER LINE** | 2011-01-05 → 2009-12-21 (-380d) |  |  |  |  |  |  |
| 1331.12000 | Fab Cold Box Transfer Line & U-Tubes | 2011-01-05 → 2009-12-21 A (-380d) | 2011-09-13 → 2013-08-12 A (+699d) | 175d → 838d | 0% → 100% | 53d → none | 1331.02010 FS-550d, 1331.02001, 1331.02000, 9-110M FS+60d → 1331.02010 FS-550d, 9-110M FS-250d, 1331.02000, 1331.02001 FS-250d | resources MECH ENG [80 h]; MECH DES [40 h]; MECH TECH [1320 h]; ELEC ENG [80 h]; ELEC TECH [240 h]; PROCUREMENT<$50K 60; SUPPLIES & MATERIALS → PROCUREMENT<$50K 60; SUPPLIES & MATERIALS; MECH DES [40 h]; MECH ENG [80 h]; MECH TECH [1320 h]; ELEC ENG [80 h]; ELEC TECH [240 h] |
| 1331.12005 | Re-Baseline Actuals Adjustment | 2013-08-30 A | 2013-08-30 A |  | 0% → 100% | 20d → none | 9-130M FS+227d → none |  |
| 2 | **1.3.3.2 HALL D** | 2010-01-05 → 2009-04-16 (-264d) |  |  |  |  |  |  |
| 13321015 | Eng Design Cryogenic Transfer Line FY11 | 2011-08-01 A | 2011-09-30 A |  | 0% → 100% | 90d → none |  |  |
| 13321055 | Design Solenoid Distribution Can (Header) BIA | 2011-08-01 A | 2012-01-13 → 2012-04-20 A (+98d) | 111d → 179d | 0% → 100% | 50d → none |  |  |
| 13321025 | Fabricate Cryogenic Transfer Line Labor FY11 | 2011-09-12 → 2011-09-01 A (-11d) | 2011-09-30 A | 15d → 21d | 0% → 100% | 90d → none |  | resources MECH ENG [19.51 h]; SR STAFF [9.76 h]; MECH DES [9.76 h]; ELEC TECH [29.27 h]; SUPPLIES & MATERIALS; MECH TECH [263.41 h]; ELEC ENG [4.88 h] → SUPPLIES & MATERIALS; ELEC ENG [4.88 h]; MECH ENG [19.51 h]; SR STAFF [9.76 h]; MECH DES [9.76 h]; ELEC TECH [29.27 h]; MECH TECH [263.41 h] |
| 13321035 | Fabricate Cryogenic Transfer Line Procurement | 2011-09-12 → 2011-09-01 A (-11d) | 2012-03-30 → 2012-09-17 A (+171d) | 135d → 259d | 0% → 100% | 90d → none |  |  |
| 13321020 | Eng Design Cryogenic Transfer Line FY12 | 2011-10-03 A | 2012-01-13 → 2012-09-17 A (+248d) | 67d → 238d | 0% → 100% | 90d → none |  | resources MECH ENG [434.59 h]; SR STAFF [96.58 h]; ELEC DES [24.14 h]; MECH DES [482.88 h]; OFFICE [96.58 h]; PLABOR; ELEC ENG [72.43 h] → ELEC ENG [72.43 h]; MECH ENG [434.59 h]; SR STAFF [96.58 h]; ELEC DES [24.14 h]; MECH DES [482.88 h]; OFFICE [96.58 h]; PLABOR |
| 13321030 | Fabricate Cryogenic Transfer Line Labor FY12 | 2011-10-03 A | 2012-03-14 → 2012-10-15 A (+215d) | 108d → 258d | 0% → 100% | 90d → none |  | resources ELEC ENG [35.12 h]; MECH ENG [140.49 h]; SR STAFF [70.24 h]; MECH DES [70.24 h]; ELEC TECH [210.73 h]; MECH TECH [1896.59 h]; SUPPLIES & MATERIALS → SUPPLIES & MATERIALS; ELEC ENG [35.12 h]; MECH ENG [140.49 h]; SR STAFF [70.24 h]; MECH DES [70.24 h]; ELEC TECH [210.73 h]; MECH TECH [1896.59 h] |
| 13321065 | Fabricate Solenoid Distribution Can (Header) Procurement | 2012-03-16 → 2011-11-14 A (-123d) | 2012-07-31 → 2012-08-20 A (+20d) | 96d → 189d | 0% → 100% | 8d → none | 13321060 FS-84d → 13321060 FS-154d |  |
| 13321060 | Fabricate Solenoid Distribution Can (Header) Labor | 2012-03-16 → 2012-03-05 A (-11d) | 2012-07-13 → 2012-10-19 A (+98d) | 84d → 162d | 0% → 100% | 8d → none | 13321055, 9-120M FS+109d → 9-120M, 13321055 FS-10d | resources ELEC DES [280 h]; PLABOR; ELEC ENG [520 h]; MECH ENG [960 h]; SR STAFF [80 h]; MECH DES [800 h]; SUPPLIES & MATERIALS → ELEC ENG [520 h]; MECH ENG [960 h]; SR STAFF [80 h]; MECH DES [800 h]; SUPPLIES & MATERIALS; ELEC DES [280 h]; PLABOR |
| 13321045 | Install Cryogenic Transfer Line Procurement | 2012-03-15 → 2012-08-27 A (+165d) | 2012-05-31 → 2012-11-12 A (+165d) |  | 0% → 100% | 90d → none | 13321030, 13321035 FS-12d → 13321035 FS-12d, 13321030 FS-30d |  |
| 13321040 | Install Cryogenic Transfer Line Labor | 2012-03-15 → 2012-10-01 A (+200d) | 2012-05-16 → 2012-11-19 A (+187d) | 45d → 36d | 0% → 100% | 104d → none | 13321030, 13321035 FS-12d → 13321030 FS-10d, 13321035 FS-12d | resources ELEC TECH [200 h]; MECH TECH [960 h]; SUPPLIES & MATERIALS; ELEC DES [40 h]; ELEC ENG [80 h]; MECH ENG [240 h]; SR STAFF [160 h]; MECH DES [120 h] → MECH DES [120 h]; ELEC TECH [200 h]; MECH TECH [960 h]; SUPPLIES & MATERIALS; ELEC DES [40 h]; ELEC ENG [80 h]; MECH ENG [240 h]; SR STAFF [160 h] |
| 13321070 | Install Solenoid Distribution Can (Header) | 2012-07-16 → 2012-10-19 A (+95d) | 2012-09-28 → 2012-10-29 A (+31d) | 54d → 7d | 0% → 100% | 8d → none | 151155, 13321065 FS-12d → 151155, 13321065 FS+27d | resources SR STAFF [80 h]; ELEC DES [240 h]; ELEC ENG [80 h]; MECH DES [120 h]; MECH ENG [720 h] → ELEC ENG [80 h]; MECH DES [120 h]; MECH ENG [720 h]; SR STAFF [80 h]; ELEC DES [240 h] |
| 13321042 | Install Hall D Solenoid External Warm/Vent Piping Labor | 2012-11-08 → 2012-11-12 A (+4d) | 2012-12-07 → 2012-12-17 A (+10d) | 20d → 18d | 0% → 100% | 90d → none |  |  |
| 13321050 | Commission Cryogenic Transfer Line | 2012-06-08 → 2012-12-17 A (+192d) | 2012-07-03 → 2013-03-22 A (+262d) | 18d → 6d | 0% → 100% | 90d → none | 13321042 FS-128d, 13321040, 13321045 FS+4d → 13321040 FS-10d, 13321045, 13321042 | resources SUPPLIES & MATERIALS; ELEC ENG [40 h]; MECH ENG [120 h]; SR STAFF [40 h]; MECH DES [80 h]; ELEC TECH [80 h]; MECH TECH [360 h] → MECH DES [80 h]; ELEC TECH [80 h]; MECH TECH [360 h]; SUPPLIES & MATERIALS; ELEC ENG [40 h]; MECH ENG [120 h]; SR STAFF [40 h] |
| 13321075 | Re-Baseline Actuals Adjustment | 2013-08-30 A | 2013-08-30 A |  | 0% → 100% | 20d → none | 9-130M FS+227d → none |  |
| 2 | **1.3.3.2.2 HALL D COLD BOX** | 2010-01-05 → 2009-04-16 (-264d) |  |  |  |  |  |  |
| 13322000 | Refurblish H-D Cold Box | 2010-01-05 → 2009-04-16 A (-264d) | 2010-02-09 → 2009-08-31 A (-162d) | 25d → 96d | 0% → 100% | 448d → none | 121322000, 9-100M FS+60d → 9-100M FS-125d, 121322000 | resources PROCUREMENT<$50K 60; SUPPLIES & MATERIALS; MECH TECH [200 h]; ELEC TECH [160 h] → MECH TECH [200 h]; PROCUREMENT<$50K 60; SUPPLIES & MATERIALS; ELEC TECH [160 h] |
| 13322005 | Relocation of Helium Refrigerator Labor (Frozen by CR11-036) | 2011-06-02 → 2011-08-01 A (+60d) | 2011-07-29 → 2011-08-08 A (+10d) | 41d → 6d | 0% → 100% | 44d → none |  | resources ELEC TECH [437.33 h]; MECH TECH [583.11 h]; ELEC ENG [291.56 h]; MECH ENG [510.22 h]; PLABOR; SR STAFF [109.33 h]; SUPPLIES & MATERIALS → MECH TECH [583.11 h]; ELEC ENG [291.56 h]; MECH ENG [510.22 h]; PLABOR; SR STAFF [109.33 h]; SUPPLIES & MATERIALS; ELEC TECH [437.33 h] |
| 13322006 | Reverse entry per CR11-036 | 2011-08-01 A | 2011-08-05 A |  | 0% → 100% | 39d → none |  | resources MECH TECH [-583.11 h]; ELEC ENG [-291.56 h]; MECH ENG [-510.22 h]; PLABOR; SR STAFF [-109.33 h]; SUPPLIES & MATERIALS; ELEC TECH [-437.33 h] → ELEC TECH [-437.33 h]; MECH TECH [-583.11 h]; ELEC ENG [-291.56 h]; MECH ENG [-510.22 h]; PLABOR; SR STAFF [-109.33 h]; SUPPLIES & MATERIALS |
| 13322007 | Relocation of Helium Refrigerator Labor (Revised by CR11-036) | 2011-10-03 A | 2012-02-01 → 2012-05-14 A (+103d) | 79d → 151d | 0% → 100% | 158d → none |  | resources MECH TECH [640 h]; ELEC ENG [320 h]; MECH ENG [560 h]; PLABOR; SR STAFF [120 h]; SUPPLIES & MATERIALS; ELEC TECH [480 h] → SR STAFF [120 h]; SUPPLIES & MATERIALS; ELEC TECH [480 h]; MECH TECH [640 h]; ELEC ENG [320 h]; MECH ENG [560 h]; PLABOR |
| 13322010 | Relocation of Helium Refrigerator Procurement | 2011-10-03 → 2011-12-01 A (+59d) | 2012-02-29 → 2012-04-27 A (+58d) | 98d → 99d | 0% → 100% | 158d → none |  |  |
| 13322015 | Re-Baseline Actuals Adjustment | 2013-08-30 A | 2013-08-30 A |  | 0% → 100% | 20d → none | 9-130M FS+227d → none |  |
| 3 | **1.3.3.2.3 HALL DISTRIBUTION SYSTEM** | 2011-03-01 → 2009-09-13 (-534d) |  |  |  |  |  |  |
| 13323000 | Proc H-D Refrigerator Equip & Piping Proc | 2011-03-01 → 2009-09-13 A (-534d) | 2012-02-29 → 2011-08-22 A (-191d) | 249d → 481d | 0% → 100% | 209d → none | 16332040F, 13322000, 121323000 → 121323000 FS-500d, 16332040F FS-500d, 13322000 FS-500d |  |
| 13323005 | Proc & Install H-D Refrigerator Equip & Piping (Original labor Frozen per CR 11-036) | 2011-03-01 → 2011-08-01 A (+153d) | 2011-07-29 → 2011-08-08 A (+10d) | 107d → 6d | 0% → 100% | 188d → none |  | resources ELEC ENG [98.77 h]; ELEC DES [98.77 h]; ELEC TECH [65.85 h]; SUPPLIES & MATERIALS; MECH ENG [98.77 h]; MECH DES [65.85 h]; MECH TECH [1415.69 h] → MECH DES [65.85 h]; MECH TECH [1415.69 h]; ELEC ENG [98.77 h]; ELEC DES [98.77 h]; ELEC TECH [65.85 h]; SUPPLIES & MATERIALS; MECH ENG [98.77 h] |
| 13323010 | Reverse Entry per CR 11-036) | 2011-08-01 A | 2011-08-05 A |  | 0% → 100% | 39d → none |  | resources SUPPLIES & MATERIALS; MECH ENG [-98.77 h]; MECH DES [-65.85 h]; MECH TECH [-1415.69 h]; ELEC ENG [-98.77 h]; ELEC DES [-98.77 h]; ELEC TECH [-65.85 h] → ELEC ENG [-98.77 h]; ELEC DES [-98.77 h]; ELEC TECH [-65.85 h]; SUPPLIES & MATERIALS; MECH ENG [-98.77 h]; MECH DES [-65.85 h]; MECH TECH [-1415.69 h] |
| 13323015 | Install H-D Refrigerator Equip & Piping Labor (Revised per CR 11-036) FY11 | 2011-09-01 A | 2011-09-30 → 2012-11-12 A (+409d) | 21d → 298.5d | 0% → 100% | 142d → none |  |  |
| 13323015a | Install H-D Refrigerator Equip & Piping Labor (Revised per CR 11-036) FY12 | 2011-10-03 → 2011-09-01 A (-32d) | 2012-02-10 → 2012-11-12 A (+276d) | 86d → 299d | 0% → 100% | 142d → none | 13323015 → 13323015 FS-90d | resources MECH DES [64.3 h]; MECH TECH [1382.43 h]; ELEC ENG [96.45 h]; ELEC DES [96.45 h]; ELEC TECH [64.3 h]; SUPPLIES & MATERIALS; MECH ENG [96.45 h] → ELEC TECH [64.3 h]; SUPPLIES & MATERIALS; MECH ENG [96.45 h]; MECH DES [64.3 h]; MECH TECH [1382.43 h]; ELEC ENG [96.45 h]; ELEC DES [96.45 h] |
| 13323020 | Install H-D Refrigerator Equip & Piping Procurement (Revised per CR 11-036) | 2011-09-01 A | 2012-02-29 → 2012-10-15 A (+229d) | 119d → 279d | 0% → 100% | 142d → none |  |  |
| 13323025 | Re-Baseline Actuals Adjustment | 2013-08-30 A | 2013-08-30 A |  | 0% → 100% | 20d → none | 9-130M FS+227d → none |  |
| 4 | **1.3.3.2.4 INSTRUMENTATION & CONTROLS** | 2011-05-17 → 2009-10-01 (-593d) |  |  |  |  |  |  |
| 13324000 | Install H-D Refrigerator Instrmenttn & Controls Procurement | 2011-05-17 → 2009-10-01 A (-593d) | 2012-03-30 → 2011-08-22 A (-221d) | 216d → 468d | 0% → 100% | 142d → none | 9-110M FS+60d, 121324000, 13326000 FS-52d → 121324000 |  |
| 13324005 | Install H-D Refrigerator Instrmenttn & Controls Original Labor Frozen per CR 11-036 | 2011-05-17 → 2011-08-01 A (+76d) | 2011-07-29 → 2011-08-08 A (+10d) | 52d → 6d | 0% → 100% | 306d → none |  |  |
| 13324010 | Reverse Entry Per CR 11-036 | 2011-08-01 A | 2011-08-05 A |  | 0% → 100% | 39d → none |  |  |
| 13324015 | Install H-D Refrigerator Instrmenttn & Controls FY11 | 2011-09-01 A | 2011-09-30 → 2012-10-22 A (+388d) | 21d → 283.11d | 0% → 100% | 158d → none |  |  |
| 13324015a | Install H-D Refrigerator Instrmenttn & Controls FY12 | 2011-10-03 → 2011-09-01 A (-32d) | 2012-03-08 → 2012-10-22 A (+228d) | 104d → 284d | 0% → 100% | 158d → none | 13324015 → 13324015 FS-110d |  |
| 13324020 | Re-Baseline Actuals Adjustment | 2013-08-30 A | 2013-08-30 A |  | 0% → 100% | 20d → none | 9-130M FS+227d → none |  |
| 5 | **1.3.3.2.5 U-TUBES** | 2011-07-07 → 2011-08-01 (+25d) |  |  |  |  |  |  |
| 13325000 | Fab Cryogenic U-Tubes (Frozen Per CR 11-036) | 2011-07-07 → 2011-08-01 A (+25d) | 2011-07-29 → 2011-08-08 A (+10d) | 17d → 6d | 0% → 100% | 165d → none | 13323005 FS-40d, 121325000, 9-110M FS+125d, 13323015a FS-155d, 13323020 FS-159d → 13323000 FS-40d, 9-110M FS+125d, 13323015a FS-155d, 13323020 FS-159d, 121325000, 13323005 FS-40d |  |
| 13325005 | Reverse Entry Per CR 11-036 | 2011-08-01 A | 2011-08-05 A |  | 0% → 100% | 39d → none |  | resources SUPPLIES & MATERIALS; MECH TECH [-255 h] → MECH TECH [-255 h]; SUPPLIES & MATERIALS |
| 13325010 | Fab Cryogenic U-Tubes Labor (Revised Per CR 11-036) | 2011-12-08 → 2012-07-02 A (+207d) | 2012-02-10 → 2012-12-17 A (+311d) | 40d → 127d | 0% → 100% | 142d → none | 9-110M FS+125d, 13323005 FS-40d, 13323015a FS-40d, 13323020 FS-52d, 121325000, 13323000 FS-119d → 13323015a FS-40d, 121325000, 13323005 FS-40d, 13323000 FS+0.5d, 13323020 FS-30d, 9-120M FS+105d, 9-110M FS+125d |  |
| 13325015 | Fab Cryogenic U-Tubes Procurment (Revised Per CR 11-036) | 2011-12-08 → 2012-07-02 A (+207d) | 2012-02-10 → 2012-12-17 A (+311d) | 40d → 127d | 0% → 100% | 142d → none | 121325000, 9-110M FS+125d, 13323000 FS-119d, 13323020 FS-52d, 13323015a FS-40d, 13323005 FS-40d → 121325000, 9-110M FS+125d, 13323020 FS-30d, 13323005 FS-40d, 13323000 FS-119d, 13323015a FS-40d |  |
| 13325020 | Re-Baseline Actuals Adjustment | 2013-08-30 A | 2013-08-30 A |  | 0% → 100% | 20d → none | 9-130M FS+227d → none |  |
| 6 | **1.3.3.2.6 FIELD INSTALLATION** | 2011-03-22 → 2011-08-01 (+132d) |  |  |  |  |  |  |
| 13326000 | Install Field Compnts (Frozen Per CR 11-036) | 2011-03-22 → 2011-08-01 A (+132d) | 2011-07-29 → 2011-08-08 A (+10d) | 92d → 6d | 0% → 100% | 142d → none | 13325015 FS-222d, 13325000 FS-115d, 3C-09M, 9-110M FS+60d, 13325010 FS-222d → 3C-09M, 13325015 FS-222d, 13325000 FS-100d, 9-120M, 9-110M FS+50d, 13325010 FS-222d | resources MECH ENG [122.67 h]; ELEC ENG [122.67 h]; ELEC TECH [552 h]; SUPPLIES & MATERIALS; MECH DES [30.67 h]; SKLLD TRADE [92 h]; MECH TECH [1870.67 h] → SKLLD TRADE [92 h]; ELEC ENG [122.67 h]; ELEC TECH [552 h]; MECH ENG [122.67 h]; MECH DES [30.67 h]; MECH TECH [1870.67 h]; SUPPLIES & MATERIALS |
| 13326005 | Reverse Entry Per CR 11-036 | 2011-08-01 A | 2011-08-05 A |  | 0% → 100% | 39d → none |  | resources ELEC ENG [-122.67 h]; ELEC TECH [-552 h]; SUPPLIES & MATERIALS; MECH DES [-30.67 h]; SKLLD TRADE [-92 h]; MECH TECH [-1870.67 h]; MECH ENG [-122.67 h] → SUPPLIES & MATERIALS; MECH DES [-30.67 h]; SKLLD TRADE [-92 h]; MECH TECH [-1870.67 h]; MECH ENG [-122.67 h]; ELEC ENG [-122.67 h]; ELEC TECH [-552 h] |
| 13326010 | Install Field Compnts Labor (Revised Per CR 11-036) | 2011-10-03 A | 2012-03-08 → 2012-09-17 A (+193d) | 104d → 238d | 0% → 100% | 158d → none | 13325000 FS-115d, 13322007 FS-79d, 13325010 FS-86d, 13322010 FS-98d, 3C-09M, 9-110M FS+60d, 13325015 FS-86d → 3C-09M, 13322007 FS-79d, 9-110M FS+60d, 13325010 FS-86d, 13325015 FS-86d, 13322010 FS-98d | resources MECH ENG [160 h]; ELEC ENG [160 h]; ELEC TECH [720 h]; SUPPLIES & MATERIALS; MECH DES [40 h]; SKLLD TRADE [120 h]; MECH TECH [2440 h] → ELEC ENG [160 h]; ELEC TECH [720 h]; SUPPLIES & MATERIALS; MECH DES [40 h]; SKLLD TRADE [120 h]; MECH TECH [2440 h]; MECH ENG [160 h] |
| 13326015 | Install Field Compnts Procurement (Revised Per CR 11-036) | 2011-10-03 A | 2012-03-30 → 2012-09-17 A (+171d) | 120d → 238d | 0% → 100% | 158d → none | 13325000 FS-115d, 13325015 FS-86d, 9-110M FS+60d, 3C-09M, 13325010 FS-86d → 3C-09M, 13325015 FS-86d, 13325010 FS-86d, 9-110M FS+60d |  |
| 13326020 | Re-Baseline Actuals Adjustment | 2013-08-30 A | 2013-08-30 A |  | 0% → 100% | 20d → none | 9-130M FS+227d → none |  |
| 7 | **1.3.3.2.7 COMMISSIONING** | 2012-04-02 → 2012-12-17 (+259d) |  |  |  |  |  |  |
| 13327000 | Cmmssn H-D Refrigerator Sys | 2012-04-02 → 2012-12-17 A (+259d) | 2012-05-02 → 2013-02-18 A (+292d) | 23d → 6d | 0% → 100% | 142d → none | 16332010U, 13324000, 13326000, 13326010, 13326015 FS-16d, 13324015a, 16332010, 13324005 → 13324000, 16332010U FS-20d, 16332010, 9-130M FS+10d, 13326015 FS-5d, 13324015a, 13324005, 13326010 FS-5d, 13326000 | resources PROCUREMENT<$50K 60; ELEC DES [120 h]; ELEC ENG [320 h]; SUPPLIES & MATERIALS; MECH DES [120 h] → ELEC DES [120 h]; PROCUREMENT<$50K 60; ELEC ENG [320 h]; SUPPLIES & MATERIALS; MECH DES [120 h] |
| 13327005 | Re-Baseline Actuals Adjustment | 2013-08-30 A | 2013-08-30 A |  | 0% → 100% | 20d → none | 9-130M FS+227d → none |  |
| 4 | **1.3.4 BEAM TRANSPORT** |  | 2013-11-18 → 2013-12-12 (+24d) |  |  |  |  |  |
| 1 | **1.3.4.1 SPREADERS & RECOMBINERS** |  | 2013-11-11 → 2013-12-12 (+31d) |  |  |  |  |  |
| 1 | **1.3.4.1.1 DIPOLES** |  | 2013-10-15 → 2013-11-15 (+31d) |  |  |  |  |  |
| 13411909LOE | FY09 Mngmnt & Oversight (S/R Dipoles) | 2009-01-02 A | 2009-09-30 A |  | 0% → 100% | 20d → none |  |  |
| 13411075 | Prcrmnt Prep of Septa (S/R Dipoles) | 2009-01-02 → 2009-01-05 A (+3d) | 2009-06-11 → 2009-08-21 A (+71d) | 112d → 161d | 0% → 100% | 362d → none |  | resources MECH ENG [160 h]; MECH DES [60 h] → MECH DES [60 h]; MECH ENG [160 h] |
| 13411095 | Prcrmnt Prep of Curved Dipoles (S/R Dipoles) | 2009-01-12 → 2009-03-02 A (+49d) | 2009-06-26 → 2009-11-18 A (+145d) | 117d → 185d | 0% → 100% | 111d → none |  |  |
| 13411115 | Prcrmnt Prep for C Dipoles & Coils (S/R Dipoles) | 2009-01-12 → 2009-04-20 A (+98d) | 2009-06-26 → 2009-11-30 A (+157d) | 117d → 156d | 0% → 100% | 196d → none |  | resources MECH DES [72 h]; MECH ENG [80 h] → MECH ENG [80 h]; MECH DES [72 h] |
| 13411085 | Vend Fab Septa (S/R Dipoles) LABOR INITIAL FY09 | 2009-06-12 → 2009-08-03 A (+52d) | 2009-07-31 → 2009-08-03 A (+3d) | 35d → 1d | 0% → 100% | 362d → none |  |  |

| ID | Task | Start | Finish | Duration | Complete | Total float | Predecessors | Other |
| --- | --- | --- | --- | --- | --- | --- | --- | --- |
| 13411086 | Vend Fab Septa (S/R Dipoles) LABOR FINAL FY09 | 2009-08-03 A | 2009-09-30 A |  | 0% → 100% | 362d → none |  |  |
| 13411087 | Vend Fab Septa (S/R Dipoles) Materials | 2009-08-26 → 2009-08-03 A (-23d) | 2009-10-15 → 2010-03-29 A (+165d) | 36d → 160d | 0% → 100% | 764d → none |  | resources PROCUREMENT>$50K 69 NO ESCALATION; PROCUREMENT<$50K 60 NO ESCALATION → PROCUREMENT<$50K 60 NO ESCALATION; PROCUREMENT>$50K 69 NO ESCALATION |
| 13411087A | Vend Fab Septa (S/R Dipoles) First Article ZA Magnet | 2009-08-26 → 2009-08-03 A (-23d) | 2010-02-02 → 2011-06-20 A (+503d) | 105d → 466d | 0% → 100% | 468d → none | 9-090M FS+223d → 13411087 FS-32d |  |
| 13411087B | Vend Fab Septa (S/R Dipoles) Deliver (4) ZA Magnet Assemblies | 2009-08-26 → 2009-08-03 A (-23d) | 2011-03-31 → 2011-06-20 A (+81d) | 393d → 466d | 0% → 100% | 407d → none | 9-090M FS+223d → 13411087A FS-145d |  |
| 13411087C | Vend Fab Septa (S/R Dipoles) Deliver (3) ZA Magnet Assemblies | 2009-08-26 → 2009-08-03 A (-23d) | 2011-07-29 → 2011-06-20 A (-39d) | 477d → 466d | 0% → 100% | 323d → none | 9-090M FS+223d → 13411087B FS-275d |  |
| 13411087D | Vend Fab Septa (S/R Dipoles) Deliver ZA Spare Coil Set (Frozen by CR 11-041) | 2009-08-26 → 2009-08-03 A (-23d) | 2011-07-29 → 2011-06-20 A (-39d) | 477d → 466d | 0% → 100% | 323d → none | 9-090M FS+223d → 13411087C FS-338d |  |
| 13411087D10 | Vend Fab Septa (S/R Dipoles) Deliver (2) YA Magnet Assemblies (Frozen by CR 11-041) | 2009-08-26 → 2009-08-03 A (-23d) | 2011-11-30 → 2011-06-20 A (-163d) | 562d → 466d | 0% → 100% | 238d → none | 9-090M FS+223d → 13411087D FS-338d |  |
| 13411087D5 | Vend Fab Septa (S/R Dipoles) Deliver (2) ZB Coil Sets (Frozen by CR 11-041) | 2009-08-26 → 2009-08-03 A (-23d) | 2011-12-30 → 2011-06-20 A (-193d) | 579d → 466d | 0% → 100% | 221d → none |  |  |
| 13411080M | Award Contract for Septa (S/R DIPOLES) | 2009-06-12 → 2009-08-26 A (+75d) | 2009-06-12 → 2009-08-26 A (+75d) |  | 0% → 100% | 362d → none | 121416010, 13411075, 121411110M FS-34d → 13411075, 121416010 FS-100d, 121411110M FS-100d |  |
| 13411055 | Prcrmnt Prep for H Steel (S/R Dipoles) | 2009-10-05 → 2009-09-08 A (-27d) | 2010-03-19 → 2010-01-22 A (-56d) | 110d → 90d | 0% → 100% | 169d → none |  | resources MECH ENG [80 h]; MECH DES [60 h] → MECH DES [60 h]; MECH ENG [80 h] |
| 13411086ALOE | Vend Fab Septa (S/R Dipoles) LABOR FY10 | 2009-10-01 A | 2010-09-30 A |  | 0% → 100% | 362d → none |  |  |
| 13411910LOE | FY10 Mngmnt & Oversight (S/R Dipoles) | 2009-10-01 A | 2010-09-30 A |  | 0% → 100% | 20d → none |  | resources SR STAFF [520 h]; TRAVEL → TRAVEL; SR STAFF [520 h] |
| 13411100M | Award Contract for Curved Dipoles (S/R DIPOLES) | 2009-06-29 → 2009-11-18 A (+142d) | 2009-06-29 → 2009-11-18 A (+142d) |  | 0% → 100% | 111d → none |  |  |
| 13411105 | P-1 Vend Fab Curved Dipoles (S/R Dipoles) Labor FY09 | 2009-06-29 → 2009-11-18 A (+142d) | 2009-09-30 → 2010-09-30 A (+365d) | 66d → 214d | 0% → 100% | 111d → none |  | resources MECH DES [12.77 h]; MECH ENG [28.74 h] → MECH ENG [28.74 h]; MECH DES [12.77 h] |
| 13411105b | P-1 Vend Fab Curved Dipoles (S/R Dipoles) Labor FY10 | 2009-10-01 → 2009-11-18 A (+48d) | 2010-06-28 → 2010-09-30 A (+94d) | 182d → 214d | 0% → 100% | 111d → none | 13411105 → 13411105 FS-400d | resources MECH DES [35.23 h]; MECH ENG [79.26 h] → MECH ENG [79.26 h]; MECH DES [35.23 h] |
| 13411105c | Vend Fab Curved Dipoles Peg Point #1 Receipt of Coil Materials and Tooling | 2009-11-18 A | 2010-02-26 → 2010-06-28 A (+122d) | 63d → 148d | 0% → 100% | 46d → none |  |  |
| 13411105d | Vend Fab Curved Dipoles Peg Point #2 Receipt of Core Materials | 2009-11-18 A | 2010-02-26 → 2010-06-28 A (+122d) | 63d → 148d | 0% → 100% | 46d → none |  |  |
| 13411105f | Vend Fab Curved Dipoles Peg Point #3 JLab Approval of First Article XU Coil | 2009-11-18 A | 2010-04-30 → 2010-07-19 A (+80d) | 108d → 162d | 0% → 100% | 46d → none |  |  |
| 13411105g | Vend Fab Curved Dipoles Peg Point #4 JLab Approval of First Article XU Core Assembly | 2009-11-18 A | 2010-06-30 → 2010-07-19 A (+19d) | 150d → 162d | 0% → 100% | 46d → none |  |  |
| 13411105h | Vend Fab Curved Dipoles Peg Point #5 Receipt and Acceptance of XU Coils by JLab | 2009-11-18 A | 2010-06-30 → 2010-11-15 A (+138d) | 150d → 246d | 0% → 100% | 46d → none |  |  |
| 13411105j | Vend Fab Curved Dipoles Peg Point #6 Receipt and Acceptance of XU Magnet Assemblies by JLab | 2009-11-18 A | 2010-10-29 → 2010-11-15 A (+17d) | 235d → 246d | 0% → 100% | 46d → none |  |  |
| 13411105k | Vend Fab Curved Dipoles Peg Point #7 Receipt and Acceptance of XM Coils by JLab | 2009-11-18 A | 2010-12-30 → 2011-03-01 A (+61d) | 272d → 311d | 0% → 100% | 46d → none | 13411105j FS-235d → 13411105j FS-193d |  |
| 13411105n | Vend Fab Curved Dipoles Peg Point #8 Receipt and Acceptance of XV Coils by JLab | 2009-11-18 A | 2011-01-31 → 2011-03-01 A (+29d) | 292d → 312d | 0% → 100% | 46d → none | 13411105k FS-272d → 13411105k FS-214d |  |
| 13411105o | Vend Fab Curved Dipoles Peg Point #9 Receipt and Acceptance of XV Magnet Assemblies by JLab | 2009-11-18 A | 2011-01-31 → 2011-03-21 A (+49d) | 292d → 326d | 0% → 100% | 46d → none | 13411105n FS-292d → 13411105n FS-235d |  |
| 13411105p | Vend Fab Curved Dipoles Peg Point #10 Receipt and Acceptance of BP Coils by JLab | 2009-11-18 A | 2011-01-31 → 2011-06-20 A (+140d) | 292d → 390d | 0% → 100% | 46d → none | 13411105o FS-292d → 13411105o FS-235d |  |
| 13411105q | Vend Fab Curved Dipoles Peg Point #11 Receipt and Acceptance of JF Coils by JLab | 2009-11-18 A | 2011-02-28 → 2011-12-12 A (+287d) | 311d → 511d | 0% → 100% | 46d → none | 13411105p FS-292d → 13411105p FS-235d |  |
| 13411105r | Vend Fab Curved Dipoles Peg Point #12 Receipt and Acceptance of XM Magnet Assemblies by JLab | 2009-11-18 A | 2011-02-28 → 2011-03-01 A (+1d) |  | 0% → 100% | 46d → none | 13411105q FS-311d → 13411105q FS-255d |  |
| 13411105s | Vend Fab Curved Dipoles Peg Point #13 Receipt and Acceptance of XX Coils by JLab | 2009-11-18 A | 2011-03-31 → 2011-08-15 A (+137d) | 334d → 429d | 0% → 100% | 46d → none | 13411105r FS-311d → 13411105r FS-255d |  |
| 13411105t | Vend Fab Curved Dipoles Peg Point #14 Receipt and Acceptance of JG Magnet Assemblies by JLab | 2009-11-18 A | 2011-05-31 → 2011-06-20 A (+20d) | 376d → 390d | 0% → 100% | 46d → none | 13411105s FS-334d → 13411105s FS-272d |  |
| 13411105u | Vend Fab Curved Dipoles Peg Point #15 Receipt and Acceptance of JH Magnet Assemblies by JLab | 2009-11-18 A | 2011-08-31 → 2011-06-20 A (-72d) | 441d → 390d | 0% → 100% | 46d → none | 13411105t FS-376d → 13411105t FS-311d |  |
| 13411105v | Vend Fab Curved Dipoles Peg Point #16 Receipt and Acceptance of XX Magnet Assemblies by JLab | 2009-11-18 A | 2011-09-30 → 2011-08-15 A (-46d) | 462d → 429d | 0% → 100% | 99d → none | 13411105u FS-441d → 13411105u FS-376d |  |
| 13411125 | P-1 Vend Fab C Dipoles & Coils (S/R Dipoles) Labor FY09 | 2009-06-29 → 2009-11-18 A (+142d) | 2009-09-30 → 2010-09-30 A (+365d) | 66d → 214d | 0% → 100% | 196d → none |  |  |
| 13411125b | P-1 Vend Fab C Dipoles & Coils (S/R Dipoles) Labor FY10 | 2009-10-01 → 2009-11-18 A (+48d) | 2010-06-28 → 2010-09-30 A (+94d) | 182d → 214d | 0% → 100% | 196d → none | 13411125 → 13411125 FS-200d |  |
| 13411120M | Award Contract for C Dipoles & Coils (S/R DIPOLES) | 2009-06-29 → 2009-11-30 A (+154d) | 2009-06-29 → 2009-11-30 A (+154d) |  | 0% → 100% | 196d → none |  |  |
| 13411060M | Award Contract for H Steel (S/R DIPOLES) | 2010-03-22 → 2010-01-22 A (-59d) | 2010-03-22 → 2010-01-22 A (-59d) |  | 0% → 100% | 169d → none |  |  |
| 13411106 | P-2 Vend Fab Curved Dipoles (S/R Dipoles) Original Labor FY10 | 2010-01-29 A | 2010-09-30 → 2011-01-28 A (+120d) | 171d → 247.4d | 0% → 100% | 111d → none | 9-100M FS+60d, 13411105b FS-105d, 13411105c FS-105d → 9-100M FS+60d, 13411105c FS-400d, 13411105b FS-400d | resources MECH ENG [68.95 h]; MECH DES [27.58 h] → MECH DES [27.58 h]; MECH ENG [68.95 h] |
| 13411106a | P-2 Vend Fab Curved Dipoles (S/R Dipoles) Original Labor FY11 | 2010-10-01 → 2010-01-29 A (-245d) | 2011-01-28 A | 77d → 248d | 0% → 100% | 111d → none | 13411106 → 13411105c FS-400d, 13411105b FS-400d, 9-100M FS+60d | resources MECH ENG [31.05 h]; MECH DES [12.42 h] → MECH DES [12.42 h]; MECH ENG [31.05 h] |
| 13411126 | P-2 Vend Fab C Dipoles & Coils (S/R Dipoles) Original Labor FY10 | 2010-01-29 A | 2010-09-30 → 2011-01-28 A (+120d) | 171d → 248d | 0% → 100% | 196d → none | 13411125b FS-105d → 13411125b FS-125d |  |
| 13411126a | P-2 Vend Fab C Dipoles & Coils (S/R Dipoles) Original Labor FY11 | 2010-10-01 → 2010-01-29 A (-245d) | 2011-01-28 A | 77d → 248d | 0% → 100% | 196d → none | 13411126 → 13411125b FS-125d |  |
| 13411065 | P-1 Vend Fab H Steel (S/R Dipoles) Labor FY10 | 2010-03-22 A | 2010-09-30 → 2011-10-17 A (+382d) | 136d → 394.57d | 0% → 100% | 169d → none |  |  |
| 13411065a | P-1 Vend Fab H Steel (S/R Dipoles) Labor FY11 | 2010-10-01 → 2010-03-22 A (-193d) | 2011-03-21 → 2011-10-17 A (+210d) | 112d → 394.71d | 0% → 100% | 169d → none | 13411065 → 13411060M |  |
| 13411065b | P-1 Vend Fab H Steel (S/R Dipoles) Procurement | 2010-03-22 A | 2011-03-21 → 2011-08-08 A (+140d) | 248d → 346d | 0% → 100% | 169d → none |  |  |
| 13411136 | Proc Prep BCOMM and Additional Steel FY10 | 2010-07-02 → 2010-03-22 A (-102d) | 2010-09-30 → 2010-08-30 A (-31d) | 63d → 114d | 0% → 100% | 285d → none | 9-100M FS+185d → 9-100M |  |
| 13411160 | Proc Prep Extra Coils FY10 | 2010-07-01 → 2010-03-29 A (-94d) | 2010-09-30 → 2010-07-26 A (-66d) | 64d → 84d | 0% → 100% | 520d → none | 9-100M FS+184d → 9-100M | resources MECH DES [59.5 h]; MECH ENG [29.7 h] → MECH ENG [29.7 h]; MECH DES [59.5 h] |
| 13411105w | Vend Fab Curved Dipoles Peg Point #17 Additional Material for XH and XY Magnets | 2010-07-01 A | 2010-07-30 → 2010-07-26 A (-4d) | 21d → 17d | 0% → 100% | 99d → none |  |  |
| 13411165 | Proc Prep Extra Coils FY11 | 2010-10-01 → 2010-07-01 A (-92d) | 2010-11-01 → 2010-07-26 A (-98d) | 22d → 17d | 0% → 100% | 520d → none |  | resources MECH ENG [10.3 h]; MECH DES [20.5 h] → MECH DES [20.5 h]; MECH ENG [10.3 h] |
| 13411200 | Spreader Recombiner Dipole Refurb and Mod Documentation FY10 | 2010-07-01 A | 2010-09-30 → 2011-01-24 A (+116d) | 64d → 136.11d | 0% → 100% | 340d → none |  |  |
| 13411200a | Spreader Recombiner Dipole Refurb and Mod Documentation FY11 | 2010-10-01 → 2010-07-01 A (-92d) | 2010-12-30 → 2011-01-24 A (+25d) | 58d → 137d | 0% → 100% | 340d → none | 13411200 → 9-100M FS+184d, 13411200 |  |
| 13411087F | Vend Fab Septa (S/R Dipoles) Material Annealing | 2010-07-30 → 2010-08-02 A (+3d) | 2010-10-29 → 2010-10-25 A (-4d) | 65d → 60d | 0% → 100% | 506d → none |  | resources PROCUREMENT<$50K 60 NO ESCALATION; PROCUREMENT>$50K 69 NO ESCALATION → PROCUREMENT>$50K 69 NO ESCALATION; PROCUREMENT<$50K 60 NO ESCALATION |
| 13411105x | Vend Fab Curved Dipoles Peg Point #18 Receipt and Acceptance XH and XY Magnets | 2010-09-28 → 2010-08-02 A (-57d) | 2011-09-30 → 2011-08-15 A (-46d) | 251d → 258d | 0% → 100% | 99d → none | 13411105w FS+40d → 13411105w | resources PROCUREMENT<$50K 60 NO ESCALATION; PROCUREMENT>$50K 69 NO ESCALATION → PROCUREMENT>$50K 69 NO ESCALATION; PROCUREMENT<$50K 60 NO ESCALATION |
| 13411170M | Award Vend Fab Extra Coils | 2010-11-02 → 2010-08-30 A (-64d) | 2010-11-02 → 2010-08-30 A (-64d) |  | 0% → 100% | 520d → none |  |  |
| 13411175 | Vend Fab Extra Coils Oversight | 2010-11-02 → 2010-08-30 A (-64d) | 2011-07-01 → 2011-06-30 A (-1d) | 163d → 207d | 0% → 100% | 520d → none |  |  |
| 13411180 | Vend Fab Extra Coils 1st Article | 2010-11-02 → 2010-08-30 A (-64d) | 2011-03-01 → 2011-03-14 A (+13d) | 76d → 130d | 0% → 100% | 520d → none |  |  |
| 13411185 | Vend Fab Extra Coils Production (18) | 2010-11-02 → 2010-08-30 A (-64d) | 2011-07-01 → 2011-06-20 A (-11d) | 163d → 199d | 0% → 100% | 520d → none |  | was named Vend Fab Extra Coils Production (19) |
| 13411066 | P-2 Vend Fab H Steel (S/R Dipoles) | 2011-01-04 → 2010-09-02 A (-124d) | 2011-09-02 → 2011-10-17 A (+45d) | 170d → 279d | 0% → 100% | 169d → none | 13411065b FS-53d, 13411065a FS-53d → 13411065a FS-95d, 13411065 FS-95d, 13411065b FS-95d |  |
| 13411136a | Proc Prep BCOMM and Additional Steel FY11 | 2010-10-01 → 2010-09-13 A (-18d) | 2010-11-01 → 2010-09-30 A (-32d) | 22d → 14d | 0% → 100% | 285d → none |  |  |
| 13411108M | Deliver First Curved Dipoles (S/R Dipoles) | 2010-06-30 → 2010-09-27 A (+89d) | 2010-06-30 → 2010-09-27 A (+89d) |  | 0% → 100% | 252d → none | 13411105g, 13411100M FS+208d → 13411105g, 13411100M |  |
| 13411086BLOE | Vend Fab Septa (S/R Dipoles) LABOR FY11 | 2010-10-01 A | 2011-06-03 A |  | 0% → 100% | 362d → none |  |  |
| 13411911LOE | FY11 Mngmnt & Oversight (S/R Dipoles) | 2010-10-01 A | 2011-09-30 A |  | 0% → 100% | 20d → none |  |  |
| 13411140 | Mag Measurment of New C & Curved Dipoles (S/R Dipoles) FY11 | 2011-08-25 → 2011-01-17 A (-220d) | 2011-09-30 → 2012-04-16 A (+199d) | 26d → 310.71d | 0% → 100% | 46d → none | 13411110M FS+80d, 13411130M FS-5d → 13411130M FS-250d, 13411110M FS-250d, 13411105v FS-200d, 13411105x FS-200d | resources MECH TECH [84.8 h]; MECH ENG [56 h] → MECH ENG [56 h]; MECH TECH [84.8 h] |
| 13411140a | Mag Measurment of New C & Curved Dipoles (S/R Dipoles) FY12 | 2011-10-03 → 2011-01-17 A (-259d) | 2012-03-08 → 2012-04-16 A (+39d) | 104d → 311d | 0% → 100% | 46d → none | 13411140 → 13411140 FS-110d |  |
| 13411136M | Award Vend Fab BCOMM and Additional Steel | 2010-11-02 → 2011-02-01 A (+91d) | 2010-11-02 → 2011-02-01 A (+91d) |  | 0% → 100% | 285d → none | 13411136a → 13411136a FS+60d |  |
| 13411137 | Vend Fab BCOMM and Additional Steel Oversight | 2010-11-02 → 2011-02-01 A (+91d) | 2011-07-01 → 2012-02-13 A (+227d) | 163d → 257d | 0% → 100% | 520d → none |  |  |
| 13411138 | Vend Fab BCOMM and Additional Steel (Materials) | 2010-11-02 → 2011-02-01 A (+91d) | 2011-09-30 → 2011-08-30 A (-31d) | 226d → 148d | 0% → 100% | 285d → none |  |  |
| 13411138a | Vend Fab BCOMM and Additional Steel (Machining) | 2011-10-03 → 2011-02-01 A (-244d) | 2012-03-30 → 2012-02-13 A (-46d) | 120d → 257d | 0% → 100% | 285d → none | 9-120M, 13411138 → 13411138 FS-163d |  |
| 13411190 | Receive and Inspect Extra Coils | 2011-02-01 → 2011-03-01 A (+28d) | 2011-07-01 → 2011-08-01 A (+31d) | 107d → 108d | 0% → 100% | 520d → none |  |  |
| 13411087G | Vend Fab Septa (S/R Dipoles) Peg Point #1 Receipt of Material | 2011-03-29 A | 2011-08-31 A |  | 0% → 100% | 181d → none |  |  |
| 13411087H | Vend Fab Septa (S/R Dipoles) Peg Point #2 Acceptance and Shipping of First Article ZA Magnet Assembly | 2011-03-29 A | 2011-11-30 → 2012-10-15 A (+320d) | 172d → 389d | 0% → 100% | 181d → none |  |  |
| 13411087J | Vend Fab Septa (S/R Dipoles) Peg Point #3 Delivery and Acceptance of Quantity 4 ZA Magnet Assemblies | 2011-03-29 A | 2011-12-29 → 2013-02-11 A (+410d) | 188d → 439d | 0% → 100% | 181d → none |  |  |
| 13411087K | Vend Fab Septa (S/R Dipoles) Peg Point #4 Delivery and Acceptance of Quantity 3 ZA Magnet Assemblies | 2011-03-29 A | 2012-01-31 → 2013-06-17 A (+503d) | 209d → 439d | 0% → 100% | 181d → none |  |  |

| ID | Task | Start | Finish | Duration | Complete | Total float | Predecessors | Other |
| --- | --- | --- | --- | --- | --- | --- | --- | --- |
| 13411087N | Vend Fab Septa (S/R Dipoles) Peg Point #5 Delivery and Acceptance of ZA Spare Coil Set | 2011-03-29 A | 2012-01-31 → 2013-08-30 A (+577d) | 209d → 476d | 0% → 100% | 181d → none |  |  |
| 13411087P | Vend Fab Septa (S/R Dipoles) Peg Point #6 Delivery and Acceptance of Quantity 2 YA Magnet Assemblies | 2011-03-29 A | 2012-02-29 → 2013-06-17 A (+474d) | 229d → 476d | 0% → 100% | 181d → none |  |  |
| 13411087Q | Vend Fab Septa (S/R Dipoles) Peg Point #7 Delivery and Acceptance of Quantity 2 ZB Coil Sets | 2011-03-29 A | 2012-02-29 → 2013-08-30 A (+548d) | 229d → 476d | 0% → 100% | 181d → none |  |  |
| 13411087C5 | Vend Fab Septa (S/R Dipoles) Deliver (3) ZA Magnet Assemblies (WANG Additional Cost to Terminate) | 2011-06-01 A | 2011-07-29 → 2011-06-20 A (-39d) | 42d → 14d | 0% → 100% | 323d → none |  |  |
| 13411087D05 | Vend Fab Septa (S/R Dipoles) Deliver ZA Spare Coil Set (Reverse Entry per CR 11-041) | 2011-06-01 A | 2011-07-29 → 2011-06-20 A (-39d) | 42d → 14d | 0% → 100% | 323d → none |  |  |
| 13411087D15 | Vend Fab Septa (S/R Dipoles) Deliver (2) YA Magnet Assemblies (Reverse Entry per CR 11-041) | 2011-06-01 A | 2011-11-30 → 2011-06-20 A (-163d) | 127d → 14d | 0% → 100% | 238d → none |  |  |
| 13411087D7 | Vend Fab Septa (S/R Dipoles) Deliver (2) ZB Coil Sets (Reverse Entry per CR 11-041) | 2011-06-01 A | 2011-12-30 → 2011-06-20 A (-193d) | 144d → 14d | 0% → 100% | 221d → none |  |  |
| 13411087F5 | Stangenes Septa Contract Oversight Labor FY11 | 2011-06-01 A | 2011-09-30 → 2012-02-29 A (+152d) | 86d → 183.27d | 0% → 100% | 181d → none |  |  |
| 13411087F5a | Stangenes Septa Contract Oversight Labor FY12 | 2011-10-03 → 2011-06-01 A (-124d) | 2012-02-29 A | 98d → 184d | 0% → 100% | 181d → none | 13411087F5 → 13411087F5 FS-105d |  |
| 13411087F7 | Completion of Core Machining | 2011-06-01 A | 2011-12-30 → 2012-04-16 A (+108d) | 144d → 217d | 0% → 100% | 221d → none |  | was named Completion of Core Macining |
| 13411110M | Delivery Complete for Curved Dipoles (S/R DIPOLES) | 2011-02-28 → 2011-08-30 A (+183d) | 2011-02-28 → 2011-08-30 A (+183d) |  | 0% → 100% | 91d → none | 13411106a, 13411105r, 13411108M → 13411106, 13411105r, 13411108M, 13411105x, 13411106a |  |
| 13411135 | Proc & Vend Fab Misc shims & Brackets (S/R Dipoles) Labor FY10 | 2010-01-05 → 2011-09-02 A (+605d) | 2010-09-30 → 2012-02-19 A (+507d) | 188d → 111d | 0% → 100% | 399d → none | 13411909LOE, 9-100M FS+60d → 9-100M FS+60d, 13411909LOE, 9-120M |  |
| 13411135a | Proc & Vend Fab Misc shims & Brackets (S/R Dipoles) Labor FY11 | 2010-10-01 → 2011-09-02 A (+336d) | 2011-09-30 → 2012-02-17 A (+140d) | 248d → 110d | 0% → 100% | 399d → none | 13411135 → 13411135 FS-70d, 9-100M FS+60d, 13411909LOE | resources MECH TECH [20.08 h]; MECH DES [20.08 h]; MECH ENG [20.08 h] → MECH DES [20.08 h]; MECH ENG [20.08 h]; MECH TECH [20.08 h] |
| 13411135ab | Proc & Vend Fab Misc shims & Brackets (S/R Dipoles) Labor FY12 | 2011-10-03 → 2011-09-02 A (-31d) | 2011-12-30 → 2012-02-19 A (+51d) | 58d → 111d | 0% → 100% | 399d → none | 13411135a → 13411135a FS-60d |  |
| 13411135b | Proc & Vend Fab Misc shims & Brackets (S/R Dipoles) Procurement | 2011-12-14 → 2011-09-02 A (-103d) | 2012-04-30 → 2012-04-16 A (-14d) | 91d → 151d | 0% → 100% | 316d → none | 13411909LOE, 9-120M FS+50d → 13411909LOE |  |
| 13411195 | Magnet End Shim Form Factor Documentation | 2010-11-03 → 2011-10-03 A (+334d) | 2011-03-31 → 2012-05-14 A (+410d) | 97d → 151d | 0% → 100% | 585d → none | 9-110M FS+23d → 9-120M, 9-110M FS+23d |  |
| 13411912LOE | FY12 Mngmnt & Oversight (S/R Dipoles) | 2011-10-03 A | 2012-09-28 A |  | 0% → 100% | 20d → none |  |  |
| 13411070M | Deliver Complete for H Steel for S/R Dipoles (S/R DIPOLES) | 2011-09-02 → 2011-10-17 A (+45d) | 2011-09-02 → 2011-10-17 A (+45d) |  | 0% → 100% | 169d → none |  | was named Delivery Complete for H Steel for S/R Dipoles (S/R DIPOLES) |
| 13411196 | Procurement of CNC Machining Center | 2011-12-01 A | 2012-03-30 → 2012-05-14 A (+45d) | 79d → 110d | 0% → 100% | 30d → none |  |  |
| 13411130M | Delivery Complete for C Dipoles & Coils (S/R DIPOLES) | 2011-08-31 → 2011-12-12 A (+103d) | 2011-08-31 → 2011-12-12 A (+103d) |  | 0% → 100% | 46d → none | 13411126a, 13411105u → 13411105q, 13411126a, 13411105u, 13411126 | was named Delivery Complete for C Dipoles & Coils (S/R DIPOLES) (IPL 534213060 and 534213120) |
| 13411139 | Receive and Inspect BCOMM and Additional Steel | 2012-04-02 → 2012-02-13 A (-49d) | 2012-08-30 → 2012-04-16 A (-136d) | 107d → 45d | 0% → 100% | 285d → none |  |  |
| 13411145 | Mag Measurement of Septa's (S/R Dipoles) | 2011-11-30 → 2012-05-09 A (+161d) | 2012-04-25 → 2013-08-30 A (+492d) | 98d → 188d | 0% → 100% | 12d → none | 13416048M FS-125d, 13411090M FS-227d, 13411087A → 9-120M, 13411090M FS-120d, 13416048M FS-125d, 13411087A |  |
| 13411088M | First Septa Dipole Delivery | 2011-11-30 → 2012-05-09 A (+161d) | 2011-11-30 → 2012-05-09 A (+161d) |  | 0% → 100% | 238d → none |  |  |
| 13411088 | Septa Core Shipping Costs | 2012-10-01 A | 2012-10-26 → 2012-10-15 A (-11d) | 20d → 11d | 0% → 100% | 12d → none |  |  |
| 13411150LOE | Management Oversight of Septa's (S/R Dipoles) 2012 ETC | 2012-10-01 A | 2013-01-31 A |  | 0% → 100% | 157d → none |  |  |
| 13411950 | Re-Baseline Actuals Adjustment | 2013-08-30 A | 2013-08-30 A |  | 0% → 100% | 20d → none | 9-130M FS+227d → none |  |
| 13411090M | Delivery Complete for Septa (S/R DIPOLES) | 2012-10-26 → 2013-08-30 A (+308d) | 2012-10-26 → 2013-08-30 A (+308d) |  | 0% → 100% | 12d → none | 13411087D15, 13411087F, 13411087D10, 13411087F5a, 13411087C, 13411087D7, 13411087D5, 13411087F7, 13411088M, 13411087, 13411087D, 13411087Q, 13411087D05, 13411087A, 13411087C5, 13411086BLOE, 13411087B, 13411088 → 13411087D10, 13411087D5, 13411088M, 13411087F, 13411086BLOE, 13411087D15, 13411087D7, 13411087F5a, 13411087C5, 13411087Q, 13411087F7, 13411087D05, 13411088 |  |
| 23411087N | Vend Fab Septa (S/R Dipoles) Peg Point #5 Delivery and Acceptance of ZA Spare Coil Set | 2013-09-03 A | 2013-10-15 → 2013-11-15 (+31d) |  | 0% → 50% | 3d → 121d |  |  |
| 23411087Q | Vend Fab Septa (S/R Dipoles) Peg Point #7 Delivery and Acceptance of Quantity 2 ZB Coil Sets | 2013-09-03 A | 2013-10-15 → 2013-11-15 (+31d) |  | 0% → 50% | 3d → 101d |  |  |
| 23411145 | Mag Measurement of Septa's (S/R Dipoles) FY13 | 2013-09-18 → 2013-09-03 A (-15d) | 2013-09-30 → 2013-09-23 A (-7d) | 9d → 20d | 0% → 100% | 3d → none | 23411090M FS-20d → 23411090M FS-50d |  |
| 23411145a | Mag Measurement of Septa's (S/R Dipoles) FY14 | 2013-10-01 → 2013-09-03 A (-28d) | 2013-10-15 → 2013-09-23 A (-22d) |  | 0% → 100% | 3d → none | 23411145, 23411090M FS-20d → 23411145 |  |
| 23411090M | Delivery Complete for Septa (S/R DIPOLES) | 2013-10-15 → 2013-11-15 (+31d) | 2013-10-15 → 2013-11-15 (+31d) |  |  | 3d → 101d |  |  |
| 4 | **1.3.4.1.4 STANDS** | 2010-01-05 → 2010-03-01 (+55d) |  |  |  |  |  |  |
| 13414055 | Vend Fab S/R Cartridges & Brackets (S/R Stands) (Original) | 2010-01-05 → 2010-03-01 A (+55d) | 2010-02-26 → 2010-03-01 A (+3d) | 37d → 1d | 0% → 100% | 549d → none |  |  |
| 13414015 | Prcrmnt Prep of New S/R Stands (S/R Stands) Initial | 2010-03-01 → 2010-03-22 A (+21d) | 2010-05-14 → 2010-07-29 A (+76d) | 55d → 92d | 0% → 100% | 298d → none |  | resources MECH ENG [1600 h]; MECH DES [3200 h] → MECH DES [3200 h]; MECH ENG [1600 h] |
| 13414017 | Prcrmnt Prep of New S/R Stands (S/R Stands) Final | 2010-12-01 → 2010-08-23 A (-100d) | 2011-09-30 → 2011-04-25 A (-158d) | 207d → 165d | 0% → 100% | 161d → none | 121414015a, 9-110M FS+41d, 13414015, 121414020a, 121414016, 121416010 → 121414016, 9-110M FS-20d, 13414015, 121416010, 121414020a, 121414015a | resources MECH DES [1600 h]; MECH ENG [800 h] → MECH ENG [800 h]; MECH DES [1600 h] |
| 13414060 | Procurement Prep of S/R Brackets (S/R Stands) | 2011-05-27 → 2011-02-01 A (-115d) | 2011-09-30 → 2012-04-16 A (+199d) | 88d → 301d | 0% → 100% | 75d → none | 9-120M FS-88d → 9-110M | resources MECH ENG [240 h]; MECH DES [160 h] → MECH DES [160 h]; MECH ENG [240 h] |
| 13414100 | Vend Fab New Girders for S/R (S/R Stands) | 2011-04-01 → 2011-12-01 A (+244d) | 2011-07-28 → 2012-04-16 A (+263d) | 83d → 90d | 0% → 100% | 502d → none | 9-110M FS+120d → 9-120M, 9-110M FS+120d |  |
| 13414022LOE | Vend Fab New S/R Stands (S/R Stands) Oversight | 2011-12-14 A | 2012-05-14 → 2012-04-16 A (-28d) | 101d → 81d | 0% → 100% | 174d → none | 13414020M FS-91d → 13414020M FS-40d |  |
| 13414070LOE | Vend Fab S/R Brackets (S/R Stands) Oversight | 2011-12-21 A | 2012-03-30 A |  | 0% → 100% | 129d → none | 13414065M, 13414060 → 13414060 FS-20d, 13414065M FS-40d | resources MECH DES [40 h]; MECH ENG [40 h] → MECH ENG [40 h]; MECH DES [40 h] |
| 13414028 | Reverse Entry Per CR 12-035 | 2012-04-02 A | 2012-04-20 → 2012-04-09 A (-11d) | 15d → 6d | 0% → 100% | 112d → none |  |  |
| 13414090 | Receive and Inspect S/R Brackets (S/R Stands) Frozen Per CR 12-035 | 2012-03-20 → 2012-04-02 A (+13d) | 2012-03-30 → 2012-04-09 A (+10d) | 9d → 6d | 0% → 100% | 129d → none | 9-120M FS+111d → 13414075 FS-30d |  |
| 13414027 | Receive and Inspect to S/R Stands Frozen Per CR 12-035 | 2012-03-28 → 2012-04-09 A (+12d) | 2012-03-30 → 2012-04-16 A (+17d) | 3d → 6d | 0% → 100% | 205d → none | 9-120M FS+117d → none |  |
| 13414020M | Award Contract for New S/R Stands (S/R STANDS) | 2012-05-01 → 2012-04-16 A (-15d) | 2012-05-01 → 2012-04-16 A (-15d) |  | 0% → 100% | 20d → none |  |  |
| 13414025A | Vend Fab Stands Peg Point #1 Receipt of Material | 2012-05-01 → 2012-04-16 A (-15d) | 2012-07-31 → 2012-06-11 A (-50d) | 64d → 39d | 0% → 100% | 20d → none |  |  |
| 13414025B | Vend Fab Stands Peg Point #2 Receipt and Acceptance of Finished Stands 002-015 (Qty 14) | 2012-05-01 → 2012-04-16 A (-15d) | 2012-08-31 A | 87d → 98d | 0% → 100% | 20d → none |  |  |
| 13414025C | Vend Fab Stands Peg Point #3 Receipt and Acceptance of Finished Stands 016-029 (Qty 14) | 2012-05-01 → 2012-04-16 A (-15d) | 2012-09-28 → 2012-09-17 A (-11d) | 106d → 108d | 0% → 100% | 20d → none |  |  |
| 13414025D | Vend Fab Stands Peg Point #4 Receipt and Acceptance of Finished Stands 030-040 (Qty 11) | 2012-05-01 → 2012-04-16 A (-15d) | 2012-10-31 → 2012-10-22 A (-9d) | 129d → 133d | 0% → 100% | 20d → none |  |  |
| 13414025F | Vend Fab Stands Peg Point #5 Receipt and Acceptance of Finished Stands 041-051 (Qty 11) | 2012-05-01 → 2012-04-16 A (-15d) | 2012-11-30 → 2012-11-12 A (-18d) | 149d → 171d | 0% → 100% | 20d → none |  |  |
| 13414025G | Vend Fab Stands Peg Point #6 Receipt and Acceptance of Finished Stands 052-071 (Qty 20) | 2012-05-01 → 2012-04-16 A (-15d) | 2012-12-31 → 2012-12-17 A (-14d) | 165d → 176d | 0% → 100% | 20d → none |  |  |
| 13414065M | Award Contract for Brackets (S/R Stands) | 2011-12-21 → 2012-06-15 A (+177d) | 2011-12-21 → 2012-06-15 A (+177d) |  | 0% → 100% | 20d → none | 9-120M FS+55d, 13414060 → 9-120M FS+90d, 13414060 |  |
| 13414075 | Vend Fab S/R Brackets (S/R Stands) | 2011-12-21 → 2012-06-15 A (+177d) | 2012-09-28 → 2012-10-15 A (+17d) | 192d → 86d | 0% → 100% | 20d → none |  |  |
| 13414029 | Receive and Inspect to S/R Stands Revised Per CR 12-035 FY12 | 2012-08-16 → 2012-08-27 A (+11d) | 2012-09-28 → 2012-12-17 A (+80d) | 31d → 82d | 0% → 100% | 20d → none |  |  |
| 13414029a | Receive and Inspect to S/R Stands Revised Per CR 12-035 FY13 | 2012-10-01 → 2012-08-27 A (-35d) | 2012-12-21 → 2012-12-17 A (-4d) | 58d → 82d | 0% → 100% | 20d → none | 13414029 → 13414029 FS-75d |  |
| 13414092 | Receive and Inspect S/R Brackets (S/R Stands) Revised Per CR 12-035 | 2012-07-16 → 2012-08-27 A (+42d) | 2012-09-04 → 2012-10-15 A (+41d) | 36d → 35d | 0% → 100% | 20d → none |  |  |
| 13414095M | Delivery Complete for S/R Cartridges & Brackets (S/R Stands) | 2012-09-04 → 2012-10-15 A (+41d) | 2012-09-04 → 2012-10-15 A (+41d) |  | 0% → 100% | 20d → none |  |  |
| 13414030M | Delivery Complete for New S/R Stands (S/R STANDS) | 2012-12-21 → 2012-12-17 A (-4d) | 2012-12-21 → 2012-12-17 A (-4d) |  | 0% → 100% | 20d → none |  |  |
| 13414105 | Re-Baseline Actuals Adjustment | 2013-08-30 A | 2013-08-30 A |  | 0% → 100% | 20d → none | 9-130M FS+227d → none |  |
| 6 | **1.3.4.1.6 VACUUM** | 2010-01-05 → 2009-12-21 (-15d) |  |  |  |  |  |  |
| 13416020 | Prcrmnt Prep of S/R Dipole Chambers (S/R Vac) Initial | 2010-01-05 → 2009-12-21 A (-15d) | 2010-03-31 → 2010-03-29 A (-2d) | 60d → 63d | 0% → 100% | 415d → none |  |  |
| 13416040 | Procurement Prep of S/R Septa Chambers (S/R Vac) | 2010-03-01 → 2010-03-22 A (+21d) | 2010-04-30 → 2010-04-23 A (-7d) | 45d → 25d | 0% → 100% | 313d → none |  |  |
| 13416042LOE | Vend Fab S/R Septa Chambers (S/R Vac) Oversight | 2010-04-22 → 2010-04-23 A (+1d) | 2010-09-22 A | 107d → 106d | 0% → 100% | 431d → none |  | resources MECH DES [40 h]; MECH ENG [40 h] → MECH ENG [40 h]; MECH DES [40 h] |
| 13416045 | Vend Fab S/R Septa Chambers- ZAs (S/R Vac) ORG | 2010-04-22 → 2010-04-23 A (+1d) | 2010-06-30 → 2011-12-19 A (+537d) | 49d → 414d | 0% → 100% | 313d → none |  |  |
| 13416046 | Vend Fab S/R Septa Chambers- YRs (S/R Vac) ORG | 2010-06-03 → 2010-04-23 A (-41d) | 2010-06-30 → 2013-01-18 A (+933d) | 20d → 663d | 0% → 100% | 313d → none | 13416045 FS-20d → 13416045 FS-105d |  |
| 13416047 | Vend Fab S/R Septa Chambers- YB (S/R Vac) | 2010-11-01 → 2010-04-23 A (-192d) | 2011-03-21 → 2012-10-15 A (+574d) | 91d → 618d | 0% → 100% | 313d → none | 13416046 FS+85d → 13416046 FS-100d |  |
| 13416025 | Prcrmnt Prep of S/R Dipole Chambers (S/R Vac) Final | 2010-10-01 → 2010-08-23 A (-39d) | 2011-03-17 → 2011-01-31 A (-45d) | 110d → 106d | 0% → 100% | 177d → none | 9-110M → 9-110M FS-20d |  |
| 13416049A | Vend Fab New Bellows (S/R Vac) | 2010-10-01 → 2010-12-01 A (+61d) | 2011-03-17 → 2011-02-21 A (-24d) | 110d → 51d | 0% → 100% | 288d → none |  |  |
| 13416046a | Vend Fab S/R Septa Chambers- YRs (S/R Vac) REDESIGN | 2010-11-01 → 2011-12-01 A (+395d) | 2011-03-21 → 2013-01-18 A (+669d) | 91d → 262d | 0% → 100% | 313d → none | 13416046 FS+85d → 13416046 FS-110d |  |
| 13416025M | Award Contract for S/R Dipole Chambers (S/R VACUUM) | 2011-11-14 → 2011-12-12 A (+28d) | 2011-11-14 → 2011-12-12 A (+28d) |  | 0% → 100% | 9d → none | 13416020, 9-120M FS+30d, 13416025 → 13416025, 13416020, 9-120M FS+50d |  |
| 13416030 | Vend Fab S/R Dipole Chambers (S/R Vac) | 2011-11-14 → 2011-12-12 A (+28d) | 2012-04-30 → 2012-04-16 A (-14d) | 111d → 83d | 0% → 100% | 9d → none |  | resources PROCUREMENT<$50K 60; PROCUREMENT>$50K 69 → PROCUREMENT>$50K 69; PROCUREMENT<$50K 60 |

| ID | Task | Start | Finish | Duration | Complete | Total float | Predecessors | Other |
| --- | --- | --- | --- | --- | --- | --- | --- | --- |
| 13416045a | Vend Fab S/R Septa Chambers- ZAs (S/R Vac) REDESIGN FY10 | 2010-09-01 → 2011-12-19 A (+474d) | 2010-09-30 → 2013-06-17 A (+991d) | 21d → 250d | 0% → 100% | 368d → none | 13416045 FS+43d → 13416045 |  |
| 13416045ab | Vend Fab S/R Septa Chambers- ZAs (S/R Vac) REDESIGN FY11 | 2010-10-01 → 2011-12-19 A (+444d) | 2010-12-29 → 2013-06-17 A (+901d) | 57d → 250d | 0% → 100% | 368d → none | 13416045a → 13416045a FS-80d, 13416045 |  |
| 13416032 | Receive and Inspect S/R Dipole Chambers (S/R Vac) | 2012-04-17 → 2012-03-12 A (-36d) | 2012-04-30 → 2012-04-16 A (-14d) | 10d → 26d | 0% → 100% | 9d → none | 13416030 FS-10d → 13416030 FS-30d | resources MECH ENG [60 h]; MECH TECH [80 h] → MECH TECH [80 h]; MECH ENG [60 h] |
| 13416049B | Proc Vac Materials Flanges/Gaskets/Hardware (S/R Vac) | 2010-10-01 → 2012-03-19 A (+535d) | 2011-03-17 → 2012-06-11 A (+452d) | 110d → 59d | 0% → 100% | 288d → none | 9-110M → 9-110M, 9-120M FS+85d |  |
| 13416035M | Delivery Complete for S/R Dipole Chambers (S/R VACUUM) | 2012-04-30 → 2012-04-16 A (-14d) | 2012-04-30 → 2012-04-16 A (-14d) |  | 0% → 100% | 9d → none |  |  |
| 13416049 | Vend Fab New Drift Tubes (S/R Vac) | 2012-02-15 → 2012-05-01 A (+76d) | 2012-08-29 → 2013-05-13 A (+257d) | 138d → 170d | 0% → 100% | 258d → none | 9-120M FS+88d → 9-120M FS+144d |  |
| 13416048M | Fabrication Complete S/R Septa Chambers (S/R Vac) | 2011-03-21 → 2013-06-17 A (+819d) | 2011-03-21 → 2013-06-17 A (+819d) |  | 0% → 100% | 313d → none | 13416047, 13416046a, 13416046, 13416045ab, 13416045, 13416042LOE → 13416045ab, 13416045a, 13416046a, 13416045, 13416042LOE, 13416046, 13416047 |  |
| 13416050 | Re-Baseline Actuals Adjustment | 2013-08-30 A | 2013-08-30 A |  | 0% → 100% | 20d → none | 9-130M FS+227d → none |  |
| 7 | **1.3.4.1.7 INSTALLATION** |  | 2013-11-11 → 2013-12-12 (+31d) |  |  |  |  |  |
| 13417015 | Accelerator Down Planning Activity | 2011-11-14 A | 2012-05-04 A |  | 0% → 100% | 5d → none |  |  |
| 13417155 | LCW Hoses FY12 | 2012-04-02 A | 2012-09-28 → 2012-06-11 A (-109d) | 127d → 49d | 0% → 100% | 58d → none |  | resources PROCUREMENT<$50K 60; PROCUREMENT>$50K 69 → PROCUREMENT>$50K 69; PROCUREMENT<$50K 60 |
| 13417165 | Material handling/tooling/transporation FY12 | 2012-04-02 A | 2012-09-28 A |  | 0% → 100% | 9d → none |  |  |
| 13417020 | Re-survey align network | 2012-06-18 → 2012-05-18 A (-31d) | 2012-06-29 → 2012-07-16 A (+17d) | 10d → 40d | 0% → 100% | 284d → none | 13411137, 13411139 FS-55d, 13414100, 2-02M FS+23d, 13411175, 13411195, 13411135ab, 3A-19M, 13411135b, 13411190 → 13411139 FS-55d, 13411137, 13411190, 13411175, 13411135b, 2-02M, 13411195 FS-40d, 13411135ab, 3A-19M FS-20d, 13414100 |  |
| 13417035 | ER - Upstairs | 2012-06-05 A | 2012-08-08 → 2013-03-11 A (+215d) | 47d → 140d | 0% → 100% | 273d → none |  |  |
| 13417100M | WS - Removed (BIA Activity Complete) | 2012-11-14 → 2012-06-05 A (-162d) | 2012-11-14 → 2012-06-05 A (-162d) |  | 0% → 100% | 24d → none |  |  |
| 13417060 | WR - Upstairs FY12 | 2012-07-02 → 2012-06-06 A (-26d) | 2012-09-28 → 2013-03-11 A (+164d) | 64d → 132d | 0% → 100% | 140d → none | 13417050M FS-48d → 13417050M FS-50d | resources MSHOP; MECH ENG [708.64 h]; MECH TECH [1031.42 h] → MECH ENG [708.64 h]; MECH TECH [1031.42 h]; MSHOP |
| 13417060a | WR - Upstairs FY13 | 2012-10-01 → 2012-06-06 A (-117d) | 2012-10-05 → 2013-03-11 A (+157d) | 5d → 132d | 0% → 100% | 140d → none | 13417060 → 13417060 FS-70d |  |
| 13417110 | WS - Upstairs | 2012-10-26 → 2012-06-11 A (-137d) | 2013-02-07 → 2013-03-11 A (+32d) | 66d → 129d | 0% → 100% | 24d → none |  |  |
| 13417026M | ER - Removed (BIA Activity Complete) | 2012-06-28 → 2012-06-11 A (-17d) | 2012-06-28 → 2012-06-11 A (-17d) |  | 0% → 100% | 63d → none |  |  |
| 13417030 | ER - Install stands | 2012-06-27 → 2012-07-02 A (+5d) | 2012-09-11 → 2012-12-17 A (+97d) | 54d → 117d | 0% → 100% | 63d → none |  |  |
| 13417085 | ES - Upstairs FY12 | 2012-07-23 → 2012-07-16 A (-7d) | 2012-09-28 → 2013-03-11 A (+164d) | 49d → 104d | 0% → 100% | 75d → none |  |  |
| 13417085a | ES - Upstairs FY13 | 2012-10-01 → 2012-07-16 A (-77d) | 2012-12-04 → 2013-03-11 A (+97d) | 45d → 104d | 0% → 100% | 75d → none | 13417085 → 13417085 FS-70d |  |
| 13417135 | TR - Upstairs | 2013-02-19 → 2012-08-13 A (-190d) | 2013-04-16 → 2013-08-30 A (+136d) | 41d → 93d | 0% → 100% | 46d → none | 13417125M FS-11d → 13417125M FS-140d |  |
| 13417050M | WR - Removed (BIA Activity Complete) | 2012-09-06 → 2012-08-13 A (-24d) | 2012-09-06 → 2012-08-13 A (-24d) |  | 0% → 100% | 78d → none |  |  |
| 13417080 | ES - Install stands FY12 | 2012-09-13 → 2012-08-20 A (-24d) | 2012-09-28 → 2013-03-11 A (+164d) | 12d → 86d | 0% → 100% | 163d → none |  |  |
| 13417080a | ES - Install stands FY13 | 2012-10-01 → 2012-08-20 A (-42d) | 2012-10-18 → 2013-03-11 A (+144d) | 14d → 86d | 0% → 100% | 163d → none | 13417080 → 13417080 FS-70d |  |
| 13417075M | ES - Removed (BIA Activity Complete) | 2012-09-12 → 2012-08-20 A (-23d) | 2012-09-12 → 2012-08-20 A (-23d) |  | 0% → 100% | 75d → none |  |  |
| 13417040 | ER - Install magnets and girders FY12 | 2012-09-18 → 2012-09-10 A (-8d) | 2012-09-28 → 2013-05-13 A (+227d) | 9d → 82d | 0% → 100% | 63d → none | 13417030 FS+4d → 13417030 FS-30d |  |
| 13417040a | ER - Install magnets and girders FY13 | 2012-10-01 → 2012-09-10 A (-21d) | 2013-01-11 → 2013-05-13 A (+122d) | 67d → 82d | 0% → 100% | 63d → none | 13417040 → 13417040 FS-70d |  |
| 13417055 | WR - Install stands | 2012-11-20 → 2012-09-10 A (-71d) | 2013-01-11 → 2013-04-13 A (+92d) | 31d → 82d | 0% → 100% | 78d → none | 13447035 → 13447035 FS-50d |  |
| 13417105 | WS - Install stands | 2012-11-15 → 2012-10-01 A (-45d) | 2012-12-17 → 2013-08-09 A (+235d) | 21d → 50d | 0% → 100% | 55d → none |  | resources MECH TECH [752 h]; MECH ENG [168 h] → MECH ENG [168 h]; MECH TECH [752 h] |
| 13417160 | LCW Hoses FY13 | 2012-10-01 A | 2013-03-29 → 2013-02-11 A (-46d) |  | 0% → 100% | 58d → none | 13417155 → 13417155, 9-130M FS+22d |  |
| 13417170 | Material handling/tooling/transporation FY13 | 2012-10-01 A | 2013-08-30 A |  | 0% → 100% | 9d → none |  |  |
| 13417090 | ES - Install magnets & girders | 2013-03-06 → 2012-11-12 A (-114d) | 2013-05-14 → 2013-07-15 A (+62d) | 50d → 122d | 0% → 100% | 75d → none | 13417080a, 13417085a FS+57d → 13417085a FS-60d, 13417080a FS-20d | resources MECH ENG [344 h]; MECH TECH [1528 h] → MECH TECH [1528 h]; MECH ENG [344 h] |
| 13417115 | WS - Install magnets and girders | 2013-02-08 → 2013-01-11 A (-28d) | 2013-06-11 → 2013-08-30 A (+80d) |  | 0% → 100% | 24d → none | 13417110, 13417105 → 13417105 FS-15d, 13417110 FS-35d |  |
| 13417065 | WR - Install magnets & girders | 2013-01-14 A | 2013-04-16 → 2013-08-16 A (+122d) |  | 0% → 100% | 78d → none | 13417060a, 13417055 → 13417060a FS-40d, 13417055 FS-20d |  |
| 13417130 | TR - Install stands | 2013-03-06 → 2013-02-01 A (-33d) | 2013-04-04 → 2013-08-30 A (+148d) |  | 0% → 100% | 59d → none | 13417125M → 13417125M FS-10d |  |
| 13417140 | TR - Install magnets and girders | 2013-04-24 → 2013-03-04 A (-51d) | 2013-06-28 → 2013-08-30 A (+63d) |  | 0% → 100% | 46d → none | 13417130, 13417135 FS+5d → 13417130 FS-25d, 13417135 FS-25d |  |
| 13417125M | TR - Removed (BIA Activity Complete) | 2013-03-05 → 2013-03-11 A (+6d) | 2013-03-05 → 2013-03-11 A (+6d) |  | 0% → 100% | 46d → none |  |  |
| 13417045 | ER - Final align | 2013-04-01 → 2013-06-03 A (+63d) | 2013-04-10 → 2013-07-15 A (+96d) |  | 0% → 100% | 58d → none | 13417040a FS+48d, 13417160 → 13417160, 13417040a |  |
| 13417095 | ES - Final align | 2013-07-29 → 2013-07-08 A (-21d) | 2013-08-02 → 2013-08-07 A (+5d) |  | 0% → 100% | 24d → none |  |  |
| 13417070 | WR - Final align | 2013-07-03 → 2013-08-01 A (+29d) | 2013-07-15 → 2013-08-26 A (+42d) |  | 0% → 100% | 24d → none |  |  |
| 13417120 | WS - Final align | 2013-06-12 → 2013-08-12 A (+61d) | 2013-06-18 → 2013-08-30 A (+73d) |  | 0% → 100% | 24d → none |  | resources MECH ENG [44 h]; MECH TECH [200 h] → MECH TECH [200 h]; MECH ENG [44 h] |
| 13417145 | TR - Final align | 2013-07-01 → 2013-08-30 A (+60d) | 2013-07-05 → 2013-08-30 A (+56d) |  | 0% → 100% | 46d → none |  |  |
| 13417150 | Alignment complete | 2013-08-07 → 2013-08-30 A (+23d) | 2013-08-09 → 2013-08-30 A (+21d) |  | 0% → 100% | 24d → none | 13427061, 13417145, 13427032 → 13456029, 13417145, 13427032, 13427061, 13456030M |  |
| 13417175 | Re-Baseline Actuals Adjustment | 2013-08-30 A | 2013-08-30 A |  | 0% → 100% | 20d → none | 9-130M FS+227d → none |  |
| 23417065 | WR - Install magnets & girders | 2013-09-03 A | 2013-09-30 → 2013-09-23 A (-7d) |  | 0% → 100% | 4d → none |  |  |
| 23417115 | WS - Install magnets and girders | 2013-09-03 A | 2013-09-17 → 2013-09-23 A (+6d) |  | 0% → 100% | 27d → none |  |  |
| 23417120 | WS - Final align | 2013-09-03 A | 2013-09-19 → 2013-09-23 A (+4d) |  | 0% → 100% | 27d → none |  |  |
| 23417130 | TR - Install stands | 2013-09-03 A | 2013-09-24 → 2013-11-22 (+59d) |  | 0% → 85% | 4d → 23d |  |  |
| 23417140 | TR - Install magnets and girders FY13 | 2013-09-03 A | 2013-09-30 → 2013-11-22 (+53d) | 20d → 21d | 0% → 95% | 4d → 23d |  |  |
| 23417140a | TR - Install magnets and girders FY14 | 2013-10-01 → 2013-09-03 A (-28d) | 2013-10-01 → 2013-11-22 (+52d) |  | 0% → 95% | 4d → 23d | 23417140, 23417130 FS-16d → 23417140 FS-25d |  |
| 23417165 | Procure S/R plumbing materials | 2013-09-03 A | 2013-09-30 → 2013-10-21 A (+21d) |  | 0% → 100% | 4d → none |  |  |
| 23417170 | Procure S/R Vacuum materials | 2013-09-03 A | 2013-09-30 → 2013-09-23 A (-7d) |  | 0% → 100% | 4d → none |  |  |
| 23417145 | TR - Final align FY13 | 2013-09-30 → 2013-10-21 A (+21d) | 2013-09-30 → 2013-11-27 (+58d) |  | 0% → 50% | 4d → 19d | 23417140 FS-2d, 23417140a FS-2d → 23417140 FS-20d, 23417140a FS-20d |  |
| 23417145a | TR - Final align FY14 | 2013-10-01 → 2013-10-21 A (+20d) | 2013-10-29 → 2013-11-27 (+29d) | 21d → 4d | 0% → 50% | 4d → 19d | 23417145, 23417140a FS-2d, 23417140 FS-2d → 23417145 FS-20d, 23417140a FS-20d |  |
| 23417150 | Alignment complete | 2013-11-07 → 2013-12-10 (+33d) | 2013-11-11 → 2013-12-12 (+31d) |  |  | 4d → 79d |  |  |
| 2 | **1.3.4.2 EXISTING ARCS (1-9, A, B, & C)** |  | 2013-11-18 → 2013-11-27 (+9d) |  |  |  |  |  |
| 13421909LOE | FY09 Mngmnt & Oversight (EXIST ARC Dipoles) | 2009-01-02 A | 2009-09-30 A |  | 0% → 100% | 20d → none |  |  |
| 13421025 | Prcrmnt Prep for New Hall A&C Dipoles | 2009-01-12 → 2009-03-16 A (+63d) | 2009-06-26 → 2009-07-27 A (+31d) | 117d → 94d | 0% → 100% | 321d → none | 9-090M FS+65d → 9-090M | resources MECH ENG [44 h]; MECH DES [40 h] → MECH DES [40 h]; MECH ENG [44 h] |
| 13421030 | Vendor Fab New Hall A&C Dipoles Original Labor FY10 | 2009-06-29 → 2009-07-01 A (+2d) | 2010-09-30 → 2009-07-27 A (-430d) | 314d → 18d | 0% → 100% | 321d → none |  | resources MECH DES [73.88 h]; MECH ENG [170.25 h] → MECH ENG [170.25 h]; MECH DES [73.88 h] |
| 13421030a | Vendor Fab New Hall A&C Dipoles Original Labor FY11 | 2010-10-01 → 2009-07-01 A (-457d) | 2011-01-28 → 2009-07-27 A (-550d) | 77d → 18d | 0% → 100% | 321d → none | 13421030 → 13421030, 13421025 | resources MECH DES [18.12 h]; MECH ENG [41.75 h] → MECH ENG [41.75 h]; MECH DES [18.12 h] |
| 13421050M | Delivery Complete for Magnet Steel & Conductor (EXIST ARC DIPOLES) | 2009-06-29 → 2009-07-27 A (+28d) | 2009-06-29 → 2009-07-27 A (+28d) |  | 0% → 100% | 1361d → none |  |  |
| 13421055 | Prcrmnt Prep for H Steel (EXIST ARC Dipoles) | 2009-10-05 → 2009-08-25 A (-41d) | 2010-03-19 → 2010-01-22 A (-56d) | 110d → 99d | 0% → 100% | 169d → none | 121425015, 121421021, 121421020, 13411055 FS-110d → 13411055 FS-110d, 121421021 FS-500d, 121421020 FS-500d, 121425015 FS-500d |  |
| 13421910LOE | FY10 Mngmnt & Oversight (EXIST ARC Dipoles) | 2009-10-01 A | 2010-09-30 A |  | 0% → 100% | 20d → none |  |  |
| 13421046 | Fabrication of Existing Arc Dipole Rebuild Parts (Procurement Prep) | 2009-01-12 → 2009-11-02 A (+294d) | 2009-05-29 → 2010-07-28 A (+425d) | 97d → 181d | 0% → 100% | 89.54d → none |  | was named Fabrication of Existing Arc Dipole Rebuild Parts; resources MECH TECH [72 h]; MECH ENG [72 h]; MECH DES [21 h] → MECH DES [21 h]; MECH TECH [72 h]; MECH ENG [72 h] |
| 13421060M | Award Contract for H Steel (EXIST ARC DIPOLES) | 2010-03-22 → 2010-01-22 A (-59d) | 2010-03-22 → 2010-01-22 A (-59d) |  | 0% → 100% | 169d → none |  |  |
| 13421065 | P-1 Vend Fab H Steel (EXIST ARC Dipoles) Labor FY10 | 2010-03-22 → 2010-03-15 A (-7d) | 2010-09-30 → 2011-06-27 A (+270d) | 136d → 321.71d | 0% → 100% | 169d → none |  | resources MECH DES [21.94 h]; MECH ENG [21.94 h] → MECH ENG [21.94 h]; MECH DES [21.94 h] |
| 13421065a | P-1 Vend Fab H Steel (EXIST ARC Dipoles) Labor FY11 | 2010-10-01 → 2010-03-15 A (-200d) | 2011-03-21 → 2011-06-27 A (+98d) | 112d → 321.8d | 0% → 100% | 169d → none | 13421065 → 13421060M |  |
| 13421065b | P-1 Vend Fab H Steel (EXIST ARC Dipoles) Procurement | 2010-03-22 → 2010-03-15 A (-7d) | 2011-03-21 → 2011-02-28 A (-21d) | 248d → 238d | 0% → 100% | 169d → none |  | resources PROCUREMENT<$50K 60 NO ESCALATION FY11; PROCUREMENT>$50K 69 NO ESCALATION FY11 → PROCUREMENT>$50K 69 NO ESCALATION FY11; PROCUREMENT<$50K 60 NO ESCALATION FY11 |

| ID | Task | Start | Finish | Duration | Complete | Total float | Predecessors | Other |
| --- | --- | --- | --- | --- | --- | --- | --- | --- |
| 13421046a | Fabrication of Existing Arc Dipole Rebuild Parts (Labor) FY10 | 2010-05-03 → 2010-08-23 A (+112d) | 2010-09-30 → 2011-02-28 A (+151d) | 105d → 125d | 0% → 100% | 89.54d → none | 13421046 FS+228.46d → 13421046 FS-60d | resources MECH DES [14.62 h]; MECH TECH [45.78 h]; MECH ENG [45.78 h] → MECH ENG [45.78 h]; MECH DES [14.62 h]; MECH TECH [45.78 h] |
| 13421046ab | Fabrication of Existing Arc Dipole Rebuild Parts (Labor) FY11 | 2010-09-30 → 2010-08-23 A (-38d) | 2011-01-05 → 2011-02-28 A (+54d) | 61d → 124.1d | 0% → 100% | 89.54d → none | 13421046a → 13421046 FS-60d | resources MECH DES [8.38 h]; MECH TECH [26.22 h]; MECH ENG [26.22 h] → MECH ENG [26.22 h]; MECH DES [8.38 h]; MECH TECH [26.22 h] |
| 13421046b | Fabrication of Existing Arc Dipole Rebuild Parts (proc) | 2010-05-03 → 2010-08-23 A (+112d) | 2011-01-05 → 2011-02-28 A (+54d) | 166d → 125d | 0% → 100% | 89.54d → none | 13421046 FS+228.46d → 13421046 FS-60d | resources PROCUREMENT>$50K 69 NO ESCALATION FY11; PROCUREMENT<$50K 60 NO ESCALATION FY11 → PROCUREMENT<$50K 60 NO ESCALATION FY11; PROCUREMENT>$50K 69 NO ESCALATION FY11 |
| 13421095 | Vend Fab Survey Instrument | 2010-10-01 → 2010-09-13 A (-18d) | 2010-11-29 → 2010-10-25 A (-35d) | 40d → 31d | 0% → 100% | 110d → none |  | resources MECH ENG [40 h]; PROCUREMENT<$50K 60; PROCUREMENT>$50K 69 → PROCUREMENT<$50K 60; PROCUREMENT>$50K 69; MECH ENG [40 h] |
| 13421066 | P-2 Vend Fab H Steel (EXIST ARC Dipoles) | 2011-01-04 → 2010-10-01 A (-95d) | 2011-09-02 → 2011-06-14 A (-80d) | 170d → 172d | 0% → 100% | 169d → none | 13421065a FS-53d, 13421065b FS-53d → 13421065 FS-95d, 13421065a FS-95d, 13421065b FS-95d | resources PROCUREMENT>$50K 69; MECH ENG [20 h]; MECH DES [20 h]; PROCUREMENT<$50K 60 → PROCUREMENT<$50K 60; PROCUREMENT>$50K 69; MECH ENG [20 h]; MECH DES [20 h] |
| 13421911LOE | FY11 Mngmnt & Oversight (EXIST ARC Dipoles) | 2010-10-01 A | 2011-09-30 A |  | 0% → 100% | 20d → none |  |  |
| 13421085 | Vendor Fab and Delivery of Magnet Refurbishment Crane | 2010-09-13 → 2010-10-11 A (+28d) | 2010-11-19 → 2011-02-28 A (+101d) | 50d → 91d | 0% → 100% | 54d → none |  |  |
| 13421090 | Installation of Magnetic Refurbishment Crane | 2010-11-22 → 2010-10-11 A (-42d) | 2011-02-25 → 2011-02-28 A (+3d) | 60d → 91d | 0% → 100% | 54d → none | 13421085 → 13421085 FS-50d | resources PROCUREMENT<$50K 60; MECH TECH [120 h]; PROCUREMENT>$50K 69 → PROCUREMENT>$50K 69; MECH TECH [120 h]; PROCUREMENT<$50K 60 |
| 13421067M | Delivery of First Article H Steel | 2011-02-22 → 2010-11-15 A (-99d) | 2011-02-22 → 2010-11-15 A (-99d) |  | 0% → 100% | 305d → none |  |  |
| 13421070M | Delivery Complete for H Steel for S/R Dipoles (EXIST ARC DIPOLES) | 2011-09-02 → 2011-06-14 A (-80d) | 2011-09-02 → 2011-06-14 A (-80d) |  | 0% → 100% | 169d → none | 13421065b, 13421067M, 13421066, 13421065a → 13421065a, 13421065b, 13421066, 13421067M, 13421065 |  |
| 13421912LOE | FY12 Mngmnt & Oversight (EXIST ARC Dipoles) | 2011-10-03 A | 2012-09-28 → 2012-05-14 A (-137d) | 247d → 151d | 0% → 100% | 20d → none |  | resources SR STAFF [320 h]; TRAVEL → TRAVEL; SR STAFF [320 h] |
| 13421950 | Re-Baseline Actuals Adjustment | 2013-08-30 A | 2013-08-30 A |  | 0% → 100% | 20d → none | 9-130M FS+227d → none |  |
| 2 | **1.3.4.2.2 QUADRUPOLES** | 2009-01-02 → 2009-01-05 (+3d) |  |  |  |  |  |  |
| 13422035 | Prcrmnt Prep for Quads (EXIST ARC Q-POLES) | 2009-01-02 → 2009-01-05 A (+3d) | 2009-02-18 → 2009-05-25 A (+96d) | 32d → 98d | 0% → 100% | 1477d → none |  | resources MECH ENG [42.2 h]; MECH DES [28.13 h] → MECH DES [28.13 h]; MECH ENG [42.2 h] |
| 13432004 | Procurement Prep for Linac Correctors FY09 | 2009-07-02 → 2009-07-16 A (+14d) | 2009-09-30 → 2009-12-21 A (+82d) | 63d → 109d | 0% → 100% | 302d → none |  | resources MECH DES [21.72 h]; MECH ENG [21.72 h] → MECH ENG [21.72 h]; MECH DES [21.72 h] |
| 13422040M | Award Contract for Quadrupoles (EXIST ARC Q-POLES) | 2009-08-03 A | 2009-08-03 A |  | 0% → 100% | 1362d → none | 9-090M FS+206d, 13422035, 1114010 → 13422035, 13422035XD, 1114010, 9-090M FS+206d |  |
| 13422045 | Vend Fab Quads (EXIST ARC Q-POLES) LABOR Initial | 2009-02-19 → 2009-08-03 A (+165d) | 2009-07-31 → 2009-09-23 A (+54d) | 115d → 37d | 0% → 100% | 576d → none |  |  |
| 13422047 | Vend Fab Quads (EXIST ARC Q-POLES) Recieve Materials | 2009-08-03 A | 2009-10-05 → 2009-10-30 A (+25d) | 45d → 64d | 0% → 100% | 839d → none |  | resources PROCUREMENT<$50K 60 NO ESCALATION; PROCUREMENT>$50K 69 NO ESCALATION → PROCUREMENT>$50K 69 NO ESCALATION; PROCUREMENT<$50K 60 NO ESCALATION |
| 13422047A | Vend Fab Quads (EXIST ARC Q-POLES) Lamination Stampings | 2009-08-03 A | 2009-08-03 → 2009-12-21 A (+140d) | 1d → 97d | 0% → 100% | 883d → none | 9-090M FS+206d → 13422047 FS-24d |  |
| 13422047B | Vend Fab Quads (EXIST ARC Q-POLES) First Article QR | 2009-08-03 A | 2009-10-28 → 2009-11-18 A (+21d) | 62d → 77d | 0% → 100% | 822d → none | 9-090M FS+206d → 13422047A FS-32d |  |
| 13422047C | Vend Fab Quads (EXIST ARC Q-POLES) Deliver 5 QR Magnets | 2009-08-03 A | 2010-01-29 → 2010-01-25 A (-4d) | 120d → 116d | 0% → 100% | 764d → none | 9-090M FS+206d → 13422047B FS-41d |  |
| 13422047D | Vend Fab Quads (EXIST ARC Q-POLES) Deliver 5 QR Magnets | 2009-08-03 A | 2010-02-26 → 2010-02-25 A (-1d) | 139d → 138d | 0% → 100% | 745d → none | 9-090M FS+206d → 13422047C FS-99d |  |
| 13422047F | Vend Fab Quads (EXIST ARC Q-POLES) Deliver 5 QR Magnets | 2009-08-03 A | 2010-03-29 A |  | 0% → 100% | 724d → none | 9-090M FS+206d → 13422047D FS-118d |  |
| 13422047G | Vend Fab Quads (EXIST ARC Q-POLES) Deliver 5 QR Magnets | 2009-08-03 A | 2010-04-30 → 2010-03-29 A (-32d) | 184d → 160d | 0% → 100% | 700d → none | 9-090M FS+206d → 13422047F FS-139d |  |
| 13422047H | Vend Fab Quads (EXIST ARC Q-POLES) Deliver 5 QR Magnets | 2009-08-03 A | 2010-05-28 → 2010-04-22 A (-36d) | 204d → 178d | 0% → 100% | 680d → none | 9-090M FS+206d → 13422047G FS-163d |  |
| 13422047J | Vend Fab Quads (EXIST ARC Q-POLES) Deliver 5 QR Magnets | 2009-08-03 A | 2010-06-23 → 2010-04-22 A (-62d) | 221d → 178d | 0% → 100% | 663d → none | 9-090M FS+206d → 13422047H FS-183d |  |
| 13422047K | Vend Fab Quads (EXIST ARC Q-POLES) Deliver 4 QR Magnets | 2009-08-03 A | 2010-07-26 A |  | 0% → 100% | 641d → none | 9-090M FS+206d → 13422047J FS-200d |  |
| 13422047L | Vend Fab Quads (EXIST ARC Q-POLES) Deliver 2 QR Magnets | 2009-08-03 A | 2010-10-26 → 2010-07-26 A (-92d) | 308d → 243d | 0% → 100% | 576d → none | 9-090M FS+206d → 13422047K FS-222d | resources PROCUREMENT<$50K 60 NO ESCALATION; PROCUREMENT>$50K 69 NO ESCALATION → PROCUREMENT>$50K 69 NO ESCALATION; PROCUREMENT<$50K 60 NO ESCALATION |
| 13422046 | Vend Fab Quads (EXIST ARC Q-POLES) LABOR Final FY09 | 2009-08-03 → 2009-09-24 A (+52d) | 2009-09-30 → 2009-10-30 A (+30d) | 42d → 26.23d | 0% → 100% | 576d → none | 13422045 → 13422045 FS-120d |  |
| 13432004b | Procurement Prep for Linac Correctors FY10 | 2009-10-01 → 2009-09-30 A (-1d) | 2009-12-16 → 2009-12-21 A (+5d) | 53d → 56d | 0% → 100% | 302d → none | 13432004 → 13432004 FS-300d |  |
| 13422046b | Vend Fab Quads (EXIST ARC Q-POLES) LABOR Final FY10 | 2009-10-01 A | 2010-09-30 → 2010-10-26 A (+26d) | 248d → 265.86d | 0% → 100% | 576d → none |  | resources MECH ENG [131.37 h]; MECH DES [105.07 h] → MECH DES [105.07 h]; MECH ENG [131.37 h] |
| 13422046ba | Vend Fab Quads (EXIST ARC Q-POLES) LABOR Final FY11 | 2010-10-01 → 2009-10-01 A (-365d) | 2010-10-26 A | 18d → 266d | 0% → 100% | 576d → none | 13422046b → 13422046 | resources MECH DES [7.63 h]; MECH ENG [9.53 h] → MECH ENG [9.53 h]; MECH DES [7.63 h] |
| 13422055 | Mag Measurment of New Quads (EXIST ARC Q-POLES) FY10 | 2010-05-05 → 2009-11-30 A (-156d) | 2010-09-30 → 2010-07-26 A (-66d) | 104d → 161d | 0% → 100% | 576d → none | 13422050M FS-122d → 13422050M FS-600d |  |
| 13422055a | Mag Measurment of New Quads (EXIST ARC Q-POLES) FY11 | 2010-10-01 → 2009-11-30 A (-305d) | 2011-02-25 → 2010-07-26 A (-214d) | 96d → 161d | 0% → 100% | 576d → none | 13422055 → 13422050M FS-600d | resources MECH ENG [59.52 h]; MECH TECH [99.84 h] → MECH TECH [99.84 h]; MECH ENG [59.52 h] |
| 13422050M | Delivery Complete forQuadrupoles (EXIST ARC Q-POLES) | 2010-10-26 → 2010-07-26 A (-92d) | 2010-10-26 → 2010-07-26 A (-92d) |  | 0% → 100% | 576d → none | 13422047K, 13422047C, 13422047B, 13422047, 13422047D, 13422047F, 13422047A, 13422047J, 13422047L, 13422047H, 13422047G, 13422046ba → 13422047L, 13422046b, 13422046ba | was named Delivery Complete for Quadrupoles(EXIST ARC Q-POLES) |
| 13422065 | Measure 69 S/R Quads at Higher Current (EXIST ARC Q-POLES) | 2011-10-03 → 2011-04-01 A (-185d) | 2011-12-13 → 2011-04-25 A (-232d) | 50d → 17d | 0% → 100% | 197d → none |  |  |
| 13422100 | Prcrmnt Prep for QY Quads FY10 | 2010-04-01 → 2011-05-02 A (+396d) | 2010-06-30 → 2011-05-16 A (+320d) | 64d → 11d | 0% → 100% | 528d → none |  | was named Prcrmnt Prep for QY Quads FY10a; resources MECH DES [211.25 h]; MECH ENG [273.4 h] → MECH ENG [273.4 h]; MECH DES [211.25 h] |
| 13422102 | Prcrmnt Prep for QY Quads FY10b | 2010-07-01 → 2011-05-09 A (+312d) | 2010-09-30 → 2011-05-23 A (+235d) | 64d → 11d | 0% → 100% | 528d → none |  |  |
| 13422110 | Vend Fab QY Quads Labor Support FY11 | 2010-10-21 → 2011-05-09 A (+200d) | 2011-06-30 → 2011-05-23 A (-38d) | 170d → 11d | 0% → 100% | 528d → none |  |  |
| 13422115 | Vend Fab QY Quads 1st Article | 2010-10-21 → 2011-05-16 A (+207d) | 2011-03-31 → 2011-05-30 A (+60d) | 106d → 10d | 0% → 100% | 528d → none |  |  |
| 13422123 | Magnetic Measurement QY Quads | 2011-03-02 → 2011-08-01 A (+152d) | 2011-07-29 → 2011-08-15 A (+17d) | 106d → 11d | 0% → 100% | 528d → none |  | resources MECH TECH [115.22 h]; MECH ENG [23.04 h] → MECH ENG [23.04 h]; MECH TECH [115.22 h] |
| 13422105M | Award Contract for QY Quadrupoles | 2010-10-21 → 2011-08-31 A (+314d) | 2010-10-21 → 2011-08-31 A (+314d) |  | 0% → 100% | 528d → none | 13422102a → 13422102a, 13422102 |  |
| 13422122 | Receive and Inspect QY Quads | 2011-01-31 → 2011-09-05 A (+217d) | 2011-07-29 → 2011-09-28 A (+61d) | 127d → 17d | 0% → 100% | 528d → none |  | resources MECH ENG [74.34 h]; MECH DES [24.78 h]; COMP SCIENT [24.78 h]; MECH TECH [74.34 h] → MECH TECH [74.34 h]; MECH ENG [74.34 h]; MECH DES [24.78 h]; COMP SCIENT [24.78 h] |
| 13422112 | Vend Fab QY Quads Labor Support FY12 | 2011-07-01 → 2011-09-12 A (+73d) | 2011-07-29 → 2011-09-27 A (+60d) | 20d → 12d | 0% → 100% | 528d → none |  |  |
| 13422102a | Prcrmnt Prep for QY Quads FY11 | 2010-10-01 → 2011-09-14 A (+348d) | 2010-10-20 → 2011-09-24 A (+339d) | 14d → 8d | 0% → 100% | 528d → none | 13422102 → 13422102, 13422100, 9-120M FS+30d | resources MECH DES [84.13 h]; MECH ENG [108.88 h] → MECH ENG [108.88 h]; MECH DES [84.13 h] |
| 13422060 | Add Klixons to 20 Amp Quads (EXIST ARC Q-POLES) | 2012-05-07 → 2012-04-09 A (-28d) | 2012-07-31 → 2013-06-17 A (+321d) | 60d → 253d | 0% → 100% | 279d → none | 2-02M FS-5d, 13422055a → 2-02M FS-30d, 13422055, 13422055a | resources PROCUREMENT<$50K 60; MECH TECH [132 h]; PROCUREMENT>$50K 69 → PROCUREMENT<$50K 60; PROCUREMENT>$50K 69; MECH TECH [132 h] |
| 13422120 | Vend Fab Additional QR Quads | 2011-11-14 → 2013-03-04 A (+476d) | 2012-05-31 → 2013-04-15 A (+319d) | 133d → 48d | 0% → 100% | 316d → none | 9-120M FS+30d, 13422115 FS-106d → 9-130M, 13422115 FS-106d |  |
| 13422123a | Magnetic Measurement QR Quads FY11 | 2011-09-09 → 2013-03-04 A (+542d) | 2011-09-30 → 2013-03-18 A (+535d) | 16d → 14d | 0% → 100% | 316d → none | 13422122 FS-184d, 13422125M FS-184d → 13422120 FS-500d, 13422125M FS-500d, 13422122 FS-184d | resources MECH TECH [7.37 h]; MECH ENG [1.47 h] → MECH ENG [1.47 h]; MECH TECH [7.37 h] |
| 13422123b | Magnetic Measurement QR Quads FY12 | 2011-10-03 → 2013-03-04 A (+518d) | 2012-06-08 → 2013-04-15 A (+311d) | 168d → 5d | 0% → 100% | 316d → none |  | resources MECH TECH [77.41 h]; MECH ENG [15.49 h] → MECH ENG [15.49 h]; MECH TECH [77.41 h] |
| 13422122a | Receive and Inspect QR Quads | 2012-06-01 → 2013-03-11 A (+283d) | 2012-06-08 → 2013-04-15 A (+311d) | 5d → 14d | 0% → 100% | 316d → none | 13422120 → 13422120 FS-400d |  |
| 13422117 | Vend Fab QR Quads Labor Support | 2011-11-14 → 2013-04-04 A (+507d) | 2012-05-31 → 2013-04-22 A (+326d) | 133d → 48d | 0% → 100% | 321d → none | 9-120M FS+30d → 9-130M FS+165d |  |
| 13422125M | Delivery Complete for QR Quadrupoles | 2012-06-08 → 2013-04-15 A (+311d) | 2012-06-08 → 2013-04-15 A (+311d) |  | 0% → 100% | 316d → none | 13422117, 13422112, 13422120, 13422122a, 13422115, 13422122 → 13422112, 13422122, 13422115, 13422120, 13422122a FS-20d |  |
| 13422130 | Re-Baseline Actuals Adjustment | 2013-08-30 A | 2013-08-30 A |  | 0% → 100% | 20d → none | 9-130M FS+227d → none |  |
| 4 | **1.3.4.2.4 STANDS** | 2009-01-05 → 2010-02-01 (+392d) |  |  |  |  |  |  |
| 13425020 | Proc Girder Matrl (EXIST ARC Girders) | 2009-01-05 → 2010-02-01 A (+392d) | 2009-05-29 → 2010-02-22 A (+269d) | 102d → 15d | 0% → 100% | 592d → none |  |  |
| 13425025 | Proc Prep of Girders/Stands for QY Quads (EXIST ARC Girders) | 2011-03-11 → 2011-01-17 A (-53d) | 2011-06-30 → 2011-05-29 A (-32d) | 79d → 93d | 0% → 100% | 153d → none | 9-110M FS+105d, 13425020 → 13422100 FS-20d, 9-110M, 13425020 |  |
| 13425030 | Vend Fab Girders/Stands for QY Quads (EXIST ARC Girders) | 2012-02-03 → 2011-09-03 A (-153d) | 2012-04-30 → 2011-09-19 A (-224d) | 61d → 10d | 0% → 100% | 9d → none | 13425020, 13425025, 9-120M FS+80d → 13425025, 9-100M FS+85d, 13425020, 9-120M FS+80d |  |
| 13425035 | Re-Baseline Actuals Adjustment | 2013-08-30 A | 2013-08-30 A |  | 0% → 100% | 20d → none | 9-130M FS+227d → none |  |
| 13426000 | Re-Baseline Actuals Adjustment | 2013-08-30 A | 2013-08-30 A |  | 0% → 100% | 20d → none | 9-130M FS+227d → none |  |
| 7 | **1.3.4.2.7 INSTALLATION** | 2010-07-02 → 2010-07-01 (-1d) | 2013-11-18 → 2013-11-27 (+9d) |  |  |  |  |  |
| 13427180 | Accelerator Down Planning FY10 | 2010-07-02 → 2010-07-01 A (-1d) | 2010-09-30 → 2011-05-09 A (+221d) | 63d → 210.9d | 0% → 100% | 3d → none |  | resources MECH ENG [288 h]; MECH TECH [144 h] → MECH TECH [144 h]; MECH ENG [288 h] |
| 13427180a | Accelerator Down Planning FY11 | 2010-10-01 → 2010-07-01 A (-92d) | 2011-05-09 A | 147d → 211d | 0% → 100% | 3d → none | 13427180 → 9-100M FS+185d |  |
| 13427055 | Procure new material handling equipment | 2010-11-05 → 2010-10-11 A (-25d) | 2011-04-18 → 2011-03-28 A (-21d) | 107d → 111d | 0% → 100% | 18d → none |  | resources PROCUREMENT<$50K 60; MECH TECH [80 h] → MECH TECH [80 h]; PROCUREMENT<$50K 60 |
| 13427060 | Procure Temporary Space for expanded technician work force | 2011-03-04 → 2010-12-06 A (-88d) | 2011-08-31 → 2011-04-25 A (-128d) | 127d → 93d | 0% → 100% | 51d → none | 9-110M FS+100d → 9-110M |  |
| 13427063LOE | Tech Training | 2011-03-04 → 2011-04-01 A (+28d) | 2011-04-28 → 2011-05-30 A (+32d) | 40d → 41d | 0% → 100% | 10d → none |  |  |
| 13427065 | AS-FOUND SURVEY (B/L UNDER VACUUM) SOUTH SIDE WEST ARC | 2011-05-20 → 2011-05-08 A (-12d) | 2011-06-01 → 2011-05-23 A (-9d) | 8d → 11d | 0% → 100% | 46d → none |  |  |
| 13427120 | REMOVE MAGNETS - QUAD 1 | 2011-06-03 → 2011-05-09 A (-25d) | 2011-06-09 → 2011-05-13 A (-27d) |  | 0% → 100% | 46d → none | 3A-34M, 13427070 → 13427070 |  |
| 13427135 | REMOVE MAGNETS - QUAD 2 | 2011-06-08 → 2011-05-09 A (-30d) | 2011-06-13 → 2011-05-16 A (-28d) | 4d → 6d | 0% → 100% | 52d → none |  |  |
| 13427062LOE | Engineering Support 6 Month Down | 2011-05-13 A | 2011-09-06 A |  | 0% → 100% | 48d → none |  |  |
| 13427070 | BLEED UP VACUUM SOUTH SIDE OF W/ARC | 2011-06-02 → 2011-05-20 A (-13d) | 2011-06-02 → 2011-05-23 A (-10d) | 1d → 2d | 0% → 100% | 46d → none |  |  |

| ID | Task | Start | Finish | Duration | Complete | Total float | Predecessors | Other |
| --- | --- | --- | --- | --- | --- | --- | --- | --- |
| 13427075 | AS-FOUND SURVEY (B/L UNDER VACUUM) NORTH SIDE WEST ARC | 2011-06-02 → 2011-05-20 A (-13d) | 2011-06-13 → 2011-05-29 A (-15d) | 8d → 6d | 0% → 100% | 57d → none |  |  |
| 13427125 | REFURB, UPGRADE AND TEST MAGNETS - QUAD 1 | 2011-06-08 → 2011-05-23 A (-16d) | 2011-06-22 → 2011-06-25 A (+3d) | 11d → 24d | 0% → 100% | 46d → none | 13427120 FS-2d → 13427120 FS-20d | resources MSHOP; MECH TECH [1545.6 h] → MECH TECH [1545.6 h]; MSHOP |
| 13427130 | INSTALL MAGNETS AND ARC 10 - QUAD 1 | 2011-06-15 → 2011-05-23 A (-23d) | 2011-07-12 → 2011-06-11 A (-31d) | 19d → 14d | 0% → 100% | 72d → none | 13427125 FS-6d → 13427125 FS-15d |  |
| 13427140 | REFURB, UPGRADE AND TEST MAGNETS - QUAD 2 | 2011-06-22 → 2011-05-23 A (-30d) | 2011-07-06 → 2011-06-13 A (-23d) | 10d → 15d | 0% → 100% | 46d → none | 13427135, 13427125 FS-1d → 13427135, 13427125 FS-20d |  |
| 13427150 | REMOVE MAGNETS - QUAD 3 | 2011-06-15 → 2011-05-25 A (-21d) | 2011-06-20 → 2011-05-31 A (-20d) |  | 0% → 100% | 57d → none |  |  |
| 13427080 | BLEED UP VACUUM NORTH SIDE OF W/ARC | 2011-06-14 → 2011-05-27 A (-18d) | 2011-06-14 → 2011-05-31 A (-14d) | 1d → 2d | 0% → 100% | 57d → none |  |  |
| 13427145 | INSTALL MAGNETS AND ARC 10 - QUAD 2 | 2011-06-28 → 2011-06-01 A (-27d) | 2011-07-20 → 2011-06-27 A (-23d) | 16d → 19d | 0% → 100% | 66d → none |  |  |
| 13427160 | INSTALL MAGNETS AND ARC 10 - QUAD 3 | 2011-07-12 → 2011-06-06 A (-36d) | 2011-08-16 → 2011-08-19 A (+3d) | 26d → 54d | 0% → 100% | 50d → none | 13427155 FS-7d → 13427155 FS-15d |  |
| 13427165 | REMOVE MAGNETS - QUAD 4 | 2011-06-20 → 2011-06-11 A (-9d) | 2011-06-27 → 2011-06-20 A (-7d) |  | 0% → 100% | 61d → none |  |  |
| 13427155 | REFURB, UPGRADE AND TEST MAGNETS - QUAD 3 | 2011-07-07 → 2011-06-20 A (-17d) | 2011-07-20 → 2011-07-12 A (-8d) | 10d → 16d | 0% → 100% | 46d → none |  |  |
| 13427170 | REFURB, UPGRADE AND TEST MAGNETS - QUAD 4 | 2011-07-20 → 2011-06-22 A (-28d) | 2011-08-02 → 2011-08-15 A (+13d) | 10d → 38d | 0% → 100% | 46d → none | 13427165, 13427155 FS-1d → 13427155 FS-35d, 13427165 |  |
| 13427021 | Rework of arcs 5, 7, and 9 Part A FY12 | 2012-08-14 → 2011-07-01 A (-410d) | 2012-09-28 → 2011-10-09 A (-355d) | 33d → 69d | 0% → 100% | 193d → none | 2-02M FS+5d, 3A-36M → 2-02M FS-245d |  |
| 13427021a | Rework of arcs 5, 7, and 9 Part A FY13 | 2012-10-01 → 2011-07-01 A (-458d) | 2012-12-03 → 2011-10-09 A (-421d) | 44d → 69d | 0% → 100% | 193d → none |  |  |
| 13427022 | Rework of arcs 5, 7, and 9 Part B FY12 | 2012-06-01 → 2011-07-01 A (-336d) | 2012-09-28 → 2011-08-22 A (-403d) | 84d → 36d | 0% → 100% | 225d → none | 2-02M FS+13d → 2-02M FS-245d |  |
| 13427022a | Rework of arcs 5, 7, and 9 Part B FY13 | 2012-10-01 → 2011-07-01 A (-458d) | 2012-10-16 → 2011-08-22 A (-421d) | 12d → 36d | 0% → 100% | 225d → none |  |  |
| 13427023 | Rework of arcs 5, 7, and 9 Part C FY12 | 2012-06-14 → 2011-07-01 A (-349d) | 2012-09-28 → 2011-07-25 A (-431d) | 76d → 16d | 0% → 100% | 174d → none |  |  |
| 13427023a | Rework of arcs 5, 7, and 9 Part C FY13 | 2012-10-01 → 2011-07-01 A (-458d) | 2013-01-07 → 2011-07-25 A (-532d) | 63d → 16d | 0% → 100% | 174d → none |  |  |
| 13427024 | Rework of arcs 5, 7, and 9 Part D FY12 | 2012-06-27 → 2011-07-01 A (-362d) | 2012-09-28 → 2011-07-25 A (-431d) | 67d → 16d | 0% → 100% | 153d → none |  |  |
| 13427024a | Rework of arcs 5, 7, and 9 Part D FY13 | 2012-10-01 → 2011-07-01 A (-458d) | 2013-02-06 → 2011-07-25 A (-562d) | 84d → 16d | 0% → 100% | 153d → none |  |  |
| 13427085 | PUMP OUT SOUTH SIDE WEST ARC | 2011-07-21 → 2011-07-01 A (-20d) | 2011-07-25 → 2011-07-04 A (-21d) | 3d → 1d | 0% → 100% | 66d → none |  |  |
| 13427090 | QA CHECKS - SOUTH SIDE WEST ARC | 2011-07-25 → 2011-07-03 A (-22d) | 2011-07-28 → 2011-07-08 A (-20d) |  | 0% → 100% | 66d → none |  |  |
| 13427175 | INSTALL MAGNETS AND ARC 10 - QUAD 4 | 2011-07-25 → 2011-07-04 A (-21d) | 2011-08-22 → 2011-08-17 A (-5d) | 21d → 32d | 0% → 100% | 46d → none |  |  |
| 13427095 | 2B FINAL STACK ALIGNMENT (B/L UNDER VACUUM) - SOUTH SIDE WEST ARC | 2011-07-29 → 2011-07-09 A (-20d) | 2011-08-10 → 2011-07-19 A (-22d) | 9d → 7d | 0% → 100% | 66d → none |  |  |
| 13427105 | QA CHECKS - NORTH SIDE WEST ARC | 2011-08-25 → 2011-07-19 A (-37d) | 2011-08-30 → 2011-08-16 A (-14d) | 4d → 21d | 0% → 100% | 46d → none | 13427100 FS-1d → 13427100 FS-40d |  |
| 13427100 | PUMP OUT NORTH SIDE WEST ARC | 2011-08-23 → 2011-08-01 A (-22d) | 2011-08-25 → 2011-08-15 A (-10d) | 3d → 11d | 0% → 100% | 46d → none |  |  |
| 13427110 | 2B FINAL STACK ALIGNMENT (B/L UNDER VACUUM) - NORTH SIDE WEST ARC | 2011-08-30 → 2011-08-16 A (-14d) | 2011-09-08 → 2011-08-18 A (-21d) | 7d → 3d | 0% → 100% | 46d → none |  |  |
| 13427115M | WEST ARC FINISHED | 2011-09-08 A | 2011-09-08 A |  | 0% → 100% | 46d → none |  |  |
| 13427015LOE | Installation Team Engineering Support FY12 (12 Month Down) | 2012-05-01 A | 2012-09-28 A |  | 0% → 100% | 9d → none | 2-02M FS-9d → 2-02M FS-5d |  |
| 13427020 | Arcs 1 & 3 - Remove | 2012-08-02 → 2012-06-05 A (-58d) | 2012-08-13 → 2012-07-16 A (-28d) | 8d → 30d | 0% → 100% | 144d → none | 2-02M FS+56d, 3A-14M → 2-02M, 3A-14M |  |
| 13427025 | Arcs 1 & 3 - Refurb and measure FY12 | 2012-08-07 → 2012-06-05 A (-63d) | 2012-09-28 → 2012-09-17 A (-11d) | 38d → 73.85d | 0% → 100% | 144d → none | 2-02M FS+13d, 13427020 FS-5d → 2-02M FS+13d, 13427020 FS-35d |  |
| 13427025a | Arcs 1 & 3 - Refurb and measure FY13 | 2012-10-01 → 2012-06-05 A (-118d) | 2013-01-02 → 2012-09-17 A (-107d) | 60d → 74d | 0% → 100% | 144d → none | 13427025 → 13427025 FS-20d |  |
| 13427027 | Arcs 1 & 3 - Install FY12 | 2012-08-07 → 2012-07-16 A (-22d) | 2012-09-28 → 2012-12-17 A (+80d) | 38d → 107d | 0% → 100% | 144d → none |  | resources MECH ENG [277.75 h]; MECH TECH [699.2 h] → MECH TECH [699.2 h]; MECH ENG [277.75 h] |
| 13427027a | Arcs 1 & 3 - Install FY13 | 2012-10-01 → 2012-07-16 A (-77d) | 2013-01-18 → 2012-12-17 A (-32d) | 72d → 107d | 0% → 100% | 144d → none | 13427027 → 13427027 FS-25d |  |
| 13427030 | Arcs - Final align west end | 2013-02-15 → 2012-07-23 A (-207d) | 2013-03-12 → 2013-08-30 A (+171d) | 17d → 156d | 0% → 100% | 130d → none | 9-130M, 13417020, 13427028, 13458010, 13458012, 13458040 → 13427028 FS-150d, 13417020, 13458040 FS-250d, 13458010, 13458012 |  |
| 13427032 | Arcs - Final align east end | 2013-01-22 → 2012-08-20 A (-155d) | 2013-02-14 → 2013-04-15 A (+60d) | 18d → 119d | 0% → 100% | 144d → none | 13427027a → 13427027a FS-30d | resources MECH TECH [720 h]; MECH ENG [160 h] → MECH ENG [160 h]; MECH TECH [720 h] |
| 13427016LOE | Installation Team Engineering Support FY13 (12 Month Down) | 2012-10-01 A | 2013-08-30 A | 228d → 237d | 0% → 100% | 9d → none |  | was named Installation Team Engineering Support FY13 (12 Month Down) *** Re-Baseline Split |
| 13427028 | West Arc LCW Work | 2013-01-03 → 2012-11-12 A (-52d) | 2013-02-14 → 2013-08-30 A (+197d) | 30d → 60d | 0% → 100% | 130d → none | 9-130M FS+60d → 9-130M |  |
| 13427061 | NE matching final alignment | 2013-08-05 → 2012-11-12 A (-266d) | 2013-08-06 → 2013-08-30 A (+24d) | 2d → 151d | 0% → 100% | 24d → none | 13417095 → 13417095 FS-200d | resources MECH TECH [144 h]; MECH ENG [32 h] → MECH ENG [32 h]; MECH TECH [144 h] |
| 13427062 | SW matching final alignment | 2013-06-27 → 2012-11-12 A (-227d) | 2013-07-02 → 2013-08-30 A (+59d) | 4d → 151d | 0% → 100% | 24d → none | 13463050 → 13463050 FS-160d |  |
| 13427035 | Hall A - Remove | 2012-10-11 → 2013-02-01 A (+113d) | 2012-10-19 → 2013-02-11 A (+115d) | 7d → 26d | 0% → 100% | 186d → none |  |  |
| 13427042 | Hall B - Remove | 2012-10-16 → 2013-02-02 A (+109d) | 2012-11-02 → 2013-03-11 A (+129d) |  | 0% → 100% | 207d → none | 3A-17M, 13427035 FS-4d → 3A-17M, 13427035 FS-4d, 9-130M FS+43d |  |
| 13427050 | Hall C - Remove | 2012-10-23 → 2013-03-01 A (+129d) | 2012-11-09 → 2013-03-18 A (+129d) |  | 0% → 100% | 207d → none |  | resources MECH TECH [144 h]; MECH ENG [32 h] → MECH ENG [32 h]; MECH TECH [144 h] |
| 13427037 | Hall A - Upstairs | 2012-10-22 → 2013-03-04 A (+133d) | 2012-11-20 → 2013-05-13 A (+174d) |  | 0% → 100% | 186d → none |  |  |
| 13427045 | Hall B - Upstairs | 2012-11-05 → 2013-03-04 A (+119d) | 2013-01-15 → 2013-08-30 A (+227d) |  | 0% → 100% | 293d → none |  | resources MECH TECH [784 h]; MECH ENG [176 h] → MECH ENG [176 h]; MECH TECH [784 h] |
| 13427047 | Hall B - Install | 2012-11-05 → 2013-06-01 A (+208d) | 2013-03-20 → 2013-08-30 A (+163d) |  | 0% → 100% | 292d → none |  |  |
| 13427040 | Hall A - Install | 2012-11-12 → 2013-07-01 A (+231d) | 2013-03-28 → 2013-08-30 A (+155d) |  | 0% → 100% | 186d → none |  |  |
| 13427052 | Hall C - Upstairs | 2012-11-12 → 2013-07-01 A (+231d) | 2012-12-19 → 2013-08-30 A (+254d) |  | 0% → 100% | 328d → none |  | resources MECH TECH [472 h]; MECH ENG [104 h] → MECH ENG [104 h]; MECH TECH [472 h] |
| 13427057 | Hall C - Install | 2012-12-11 → 2013-08-30 A (+262d) | 2013-01-28 → 2013-08-30 A (+214d) |  | 0% → 100% | 328d → none |  | resources MECH TECH [528 h]; MECH ENG [120 h] → MECH ENG [120 h]; MECH TECH [528 h] |
| 13427185 | Re-Baseline Actuals Adjustment | 2013-08-30 A | 2013-08-30 A |  | 0% → 100% | 20d → none | 9-130M FS+227d → none |  |
| 23427016LOE | Installation Team Engineering Support FY13 (12 Month Down) | 2013-09-03 A | 2013-09-30 A | 20d → 54d | 0% → 100% | 0d → none |  |  |
| 23427040 | Hall A - Install FY13 | 2013-09-03 A | 2013-09-30 → 2013-11-27 (+58d) | 20d → 29d | 0% → 90% | 48d → 19d |  |  |
| 23427040a | Hall A - Install FY14 | 2013-10-01 → 2013-09-03 A (-28d) | 2013-10-11 → 2013-11-27 (+47d) |  | 0% → 90% | 48d → 19d | 23427040, 9-130M FS+228d → 23427040 FS-30d |  |
| 23427052 | Hall C - Upstairs FY13 | 2013-09-03 A | 2013-09-30 → 2013-11-11 (+42d) | 20d → 27d | 0% → 90% | 122d → 22d |  |  |
| 23427052a | Hall C - Upstairs FY14 | 2013-10-01 → 2013-09-03 A (-28d) | 2013-10-09 → 2013-11-11 (+33d) |  | 0% → 90% | 122d → 22d | 9-130M FS+228d, 23427052 → 23427052 FS-10d |  |
| 23427062 | Material Handling costs (Vehicle) | 2013-09-03 A | 2013-11-15 → 2013-11-27 (+12d) |  | 0% → 67% | 81d → 74d |  | resources PROCUREMENT<$50K 60 NO ESCALATION FY14 → PROCUREMENT<$50K 60 |
| 23427016LOEa | Installation Team Engineering Support FY14 (12 Month Down) | 2013-10-01 A |  |  | 0% → 68% | 0d → 96d | 9-130M FS+228d, 23427016LOE → 23427016LOE |  |
| 23427047 | Hall B - Install FY13 | 2013-09-03 → 2013-10-01 A (+28d) | 2013-09-30 → 2013-11-14 (+45d) |  | 0% → 80% | 126d → 28d |  |  |
| 23427047a | Hall B - Install FY14 | 2013-10-01 A | 2013-11-11 → 2013-11-14 (+3d) | 30d → 10d | 0% → 80% | 126d → 28d | 9-130M FS+228d, 23427047 → 23427047 FS-20d |  |
| 23427057 | Hall C - Install | 2013-10-10 → 2013-10-01 A (-9d) | 2013-11-15 → 2013-11-27 (+12d) |  | 0% → 80% | 122d → 19d | 23427052, 23427052a → 23427052a FS-10d, 23427052 FS-10d |  |
| 23427067 | Material Handling costs DeObligation | 2013-11-18 → 2013-10-21 A (-28d) | 2013-11-18 → 2013-10-28 A (-21d) |  | 0% → 100% | 81d → none |  |  |
| 3 | **1.3.4.3 LINACS** | 2009-12-17 → 2009-12-21 (+4d) |  |  |  |  |  |  |
| 2 | **1.3.4.3.2 CORRECTORS** | 2009-12-17 → 2009-12-21 (+4d) |  |  |  |  |  |  |
| 13432005 | Vend Fab H & V Linac Correctors (Linac Correctors) Labor FY10 | 2009-12-17 → 2009-12-21 A (+4d) | 2010-09-30 → 2011-10-16 A (+381d) | 195d → 451d | 0% → 100% | 302d → none |  |  |
| 13432005a | Vend Fab H & V Linac Correctors (Linac Correctors) Labor FY11 | 2010-10-01 → 2009-12-21 A (-284d) | 2011-01-12 → 2011-10-15 A (+276d) | 66d → 451d | 0% → 100% | 302d → none | 13432005 → 13432004b, 121434999, 121432005 | resources MECH ENG [10.12 h]; MECH DES [10.12 h] → MECH DES [10.12 h]; MECH ENG [10.12 h] |
| 13432005b | Vend Fab H & V Linac Correctors (Linac Correctors) Procurement | 2009-12-17 → 2009-12-21 A (+4d) | 2011-01-12 → 2011-10-15 A (+276d) | 261d → 451d | 0% → 100% | 302d → none |  |  |
| 13432015 | Mag Measurement of Linac Correctors & Skew Quads (Linac Correctors) | 2011-04-15 → 2011-12-12 A (+241d) | 2011-05-26 → 2011-12-19 A (+207d) | 30d → 6d | 0% → 100% | 238d → none | 13432005b, 13432005a, 9-110M FS+130d → 13432005, 13432005b, 13432005a | resources MECH TECH [164 h]; MECH ENG [8 h] → MECH ENG [8 h]; MECH TECH [164 h] |
| 13432020 | Re-Baseline Actuals Adjustment | 2013-08-30 A | 2013-08-30 A |  | 0% → 100% | 20d → none | 9-130M FS+227d → none |  |
| 13434005 | Proc Prep Linac Girders (Linac Girders) FY10 | 2010-08-16 A | 2010-09-30 → 2010-11-15 A (+46d) | 33d → 64.63d | 0% → 100% | 54d → none |  |  |
| 13434005a | Proc Prep Linac Girders (Linac Girders) FY11 | 2010-10-01 → 2010-08-16 A (-46d) | 2010-11-05 → 2010-11-15 A (+10d) | 26d → 65d | 0% → 100% | 54d → none | 13434005 → 121434005, 9-100M FS+215d, 121434999 |  |
| 13433005 | Proc Prep Linac Stands (Linac Stands) | 2010-10-01 → 2010-09-13 A (-18d) | 2010-12-02 → 2010-11-15 A (-17d) | 43d → 46d | 0% → 100% | 55d → none |  | resources MECH DES [20 h]; MECH ENG [80 h] → MECH ENG [80 h]; MECH DES [20 h] |

| ID | Task | Start | Finish | Duration | Complete | Total float | Predecessors | Other |
| --- | --- | --- | --- | --- | --- | --- | --- | --- |
| 13433010 | Vend Fab Linac Stands (Linac Stands) | 2010-12-03 → 2010-11-15 A (-18d) | 2011-02-24 → 2011-02-28 A (+4d) | 52d → 66d | 0% → 100% | 55d → none |  |  |
| 13434006 | Vend Fab Linac Girders (Linac Girders) | 2010-11-08 → 2010-11-15 A (+7d) | 2011-02-25 → 2011-03-21 A (+24d) | 70d → 81d | 0% → 100% | 54d → none | 13434005a → 13434005, 13434005a |  |
| 13434007 | Receive and Inspect Linac Girders (Linac Girders) | 2011-02-14 → 2011-01-17 A (-28d) | 2011-02-25 → 2011-03-25 A (+28d) | 9d → 48d | 0% → 100% | 54d → none | 13434006 FS-9d → 13434006 FS-40d |  |
| 13433015 | Receive and Inspect Linac Stands (Linac Stands) | 2011-02-11 → 2011-02-01 A (-10d) | 2011-02-24 → 2011-03-21 A (+25d) | 9d → 34d | 0% → 100% | 55d → none |  |  |
| 13433020 | Re-Baseline Actuals Adjustment | 2013-08-30 A | 2013-08-30 A |  | 0% → 100% | 20d → none | 9-130M FS+227d → none |  |
| 5 | **1.3.4.3.5 VACUUM** | 2010-09-17 → 2011-02-14 (+150d) |  |  |  |  |  |  |
| 13435010 | Proc New DI Ion Pumps (Linac Vac) | 2010-09-17 → 2011-02-14 A (+150d) | 2011-02-16 → 2011-04-25 A (+68d) | 100d → 50d | 0% → 100% | 308d → none |  |  |
| 13435015 | Rebuild 3 South Linac Girders (Linac Vac) | 2011-05-23 → 2011-04-11 A (-42d) | 2011-05-31 → 2011-05-29 A (-2d) | 6d → 35d | 0% → 100% | 60d → none | 13436020 → 13436020 FS-20d | resources MECH TECH [210 h]; MECH DES [20 h]; PROCUREMENT<$50K 60; MECH ENG [10 h] → PROCUREMENT<$50K 60; MECH ENG [10 h]; MECH TECH [210 h]; MECH DES [20 h] |
| 13435020 | Re-Baseline Actuals Adjustment | 2013-08-30 A | 2013-08-30 A |  | 0% → 100% | 20d → none | 9-130M FS+227d → none |  |
| 6 | **1.3.4.3.6 INSTALLATION** | 2011-05-13 → 2011-05-16 (+3d) |  |  |  |  |  |  |
| 13436020 | Remove Warm Girder SL22 | 2011-05-13 → 2011-05-16 A (+3d) | 2011-05-20 → 2011-05-23 A (+3d) |  | 0% → 100% | 60d → none |  |  |
| 13436030 | Remove Warm Girder SL23 | 2011-06-09 → 2011-05-16 A (-24d) | 2011-06-16 → 2011-05-23 A (-24d) |  | 0% → 100% | 60d → none |  |  |
| 13436025 | Reinstall Warm Girder SL22 | 2011-06-01 → 2011-08-01 A (+61d) | 2011-06-08 → 2011-08-15 A (+68d) | 6d → 11d | 0% → 100% | 60d → none |  |  |
| 13436035 | Reinstall Warm Girder SL23 | 2011-07-28 → 2011-08-08 A (+11d) | 2011-08-04 → 2011-08-15 A (+11d) |  | 0% → 100% | 37d → none |  |  |
| 13436040 | SL - remove girders | 2012-05-21 → 2012-05-18 A (-3d) | 2012-06-05 → 2012-05-30 A (-6d) | 10d → 8d | 0% → 100% | 38d → none |  | resources MECH ENG [128 h]; MECH TECH [176 h] → MECH TECH [176 h]; MECH ENG [128 h] |
| 13436045 | NL - remove girders | 2012-06-06 → 2012-05-18 A (-19d) | 2012-07-02 → 2012-05-30 A (-33d) | 19d → 8d | 0% → 100% | 149d → none |  |  |
| 13436050 | SL - rebuild girders | 2012-05-22 → 2012-05-18 A (-4d) | 2012-05-22 → 2012-05-30 A (+8d) | 1d → 8d | 0% → 100% | 38d → none |  | resources MECH TECH [16 h]; MECH ENG [12 h] → MECH ENG [12 h]; MECH TECH [16 h] |
| 13436055 | NL - rebuild girders | 2012-07-03 → 2012-05-18 A (-46d) | 2012-07-24 → 2012-05-30 A (-55d) | 16d → 8d | 0% → 100% | 149d → none |  |  |
| 13436060 | SL final alignment | 2013-04-11 → 2012-09-10 A (-213d) | 2013-04-23 → 2013-06-17 A (+55d) | 9d → 152d | 0% → 100% | 58d → none | 13417045 → 13417045 FS-125d |  |
| 13436065 | NL final alignment | 2013-07-16 → 2012-09-10 A (-309d) | 2013-07-26 → 2013-06-17 A (-39d) | 9d → 197d | 0% → 100% | 24d → none | 13417070 → 13417070 FS-170d |  |
| 13436070 | Re-Baseline Actuals Adjustment | 2013-08-30 A | 2013-08-30 A |  | 0% → 100% | 20d → none | 9-130M FS+227d → none |  |
| 4 | **1.3.4.4 INJECTOR & RE-INJECTION** |  | 2013-09-17 → 2013-10-21 (+34d) |  |  |  |  |  |
| 1 | **1.3.4.4.1 DIPOLES** | 2009-07-02 → 2009-07-01 (-1d) |  |  |  |  |  |  |
| 13441004 | Proc Prep for Chicane Dipoles (INJ/REINJ Dipoles) FY09 | 2009-07-02 → 2009-07-01 A (-1d) | 2009-09-30 → 2009-12-21 A (+82d) | 63d → 119d | 0% → 100% | 312d → none |  | resources MECH DES [28.24 h]; MECH ENG [28.24 h] → MECH ENG [28.24 h]; MECH DES [28.24 h] |
| 13441004b | Proc Prep for Chicane Dipoles (INJ/REINJ Dipoles) FY10 | 2009-10-01 A | 2009-12-16 → 2009-12-21 A (+5d) | 53d → 55d | 0% → 100% | 312d → none | 13441004 → 13441004 FS-300d | resources MECH DES [23.76 h]; MECH ENG [23.76 h] → MECH ENG [23.76 h]; MECH DES [23.76 h] |
| 13441005 | Vend Fab New Chicane Dipoles (INJ/REINJ Dipoles) Labor FY10 | 2009-12-17 → 2009-12-21 A (+4d) | 2010-09-30 → 2011-10-17 A (+382d) | 195d → 451.88d | 0% → 100% | 312d → none |  | was named Vend Fab New Chicane Dipoles (INJ/REINJ Dipoles) FY10 |
| 13441005a | Vend Fab New Chicane Dipoles (INJ/REINJ Dipoles) Labor FY11 | 2010-10-01 → 2009-12-21 A (-284d) | 2011-01-12 → 2011-10-17 A (+278d) | 66d → 452d | 0% → 100% | 312d → none | 13441005 → 13441004b, 121441010a | was named Vend Fab New Chicane Dipoles (INJ/REINJ Dipoles) FY11; resources MECH ENG [54.62 h]; MECH DES [4.05 h] → MECH DES [4.05 h]; MECH ENG [54.62 h] |
| 13441005b | Vend Fab New Chicane Dipoles (INJ/REINJ Dipoles) Procurement | 2009-12-17 → 2009-12-21 A (+4d) | 2011-01-12 → 2011-10-17 A (+278d) | 261d → 452d | 0% → 100% | 312d → none |  |  |
| 13441010 | Mag Measurement of Chicane Dipoles (INJ/REINJ Dipoles) | 2011-04-15 → 2012-10-01 A (+535d) | 2011-05-12 → 2013-07-15 A (+795d) | 20d → 54d | 0% → 100% | 248d → none | 13441005b, 13441005a, 9-110M FS+130d → 9-130M, 9-110M FS+130d, 13441005b, 9-120M FS+135d, 13441005, 13441005a | resources MECH ENG [12 h]; MECH TECH [20 h] → MECH TECH [20 h]; MECH ENG [12 h] |
| 13441015 | Re-Baseline Actuals Adjustment | 2013-08-30 A | 2013-08-30 A |  | 0% → 100% | 20d → none | 9-130M FS+227d → none |  |
| 13444909LOE | FY09 Mngmnt/Planning for Reinjection Modifications (INJ/RE-INJ Stands) | 2009-01-02 A | 2009-09-30 A |  | 0% → 100% | 20d → none |  |  |
| 13444015 | Proc Prep New ReInjection Stands (INJ/RE-INJ Stands) | 2011-06-15 → 2010-11-15 A (-212d) | 2011-08-16 → 2011-12-19 A (+125d) | 44d → 271d | 0% → 100% | 155d → none |  | resources MECH DES [36 h]; MECH ENG [48 h] → MECH ENG [48 h]; MECH DES [36 h] |
| 13444020 | Proc Alignment Cartridges (INJ/RE-INJ Stands) | 2010-12-07 → 2010-11-15 A (-22d) | 2011-05-05 → 2011-02-28 A (-66d) | 100d → 66d | 0% → 100% | 253d → none |  |  |
| 13445005 | Proc/Vend Fab New Girder for Chicane (INJ/RE-INJ Girders) | 2010-08-12 → 2010-11-15 A (+95d) | 2010-11-05 → 2011-03-25 A (+140d) | 61d → 85d | 0% → 100% | 372d → none |  |  |
| 13444025 | Procurem/Vend Fab Modifications for Spectrometer (INJ/RE-INJ Stands) | 2010-12-07 → 2011-03-01 A (+84d) | 2011-06-17 → 2011-03-25 A (-84d) | 130d → 19d | 0% → 100% | 223d → none | 9-110M FS+45d, 121444020 → 121444020, 9-110M FS+80d |  |
| 13444017 | Vend Fab New ReInjection Stands (INJ/RE-INJ Stands) | 2012-01-13 → 2011-12-19 A (-25d) | 2012-04-24 → 2012-04-16 A (-8d) | 71d → 78d | 0% → 100% | 57d → none | 13444015, 9-120M FS+66d → 9-120M, 13444015 |  |
| 13444018 | Receive and Inspect New ReInjection Stands (INJ/RE-INJ Stands) | 2012-04-11 → 2012-02-01 A (-70d) | 2012-04-24 → 2012-04-16 A (-8d) | 10d → 53d | 0% → 100% | 57d → none | 13444017 FS-10d → 13444017 FS-70d |  |
| 13444950 | Re-Baseline Actuals Adjustment | 2013-08-30 A | 2013-08-30 A |  | 0% → 100% | 20d → none | 9-130M FS+227d → none |  |
| 6 | **1.3.4.4.6 VACUUM** | 2011-04-08 → 2011-09-01 (+146d) |  |  |  |  |  |  |
| 13446010 | Proc Prep New Vac Chambers (INJ/RE-INJ Vac) | 2011-04-08 → 2011-09-01 A (+146d) | 2011-06-09 → 2011-11-13 A (+157d) | 44d → 51d | 0% → 100% | 161d → none | 9-110M FS+125d, 121446005, 121446999 → 121446999, 9-110M FS+125d, 9-120M, 121446005 | resources MECH DES [40 h]; MECH ENG [80 h] → MECH ENG [80 h]; MECH DES [40 h] |
| 13446010a | Vend Fab New Vac Chambers (INJ/RE-INJ Vac) | 2011-11-14 A | 2012-02-29 → 2012-02-20 A (-9d) | 68d → 61d | 0% → 100% | 52d → none |  |  |
| 13446010b | Receive and Inspect New Vac Chambers (INJ/RE-INJ Vac) | 2012-02-15 → 2012-02-01 A (-14d) | 2012-02-29 → 2012-02-28 A (-1d) | 10d → 19d | 0% → 100% | 52d → none |  |  |
| 13446015 | Re-Baseline Actuals Adjustment | 2013-08-30 A | 2013-08-30 A |  | 0% → 100% | 20d → none | 9-130M FS+227d → none |  |
| 7 | **1.3.4.4.7 INSTALLATION** | 2012-06-05 → 2012-05-18 (-18d) | 2013-09-17 → 2013-10-21 (+34d) |  |  |  |  |  |
| 13447005 | 45 MeV Dump - Remove | 2012-06-05 → 2012-05-18 A (-18d) | 2012-06-08 → 2012-05-30 A (-9d) | 4d → 8d | 0% → 100% | 30d → none |  |  |
| 13447015 | OL/OR - Remove | 2012-09-07 → 2012-06-11 A (-88d) | 2012-09-21 → 2012-07-16 A (-67d) | 11d → 26d | 0% → 100% | 78d → none | 13417050M → 13417050M FS-50d |  |
| 13447025 | OL/OR - Upstairs | 2012-09-17 → 2012-07-09 A (-70d) | 2012-09-26 → 2013-05-13 A (+229d) | 8d → 119d | 0% → 100% | 85d → none |  | resources MECH ENG [140 h]; MECH TECH [192 h] → MECH TECH [192 h]; MECH ENG [140 h] |
| 13447020 | OL/OR - Install stands FY12 | 2012-09-24 → 2012-08-06 A (-49d) | 2012-09-28 → 2012-10-15 A (+17d) | 5d → 49.58d | 0% → 100% | 78d → none |  | resources MECH ENG [86 h]; MECH TECH [180 h] → MECH TECH [180 h]; MECH ENG [86 h] |
| 13447020a | OL/OR - Install stands FY13 | 2012-10-01 → 2012-08-06 A (-56d) | 2012-10-05 → 2012-10-15 A (+10d) | 5d → 50d | 0% → 100% | 78d → none | 13447020 → 13447020 FS-20d | resources MECH ENG [86 h]; MECH TECH [180 h] → MECH TECH [180 h]; MECH ENG [86 h] |
| 13447030 | OL/OR - Install magnets and girders | 2012-10-08 → 2012-09-10 A (-28d) | 2012-11-05 → 2013-06-17 A (+224d) | 21d → 84d | 0% → 100% | 78d → none | 13447025, 13447020a → 13447020 FS-10d, 13447020a FS-10d, 13447025 FS-20d |  |
| 13447035 | OL/OR - Final align | 2012-11-06 → 2012-12-10 A (+34d) | 2012-11-19 → 2013-07-15 A (+238d) |  | 0% → 100% | 78d → none | 13447030 → 13447030 FS-25d | resources MECH ENG [44 h]; MECH TECH [200 h] → MECH TECH [200 h]; MECH ENG [44 h] |
| 13447010 | 45 MeV Dump - Re-install | 2013-07-25 → 2013-08-30 A (+36d) | 2013-08-01 → 2013-08-30 A (+29d) |  | 0% → 100% | 30d → none |  |  |
| 13447040 | Re-Baseline Actuals Adjustment | 2013-08-30 A | 2013-08-30 A |  | 0% → 100% | 20d → none | 9-130M FS+227d → none |  |
| 23447010 | 45 MeV Dump - Re-install | 2013-09-03 A | 2013-09-17 → 2013-10-21 A (+34d) |  | 0% → 100% | 3d → none |  |  |
| 5 | **1.3.4.5 ARC 10 & HALL D BEAMLINE** |  | 2013-10-23 → 2013-12-03 (+41d) |  |  |  |  |  |
| 13451909LOE | FY09 Mngmnt & Oversight (ARC10/H-D Dipoles) | 2009-01-02 A | 2009-09-30 A |  | 0% → 100% | 20d → none |  | was named FY09 Mngmnt & Oversight (ARC10/H-D Dipl) |
| 13451055 | Prcrmnt Prep of 4m Dipoles (ARC10/H-D Dipoles) | 2009-01-02 → 2009-01-05 A (+3d) | 2009-01-12 → 2009-05-25 A (+133d) | 7d → 98d | 0% → 100% | 117d → none |  | was named Prcrmnt Prep of 4m Dipls (ARC10/H-D Dipl) |
| 13451075 | Prcrmnt Prep for 2m Pass 6 Dipole (ARC10/H-D Dipoles) | 2009-01-12 → 2009-03-02 A (+49d) | 2009-06-26 → 2009-11-23 A (+150d) | 117d → 188d | 0% → 100% | 270d → none | 121451035, 9-090M FS+65d, 121456999 → 121451035, 9-090M FS+65d, 121456999 FS-15d | was named Prcrmnt Prep for 2m Pass 6 Dipole (ARC10/H-D Dipl); resources MECH ENG [40 h]; MECH DES [36 h] → MECH DES [36 h]; MECH ENG [40 h] |
| 13451060M | Award Contract for 4m Dipl (ARC10/H-D Dipl) | 2009-01-12 → 2009-06-02 A (+141d) | 2009-01-12 → 2009-06-02 A (+141d) |  | 0% → 100% | 117d → none |  |  |
| 13451063a | PROC 4m Dpl Cntr PP3a for Coil Material (ARC10/H-D Dipl) | 2009-06-30 → 2009-07-01 A (+1d) | 2009-09-30 → 2009-08-24 A (-37d) | 65d → 38d | 0% → 100% | 486d → none | 13451060M FS+117d → 13451060M FS+21d |  |
| 13451063b | PROC 4m Dpl Cntr PP3b for Core Material (ARC10/H-D Dipl) | 2009-06-30 → 2009-07-01 A (+1d) | 2009-08-31 → 2009-09-22 A (+22d) | 44d → 58d | 0% → 100% | 507d → none | 13451060M FS+117d → 13451063a FS-65d | resources PROCUREMENT>$50K 69; PROCUREMENT<$50K 60 → PROCUREMENT<$50K 60; PROCUREMENT>$50K 69 |
| 13451063c | PROC 4m Dipl Cntr PP3c for 1st Article Coil Set (ARC10/H-D Dipl) | 2009-06-30 → 2009-07-01 A (+1d) | 2009-11-30 → 2010-02-24 A (+86d) | 106d → 159d | 0% → 100% | 445d → none | 13451060M FS+117d → 13451063b FS-21d |  |
| 13451063d | PROC 4m Dipl Cntr PP3d for 1st Article Core Set (ARC10/H-D Dipl) | 2009-06-30 → 2009-07-01 A (+1d) | 2009-12-31 → 2010-02-24 A (+55d) | 124d → 159d | 0% → 100% | 427d → none | 13451060M FS+117d → 13451063c FS-62d, 13451060M FS+21d |  |
| 13451063e-1 | PROC 4m Dipl Cntr PP3e-1 Deliver 6 Magnets (ARC10/H-D Dipl) | 2009-06-30 → 2009-07-01 A (+1d) | 2010-02-26 → 2010-05-24 A (+87d) | 162d → 222d | 0% → 100% | 389d → none | 13451060M FS+117d → 13451063d FS-80d |  |
| 13451063e-2 | PROC 4m Dipl Cntr PP3e-2 Deliver 10 Magnets (ARC10/H-D Dipl) | 2009-06-30 → 2009-07-01 A (+1d) | 2010-04-30 → 2010-08-23 A (+115d) | 207d → 285d | 0% → 100% | 344d → none | 13451060M FS+117d → 13451063e-1 FS-118d | resources PROCUREMENT<$50K 60 NO ESCALATION; PROCUREMENT>$50K 69 NO ESCALATION → PROCUREMENT>$50K 69 NO ESCALATION; PROCUREMENT<$50K 60 NO ESCALATION |
| 13451063e-3 | PROC 4m Dipl Cntr PP3e-3 Deliver 10 Magnets (ARC10/H-D Dipl) | 2009-06-30 → 2009-07-01 A (+1d) | 2010-06-30 → 2010-11-15 A (+138d) | 249d → 344d | 0% → 100% | 302d → none | 13451060M FS+117d → 13451063e-2 FS-163d | resources PROCUREMENT<$50K 60 NO ESCALATION; PROCUREMENT>$50K 69 NO ESCALATION → PROCUREMENT>$50K 69 NO ESCALATION; PROCUREMENT<$50K 60 NO ESCALATION |
| 13451063e-4 | PROC 4m Dipl Cntr PP3e-4 Deliver 10 Magnets (ARC10/H-D Dipl) | 2009-06-30 → 2009-07-01 A (+1d) | 2010-12-30 → 2011-01-24 A (+25d) | 371d → 385d | 0% → 100% | 180d → none | 13451060M FS+117d → 13451063e-3 FS-205d | resources PROCUREMENT<$50K 60 NO ESCALATION; PROCUREMENT>$50K 69 NO ESCALATION → PROCUREMENT>$50K 69 NO ESCALATION; PROCUREMENT<$50K 60 NO ESCALATION |
| 13451065 | FY09 LABOR Oversight 4m Dipl Contract (ARC10/H-D Dipl) | 2009-01-13 → 2009-07-01 A (+169d) | 2009-09-30 A | 182d → 64d | 0% → 100% | 259d → none |  | resources MECH DES [41.1 h]; MECH ENG [114.48 h] → MECH ENG [114.48 h]; MECH DES [41.1 h] |
| 13451066 | FY 10 LABOR Oversight 4m Dipl Contract (ARC10/H-D Dipl) | 2009-10-01 A | 2010-08-31 A |  | 0% → 100% | 259d → none |  |  |
| 13451910LOE | FY10 Mngmnt & Oversight (ARC10/H-D Dipoles) | 2009-10-01 A | 2010-09-30 A |  | 0% → 100% | 20d → none |  | was named FY10 Mngmnt & Oversight (ARC10/H-D Dipl) |

| ID | Task | Start | Finish | Duration | Complete | Total float | Predecessors | Other |
| --- | --- | --- | --- | --- | --- | --- | --- | --- |
| 13451085 | P-1 Vend Fab 2m Pass 6 Dipole (ARC10/H-D Dipoles) Labor FY09 | 2009-06-29 → 2009-11-18 A (+142d) | 2009-09-30 → 2010-02-26 A (+149d) | 66d → 63d | 0% → 100% | 270d → none |  | was named P-1 Vend Fab 2m Pass 6 Dipole (ARC10/H-D Dipl) Labor FY09; resources MECH DES [11.71 h]; MECH ENG [27.68 h] → MECH ENG [27.68 h]; MECH DES [11.71 h] |
| 13451085b | P-1 Vend Fab 2m Pass 6 Dipole (ARC10/H-D Dipoles) Labor FY10 | 2009-10-01 → 2009-11-18 A (+48d) | 2010-06-28 → 2010-02-26 A (-122d) | 182d → 63d | 0% → 100% | 270d → none | 13451085 → 13451085 FS-250d | was named P-1 Vend Fab 2m Pass 6 Dipole (ARC10/H-D Dipl) Labor FY10; resources MECH DES [32.29 h]; MECH ENG [76.32 h] → MECH ENG [76.32 h]; MECH DES [32.29 h] |
| 13451080M | Award Contract for 2m Pass 6 Dipole (ARC10/H-D DIPOLES) | 2009-06-26 → 2009-11-23 A (+150d) | 2009-06-26 → 2009-11-23 A (+150d) |  | 0% → 100% | 270d → none |  | was named Award Contract for 2m Pass 6 Dipole (ARC10/H-D Dipl) |
| 13451086 | P-2 Vend Fab 2m Pass 6 Dipole (ARC10/H-D Dipoles) Original Labor FY10 | 2010-01-29 A | 2010-09-30 → 2011-01-28 A (+120d) | 171d → 248d | 0% → 100% | 270d → none | 13451085b FS-105d → 13451085b FS-125d | was named P-2 Vend Fab 2m Pass 6 Dipole (ARC10/H-D Dipl) Original Labor FY10; resources MECH DES [30.34 h]; MECH ENG [68.95 h] → MECH ENG [68.95 h]; MECH DES [30.34 h] |
| 13451086a | P-2 Vend Fab 2m Pass 6 Dipole (ARC10/H-D Dipoles) Original Labor FY11 | 2010-10-01 → 2010-01-29 A (-245d) | 2011-01-28 A | 77d → 248d | 0% → 100% | 270d → none | 13451086 → 13451085b FS-125d | was named P-2 Vend Fab 2m Pass 6 Dipole (ARC10/H-D Dipl) Original Labor FY11 |
| 13451068M | Deliver 1st Article 4m Dipl (ARC10/H-D Dipl) (IPL) | 2009-12-31 → 2010-02-24 A (+55d) | 2009-12-31 → 2010-02-24 A (+55d) |  | 0% → 100% | 427d → none | 13451063d, 13451063c, 13451063b, 13451063a → 13451063a, 13451063d | was named Deliver 1st Article 4m Dipl (ARC10/H-D Dipl) (IPL 534213030, 534213090 and 534213150) |
| 13451100 | Mag Measurement of Arc 10 & H-D Dipoles (ARC10/H-D Dipoles) FY10 | 2010-02-22 → 2010-07-02 A (+130d) | 2010-09-30 → 2010-07-26 A (-66d) | 156d → 16d | 0% → 100% | 99d → none | 121421022, 13451090M FS-404d, 13451070M FS-295d → 13451070M FS-295d, 13451090M FS-404d, 121421022 FS-100d | was named Mag Measurement of Arc 10 & H-D Dipl (ARC10/H-D Dipl) (IPL) FY10; resources MECH TECH [320 h]; MECH ENG [192 h]; COMP SCIENT [8 h]; OFFICE [8 h] → OFFICE [8 h]; MECH ENG [192 h]; MECH TECH [320 h]; COMP SCIENT [8 h] |
| 13451100a | Mag Measurement of Arc 10 & H-D Dipoles (ARC10/H-D Dipoles) FY11 | 2010-10-01 → 2010-07-02 A (-91d) | 2011-09-12 → 2010-07-26 A (-413d) | 234d → 16d | 0% → 100% | 99d → none | 13451100 → 121421022 FS-100d, 13451070M FS-295d, 13451090M FS-404d | was named Mag Measurement of Arc 10 & H-D Dipl (ARC10/H-D Dipl) (IPL) FY11; resources OFFICE [12 h]; MECH TECH [480 h]; MECH ENG [288 h]; COMP SCIENT [12 h] → MECH ENG [288 h]; MECH TECH [480 h]; COMP SCIENT [12 h]; OFFICE [12 h] |
| 13451105 | Completion of Mag Measurement of Arc 10 & H-D Dipl (ARC10/H-D Dipl) FY11 | 2011-09-13 → 2010-09-13 A (-365d) | 2011-09-30 → 2011-04-25 A (-158d) | 14d → 151d | 0% → 100% | 99d → none | 13451100a → 13451100 FS-50d, 13451100a FS-50d |  |
| 13451105a | Completion of Mag Measurement of Arc 10 & H-D Dipl (ARC10/H-D Dipl) FY12 | 2011-10-03 → 2010-09-13 A (-385d) | 2011-12-14 → 2011-04-25 A (-233d) | 51d → 151d | 0% → 100% | 99d → none |  | resources MECH ENG [596.31 h]; MECH TECH [1569.23 h] → MECH TECH [1569.23 h]; MECH ENG [596.31 h] |
| 13451911LOE | FY11 Mngmnt & Oversight (ARC10/H-D Dipoles) | 2010-10-01 A | 2011-09-30 A |  | 0% → 100% | 20d → none |  | was named FY11 Mngmnt & Oversight (ARC10/H-D Dipl) |
| 13451070M | Delivery Complete for all 4m Dipl (ARC10/H-D Dipl) | 2010-12-30 → 2011-01-24 A (+25d) | 2010-12-30 → 2011-01-24 A (+25d) |  | 0% → 100% | 180d → none | 13451063e-4, 13451068M, 13451063e-3, 13451063e-1, 13451063e-2, 13451066 → 13451063e-4, 13451068M, 13451063e-4 FF, 13451066 |  |
| 13451090M | Delivery Complete for 2m Pass 6 Dipole (ARC10/H-D Dipl) | 2011-09-30 → 2011-01-24 A (-249d) | 2011-09-30 → 2011-01-24 A (-249d) |  | 0% → 100% | 99d → none | 13411105v, 13411105x, 13451086a → 13451086, 13451086a |  |
| 13451095 | Modify Alignment Fixture for Dipoles (ARC10/H-D Dipoles) | 2011-04-01 → 2011-03-01 A (-31d) | 2011-07-05 → 2011-04-25 A (-71d) | 66d → 40d | 0% → 100% | 212d → none |  | was named Modify Alignment Fixture for Dipl (ARC10/H-D Dipl) |
| 13451912LOE | FY12 Mngmnt & Oversight (ARC10/H-D Dipoles) | 2011-10-03 → 2011-09-03 A (-30d) | 2012-09-28 → 2011-09-26 A (-368d) | 247d → 15d | 0% → 100% | 20d → none |  | was named FY12 Mngmnt & Oversight (ARC10/H-D Dipl) |
| 13451950 | Re-Baseline Actuals Adjustment | 2013-08-30 A | 2013-08-30 A |  | 0% → 100% | 20d → none | 9-130M FS+227d → none |  |
| 2 | **1.3.4.5.2 QUADRUPOLES** | 2009-01-02 → 2009-01-05 (+3d) |  |  |  |  |  |  |
| 13452025 | Prcrmnt Prep for Quads (ARC 10/H-D Q-POLES) | 2009-01-02 → 2009-01-05 A (+3d) | 2009-02-18 → 2009-06-30 A (+132d) | 32d → 124d | 0% → 100% | 92d → none |  |  |
| 13452030M | Award Contract for Quadrupoles (ARC 10/H-D Q-POLES) | 2009-08-03 → 2009-07-01 A (-33d) | 2009-08-03 → 2009-07-01 A (-33d) |  | 0% → 100% | -23d → none | 13452025, 9-090M FS+206d, 1114010 → 13452025X, 13452025, 9-090M FS+206d, 1114010 |  |
| 13453010 | Prcrmnt Prep for Correctors (ARC10/H-D Correctors) FY09 | 2009-07-02 → 2009-07-16 A (+14d) | 2009-09-30 → 2009-12-21 A (+82d) | 63d → 109d | 0% → 100% | 148d → none |  |  |
| 13452035 | Vend Fab Quads (ARC 10/H-D Q-POLES) LABOR Initial | 2009-02-19 → 2009-08-03 A (+165d) | 2009-07-31 → 2009-09-30 A (+61d) | 115d → 42d | 0% → 100% | 404d → none |  | resources MECH DES [74.2 h]; MECH ENG [64.92 h] → MECH ENG [64.92 h]; MECH DES [74.2 h] |
| 13452037 | Vend Fab Quads (ARC 10/H-D Q-POLES) Recieve Materials | 2009-08-03 A | 2009-10-05 → 2009-10-30 A (+25d) | 45d → 64d | 0% → 100% | 652d → none | 13452035 → 13452035 FS-115d |  |
| 13452037A | Vend Fab Quads (ARC 10/H-D Q-POLES) Lamination Stampings | 2009-08-03 A | 2009-08-03 → 2009-12-21 A (+140d) | 1d → 97d | 0% → 100% | 696d → none | 13452035 → 13452037 FS-24d, 13452035 FS-115d |  |
| 13452037B | Vend Fab Quads (ARC 10/H-D Q-POLES) First Article QP | 2009-08-03 A | 2009-10-16 → 2009-11-30 A (+45d) | 54d → 83d | 0% → 100% | 404d → none | 13452035 → 13452037A FS-1d |  |
| 13452037C | Vend Fab Quads (ARC 10/H-D Q-POLES) Deliver 8 QP Magnets | 2009-08-03 A | 2009-12-31 → 2010-01-25 A (+25d) | 101d → 116d | 0% → 100% | 596d → none | 13452035 → 13452037B FS-33d |  |
| 13452037D | Vend Fab Quads (ARC 10/H-D Q-POLES) Deliver 8 QP Magnets | 2009-08-03 A | 2010-01-29 → 2010-03-29 A (+59d) | 120d → 160d | 0% → 100% | 577d → none | 13452035 → 13452037C FS-80d |  |
| 13452037F | Vend Fab Quads (ARC 10/H-D Q-POLES) Deliver 3 QR Magnets | 2009-08-03 A | 2010-01-29 → 2010-01-25 A (-4d) | 120d → 116d | 0% → 100% | 577d → none | 13452035 → 13452037D FS-99d |  |
| 13452037G | Vend Fab Quads (ARC 10/H-D Q-POLES) Deliver 8 QP Magnets | 2009-08-03 A | 2010-02-26 → 2010-04-27 A (+60d) | 139d → 181d | 0% → 100% | 558d → none | 13452035 → 13452037F FS-99d |  |
| 13452037H | Vend Fab Quads (ARC 10/H-D Q-POLES) Deliver 3 QR Magnets | 2009-08-03 A | 2010-02-26 → 2010-02-25 A (-1d) | 139d → 138d | 0% → 100% | 558d → none | 13452035 → 13452037G FS-118d |  |
| 13452037J | Vend Fab Quads (ARC 10/H-D Q-POLES) Deliver 8 QP Magnets | 2009-08-03 A | 2010-03-29 → 2010-05-24 A (+56d) | 160d → 200d | 0% → 100% | 537d → none | 13452035 → 13452037H FS-118d |  |
| 13452037K | Vend Fab Quads (ARC 10/H-D Q-POLES) Deliver 3 QR Magnets | 2009-08-03 A | 2010-03-29 → 2010-05-24 A (+56d) | 160d → 200d | 0% → 100% | 537d → none | 13452035 → 13452037J FS-139d |  |
| 13452037L | Vend Fab Quads (ARC 10/H-D Q-POLES) Deliver 8 QP Magnets | 2009-08-03 A | 2010-04-30 → 2010-06-30 A (+61d) | 184d → 226d | 0% → 100% | 513d → none | 13452035 → 13452037K FS-139d |  |
| 13452037N | Vend Fab Quads (ARC 10/H-D Q-POLES) Deliver 3 QR Magnets | 2009-08-03 A | 2010-04-30 → 2010-05-24 A (+24d) | 184d → 200d | 0% → 100% | 513d → none | 13452035 → 13452037L FS-163d |  |
| 13452037P | Vend Fab Quads (ARC 10/H-D Q-POLES) Deliver 3 QR Magnets | 2009-08-03 A | 2010-05-28 → 2010-06-30 A (+33d) | 204d → 226d | 0% → 100% | 493d → none | 13452035 → 13452037o FS-183d |  |
| 13452037Q | Vend Fab Quads (ARC 10/H-D Q-POLES) Deliver 4 QP Magnets | 2009-08-03 A | 2010-06-23 → 2010-07-26 A (+33d) | 221d → 243d | 0% → 100% | 476d → none | 13452035 → 13452037P FS-183d |  |
| 13452037R | Vend Fab Quads (ARC 10/H-D Q-POLES) Deliver 3 QR Magnets | 2009-08-03 A | 2010-06-23 → 2010-06-30 A (+7d) | 221d → 226d | 0% → 100% | 476d → none | 13452035 → 13452037Q FS-200d |  |
| 13452037S | Vend Fab Quads (ARC 10/H-D Q-POLES) Deliver 2 QR Magnets | 2009-08-03 A | 2010-07-26 → 2010-06-30 A (-26d) | 243d → 226d | 0% → 100% | 454d → none | 13452035 → 13452037R FS-200d |  |
| 13452037T | Vend Fab Quads (ARC 10/H-D Q-POLES) Deliver 4 QP Magnets | 2009-08-03 A | 2010-07-21 → 2010-07-26 A (+5d) | 240d → 243d | 0% → 100% | 457d → none | 13452035 → 13452037S FS-222d |  |
| 13452037o | Vend Fab Quads (ARC 10/H-D Q-POLES) Deliver 8 QP Magnets | 2009-08-03 A | 2010-05-28 → 2010-07-26 A (+59d) | 204d → 243d | 0% → 100% | 493d → none | 13452035 → 13452037N FS-163d |  |
| 13452036 | Vend Fab Quads (ARC 10/H-D Q-POLES) LABOR Final FY09 | 2009-08-03 → 2009-09-01 A (+29d) | 2009-09-30 → 2009-10-30 A (+30d) |  | 0% → 100% | 454d → none | 13452035 → 13452035 FS-115d |  |
| 13453010b | Prcrmnt Prep for Correctors (ARC10/H-D Correctors) FY10 | 2009-10-01 → 2009-09-30 A (-1d) | 2009-12-16 → 2009-12-21 A (+5d) | 53d → 56d | 0% → 100% | 148d → none | 13453010 → 13453010 FS-300d |  |
| 13452036b | Vend Fab Quads (ARC 10/H-D Q-POLES) LABOR Final FY10 | 2009-10-01 A | 2010-07-26 A |  | 0% → 100% | 454d → none | 13452036 → 13452036 FS-500d |  |
| 13452045 | Mag Measurment of New Quads (ARC 10/H-D Q-POLES) Labor FY10 | 2010-04-16 → 2009-11-30 A (-137d) | 2010-09-30 → 2010-07-26 A (-66d) | 117d → 160.16d | 0% → 100% | 404d → none | 13452040M FS-120d, 13452038M FS+119d → 13452040M FS-600d, 13452038M |  |
| 13452045a | Mag Measurment of New Quads (ARC 10/H-D Q-POLES) Labor FY11 | 2010-10-01 → 2009-11-30 A (-305d) | 2011-02-07 → 2010-07-26 A (-196d) | 83d → 160.16d | 0% → 100% | 404d → none | 13452045 → 13452038M, 13452040M FS-600d | resources COMP SCIENT [16.6 h]; OFFICE [16.6 h]; MECH ENG [199.2 h]; MECH TECH [332 h] → MECH ENG [199.2 h]; MECH TECH [332 h]; COMP SCIENT [16.6 h]; OFFICE [16.6 h] |
| 13452045b | Mag Measurment of New Quads (ARC 10/H-D Q-POLES) Procurement | 2010-04-16 → 2009-11-30 A (-137d) | 2011-02-07 → 2010-07-26 A (-196d) | 200d → 160.16d | 0% → 100% | 404d → none | 13452040M FS-120d, 13452038M FS+119d → 13452040M FS-600d, 13452038M |  |
| 13452038M | Deliver 1st Article Quadrupoles (ARC 10/H-D Q-POLES) (IPL 534213165) | 2009-10-16 → 2009-11-30 A (+45d) | 2009-10-16 → 2009-11-30 A (+45d) |  | 0% → 100% | 404d → none |  |  |
| 13453020 | Vend Fab Correctors (ARC10/H-D Correctors) Labor FY10 | 2009-12-17 → 2009-12-21 A (+4d) | 2010-09-30 → 2011-01-24 A (+116d) | 195d → 265.14d | 0% → 100% | 148d → none |  | resources MECH DES [59.77 h]; MECH ENG [89.66 h] → MECH ENG [89.66 h]; MECH DES [59.77 h] |
| 13453020a | Vend Fab Correctors (ARC10/H-D Correctors) Labor FY11 | 2010-10-01 → 2009-12-21 A (-284d) | 2011-01-12 → 2011-01-24 A (+12d) | 66d → 266d | 0% → 100% | 148d → none | 13453020 → 13453015M | resources MECH DES [20.23 h]; MECH ENG [30.34 h] → MECH ENG [30.34 h]; MECH DES [20.23 h] |
| 13453020b | Vend Fab Correctors (ARC10/H-D Correctors) Procurement | 2009-12-17 → 2009-12-21 A (+4d) | 2011-01-12 → 2011-01-24 A (+12d) | 261d → 266d | 0% → 100% | 148d → none |  |  |
| 13453015M | Award Contract for Correctors (ARC10/H-D CORRECTORS) | 2009-12-16 → 2009-12-21 A (+5d) | 2009-12-16 → 2009-12-21 A (+5d) |  | 0% → 100% | 148d → none |  |  |
| 13452040M | Delivery Complete for Quadrupoles (ARC 10/H-D Q-POLES) | 2010-07-26 A | 2010-07-26 A |  | 0% → 100% | 454d → none | 13452037G, 13452037Q, 13452037J, 13452037H, 13452037R, 13452037D, 13452037N, 13452037S, 13452037C, 13452037o, 13452037L, 13452038M, 13452037A, 13452037F, 13452037B, 13452037, 13452037K, 13452037T, 13452036b, 13452037P → 13452037, 13452036b, 13452038M, 13452037T |  |
| 13453030 | Mag Measurment of Correctors (ARC10/H-D Correctors) | 2011-01-13 → 2010-09-13 A (-122d) | 2011-07-08 → 2011-11-14 A (+129d) | 123d → 293d | 0% → 100% | 148d → none | 13453015M FS+159d, 13453025 → 13453025 FS-70d, 13453015M | resources COMP SCIENT [20 h]; OFFICE [20 h]; MECH TECH [184 h]; MECH ENG [12 h] → OFFICE [20 h]; MECH TECH [184 h]; COMP SCIENT [20 h]; MECH ENG [12 h] |
| 13452050 | Completion of Quadrapole Mag Measurement FY10 | 2010-07-01 → 2010-10-01 A (+92d) | 2010-09-30 → 2011-03-25 A (+176d) | 64d → 116d | 0% → 100% | 254d → none |  |  |
| 13452050a | Completion of Quadrapole Mag Measurement FY11 | 2010-10-01 A | 2011-02-07 → 2011-03-25 A (+46d) | 83d → 116d | 0% → 100% | 254d → none | 9-100M FS+184d, 13452050 → 9-100M FS+184d, 13452050 FS-60d |  |
| 13453025 | Delivery Complete for Correctors (ARC10/H-D CORRECTORS) | 2011-01-12 → 2011-01-24 A (+12d) | 2011-01-12 → 2011-01-24 A (+12d) |  | 0% → 100% | 148d → none | 13453020a, 13453020b → 13453020b, 13453020, 13453020a |  |
| 13452055 | Re-Baseline Actuals Adjustment | 2013-08-30 A | 2013-08-30 A |  | 0% → 100% | 20d → none | 9-130M FS+227d → none |  |
| 4 | **1.3.4.5.4 STANDS** | 2010-01-05 → 2009-12-21 (-15d) | 2013-10-23 → 2013-11-25 (+33d) |  |  |  |  |  |
| 13454015 | Prcrmnt Prep for Arc 10 Stands | 2010-10-01 → 2009-12-21 A (-284d) | 2010-12-13 → 2010-03-22 A (-266d) | 50d → 57.68d | 0% → 100% | 716d → none | 121456999, 9-110M, 121454015a → 121456999, 9-110M FS-250d, 121454015a |  |
| 13454022LOE | Vend Fab Arc 10 Stands Oversight | 2010-03-15 A | 2010-06-28 A |  | 0% → 100% | 716d → none |  | resources MECH DES [50 h]; MECH ENG [20 h] → MECH ENG [20 h]; MECH DES [50 h] |
| 13454020M | Award Arc 10 Stands | 2010-03-15 → 2010-03-22 A (+7d) | 2010-03-15 → 2010-03-22 A (+7d) |  | 0% → 100% | 716d → none | 13454015 FS-191d → 13454015 FS-210d |  |
| 13454025 | Vend Fab Arc 10 Stands Phase 1 | 2010-03-15 → 2010-03-22 A (+7d) | 2010-05-24 → 2010-06-30 A (+37d) | 51d → 72d | 0% → 100% | 716d → none |  |  |
| 13454025A | Vend Fab Arc 10 Stands Phase 2 | 2010-03-15 → 2010-03-22 A (+7d) | 2010-06-11 → 2010-06-30 A (+19d) | 64d → 72d | 0% → 100% | 716d → none |  |  |
| 13454025B | Vend Fab Arc 10 Stands Phase 3 | 2010-03-15 → 2010-03-22 A (+7d) | 2010-06-28 → 2010-07-26 A (+28d) | 75d → 89d | 0% → 100% | 716d → none |  |  |
| 13455015 | Proc/Vend Fab Arc 10 Griders (ARC 10/H-D Girders) (Original) | 2010-01-05 → 2010-03-29 A (+83d) | 2010-02-26 → 2010-03-29 A (+31d) | 37d → 1d | 0% → 100% | 200d → none |  | resources MECH DES [18.5 h]; MECH ENG [8.88 h]; MECH TECH [14.8 h] → MECH DES [18.5 h]; MECH TECH [14.8 h]; MECH ENG [8.88 h] |
| 13455020 | Proc/Vend Fab H-D Girders (ARC 10/H-D Girders) (Original) | 2010-01-05 → 2010-03-29 A (+83d) | 2010-02-26 → 2010-03-29 A (+31d) | 37d → 1d | 0% → 100% | 200d → none |  | resources MECH TECH [11.1 h]; MECH DES [18.5 h]; MECH ENG [8.88 h] → MECH DES [18.5 h]; MECH TECH [11.1 h]; MECH ENG [8.88 h] |
| 13454031 | Prcrmnt Prep for Hall D Girder Floor Plates | 2010-04-01 → 2010-04-12 A (+11d) | 2010-04-28 → 2010-06-29 A (+62d) | 20d → 56d | 0% → 100% | 869d → none |  |  |
| 13455010 | Proc Prep For Arc 10 Girders | 2010-04-05 → 2010-04-12 A (+7d) | 2010-07-16 → 2010-07-26 A (+10d) | 73d → 74d | 0% → 100% | 12d → none |  | resources MECH ENG [240 h]; MECH TECH [160 h]; MECH DES [120 h] → MECH DES [120 h]; MECH ENG [240 h]; MECH TECH [160 h] |
| 13454026 | Receive and Inspect Arc 10 Stands | 2010-05-25 → 2010-06-01 A (+7d) | 2010-06-28 → 2010-07-26 A (+28d) | 24d → 39d | 0% → 100% | 716d → none |  |  |
| 13454032 | Vend fab Hall D Girder Floor Plates | 2010-04-29 → 2010-06-28 A (+60d) | 2010-06-23 → 2010-08-23 A (+61d) | 39d → 40d | 0% → 100% | 869d → none |  |  |
| 13455023 | Vend Fab Arc 10 Girders Oversight FY10 | 2010-07-19 A | 2010-09-30 → 2010-11-19 A (+50d) | 53d → 88.59d | 0% → 100% | 13d → none |  | resources MECH ENG [23.82 h]; MECH DES [35.73 h] → MECH DES [35.73 h]; MECH ENG [23.82 h] |

| ID | Task | Start | Finish | Duration | Complete | Total float | Predecessors | Other |
| --- | --- | --- | --- | --- | --- | --- | --- | --- |
| 13455023a | Vend Fab Arc 10 Girders Oversight FY11 | 2010-10-01 → 2010-07-19 A (-74d) | 2010-11-19 A | 36d → 89d | 0% → 100% | 13d → none | 13455023 → 13455010 |  |
| 13454030M | Delivery Complete for Arc 10 Stands | 2010-06-28 → 2010-07-26 A (+28d) | 2010-06-28 → 2010-07-26 A (+28d) |  | 0% → 100% | 716d → none |  |  |
| 13455130 | Proc Prep Tagger Dump Enclosure | 2010-08-02 → 2010-07-30 A (-3d) | 2010-09-24 → 2010-08-30 A (-25d) | 39d → 22d | 0% → 100% | 1286d → none |  | resources MECH DES [160 h]; MECH ENG [80 h] → MECH ENG [80 h]; MECH DES [160 h] |
| 13455140 | Proc Prep Hall D Movaable Shield Wall FY10 | 2010-08-02 → 2010-07-30 A (-3d) | 2010-09-30 → 2010-09-27 A (-3d) | 43d → 41d | 0% → 100% | 1179d → none |  |  |
| 13455140a | Proc Prep Hall D Movaable Shield Wall FY11 | 2010-10-01 → 2010-07-30 A (-63d) | 2010-10-11 → 2010-09-27 A (-14d) | 7d → 41d | 0% → 100% | 1179d → none | 13455140 → 9-100M FS+205d | resources MECH DES [33.6 h]; MECH ENG [16.8 h] → MECH ENG [16.8 h]; MECH DES [33.6 h] |
| 13454042 | Prcrmnt Prep for Alignment Cartridges (ARC10/H-D Stands) FY10 | 2010-08-02 A | 2010-09-30 → 2010-11-15 A (+46d) | 43d → 74.81d | 0% → 100% | 272d → none |  | resources MECH DES [4.35 h]; MECH ENG [43.54 h] → MECH ENG [43.54 h]; MECH DES [4.35 h] |
| 13454042a | Prcrmnt Prep for Alignment Cartridges (ARC10/H-D Stands) FY11 | 2010-10-01 → 2010-08-02 A (-60d) | 2010-11-19 → 2010-11-15 A (-4d) | 36d → 75d | 0% → 100% | 272d → none | 13454042 → 9-100M FS+205d | resources MECH DES [3.65 h]; MECH ENG [36.46 h] → MECH ENG [36.46 h]; MECH DES [3.65 h] |
| 13455025 | Vend Fab Arc 10 Girders Phase 1 | 2010-07-19 → 2010-08-02 A (+14d) | 2010-10-22 → 2010-11-15 A (+24d) | 69d → 75d | 0% → 100% | 12d → none |  | resources PROCUREMENT<$50K 60 NO ESCALATION FY11; PROCUREMENT>$50K 69 NO ESCALATION FY11 → PROCUREMENT>$50K 69 NO ESCALATION FY11; PROCUREMENT<$50K 60 NO ESCALATION FY11 |
| 13455075 | Prcrmnt Prep for Hall D Stands Part 1 | 2010-06-01 → 2010-08-09 A (+69d) | 2010-06-30 → 2010-08-23 A (+54d) | 22d → 11d | 0% → 100% | 624d → none |  | was named Prcrmnt Prep for Hall D Stands Phase 1; resources MECH ENG [40 h]; MECH DES [20 h] → MECH DES [20 h]; MECH ENG [40 h] |
| 13454035 | Proc Misc Brackets & Hardware (ARC10/H-D Stands) | 2010-10-01 → 2010-08-23 A (-39d) | 2011-04-14 → 2012-09-17 A (+522d) | 130d → 514d | 0% → 100% | 520d → none | 121456999, 9-110M → 9-110M FS-25d, 121456999 |  |
| 13455135 | Vend Fab Tagger Dump Enclosure | 2010-08-20 → 2010-08-23 A (+3d) | 2010-10-14 → 2010-09-20 A (-24d) | 39d → 20d | 0% → 100% | 1286d → none | 13455130 FS-25d → 13455130 |  |
| 13455028 | Vend Fab Arc 10 Girders Phase 2 | 2010-07-19 → 2010-09-13 A (+56d) | 2010-12-08 → 2011-03-25 A (+107d) | 100d → 130d | 0% → 100% | 12d → none | 13455025 FS-69d → 13455025 FS-20d |  |
| 13455035 | Vend Fab Hall D Floor Girders | 2010-08-09 → 2010-10-01 A (+53d) | 2010-11-24 → 2011-03-25 A (+121d) | 77d → 116d | 0% → 100% | 10d → none | 9-100M FS+210d → 9-100M FS+210d, 9-110M |  |
| 13455115 | Proc Prep Arc 10 Floor to Ceiling Stands | 2010-06-04 → 2010-10-11 A (+129d) | 2010-08-23 → 2011-10-15 A (+418d) | 56d → 252d | 0% → 100% | 551d → none |  |  |
| 13455030 | Receive and Inspect Arc 10 Girders | 2010-11-09 → 2010-11-15 A (+6d) | 2010-12-08 → 2011-03-25 A (+107d) | 20d → 85d | 0% → 100% | 12d → none | 13455025, 13455028 FS-20d → 13455025, 13455028 FS-60d |  |
| 13454045 | Vend Fab Alignment Cartridges (ARC10/H-D Stands) | 2010-11-22 → 2010-12-03 A (+11d) | 2011-04-08 → 2011-02-21 A (-46d) | 90d → 49d | 0% → 100% | 272d → none | 13454042a → 13454042a, 13454042 |  |
| 13455040 | Proc Prep For Hall D Girders | 2010-12-03 A | 2011-04-07 → 2011-06-20 A (+74d) | 82d → 133d | 0% → 100% | 109d → none |  | resources MECH DES [40 h]; MECH ENG [80 h] → MECH ENG [80 h]; MECH DES [40 h] |
| 13454047 | Receive and Inspect Alignment Cartridges (ARC10/H-D Stands) | 2011-03-28 → 2011-02-21 A (-35d) | 2011-04-08 → 2011-03-25 A (-14d) | 10d → 24d | 0% → 100% | 272d → none |  |  |
| 13455045 | Vend Fab Hall D Girders Oversight | 2011-04-08 → 2011-03-01 A (-38d) | 2011-09-01 → 2011-10-11 A (+40d) | 103d → 158d | 0% → 100% | 109d → none | 13455040 → 13455040 FS-20d |  |
| 13455050 | Vend Fab Hall D Girders Part 1 | 2011-04-08 → 2011-03-01 A (-38d) | 2011-07-28 → 2011-04-25 A (-94d) | 78d → 40d | 0% → 100% | 109d → none | 13455040 → 13455040 FS-20d |  |
| 13455060 | Receive and Inspect Hall D Girders | 2011-07-29 → 2011-04-01 A (-119d) | 2011-09-01 → 2011-10-11 A (+40d) | 25d → 135d | 0% → 100% | 109d → none | 13455055 FS-25d, 13455050 → 13455055 FS-125d, 13455050 | resources MECH TECH [60 h]; MECH ENG [8 h] → MECH ENG [8 h]; MECH TECH [60 h] |
| 13455055 | Vend Fab Hall D Girders Part 2 | 2011-04-08 → 2011-06-30 A (+83d) | 2011-09-01 → 2011-10-15 A (+44d) | 103d → 75d | 0% → 100% | 109d → none |  |  |
| 13454036 | Prcrmnt Prep for Insertable Dumps (ARC10/H-D Stands) | 2011-01-05 → 2011-10-10 A (+278d) | 2011-03-07 → 2011-11-14 A (+252d) | 42d → 26d | 0% → 100% | 229d → none | 9-110M FS+60d → 9-120M, 9-110M FS+60d |  |
| 13455120 | Vend Fab Arc 10 Floor to Ceiling Stands | 2010-11-17 → 2011-10-17 A (+334d) | 2011-03-03 → 2012-01-16 A (+319d) | 67d → 57d | 0% → 100% | 551d → none | 13455115 FS+60d → 13455115 |  |
| 13454040 | Vend Fab Insertable Dumps (ARC10/H-D Stands) | 2012-01-13 → 2011-11-14 A (-60d) | 2012-06-29 → 2012-04-16 A (-74d) | 117d → 101d | 0% → 100% | 17d → none | 9-120M FS+66d, 13454036 → 9-120M, 13454036 |  |
| 13455080 | Prcrmnt Prep for Hall D Stands Part 2 | 2011-06-09 → 2012-01-03 A (+208d) | 2011-09-30 → 2012-05-02 A (+215d) | 80d → 85d | 0% → 100% | 392d → none | 9-120M FS-80d, 13455075 → 9-120M FS+60d, 13455075 | was named Prcrmnt Prep for Hall D Stands Phase 2; resources MECH ENG [120 h]; MECH DES [60 h] → MECH DES [60 h]; MECH ENG [120 h] |
| 13455125 | Receive and Inspect Arc 10 Floor to Ceiling Stands | 2011-02-17 → 2012-01-16 A (+333d) | 2011-03-03 → 2012-01-23 A (+326d) | 10d → 5d | 0% → 100% | 551d → none |  |  |
| 13455085LOE | Vend Fab Hall D Stands Oversight | 2012-01-18 A | 2012-04-30 A |  | 0% → 100% | 411d → none | 13455080M → 13455080M FS-55d |  |
| 13454050 | 100 kW dump Modifications (ARC10/H-D Stands) Original | 2011-06-08 → 2012-03-20 A (+286d) | 2011-07-29 → 2013-03-11 A (+591d) | 37d → 197d | 0% → 100% | 549d → none | 13458030 FS-18d → 9-120M FS+85d, 13458030 FS-18d | resources MECH TECH [40 h]; MECH DES [40 h]; MECH ENG [60 h] → MECH ENG [60 h]; MECH DES [40 h]; MECH TECH [40 h] |
| 13455145 | Vend Fab Hall D Movable Shield Wall | 2010-10-12 → 2012-04-16 A (+552d) | 2011-03-28 → 2012-11-12 A (+595d) | 110d → 148d | 0% → 100% | 1179d → none | 13455140a → 13455140, 13455140a, 9-120M FS+125d, 9-110M FS+100d | was named Vend Fab Hall D Movaable Shield Wall |
| 13455080M | Award Hall D Stands | 2012-01-17 → 2012-06-02 A (+137d) | 2012-01-17 → 2012-06-02 A (+137d) |  | 0% → 100% | 324d → none | 13455080, 9-120M FS+68d → 13455080, 9-120M FS+150d |  |
| 13455090 | Vend Fab Hall D Stands | 2012-06-11 → 2012-06-05 A (-6d) | 2012-08-31 → 2013-05-13 A (+255d) | 60d → 134d | 0% → 100% | 324d → none | 13455080M FS+100d → 13455080M FS+8d | resources PROCUREMENT>$50K 69; PROCUREMENT<$50K 60 → PROCUREMENT<$50K 60; PROCUREMENT>$50K 69 |
| 13455105 | Receive and Inspect Hall D Stands | 2012-03-07 → 2012-09-10 A (+187d) | 2012-04-30 → 2013-05-13 A (+378d) | 39d → 74d | 0% → 100% | 416d → none | 13455090 FS-126d → 13455090 FS-39d | was named Receive and Inspect Hall DStands |
| 13454055 | 100 kW dump Modifications (ARC10/H-D Stands) Revised | 2011-11-02 → 2013-05-03 A (+548d) | 2012-02-29 → 2013-08-30 A (+548d) |  | 0% → 100% | 407d → none | 9-120M FS+22d → 9-130M FS+80d, 9-120M FS+85d, 13454050 | resources MECH TECH [120 h]; MECH DES [120 h]; MECH ENG [180 h]; PROCUREMENT<$50K 60 → MECH DES [120 h]; MECH TECH [120 h]; MECH ENG [180 h]; PROCUREMENT<$50K 60 |
| 13455110M | Delivery Complete for Hall D Stands | 2012-08-31 → 2013-05-13 A (+255d) | 2012-08-31 → 2013-05-13 A (+255d) |  | 0% → 100% | 324d → none | 13455105 FS-5d, 13455090 → 13455105, 13455090 |  |
| 13454060 | Re-Baseline Actuals Adjustment | 2013-08-30 A | 2013-08-30 A |  | 0% → 100% | 20d → none | 9-130M FS+227d → none |  |
| 23454055 | 100 kW dump Modifications (ARC10/H-D Stands) Procurement | 2013-09-03 A | 2013-10-23 → 2013-11-25 (+33d) |  | 0% → 50% | 13d → 65d |  | resources MECH TECH; MECH DES; MECH ENG; SUPPLIES & MATERIALS; PROCUREMENT<$50K 60 NO ESCALATION FY14 → MECH TECH; MECH DES; MECH ENG; SUPPLIES & MATERIALS; PROCUREMENT<$50K 60 |
| 23454055a | 100 kW dump Modifications (ARC10/H-D Stands) Labor/Expenses FY13 | 2013-09-03 A | 2013-09-30 → 2013-11-25 (+56d) |  | 0% → 50% | 13d → 68d |  |  |
| 23454055b | 100 kW dump Modifications (ARC10/H-D Stands) Labor/Expenses FY14 | 2013-10-01 → 2013-09-03 A (-28d) | 2013-10-23 → 2013-11-25 (+33d) |  | 0% → 50% | 13d → 65d | 23454055a, 9-130M FS+228d → 23454055a FS-20d |  |
| 6 | **1.3.4.5.6 VACUUM** | 2010-04-14 → 2010-01-15 (-89d) |  |  |  |  |  |  |
| 13456015 | Prcrmnt Prep for Dipole Chambers (ARC 10/H-D Vac) | 2010-10-01 → 2010-01-15 A (-259d) | 2010-12-13 → 2010-07-26 A (-140d) | 50d → 133d | 0% → 100% | 232d → none | 121456999, 9-110M, 121456015 → 9-110M FS-250d, 121456015, 121456999 | resources MECH ENG [120 h]; MECH DES [20 h] → MECH DES [20 h]; MECH ENG [120 h] |
| 13456032 | Prcrmnt Prep of Ion Pumps & Vac Valves (ARC 10/H-D Vac) | 2010-04-14 → 2010-06-21 A (+68d) | 2010-06-15 → 2011-09-24 A (+466d) | 44d → 315d | 0% → 100% | 254d → none |  |  |
| 13456037 | Prcrmnt Prep of Bellows & Drift tubes (ARC 10/H-D Vac) | 2010-05-11 → 2010-06-21 A (+41d) | 2010-08-02 → 2010-09-27 A (+56d) | 58d → 69d | 0% → 100% | 9d → none |  |  |
| 13456025 | Vend Fab Dipole Chambers (ARC 10/H-D Vac) Phase 1 | 2010-07-30 → 2010-06-28 A (-32d) | 2010-11-19 → 2010-09-29 A (-51d) | 80d → 66d | 0% → 100% | 232d → none | 13456020M → 13456020M FS-20d |  |
| 13456020M | Award Contract for Dipole Chambers (ARC 10/H-D VACUUM) | 2010-07-30 → 2010-07-27 A (-3d) | 2010-07-30 → 2010-07-27 A (-3d) |  | 0% → 100% | 232d → none | 13456015 FS-94d → 13456015 |  |
| 13456022LOE | Vend Fab Dipole Chambers (ARC 10/H-D Vac) Oversight FY10 | 2010-07-30 A | 2010-09-30 → 2011-03-11 A (+162d) | 44d → 149.21d | 0% → 100% | 292d → none | 13456020M → 13456020M FS-20d |  |
| 13456022LOEa | Vend Fab Dipole Chambers (ARC 10/H-D Vac) Oversight FY11 | 2010-10-01 → 2010-07-30 A (-63d) | 2011-03-11 A | 106d → 150d | 0% → 100% | 292d → none | 13456022LOE → 13456020M FS-20d, 13456022LOE |  |
| 13456027 | Vend Fab Dipole Chambers (ARC 10/H-D Vac) Phase 2 | 2010-07-30 → 2010-09-27 A (+59d) | 2011-01-14 → 2010-12-15 A (-30d) | 112d → 56d | 0% → 100% | 292d → none |  |  |
| 13456040 | Prcrmnt of Bellows & Drift tubes (ARC 10/H-D Vac) | 2010-09-29 → 2010-09-27 A (-2d) | 2011-02-16 → 2011-02-28 A (+12d) | 92d → 101d | 0% → 100% | 9d → none | 13456037 FS+40d → 13456037 |  |
| 13456029 | Receive and Inspect Dipole Chambers (ARC 10/H-D Vac) | 2010-11-22 → 2010-12-03 A (+11d) | 2011-03-11 → 2013-01-24 A (+685d) | 70d → 511d | 0% → 100% | 292d → none | 13456025, 13456028 FS-70d → 13456028 FS-120d, 13456025 | resources MECH ENG [20 h]; MECH TECH [80 h] → MECH TECH [80 h]; MECH ENG [20 h] |
| 13456045 | Assemble Quad Girders for Arc10 & Hall D on Floor (ARC 10/H-D Vac) | 2010-11-30 → 2010-12-14 A (+14d) | 2011-04-29 → 2012-01-22 A (+268d) | 101d → 269d | 0% → 100% | 9d → none | 13455030 FS-10d, 13455023a, 13455035, 13456040 FS-50d, 13455015, 13455020 → 13455023, 13455015, 13455035 FS-5d, 13455020, 13456040 FS-55d, 13455030 FS-40d, 13455023a | resources MECH ENG [40 h]; MECH TECH [760 h]; MECH DES [60 h]; PROCUREMENT<$50K 60 → MECH TECH [760 h]; PROCUREMENT<$50K 60; MECH ENG [40 h]; MECH DES [60 h] |
| 13456028 | Vend Fab Dipole Chambers (ARC 10/H-D Vac) Phase 3 | 2010-07-30 → 2010-12-16 A (+139d) | 2011-03-11 → 2013-01-24 A (+685d) | 150d → 502d | 0% → 100% | 292d → none |  |  |
| 13456035 | Prcrmnt of Ion Pumps & Vac Valves (ARC 10/H-D Vac) | 2010-09-10 → 2011-10-10 A (+395d) | 2011-02-07 → 2012-01-16 A (+343d) | 98d → 62d | 0% → 100% | 254d → none | 13456032 FS+60d → 13456032 |  |
| 13456042 | Prcrmnt of Hall D Drift tubes (ARC 10/H-D Vac) | 2012-02-16 → 2011-10-17 A (-122d) | 2012-04-30 → 2012-02-13 A (-77d) | 52d → 77d | 0% → 100% | 9d → none | 9-120M FS+89d → 9-120M |  |
| 13456047 | Assemble Quad Girders for Arc10 & Hall D (ARC 10/H-D Vac) | 2011-10-06 → 2011-12-12 A (+67d) | 2012-03-08 → 2013-02-11 A (+340d) | 101d → 249d | 0% → 100% | 86d → none | 9-120M FS+3d, 13455010, 13456035, 13456040 FS-50d, 13452045b FS-150d, 13452050, 13455020, 13453030, 13455015, 13452045a FS-150d, 13455060, 13455045, 13455030, 13452050a, 13455023a → 13453030 FS-3d, 13455030, 13455010, 13452050a, 13455023, 13452045 FS-150d, 13452050, 13455060, 13456040 FS-50d, 13452045a FS-150d, 13452045b FS-150d, 13455015, 13455045, 13455023a, 13455020 | resources MECH ENG [40 h]; MECH TECH [290 h]; MECH DES [60 h]; PROCUREMENT<$50K 60 → MECH TECH [290 h]; MECH DES [60 h]; PROCUREMENT<$50K 60; MECH ENG [40 h] |
| 13456030M | Delivery Complete for Dipole Chambers (ARC 10/H-D VACUUM) | 2010-11-19 → 2013-01-24 A (+797d) | 2010-11-19 → 2013-01-24 A (+797d) |  | 0% → 100% | 232d → none | 13456025 → 13456025, 13456028 |  |
| 13456050 | Re-Baseline Actuals Adjustment | 2013-08-30 A | 2013-08-30 A |  | 0% → 100% | 20d → none | 9-130M FS+227d → none |  |
| 8 | **1.3.4.5.8 INSTALLATION** | 2011-05-13 → 2010-01-04 (-494d) | 2013-10-23 → 2013-12-03 (+41d) |  |  |  |  |  |
| 13458010 | Install Stands in Arc 10 Phase 1 | 2011-06-27 → 2010-01-04 A (-539d) | 2011-09-27 → 2010-09-27 A (-365d) | 65d → 186d | 0% → 100% | 470d → none | 13454030M, 13454035, 13454022LOE, 4A-01M FS+30d, 9-110M → 9-110M FS-500d, 13454035 FS-200d, 13454022LOE FS-20d, 4A-01M FS-500d, 13454030M | resources MECH DES [20 h]; MECH ENG [16 h]; MECH TECH [80 h]; PROCUREMENT<$50K 60 → MECH TECH [80 h]; PROCUREMENT<$50K 60; MECH ENG [16 h]; MECH DES [20 h] |
| 13458030 | Remove North Stub dump & Steel (ARC 10/H-D Installtn) | 2011-05-13 → 2010-07-01 A (-316d) | 2011-07-01 → 2010-07-12 A (-354d) | 35d → 7d | 0% → 100% | 549d → none |  |  |
| 13458012 | Install Stands in Arc 10 Phase 2 | 2011-05-17 → 2010-09-02 A (-257d) | 2011-08-16 → 2011-06-20 A (-57d) | 64d → 196d | 0% → 100% | 499d → none | 13454030M, 13454035, 4A-01M FS+2d, 13455125 → 4A-01M FS-150d, 13455125 FS-150d, 13454035 FS-130d, 13454030M | resources MECH DES [60 h]; MECH TECH [232 h]; MECH ENG [44 h] → MECH DES [60 h]; MECH ENG [44 h]; MECH TECH [232 h] |
| 13458040 | Arc 10 Installation Completion | 2012-10-01 → 2012-07-09 A (-84d) | 2013-02-14 → 2013-08-14 A (+181d) | 90d → 149d | 0% → 100% | 130d → none | 9-130M → 9-130M FS-50d | resources MECH ENG [156 h]; MECH TECH [688 h] → MECH TECH [688 h]; MECH ENG [156 h] |
| 13458050 | Hall D - Green door install | 2012-10-01 → 2012-07-09 A (-84d) | 2012-11-02 → 2012-12-17 A (+45d) | 25d → 110d | 0% → 100% | 353d → none | 9-130M → 9-130M FS-50d |  |
| 13458055 | Hall D - Install Stands | 2013-01-30 → 2012-10-01 A (-121d) | 2013-03-01 → 2013-08-30 A (+182d) | 22d → 100d | 0% → 100% | 227d → none | 13454032, 13455110M, 3A-12M, 9-130M FS+78d, 13455085LOE → 13455085LOE, 13454032, 13455110M FS-60d, 3A-12M, 9-130M |  |
| 13458060 | Hall D - Install magnets and girders | 2013-03-04 → 2013-05-06 A (+63d) | 2013-05-06 → 2013-08-30 A (+116d) |  | 0% → 100% | 227d → none | 13458055 → 13458055 FS-20d, 13456047 |  |
| 13458045 | Hall D - Tagger dump installation | 2013-04-04 → 2013-08-30 A (+148d) | 2013-05-17 → 2013-08-30 A (+105d) |  | 0% → 100% | 82d → none |  |  |
| 13458065 | Hall D - Final align | 2013-05-07 → 2013-08-30 A (+115d) | 2013-05-13 → 2013-08-30 A (+109d) |  | 0% → 100% | 227d → none |  |  |
| 13458070 | Re-Baseline Actuals Adjustment | 2013-08-30 A | 2013-08-30 A |  | 0% → 100% | 20d → none | 9-130M FS+227d → none |  |
| 23458040 | Arc 10 Installation Completion FY13 | 2013-09-03 A | 2013-09-30 → 2013-11-14 (+45d) | 20d → 30d | 0% → 60% | 31d → 58d |  |  |
| 23458040a | Arc 10 Installation Completion FY14 | 2013-10-01 → 2013-09-03 A (-28d) | 2013-10-14 → 2013-11-14 (+31d) |  | 0% → 60% | 31d → 58d | 9-130M FS+228d, 23458040 → 23458040 FS-20d |  |

| ID | Task | Start | Finish | Duration | Complete | Total float | Predecessors | Other |
| --- | --- | --- | --- | --- | --- | --- | --- | --- |
| 23458060 | Hall D - Install magnets and girders FY13 | 2013-09-03 A | 2013-09-30 → 2013-11-27 (+58d) | 20d → 23d | 0% → 60% | 35d → 61d |  |  |
| 23458060a | Hall D - Install magnets and girders FY14 | 2013-10-01 → 2013-09-03 A (-28d) | 2013-10-03 → 2013-11-27 (+55d) |  | 0% → 60% | 35d → 61d | 23458060, 9-130M FS+228d → 23458060 FS-30d |  |
| 23458065 | Hall D - Final align FY13 | 2013-09-25 → 2013-10-07 A (+12d) | 2013-09-30 → 2013-11-06 (+37d) |  | 0% → 50% | 35d → 40d | 23458060a FS-7d, 23458060 FS-7d → 23458060 FS-40d, 23458060a FS-40d |  |
| 23458065a | Hall D - Final align FY14 | 2013-10-01 → 2013-10-07 A (+6d) | 2013-10-01 → 2013-11-06 (+36d) |  | 0% → 50% | 35d → 40d | 23458060a FS-7d, 23458065, 23458060 FS-7d → 23458065 FS-20d, 23458060a FS-40d |  |
| 23458045 | Hall D - Tagger dump installation FY13 | 2013-09-25 → 2013-11-01 (+37d) | 2013-09-30 → 2013-11-06 (+37d) |  |  | 90d → 63d |  |  |
| 23458045a | Hall D - Tagger dump installation FY14 | 2013-10-01 → 2013-11-07 (+37d) | 2013-10-23 → 2013-12-03 (+41d) |  |  | 90d → 63d | 9-130M FS+244d, 23458045 → 23458045 |  |
| 6 | **1.3.4.6 EXTRACTION** |  | 2013-10-09 → 2013-10-21 (+12d) |  |  |  |  |  |
| 13461000 | Proc Coil Packs for Lambertson LABOR (LAMBERTSON) | 2012-01-05 → 2011-04-01 A (-279d) | 2012-04-05 → 2011-08-22 A (-227d) | 64d → 100d | 0% → 100% | 383d → none | 12154020M, 9-120M FS+60d → 12154020M |  |
| 13461050LOE | FY11 Engrng Oversight (LAMBERTSON) | 2011-04-01 A | 2011-09-30 A |  | 0% → 100% | 20d → none |  |  |
| 13461005 | Proc Coil Packs for Lambertson MATL (LAMBERTSON) | 2012-01-05 → 2011-06-01 A (-218d) | 2012-04-05 → 2011-06-30 A (-280d) | 64d → 22d | 0% → 100% | 383d → none |  |  |
| 13461015 | Machine Lambertson Mag Iron MATL (LAMBERTSON) | 2011-10-03 → 2013-02-04 A (+490d) | 2011-12-21 → 2013-02-18 A (+425d) | 56d → 11d | 0% → 100% | 451d → none | 13461010 FS-70d → 9-130M FS+165d, 13461010 FS-30d |  |
| 13461010 | Machine Lambertson Mag Iron LABOR (LAMBERTSON) | 2012-01-05 → 2013-05-04 A (+485d) | 2012-01-19 → 2013-06-17 A (+515d) |  | 0% → 100% | 451d → none | 9-120M FS+60d → 9-130M FS+165d, 9-120M FS+220d |  |
| 13461035 | Install New Lambertson MATL (LAMBERTSON) | 2012-11-26 → 2013-05-18 A (+173d) | 2012-11-30 → 2013-05-24 A (+175d) |  | 0% → 100% | 232d → none | 13461025, 13461020 → 13461020 FS-20d |  |
| 13461025 | Install Lambertson Coil pack (LAMBERTSON) | 2012-11-08 → 2013-06-10 A (+214d) | 2012-11-14 → 2013-07-15 A (+243d) |  | 0% → 100% | 232d → none | 13461005, 2-02M FS+125d, 13461015 → 2-02M FS+125d, 9-130M FS+165d, 13461005, 13461015 |  |
| 13461040 | Test New Lambertson (LAMBERTSON) | 2012-12-03 → 2013-06-10 A (+189d) | 2012-12-07 → 2013-08-30 A (+266d) |  | 0% → 100% | 232d → none | 13461035 → 13461035 FS-20d |  |
| 13461020 | Lambertson Mag measurements (LAMBERTSON) | 2012-11-15 → 2013-08-30 A (+288d) | 2012-11-21 → 2013-08-30 A (+282d) |  | 0% → 100% | 232d → none | 9-130M FS+30d, 13461025 → 13461025, 9-130M FS+165d |  |
| 13461055 | Re-Baseline Actuals Adjustment | 2013-08-30 A | 2013-08-30 A |  | 0% → 100% | 20d → none | 9-130M FS+227d → none |  |
| 13461045M | Ready for Beam Commssng (LAMBERTSON) | 2012-12-07 → 2013-08-30 A (+266d) | 2012-12-07 → 2013-08-30 A (+266d) |  | 0% → 100% | 232d → none |  |  |
| 13462000 | Fab Dipole Magnets (CHICANE) Original Labor FY11 | 2011-04-01 A | 2011-09-30 → 2012-02-08 A (+131d) | 128d → 211d | 0% → 100% | 233d → none |  |  |
| 13462000a | Fab Dipole Magnets (CHICANE) Original Labor FY12 | 2011-10-03 → 2011-04-01 A (-185d) | 2012-02-08 A | 84d → 212d | 0% → 100% | 233d → none | 13462000 → 13462000 FS-90d |  |
| 13462015LOE | FY11 Mech Eng/Dsgner Oversight (CHICANE) | 2011-04-01 A | 2011-09-30 A |  | 0% → 100% | 20d → none |  |  |
| 13462005 | Measure Dipole Magnets (CHICANE) | 2012-02-09 → 2012-03-06 A (+26d) | 2012-05-10 → 2013-03-11 A (+305d) | 65d → 200d | 0% → 100% | 233d → none | 13411105u, 13411105t, 13462000a → 13411105t, 13411105u, 13462000a FS+40d | was named Measure Dipole Magnets (CHICANE) (IPL 534213060 and 534213120); resources MECH TECH [80 h]; MECH ENG [40 h] → MECH ENG [40 h]; MECH TECH [80 h] |
| 13462010M | Extraction Dipoles Ready for Installtn (CHICANE) | 2012-05-10 → 2013-03-11 A (+305d) | 2012-05-10 → 2013-03-11 A (+305d) |  | 0% → 100% | 233d → none |  |  |
| 13462020 | Re-Baseline Actuals Adjustment | 2013-08-30 A | 2013-08-30 A |  | 0% → 100% | 20d → none | 9-130M FS+227d → none |  |
| 3 | **1.3.4.6.3 STANDS** | 2012-01-03 → 2011-12-05 (-29d) | 2013-10-09 → 2013-10-21 (+12d) |  |  |  |  |  |
| 13463005 | Fab Stands LABOR (Stands) | 2012-01-03 → 2011-12-05 A (-29d) | 2012-05-03 → 2011-12-19 A (-136d) | 86d → 11d | 0% → 100% | 173d → none | 13463000 FS-86d → 13463000 FS-125d |  |
| 13463010 | Fab Stands MATL (Stands) Frozen Per CR12-039 | 2012-01-03 A | 2012-04-30 → 2012-05-01 A (+1d) | 83d → 84d | 0% → 100% | 176d → none |  |  |
| 13463045LOE | FY12 Mech Eng/Dsgner Oversight (Stands) | 2012-01-05 → 2012-01-03 A (-2d) | 2012-09-28 A | 187d → 189d | 0% → 100% | 20d → none |  |  |
| 13463012 | Reverse Entry Per CR12-039 | 2012-05-01 A | 2012-05-03 A |  | 0% → 100% | 103d → none |  |  |
| 13463013 | Fab Stands MATL (Stands) Revised Per CR12-039 | 2012-05-01 A | 2012-05-03 → 2013-07-15 A (+438d) | 3d → 169d | 0% → 100% | 173d → none |  |  |
| 13463000 | Insp Matls (Stands) | 2012-04-13 → 2012-05-11 A (+28d) | 2012-05-03 → 2012-05-30 A (+27d) | 15d → 13d | 0% → 100% | 173d → none | 1356020, 9-120M FS+129d, 1356018 → 1356018 FS-100d, 9-120M, 1356020 FS-150d | resources MECH ENG [5.4 h]; MECH TECH [18 h] → MECH TECH [18 h]; MECH ENG [5.4 h] |
| 13463015 | Extraction - Remove | 2012-08-15 → 2012-05-18 A (-89d) | 2012-09-28 → 2012-10-15 A (+17d) | 32d → 104d | 0% → 100% | 102d → none | 2-02M FS+65d, 13463010, 13463013 → 2-02M, 13463013 FS-20d, 13463010 |  |
| 13463035 | Extraction - Upstairs FY12 | 2012-08-31 → 2012-10-01 A (+31d) | 2012-09-28 → 2013-08-27 A (+333d) | 20d → 59d | 0% → 100% | 140d → none |  |  |
| 13463035a | Extraction - Upstairs FY13 | 2012-10-01 A | 2012-10-23 → 2013-08-27 A (+308d) | 17d → 59d | 0% → 100% | 140d → none | 13463035 → 13463035 FS-60d |  |
| 13463025 | Extraction - Install stands | 2012-11-15 → 2012-11-12 A (-3d) | 2012-12-18 → 2013-02-11 A (+55d) | 22d → 35d | 0% → 100% | 102d → none | 13463020 FS-22d, 1355025M, 13463015, 13462010M → 13462010M FS-20d, 1355025M, 13463015, 13463020 FS-30d |  |
| 13463020 | Install Stands MATL (Stands) | 2012-11-15 → 2012-12-03 A (+18d) | 2012-12-18 → 2013-08-30 A (+255d) |  | 0% → 100% | 102d → none |  |  |
| 13463030 | Install Septa & Dipoles MATL (Stands) | 2012-12-19 → 2013-04-01 A (+103d) | 2013-02-27 → 2013-06-17 A (+110d) |  | 0% → 100% | 102d → none |  |  |
| 13463045 | Extraction - Install magnets and girders | 2012-12-19 → 2013-07-15 A (+208d) | 2013-02-27 → 2013-08-30 A (+184d) |  | 0% → 100% | 102d → none | 13463020, 13463035a, 13463025 → 13463025, 13463020 FS-20d, 13463035a FS-20d |  |
| 13463050 | Extraction - Final align | 2013-06-19 → 2013-08-30 A (+72d) | 2013-06-26 → 2013-08-30 A (+65d) |  | 0% → 100% | 24d → none |  |  |
| 13463055 | Re-Baseline Actuals Adjustment | 2013-08-30 A | 2013-08-30 A |  | 0% → 100% | 20d → none | 9-130M FS+227d → none |  |
| 23463035a | Extraction - Upstairs | 2013-09-03 A | 2013-09-10 → 2013-09-23 A (+13d) |  | 0% → 100% | 44d → none |  |  |
| 23463045 | Extraction - Install magnets and girders | 2013-09-03 A | 2013-09-23 → 2013-10-21 A (+28d) |  | 0% → 100% | 2d → none |  |  |
| 23463050 | Extraction - Final align FY13 | 2013-09-24 → 2013-09-16 A (-8d) | 2013-09-30 → 2013-10-21 A (+21d) | 5d → 12d | 0% → 100% | 2d → none | 23463045, 23417120 FS-23d → 23463045 FS-15d, 23417120 FS-23d |  |
| 23463050a | Extraction - Final align FY14 | 2013-10-01 → 2013-09-16 A (-15d) | 2013-10-09 → 2013-10-21 A (+12d) |  | 0% → 100% | 2d → none | 23463050, 23417120 FS-23d, 23463045 → 23463050 FS-20d |  |
| 1351909LOE | FY09 Mngmnt Oversight (Cavities) | 2009-01-02 A | 2009-09-30 A |  | 0% → 100% | 20d → none |  | resources SCIENTIST [423.73 h]; TRAVEL → TRAVEL; SCIENTIST [423.73 h] |
| 1351910LOE | FY10 Mngmnt Oversight (Cavities) | 2009-10-01 A | 2010-09-30 A |  | 0% → 100% | 20d → none |  |  |
| 1351018 | Fab fixturing Assys for Fab (Cavities) | 2010-10-01 A | 2010-10-21 → 2010-10-19 A (-2d) | 15d → 13d | 0% → 100% | 588d → none |  |  |
| 1351911LOE | FY11 Mngmnt Oversight (Cavities) | 2010-10-01 A | 2011-09-30 A |  | 0% → 100% | 20d → none |  |  |
| 1351016 | Proc Separator Cavity Matls & subassemblies LABOR (Cavities) | 2011-12-01 → 2011-11-01 A (-30d) | 2012-03-02 → 2013-05-13 A (+437d) | 59d → 286d | 0% → 100% | 230d → none |  | resources MECH TECH [20 h]; MECH ENG [48 h] → MECH ENG [48 h]; MECH TECH [20 h] |
| 1351016a | Proc Separator Cavity Matls & subassemblies MATERIALS (Cavities) | 2011-12-01 → 2012-02-01 A (+62d) | 2012-03-02 → 2013-07-15 A (+500d) | 59d → 229d | 0% → 100% | 230d → none | 1351016 FS-59d → 1351016 FS-115d |  |
| 1351040 | Assy of Separator Cavities (Cavities) | 2012-04-09 → 2013-01-14 A (+280d) | 2012-06-19 → 2013-07-16 A (+392d) |  | 0% → 100% | 230d → none | 1351018, 1351016a FS+25d → 1351018, 1351016a FS-40d |  |
| 1351055 | Test Separator Cavities | 2012-06-20 → 2013-06-10 A (+355d) | 2012-08-21 → 2013-08-23 A (+367d) |  | 0% → 100% | 230d → none | 1351040 → 1351040 FS-20d | resources ELEC TECH [40 h]; MECH TECH [32 h]; ELEC ENG [40 h] → ELEC ENG [40 h]; ELEC TECH [40 h]; MECH TECH [32 h] |
| 1351080 | RF Characterization of Installed Separator Cavities (Cavities) | 2012-10-11 → 2013-06-10 A (+242d) | 2012-10-24 → 2013-08-23 A (+303d) |  | 0% → 100% | 230d → none | 1351065a → 1351065a FS-60d, 1351065 FS-60d | resources ELEC TECH [60 h]; ELEC ENG [60 h]; MECH ENG [12 h] → MECH ENG [12 h]; ELEC TECH [60 h]; ELEC ENG [60 h] |
| 1351065 | Installtn of Separator Cavities (Cavities) FY12 | 2012-09-06 → 2013-07-15 A (+312d) | 2012-09-28 → 2013-08-23 A (+329d) |  | 0% → 100% | 230d → none | 2-02M, 1351055 FS+10d → 1351055 FS-20d, 2-02M | resources ELEC TECH [68 h]; ELEC ENG [13.6 h]; MECH DES [27.2 h]; MECH TECH [68 h] → MECH DES [27.2 h]; ELEC ENG [13.6 h]; MECH TECH [68 h]; ELEC TECH [68 h] |
| 1351065a | Installtn of Separator Cavities (Cavities) FY13 | 2012-10-01 → 2013-07-15 A (+287d) | 2012-10-10 → 2013-08-23 A (+317d) |  | 0% → 100% | 230d → none | 1351065 → 1351065 FS-400d |  |
| 1351950 | Re-Baseline Actuals Adjustment | 2013-08-30 A | 2013-08-30 A |  | 0% → 100% | 20d → none | 9-130M FS+227d → none |  |
| 2 | **1.3.5.2 RF COMPONENTS** | 2012-01-05 → 2012-03-02 (+57d) |  |  |  |  |  |  |
| 1352005 | Proc RF Components LABOR (RF Compnts) | 2012-01-05 → 2012-03-02 A (+57d) | 2012-05-01 → 2012-12-17 A (+230d) | 82d → 209d | 0% → 100% | 278d → none |  |  |
| 1352005a | Proc RF Components MATERIAL (RF Compnts) | 2012-01-05 → 2012-04-09 A (+95d) | 2012-05-01 → 2013-03-11 A (+314d) | 82d → 188d | 0% → 100% | 278d → none | 1352005 FS-82d → 1352005 FS-20d |  |
| 1352020 | Install RF Components (RF Compnts) | 2012-05-14 → 2013-01-07 A (+238d) | 2012-07-18 → 2013-08-19 A (+397d) |  | 0% → 100% | 270d → none | 1352005a, 2-02M → 2-02M, 1352005a FS-20d | resources ELEC TECH [400 h]; MECH TECH [116 h] → MECH TECH [116 h]; ELEC TECH [400 h] |
| 1352035 | Characterize Sys losses (RF Compnts) | 2012-07-19 → 2013-05-06 A (+291d) | 2012-09-12 → 2013-06-17 A (+278d) |  | 0% → 100% | 270d → none | 1352020 → 1352020 FS-20d |  |
| 1352040 | Re-Baseline Actuals Adjustment | 2013-08-30 A | 2013-08-30 A |  | 0% → 100% | 20d → none | 9-130M FS+227d → none |  |
| 3 | **1.3.5.3 RESONANCE CONTROL** | 2012-01-05 → 2012-03-02 (+57d) |  |  |  |  |  |  |
| 1353005 | Procure Resonance Control LABOR (RESONANCE Control) | 2012-01-05 → 2012-03-02 A (+57d) | 2012-04-02 → 2012-12-17 A (+259d) | 61d → 209d | 0% → 100% | 345d → none |  | resources ELEC ENG [48 h]; MECH ENG [32 h]; MECH DES [8 h]; MECH TECH [40 h]; ELEC TECH [20 h] → ELEC ENG [48 h]; MECH ENG [32 h]; ELEC TECH [20 h]; MECH DES [8 h]; MECH TECH [40 h] |
| 1353005a | Procure Resonance Control MATERIAL (RESONANCE Control) | 2012-01-05 → 2012-04-16 A (+102d) | 2012-04-02 → 2012-12-17 A (+259d) | 61d → 178d | 0% → 100% | 345d → none |  |  |
| 1353070 | Install Control Valves (RESONANCE Control) | 2012-04-03 → 2012-11-05 A (+216d) | 2012-05-01 → 2012-11-19 A (+202d) | 21d → 11d | 0% → 100% | 353d → none |  |  |
| 1353020 | Assemble Heater Units (RESONANCE Control) | 2012-04-03 → 2012-11-12 A (+223d) | 2012-05-11 → 2012-12-17 A (+220d) | 29d → 60d | 0% → 100% | 345d → none | 1353005a → 1353005a FS-60d | resources MECH DES [12 h]; MECH TECH [140 h]; ELEC TECH [20 h] → ELEC TECH [20 h]; MECH TECH [140 h]; MECH DES [12 h] |
| 1353085 | Move 5th pass Controls/Rack (RESONANCE Control) | 2012-01-19 → 2012-11-12 A (+298d) | 2012-03-01 → 2013-01-21 A (+326d) | 30d → 24d | 0% → 100% | 396d → none | 4A-01M, 9-120M FS+69d → 4A-01M, 9-120M FS+184d |  |
| 1353040 | Modify Control Chassis (RESONANCE Control) | 2012-04-03 → 2013-01-14 A (+286d) | 2012-05-11 → 2013-08-17 A (+463d) |  | 0% → 100% | 345d → none |  |  |
| 1353095 | Sys Testing (RESONANCE Control) | 2012-10-25 → 2013-08-05 A (+284d) | 2012-11-07 → 2013-08-19 A (+285d) |  | 0% → 100% | 230d → none |  | resources MECH DES [20 h]; MECH TECH [60 h]; MECH ENG [60 h]; ELEC TECH [140 h]; ELEC ENG [112 h] → ELEC ENG [112 h]; MECH TECH [60 h]; ELEC TECH [140 h]; MECH ENG [60 h]; MECH DES [20 h] |

| ID | Task | Start | Finish | Duration | Complete | Total float | Predecessors | Other |
| --- | --- | --- | --- | --- | --- | --- | --- | --- |
| 1353100 | Re-Baseline Actuals Adjustment | 2013-08-30 A | 2013-08-30 A |  | 0% → 100% | 20d → none | 9-130M FS+227d → none |  |
| 1354909LOE | FY09 Engrng Oversight (LAMBERTSON) | 2009-01-02 A | 2009-09-30 A |  | 0% → 100% | 148d → none |  |  |
| 1354910LOE | FY10 Engrng Oversight (LAMBERTSON) | 2009-10-01 A | 2010-09-30 A |  | 0% → 100% | 148d → none |  | resources MECH ENG [80 h]; TRAVEL → TRAVEL; MECH ENG [80 h] |
| 1354911LOE | FY11 Engrng Oversight (LAMBERTSON) | 2010-10-01 A | 2011-03-31 A |  | 0% → 100% | 148d → none |  |  |
| 1354950 | Re-Baseline Actuals Adjustment | 2013-08-30 A | 2013-08-30 A |  | 0% → 100% | 20d → none | 9-130M FS+227d → none |  |
| 5 | **1.3.5.5 CHICANE** | 2009-10-01 → 2009-08-17 (-45d) |  |  |  |  |  |  |
| 1355016 | Proc Septa Mag Iron & Coil Packs (CHICANE) | 2010-01-05 → 2009-08-17 A (-141d) | 2010-04-07 → 2009-08-18 A (-232d) | 65d → 2d | 0% → 100% | 743d → none |  |  |
| 1355910LOE | FY10 Mech Eng/Dsgner Oversight (CHICANE) | 2009-10-01 A | 2010-09-30 A |  | 0% → 100% | 148d → none |  |  |
| 1355040 | Fab Dipole Magnets (CHICANE) Original Labor FY10 | 2010-04-22 → 2010-04-21 A (-1d) | 2010-09-30 → 2011-03-31 A (+182d) | 113d → 233d | 0% → 100% | 233d → none | 1355035 → 1355035 FS-80d |  |
| 1355040a | Fab Dipole Magnets (CHICANE) Original Labor FY11 | 2010-10-01 → 2010-04-21 A (-163d) | 2011-03-31 A | 120d → 233d | 0% → 100% | 233d → none |  |  |
| 1355018 | Insp Septa Matls (CHICANE) | 2010-04-08 → 2010-04-26 A (+18d) | 2010-04-21 → 2010-04-26 A (+5d) | 10d → 1d | 0% → 100% | 743d → none |  |  |
| 1355022 | Measure Septa Magnets (CHICANE) | 2011-12-01 → 2010-04-26 A (-584d) | 2012-03-12 → 2010-04-30 A (-682d) | 65d → 5d | 0% → 100% | 276d → none |  |  |
| 1355030 | Proc Dipole Mag Iron & Coil Packs (CHICANE) | 2010-01-05 → 2010-04-26 A (+111d) | 2010-04-07 → 2010-04-30 A (+23d) | 65d → 5d | 0% → 100% | 233d → none |  | resources MECH ENG [52 h]; MECH DES [52 h] → MECH DES [52 h]; MECH ENG [52 h] |
| 1355035 | Insp Dipole Matls (CHICANE) | 2010-04-08 → 2010-04-26 A (+18d) | 2010-04-21 → 2010-04-30 A (+9d) | 10d → 5d | 0% → 100% | 233d → none |  |  |
| 1355025M | Extraction Septas Ready for Installtn (CHICANE) | 2012-03-12 → 2010-04-30 A (-682d) | 2012-03-12 → 2010-04-30 A (-682d) |  | 0% → 100% | 276d → none |  |  |
| 1355911LOE | FY11 Mech Eng/Dsgner Oversight (CHICANE) | 2010-10-01 A | 2011-03-31 A |  | 0% → 100% | 148d → none |  |  |
| 1355950 | Re-Baseline Actuals Adjustment | 2013-08-30 A | 2013-08-30 A |  | 0% → 100% | 20d → none | 9-130M FS+227d → none |  |
| 1356910LOE | FY10 Mech Eng/Dsgner Oversight (Stands) | 2009-10-01 A | 2010-09-30 A |  | 0% → 100% | 148d → none |  |  |
| 1356911LOE | FY11 Mech Eng/Dsgner Oversight (Stands) | 2010-10-01 A | 2011-03-31 A |  | 0% → 100% | 148d → none |  |  |
| 1356018 | Proc Stands Matls (Stands) | 2010-12-07 → 2012-03-02 A (+451d) | 2011-03-16 → 2013-03-11 A (+726d) | 64d → 202d | 0% → 100% | 430d → none | 12156040M, 9-110M FS+45d, 12156045, 12156002 → 9-120M FS+70d, 12156045, 12156040M, 9-110M FS+45d | resources MECH ENG [100 h]; MECH DES [8 h]; PROCUREMENT<$50K 60 → PROCUREMENT<$50K 60; MECH DES [8 h]; MECH ENG [100 h] |
| 1356020 | Insp Matls (Stands) | 2011-03-17 → 2013-03-13 A (+727d) | 2011-03-31 → 2013-03-28 A (+728d) |  | 0% → 100% | 430d → none |  | resources MECH ENG [6.6 h]; MECH TECH [22 h] → MECH TECH [22 h]; MECH ENG [6.6 h] |
| 1356950 | Re-Baseline Actuals Adjustment | 2013-08-30 A | 2013-08-30 A |  | 0% → 100% | 20d → none | 9-130M FS+227d → none |  |
| 6 | **1.3.6 INSTRUMENTATION/CONTROLS/SAFETY SYS** |  | 2014-10-31 → 2014-10-30 (-1d) |  |  |  |  |  |
| 1 | **1.3.6.1 BEAM DIAGNOSTICS** |  | 2014-10-31 → 2014-10-30 (-1d) |  |  |  |  |  |
| 1 | **1.3.6.1.1 BPM'S** |  | 2014-10-31 → 2014-10-30 (-1d) |  |  |  |  |  |
| 13611909LOE | FY09 Mngmnt Effort for BPMs | 2009-01-02 A | 2009-09-30 A |  | 0% → 100% | 20d → none |  |  |
| 13611910LOE | FY10 Mngmnt Effort for BPMs | 2009-10-01 A | 2010-09-30 A |  | 0% → 100% | 20d → none |  |  |
| 13611911LOE | FY11 Mngmnt Effort for BPMs | 2010-10-01 A | 2011-09-30 A |  | 0% → 100% | 20d → none |  |  |
| 13611014 | Labor - SEE BPMs CANS Accelerator | 2010-11-05 → 2010-12-01 A (+26d) | 2011-01-11 → 2012-10-15 A (+643d) | 40d → 465d | 0% → 100% | 557d → none |  |  |
| 13611014A | Prcrmnt - SEE BPMs CANS Accelerator | 2010-12-01 → 2011-03-01 A (+90d) | 2011-05-31 → 2011-11-30 A (+183d) | 121d → 192d | 0% → 100% | 551d → none | 9-110M FS+41d, 13611014 FS-30d → 13611014 FS-50d, 9-110M FS+25d |  |
| 13611014Aa | Testing - SEE BPM Compnts CANS Accelerator | 2011-03-01 → 2011-05-16 A (+76d) | 2011-06-01 → 2011-11-10 A (+162d) | 66d → 126d | 0% → 100% | 551d → none |  |  |
| 13611912LOE | FY12 Mngmnt Effort for BPMs | 2011-10-03 A | 2012-09-28 A |  | 0% → 100% | 20d → none |  |  |
| 13611014Ab | Labor - SEE BPMs CANS Hall D | 2011-05-02 → 2012-01-03 A (+246d) | 2011-05-13 → 2012-08-13 A (+458d) | 10d → 156d | 0% → 100% | 465d → none | 9-110M FS+141d → 9-120M, 9-110M FS+141d | resources ELEC TECH [16 h]; ELEC ENG [12 h] → ELEC ENG [12 h]; ELEC TECH [16 h] |
| 13611026 | Labor - West ARC Completion BPMs | 2012-01-05 → 2012-01-03 A (-2d) | 2012-07-24 → 2013-08-12 A (+384d) | 140d → 239d | 0% → 100% | 279d → none |  |  |
| 13611014Af | RF Receiver - First Article Unit SEE BPM | 2012-02-01 A | 2012-04-10 → 2012-11-12 A (+216d) | 49d → 200d | 0% → 100% | 172d → none |  |  |
| 13611014Ag | Digital IF - First Article Unit SEE BPM | 2012-02-01 A | 2012-04-10 → 2012-12-17 A (+251d) | 49d → 231d | 0% → 100% | 172d → none |  |  |
| 13611026a | Procurement - West ARC Completion BPMs | 2012-01-05 → 2012-02-01 A (+27d) | 2012-01-11 → 2012-04-23 A (+103d) | 5d → 58d | 0% → 100% | 404d → none | 13611026 FS-140d → 13611026 FS-200d |  |
| 13611065 | System Documentation - BPMs First Article | 2012-02-01 A | 2012-05-23 → 2012-12-17 A (+208d) | 80d → 219d | 0% → 100% | 322d → none | 13611014Af FS-49d → 13611014Af FS-80d |  |
| 13611014Ac | Prcrmnt - SEE BPMs CANS Hall D | 2011-05-02 → 2012-04-09 A (+343d) | 2011-09-30 → 2012-08-13 A (+318d) | 107d → 89d | 0% → 100% | 465d → none | 13611014Ab FS-10d → 13611014Ab FS-20d |  |
| 13611014Ah | RF Receiver Enclosure - First Article Unit SEE BPM | 2012-04-11 → 2012-06-05 A (+55d) | 2012-07-17 → 2012-10-15 A (+90d) | 68d → 94d | 0% → 100% | 172d → none | 13611014Af, 13611014Ag → 13611014Ag FS-65d, 13611014Af FS-65d | resources ELEC ENG [544 h]; ELEC TECH [544 h] → ELEC TECH [544 h]; ELEC ENG [544 h] |
| 13611026b | Hook-up & Check-out Arc 10 BPMs | 2012-07-11 → 2012-06-05 A (-36d) | 2012-07-31 → 2013-08-30 A (+395d) | 15d → 135d | 0% → 100% | 279d → none | 13611026 FS-10d, 13611026a → 13611026 FS-50d, 13611026a |  |
| 13611014Ad | Testing - SEE BPM Compnts CANS Hall D FY11 | 2011-06-16 → 2012-08-06 A (+417d) | 2011-09-30 → 2012-10-15 A (+381d) | 75d → 50d | 0% → 100% | 465d → none | 13611014Ac FS-75d → 13611014Ac | resources ELEC ENG [15.79 h]; ELEC TECH [67.11 h] → ELEC TECH [67.11 h]; ELEC ENG [15.79 h] |
| 13611014B | Procurement Labor - SEE BPMs ELECTRONICS | 2013-02-01 → 2012-10-01 A (-123d) | 2013-04-22 → 2013-08-30 A (+130d) | 56d → 136d | 0% → 100% | 20d → none | 9-130M FS+80d → 9-130M | resources ELEC ENG [240 h]; ELEC TECH [240 h] → ELEC TECH [240 h]; ELEC ENG [240 h] |
| 13611025b | System Installation Software Support First Article - Electronics SEE BPMs | 2012-06-06 → 2012-10-01 A (+117d) | 2012-07-31 → 2013-04-15 A (+258d) | 40d → 63d | 0% → 100% | 281d → none |  |  |
| 13611913LOE | FY13 Mngmnt Effort for BPMs | 2012-10-01 A | 2013-08-30 A | 228d → 248d | 0% → 100% | 20d → none |  |  |
| 13611014Ada | Testing - SEE BPM Compnts CANS Hall D FY12 | 2011-10-03 → 2012-10-15 A (+378d) | 2011-10-03 → 2012-10-22 A (+385d) | 1d → 6d | 0% → 100% | 465d → none |  |  |
| 13611065a | System Documentation - BPMs | 2013-02-01 → 2012-10-15 A (-109d) | 2013-08-27 → 2013-08-30 A (+3d) | 145d → 215d | 0% → 100% | 33d → none | 9-130M FS+80d → 9-130M |  |
| 13611070 | First Article Unit - Power Supply SEE BPMs | 2013-03-04 → 2012-11-12 A (-112d) | 2013-05-16 → 2013-02-11 A (-94d) | 54d → 124d | 0% → 100% | 20d → none | 13611014Ah, 9-130M FS+100d → 9-130M, 13611014Ah |  |
| 13611075 | Procurement Labor - Power Supply SEE BPMs | 2013-03-04 → 2012-11-12 A (-112d) | 2013-05-24 → 2013-08-30 A (+98d) | 60d → 130d | 0% → 100% | 20d → none | 13611070 FS-54d → 13611070 FS-125d |  |
| 13611080 | Procurement - Power Supply SEE BPMs | 2013-03-04 → 2012-11-12 A (-112d) | 2013-05-24 → 2013-08-30 A (+98d) | 60d → 130d | 0% → 100% | 20d → none | 13611075 FS-60d → 13611075 FS-125d |  |
| 13611014C | Prcrmnt - SEE BPMs ELECTRONICS | 2013-02-01 → 2012-12-03 A (-60d) | 2013-07-18 → 2013-08-30 A (+43d) |  | 0% → 100% | 27d → none | 9-130M FS+80d → 9-130M |  |
| 13611025 | System Installation - Electronics SEE BPMs | 2013-07-23 → 2013-01-21 A (-183d) | 2013-08-30 A | 29d → 49d | 0% → 100% | 20d → none | 13611015B FS-20d, 13611014Aa, 1362025 FS-115d, 13611014Ada → 13611015B FS-160d, 13611014Ada, 1362025 FS-115d, 13611014Aa | resources ELEC TECH [232 h] → ELEC TECH [392 h] |
| 13611036 | First Article Cavities - nA BPM Sys | 2013-02-01 A | 2013-04-24 → 2013-08-30 A (+128d) |  | 0% → 100% | 75d → none |  |  |
| 13611015A | Labor - Fab & Assy - SEE BPMs ELECTRONICS | 2013-04-23 → 2013-03-11 A (-43d) | 2013-08-19 → 2013-08-30 A (+11d) |  | 0% → 100% | 20d → none | 13611014B, 13611014C FS-68d → 13611014B FS-40d, 13611014C FS-75d | resources ELEC ENG [664 h]; ELEC TECH [664 h] → ELEC TECH [664 h]; ELEC ENG [664 h] |
| 13611025c | System Installation Software Support - Electronics SEE BPMs | 2013-08-20 → 2013-04-08 A (-134d) | 2013-08-30 A | 9d → 70d | 0% → 100% | 20d → none | 13611014Ag, 13611025b, 13611015B → 13611014Ag, 13611015B FS-120d, 13611025b |  |
| 13611085 | Assembly Labor - Power Supply SEE BPMs | 2013-05-28 → 2013-04-08 A (-50d) | 2013-08-30 A | 68d → 100d | 0% → 100% | 20d → none | 13611080, 13611075 → 13611080 FS-20d, 13611075 FS-20d |  |
| 13611015B | Procrmnt - Fab/Assy & Testing - SEE BPMs ELECTRONICS | 2013-04-23 → 2013-06-03 A (+41d) | 2013-08-19 → 2013-08-30 A (+11d) | 83d → 68d | 0% → 100% | 20d → none | 13611015A FS-83d, 13611014C FS-68d, 13611014B → 13611015A FS-83d, 13611014C FS-68d, 13611014B FS-15d |  |
| 13611037 | Procurement Labor Cavities - nA BPM Sys | 2013-04-25 → 2013-08-30 A (+127d) | 2013-05-22 → 2013-08-30 A (+100d) |  | 0% → 100% | 75d → none |  |  |
| 13611037a | Procurement Cavities - nA BPM Sys | 2013-04-25 → 2013-08-30 A (+127d) | 2013-05-22 → 2013-08-30 A (+100d) |  | 0% → 100% | 75d → none |  |  |
| 13611038 | First Article Unit RF Receiver - nA BPM Sys | 2013-02-01 → 2013-08-30 A (+210d) | 2013-05-08 → 2013-08-30 A (+114d) |  | 0% → 100% | 66d → none |  |  |
| 13611038a | First Article Unit Digital IF - nA BPM Sys | 2013-02-01 → 2013-08-30 A (+210d) | 2013-04-10 → 2013-08-30 A (+142d) |  | 0% → 100% | 86d → none |  |  |
| 13611038b | First Article Enclosure nA Receiver - nA BPM Sys | 2013-05-09 → 2013-08-30 A (+113d) | 2013-06-05 → 2013-08-30 A (+86d) |  | 0% → 100% | 66d → none |  | resources ELEC ENG [80 h]; ELEC TECH [152 h] → ELEC TECH [152 h]; ELEC ENG [80 h] |
| 13611039 | Procurement Labor Electronics - nA BPM Sys | 2013-02-01 → 2013-08-30 A (+210d) | 2013-03-27 → 2013-08-30 A (+156d) |  | 0% → 100% | 33d → none |  |  |
| 13611040 | Procurements Electronics - nA BPM Sys | 2013-02-01 → 2013-08-30 A (+210d) | 2013-03-27 → 2013-08-30 A (+156d) |  | 0% → 100% | 33d → none |  |  |
| 13611045 | Assembly Electronics Labor - nA BPM Sys | 2013-03-27 → 2013-08-30 A (+156d) | 2013-07-23 → 2013-08-30 A (+38d) |  | 0% → 100% | 33d → none |  | resources ELEC TECH [400 h]; ELEC ENG [80 h] → ELEC ENG [80 h]; ELEC TECH [400 h] |
| 13611050 | Assembly & Testing Procurement - nA BPM Sys | 2013-03-27 → 2013-08-30 A (+156d) | 2013-07-23 → 2013-08-30 A (+38d) |  | 0% → 100% | 33d → none |  |  |
| 13611055 | System Installation Electronics - nA BPM Sytem (BPM) | 2013-07-24 → 2013-08-30 A (+37d) | 2013-08-27 → 2013-08-30 A (+3d) |  | 0% → 100% | 33d → none |  |  |
| 13611055a | System Installation Electronics Contract Labor - nA BPM Sytem (BPM) | 2013-07-24 → 2013-08-30 A (+37d) | 2013-08-27 → 2013-08-30 A (+3d) |  | 0% → 100% | 33d → none |  |  |
| 13611060 | Software support - nA BPMs | 2013-05-06 → 2013-08-30 A (+116d) | 2013-08-27 → 2013-08-30 A (+3d) |  | 0% → 100% | 33d → none |  |  |
| 13611950 | Re-Baseline Actuals Adjustment | 2013-08-30 A | 2013-08-30 A |  | 0% → 100% | 20d → none | 9-130M FS+227d → none |  |

| ID | Task | Start | Finish | Duration | Complete | Total float | Predecessors | Other |
| --- | --- | --- | --- | --- | --- | --- | --- | --- |
| 13611065M | nA BPMs Comp | 2013-08-27 → 2013-08-30 A (+3d) | 2013-08-27 → 2013-08-30 A (+3d) |  | 0% → 100% | 33d → none |  |  |
| 23611014B | Procurement Labor - SPM BPMs ELECTRONICS FY13 | 2013-09-03 A | 2013-09-30 → 2013-12-02 (+63d) | 20d → 43d | 0% → 50% | 43.5d → 99d |  |  |
| 23611014Ba | Procurement Labor - SPM BPMs ELECTRONICS FY14 | 2013-10-01 → 2013-09-03 A (-28d) | 2013-11-01 → 2013-12-02 (+31d) |  | 0% → 50% | 43.5d → 99d | 23611014B, 9-130M FS+228d → 23611014B FS-45d |  |
| 23611014D5 | Prcrmnt - SPM BPMs ELECTRONICS (Previously Obligated) | 2013-09-03 A | 2013-10-31 → 2013-10-21 A (-10d) |  | 0% → 100% | 44d → none |  |  |
| 23611015A | Labor - Fab & Assy - SEE BPMs ELECTRONICS | 2013-10-01 → 2013-09-03 A (-28d) |  |  | 0% → 66% | 53d → 103d |  |  |
| 23611025ca | System Installation Software Support - Electronics SPM BPMs Part B | 2013-12-02 → 2013-09-03 A (-90d) |  |  | 0% → 33% | 24d → 52d | 23611025c → 23611025c FS-45d |  |
| 23611026b | Hook-up & Check-out Arc 10 BPMs | 2013-09-03 A | 2013-09-30 → 2013-09-23 A (-7d) |  | 0% → 100% | 4d → none |  |  |
| 23611065a | System Documentation - BPMs FY13 | 2013-09-03 A | 2013-09-30 → 2013-11-18 (+49d) | 20d → 48d | 0% → 50% | 262d → 255d |  |  |
| 23611065aa | System Documentation - BPMs FY14 | 2013-10-01 → 2013-09-03 A (-28d) | 2013-11-07 → 2013-11-18 (+11d) |  | 0% → 50% | 262d → 255d | 9-130M FS+228d, 23611065a → 23611065a FS-30d |  |
| 23611070 | First Article Unit - Power Supplies/PC104/Timing Modules SPM BPMs | 2013-09-03 A | 2013-09-16 A |  | 0% → 100% | 50d → none |  |  |
| 23611075 | Procurement Labor - Power Supplies/PC104/Timing Modules SPM BPMs FY13 | 2013-09-03 A | 2013-09-30 → 2013-11-27 (+58d) | 20d → 62d | 0% → 50% | 50d → 200d |  |  |
| 23611075a | Procurement Labor - Power Supplies/PC104/Timing Modules SPM BPMs FY14 | 2013-10-01 → 2013-09-03 A (-28d) |  |  | 0% → 50% | 50d → 200d | 23611075, 23611070 FS-10d → 23611075 FS-45d |  |
| 23611080 | Procurement - Power Supplies/PC104/Timing Modules SPM BPMs | 2013-10-03 → 2013-09-03 A (-30d) | 2014-01-10 → 2014-01-08 (-2d) |  | 0% → 35% | 50d → 180d | 23611075 FS-40d, 23611075a FS-40d → 23611075 FS-45d, 23611075a FS-45d |  |
| 23611095 | Installation Labor - Power Supplies/PC104/Timing Modules SPM BPMs Part A | 2013-10-03 → 2013-09-03 A (-30d) |  |  | 0% → 50% | 50d → 136d |  |  |
| 23611095a | Installation Labor - Power Supplies/PC104/Timing Modules SPM BPMs Part B | 2013-12-02 → 2013-09-03 A (-90d) | 2014-02-03 → 2013-11-27 (-68d) |  | 0% → 50% | 50d → 110d | 23611095 → 23611095 FS-45d |  |
| 23611913LOE | FY13 Mngmnt Effort for BPMs | 2013-09-03 A | 2013-09-30 A |  | 0% → 100% | 67d → none |  |  |
| 23611015B | Procrmnt - Fab/Assy & Testing - SPM BPMs ELECTRONICS | 2013-11-01 → 2013-09-09 A (-53d) |  |  | 0% → 35% | 24d → 74d | 23611014B FS-20d, 23611014Ba FS-20d, 23611015A FS-83d, 23611014D FS-20d, 23611014D5 FS-20d → 23611014D5 FS-25d, 23611014Ba FS-45d, 23611014D FS-45d, 23611014B FS-45d, 23611015A FS-83d |  |
| 23611025 | System Installation - Electronics SPM BPMs Part A | 2013-11-01 → 2013-09-09 A (-53d) |  |  | 0% → 50% | 29d → 52d | 23611015B FS-20d → 23611015B FS-45d |  |
| 23611025b | System Installation Contract Labor - Electronics SPM BPMs | 2013-11-01 → 2013-09-09 A (-53d) |  |  | 0% → 10% | 86d → 49d | 23611015B FS-20d → 23611015B FS-45d |  |
| 23611025c | System Installation Software Support - Electronics SPM BPMs Part A | 2013-11-01 → 2013-09-09 A (-53d) |  |  | 0% → 50% | 24d → 78d | 23611015B FS-20d → 23611015B FS-45d |  |
| 23611027 | Hook-up & Check-out H-D B/L BPMs | 2014-03-12 → 2013-09-09 A (-184d) |  |  | 0% → 50% |  | 23458065a, 23611025b, 23458065, 23611025a, 23611025ca FS-15d, 23611100 → 23611025ca FS-125d, 23611100 FS-105d, 23611025b FS-45d, 23611025a FS-105d, 23458065a FS-20d, 23458065 FS-20d |  |
| 23611014D | Prcrmnt - SPM BPMs ELECTRONICS | 2013-10-01 → 2013-09-16 A (-15d) |  |  | 0% → 25% | 24d → 99d |  |  |
| 23611085 | Assembly Labor - Power Supplies/PC104/Timing Modules SPM BPMs Part A | 2013-10-03 → 2013-09-16 A (-17d) |  |  |  | 50d → 157d |  |  |
| 23611090 | Assembly Procurement - Power Supplies/PC104/Timing Modules SPM BPMs | 2013-10-03 → 2013-09-16 A (-17d) | 2014-02-03 → 2014-01-30 (-4d) |  | 0% → 25% | 50d → 159d |  |  |
| 23611914LOE | FY14 Mngmnt Effort for BPMs Part A | 2013-10-01 A |  |  | 0% → 55% |  |  |  |
| 23611100 | Installation Procurement - Power Supplies/PC104/Timing Modules SPM BPMs | 2013-10-03 → 2013-11-01 (+29d) | 2014-02-03 → 2014-03-04 (+29d) |  |  | 50d → 52d |  |  |
| 23611036 | First Article Cavities - nA BPM Sys | 2014-01-07 → 2014-01-03 (-4d) | 2014-03-03 → 2014-02-27 (-4d) |  |  | 23d → 25d |  |  |
| 23611037 | Procurement Labor Cavities - nA BPM Sys | 2014-03-31 → 2014-03-27 (-4d) | 2014-07-24 → 2014-07-22 (-2d) |  |  | 23d → 25d |  |  |
| 23611037a | Procurement Cavities - nA BPM Sys | 2014-03-31 → 2014-03-27 (-4d) | 2014-07-24 → 2014-07-22 (-2d) |  |  | 23d → 25d |  |  |
| 23611038 | First Article Unit RF Receiver - nA BPM Sys | 2014-03-31 → 2014-03-28 (-3d) | 2014-06-06 → 2014-06-05 (-1d) |  |  | 86d → 87d |  |  |
| 23611038a | First Article Unit Digital IF - nA BPM Sys | 2014-03-31 → 2014-03-28 (-3d) | 2014-05-08 → 2014-05-07 (-1d) |  |  | 86d → 87d |  |  |
| 23611038b | First Article Enclosure nA Receiver - nA BPM Sys | 2014-03-31 → 2014-03-28 (-3d) | 2014-04-24 → 2014-04-23 (-1d) |  |  | 86d → 87d |  |  |
| 23611060 | Software support - nA BPMs | 2014-03-31 → 2014-03-28 (-3d) | 2014-08-28 → 2014-08-27 (-1d) |  |  | 65d → 66d |  |  |
| 23611039 | Procurement Labor Electronics - nA BPM Sys | 2014-05-01 → 2014-04-30 (-1d) | 2014-05-28 → 2014-05-27 (-1d) |  |  | 20d → 21d |  |  |
| 23611040 | Procurements Electronics - nA BPM Sys | 2014-05-01 → 2014-04-30 (-1d) | 2014-05-28 → 2014-05-27 (-1d) |  |  | 20d → 21d |  |  |
| 23611045 | Assembly Electronics Labor - nA BPM Sys | 2014-06-30 → 2014-06-27 (-3d) | 2014-10-24 → 2014-10-23 (-1d) |  |  | 20d → 21d |  |  |
| 23611050 | Assembly & Testing Procurement - nA BPM Sys | 2014-06-30 → 2014-06-27 (-3d) | 2014-10-24 → 2014-10-23 (-1d) |  |  | 20d → 21d |  |  |
| 23611055 | System Installation Electronics - nA BPM Sytem (BPM) | 2014-07-30 → 2014-07-29 (-1d) | 2014-10-31 → 2014-10-30 (-1d) |  |  | 20d → 21d |  |  |
| 23611055a | System Installation Electronics Contract Labor - nA BPM Sytem (BPM) | 2014-07-30 → 2014-07-29 (-1d) | 2014-10-31 → 2014-10-30 (-1d) |  |  | 20d → 21d |  |  |
| 23611065M | nA BPMs Comp | 2014-10-31 → 2014-10-30 (-1d) | 2014-10-31 → 2014-10-30 (-1d) |  |  | 20d → 21d |  |  |
| 13612909LOE | FY09 Mngmnt Effort for Harps | 2009-01-02 A | 2009-09-30 A |  | 0% → 100% | 20d → none |  |  |
| 13612910LOE | FY10 Mngmnt Effort for Harps | 2009-10-01 A | 2010-09-30 A |  | 0% → 100% | 20d → none |  |  |
| 13612911LOE | FY11 Mngmnt Effort for Harps | 2010-10-01 A | 2011-09-30 A |  | 0% → 100% | 20d → none |  |  |
| 13612011 | LABOR Prep for Harp Sys Procuremnts (prior to 6 mon down) | 2011-10-03 A | 2011-11-29 → 2012-06-11 A (+195d) | 40d → 169d | 0% → 100% | 170d → none |  | was named LABOR Prep for Harp Sys Procuremnts |
| 13612912LOE | FY12 Mngmnt Effort for Harps | 2011-10-03 A | 2012-09-28 A |  | 0% → 100% | 20d → none |  |  |
| 13612014 | Vendors Fab Harp Sys Pieces & Components (spanning 6 month down) | 2011-10-03 → 2012-01-03 A (+92d) | 2012-02-24 → 2012-08-20 A (+178d) | 95d → 161d | 0% → 100% | 170d → none | 13612011 FS-40d → 13612011 FS-50d | was named Vendors Fab Harp Sys Pieces & Components |
| 13612015 | Harp Sys Fab & Assy | 2012-02-27 → 2012-04-16 A (+49d) | 2012-08-21 → 2012-08-13 A (-8d) | 125d → 84d | 0% → 100% | 170d → none | 13612014 → 13612014 FS-25d | resources SCIENTIST [120 h]; SUPPLIES & MATERIALS; MECH TECH [40 h]; ELEC DES [40 h]; ELEC TECH [320 h]; ELEC ENG [60 h] → ELEC ENG [60 h]; SCIENTIST [120 h]; SUPPLIES & MATERIALS; ELEC DES [40 h]; MECH TECH [40 h]; ELEC TECH [320 h] |
| 13612020 | Harp Component Testing FY12 | 2012-08-22 → 2012-07-02 A (-51d) | 2012-09-28 → 2012-12-17 A (+80d) | 27d → 127d | 0% → 100% | 170d → none | 13612015, 9-120M → 9-120M, 13612015 FS-80d | resources COMP SCIENT [61.71 h]; ELEC TECH [92.57 h]; ELEC ENG [30.86 h] → ELEC TECH [92.57 h]; COMP SCIENT [61.71 h]; ELEC ENG [30.86 h] |
| 13612020a | Harp Component Testing FY13 | 2012-10-01 → 2012-07-02 A (-91d) | 2012-10-10 → 2012-12-17 A (+68d) | 8d → 127d | 0% → 100% | 170d → none | 13612020 → 13612020 FS-85d | resources ELEC ENG [9.14 h]; COMP SCIENT [18.29 h]; ELEC TECH [27.43 h] → COMP SCIENT [18.29 h]; ELEC TECH [27.43 h]; ELEC ENG [9.14 h] |
| 13612020b | Harp Component Testing Procurement | 2012-08-22 → 2012-07-02 A (-51d) | 2012-10-10 → 2012-11-12 A (+33d) | 35d → 95d | 0% → 100% | 170d → none | 13612015, 9-120M → 13612015 FS-100d, 9-120M |  |
| 13612913LOE | FY13 Mngmnt Effort for Harps | 2012-10-01 A | 2013-08-30 A | 228d → 248d | 0% → 100% | 20d → none |  |  |
| 13612025 | Harp Sys Implementn | 2012-10-11 → 2012-10-15 A (+4d) | 2013-01-14 → 2013-04-15 A (+91d) | 60d → 73d | 0% → 100% | 170d → none | 1362025, 13612020a, 13612020b, 2-02M → 2-02M, 13612020b FS-100d, 13612020a FS-100d, 1362025 | resources ELEC ENG [40 h]; MECH TECH [40 h]; ELEC TECH [360 h]; PROCUREMENT<$50K 60; SUPPLIES & MATERIALS; ELEC DES [40 h] → PROCUREMENT<$50K 60; ELEC TECH [360 h]; SUPPLIES & MATERIALS; ELEC DES [40 h]; ELEC ENG [40 h]; MECH TECH [40 h] |
| 13612030 | Harp Systems Software Implementn & Cmmssng FY12 | 2012-09-27 → 2013-01-21 A (+116d) | 2012-09-28 → 2013-08-30 A (+336d) |  | 0% → 100% | 170d → none | 13612025 FS-70d → 13612025 FS-30d |  |
| 13612035 | Harp Systems Software Implementn & Cmmssng FY13 | 2012-10-01 → 2013-01-21 A (+112d) | 2013-02-12 → 2013-08-30 A (+199d) |  | 0% → 100% | 170d → none | 13612030 → 13612030 FS-70d |  |
| 13612950 | Re-Baseline Actuals Adjustment | 2013-08-30 A | 2013-08-30 A |  | 0% → 100% | 20d → none | 9-130M FS+227d → none |  |
| 13612035M | Harp Sys Comp | 2013-02-12 → 2013-08-30 A (+199d) | 2013-02-12 → 2013-08-30 A (+199d) |  | 0% → 100% | 170d → none | 13612035 → 13612035, 13612030 |  |
| 23612030 | Harp Sys Implementn Labor | 2013-09-03 A | 2013-09-30 → 2013-09-23 A (-7d) |  | 0% → 100% | 30d → none |  |  |
| 23612035 | Harp Systems Software Implementn & Cmmssng | 2013-09-03 A | 2013-09-30 → 2013-09-28 A (-2d) |  | 0% → 100% | 30d → none |  |  |
| 23612913LOE | FY13 Mngmnt Effort for Harps | 2013-09-03 A | 2013-09-30 A |  | 0% → 100% | 89d → none |  |  |
| 23612035M | Harp Sys Comp | 2013-09-30 → 2013-09-28 A (-2d) | 2013-09-30 → 2013-09-28 A (-2d) |  | 0% → 100% | 30d → none |  |  |
| 3 | **1.3.6.1.3 VIEWERS** |  | 2013-12-02 → 2013-11-27 (-5d) |  |  |  |  |  |
| 13613909LOE | FY09 Mngmnt Effort for Viewer Syss | 2009-01-02 A | 2009-09-30 A |  | 0% → 100% | 20d → none |  |  |
| 13613910LOE | FY10 Mngmnt Effort for Viewer Syss | 2009-10-01 A | 2010-09-30 A |  | 0% → 100% | 20d → none |  |  |
| 13613911LOE | FY11 Mngmnt Effort for Viewer Syss | 2010-10-01 A | 2011-09-30 A |  | 0% → 100% | 20d → none |  |  |
| 13613912LOE | FY12 Mngmnt Effort for Viewer Syss | 2011-10-03 A | 2012-09-28 A |  | 0% → 100% | 20d → none |  |  |
| 13613014 | Procurements for Viewer Syss | 2012-02-03 → 2012-04-02 A (+59d) | 2012-05-25 → 2012-07-16 A (+52d) | 80d → 74d | 0% → 100% | 20d → none | 121613040M, 9-120M FS+80d → 121613040M, 9-120M FS+120d | resources ELEC TECH [160 h]; SCIENTIST [100 h]; TRAVEL; SUPPLIES & MATERIALS; PROCUREMENT<$50K 60; ELEC ENG [80 h] → SCIENTIST [100 h]; TRAVEL; SUPPLIES & MATERIALS; PROCUREMENT<$50K 60; ELEC ENG [80 h]; ELEC TECH [160 h] |
| 13613015 | Fab & Assy of Viewer Syss FY12 | 2012-05-29 → 2012-06-05 A (+7d) | 2012-09-28 → 2012-08-13 A (-46d) | 87d → 50d | 0% → 100% | 20d → none | 13613014, 9-120M → 13613014 FS-20d, 9-120M | resources SUPPLIES & MATERIALS; TRAVEL; SCIENTIST [38.67 h]; ELEC ENG [77.33 h]; ELEC DES [19.33 h]; MECH TECH [19.33 h]; ELEC TECH [193.33 h] → ELEC DES [19.33 h]; MECH TECH [19.33 h]; ELEC TECH [193.33 h]; SCIENTIST [38.67 h]; SUPPLIES & MATERIALS; TRAVEL; ELEC ENG [77.33 h] |
| 13613015a | Fab & Assy of Viewer Syss FY13 | 2012-10-01 → 2012-06-05 A (-118d) | 2013-02-20 → 2012-08-13 A (-191d) | 93d → 50d | 0% → 100% | 20d → none |  |  |
| 13613015b | Fab & Assy of Viewer Syss Procurement | 2012-05-29 → 2012-06-05 A (+7d) | 2013-02-20 → 2012-08-13 A (-191d) | 180d → 50d | 0% → 100% | 20d → none | 9-120M, 13613014 → 9-120M, 13613014 FS-20d |  |
| 13613020 | Testing of Viewer Sys Compnts | 2013-02-21 → 2012-08-20 A (-185d) | 2013-08-16 → 2013-04-15 A (-123d) | 125d → 131d | 0% → 100% | 20d → none | 13613015a, 13613015b → 13613015, 13613015a, 13613015b | resources ELEC ENG [40 h]; ELEC TECH [160 h]; COMP SCIENT [320 h]; SCIENTIST [20 h]; PROCUREMENT<$50K 60 → ELEC TECH [160 h]; SCIENTIST [20 h]; COMP SCIENT [320 h]; PROCUREMENT<$50K 60; ELEC ENG [40 h] |

| ID | Task | Start | Finish | Duration | Complete | Total float | Predecessors | Other |
| --- | --- | --- | --- | --- | --- | --- | --- | --- |
| 13613913LOE | FY13 Mngmnt Effort for Viewer Syss | 2012-10-01 A | 2013-08-30 A | 228d → 248d | 0% → 100% | 20d → none |  |  |
| 13613025 | Implementn of Viewer Syss | 2013-08-19 → 2012-10-08 A (-315d) | 2013-08-30 A | 10d → 158d | 0% → 100% | 20d → none | 13613020, 1362025 → 1362025, 13613020 FS-100d | resources ELEC DES [2.86 h]; MECH TECH [2.86 h]; ELEC TECH [20 h]; PROCUREMENT<$50K 60 NO ESCALATION FY14; ELEC ENG [2.86 h] → ELEC ENG [2.86 h]; ELEC DES [2.86 h]; MECH TECH [2.86 h]; ELEC TECH [20 h]; PROCUREMENT<$50K 60 NO ESCALATION FY14 |
| 13613030 | Software Implementn Viewer Systems | 2013-08-05 → 2012-11-12 A (-266d) | 2013-08-30 A | 20d → 178d | 0% → 100% | 20d → none | 13613025 FS-20d, 121613040M → 9-130M, 13613025 FS-150d, 121613040M | resources SCIENTIST [4.85 h]; COMP SCIENT [19.39 h]; ELEC ENG [14.55 h]; ELEC TECH [29.09 h] → ELEC ENG [14.55 h]; ELEC TECH [29.09 h]; SCIENTIST [4.85 h]; COMP SCIENT [19.39 h] |
| 13613950 | Re-Baseline Actuals Adjustment | 2013-08-30 A | 2013-08-30 A |  | 0% → 100% | 20d → none | 9-130M FS+227d → none |  |
| 23613025a | Implementn of Viewer Syss Labor | 2013-09-03 A | 2013-09-30 → 2013-11-27 (+58d) |  | 0% → 50% | 30d → 19d |  |  |
| 23613030 | Software Implementn Viewer Systems | 2013-09-03 A | 2013-09-30 → 2013-11-27 (+58d) |  | 0% → 30% | 30d → 19d |  |  |
| 23613913LOE | FY13 Mngmnt Effort for Viewer Syss | 2013-09-03 A | 2013-09-30 A |  | 0% → 100% | 89d → none |  |  |
| 23613050 | SLM System Controls | 2013-10-01 → 2013-09-16 A (-15d) | 2013-12-02 → 2013-10-21 A (-42d) |  | 0% → 100% | 73d → none |  |  |
| 23613035M | Viewers Sys Comp | 2013-09-30 → 2013-11-27 (+58d) | 2013-09-30 → 2013-11-27 (+58d) |  |  | 30d → 19d |  |  |
| 4 | **1.3.6.1.4 BEAM-BASED FEEDBACK SYSTEMS** |  | 2014-09-22 → 2014-09-19 (-3d) |  |  |  |  |  |
| 13614909LOE | FY09 FFB Sys Mangement Effort | 2009-01-02 A | 2009-09-30 A |  | 0% → 100% | 20d → none |  |  |
| 13614910LOE | FY10 FFB Sys Mangement Effort | 2009-10-01 A | 2010-09-30 A |  | 0% → 100% | 20d → none |  |  |
| 13614911LOE | FY11 FFB Sys Mangement Effort | 2010-10-01 A | 2011-09-30 A |  | 0% → 100% | 20d → none |  |  |
| 13614014 | FFB Sys Prcrmnts | 2013-02-06 → 2013-08-30 A (+205d) | 2013-05-01 → 2013-08-30 A (+121d) | 60d → 55d | 0% → 100% | 65d → none | 121614035M, 2-02M FS+180d → 9-130M FS+130d, 2-02M FS+180d, 121614035M, 9-140M | resources ELEC TECH [60 h]; SUPPLIES & MATERIALS; PROCUREMENT<$50K 60 → ELEC TECH [60 h]; PROCUREMENT<$50K 60; SUPPLIES & MATERIALS |
| 13614015 | FFB Sys Fabriation & Assy | 2013-05-02 → 2013-08-30 A (+120d) | 2013-06-27 → 2013-08-30 A (+64d) | 40d → 43d | 0% → 100% | 65d → none | 13614014 → 13614014 FS-20d | resources PROCUREMENT<$50K 60; ELEC TECH [120 h]; ELEC DES [40 h]; SUPPLIES & MATERIALS → PROCUREMENT<$50K 60; ELEC TECH [120 h]; SUPPLIES & MATERIALS; ELEC DES [40 h] |
| 13614020 | FFB Sys Component & VME Testing | 2013-05-02 → 2013-08-30 A (+120d) | 2013-06-27 → 2013-08-30 A (+64d) | 40d → 43d | 0% → 100% | 65d → none | 13614014 → 13614014 FS-20d | resources ELEC TECH [80 h]; COMP SCIENT [60 h]; ELEC ENG [60 h]; PROCUREMENT<$50K 60 → PROCUREMENT<$50K 60; ELEC ENG [60 h]; ELEC TECH [80 h]; COMP SCIENT [60 h] |
| 13614950 | Re-Baseline Actuals Adjustment | 2013-08-30 A | 2013-08-30 A |  | 0% → 100% | 20d → none | 9-130M FS+227d → none |  |
| 23614014 | FFB Sys Prcrmnts | 2014-03-05 → 2014-03-04 (-1d) | 2014-05-20 → 2014-05-19 (-1d) |  |  | 49d → 50d |  |  |
| 23614050LOE | FY14 Mngmnt Effort for FFB | 2014-03-05 → 2014-03-04 (-1d) | 2014-09-19 → 2014-09-18 (-1d) |  |  | 50d → 51d |  |  |
| 23614015 | FFB Sys Fabriation & Assy | 2014-04-23 → 2014-04-22 (-1d) | 2014-06-23 → 2014-06-20 (-3d) |  |  | 49d → 50d |  |  |
| 23614020 | FFB Sys Component & VME Testing | 2014-04-23 → 2014-04-22 (-1d) | 2014-06-23 → 2014-06-20 (-3d) |  |  | 112d → 113d |  |  |
| 23614030 | FFB Software Implementn | 2014-05-27 → 2014-05-23 (-4d) | 2014-08-01 → 2014-07-31 (-1d) |  |  | 49d → 50d |  |  |
| 23614025 | FFB Sys Hardware Implementn | 2014-06-24 → 2014-06-23 (-1d) | 2014-07-22 → 2014-07-21 (-1d) |  |  | 49d → 50d |  |  |
| 23614035 | FFB Slow Lock Implementn | 2014-08-04 → 2014-08-01 (-3d) | 2014-09-15 → 2014-09-12 (-3d) |  |  | 49d → 50d |  |  |
| 23614040 | FFB Slow Lock & FFB Cmmssng | 2014-09-02 → 2014-08-29 (-4d) | 2014-09-22 → 2014-09-19 (-3d) |  |  | 49d → 50d |  |  |
| 23614045M | FFB Sys Comp | 2014-09-22 → 2014-09-19 (-3d) | 2014-09-22 → 2014-09-19 (-3d) |  |  | 49d → 50d |  |  |
| 1362909LOE | FY09 CSH Sys Mngmnt Effort | 2009-01-02 A | 2009-09-30 A |  | 0% → 100% | 20d → none |  |  |
| 1362910LOE | FY10 CSH Sys Mngmnt Effort | 2009-10-01 A | 2010-09-30 A |  | 0% → 100% | 20d → none |  |  |
| 1362014 | CSH Proc Compnts (multiple reqs) Linacs - Labor | 2010-04-01 A | 2010-05-26 → 2010-07-26 A (+61d) | 40d → 81d | 0% → 100% | 451d → none |  |  |
| 1362014A | CSH Proc Compnts (multiple reqs) Linacs - Procurements | 2010-04-01 A | 2010-05-26 → 2010-07-26 A (+61d) | 40d → 81d | 0% → 100% | 451d → none |  |  |
| 1362910ALOE | FY10 Engineering Oversight | 2010-04-01 A | 2010-09-30 A |  | 0% → 100% | 20d → none |  |  |
| 1362015 | CSH Hardware Setup/Configuration Linacs - Labor FY10 | 2010-05-27 → 2010-06-21 A (+25d) | 2010-09-30 A | 88d → 72d | 0% → 100% | 451d → none |  |  |
| 1362015ab | CSH Hardware Setup/Configuration Linacs - Labor FY11 | 2010-10-01 → 2010-06-21 A (-102d) | 2010-12-15 → 2010-09-30 A (-76d) | 52d → 72d | 0% → 100% | 451d → none |  |  |
| 1362015A | CSH Hardware Setup/Configuration Linacs - Procurement | 2010-05-27 → 2010-07-01 A (+35d) | 2010-12-15 → 2010-09-30 A (-76d) | 140d → 64d | 0% → 100% | 451d → none |  |  |
| 1362911LOE | FY11 CSH Sys Mngmnt Effort (Including Engineering Oversight) | 2010-10-01 A | 2011-09-30 A |  | 0% → 100% | 20d → none |  |  |
| 1362020 | CSH Installtn Network/Controls Linacs - Labor | 2010-12-16 → 2010-11-15 A (-31d) | 2011-02-18 → 2011-02-14 A (-4d) | 40d → 57d | 0% → 100% | 451d → none |  |  |
| 1362020A | CSH Installtn Network/Controls Linacs - Procurement | 2010-12-16 → 2010-12-06 A (-10d) | 2011-02-18 → 2011-02-14 A (-4d) | 40d → 44d | 0% → 100% | 451d → none |  |  |
| 1362025 | CSH Commisioning Network/Controls Linacs | 2011-02-22 → 2011-02-15 A (-7d) | 2011-05-31 → 2011-05-29 A (-2d) | 70d → 73d | 0% → 100% | 451d → none | 1362020A, 1362020 → 1362020A FS-30d, 1362020 | resources ELEC ENG [40 h]; ELEC TECH [140 h]; COMP SCIENT [80 h] → COMP SCIENT [80 h]; ELEC ENG [40 h]; ELEC TECH [140 h] |
| 1362912LOE | FY12 CSH Sys Mngmnt Effort (Including Engineering Oversight) | 2011-10-03 A | 2012-09-28 A |  | 0% → 100% | 20d → none |  | resources ELEC ENG [150.8 h]; SR STAFF [60 h] → SR STAFF [60 h]; ELEC ENG [150.8 h] |
| 1362014B | CSH Proc Compnts (multiple reqs) Tagger Service Building - Labor | 2011-10-03 → 2011-10-10 A (+7d) | 2011-11-29 → 2012-04-09 A (+132d) | 40d → 121d | 0% → 100% | 105d → none |  |  |
| 1362014C | CSH Proc Compnts (multiple reqs) Tagger Service Building - Procurements | 2011-10-03 → 2012-02-01 A (+121d) | 2011-11-29 → 2012-04-09 A (+132d) | 40d → 48d | 0% → 100% | 105d → none | 9-120M → 9-120M FS+90d | resources PROCUREMENT>$50K 69; PROCUREMENT<$50K 60 → PROCUREMENT<$50K 60; PROCUREMENT>$50K 69 |
| 1362015B | CSH Hardware Setup/Configuration Tagger Service Building - Labor | 2011-11-30 → 2012-03-12 A (+103d) | 2012-06-26 → 2012-07-09 A (+13d) | 140d → 84d | 0% → 100% | 105d → none | 1362014B, 1362014C → 1362014B FS-20d, 1362014C FS-20d |  |
| 1362020B | CSH Installtn Network/Controls Tagger Service Building - Labor | 2012-06-27 → 2012-03-12 A (-107d) | 2012-08-21 → 2012-08-13 A (-8d) | 40d → 109d | 0% → 100% | 105d → none | 1362015B, 1362015C → 1362015C FS-150d, 1362015B FS-150d |  |
| 1362015C | CSH Hardware Setup/Configuration Tagger Service Building - Procurement | 2011-11-30 → 2012-04-02 A (+124d) | 2012-06-26 → 2012-06-11 A (-15d) | 140d → 49d | 0% → 100% | 105d → none |  |  |
| 1362020C | CSH Installtn Network/Controls Tagger Service Building - Procurement | 2012-06-27 → 2012-04-09 A (-79d) | 2012-08-21 → 2012-05-14 A (-99d) | 40d → 26d | 0% → 100% | 105d → none | 1362015C, 1362015B → 1362015B FS-135d, 1362015C FS-135d |  |
| 1362030 | CSH Gateway , Data Storage, CPU Capacity | 2012-12-03 → 2012-10-01 A (-63d) | 2013-05-01 → 2013-03-11 A (-51d) | 100d → 123d | 0% → 100% | 105d → none | 1362025Aa, 1362025 → 1362025, 1362025Aa FS-120d | resources COMP SCIENT [160 h]; TRAVEL; PROCUREMENT<$50K 60 → PROCUREMENT<$50K 60; COMP SCIENT [160 h]; TRAVEL |
| 1362025A | CSH Commisioning Network/Controls Tagger Service Building FY12 | 2012-08-22 → 2013-01-14 A (+145d) | 2012-09-28 → 2013-02-11 A (+136d) |  | 0% → 100% | 105d → none | 1362020B, 1362020C → 1362020C, 1362020B, 9-130M FS+60d |  |
| 1362027 | East Arc 12Gev Network Upgrade Installations | 2012-12-03 → 2013-01-14 A (+42d) | 2013-05-01 → 2013-03-11 A (-51d) |  | 0% → 100% | 105d → none | 1362025Aa, 1362025 → 1362025 FS-40d, 1362025Aa FS-50d |  |
| 1362026 | East Arc 12Gev Network Upgrade Procuremnts | 2012-12-03 → 2013-01-21 A (+49d) | 2013-05-01 → 2013-03-11 A (-51d) |  | 0% → 100% | 105d → none | 1362025, 1362025Aa → 1362025, 1362025Aa FS-70d |  |
| 1362028 | East Arc 12Gev Network Upgrade Testing | 2012-12-03 → 2013-01-21 A (+49d) | 2013-05-01 → 2013-04-15 A (-16d) |  | 0% → 100% | 105d → none | 1362025Aa, 1362025 → 1362025Aa FS-50d, 1362025 FS-40d |  |
| 1362025Aa | CSH Commisioning Network/Controls Tagger Service Building FY13 | 2012-10-01 → 2013-02-04 A (+126d) | 2012-11-30 → 2013-03-11 A (+101d) |  | 0% → 100% | 105d → none |  |  |
| 1362035M | CSH Comp Milestone | 2013-05-01 → 2013-08-26 A (+117d) | 2013-05-01 → 2013-08-26 A (+117d) |  | 0% → 100% | 105d → none |  |  |
| 1362950 | Re-Baseline Actuals Adjustment | 2013-08-30 A | 2013-08-30 A |  | 0% → 100% | 20d → none | 9-130M FS+227d → none |  |
| 3 | **1.3.6.3 CONTROL SYSTEM SOFTWARE** |  | 2013-09-30 → 2013-10-21 (+21d) |  |  |  |  |  |
| 1363909LOE | FY09 CSS Sys Mngmnt Effort | 2009-01-02 A | 2009-09-30 A |  | 0% → 100% | 20d → none |  |  |
| 1363910LOE | FY10 CSS Sys Mngmnt Effort | 2009-10-01 A | 2010-09-30 A |  | 0% → 100% | 20d → none |  |  |
| 1363911LOE | FY11 CSS Sys Mngmnt Effort | 2010-10-01 A | 2011-09-30 A |  | 0% → 100% | 20d → none |  |  |
| 1363015 | Update Hi-Level Applications Labor FY11 | 2011-04-29 → 2011-05-02 A (+3d) | 2011-09-30 A | 108d → 107d | 0% → 100% | 160d → none |  |  |
| 1363015b | Update Hi-Level Applications Procurement | 2011-04-29 → 2011-05-02 A (+3d) | 2013-03-29 → 2013-04-15 A (+17d) | 475d → 474d | 0% → 100% | 160d → none |  |  |
| 1363015a | Update Hi-Level Applications Labor FY12 | 2011-10-03 A | 2012-09-28 → 2013-08-30 A (+336d) | 247d → 367d | 0% → 100% | 160d → none |  |  |
| 1363015aa | Update Hi-Level Applications Labor FY13 | 2012-10-01 → 2011-10-03 A (-364d) | 2013-03-29 → 2013-08-30 A (+154d) | 120d → 367d | 0% → 100% | 160d → none | 1363015a → 1363015a FS-140d |  |
| 1363912LOE | FY12 CSS Sys Mngmnt Effort | 2011-10-03 A | 2012-09-28 A |  | 0% → 100% | 20d → none |  |  |
| 1363020 | Update Sys Tools (CONT SYS SW) FY12 | 2012-04-30 → 2012-02-13 A (-77d) | 2012-09-28 → 2013-03-11 A (+164d) | 107d → 219d | 0% → 100% | 320d → none | 9-120M FS+140d → 9-120M |  |
| 1363020a | Update Sys Tools (CONT SYS SW) FY13 | 2012-10-01 → 2012-02-13 A (-231d) | 2012-12-21 → 2013-03-11 A (+80d) | 58d → 219d | 0% → 100% | 320d → none | 1363020 → 1363020 FS-80d |  |
| 1363020b | Update Sys Tools (CONT SYS SW) Procurement | 2012-04-30 → 2012-02-13 A (-77d) | 2012-12-21 → 2013-03-11 A (+80d) | 165d → 219d | 0% → 100% | 320d → none | 9-120M FS+140d → 9-120M |  |
| 1363035 | Integration with Sys administration Mngmnt Software (CONT SYS SW) | 2012-05-14 → 2012-02-13 A (-91d) | 2012-06-12 → 2013-01-28 A (+230d) | 20d → 211d | 0% → 100% | 335d → none | 2-02M → 2-02M FS-60d |  |
| 1363025 | Update Low-Level Applications (CONT SYS SW) FY12 | 2012-04-30 → 2012-04-02 A (-28d) | 2012-09-28 → 2013-08-30 A (+336d) | 107d → 205d | 0% → 100% | 180d → none |  |  |
| 1363025a | Update Low-Level Applications (CONT SYS SW) FY13 | 2012-10-01 → 2012-04-04 A (-180d) | 2013-01-29 → 2013-08-30 A (+213d) | 78d → 203d | 0% → 100% | 180d → none | 1363025 → 1363025 FS-100d |  |
| 1363025b | Update Low-Level Applications (CONT SYS SW) Procurement | 2012-04-30 → 2012-04-04 A (-26d) | 2013-01-29 → 2013-08-30 A (+213d) | 185d → 203d | 0% → 100% | 180d → none |  |  |
| 1363014 | Update Synoptic Displays (CONT SYS SW) FY12 | 2012-05-14 → 2012-06-02 A (+19d) | 2012-09-28 → 2013-03-11 A (+164d) | 97d → 136d | 0% → 100% | 205d → none |  |  |

| ID | Task | Start | Finish | Duration | Complete | Total float | Predecessors | Other |
| --- | --- | --- | --- | --- | --- | --- | --- | --- |
| 1363014a | Update Synoptic Displays (CONT SYS SW) FY13 | 2012-10-01 → 2012-06-02 A (-121d) | 2012-12-14 → 2013-03-11 A (+87d) | 53d → 136d | 0% → 100% | 205d → none | 1363014 → 1363014 FS-80d |  |
| 1363913LOE | FY13 CSS Sys Mngmnt Effort | 2012-10-01 A | 2013-08-30 A | 228d → 248d | 0% → 100% | 20d → none |  |  |
| 1363030 | Update Communication/Coordination Tools (CONT SYS SW) FY12 | 2012-09-06 → 2012-11-12 A (+67d) | 2012-09-28 → 2013-03-11 A (+164d) | 17d → 38d | 0% → 100% | 180d → none |  |  |
| 1363030a | Update Communication/Coordination Tools (CONT SYS SW) FY13 | 2012-10-01 → 2012-11-12 A (+42d) | 2013-01-14 → 2013-03-11 A (+56d) | 68d → 38d | 0% → 100% | 180d → none | 1363030 → 1363030 FS-30d |  |
| 1363950 | Re-Baseline Actuals Adjustment | 2013-08-30 A | 2013-08-30 A |  | 0% → 100% | 20d → none | 9-130M FS+227d → none |  |
| 2363015aa | Update Hi-Level Applications Labor | 2013-09-03 A | 2013-09-30 → 2013-10-21 A (+21d) |  | 0% → 100% | 32d → none |  |  |
| 2363913LOE | FY13 CSS Sys Mngmnt Effort | 2013-09-03 A | 2013-09-30 A |  | 0% → 100% | 89d → none |  |  |
| 13641909LOE | FY09 Mngmnt & Elect Dsgn Supprt Effort for MPS | 2009-01-02 A | 2009-09-30 A |  | 0% → 100% | 20d → none |  |  |
| 13641910LOE | FY10 Mngmnt & Elect Dsgn Supprt Effort for MPS | 2009-10-01 A | 2010-09-30 A |  | 0% → 100% | 20d → none |  | resources SR STAFF [4 h]; ELEC DES [4 h] → ELEC DES [4 h]; SR STAFF [4 h] |
| 13641911LOE | FY11 Mngmnt & Elect Dsgn Supprt Effort for MPS | 2010-10-01 A | 2011-09-30 A |  | 0% → 100% | 20d → none |  | resources SR STAFF [36 h]; ELEC DES [64 h] → ELEC DES [64 h]; SR STAFF [36 h] |
| 13641014a | Proc Wire & Cable for RF Installation (MPS) | 2011-01-05 → 2011-02-01 A (+27d) | 2011-03-17 → 2011-02-21 A (-24d) | 50d → 14d | 0% → 100% | 540d → none | 9-110M FS+60d → 9-110M FS+68d | resources ELEC TECH [18 h]; ELEC ENG [20 h]; PROCUREMENT<$50K 60 → PROCUREMENT<$50K 60; ELEC TECH [18 h]; ELEC ENG [20 h] |
| 13641015a | Proc FSD Hardware for RF Installation (MPS) | 2011-03-18 → 2011-02-25 A (-21d) | 2011-05-12 → 2011-07-25 A (+74d) | 40d → 105d | 0% → 100% | 540d → none |  |  |
| 13641025a | Install FSD Wire & Cable for RF Installation (MPS) FY11 | 2011-06-27 → 2011-03-01 A (-118d) | 2011-09-30 → 2011-08-05 A (-56d) | 68d → 112d | 0% → 100% | 540d → none | 13641020a → 13641020a FS-60d |  |
| 13641025ab | Install FSD Wire & Cable for RF Installation (MPS) FY12 | 2011-10-03 → 2011-03-01 A (-216d) | 2012-02-06 → 2011-08-05 A (-185d) | 82d → 112d | 0% → 100% | 540d → none |  |  |
| 13641020a | Test/QA FSD Hardware for RF Installation (MPS) | 2011-05-13 A | 2011-06-24 → 2011-09-13 A (+81d) | 30d → 85d | 0% → 100% | 540d → none | 13641015a → 13641015a FS-35d |  |
| 13641030a | Install/Test FSD Hardware for RF Installation(MPS) | 2012-02-07 → 2011-05-23 A (-260d) | 2012-03-20 → 2013-08-30 A (+528d) | 30d → 393d | 0% → 100% | 540d → none | 13641025ab → 13641025ab FS-250d | was named Install/Test FSD Hardwarefor RF Installation(MPS) |
| 13641912LOE | FY12 Mngmnt & Elect Dsgn Supprt Effort for MPS | 2011-10-03 A | 2012-09-28 A |  | 0% → 100% | 20d → none |  | resources ELEC DES [64 h]; SR STAFF [36 h] → SR STAFF [36 h]; ELEC DES [64 h] |
| 13641014 | Proc Wire & Cable (MPS) | 2012-01-05 → 2012-01-03 A (-2d) | 2012-03-16 → 2012-10-15 A (+213d) | 50d → 200d | 0% → 100% | 30d → none |  |  |
| 13641050 | Proc BLM Hardware (MPS) | 2012-01-05 → 2012-02-01 A (+27d) | 2012-03-02 → 2013-08-28 A (+544d) | 40d → 242d | 0% → 100% | 347d → none | 9-120M FS+60d → 9-120M | resources ELEC ENG [40 h]; PROCUREMENT<$50K 60; ELEC TECH [80 h] → ELEC TECH [80 h]; PROCUREMENT<$50K 60; ELEC ENG [40 h] |
| 13641035 | Develop/Install/Test FSD Firmware (MPS) | 2012-10-18 → 2012-02-06 A (-255d) | 2012-12-14 → 2013-08-26 A (+255d) | 40d → 220d | 0% → 100% | 352d → none | 13641025b, 13641030 FS-45d → 13641025b FS-190d, 13641030 FS-190d |  |
| 13641015 | Proc FSD Hardware (MPS) | 2012-03-19 → 2012-07-02 A (+105d) | 2012-05-11 → 2013-08-28 A (+474d) | 40d → 132d | 0% → 100% | 347d → none | 13641014, 121641110M, 121641170 → 13641014 FS-60d, 121641110M, 121641170 |  |
| 13641020 | Test/QA FSD Hardware (MPS) FY12 | 2012-08-30 → 2012-09-14 A (+15d) | 2012-09-28 → 2013-08-28 A (+334d) | 21d → 83d | 0% → 100% | 347d → none | 13641015 FS+76d → 13641015 FS-30d |  |
| 13641020b | Test/QA FSD Hardware (MPS) FY13 | 2012-10-01 → 2012-09-14 A (-17d) | 2012-10-29 → 2013-08-19 A (+294d) | 21d → 83d | 0% → 100% | 347d → none | 13641020 → 13641020 FS-70d |  |
| 13641085 | Proc Tagger/Hall D Beam Loss Monitoring Hardware (MPS) | 2012-01-05 → 2012-10-01 A (+270d) | 2012-03-16 → 2013-08-30 A (+532d) | 50d → 66d | 0% → 100% | 480d → none | 9-120M FS+60d → 9-130M FS+20d, 9-120M FS+235d | resources ELEC TECH [40 h]; PROCUREMENT<$50K 60; ELEC ENG [40 h] → ELEC ENG [40 h]; ELEC TECH [40 h]; PROCUREMENT<$50K 60 |
| 13641913LOE | FY13 Mngmnt & Elect Dsgn Supprt Effort for MPS | 2012-10-01 A | 2013-08-30 A | 228d → 248d | 0% → 100% | 20d → none |  |  |
| 13641070 | Develop/Install/Test BLM Firmware (MPS) | 2012-11-01 → 2013-01-07 A (+67d) | 2012-12-21 → 2013-07-15 A (+206d) | 35d → 67d | 0% → 100% | 347d → none | 13641065 FS-87d → 13641065 FS-120d |  |
| 13641090 | Test/QA Tagger/Hall D Beam Loss Monitoring Hardware (MPS) | 2012-03-19 → 2013-02-14 A (+332d) | 2012-04-13 → 2013-08-30 A (+504d) |  | 0% → 100% | 480d → none | 13641085 → 13641085 FS-70d | resources ELEC ENG [40 h]; ELEC TECH [80 h] → ELEC TECH [80 h]; ELEC ENG [40 h] |
| 13641055 | Test/QA BLM Hardware (MPS) | 2012-03-05 → 2013-02-22 A (+354d) | 2012-04-13 → 2013-08-30 A (+504d) | 30d → 4d | 0% → 100% | 459d → none | 13641050 → 13641050 FS-45d |  |
| 13641014b | Proc Remaining Wire & Cable (MPS) | 2012-11-01 → 2013-04-01 A (+151d) | 2012-11-14 → 2013-06-17 A (+215d) | 10d → 44d | 0% → 100% | 372d → none | 9-130M FS+23d → 9-130M FS+100d |  |
| 13641040 | Develop/Install/Test FSD Software (MPS) | 2012-11-20 → 2013-06-03 A (+195d) | 2012-12-21 → 2013-08-30 A (+252d) | 22d → 25d | 0% → 100% | 347d → none | 13641030 FS-22d → 13641030 FS-80d |  |
| 13641060 | Install BLM Wire & Cable (MPS) | 2012-11-01 → 2013-06-03 A (+214d) | 2012-12-21 → 2013-08-30 A (+252d) | 35d → 84d | 0% → 100% | 347d → none | 16333030 FS-125d, 13641050 FS+170d, 16332030, 16332010U → 16332010U, 16332030, 16333030 FS-125d, 16332010, 13641050 FS-20d |  |
| 13641075 | Develop/Install/Test BLM Software (MPS) | 2013-03-18 → 2013-06-03 A (+77d) | 2013-05-15 → 2013-08-30 A (+107d) | 43d → 48d | 0% → 100% | 252d → none | 13641065 → 13641065 FS-70d |  |
| 13641025 | Install FSD Wire & Cable (MPS) FY12 | 2012-03-19 → 2013-08-30 A (+529d) | 2012-09-28 → 2013-08-30 A (+336d) | 137d → 51d | 0% → 100% | 352d → none | 3A-08M, 16332030, 16332010U, 13641014 → 16332010U, 16332010, 13641014, 16332030, 9-130M FS+100d, 3A-08M | resources ELEC TECH [154.88 h]; PLABOR; ELEC ENG [25.81 h] → ELEC ENG [25.81 h]; ELEC TECH [154.88 h]; PLABOR |
| 13641025b | Install FSD Wire & Cable (MPS) FY13 | 2012-10-01 → 2013-08-30 A (+333d) | 2012-10-17 → 2013-08-30 A (+317d) |  | 0% → 100% | 352d → none | 13641025 → 13641025 FS-13d | resources ELEC ENG [2.45 h]; ELEC TECH [14.7 h]; PLABOR → ELEC TECH [14.7 h]; PLABOR; ELEC ENG [2.45 h] |
| 13641030 | Install/Test FSD Hardware (MPS) | 2012-11-01 → 2013-08-30 A (+302d) | 2012-12-21 → 2013-08-30 A (+252d) | 35d → 8d | 0% → 100% | 347d → none | 1362020, 16332030, 13641020b FS+2d → 13641020b FS+54d, 16332030, 1362020 |  |
| 13641065 | Install BLM Hardware (MPS) | 2013-02-15 → 2013-08-30 A (+196d) | 2013-03-15 → 2013-08-30 A (+168d) | 20d → 11d | 0% → 100% | 252d → none | 1362020, 9-130M FS+90d, 16332030, 13641055 → 1362020, 9-130M FS+90d, 13641055 FS+35d, 16332030 | resources ELEC ENG [40 h]; ELEC TECH [160 h] → ELEC TECH [160 h]; ELEC ENG [40 h] |
| 13641095 | Install/Test Tagger/Hall D Beam Loss Monitoring Sys (MPS) | 2013-01-14 → 2013-08-30 A (+228d) | 2013-03-14 → 2013-08-30 A (+169d) | 42d → 37d | 0% → 100% | 296d → none | 16332010U, 16333030, 16332030, 9-130M FS+67d, 13641090 → 16332010U, 16332030, 13641090 FS-10d, 16333030, 9-130M FS+67d, 16332010 |  |
| 13641950 | Re-Baseline Actuals Adjustment | 2013-08-30 A | 2013-08-30 A |  | 0% → 100% | 20d → none | 9-130M FS+227d → none |  |
| 13641045M | FSD Sys Comp (MPS) | 2012-12-21 → 2013-08-30 A (+252d) | 2012-12-21 → 2013-08-30 A (+252d) |  | 0% → 100% | 347d → none |  |  |
| 13641080M | BLM Sys Comp (MPS) | 2013-05-15 → 2013-08-30 A (+107d) | 2013-05-15 → 2013-08-30 A (+107d) |  | 0% → 100% | 252d → none |  |  |
| 13641100M | Beam Loss Ion Chamb Sys Comp (MPS) | 2013-03-14 → 2013-08-30 A (+169d) | 2013-03-14 → 2013-08-30 A (+169d) |  | 0% → 100% | 296d → none |  |  |
| 23641020 | Test/QA FSD Hardware (MPS) | 2013-09-03 A | 2013-09-13 → 2013-09-27 A (+14d) |  | 0% → 100% | 119d → none |  |  |
| 23641040 | Develop/Install/Test FSD Software (MPS) FY13 | 2013-09-16 → 2013-09-03 A (-13d) | 2013-09-30 → 2013-10-21 A (+21d) | 11d → 34d | 0% → 100% | 133d → none |  |  |
| 23641040a | Develop/Install/Test FSD Software (MPS) FY14 | 2013-10-01 → 2013-09-03 A (-28d) | 2013-10-31 → 2013-10-21 A (-10d) |  | 0% → 100% | 133d → none | 9-130M FS+237d, 23641040 → 23641040 FS-40d |  |
| 23641055 | Test/QA BLM Hardware (MPS) FY13 | 2013-09-03 A | 2013-09-30 → 2013-11-27 (+58d) | 20d → 25d | 0% → 25% | 134d → 99d |  |  |
| 23641055a | Test/QA BLM Hardware (MPS) FY14 | 2013-10-01 → 2013-09-03 A (-28d) | 2013-10-07 → 2013-11-27 (+51d) |  | 0% → 25% | 134d → 99d | 23641055, 9-130M FS+228d → 23641055 FS-45d |  |
| 23641085 | Proc Tagger/Hall D Beam Loss Monitoring Hardware (MPS) | 2013-09-03 A | 2013-09-30 → 2013-11-15 (+46d) |  | 0% → 67% | 129d → 95d |  |  |
| 23641913LOE | FY13 Mngmnt & Elect Dsgn Supprt Effort for MPS | 2013-09-03 A | 2013-09-30 A |  | 0% → 100% | 142d → none |  |  |
| 23641025 | Install FSD Wire & Cable (MPS) FY13 | 2013-09-23 → 2013-09-16 A (-7d) | 2013-09-30 → 2013-11-15 (+46d) | 6d → 40d | 0% → 25% |  | 9-130M FS+242d → 9-130M SS+242d |  |
| 23641025a | Install FSD Wire & Cable (MPS) FY14 | 2013-10-01 → 2013-09-16 A (-15d) |  |  | 0% → 25% |  | 9-130M FS+242d, 23641025 → 23641025 FS-40d |  |
| 23641030a | Install/Test FSD Hardware for RF Installation(MPS) FY13 | 2013-09-16 A | 2013-09-30 → 2013-10-21 A (+21d) | 11d → 34d | 0% → 100% | 133d → none |  | was named Install/Test FSD Hardwarefor RF Installation(MPS) FY13 |
| 23641030aa | Install/Test FSD Hardware for RF Installation(MPS) FY14 | 2013-10-01 → 2013-09-16 A (-15d) | 2013-10-31 → 2013-10-21 A (-10d) |  | 0% → 100% | 133d → none | 23641030a, 9-130M FS+237d → 23641030a FS-40d | was named Install/Test FSD Hardwarefor RF Installation(MPS) FY14 |
| 23641100 | Rework FSD Cards | 2013-10-01 A |  |  | 0% → 40% |  |  |  |
| 23641065 | Install BLM Hardware (MPS) FY13 | 2013-09-03 → 2013-10-01 A (+28d) | 2013-09-30 → 2014-01-27 (+119d) | 20d → 37d | 0% → 33% | 99d → 58d | 23641055 FS-60d, 23641060 FS-57d, 23641060a FS-57d, 23641055a FS-60d → 23641060 FS-51d, 23641055a FS-60d, 23641055 FS-60d |  |
| 23641065a | Install BLM Hardware (MPS) FY14 | 2013-10-01 A | 2013-11-20 → 2014-01-27 (+68d) |  | 0% → 33% | 99d → 58d | 23641060 FS-57d, 23641055 FS-60d, 23641060a FS-57d, 23641065, 23641055a FS-60d → 23641065 FS-51d, 23641060a FS-57d, 23641055a FS-60d |  |
| 23641914LOE | FY14 Mngmnt & Elect Dsgn Supprt Effort for MPS | 2013-10-01 A |  |  | 0% → 14% |  |  |  |
| 23641060 | Install BLM Wire & Cable (MPS) FY13 | 2013-09-03 → 2013-10-08 A (+35d) | 2013-09-30 → 2013-11-20 (+51d) |  | 0% → 56% | 99d → 95d | 9-130M FS+228d → 9-140M |  |
| 23641060a | Install BLM Wire & Cable (MPS) FY14 | 2013-10-01 → 2013-10-08 A (+7d) |  | 37d → 12d | 0% → 56% | 99d → 101d | 9-130M FS+228d, 23641060 → 23641060 FS-20d |  |
| 23641087 | Install BLM Wire & Cable (MPS) Tagger Hall D FY13 | 2013-09-03 → 2013-10-08 A (+35d) | 2013-09-30 → 2014-01-13 (+105d) |  | 0% → 56% | 40d → 39d | 9-130M FS+228d → 9-140M |  |
| 23641087a | Install BLM Wire & Cable (MPS) Tagger Hall D FY14 | 2013-10-01 → 2013-10-08 A (+7d) |  | 65d → 22d | 0% → 56% | 40d → 39d | 9-130M FS+228d, 23641087 → 23641087 FS-42d |  |
| 23641095 | Install/Test Tagger/Hall D Beam Loss Monitoring Sys (MPS) | 2014-01-07 → 2013-10-11 A (-88d) | 2014-02-17 → 2014-02-18 (+1d) |  | 0% → 10% | 40d → 39d | 23641090 FS-4d, 23641090a FS-4d → 23641090a FS-60d, 23641090 FS-40d |  |
| 23641030 | Install/Test FSD Hardware (MPS) FY13 | 2013-09-03 → 2013-11-11 (+69d) | 2013-09-30 → 2013-12-10 (+71d) |  |  | 119d → 70d | 23641020 FS-9d → 23641020 FS+30d |  |
| 23641090 | Test/QA Tagger/Hall D Beam Loss Monitoring Hardware (MPS) FY13 | 2013-09-03 → 2013-11-12 (+70d) | 2013-09-30 → 2014-01-10 (+102d) | 20d → 34d |  | 40d → 39d | 23641087a FS-85d, 23641087 FS-85d → 23641087a FS-35d, 23641087 FS-35d |  |
| 23641090a | Test/QA Tagger/Hall D Beam Loss Monitoring Hardware (MPS) FY14 | 2013-10-01 → 2013-11-12 (+42d) |  | 64d → 34d |  | 40d → 59d | 23641087a FS-85d, 23641090, 23641087 FS-85d → 23641087a FS-45d, 23641090 FS-34d |  |
| 23641030b | Install/Test FSD Hardware (MPS) FY14 | 2013-10-01 → 2013-12-11 (+71d) | 2013-11-20 → 2014-02-12 (+84d) |  |  | 119d → 70d | 23641020 FS-9d, 23641030 → 23641030 |  |
| 23641075 | Develop/Install/Test BLM Software (MPS) | 2013-11-15 → 2014-01-28 (+74d) | 2013-12-20 → 2014-02-28 (+70d) |  |  | 99d → 58d | 23641065a FS-4d, 23641065 FS-4d → 23641065a, 23641065 FS-4d |  |
| 23641045M | FSD Sys Comp (MPS) | 2013-11-20 → 2014-02-12 (+84d) | 2013-11-20 → 2014-02-12 (+84d) |  |  | 119d → 70d |  |  |
| 23641100M | Beam Loss Ion Chamb Sys Comp (MPS) | 2014-02-17 → 2014-02-18 (+1d) | 2014-02-17 → 2014-02-18 (+1d) |  |  | 40d → 39d |  |  |
| 23641080M | BLM Sys Comp (MPS) | 2013-12-20 → 2014-02-28 (+70d) | 2013-12-20 → 2014-02-28 (+70d) |  |  | 99d → 58d |  |  |
| 13642909LOE | FY09 Mngmnt & Elect Dsgn Supprt Effort for BELS | 2009-01-02 A | 2009-09-30 A |  | 0% → 100% | 20d → none |  |  |

| ID | Task | Start | Finish | Duration | Complete | Total float | Predecessors | Other |
| --- | --- | --- | --- | --- | --- | --- | --- | --- |
| 13642910LOE | FY10 Mngmnt & Elect Dsgn Supprt Effort for BELS | 2009-10-01 A | 2010-09-30 A |  | 0% → 100% | 20d → none |  |  |
| 13642911LOE | FY11 Mngmnt & Elect Dsgn Supprt Effort for BELS | 2010-10-01 A | 2011-09-30 A |  | 0% → 100% | 20d → none |  | resources SR STAFF [36 h]; ELEC DES [36 h] → ELEC DES [36 h]; SR STAFF [36 h] |
| 13642912LOE | FY12 Mngmnt & Elect Dsgn Supprt Effort for BELS | 2011-10-03 A | 2012-09-28 A |  | 0% → 100% | 20d → none |  |  |
| 13642913LOE | FY13 Mngmnt & Elect Dsgn Supprt Effort for BELS | 2012-10-01 A | 2013-08-30 A | 228d → 248d | 0% → 100% | 20d → none |  |  |
| 13642014 | Proc BELS Hardware | 2012-01-05 → 2013-04-01 A (+452d) | 2012-04-20 → 2013-08-30 A (+497d) | 75d → 42d | 0% → 100% | 295d → none | 9-120M FS+60d, 121642070M, 121642170 → 9-120M FS+60d, 9-130M FS+100d, 121642070M, 121642170, 121642060 | resources PROCUREMENT<$50K 60; ELEC ENG [40 h] → ELEC ENG [40 h]; PROCUREMENT<$50K 60 |
| 13642005 | Develop/Install/Test BELS Software | 2013-05-21 → 2013-08-26 A (+97d) | 2013-07-02 → 2013-08-30 A (+59d) |  | 0% → 100% | 72d → none | 13642015, 13642020 FS-20d → 13642015, 13642020 FS-5d | resources COMP SCIENT [80 h]; ELEC ENG [80 h] → ELEC ENG [80 h]; COMP SCIENT [80 h] |
| 13642015 | Test/QA BELS Compnts | 2013-03-19 → 2013-08-30 A (+164d) | 2013-04-17 → 2013-08-30 A (+135d) | 22d → 23d | 0% → 100% | 72d → none | 13642014, 13642019, 9-130M FS+111d → 13642014 FS+35d, 13642019 FS-25d | resources ELEC ENG [40 h]; ELEC TECH [160 h] → ELEC TECH [160 h]; ELEC ENG [40 h] |
| 13642019 | Proc Remaining BELS Hardware | 2013-01-17 → 2013-08-30 A (+225d) | 2013-03-15 → 2013-08-30 A (+168d) | 40d → 35d | 0% → 100% | 73d → none | 9-130M FS+70d → 9-130M FS+193d |  |
| 13642020 | Install BELS Hardware | 2013-04-18 → 2013-08-30 A (+134d) | 2013-06-18 → 2013-08-30 A (+73d) | 43d → 42d | 0% → 100% | 72d → none | 13642015, 16332030, 9-130M FS+45d → 16332030, 9-130M FS+45d, 13642015 FS-40d | resources PLABOR; ELEC ENG [40 h]; ELEC TECH [240 h] → ELEC TECH [240 h]; PLABOR; ELEC ENG [40 h] |
| 13642950 | Re-Baseline Actuals Adjustment | 2013-08-30 A | 2013-08-30 A |  | 0% → 100% | 20d → none | 9-130M FS+227d → none |  |
| 13642030M | BELS Sys Comp | 2013-07-02 → 2013-08-30 A (+59d) | 2013-07-02 → 2013-08-30 A (+59d) |  | 0% → 100% | 72d → none |  |  |
| 23642913LOE | FY13 Mngmnt & Elect Dsgn Supprt Effort for BELS | 2013-09-03 A | 2013-09-30 A |  | 0% → 100% | 142d → none |  |  |
| 23642005 | Develop/Install/Test BELS Software | 2013-10-14 → 2013-10-01 A (-13d) | 2014-01-03 → 2013-12-20 (-14d) |  |  | 70d → 72d | 23642020 FS-120d, 23642015 FS-53d → 23642015 FS-60d, 23642020 FS-120d |  |
| 23642014 | Proc BELS Hardware | 2013-10-01 A | 2013-11-12 → 2013-11-18 (+6d) |  |  |  |  |  |
| 23642914LOE | FY14 Mngmnt & Elect Dsgn Supprt Effort for BELS | 2013-10-01 A |  |  | 0% → 14% |  |  |  |
| 23642015 | Test/QA BELS Compnts | 2013-10-29 → 2013-11-11 (+13d) | 2014-01-08 → 2014-01-22 (+14d) |  |  | 21d → 16d |  |  |
| 23642019 | Proc Remaining BELS Hardware | 2013-10-01 → 2013-11-12 (+42d) | 2013-12-11 → 2014-01-03 (+23d) | 50d → 29d |  | 21d → 16d | 9-140M → 9-140M FS+30d |  |
| 23642020 | Install BELS Hardware | 2014-02-13 → 2014-02-20 (+7d) | 2014-03-14 → 2014-03-21 (+7d) |  |  | 21d → 16d | 23642015 FS+24d, 9-130M FS+228d → 23642015 FS+20d |  |
| 23642030M | BELS Sys Comp | 2014-03-14 → 2014-03-21 (+7d) | 2014-03-14 → 2014-03-21 (+7d) |  |  | 21d → 16d |  |  |
| 13643909LOE | FY09 Mngmnt & Supprt Effort for PSS | 2009-01-02 A | 2009-09-30 A |  | 0% → 100% | 20d → none |  | resources ELEC DES [18.29 h]; ELEC ENG [9.15 h]; OFFICE [18.29 h]; SR STAFF [6.1 h] → OFFICE [18.29 h]; ELEC ENG [9.15 h]; SR STAFF [6.1 h]; ELEC DES [18.29 h] |
| 13643910LOE | FY10 Mngmnt & Supprt Effort for PSS | 2009-10-01 A | 2010-09-30 A |  | 0% → 100% | 20d → none |  | resources OFFICE [24 h]; ELEC DES [24 h]; ELEC ENG [12 h]; SR STAFF [8 h] → ELEC ENG [12 h]; OFFICE [24 h]; SR STAFF [8 h]; ELEC DES [24 h] |
| 13643040a | Proc Local Cable, Conduit, Infrastructure for RF Installation (PSS) | 2010-12-07 → 2010-05-03 A (-218d) | 2011-04-01 → 2010-06-30 A (-275d) | 76d → 42d | 0% → 100% | 83d → none | 9-110M FS+45d → 9-110M FS-100d |  |
| 13643045a | Install Linac Cable Conduit, Infrastructure for RF Installation (PSS) | 2011-05-02 → 2010-07-01 A (-305d) | 2011-07-01 → 2010-07-26 A (-340d) | 44d → 17d | 0% → 100% | 83d → none | 13643040a FS+20d → 13643040a FS+80d |  |
| 13643911LOE | FY11 Mngmnt & Supprt Effort for PSS | 2010-10-01 → 2010-08-23 A (-39d) | 2011-09-30 A | 248d → 276d | 0% → 100% | 20d → none | 13643910LOE → 13643910LOE FS-20d | resources ELEC ENG [196 h]; ELEC DES [396 h]; OFFICE [24 h]; SR STAFF [88 h] → ELEC DES [396 h]; OFFICE [24 h]; ELEC ENG [196 h]; SR STAFF [88 h] |
| 13643040 | Proc Local Cable, Conduit, Infrastructure (PSS) Labor FY11 (FY12 @ 13643040b) | 2010-12-07 → 2010-09-01 A (-97d) | 2011-09-30 → 2013-08-30 A (+700d) | 203d → 584d | 0% → 100% | 35d → none | 121643140, 9-110M FS+45d → 9-110M, 121643140 |  |
| 13643040b | Proc Local Cable, Conduit, Infrastructure (PSS) Labor FY12 (FY11 @ 13643040) | 2011-10-03 → 2010-09-01 A (-397d) | 2011-12-01 → 2012-11-12 A (+347d) | 42d → 547d | 0% → 100% | 35d → none | 13643040 → 13643040 FS-95d |  |
| 13643040c | Proc Local Cable, Conduit, Infrastructure (PSS) Labor Procurement | 2010-12-07 → 2010-09-01 A (-97d) | 2011-12-01 → 2012-11-12 A (+347d) | 245d → 547d | 0% → 100% | 35d → none | 9-110M FS+45d, 121643140 → 121643140, 9-110M |  |
| 13643030 | Proc Custom Compnts (Run/Safe, Interface Chassis) (PSS) Labor FY11(FY12 @ 13643030b) | 2010-10-01 A | 2011-09-30 → 2012-03-19 A (+171d) | 248d → 358d | 0% → 100% | 173d → none |  | resources PLABOR; ELEC ENG [7.31 h]; ELEC TECH [14.62 h] → ELEC ENG [7.31 h]; ELEC TECH [14.62 h]; PLABOR |
| 13643030a | Proc Custom Compnts (Run/Safe, Interface Chassis) for RF Installation (PSS) | 2010-10-01 A | 2011-01-21 → 2011-03-25 A (+63d) | 72d → 116d | 0% → 100% | 173d → none |  | resources ELEC TECH [60 h]; PLABOR; ELEC ENG [20 h]; PROCUREMENT<$50K 60 → PLABOR; PROCUREMENT<$50K 60; ELEC TECH [60 h]; ELEC ENG [20 h] |
| 13643030b | Proc Custom Compnts (Run/Safe, Interface Chassis) (PSS) Labor FY12 (FY11 @ 13643030) | 2011-10-03 → 2010-10-01 A (-367d) | 2012-09-21 → 2012-03-19 A (-186d) | 242d → 359d | 0% → 100% | 173d → none | 13643030 → 13643030 FS-245d |  |
| 13643030c | Proc Custom Compnts (Run/Safe, Interface Chassis) (PSS) Procurement | 2010-10-01 A | 2012-09-21 → 2012-03-19 A (-186d) | 490d → 359d | 0% → 100% | 173d → none |  |  |
| 13643035 | Test/QA Custom Compnts (PSS) FY11 (FY12 @ 13643035b) | 2010-11-12 → 2010-11-01 A (-11d) | 2011-09-30 → 2012-04-16 A (+199d) | 218d → 357.07d | 0% → 100% | 173d → none |  |  |
| 13643035b | Test/QA Custom Compnts (PSS) FY12 (FY11 @ 13643035) | 2011-10-03 → 2010-11-01 A (-336d) | 2012-09-28 → 2013-02-13 A (+138d) | 247d → 542d | 0% → 100% | 173d → none | 13643035 → 13643035 FS-275d |  |
| 13643035ba | Test/QA Custom Compnts (PSS) FY13 | 2012-10-01 → 2010-11-01 A (-700d) | 2012-11-02 → 2013-02-14 A (+104d) | 25d → 542d | 0% → 100% | 173d → none | 13643035b → 13643035b FS-50d |  |
| 13643160 | Create & Simulate PSS Logic Programs | 2010-10-01 → 2010-11-01 A (+31d) | 2011-03-03 → 2013-08-30 A (+911d) | 100d → 543d | 0% → 100% | 673d → none |  |  |
| 13643020a | Proc PLC Systems for RF Installation (PSS) | 2010-11-01 → 2010-11-15 A (+14d) | 2011-01-05 → 2011-01-27 A (+22d) | 40d → 45d | 0% → 100% | 742d → none |  |  |
| 13643035a | Test/QA Custom Compnts for RF Installation (PSS) FY11 | 2011-01-24 → 2011-01-04 A (-20d) | 2011-09-30 → 2011-02-10 A (-232d) | 176d → 27d | 0% → 100% | 173d → none | 13643030a → 13643030a FS-20d |  |
| 13643035ab | Test/QA Custom Compnts for RF Installation (PSS) FY12 | 2011-10-03 → 2011-01-04 A (-272d) | 2012-09-28 → 2011-02-10 A (-596d) | 247d → 27d | 0% → 100% | 173d → none |  |  |
| 13643035abb | Test/QA Custom Compnts for RF Installation (PSS) FY13 | 2012-10-01 → 2011-01-04 A (-636d) | 2012-11-02 → 2011-02-10 A (-631d) | 25d → 27d | 0% → 100% | 173d → none |  |  |
| 13643045 | Install Linac Cable Conduit, Infrastructure (PSS) FY12 | 2012-01-23 → 2011-03-25 A (-304d) | 2012-09-28 → 2013-05-13 A (+227d) | 176d → 443d | 0% → 100% | 174d → none | 13643040c, 13643040b, 3A-07M, 16332030, 16331030, 16331032 → 13643040c FS-200d, 16332030 FS-200d, 16331032, 13643040b FS-200d, 3A-07M FS-200d, 16331030 | resources ELEC TECH [567.85 h]; ELEC DES [56.79 h]; SKLLD TRADE [369.1 h]; PLABOR → SKLLD TRADE [369.1 h]; ELEC TECH [567.85 h]; ELEC DES [56.79 h]; PLABOR |
| 13643045b | Install Linac Cable Conduit, Infrastructure (PSS) FY13 | 2012-10-01 → 2011-03-25 A (-556d) | 2012-11-01 → 2013-05-13 A (+193d) | 24d → 443d | 0% → 100% | 174d → none | 13643045 → 13643045 FS-50d |  |
| 13643050 | Proc COTS Compnts (Access Control, Video,etc) (PSS) Labor FY11 | 2011-01-05 → 2011-03-25 A (+79d) | 2011-09-30 → 2012-12-17 A (+444d) | 188d → 438d | 0% → 100% | 328d → none | 9-110M FS+60d, 121643140 → 121643170, 121643140, 9-110M FS+60d | resources ELEC TECH [184.16 h]; ELEC ENG [245.55 h] → ELEC ENG [245.55 h]; ELEC TECH [184.16 h] |
| 13643050a | Proc COTS Compnts (Access Control, Video,etc) (PSS) Labor FY12 | 2011-10-03 → 2011-03-25 A (-192d) | 2011-12-29 → 2012-12-17 A (+354d) | 57d → 438d | 0% → 100% | 328d → none | 13643050 → 13643050 FS-145d | resources ELEC TECH [55.84 h]; ELEC ENG [74.45 h] → ELEC ENG [74.45 h]; ELEC TECH [55.84 h] |
| 13643050b | Proc COTS Compnts (Access Control, Video,etc) (PSS) Procurement | 2011-01-05 → 2011-03-25 A (+79d) | 2011-12-29 → 2012-12-17 A (+354d) | 245d → 438d | 0% → 100% | 328d → none | 9-110M FS+60d, 121643140 → 121643170, 9-110M FS+60d, 121643140 |  |
| 13643110 | Proc PSS Beam Current Monitor Compnts | 2012-01-05 → 2011-03-25 A (-286d) | 2012-07-10 → 2012-07-09 A (-1d) | 130d → 322d | 0% → 100% | 385d → none | 9-120M FS+60d, 121643140 → 121643170, 121643140 |  |
| 13643025a | Test/QA PLC Systems for RF Installation (PSS) | 2011-01-06 → 2011-05-01 A (+115d) | 2011-02-17 → 2011-05-23 A (+95d) | 30d → 16d | 0% → 100% | 742d → none |  | resources ELEC TECH [16 h]; ELEC ENG [24 h] → ELEC ENG [24 h]; ELEC TECH [16 h] |
| 13643075 | Install RF, Mag Interfaces (PSS) | 2011-12-01 → 2011-05-16 A (-199d) | 2012-01-20 → 2012-07-16 A (+178d) | 30d → 291d | 0% → 100% | 554d → none | 16111025, 16332030, 13224020 → 16111025, 13224020 FS-20d, 16332030 FS-300d | resources ELEC TECH [120 h]; ELEC ENG [120 h] → ELEC ENG [120 h]; ELEC TECH [120 h] |
| 13643080 | Upgrade Existing PLC Sys in Linacs (PSS) | 2012-05-14 → 2011-05-16 A (-364d) | 2012-07-10 → 2012-12-17 A (+160d) | 40d → 416d | 0% → 100% | 435d → none | 13643025, 13643025a, 2-02M → 13643025 FS-235d, 13643025a |  |
| 13643165a | Install & Test PSS Logic Programs for Linac RF Upgrade | 2011-07-25 → 2011-06-15 A (-40d) | 2011-08-01 → 2011-08-08 A (+7d) | 6d → 38d | 0% → 100% | 83d → none | 13643045a FS+14d → 13643045a FS+246d |  |
| 13643912LOE | FY12 Mngmnt & Supprt Effort for PSS | 2011-10-03 A | 2012-09-28 A |  | 0% → 100% | 20d → none |  | resources OFFICE [24 h]; SR STAFF [88 h]; ELEC ENG [196 h]; ELEC DES [396 h] → ELEC ENG [196 h]; ELEC DES [396 h]; OFFICE [24 h]; SR STAFF [88 h] |
| 13643085 | Fab & Install Tagger Bldg. Racks (PSS) | 2011-12-01 → 2012-01-03 A (+33d) | 2012-01-20 → 2012-08-20 A (+213d) | 30d → 161d | 0% → 100% | 6d → none | 16332030 → 16332030 FS-250d | resources ELEC ENG [40 h]; ELEC TECH [80 h]; PLABOR → ELEC ENG [40 h]; PLABOR; ELEC TECH [80 h] |
| 13643090 | Fab & Install H-D Racks PSS | 2011-12-01 → 2012-01-03 A (+33d) | 2012-01-20 → 2012-08-20 A (+213d) | 30d → 161d | 0% → 100% | 6d → none | 16332030 → 16332030 FS-250d | resources PLABOR; ELEC ENG [40 h]; ELEC TECH [80 h] → ELEC ENG [40 h]; ELEC TECH [80 h]; PLABOR |
| 13643014 | Let Endstation PSS Cable Plant Contract | 2012-01-05 → 2012-02-01 A (+27d) | 2012-03-02 → 2012-03-19 A (+17d) | 40d → 33d | 0% → 100% | 312d → none | 9-120M FS+60d, 16332030 FS-60d → 121643170, 16332030 FS-60d, 9-120M FS+60d |  |
| 13643055 | Test/QA COTS Compnts (PSS) | 2011-12-30 → 2012-03-02 A (+63d) | 2012-03-27 → 2013-03-11 A (+349d) | 60d → 214d | 0% → 100% | 328d → none | 13643050a, 13643050b → 13643050b FS-80d, 13643050a FS-80d | resources ELEC ENG [40 h]; ELEC TECH [400 h] → ELEC TECH [400 h]; ELEC ENG [40 h] |
| 13643145 | Install & Test Access Control Sys (PSS) | 2012-12-17 → 2012-03-15 A (-277d) | 2013-03-20 → 2013-08-30 A (+163d) | 60d → 366d | 0% → 100% | 145d → none | 16331030, 16333030, 16331032, 13643035abb, 13643035ba, 13643055, 13643045b, 13643210, 16332030 → 16333030, 13643035ab, 13643035ba FS-165d, 13643045b FS-165d, 16331032, 16331030, 13643055 FS-125d, 13643210 FS-180d, 13643035abb, 16332030 |  |
| 13643015 | PSS Cable Plant Installtn (Contract Oversight) | 2012-03-05 → 2012-04-02 A (+28d) | 2012-03-30 → 2012-05-14 A (+45d) | 20d → 31d | 0% → 100% | 312d → none |  | resources ELEC TECH [40 h]; ELEC ENG [80 h] → ELEC ENG [80 h]; ELEC TECH [40 h] |
| 13643210 | Cable Plant - Field Termination (PSS) | 2012-11-28 → 2012-06-01 A (-180d) | 2012-12-14 → 2013-08-30 A (+259d) | 13d → 156d | 0% → 100% | 145d → none | 13643015, 9-130M FS+40d → 13643015 |  |
| 13643115 | Test/QA PSS Beam Current Monitor Compnts | 2012-07-11 → 2012-06-11 A (-30d) | 2012-08-07 → 2013-08-30 A (+388d) | 20d → 133d | 0% → 100% | 385d → none | 13643110 → 13643110 FS-15d |  |
| 13643125 | Proc ODH Monitoring Sys (PSS) | 2011-10-03 → 2012-07-09 A (+280d) | 2011-11-11 → 2012-08-20 A (+283d) | 30d → 31d | 0% → 100% | 415d → none | 9-120M, 121643140 → 121643140, 121643170, 9-120M FS+190d |  |
| 13643215 | Tagger ODH Management Oversight FY12 | 2012-08-01 A | 2012-09-28 → 2013-03-11 A (+164d) | 42d → 121d | 0% → 100% | 344d → none |  |  |
| 13643215a | Tagger ODH Management Oversight FY13 | 2012-10-01 → 2012-08-01 A (-61d) | 2012-11-16 → 2013-03-11 A (+115d) | 35d → 121d | 0% → 100% | 344d → none | 13643215 → 13643215 FS-75d |  |
| 13643220 | Change Control Process | 2012-08-01 A | 2012-08-10 A |  | 0% → 100% | 412d → none |  | resources SCIENTIST [4 h]; ELEC ENG [4 h] → ELEC ENG [4 h]; SCIENTIST [4 h] |
| 13643240 | 5 C Line ODH Procurements | 2012-08-08 → 2012-08-01 A (-7d) | 2012-09-28 → 2012-09-26 A (-2d) | 37d → 39d | 0% → 100% | 362d → none |  |  |
| 13643255 | Hall D ODH Procurements | 2012-08-08 → 2012-08-01 A (-7d) | 2012-09-28 → 2012-09-17 A (-11d) | 37d → 32d | 0% → 100% | 344d → none |  |  |
| 13643280 | EPICS Interface Development FY12 | 2012-09-21 → 2012-08-15 A (-37d) | 2012-09-28 → 2013-08-30 A (+336d) | 6d → 111d | 0% → 100% | 364d → none | 9-120M FS+241d → 9-120M |  |
| 13643280a | EPICS Interface Development FY13 | 2012-10-01 → 2012-08-15 A (-47d) | 2012-10-18 → 2013-08-30 A (+316d) | 14d → 111d | 0% → 100% | 364d → none | 13643280 → 13643280 FS-40d |  |
| 13643130 | Test/QA ODH Monitoring Sys (PSS) | 2011-11-14 → 2012-08-20 A (+280d) | 2012-01-04 → 2012-12-17 A (+348d) | 30d → 80d | 0% → 100% | 415d → none |  | resources ELEC TECH [80 h]; ELEC ENG [40 h] → ELEC ENG [40 h]; ELEC TECH [80 h] |
| 13643225 | Design 5C Line ODH Monitoring | 2012-08-01 → 2012-08-20 A (+19d) | 2012-08-15 → 2012-11-13 A (+90d) | 11d → 61d | 0% → 100% | 344d → none |  |  |
| 13643230 | Design HD Tagger ODH Monitoring | 2012-08-01 → 2012-08-20 A (+19d) | 2012-08-15 → 2012-09-14 A (+30d) | 11d → 18d | 0% → 100% | 344d → none |  | resources ELEC TECH [20 h]; ELEC DES [8 h]; ELEC ENG [30 h] → ELEC ENG [30 h]; ELEC TECH [20 h]; ELEC DES [8 h] |
| 13643235 | Design Review (Internal) | 2012-08-16 → 2012-08-27 A (+11d) | 2012-08-16 → 2012-09-10 A (+25d) | 1d → 9d | 0% → 100% | 344d → none | 13643230, 13643225 → 13643225 FS-10d, 13643230 FS-10d |  |

| ID | Task | Start | Finish | Duration | Complete | Total float | Predecessors | Other |
| --- | --- | --- | --- | --- | --- | --- | --- | --- |
| 13643135 | Install & Test ODH Monitoring Sys (PSS) | 2012-01-05 → 2012-08-28 A (+236d) | 2012-02-16 → 2012-12-17 A (+305d) | 30d → 81d | 0% → 100% | 415d → none | 16333030, 13643130, 16332010U → 16332010U, 16332010, 16333030, 13643130 FS-50d |  |
| 13643260 | Hall D ODH Installation | 2012-10-01 → 2012-08-28 A (-34d) | 2012-10-31 → 2012-12-17 A (+47d) | 23d → 77d | 0% → 100% | 344d → none | 13643255 → 13643255 FS-20d |  |
| 13643270 | QA Equipment FY12 | 2012-09-10 → 2012-09-03 A (-7d) | 2012-09-28 → 2012-12-17 A (+80d) | 15d → 74d | 0% → 100% | 358d → none |  |  |
| 13643270a | QA Equipment FY13 | 2012-10-01 → 2012-09-03 A (-28d) | 2012-10-26 → 2012-12-17 A (+52d) | 20d → 74d | 0% → 100% | 358d → none | 13643270 → 13643270 FS-40d |  |
| 13643275 | Modify PSS Racks FY12 | 2012-09-21 → 2012-09-17 A (-4d) | 2012-09-28 → 2012-10-15 A (+17d) | 6d → 21d | 0% → 100% | 372d → none |  |  |
| 13643275a | Modify PSS Racks FY13 | 2012-10-01 → 2012-09-17 A (-14d) | 2012-10-08 → 2012-10-15 A (+7d) | 6d → 21d | 0% → 100% | 372d → none | 13643275 → 13643275 FS-15d |  |
| 13643325 | Install Local Alarms | 2012-10-19 → 2012-09-17 A (-32d) | 2012-11-15 → 2012-11-12 A (-3d) | 20d → 41d | 0% → 100% | 344d → none | 13643260 FS-9d → 13643260 FS-25d |  |
| 13643245 | 5 C Line ODH Installation FY12 | 2012-08-23 → 2012-09-24 A (+32d) | 2012-09-28 → 2013-02-15 A (+140d) | 26d → 59d | 0% → 100% | 362d → none |  | resources ELEC ENG [2.48 h]; ELEC TECH [37.14 h]; SKLLD TRADE [14.86 h] → SKLLD TRADE [14.86 h]; ELEC ENG [2.48 h]; ELEC TECH [37.14 h] |
| 13643245a | 5 C Line ODH Installation FY13 | 2012-10-01 → 2012-09-24 A (-7d) | 2012-10-22 → 2013-02-15 A (+116d) | 16d → 58d | 0% → 100% | 362d → none | 13643245 → 13643245 FS-20d |  |
| 13643020 | Proc PLC Systems (PSS) | 2011-11-01 → 2012-10-01 A (+335d) | 2012-01-05 → 2012-12-17 A (+347d) | 40d → 69d | 0% → 100% | 494d → none | 9-120M FS+21d, 121643140 → 9-110M, 121643140, 9-130M FS+15d, 9-120M FS+151d |  |
| 13643020b | Proc Remaining Cable and PLC Systems | 2012-11-01 → 2012-10-01 A (-31d) | 2012-12-05 → 2013-08-28 A (+266d) | 23d → 69d | 0% → 100% | 494d → none |  |  |
| 13643913LOE | FY13 Mngmnt & Supprt Effort for PSS | 2012-10-01 A | 2013-08-30 A | 228d → 248d | 0% → 100% | 20d → none |  | resources OFFICE [22.06 h]; SR STAFF [80.9 h]; ELEC ENG [180.19 h]; ELEC DES [364.07 h] → ELEC DES [364.07 h]; OFFICE [22.06 h]; SR STAFF [80.9 h]; ELEC ENG [180.19 h] |
| 13643320 | Program Local Electronics | 2012-10-19 → 2012-10-05 A (-14d) | 2012-11-15 → 2012-12-09 A (+24d) | 20d → 45d | 0% → 100% | 344d → none | 13643260 FS-9d → 13643260 FS-15d |  |
| 13643330 | Install Alarm Segment Interface | 2012-10-26 → 2012-10-08 A (-18d) | 2012-11-15 → 2012-12-09 A (+24d) | 15d → 44d | 0% → 100% | 344d → none | 13643325 FS-15d → 13643325 FS-25d |  |
| 13643137 | Complete the Install & Test of ODH Monitoring Sys (PSS) | 2012-11-01 → 2012-11-05 A (+4d) | 2012-12-07 → 2012-12-17 A (+10d) | 25d → 28d | 0% → 100% | 210d → none |  |  |
| 13643335 | Software Checkout | 2012-11-01 → 2012-11-12 A (+11d) | 2012-11-15 → 2012-12-14 A (+29d) | 11d → 22d | 0% → 100% | 344d → none |  | resources ELEC ENG [8 h]; COMP SCIENT [8 h]; ELEC TECH [4 h] → ELEC TECH [4 h]; ELEC ENG [8 h]; COMP SCIENT [8 h] |
| 13643340 | Test and Commission | 2012-11-12 → 2012-12-02 A (+20d) | 2012-11-15 → 2012-12-14 A (+29d) | 4d → 9d | 0% → 100% | 344d → none |  |  |
| 13643140 | Upgrade MCC Console (PSS) | 2012-02-17 → 2013-01-07 A (+325d) | 2012-02-24 → 2013-08-30 A (+553d) |  | 0% → 100% | 530d → none |  | resources ELEC TECH [120 h]; ELEC ENG [20 h] → ELEC ENG [20 h]; ELEC TECH [120 h] |
| 13643150 | Proc Equipment for H-A, B, C Upgrades (PSS) | 2012-01-05 → 2013-01-07 A (+368d) | 2012-02-16 → 2013-08-30 A (+561d) | 30d → 21d | 0% → 100% | 373d → none | 9-120M FS+60d, 121643140, 2-02M FS-175d → 2-02M FS-175d, 9-120M FS+60d, 121643140, 9-130M FS+70d |  |
| 13643350 | PSS PLC Communications - Labor | 2012-11-01 → 2013-02-14 A (+105d) | 2013-07-15 → 2013-08-30 A (+46d) |  | 0% → 100% | 95d → none | 9-130M FS+23d → 9-130M FS+80d |  |
| 13643205 | Install Public Address Sys (PSS) | 2012-12-17 → 2013-02-21 A (+66d) | 2013-02-05 → 2013-08-30 A (+206d) |  | 0% → 100% | 175d → none | 16332030, 16331030, 16333030, 16331032, 16332010U, 13643210 → 16331030, 16331032, 16332010, 13643210 FS-70d, 16332030, 16332010U, 16333030 | resources ELEC ENG [40 h]; ELEC TECH [160 h] → ELEC TECH [160 h]; ELEC ENG [40 h] |
| 13643345 | 5C Line ODH Extension Complete | 2012-11-16 → 2013-03-01 A (+105d) | 2012-11-16 → 2013-03-01 A (+105d) |  | 0% → 100% | 344d → none | 13643220, 13643340, 13643215a FS-1d, 13643270a, 13643330, 13643275a, 13643235 FS-7d, 13643245a, 13643255, 13643280a, 13643335 → 13643340, 13643245a, 13643335, 13643220, 13643255, 13643215a FS-1d, 13643270a, 13643275a, 13643235 FS-7d, 13643330, 13643280a FS-10d |  |
| 13643025 | Test/QA PLC Systems (PSS) | 2012-01-06 → 2013-03-04 A (+423d) | 2012-02-17 → 2013-08-30 A (+560d) | 30d → 27d | 0% → 100% | 494d → none | 13643020b FS-232d, 13643020 → 13643020b FS-70d, 13643020 |  |
| 13643095 | Proc Matrl's for Beam Stoppers & Diffusers (PSS) | 2012-01-05 → 2013-03-04 A (+424d) | 2012-03-02 → 2013-08-19 A (+535d) | 40d → 44d | 0% → 100% | 453d → none | 121643140, 9-120M FS+60d → 121643170, 121643140, 9-130M FS+105d, 9-120M FS+229d | resources MECH TECH [40 h]; PROCUREMENT<$50K 60; ELEC ENG [80 h] → PROCUREMENT<$50K 60; MECH TECH [40 h]; ELEC ENG [80 h] |
| 13643060 | Proc Beam Transport Monitor Compnts (PSS) | 2012-01-05 → 2013-04-01 A (+452d) | 2012-03-02 → 2013-08-30 A (+546d) | 40d → 22d | 0% → 100% | 471d → none | 9-120M FS+60d, 121643140 → 121643170, 121643140, 9-130M FS+100d, 9-120M FS+152d |  |
| 13643360 | C-100 RF Commissioning PSS Support | 2012-11-13 → 2013-04-01 A (+139d) | 2013-08-23 → 2013-08-30 A (+7d) | 192d → 98d | 0% → 100% | 14d → none | 9-130M FS+31d → 9-130M |  |
| 13643355 | PSS PLC Communications - Procurements | 2013-02-01 → 2013-05-01 A (+89d) | 2013-04-30 → 2013-08-30 A (+122d) |  | 0% → 100% | 95d → none |  |  |
| 13643100 | Fab & Test Beam Stoppers & Diffusers (PSS) | 2012-03-05 → 2013-06-03 A (+455d) | 2012-05-11 → 2013-08-30 A (+476d) | 50d → 37d | 0% → 100% | 453d → none | 13643095 → 13643095 FS-20d | resources MECH DES [40 h]; MECH TECH [200 h]; MSHOP; ELEC ENG [120 h]; ELEC TECH [80 h]; COMP SCIENT [80 h] → MECH DES [40 h]; MECH TECH [200 h]; ELEC ENG [120 h]; MSHOP; ELEC TECH [80 h]; COMP SCIENT [80 h] |
| 13643120 | Install & Test PSS Beam Current Monitor | 2012-08-08 → 2013-07-08 A (+334d) | 2012-09-19 → 2013-08-30 A (+345d) | 30d → 67d | 0% → 100% | 385d → none | 16333030, 13643115 → 16333030, 13643115 FS-25d | resources ELEC TECH [120 h]; ELEC ENG [40 h]; MECH TECH [80 h]; COMP SCIENT [80 h] → COMP SCIENT [80 h]; ELEC ENG [40 h]; MECH TECH [80 h]; ELEC TECH [120 h] |
| 13643172M | Linac RF PSS Systems Comp | 2011-08-11 → 2013-08-19 A (+739d) | 2011-08-11 → 2013-08-19 A (+739d) |  | 0% → 100% | 83d → none | 13643165a FS+8d → 13643080, 13643165a FS+180d |  |
| 13643065 | Fab & Test Beam Transport Monitor (PSS) | 2012-03-05 → 2013-08-30 A (+543d) | 2012-04-13 → 2013-08-30 A (+504d) | 30d → 21d | 0% → 100% | 471d → none |  |  |
| 13643070 | Install Beam Transport Monitor (PSS) | 2013-05-13 → 2013-08-30 A (+109d) | 2013-06-14 → 2013-08-30 A (+77d) | 24d → 42d | 0% → 100% | 204d → none | 9-130M FS+150d, 13643065, 13643210 → 13643065, 9-140M, 13643210 |  |
| 13643105 | Install Beam Stoppers & Diffusers (PSS) | 2013-05-06 → 2013-08-30 A (+116d) | 2013-06-05 → 2013-08-30 A (+86d) | 22d → 24d | 0% → 100% | 211d → none | 13643210, 16333030, 13643100, 9-130M FS+145d → 13643210, 16333030, 9-130M FS+145d, 13643100 FS+25d |  |
| 13643155 | Install & Test H-A, B, C Upgrades (PSS) | 2013-07-01 → 2013-08-30 A (+60d) | 2013-08-28 → 2013-08-30 A (+2d) | 42d → 45d | 0% → 100% | 32d → none | 13643150, 2-02M, 9-130M FS+184d → 13643150, 2-02M |  |
| 13643165 | Install & Test PSS Logic Programs | 2012-01-23 → 2013-08-30 A (+585d) | 2012-06-13 → 2013-08-30 A (+443d) | 100d → 44d | 0% → 100% | 454d → none | 13643085, 13643160, 13643090 → 9-130M FS+184d, 13643160, 13643090, 13643085 |  |
| 13643170M | Linac PSS Systems Comp | 2012-11-02 → 2013-08-30 A (+301d) | 2012-11-02 → 2013-08-30 A (+301d) |  | 0% → 100% | 353d → none |  |  |
| 13643950 | Re-Baseline Actuals Adjustment | 2013-08-30 A | 2013-08-30 A |  | 0% → 100% | 20d → none | 9-130M FS+227d → none |  |
| 13643175M | Halls A, B, C PSS Systems Comp | 2013-08-28 → 2013-08-30 A (+2d) | 2013-08-28 → 2013-08-30 A (+2d) |  | 0% → 100% | 32d → none |  |  |
| 13643180M | Tagger Bldng PSS Systems Comp | 2013-03-20 → 2013-08-30 A (+163d) | 2013-03-20 → 2013-08-30 A (+163d) |  | 0% → 100% | 145d → none |  |  |
| 13643185M | H-D PSS Systems Comp | 2013-03-20 → 2013-08-30 A (+163d) | 2013-03-20 → 2013-08-30 A (+163d) |  | 0% → 100% | 145d → none |  |  |
| 23643020b | Proc Remaining Cable and PLC Systems | 2013-09-03 A | 2013-10-31 → 2013-10-21 A (-10d) |  | 0% → 100% | 76d → none |  | resources PROCUREMENT<$50K 60 NO ESCALATION FY14; PROCUREMENT>$50K 69 NO ESCALATION → PROCUREMENT<$50K 60 |
| 23643045 | Install Linac Cable Conduit, Infrastructure (PSS) FY13 | 2013-09-03 A | 2013-09-30 → 2013-11-15 (+46d) | 20d → 32d |  | 76d → 88d |  |  |
| 23643045a | Install Linac Cable Conduit, Infrastructure (PSS) FY14 | 2013-10-01 → 2013-09-03 A (-28d) | 2013-10-16 → 2013-11-15 (+30d) |  |  | 76d → 88d | 23643020b FS-43d, 23643045 → 23643045 FS-20d |  |
| 23643100 | Fab & Test Beam Stoppers & Diffusers (PSS) FY13 | 2013-09-03 A | 2013-09-30 → 2013-11-20 (+51d) | 20d → 24d | 0% → 86% | 112d → 101d |  |  |
| 23643100a | Fab & Test Beam Stoppers & Diffusers (PSS) FY14 | 2013-10-01 → 2013-09-03 A (-28d) | 2013-10-04 → 2013-11-20 (+47d) |  | 0% → 86% | 112d → 101d | 9-130M FS+228d, 23643100 → 23643100 FS-15d |  |
| 23643117 | Proc BCM Cavity Components- (PSS) - Procurement | 2013-09-03 A | 2013-10-31 → 2013-09-16 A (-45d) |  | 0% → 100% | 106d → none |  | was named Proc BCM Cavity Components- (PSS) Procurement; resources PROCUREMENT<$50K 60 NO ESCALATION FY14 → PROCUREMENT<$50K 60; MSHOP |
| 23643117a | Proc BCM Cavity Components- (PSS) Expenses FY13 | 2013-09-03 A | 2013-09-30 → 2013-09-16 A (-14d) |  | 0% → 100% | 105.5d → none |  |  |
| 23643117b | Proc BCM Cavity Components- (PSS) Expenses FY14 | 2013-10-01 → 2013-09-03 A (-28d) | 2013-11-01 → 2013-09-16 A (-46d) |  | 0% → 100% | 105.5d → none | 9-130M FS+228d, 23643117a → 23643117a |  |
| 23643140 | Upgrade MCC Console (PSS) FY13 | 2013-09-03 A | 2013-09-30 → 2013-11-15 (+46d) | 20d → 31d | 0% → 50% | 118d → 95d |  |  |
| 23643140a | Upgrade MCC Console (PSS) FY14 | 2013-10-01 → 2013-09-03 A (-28d) | 2013-10-15 → 2013-11-15 (+31d) |  | 0% → 50% | 118d → 95d | 23643140, 9-130M FS+228d → 23643140 FS-20d |  |
| 23643350 | PSS PLC Communications - Labor FY13 | 2013-09-16 → 2013-09-03 A (-13d) | 2013-09-30 → 2013-11-27 (+58d) | 11d → 53d |  | 6d → 124d |  |  |
| 23643350a | PSS PLC Communications - Labor FY14 | 2013-10-01 → 2013-09-03 A (-28d) |  |  |  | 6d → 124d | 9-130M FS+237d, 23643350 → 23643350 FS-45d |  |
| 23643360 | C-100 RF Commissioning PSS Support | 2013-09-03 A | 2013-09-30 → 2013-09-23 A (-7d) |  | 0% → 100% | 30d → none |  |  |
| 23643913LOE | FY13 Mngmnt & Supprt Effort for PSS | 2013-09-03 A | 2013-09-30 A |  | 0% → 100% | 142d → none |  |  |
| 23643145 | Install & Test Tagger Access Control Sys (PSS) FY13 | 2013-09-16 A | 2013-09-30 → 2013-11-27 (+58d) | 11d → 53d |  |  |  |  |
| 23643145a | Install & Test Tagger Access Control Sys (PSS) FY14 | 2013-10-01 → 2013-09-16 A (-15d) |  |  |  |  | 23643045 FS-23d, 23643045a FS-23d, 23643145 → 23643145 FS-45d, 23643045a FS-23d |  |
| 23643145b | Install & Test Hall D-MCC Access Control Sys (PSS) FY13 | 2013-09-16 A | 2013-09-30 → 2013-12-16 (+77d) | 11d → 64d |  |  |  |  |
| 23643145ba | Install & Test Hall D-MCC Access Control Sys (PSS) FY14 | 2013-10-01 → 2013-09-16 A (-15d) |  |  |  |  | 23643045a FS-23d, 23643045 FS-23d, 23643145b → 23643045a FS-23d, 23643145b FS-55d |  |
| 23643170M | Linac PSS Systems Comp | 2013-09-30 A | 2013-09-30 A |  | 0% → 100% | 30d → none |  |  |
| 23643914LOE | FY14 Mngmnt & Supprt Effort for PSS | 2013-10-01 A |  |  | 0% → 14% |  |  |  |
| 23643355 | PSS PLC Communications - Procurements | 2013-10-03 A | 2013-10-31 → 2013-11-27 (+27d) |  |  | 6d → 103d |  |  |
| 23643105 | Install Beam Stoppers & Diffusers (PSS) FY13 | 2013-09-16 → 2013-10-17 A (+31d) | 2013-09-30 → 2013-11-15 (+46d) |  | 0% → 20% | 107d → 95d | 23643100a FS-20d, 23643102 FS-68d, 23643100 FS-20d → 23643100a FS-20d, 23643100 FS-20d, 23643102 FS-60d |  |
| 23643105a | Install Beam Stoppers & Diffusers (PSS) FY14 | 2013-10-01 → 2013-10-17 A (+16d) | 2013-10-30 → 2013-11-15 (+16d) |  | 0% → 20% | 107d → 95d | 23643105, 23643100 FS-20d, 23643102 FS-68d, 23643100a FS-20d → 23643105 FS-15d, 23643100a FS-20d |  |
| 23643065 | Fab & Test Beam Transport Monitor (PSS) | 2013-10-14 → 2013-11-01 (+18d) | 2013-11-18 → 2013-12-10 (+22d) |  |  | 65d → 51d |  |  |
| 23643120 | Install & Test PSS Beam Current Monitor | 2013-10-15 → 2013-11-01 (+17d) | 2013-12-20 → 2014-01-21 (+32d) |  |  | 72d → 59d |  |  |
| 23643155 | Install & Test H-A, B, C Upgrades (PSS) | 2013-12-04 → 2013-11-01 (-33d) | 2014-02-28 → 2014-01-30 (-29d) |  |  | 18d → 39d |  |  |
| 23643150 | Proc Equipment for H-A, B, C Upgrades (PSS) |  | 2014-02-28 → 2014-01-28 (-31d) | 74d → 51d |  | 18d → 41d |  |  |
| 23643070 | Install Beam Transport Monitor (PSS) | 2013-11-01 → 2013-11-21 (+20d) | 2013-12-20 → 2014-01-22 (+33d) |  |  | 65d → 51d |  |  |
| 23643102 | Update Stopper/Diffuser Software (PSS) | 2013-11-01 → 2013-11-21 (+20d) | 2013-12-20 → 2014-01-22 (+33d) |  |  |  |  |  |
| 23643070a | Install Beam Transport Monitor - EPICS Interface (PSS) | 2013-12-02 → 2013-12-20 (+18d) | 2014-01-10 → 2014-01-31 (+21d) |  |  | 65d → 51d |  |  |

| ID | Task | Start | Finish | Duration | Complete | Total float | Predecessors | Other |
| --- | --- | --- | --- | --- | --- | --- | --- | --- |
| 23643175M | Halls A, B, C PSS Systems Comp | 2014-02-28 → 2014-01-30 (-29d) | 2014-02-28 → 2014-01-30 (-29d) |  |  | 18d → 39d |  |  |
| 23643185M | H-D PSS Systems Comp | 2014-01-10 → 2014-01-31 (+21d) | 2014-01-10 → 2014-01-31 (+21d) |  |  | 65d → 51d |  |  |
| 5 | **1.3.6.5 DUMPS (HALL D & INSERTABLE)** |  | 2014-01-17 → 2014-02-20 (+34d) |  |  |  |  |  |
| 1365909LOE | FY09 Mngmnt Effort for Dump | 2009-01-02 A | 2009-09-30 A |  | 0% → 100% | 20d → none |  |  |
| 1365910LOE | FY10 Mngmnt Effort for Dump | 2009-10-01 A | 2010-09-30 A |  | 0% → 100% | 20d → none |  |  |
| 1365911LOE | FY11 Mngmnt Effort for Dump | 2010-10-01 A | 2011-09-30 A |  | 0% → 100% | 20d → none |  |  |
| 1365912LOE | FY12 Mngmnt Effort for Dump | 2011-10-03 A | 2012-09-28 A |  | 0% → 100% | 20d → none |  |  |
| 1365913LOE | FY13 Mngmnt Effort for Dump | 2012-10-01 A | 2013-08-30 A | 228d → 248d | 0% → 100% | 20d → none |  |  |
| 1365014 | HD Dump Sys Prcrmnts | 2011-10-03 → 2012-10-05 A (+368d) | 2011-11-29 → 2013-08-30 A (+640d) | 40d → 59d | 0% → 100% | 310d → none | 12165030, 9-120M, 12165035 → 12165030, 12165035, 9-130M, 9-120M FS+140d | resources ELEC TECH [40 h]; PROCUREMENT<$50K 60; ELEC ENG [80 h] → PROCUREMENT<$50K 60; ELEC ENG [80 h]; ELEC TECH [40 h] |
| 1365040 | Insertable Dump Sys Prcrmnts | 2012-01-05 → 2012-10-05 A (+274d) | 2012-03-02 → 2013-04-15 A (+409d) | 40d → 59d | 0% → 100% | 320d → none | 9-120M FS+60d, 12165035, 12165030 → 9-120M FS+60d, 12165035, 12165030, 9-130M |  |
| 1365015 | HD Dump Sys Fab & Assy | 2011-11-30 → 2013-01-14 A (+411d) | 2012-03-30 → 2013-08-30 A (+518d) | 80d → 20d | 0% → 100% | 310d → none | 1365014 → 1365014 FS-85d | resources PROCUREMENT<$50K 60; ELEC DES [40 h]; SUPPLIES & MATERIALS; ELEC ENG [80 h]; ELEC TECH [400 h] → ELEC ENG [80 h]; ELEC TECH [400 h]; PROCUREMENT<$50K 60; SUPPLIES & MATERIALS; ELEC DES [40 h] |
| 1365045 | Insertable Dump Sys Fab & Assy | 2012-10-01 → 2013-01-14 A (+105d) | 2013-01-02 → 2013-08-30 A (+240d) | 60d → 41d | 0% → 100% | 173d → none | 9-130M, 1365040 → 9-130M, 1365040 FS-40d | resources ELEC TECH [240 h]; PROCUREMENT<$50K 60; SUPPLIES & MATERIALS; ELEC DES [80 h] → PROCUREMENT<$50K 60; SUPPLIES & MATERIALS; ELEC DES [80 h]; ELEC TECH [240 h] |
| 1365020 | HD Dump Component Testing | 2012-10-01 → 2013-01-28 A (+119d) | 2013-03-29 → 2013-08-30 A (+154d) | 120d → 64d | 0% → 100% | 183d → none | 1365015, 9-130M → 9-130M, 1365015 FS-20d |  |
| 1365025 | HD Dump Sys Implementn | 2013-04-01 → 2013-01-28 A (-63d) | 2013-06-24 → 2013-08-30 A (+67d) |  | 0% → 100% | 183d → none | 16331030, 1365020, 16331032 → 16331032, 16331030, 1365020 FS-65d | resources PLABOR; ELEC TECH [160 h]; ELEC DES [40 h]; PROCUREMENT<$50K 60 → ELEC TECH [160 h]; ELEC DES [40 h]; PLABOR; PROCUREMENT<$50K 60 |
| 1365050 | Insertable Dump Component Testing | 2013-01-03 → 2013-01-28 A (+25d) | 2013-02-22 → 2013-08-30 A (+189d) | 35d → 42d | 0% → 100% | 173d → none | 1365045 → 1365045 FS-45d | resources ELEC ENG [40 h]; ELEC TECH [80 h] → ELEC TECH [80 h]; ELEC ENG [40 h] |
| 1365055 | Insertable Dump Sys Implementn | 2013-02-25 → 2013-01-28 A (-28d) | 2013-06-03 → 2013-08-30 A (+88d) | 70d → 41d | 0% → 100% | 173d → none | 1365050, 1362025 → 1365050 FS-50d, 1362025 | resources PLABOR; ELEC TECH [240 h]; ELEC DES [40 h]; PROCUREMENT<$50K 60 → ELEC DES [40 h]; PROCUREMENT<$50K 60; PLABOR; ELEC TECH [240 h] |
| 1365030 | HD Dump Software Implementn & Cmmssng | 2013-04-29 → 2013-08-30 A (+123d) | 2013-07-16 → 2013-08-30 A (+45d) |  | 0% → 100% | 183d → none | 1365025 FS-40d → 1365025 FS-41d | resources ELEC TECH [80 h]; COMP SCIENT [320 h]; ELEC ENG [120 h] → COMP SCIENT [320 h]; ELEC ENG [120 h]; ELEC TECH [80 h] |
| 1365060 | Insertable Dump Software Implementn & Cmmssng | 2013-02-08 → 2013-08-30 A (+203d) | 2013-07-30 → 2013-08-30 A (+31d) | 120d → 75d | 0% → 100% | 173d → none | 1363035, 1365055 FS-80d → 1365055 FS-35d, 1363035 | resources ELEC TECH [80 h]; ELEC ENG [200 h]; COMP SCIENT [160 h] → ELEC ENG [200 h]; ELEC TECH [80 h]; COMP SCIENT [160 h] |
| 1365950 | Re-Baseline Actuals Adjustment | 2013-08-30 A | 2013-08-30 A |  | 0% → 100% | 20d → none | 9-130M FS+227d → none |  |
| 1365035M | HD Dump Comp | 2013-07-16 → 2013-08-30 A (+45d) | 2013-07-16 → 2013-08-30 A (+45d) |  | 0% → 100% | 183d → none |  |  |
| 1365065M | Insertable Dump Comp | 2013-07-30 → 2013-08-30 A (+31d) | 2013-07-30 → 2013-08-30 A (+31d) |  | 0% → 100% | 173d → none |  |  |
| 2365045 | Insertable Dump Sys Fab & Assy | 2013-10-01 → 2013-09-03 A (-28d) | 2013-10-25 → 2013-09-23 A (-32d) |  | 0% → 100% | 11d → none |  |  |
| 2365050 | Insertable Dump Component Testing | 2013-10-01 → 2013-09-03 A (-28d) | 2013-10-25 → 2013-09-23 A (-32d) |  | 0% → 100% | 11d → none |  |  |
| 2365055 | Insertable Dump Sys Implementn | 2013-10-01 → 2013-09-03 A (-28d) | 2013-10-25 → 2013-09-23 A (-32d) |  | 0% → 100% | 11d → none |  |  |
| 2365060 | Insertable Dump Software Implementn & Cmmssng | 2013-10-01 → 2013-09-03 A (-28d) | 2013-10-25 → 2013-09-23 A (-32d) |  | 0% → 100% | 11d → none |  |  |
| 2365913LOE | FY13 Mngmnt Effort for Dump | 2013-09-03 A | 2013-09-30 A |  | 0% → 100% | 89d → none |  |  |
| 2365014 | HD Dump Sys Prcrmnts | 2013-10-01 → 2013-09-16 A (-15d) | 2013-10-25 → 2013-10-21 A (-4d) |  | 0% → 100% | 60d → none |  |  |
| 2365065M | Insertable Dump Comp | 2013-10-25 → 2013-09-23 A (-32d) | 2013-10-25 → 2013-09-23 A (-32d) |  | 0% → 100% | 11d → none |  |  |
| 2365015 | HD Dump Sys Fab & Assy | 2013-10-01 A | 2013-10-25 → 2013-11-27 (+33d) |  | 0% → 50% | 60d → 37d |  |  |
| 2365020 | HD Dump Component Testing | 2013-10-01 → 2013-11-01 (+31d) | 2013-10-25 → 2013-11-27 (+33d) |  |  | 60d → 37d |  |  |
| 2365025 | HD Dump Sys Implementn | 2013-10-01 → 2013-11-01 (+31d) | 2013-12-17 → 2014-01-30 (+44d) |  |  | 60d → 37d |  |  |
| 2365030 | HD Dump Software Implementn & Cmmssng | 2013-10-21 → 2013-11-21 (+31d) | 2014-01-17 → 2014-02-20 (+34d) |  |  | 60d → 37d |  |  |
| 2365035M | HD Dump Comp | 2014-01-17 → 2014-02-20 (+34d) | 2014-01-17 → 2014-02-20 (+34d) |  |  | 60d → 37d |  |  |
| 6 | **1.3.6.6 VACUUM CONTROLS** |  | 2013-09-27 → 2013-11-27 (+61d) |  |  |  |  |  |
| 1366909LOE | FY09 Mngmnt Effort for SRFand ARC Vac Controls | 2009-01-02 A | 2009-09-30 A |  | 0% → 100% | 20d → none |  |  |
| 1366910LOE | FY10 Mngmnt Effort for SRFand ARC Vac Controls | 2009-10-01 A | 2010-09-30 A |  | 0% → 100% | 20d → none |  |  |
| 1366014 | SRF Vac Controls Sys Prcrmnts | 2010-05-03 A | 2010-06-28 → 2011-02-21 A (+238d) | 40d → 198d | 0% → 100% | 504d → none |  | resources ELEC ENG [160 h]; ELEC TECH [160 h]; PROCUREMENT<$50K 60 → ELEC TECH [160 h]; PROCUREMENT<$50K 60; ELEC ENG [160 h] |
| 1366015 | SRF Vac Controls Hardware Fab/Assy/Configuration | 2010-10-01 → 2010-08-16 A (-46d) | 2011-05-26 → 2011-04-25 A (-31d) | 160d → 170d | 0% → 100% | 438d → none | 1366014, 9-110M → 1366014 FS-60d, 9-110M FS-20d |  |
| 1366020 | SRF Vac Controls Sys Installtn Labor FY11 | 2011-05-27 → 2010-08-16 A (-284d) | 2011-09-30 → 2011-07-25 A (-67d) | 88d → 233d | 0% → 100% | 438d → none | 1366015, 1362025 FS-115d → 1362025 FS-265d, 1366015 FS-180d | resources ELEC DES [54.15 h]; ELEC TECH [433.23 h] → ELEC TECH [433.23 h]; ELEC DES [54.15 h] |
| 1366020a | SRF Vac Controls Sys Installtn Labor FY12 | 2011-10-03 → 2010-08-16 A (-413d) | 2011-12-01 → 2011-07-25 A (-129d) | 42d → 233d | 0% → 100% | 438d → none |  | resources ELEC TECH [206.77 h]; ELEC DES [25.85 h] → ELEC DES [25.85 h]; ELEC TECH [206.77 h] |
| 1366020b | SRF Vac Controls Sys Installtn Labor Procurement | 2011-05-27 → 2010-08-16 A (-284d) | 2011-12-01 → 2011-07-25 A (-129d) | 130d → 233d | 0% → 100% | 438d → none | 1362025 FS-115d, 1366015 → 1362025 FS-265d, 1366015 FS-180d |  |
| 1366911LOE | FY11 Mngmnt Effort for SRFand ARC Vac Controls | 2010-10-01 A | 2011-09-30 A |  | 0% → 100% | 20d → none |  |  |
| 1366025 | SRF Vac Controls Software Implementn & Sys Testing FY11 | 2011-06-06 → 2011-03-01 A (-97d) | 2011-09-30 → 2011-07-25 A (-67d) | 83d → 103d | 0% → 100% | 438d → none | 1366020a FS-125d, 1366020b FS-125d → 1366020b FS-165d, 1366020 FS-165d, 1366020a FS-165d |  |
| 1366025a | SRF Vac Controls Software Implementn & Sys Testing FY12 | 2011-10-03 → 2011-03-01 A (-216d) | 2012-01-13 → 2011-07-25 A (-172d) | 67d → 103d | 0% → 100% | 438d → none |  | resources ELEC TECH [53.6 h]; COMP SCIENT [178.67 h]; ELEC ENG [53.6 h] → COMP SCIENT [178.67 h]; ELEC ENG [53.6 h]; ELEC TECH [53.6 h] |
| 1366030M | SRF Vacuum Controls Sys Comp | 2012-01-13 → 2011-07-25 A (-172d) | 2012-01-13 → 2011-07-25 A (-172d) |  | 0% → 100% | 438d → none |  |  |
| 1366912LOE | FY12 Mngmnt Effort for SRFand ARC Vac Controls | 2011-10-03 A | 2012-09-28 A |  | 0% → 100% | 20d → none |  |  |
| 1366035 | ARC Vac Controls Sys Prcrmnts | 2012-02-03 → 2012-02-01 A (-2d) | 2012-03-30 → 2012-04-16 A (+17d) | 40d → 53d | 0% → 100% | 355d → none |  | resources ELEC ENG [40 h]; ELEC TECH [120 h]; PROCUREMENT<$50K 60 → ELEC TECH [120 h]; PROCUREMENT<$50K 60; ELEC ENG [40 h] |
| 1366040 | ARC Vac Controls Hardware Fab/Assy/Configuration | 2012-04-02 → 2012-04-09 A (+7d) | 2012-08-07 → 2013-01-31 A (+177d) | 90d → 173d | 0% → 100% | 355d → none |  | resources SUPPLIES & MATERIALS; TRAVEL; PROCUREMENT<$50K 60; ELEC DES [40 h]; ELEC TECH [320 h] → TRAVEL; ELEC DES [40 h]; PROCUREMENT<$50K 60; ELEC TECH [320 h]; SUPPLIES & MATERIALS |
| 1366045 | ARC Vac Controls Sys Installtn FY12 | 2012-08-08 → 2012-06-05 A (-64d) | 2012-09-28 → 2013-01-31 A (+125d) | 37d → 134d | 0% → 100% | 355d → none | 2-02M, 1366040 → 2-02M, 1366040 FS-30d | resources PLABOR; ELEC TECH [164.44 h]; ELEC DES [32.89 h] → ELEC TECH [164.44 h]; ELEC DES [32.89 h]; PLABOR |
| 1366045a | ARC Vac Controls Sys Installtn FY13 | 2012-10-01 → 2012-06-05 A (-118d) | 2012-10-10 → 2013-08-30 A (+324d) | 8d → 134d | 0% → 100% | 355d → none | 1366045 → 1366045 FS-30d |  |
| 1366045b | ARC Vac Controls Sys Installtn Procurement | 2012-08-08 → 2012-06-05 A (-64d) | 2012-10-10 → 2013-01-31 A (+113d) | 45d → 134d | 0% → 100% | 355d → none | 1366040, 2-02M → 2-02M, 1366040 FS-30d |  |
| 1366047 | ARC Vac Controls Sys Installtn Additonal effort per 2012 ETC | 2012-10-01 A | 2012-10-10 → 2013-08-30 A (+324d) | 8d → 51d | 0% → 100% | 355d → none |  |  |
| 1366050a | ARC Vac Controls Software Implementn & Sys Testing FY13 | 2012-10-01 → 2013-01-14 A (+105d) | 2012-10-31 → 2013-08-30 A (+303d) |  | 0% → 100% | 355d → none | 1366050 → 1366050 FS-20d | resources COMP SCIENT [52.57 h]; ELEC TECH [26.29 h] → ELEC TECH [26.29 h]; COMP SCIENT [52.57 h] |
| 1366050 | ARC Vac Controls Software Implementn & Sys Testing FY12 | 2012-07-25 → 2013-01-21 A (+180d) | 2012-09-28 → 2013-01-31 A (+125d) | 47d → 37d | 0% → 100% | 355d → none | 1366045b FS-55d, 1366047 FS-55d, 1362025, 1366045a FS-55d → 1362025, 1366045b FS-30d, 1366045a FS-30d, 1366047 FS-40d, 1366045 FS-30d | resources COMP SCIENT [107.43 h]; ELEC TECH [53.71 h] → ELEC TECH [53.71 h]; COMP SCIENT [107.43 h] |
| 1366950 | Re-Baseline Actuals Adjustment | 2013-08-30 A | 2013-08-30 A |  | 0% → 100% | 20d → none | 9-130M FS+227d → none |  |
| 1366055M | ARC Vacuum Controls Sys Comp | 2012-10-31 → 2013-08-30 A (+303d) | 2012-10-31 → 2013-08-30 A (+303d) |  | 0% → 100% | 355d → none |  |  |
| 2366050a | ARC Vac Controls Software Implementn | 2013-09-03 A | 2013-09-27 → 2013-11-27 (+61d) |  | 0% → 50% | 130d → 87d |  |  |
| 2366051 | ARC Vac Controls Hardware Implementation & Testing | 2013-09-03 A | 2013-09-27 → 2013-11-27 (+61d) |  |  | 130d → 87d |  |  |
| 2366055M | ARC Vacuum Controls Sys Comp | 2013-09-27 → 2013-11-27 (+61d) | 2013-09-27 → 2013-11-27 (+61d) |  |  | 130d → 87d |  |  |
| 7 | **1.3.6.7 MAGNET INSTRUMENTATION** | 2011-10-03 → 2011-12-05 (+63d) |  |  |  |  |  |  |
| 1367005 | Mag Instrmenttn Prcrmnts | 2011-10-03 → 2011-12-05 A (+63d) | 2011-11-11 → 2012-12-17 A (+402d) | 30d → 254d | 0% → 100% | 185d → none | 9-120M, 12167028 → 12167028, 9-120M FS+60d |  |
| 1367010 | Mag Instrmenttn Fab & Assy | 2011-11-14 → 2012-06-05 A (+204d) | 2012-04-13 → 2012-12-17 A (+248d) | 100d → 133d | 0% → 100% | 185d → none | 1367005 → 1367005 FS-25d | resources ELEC TECH [360 h]; PROCUREMENT<$50K 60; SUPPLIES & MATERIALS; TRAVEL; ELEC DES [40 h] → ELEC TECH [360 h]; SUPPLIES & MATERIALS; TRAVEL; ELEC DES [40 h]; PROCUREMENT<$50K 60 |
| 1367015 | Mag Instrmenttn Testing | 2012-04-16 → 2012-06-05 A (+50d) | 2012-07-10 → 2012-12-17 A (+160d) | 60d → 133d | 0% → 100% | 185d → none | 9-120M, 1367010 → 1367010 FS-100d, 9-120M | resources ELEC TECH [160 h]; PROCUREMENT<$50K 60; COMP SCIENT [160 h] → COMP SCIENT [160 h]; ELEC TECH [160 h]; PROCUREMENT<$50K 60 |
| 1367020 | Mag Instrmenttn Implementn FY12 | 2012-07-11 → 2012-10-08 A (+89d) | 2012-09-28 → 2013-08-30 A (+336d) | 57d → 58d | 0% → 100% | 185d → none | 1367015, 1362025 FS-115d → 1362025 FS-115d, 1367015 FS-40d |  |
| 1367020a | Mag Instrmenttn Implementn FY13 | 2012-10-01 → 2012-10-08 A (+7d) | 2013-01-07 → 2013-08-12 A (+217d) | 63d → 58d | 0% → 100% | 185d → none | 1367020 → 1367020 FS-60d |  |
| 1367020b | Mag Instrmenttn Implementn Procurement | 2012-07-11 → 2012-11-12 A (+124d) | 2013-01-07 → 2013-08-30 A (+235d) | 120d → 133d | 0% → 100% | 185d → none | 1367015, 1362025 FS-115d → 1367015 FS-20d, 1362025 FS-115d |  |
| 1367030 | Magnet Communication New I/O IP design - Labor | 2013-02-01 → 2012-11-12 A (-81d) | 2013-04-26 → 2013-08-30 A (+126d) | 60d → 110d | 0% → 100% | 33d → none | 9-130M FS+80d → 9-130M | resources ELEC ENG [172 h]; ELEC TECH [80 h] → ELEC TECH [80 h]; ELEC ENG [172 h] |
| 1367025 | Mag Instrmenttn Software Implementn & Cmmssng FY12 | 2012-06-27 → 2013-03-04 A (+250d) | 2012-09-28 → 2013-08-30 A (+336d) |  | 0% → 100% | 185d → none | 1367020b FS-130d, 1362025, 1367020a FS-130d → 1367020b FS-130d, 1362025, 1367020a FS-130d, 1367020 FS-130d |  |
| 1367025a | Mag Instrmenttn Software Implementn & Cmmssng FY13 | 2012-10-01 → 2013-03-04 A (+154d) | 2013-01-22 → 2013-08-30 A (+220d) |  | 0% → 100% | 185d → none | 1367025 → 1367025 FS-60d |  |
| 1367035 | Magnet Communication New I/O IP design - Proc. | 2013-03-01 → 2013-04-01 A (+31d) | 2013-03-28 → 2013-08-30 A (+155d) |  | 0% → 100% | 33d → none |  | resources ELEC ENG [28 h]; PROCUREMENT<$50K 60; ELEC TECH [40 h] → ELEC TECH [40 h]; ELEC ENG [28 h]; PROCUREMENT<$50K 60 |

| ID | Task | Start | Finish | Duration | Complete | Total float | Predecessors | Other |
| --- | --- | --- | --- | --- | --- | --- | --- | --- |
| 1367040 | Magnet Communication New I/O IP Fabrication | 2013-05-01 → 2013-04-08 A (-23d) | 2013-06-26 → 2013-08-30 A (+65d) |  | 0% → 100% | 33d → none | 1367035 FS+23d → 1367035 FS-30d | resources PROCUREMENT<$50K 60; ELEC TECH [240 h] → ELEC TECH [240 h]; PROCUREMENT<$50K 60 |
| 1367045 | Magnet Communication New I/O IP Testing | 2013-06-03 → 2013-06-01 A (-2d) | 2013-06-28 → 2013-08-30 A (+63d) |  | 0% → 100% | 33d → none |  |  |
| 1367050 | Magnet Communication New I/O IP Installation | 2013-07-01 → 2013-07-08 A (+7d) | 2013-07-29 → 2013-08-30 A (+32d) |  | 0% → 100% | 33d → none | 1367045 → 1367045 FS-25d |  |
| 1367055 | Magnet Communication New I/O IP Software -Labor | 2013-07-01 → 2013-07-15 A (+14d) | 2013-08-26 → 2013-08-30 A (+4d) |  | 0% → 100% | 34d → none | 1367045 → 1367045 FS-25d |  |
| 1367060 | Re-Baseline Actuals Adjustment | 2013-08-30 A | 2013-08-30 A |  | 0% → 100% | 20d → none | 9-130M FS+227d → none |  |
| 2367025a | Mag Instrmenttn Software Implementn & Cmmssng FY13 | 2013-09-03 A | 2013-09-30 → 2014-02-07 (+130d) | 20d → 103d | 0% → 70% |  |  |  |
| 2367025aa | Mag Instrmenttn Software Implementn & Cmmssng FY14 | 2013-10-01 → 2013-09-03 A (-28d) |  |  | 0% → 70% |  | 23221024ba FS-198d, 2367025a, 9-130M FS+228d → 2367025a FS-100d |  |
| 2367030 | Magnet Communication New I/O IP design - Labor FY13 | 2013-09-03 A | 2013-09-30 → 2013-10-21 A (+21d) | 20d → 52d | 0% → 100% | 14d → none |  |  |
| 2367030a | Magnet Communication New I/O IP design - Labor FY14 | 2013-10-01 → 2013-09-03 A (-28d) | 2013-11-13 → 2013-10-21 A (-23d) |  | 0% → 100% | 14d → none | 2367030, 9-130M FS+228d → 2367030 FS-35d |  |
| 2367035 | Magnet Communication New I/O IP design - Proc. | 2013-10-02 → 2013-09-16 A (-16d) | 2013-11-13 → 2013-11-15 (+2d) |  | 0% → 13% | 14d → 141d |  |  |
| 2367040 | Magnet Communication New I/O IP Fabrication | 2013-10-02 → 2013-09-16 A (-16d) | 2013-11-13 → 2013-11-15 (+2d) |  | 0% → 50% | 14d → 121d |  |  |
| 2367045 | Magnet Communication New I/O IP Testing | 2013-10-02 → 2013-09-16 A (-16d) | 2013-11-12 → 2013-11-15 (+3d) |  | 0% → 50% | 14d → 101d |  |  |
| 2367050 | Magnet Communication New I/O IP Installation | 2013-10-01 → 2013-09-16 A (-15d) | 2013-11-11 → 2013-11-18 (+7d) |  | 0% → 50% | 86d → 81d |  |  |
| 2367055 | Magnet Communication New I/O IP Software -Labor | 2013-10-01 → 2013-09-16 A (-15d) | 2013-11-11 → 2013-11-18 (+7d) |  | 0% → 50% | 14d → 90d |  |  |
| 4 | **1.4 CONSTRUCTION UPGRADE HALLS A, B, & C** |  | 2016-02-03 → 2016-05-12 (+99d) |  |  |  |  |  |
| 1 | **1.4.1 CONSTRUCTION HALL A** |  | 2013-09-30 → 2013-12-20 (+81d) |  |  |  |  |  |
| 3 | **1.4.1.3 COMPUTING** |  | 2013-08-30 → 2012-01-30 (-578d) |  |  |  |  |  |
| 2 | **1.4.1.3.2 DAQ UPGRADES FOR HRS** |  | 2013-08-30 → 2012-01-30 (-578d) |  |  |  |  |  |
| 14132909LOE | FY09 Proj Admin H-A, All Constrctn (DAQ UPGRADES) | 2008-10-01 A | 2009-09-30 A |  | 0% → 100% | 20d → none |  |  |
| 14132910LOE | FY10 Proj Admin H-A, All Constrctn (DAQ UPGRADES) | 2009-10-01 A | 2010-09-30 A |  | 0% → 100% | 20d → none |  |  |
| 14132911LOE | FY11 Proj Admin H-A, All Constrctn (DAQ UPGRADES) | 2010-10-01 A | 2011-09-30 A |  | 0% → 100% | 20d → none |  |  |
| 14132912LOE | FY12 Proj Admin H-A, All Constrctn (DAQ UPGRADES) | 2011-10-03 A | 2012-09-28 → 2012-01-16 A (-256d) | 247d → 67d | 0% → 100% | 20d → none |  |  |
| 14132018 | Proc ADCs, TDCs,¿ (DAQ UPGRADES) | 2011-01-05 → 2012-01-02 A (+362d) | 2011-04-28 → 2012-01-23 A (+270d) | 80d → 14d | 0% → 100% | 581d → none |  |  |
| 14132020 | Install Electrnc's (DAQ UPGRADES) | 2012-01-05 → 2012-01-02 A (-3d) | 2012-04-26 → 2012-01-23 A (-94d) | 79d → 14d | 0% → 100% | 413d → none |  |  |
| 14132913LOE | FY13 Proj Admin H-A, All Constrctn (DAQ UPGRADES) | 2012-10-01 → 2012-01-16 A (-259d) | 2013-08-30 → 2012-01-30 A (-578d) | 228d → 10d | 0% → 100% | 20d → none |  |  |
| 5 | **1.4.1.5 BEAMLINE** |  | 2013-09-30 → 2013-12-20 (+81d) |  |  |  |  |  |
| 14151000M | Start Moller polarimeter upgrade (MOL POLAR) | 2011-10-03 A | 2011-10-03 A |  | 0% → 100% | 5d → none |  |  |
| 14151015 | Prepare Quadrupole Manufacturing Drawings Package | 2011-10-03 A | 2011-10-21 → 2011-12-19 A (+59d) | 15d → 54d | 0% → 100% | 273d → none |  |  |
| 14151020 | Quadrupole Procurement prep | 2011-10-24 → 2011-12-19 A (+56d) | 2012-01-20 → 2012-05-14 A (+115d) | 56d → 98d | 0% → 100% | 273d → none |  |  |
| 14151005 | Proc Compnts - Stands, Magnetic Shield insert,... (MOL POLAR) | 2011-12-07 → 2012-03-02 A (+86d) | 2012-05-04 → 2013-02-18 A (+290d) | 100d → 201d | 0% → 100% | 5d → none | 14151000M FS+45d → 14151000M |  |
| 14151035 | Procure/Refurbish Power Supply for Quadrupole | 2012-01-23 → 2012-04-02 A (+70d) | 2012-08-31 → 2012-04-25 A (-128d) | 157d → 18d | 0% → 100% | 273d → none | 14151020 → 14151020 FS-20d |  |
| 14151010 | Install Modifications (MOL POLAR) FY12 | 2012-05-14 → 2012-05-21 A (+7d) | 2012-09-28 → 2013-02-18 A (+143d) | 97d → 145d | 0% → 100% | 272d → none | 3P-01M, 2-02M, 14151035 FS-79d, 14151025 FS-79d, 14151030 FS-79d, 14151005 → 14151005 FS-80d, 2-02M, 14151035, 14151030 FS-180d, 3P-01M FS-140d, 14151025 FS-180d | resources COMP SCIENT [29.85 h]; SUPPLIES & MATERIALS; VISTNG USERS [119.38 h]; SKLLD TRADE [59.69 h]; SCIENTIST [119.38 h]; PLABOR; ELEC TECH [29.85 h] → SKLLD TRADE [59.69 h]; ELEC TECH [29.85 h]; SCIENTIST [119.38 h]; COMP SCIENT [29.85 h]; VISTNG USERS [119.38 h]; PLABOR; SUPPLIES & MATERIALS |
| 14151010a | Install Modifications (MOL POLAR) FY13 | 2012-10-01 → 2012-05-21 A (-133d) | 2012-11-14 → 2013-02-18 A (+96d) | 33d → 145d | 0% → 100% | 272d → none | 14151010 → 14151010 FS-60d |  |
| 14151025 | Quadrupole Contract Support | 2012-01-23 → 2012-05-28 A (+126d) | 2012-08-31 → 2012-09-17 A (+17d) | 157d → 78d | 0% → 100% | 273d → none | 14151020 → 14151020 FS-15d |  |
| 14151030 | Vend Fab Quadrupole | 2012-01-23 → 2012-05-28 A (+126d) | 2012-08-31 → 2012-09-17 A (+17d) | 157d → 78d | 0% → 100% | 273d → none | 14151020 → 14151020 FS-20d |  |
| 14151040 | Re-Baseline Actuals Adjustment | 2013-08-30 A | 2013-08-30 A |  | 0% → 100% | 20d → none | 9-130M FS+227d → none |  |
| 2 | **1.4.1.5.2 COMPTON POLARIMETER** |  | 2013-09-30 → 2013-12-20 (+81d) |  |  |  |  |  |
| 14152000M | Start Compton upgrade (COMP POLAR) | 2011-10-03 A | 2011-10-03 A |  | 0% → 100% | 90d → none |  |  |
| 14152005 | Proc Detector componets (COMP POLAR) | 2011-10-03 → 2011-12-01 A (+59d) | 2012-02-02 → 2012-01-30 A (-3d) | 80d → 36d | 0% → 100% | 272d → none |  |  |
| 14152015 | Proc motion sys, Stands & Beam Line (COMP POLAR) | 2011-10-03 → 2011-12-01 A (+59d) | 2012-01-04 → 2013-08-30 A (+604d) | 60d → 264d | 0% → 100% | 90d → none |  |  |
| 14152010 | Assemble & Test Detector (COMP POLAR) | 2012-02-03 → 2012-01-16 A (-18d) | 2012-05-11 → 2012-06-19 A (+39d) | 70d → 108d | 0% → 100% | 272d → none |  |  |
| 14152020 | Install & Test (COMP POLAR) FY12 | 2012-05-14 → 2012-06-11 A (+28d) | 2012-09-28 → 2013-08-30 A (+336d) | 97d → 180d | 0% → 100% | 272d → none | 14152015, 3P-01M, 2-02M, 14152010 → 3P-01M, 2-02M, 14152015 FS-70d, 14152010 FS-20d | resources PD UNIV STUDNT [149.23 h]; SCIENTIST [179.08 h]; SKLLD TRADE [119.38 h]; ELEC TECH [89.54 h]; PD UNIV STAFF [59.69 h]; MECH TECH [835.69 h] → MECH TECH [835.69 h]; PD UNIV STUDNT [149.23 h]; SKLLD TRADE [119.38 h]; ELEC TECH [89.54 h]; PD UNIV STAFF [59.69 h]; SCIENTIST [179.08 h] |
| 14152025 | Install & Test (COMP POLAR) FY13 | 2012-10-01 → 2012-06-11 A (-112d) | 2012-11-14 → 2013-08-30 A (+289d) | 33d → 180d | 0% → 100% | 272d → none | 14152020 → 14152020 FS-145d |  |
| 14152030 | Re-Baseline Actuals Adjustment | 2013-08-30 A | 2013-08-30 A |  | 0% → 100% | 20d → none | 9-130M FS+227d → none |  |
| 24152015 | Proc motion sys, Stands & Beam Line (COMP POLAR) Re-Baseline Obligation Split | 2013-09-03 A | 2013-09-30 → 2013-12-20 (+81d) |  |  | 57d → 45d |  |  |
| 24152020 | Proc motion sys, Stands & Beam Line (COMP POLAR) | 2013-09-03 → 2013-10-01 A (+28d) | 2013-09-30 → 2013-12-20 (+81d) |  |  | 57d → 45d |  |  |
| 24152025 | Install & Test (COMP POLAR) | 2013-09-03 → 2013-10-01 A (+28d) | 2013-09-30 → 2013-12-20 (+81d) |  |  | 57d → 39d | 24152020 FS-20d, 24152015 FS-20d → 24152015 FS-40d, 24152020 FS-40d | resources MECH DES [40 h]; MECH TECH [80 h] → MECH TECH [80 h]; MECH DES [40 h] |
| 3 | **1.4.1.5.3 MAPPING-ARC ENERGY MEASUREMENT** | 2012-05-14 → 2013-03-01 (+291d) | 2013-09-03 → 2013-10-14 (+41d) |  |  |  |  |  |
| 14153010 | Calibrate and Install H-A Line Magnets | 2012-05-14 → 2013-03-01 A (+291d) | 2012-08-07 → 2013-05-13 A (+279d) | 60d → 77d | 0% → 100% | 341d → none | 14153000M, 2-02M → 2-02M FS+60d, 14153000M | was named Calibrate H-A Line Magnets (MAPPER); resources PD UNIV STUDNT [600 h]; VISTNG USERS [480 h]; TRAVEL; SCIENTIST [480 h]; MECH TECH [608 h]; ELEC TECH [88 h]; SUPPLIES & MATERIALS → TRAVEL; SCIENTIST [480 h]; PD UNIV STUDNT [600 h]; MECH TECH [608 h]; ELEC TECH [88 h]; SUPPLIES & MATERIALS; VISTNG USERS [480 h] |
| 14153000M | Start Calibration | 2012-05-14 → 2013-05-03 A (+354d) | 2012-05-14 → 2013-05-03 A (+354d) |  | 0% → 100% | 341d → none | 122153010, 2-02M, 9-110M → 9-130M FS+25d, 2-02M FS+80d, 122153010, 9-110M | was named Start Mapper Constr (MAPPER) |
| 14153020 | Install Mapper & Rebuilt 9th Dipole in Shed (MAPPER) | 2012-08-08 → 2013-08-30 A (+387d) | 2012-08-08 → 2013-08-30 A (+387d) |  | 0% → 100% | 341d → none |  |  |
| 14153025 | Re-Baseline Actuals Adjustment | 2013-08-30 A | 2013-08-30 A |  | 0% → 100% | 20d → none | 9-130M FS+227d → none |  |
| 24153020 | Install Rebuilt 9th Dipole in Shed (MAPPER) | 2013-09-03 → 2013-10-01 A (+28d) | 2013-09-03 → 2013-10-14 A (+41d) |  | 0% → 100% | 76d → none |  |  |
| 2 | **1.4.2 CONSTRUCTION HALL B** | 2008-10-01 → 2009-01-02 (+93d) | 2016-01-28 → 2016-05-12 (+105d) |  |  |  |  |  |
| 1 | **1.4.2.1 MAGNET** |  | 2013-09-30 → 2013-09-16 (-14d) |  |  |  |  |  |
| 1 | **1.4.2.1.1 TOROIDAL MAGNET** |  | 2013-09-30 → 2013-09-16 (-14d) |  |  |  |  |  |
| 14211009E | Torus FY09 Travel | 2009-01-02 A | 2009-09-30 A |  | 0% → 100% | 0d → none |  |  |
| 14211030 | Vend Fab Torus - Completion of System Requirements Review (SRR) (1) | 2009-09-04 A | 2009-10-30 → 2009-10-01 A (-29d) | 40d → 19d | 0% → 100% | 1220d → none |  | was named Vend Fab Torus - Completion of System Requirements Review (SRR) |
| 14211035 | Vend Fab Torus - Completion of Preliminary Design Review (2) | 2009-09-04 A | 2009-12-30 → 2009-12-08 A (-22d) | 76d → 65d | 0% → 100% | 1220d → none |  | was named Vend Fab Torus - Completion of Preliminary Design Review |
| 14211040 | Vend Fab Torus - Superconductor Production | 2009-09-04 A | 2010-01-29 → 2010-03-01 A (+31d) | 96d → 116d | 0% → 100% | 1220d → none |  |  |
| 14211045 | Vend Fab Torus - Completion of Preliminary Design Review and Manufacturing Readiness Review | 2009-09-04 A | 2010-02-26 → 2010-03-01 A (+3d) | 115d → 116d | 0% → 100% | 1200d → none | 14211040B FS-288d, 14211040A FS-116d, 14211040 FS-116d → 14211040 FS-96d, 14211040B FS-288d, 14211040A FS-116d |  |
| 14211004 | Torus Vend Comp Dsgn & Fab FY09 Original Labor Initial | 2009-01-05 → 2009-10-01 A (+269d) | 2009-08-31 → 2010-10-25 A (+420d) | 167d → 265d | 0% → 100% | 830d → none | 14211000MX, 14211002X FS+1d → 14211002X FS-170d, 14211000MX | resources SCIENTIST [190.86 h]; MECH TECH [545.31 h]; ELEC ENG [136.33 h]; ELEC DES [190.86 h]; ELEC TECH [54.53 h]; OFFICE [54.5 h]; MECH ENG [245.39 h]; MECH DES [163.59 h] → ELEC TECH [54.53 h]; OFFICE [54.5 h]; MECH ENG [245.39 h]; MECH DES [163.59 h]; SCIENTIST [190.86 h]; MECH TECH [545.31 h]; ELEC ENG [136.33 h]; ELEC DES [190.86 h] |
| 14211004A | Torus Vend Comp Dsgn & Fab FY09 Original Labor Final | 2009-09-01 → 2009-10-01 A (+30d) | 2009-09-30 → 2010-10-25 A (+390d) | 21d → 265d | 0% → 100% | 752d → none | 9-090M FS+227d → 14211004 FS-500d, 9-090M FS+227d | resources ELEC TECH [6.86 h]; MECH DES [20.57 h]; MECH ENG [30.86 h]; MECH TECH [68.57 h]; OFFICE [6.86 h]; SCIENTIST [24 h]; ELEC DES [24 h]; ELEC ENG [17.14 h] → ELEC DES [24 h]; ELEC ENG [17.14 h]; ELEC TECH [6.86 h]; MECH DES [20.57 h]; MECH ENG [30.86 h]; MECH TECH [68.57 h]; SCIENTIST [24 h]; OFFICE [6.86 h] |
| 14211004B | Torus Vend Comp Dsgn & Fab FY10 Original Labor | 2009-10-01 A | 2009-12-29 → 2010-10-25 A (+300d) | 57d → 265d | 0% → 100% | 752d → none | 14211004A → 9-100M | resources MECH DES [55.84 h]; SCIENTIST [65.14 h]; MECH TECH [186.12 h]; OFFICE [18.61 h]; MECH ENG [83.75 h]; ELEC DES [65.14 h]; ELEC TECH [18.61 h]; ELEC ENG [46.53 h] → SCIENTIST [65.14 h]; OFFICE [18.61 h]; MECH TECH [186.12 h]; MECH ENG [83.75 h]; MECH DES [55.84 h]; ELEC TECH [18.61 h]; ELEC ENG [46.53 h]; ELEC DES [65.14 h] |
| 14211010E | Torus FY10 Travel | 2009-10-01 A | 2010-09-30 A |  | 0% → 100% | 0d → none |  |  |
| 14211040C | Vend Fab Torus -Solder Stabilizer Production | 2009-11-02 A | 2011-04-29 → 2012-02-06 A (+283d) | 367d → 556d | 0% → 100% | 1155d → none |  |  |
| 14211050Ab | Vend Fab Torus - Stability Model Coil test (5b) | 2009-11-02 A | 2011-04-29 → 2012-02-06 A (+283d) | 367d → 556d | 0% → 100% | 1319d → none |  | was named Vend Fab Torus - Stability Model Coil test |
| 14211050Ac | Vend Fab Torus - UG&GUG Duties (17P1) | 2009-11-02 A | 2011-02-28 → 2011-04-01 A (+32d) | 323d → 347d | 0% → 100% | 1319d → none | 14211050Ab FS-367d → 14211050Ab FS-390d | was named Vend Fab Torus - UG&GUG Duties |
| 14211050Ad | Vend Fab Torus - Coil Case Plates-Mill run Phase 2 Funding (17P2) | 2009-11-02 A | 2011-03-31 → 2011-04-01 A (+1d) | 346d → 347d | 0% → 100% | 1319d → none |  | was named Vend Fab Torus - Coil Case Plates-Mill run Phase 2 Funding |
| 14211050 | Vend Fab Torus -Design and Construction of Prototype Coil (Full Size) (5a) | 2009-11-02 → 2009-12-01 A (+29d) | 2011-01-31 → 2011-09-22 A (+234d) | 304d → 449d | 0% → 100% | 1200d → none |  | was named Vend Fab Torus -Design and Construction of Prototype Coil (Full Size); resources PROCUREMENT>$50K 69 NO ESCALATION; PROCUREMENT<$50K 60 NO ESCALATION → PROCUREMENT<$50K 60 NO ESCALATION; PROCUREMENT>$50K 69 NO ESCALATION |

| ID | Task | Start | Finish | Duration | Complete | Total float | Predecessors | Other |
| --- | --- | --- | --- | --- | --- | --- | --- | --- |
| 14211055 | Vend Fab Torus -Complete and Warm Test Coil #1 (6) | 2009-11-02 → 2009-12-01 A (+29d) | 2011-12-30 → 2012-02-06 A (+38d) | 532d → 537d | 0% → 100% | 1200d → none | 14211050 FS-304d, 14211050A FS-346d → 14211050 FS-220d, 14211050A FS-346d | was named Vend Fab Torus -Complete and Warm Test Coil #1 |
| 14211060 | Vend Fab Torus -Complete and Warm Test Coil #2 (7) | 2009-11-02 → 2009-12-01 A (+29d) | 2012-02-29 → 2012-02-06 A (-23d) | 572d → 537d | 0% → 100% | 1200d → none | 14211055 FS-532d → 14211055 FS-495d | was named Vend Fab Torus -Complete and Warm Test Coil #2 |
| 14211010 | Torus Vend Coil Winding Original Labor FY10 | 2010-01-05 → 2010-01-04 A (-1d) | 2010-09-30 → 2010-12-29 A (+90d) | 188d → 245.15d | 0% → 100% | 749d → none | 14211004, 14211004B, 9-100M FS+60d → 14211004B FS-200d, 9-100M FS+60d, 14211004 FS-200d | resources MECH ENG [276.24 h]; MECH TECH [767.35 h]; SCIENTIST [184.16 h]; ELEC DES [214.86 h]; ELEC ENG [153.47 h]; ELEC TECH [61.39 h]; MECH DES [184.16 h] → SCIENTIST [184.16 h]; ELEC DES [214.86 h]; ELEC ENG [153.47 h]; ELEC TECH [61.39 h]; MECH DES [184.16 h]; MECH ENG [276.24 h]; MECH TECH [767.35 h] |
| 14211010a | Torus Vend Coil Winding Original Labor FY11 | 2010-10-01 → 2010-01-04 A (-270d) | 2010-12-29 A | 57d → 245.33d | 0% → 100% | 749d → none | 14211010 → 9-100M FS+60d, 14211004B FS-200d, 14211004 FS-200d | resources MECH TECH [232.65 h]; SCIENTIST [55.84 h]; ELEC DES [65.14 h]; ELEC ENG [46.53 h]; ELEC TECH [18.61 h]; MECH DES [55.84 h]; MECH ENG [83.76 h] → SCIENTIST [55.84 h]; ELEC DES [65.14 h]; ELEC ENG [46.53 h]; ELEC TECH [18.61 h]; MECH DES [55.84 h]; MECH ENG [83.76 h]; MECH TECH [232.65 h] |
| 14211015 | Torus Vend Compnts Fab Original Labor FY10 | 2010-01-05 → 2010-01-04 A (-1d) | 2010-09-30 → 2010-12-29 A (+90d) | 188d → 246d | 0% → 100% | 749d → none | 14211004, 14211004B, 9-100M FS+60d → 14211004B FS-200d, 14211004 FS-200d, 9-100M FS+60d | resources ELEC DES [61.39 h]; ELEC ENG [61.39 h]; ELEC TECH [46.04 h]; MECH DES [122.78 h]; MECH ENG [214.86 h]; MECH TECH [306.94 h]; SCIENTIST [92.08 h]; SKLLD TRADE [36.83 h] → MECH DES [122.78 h]; MECH ENG [214.86 h]; MECH TECH [306.94 h]; SCIENTIST [92.08 h]; SKLLD TRADE [36.83 h]; ELEC DES [61.39 h]; ELEC ENG [61.39 h]; ELEC TECH [46.04 h] |
| 14211015a | Torus Vend Compnts Fab Original Labor FY11 | 2010-10-01 → 2010-01-04 A (-270d) | 2010-12-29 A | 57d → 246d | 0% → 100% | 749d → none | 14211015 → 14211004B FS-200d, 9-100M FS+60d, 14211004 FS-200d | resources MECH ENG [65.14 h]; MECH TECH [93.06 h]; SCIENTIST [27.92 h]; SKLLD TRADE [11.17 h]; ELEC DES [18.61 h]; ELEC ENG [18.61 h]; ELEC TECH [13.96 h]; MECH DES [37.22 h] → ELEC TECH [13.96 h]; MECH DES [37.22 h]; MECH ENG [65.14 h]; SCIENTIST [27.92 h]; SKLLD TRADE [11.17 h]; ELEC DES [18.61 h]; ELEC ENG [18.61 h]; MECH TECH [93.06 h] |
| 14211040A | Vend Fab Torus - Superconductor Production Reverse Entry per CR10-044 | 2010-03-01 A | 2010-03-01 A |  | 0% → 100% | 1200d → none |  |  |
| 14211040B | Vend Fab Torus - Superconductor Production Revised Delivery per CR10-044 (3a, 3b, 3c) | 2010-03-01 A | 2010-10-29 → 2011-05-23 A (+206d) | 172d → 308d | 0% → 100% | 1155d → none |  | was named Vend Fab Torus - Superconductor Production Revised Delivery per CR10-044 |
| 14211045A | Vend Fab Torus - Completion of Preliminary Design Review and Manufacturing Readiness Review Reverse Entry per CR10-044 | 2010-03-01 A | 2010-03-01 A |  | 0% → 100% | 1200d → none |  |  |
| 14211045B | Vend Fab Torus - Completion of IDR Revised Delivery per CR10-044 (4A) | 2010-03-01 A | 2010-10-29 → 2010-07-29 A (-92d) | 172d → 107d | 0% → 100% | 1236d → none |  | was named Vend Fab Torus - Completion of IDR Revised Delivery per CR10-044 |
| 14211045C | Vend Fab Torus - Completion of FDR Revised Delivery per CR10-044 (4B) | 2010-03-01 A | 2011-01-31 → 2010-12-16 A (-46d) | 229d → 204d | 0% → 100% | 1236d → none |  | was named Vend Fab Torus - Completion of FDR Revised Delivery per CR10-044 |
| 14211045D | Vend Fab Torus - Completion Manufacturing Readiness ReviewRevised Delivery per CR10-044 (4C1, 4C2) | 2010-03-01 A | 2011-01-31 → 2012-02-06 A (+371d) | 229d → 481d | 0% → 100% | 1236d → none |  | was named Vend Fab Torus - Completion Manufacturing Readiness ReviewRevised Delivery per CR10-044 |
| 14211050A | Vend Fab Torus - Testing of Prototype Coil (Full Size) (5c,5d) | 2009-11-02 → 2010-03-01 A (+119d) | 2011-03-31 → 2012-02-06 A (+312d) | 346d → 481d | 0% → 100% | 1200d → none |  | was named Vend Fab Torus - Testing of Prototype Coil (Full Size) |
| 14211011E | Torus FY11 Travel | 2010-10-01 A | 2011-09-30 A |  | 0% → 100% | 0d → none |  |  |
| 14211050AdA | Vend Fab Torus - Coil Case Plates-Mill run Phase 3 Funding (17P2) | 2010-11-01 A | 2011-03-31 → 2011-04-01 A (+1d) | 99d → 100d | 0% → 100% | 1319d → none |  | was named Vend Fab Torus - Coil Case Plates-Mill run Phase 3 Funding |
| 14211051 | Vend Fab Torus - Coil Case Plates-CNC machining (17P3) | 2010-11-01 A | 2011-08-31 → 2012-02-06 A (+159d) | 206d → 309d | 0% → 100% | 1319d → none |  | was named Vend Fab Torus - Coil Case Plates-CNC machining |
| 14211051a | Vend Fab Torus - He tracing Tube - OFHC (17P4) | 2010-11-01 A | 2011-08-31 → 2011-04-01 A (-152d) | 206d → 100d | 0% → 100% | 1319d → none |  | was named Vend Fab Torus - He tracing Tube - OFHC |
| 14211051b | Vend Fab Torus - Torus Vac Vessel Plate-Mill run (17P5) | 2010-11-01 A | 2011-08-31 → 2011-04-01 A (-152d) | 206d → 100d | 0% → 100% | 1319d → none |  | was named Vend Fab Torus - Torus Vac Vessel Plate-Mill run |
| 14211051c | Vend Fab Torus - Nitrogen tracing tube (17P6) | 2010-11-01 A | 2011-08-31 → 2011-09-19 A (+19d) | 206d → 218d | 0% → 100% | 1319d → none |  | was named Vend Fab Torus - Nitrogen tracing tube |
| 14211051d | Vend Fab Torus - Torus Vac Vessel Plate-CNC machining (17P7) | 2010-11-01 A | 2011-08-31 A |  | 0% → 100% | 1319d → none |  | was named Vend Fab Torus - Torus Vac Vessel Plate-CNC machining |
| 14211051f | Vend Fab Torus - Torus Coil Hub&Machining (17P8) | 2010-11-01 A | 2011-08-31 → 2012-02-06 A (+159d) | 206d → 309d | 0% → 100% | 1319d → none |  | was named Vend Fab Torus - Torus Coil Hub&Machining |
| 14211051g | Vend Fab Torus - Cryogenic Control Valves (17P9) | 2010-11-01 A | 2011-08-31 → 2012-02-06 A (+159d) | 206d → 309d | 0% → 100% | 1319d → none |  | was named Vend Fab Torus - Cryogenic Control Valves |
| 14211051h | Vend Fab Torus - Current Leads (17P10) | 2010-11-01 A | 2011-08-31 → 2011-04-01 A (-152d) | 206d → 100d | 0% → 100% | 1319d → none |  | was named Vend Fab Torus - Current Leads |
| 14211051j | Vend Fab Torus - Instrumentation Sensors (17P11) | 2010-11-01 A | 2011-08-31 → 2012-02-06 A (+159d) | 206d → 309d | 0% → 100% | 1319d → none |  | was named Vend Fab Torus - Instrumentation Sensors |
| 14211051k | Vend Fab Torus - Dump Switch (17P12) | 2010-11-01 A | 2011-08-31 → 2011-10-24 A (+54d) | 206d → 243d | 0% → 100% | 1319d → none |  | was named Vend Fab Torus - Dump Switch |
| 14211051n | Vend Fab Torus - PLC&Cabinets (17P13) | 2010-11-01 A | 2011-08-31 → 2012-02-06 A (+159d) | 206d → 309d | 0% → 100% | 1319d → none |  | was named Vend Fab Torus - PLC&Cabinets |
| 14211051o | Vend Fab Torus - Cold Mass Suspension Materials (17P14) | 2010-11-01 A | 2011-08-31 → 2011-06-30 A (-62d) | 206d → 163d | 0% → 100% | 1319d → none | 14211051n FS-206d → 14211051n FS-225d | was named Vend Fab Torus - Cold Mass Suspension Materials |
| 14211065 | Vend Fab Torus -Complete and Warm Test Coil #3 (8) | 2010-11-01 → 2010-11-30 A (+29d) | 2012-02-29 → 2012-02-06 A (-23d) | 325d → 290d | 0% → 100% | 1200d → none | 14211060 FS-325d → 14211060 FS-284d | was named Vend Fab Torus -Complete and Warm Test Coil #3; resources PROCUREMENT>$50K 69 NO ESCALATION; PROCUREMENT<$50K 60 NO ESCALATION → PROCUREMENT<$50K 60 NO ESCALATION; PROCUREMENT>$50K 69 NO ESCALATION |
| 14211070 | Vend Fab Torus -Complete and Warm Test Coil #4 (9) | 2010-11-01 → 2010-11-30 A (+29d) | 2012-02-29 → 2012-02-06 A (-23d) | 325d → 290d | 0% → 100% | 1200d → none | 14211065 FS-325d → 14211065 FS-390d | was named Vend Fab Torus -Complete and Warm Test Coil #4 |
| 14211075 | Vend Fab Torus -Complete and Warm Test Coil #5 (10) | 2010-11-01 → 2010-11-30 A (+29d) | 2012-02-29 → 2012-02-06 A (-23d) | 325d → 290d | 0% → 100% | 1200d → none | 14211070 FS-325d → 14211070 FS-432d | was named Vend Fab Torus -Complete and Warm Test Coil #5 |
| 14211080 | Vend Fab Torus -Complete and Warm Test Coil #6 (11) | 2010-11-01 → 2010-11-30 A (+29d) | 2012-02-29 → 2012-02-06 A (-23d) | 325d → 290d | 0% → 100% | 1200d → none | 14211075 FS-325d → 14211075 FS-455d | was named Vend Fab Torus -Complete and Warm Test Coil #6 |
| 14211020 | Torus Vend Contract Support Labor FY11 | 2011-01-05 A | 2011-09-30 → 2011-12-29 A (+90d) | 188d → 244.97d | 0% → 100% | 746d → none | 9-110M FS+60d, 14211010a, 14211015a → 14211010a, 9-110M FS+60d, 14211015a, 14211004A, 14211015, 14211010 | resources SKLLD TRADE [36.83 h]; MECH DES [122.78 h]; ELEC DES [61.39 h]; ELEC ENG [61.39 h]; ELEC TECH [46.04 h]; MECH ENG [245.55 h]; MECH TECH [306.94 h]; SCIENTIST [92.08 h] → ELEC ENG [61.39 h]; ELEC TECH [46.04 h]; MECH DES [122.78 h]; MECH ENG [245.55 h]; MECH TECH [306.94 h]; SCIENTIST [92.08 h]; SKLLD TRADE [36.83 h]; ELEC DES [61.39 h] |
| 14211020a | Torus Vend Contract Support Labor FY12 | 2011-10-03 → 2011-01-05 A (-271d) | 2011-12-29 A | 57d → 245d | 0% → 100% | 746d → none | 14211020 → 14211020 FS-60d | resources ELEC DES [18.61 h]; ELEC ENG [18.61 h]; ELEC TECH [13.96 h]; MECH DES [37.22 h]; MECH ENG [74.45 h]; MECH TECH [93.06 h]; SCIENTIST [27.92 h]; SKLLD TRADE [11.17 h] → MECH ENG [74.45 h]; MECH TECH [93.06 h]; SCIENTIST [27.92 h]; SKLLD TRADE [11.17 h]; ELEC DES [18.61 h]; ELEC ENG [18.61 h]; ELEC TECH [13.96 h]; MECH DES [37.22 h] |
| 14211012E | Torus FY12 Travel | 2011-10-03 A | 2012-09-28 A |  | 0% → 100% | 0d → none |  |  |
| 14211025 | Torus Delivery Installtn & Check-out Original Labor FY13 | 2012-01-05 → 2012-01-03 A (-2d) | 2012-09-28 A | 187d → 188.15d | 0% → 100% | 743d → none | 14211020a, 9-120M FS+60d → 9-120M FS+60d, 14211020, 14211020a | was named Torus Delivery Installtn & Check-out Original Labor FY12; resources ELEC DES [152.65 h]; ELEC ENG [30.53 h]; ELEC TECH [30.53 h]; MECH DES [122.12 h]; MECH ENG [244.24 h]; MECH TECH [457.96 h]; SCIENTIST [30.53 h]; SKLLD TRADE [48.85 h]; MSHOP → ELEC ENG [30.53 h]; ELEC TECH [30.53 h]; MECH DES [122.12 h]; MECH ENG [244.24 h]; MECH TECH [457.96 h]; SCIENTIST [30.53 h]; SKLLD TRADE [48.85 h]; MSHOP; ELEC DES [152.65 h] |
| 14211085 | Reverse Entry per CR12-024 | 2012-02-03 → 2012-02-01 A (-2d) | 2012-02-29 → 2012-02-06 A (-23d) | 18d → 4d | 0% → 100% | 149d → none |  |  |
| 14211025a | Torus Delivery Installtn & Check-out Original Labor FY13 | 2012-10-01 A | 2012-12-21 → 2012-11-19 A (-32d) |  | 0% → 100% | 743d → none |  | resources ELEC TECH [9.47 h]; MECH DES [37.88 h]; MECH ENG [75.76 h]; MECH TECH [142.04 h]; SCIENTIST [9.47 h]; SKLLD TRADE [15.15 h]; MSHOP; ELEC DES [47.35 h]; ELEC ENG [9.47 h] → MECH TECH [142.04 h]; SCIENTIST [9.47 h]; SKLLD TRADE [15.15 h]; MSHOP; ELEC DES [47.35 h]; ELEC ENG [9.47 h]; ELEC TECH [9.47 h]; MECH DES [37.88 h]; MECH ENG [75.76 h] |
| 14211095 | Re-Baseline Actuals Adjustment | 2013-08-30 A | 2013-08-30 A |  | 0% → 100% | 20d → none | 9-130M FS+227d → none |  |
| 24211090 | Wang Torus Settlement | 2013-09-03 A | 2013-09-30 → 2013-09-16 A (-14d) |  | 0% → 100% | 801d → none |  |  |
| 24211095 | Wang Torus Settlement Final | 2013-09-03 A | 2013-09-30 → 2013-09-16 A (-14d) |  | 0% → 100% | 801d → none |  |  |
| 2 | **1.4.2.1.2 SOLENOID** |  | 2013-09-30 → 2013-09-16 (-14d) |  |  |  |  |  |
| 14212009E | Solenoid FY09 Travel | 2009-01-02 A | 2009-09-30 A |  | 0% → 100% | 19d → none |  |  |
| 14212010E | Solenoid FY10 Travel | 2009-10-01 A | 2010-09-30 A |  | 0% → 100% | 19d → none |  |  |
| 14212005 | Solenoid Vend Comp Dsgn Labor FY09 | 2009-01-05 → 2009-11-20 A (+319d) | 2009-09-30 → 2010-09-30 A (+365d) | 188d → 212d | 0% → 100% | 19d → none | 14212002X FS+1d → 14212002X | resources MECH ENG [61.39 h]; ELEC TECH [15.35 h]; MECH TECH [245.55 h]; ELEC ENG [15.35 h]; MECH DES [61.39 h]; VISTNG USERS [92.08 h]; SCIENTIST [15.35 h]; OFFICE [30.69 h] → SCIENTIST [15.35 h]; OFFICE [30.69 h]; MECH DES [61.39 h]; MECH TECH [245.55 h]; ELEC ENG [15.35 h]; ELEC TECH [15.35 h]; VISTNG USERS [92.08 h]; MECH ENG [61.39 h] |
| 14212005b | Solenoid Vend Comp Dsgn Labor FY10 | 2009-10-01 → 2009-11-20 A (+50d) | 2009-12-29 → 2010-09-30 A (+275d) | 57d → 212d | 0% → 100% | 19d → none | 14212005 → 14212005 FS-250d | resources ELEC ENG [4.65 h]; MECH DES [18.61 h]; VISTNG USERS [27.92 h]; SCIENTIST [4.65 h]; OFFICE [9.31 h]; MECH ENG [18.61 h]; ELEC TECH [4.65 h]; MECH TECH [74.45 h] → MECH DES [18.61 h]; MECH TECH [74.45 h]; ELEC ENG [4.65 h]; ELEC TECH [4.65 h]; VISTNG USERS [27.92 h]; MECH ENG [18.61 h]; OFFICE [9.31 h]; SCIENTIST [4.65 h] |
| 14212005c | Vend Fab Solenoid Peg Point #1 Completion of System Requirements Review (SSR) | 2009-11-20 A | 2009-12-30 → 2010-01-18 A (+19d) | 22d → 33d | 0% → 100% | 1200d → none |  |  |
| 14212005d | Vend Fab Solenoid Peg Point #2 Completion of Preliminary Design Review | 2009-11-20 A | 2010-02-26 → 2010-03-01 A (+3d) | 61d → 62d | 0% → 100% | 1200d → none |  |  |
| 14212005f | Vend Fab Solenoid Peg Point #3 Design, Construction and Testing of Prototype Testcoil | 2009-11-20 A | 2010-11-30 → 2012-02-06 A (+433d) | 253d → 542d | 0% → 100% | 1200d → none |  |  |
| 14212005g | Vend Fab Solenoid Peg Point #4 Intermediate Design Review | 2009-11-20 A | 2010-12-30 → 2010-09-30 A (-91d) | 270d → 212d | 0% → 100% | 1200d → none |  |  |
| 14212005h | Vend Fab Solenoid Peg Point #5 Final Design Review | 2009-11-20 A | 2011-02-28 → 2011-05-23 A (+84d) | 309d → 369d | 0% → 100% | 1200d → none |  |  |
| 14212005j | Vend Fab Solenoid Peg Point #6A Manufacturing Readiness Review Phase 1 | 2009-11-20 A | 2011-05-27 → 2012-02-06 A (+255d) | 373d → 542d | 0% → 100% | 1200d → none |  |  |
| 14212005jA | Vend Fab Solenoid Peg Point #6B Manufacturing Readiness Review Phase 2 | 2009-11-20 A | 2011-07-29 → 2012-02-06 A (+192d) | 416d → 542d | 0% → 100% | 1200d → none |  |  |
| 14212005k | Vend Fab Solenoid Peg Point #7 Complete Winding & Coil Assembly of First set coils (1 to 6 modules) | 2009-11-20 A | 2012-02-28 → 2012-02-06 A (-22d) | 557d → 542d | 0% → 100% | 1200d → none |  |  |
| 14212005kA | Vend Fab Solenoid Peg Point #18 Miscellaneous Materials Procurements Phase 1 | 2009-11-20 A | 2011-11-30 → 2012-02-06 A (+68d) | 501d → 542d | 0% → 100% | 1200d → none |  |  |
| 14212007 | Solenoid Vend Comp Dsgn & Prcrmnt Original Labor FY10 | 2009-12-30 → 2010-01-01 A (+2d) | 2010-09-30 A | 191d → 246d | 0% → 100% | 19d → none | 14212005b, 9-100M → 9-100M, 14212005b FS-250d | resources MECH TECH [246.45 h]; VISTNG USERS [92.42 h]; SCIENTIST [15.4 h]; OFFICE [30.81 h]; ELEC ENG [15.4 h]; ELEC TECH [15.4 h]; MECH ENG [61.61 h]; MECH DES [61.61 h] → MECH DES [61.61 h]; ELEC ENG [15.4 h]; ELEC TECH [15.4 h]; VISTNG USERS [92.42 h]; SCIENTIST [15.4 h]; OFFICE [30.81 h]; MECH ENG [61.61 h]; MECH TECH [246.45 h] |
| 14212007a | Solenoid Vend Comp Dsgn & Prcrmnt Original Labor FY11 | 2010-10-01 → 2010-01-01 A (-273d) | 2010-12-29 A | 57d → 246d | 0% → 100% | 19d → none | 14212007 → 14212005b FS-250d, 9-100M | resources ELEC TECH [4.6 h]; MECH ENG [18.39 h]; MECH DES [18.39 h]; MECH TECH [73.55 h]; VISTNG USERS [27.58 h]; SCIENTIST [4.6 h]; OFFICE [9.19 h]; ELEC ENG [4.6 h] → ELEC TECH [4.6 h]; VISTNG USERS [27.58 h]; SCIENTIST [4.6 h]; OFFICE [9.19 h]; MECH ENG [18.39 h]; MECH DES [18.39 h]; MECH TECH [73.55 h]; ELEC ENG [4.6 h] |
| 14212005dA | Vend Fab Solenoid Peg Point #2 Completion of Preliminary Design Review Reverse Entry per CR10-044 | 2010-03-01 A | 2010-03-01 A |  | 0% → 100% | 1200d → none |  |  |
| 14212005dB | Vend Fab Solenoid Peg Point #2 Completion of Preliminary Design Review Revised Delivery per CR10-044 | 2010-03-01 A | 2010-08-31 → 2010-05-24 A (-99d) | 130d → 61d | 0% → 100% | 1202d → none |  |  |
| 14212011E | Solenoid FY11 Travel | 2010-10-01 A | 2011-09-30 A |  | 0% → 100% | 19d → none |  |  |
| 14212005n | Vend Fab Solenoid Peg Point #8 Mid-Term Manufacturing Progress Review | 2011-02-01 → 2010-12-15 A (-48d) | 2012-02-29 → 2012-02-06 A (-23d) | 268d → 279d | 0% → 100% | 1200d → none | 14212005kA5 FS-211d → 14212005kA5 FS-149d, 14212005kA FS-149d |  |
| 14212005o | Vend Fab Solenoid Peg Point #9 Complete Winding & Coil Assembly of Second set coils (7 to 12 modules) | 2011-02-01 → 2010-12-15 A (-48d) | 2012-02-29 → 2012-02-06 A (-23d) | 268d → 279d | 0% → 100% | 1200d → none | 14212005n FS-268d → 14212005n FS-290d |  |
| 14212005p | Vend Fab Solenoid Peg Point #10 Complete Winding & Coil Assembly of Third set coils (13 to 19 modules) | 2011-02-01 → 2010-12-15 A (-48d) | 2012-02-29 → 2012-02-06 A (-23d) | 268d → 279d | 0% → 100% | 1200d → none | 14212005o FS-268d → 14212005o FS-398d |  |
| 14212005q | Vend Fab Solenoid Peg Point #11 Complete Instrumentation and Control | 2011-02-01 → 2010-12-15 A (-48d) | 2012-02-29 → 2012-02-06 A (-23d) | 268d → 279d | 0% → 100% | 1200d → none | 14212005p FS-268d → 14212005p FS-516d |  |
| 14212005r | Vend Fab Solenoid Peg Point #12 Complete Subcontractor Acceptance Test Readiness Review | 2011-02-01 → 2010-12-15 A (-48d) | 2012-02-29 → 2012-02-06 A (-23d) | 268d → 279d | 0% → 100% | 1200d → none | 14212005q FS-268d → 14212005q FS-375d |  |
| 14212005s | Vend Fab Solenoid Peg Point #13 Complete Cryogenic Reservoir Subassembly Phase 1 | 2011-02-01 → 2010-12-15 A (-48d) | 2012-02-29 → 2012-02-06 A (-23d) | 268d → 279d | 0% → 100% | 1200d → none | 14212005r FS-268d → 14212005r FS-348d |  |
| 14212010 | Solenoid Vend Coil Winding Original Labor FY11 | 2010-12-30 A | 2011-09-30 → 2011-12-29 A (+90d) | 191d → 248d | 0% → 100% | 19d → none | 14212007a → 14212007a, 14212007 | resources ELEC ENG [30.81 h]; MECH TECH [308.06 h]; SCIENTIST [46.21 h]; MECH DES [92.42 h]; MECH ENG [92.42 h]; VISTNG USERS [92.42 h] → ELEC ENG [30.81 h]; MECH DES [92.42 h]; MECH TECH [308.06 h]; VISTNG USERS [92.42 h]; SCIENTIST [46.21 h]; MECH ENG [92.42 h] |
| 14212010a | Solenoid Vend Coil Winding Original Labor FY12 | 2011-10-03 → 2010-12-30 A (-277d) | 2011-12-29 A | 57d → 248d | 0% → 100% | 19d → none | 14212010 → 14212010 FS-60d | resources ELEC ENG [9.19 h]; MECH TECH [91.94 h]; SCIENTIST [13.79 h]; MECH DES [27.58 h]; MECH ENG [27.58 h]; VISTNG USERS [27.58 h] → MECH DES [27.58 h]; MECH ENG [27.58 h]; VISTNG USERS [27.58 h]; ELEC ENG [9.19 h]; MECH TECH [91.94 h]; SCIENTIST [13.79 h] |
| 14212015 | Solenoid Vend Compnts Fab Original Labor FY11 | 2010-12-30 A | 2011-09-30 → 2011-12-29 A (+90d) | 191d → 248d | 0% → 100% | 19d → none | 14212007a → 14212007a, 14212007 | resources VISTNG USERS [92.42 h]; MECH TECH [308.06 h]; ELEC ENG [15.4 h]; MECH DES [61.61 h]; ELEC TECH [15.4 h]; SCIENTIST [15.4 h]; MECH ENG [61.61 h] → ELEC TECH [15.4 h]; VISTNG USERS [92.42 h]; SCIENTIST [15.4 h]; MECH ENG [61.61 h]; MECH DES [61.61 h]; MECH TECH [308.06 h]; ELEC ENG [15.4 h] |
| 14212015a | Solenoid Vend Compnts Fab Original Labor FY12 | 2011-10-03 → 2010-12-30 A (-277d) | 2011-12-29 A | 57d → 248d | 0% → 100% | 19d → none | 14212015 → 14212015 FS-60d | resources MECH TECH [91.94 h]; ELEC ENG [4.6 h]; MECH DES [18.39 h]; ELEC TECH [4.6 h]; SCIENTIST [4.6 h]; MECH ENG [18.39 h]; VISTNG USERS [27.58 h] → VISTNG USERS [27.58 h]; MECH TECH [91.94 h]; ELEC ENG [4.6 h]; MECH DES [18.39 h]; ELEC TECH [4.6 h]; SCIENTIST [4.6 h]; MECH ENG [18.39 h] |
| 14212005kA5 | Vend Fab Solenoid Peg Point #18a Miscellaneous Materials Procurements Phase 2 | 2011-02-01 A | 2011-11-30 → 2012-02-06 A (+68d) | 211d → 252d | 0% → 100% | 1200d → none | 14212005kA FS-211d → 14212005kA FS-149d | resources PROCUREMENT<$50K 60 NO ESCALATION; PROCUREMENT>$50K 69 NO ESCALATION → PROCUREMENT>$50K 69 NO ESCALATION; PROCUREMENT<$50K 60 NO ESCALATION |

| ID | Task | Start | Finish | Duration | Complete | Total float | Predecessors | Other |
| --- | --- | --- | --- | --- | --- | --- | --- | --- |
| 14212012E | Solenoid FY12 Travel | 2011-10-03 A | 2012-08-31 A |  | 0% → 100% | 19d → none |  |  |
| 14212020 | Solenoid Vend Assy & Testing Original Labor | 2011-11-23 A | 2012-02-29 A |  | 0% → 100% | 19d → none | 9-120M FS+22d, 14212015a FS-20d, 14212010a FS-20d → 14212010 FS-20d, 14212010a FS-20d, 14212015a FS-20d, 9-120M FS+22d | resources MECH TECH [480 h]; ELEC ENG [20 h]; VISTNG USERS [120 h]; MECH DES [120 h]; SCIENTIST [40 h]; MECH ENG [120 h]; ELEC TECH [40 h] → MECH TECH [480 h]; ELEC ENG [20 h]; ELEC TECH [40 h]; VISTNG USERS [120 h]; SCIENTIST [40 h]; MECH ENG [120 h]; MECH DES [120 h] |
| 14212005sA | Reverse Entry per CR12-024 | 2012-02-03 → 2012-02-01 A (-2d) | 2012-02-29 → 2012-02-06 A (-23d) | 18d → 4d | 0% → 100% | 149d → none |  |  |
| 14212025 | Solenoid Delivery & Qualification Check-out Original Labor | 2012-03-01 A | 2012-08-31 A |  | 0% → 100% | 19d → none |  | resources ELEC TECH [40 h]; MSHOP; VISTNG USERS [120 h]; MECH ENG [120 h]; MECH DES [120 h]; MECH TECH [480 h]; ELEC ENG [20 h] → ELEC ENG [20 h]; MECH ENG [120 h]; MECH DES [120 h]; MECH TECH [480 h]; ELEC TECH [40 h]; VISTNG USERS [120 h]; MSHOP |
| 14212030 | Re-Baseline Actuals Adjustment | 2013-08-30 A | 2013-08-30 A |  | 0% → 100% | 20d → none | 9-130M FS+227d → none |  |
| 24212000 | Wang Solenoid Settlement | 2013-09-03 A | 2013-09-30 → 2013-09-16 A (-14d) |  | 0% → 100% | 801d → none |  | resources PROCUREMENT<$50K 60 NO ESCALATION; PROCUREMENT>$50K 69 NO ESCALATION → PROCUREMENT>$50K 69 NO ESCALATION |
| 24212005 | Wang Solenoid Settlement Final | 2013-09-03 A | 2013-09-30 → 2013-09-16 A (-14d) |  | 0% → 100% | 801d → none |  |  |
| 2 | **1.4.2.2 DETECTORS** | 2008-10-01 → 2009-01-02 (+93d) |  |  |  |  |  |  |
| 1 | **1.4.2.2.1 TRACKING** | 2008-10-01 → 2009-01-02 (+93d) |  |  |  |  |  |  |
| 1 | **1.4.2.2.1.1 SILICON DETECTOR** |  | 2014-12-12 → 2015-02-04 (+54d) |  |  |  |  |  |
| 142211010E | SVT-FY10 Travel | 2009-10-01 A | 2010-09-30 A |  | 0% → 100% | 20d → none |  |  |
| 142211005 | SVT-P-#1 Daq Production, Silicon Sensor Assys Labor FY10 | 2009-11-02 → 2010-10-01 A (+333d) | 2010-09-30 → 2010-10-29 A (+29d) | 226d → 20d | 0% → 100% | 539d → none | 12222015M, 9-100M FS+22d, 12222000a → 12222000a, 9-100M FS+22d, 12222015M, 9-110M | resources ELEC TECH [568.23 h]; COMP SCIENT [180.8 h]; MECH ENG [90.4 h]; MSHOP; MECH TECH [180.8 h]; MECH DES [90.4 h]; CONTRB UNIV LBR [2272.91 h]; PD UNIV STAFF [258.29 h]; SCIENTIST [126.56 h]; ELEC ENG [154.97 h]; ELEC DES [284.11 h]; VISTNG USERS [568.23 h] → ELEC TECH [568.23 h]; MECH DES [90.4 h]; SCIENTIST [126.56 h]; COMP SCIENT [180.8 h]; CONTRB UNIV LBR [2272.91 h]; PD UNIV STAFF [258.29 h]; ELEC DES [284.11 h]; VISTNG USERS [568.23 h]; MSHOP; MECH ENG [90.4 h]; MECH TECH [180.8 h]; ELEC ENG [154.97 h] |
| 142211011E | SVT-FY11 Travel | 2010-10-01 A | 2011-09-30 A |  | 0% → 100% | 20d → none |  |  |
| 142211004 | SVT Assembly Area & Clean Room | 2010-08-02 → 2010-12-01 A (+121d) | 2011-03-31 → 2011-01-24 A (-66d) | 163d → 32d | 0% → 100% | 543d → none | 9-100M FS+205d → 9-100M FS+205d, 9-110M | resources PROCUREMENT>$50K 69 NO ESCALATION FY11; PROCUREMENT<$50K 60 NO ESCALATION FY11 → PROCUREMENT<$50K 60 NO ESCALATION FY11; PROCUREMENT>$50K 69 NO ESCALATION FY11 |
| 142211005b | Vend Fab SVT Barrel Sensors Layers 1-3 Peg Point #1 NRE for Hybrid Mask | 2010-12-07 A | 2011-01-31 → 2011-01-24 A (-7d) | 33d → 28d | 0% → 100% | 20d → none |  |  |
| 142211005c | Vend Fab SVT Barrel Sensors Layers 1-3 Peg Point #2 NRE for Intermediate Mask | 2010-12-07 A | 2011-01-31 → 2011-01-28 A (-3d) | 33d → 32d | 0% → 100% | 20d → none |  |  |
| 142211005d | Vend Fab SVT Barrel Sensors Layers 1-3 Peg Point #3 NRE for FAR Mask | 2010-12-07 A | 2011-01-31 → 2011-01-28 A (-3d) | 33d → 32d | 0% → 100% | 20d → none |  |  |
| 142211005f | Vend Fab SVT Barrel Sensors Layers 1-3 Peg Point #4 NRE for Mask Redesign | 2010-12-07 A | 2011-01-31 → 2011-08-31 A (+212d) | 33d → 182d | 0% → 100% | 20d → none |  |  |
| 142211005g | Vend Fab SVT Barrel Sensors Layers 1-3 Peg Point #5 Hybrid Wafers Qty 3 | 2010-12-07 A | 2011-05-31 → 2011-08-29 A (+90d) | 117d → 180d | 0% → 100% | 20d → none | 142211005f FS-33d → 142211005f FS-90d |  |
| 142211005h | Vend Fab SVT Barrel Sensors Layers 1-3 Peg Point #6 Intermediate Wafers Qty 3 | 2010-12-07 A | 2011-05-31 → 2011-08-29 A (+90d) | 117d → 180d | 0% → 100% | 20d → none |  |  |
| 142211005j | Vend Fab SVT Barrel Sensors Layers 1-3 Peg Point #7 FAR Wafers Qty 3 | 2010-12-07 A | 2011-05-31 → 2011-08-29 A (+90d) | 117d → 180d | 0% → 100% | 20d → none |  |  |
| 142211005k | Vend Fab SVT Barrel Sensors Layers 1-3 Peg Point #8 Hybrid Sensors Qty 120 | 2010-12-07 A | 2012-08-31 → 2012-09-17 A (+17d) | 431d → 441d | 0% → 100% | 20d → none |  |  |
| 142211005n | Vend Fab SVT Barrel Sensors Layers 1-3 Peg Point #9 Intermediate Sensors Qty 120 | 2010-12-07 A | 2012-08-31 → 2012-09-17 A (+17d) | 431d → 441d | 0% → 100% | 187d → none | 142211005k FS-431d → 142211005k FS-281d |  |
| 142211005p | Vend Fab SVT Barrel Sensors Layers 1-3 Peg Point #7 FAR Sensors Qty 120 | 2010-12-07 A | 2012-08-31 → 2012-09-17 A (+17d) | 431d → 441d | 0% → 100% | 187d → none | 142211005n FS-431d → 142211005n FS-281d |  |
| 142211005a | SVT-P-#1 Daq Production, Silicon Sensor Assys Labor FY11 | 2010-10-01 → 2011-01-04 A (+95d) | 2011-04-06 → 2011-01-17 A (-79d) | 124d → 9d | 0% → 100% | 539d → none | 12222015M, 12222000a, 9-100M FS+22d, 142211005 → 142211005 | resources ELEC ENG [85.03 h]; ELEC TECH [311.77 h]; COMP SCIENT [99.2 h]; MECH ENG [49.6 h]; MSHOP; MECH TECH [99.2 h]; ELEC DES [155.89 h]; VISTNG USERS [311.77 h]; MECH DES [49.6 h]; CONTRB UNIV LBR [1247.09 h]; PD UNIV STAFF [141.71 h]; SCIENTIST [69.44 h] → ELEC DES [155.89 h]; VISTNG USERS [311.77 h]; MSHOP; MECH ENG [49.6 h]; MECH TECH [99.2 h]; ELEC ENG [85.03 h]; ELEC TECH [311.77 h]; MECH DES [49.6 h]; SCIENTIST [69.44 h]; COMP SCIENT [99.2 h]; CONTRB UNIV LBR [1247.09 h]; PD UNIV STAFF [141.71 h] |
| 142211004a | Room Preperation and Finishes EEL230 | 2011-03-01 A | 2011-03-31 → 2011-03-25 A (-6d) | 23d → 19d | 0% → 100% | 148d → none |  |  |
| 142211105 | SVT Clean Room Purchase | 2011-03-01 A | 2011-07-29 → 2011-05-31 A (-59d) | 107d → 65d | 0% → 100% | 539d → none |  |  |
| 142211105a | SVT Clean Room Electrical | 2011-03-01 A | 2011-07-29 → 2011-05-31 A (-59d) | 107d → 65d | 0% → 100% | 539d → none |  |  |
| 142211105b | SVT Clean Room Data/Comm | 2011-03-01 A | 2011-07-29 → 2011-05-31 A (-59d) | 107d → 65d | 0% → 100% | 539d → none |  |  |
| 142211105c | SVT Clean Room Demo/Interior Finishes | 2011-03-01 A | 2011-07-29 → 2011-05-31 A (-59d) | 107d → 65d | 0% → 100% | 539d → none |  |  |
| 142211105d | SVT Clean Room Mechanicals | 2011-03-01 A | 2011-07-29 → 2011-05-31 A (-59d) | 107d → 65d | 0% → 100% | 539d → none |  |  |
| 142211105f | SVT Clean Room Sprinklers | 2011-03-01 A | 2011-07-29 → 2011-05-31 A (-59d) | 107d → 65d | 0% → 100% | 539d → none |  |  |
| 142211105g | SVT Clean Room Moving Expenses | 2011-03-01 A | 2011-07-29 → 2011-05-31 A (-59d) | 107d → 65d | 0% → 100% | 539d → none |  |  |
| 142211105h | SVT Clean Room Furniture | 2011-03-01 A | 2011-07-29 → 2011-05-31 A (-59d) | 107d → 65d | 0% → 100% | 539d → none |  |  |
| 142211210 | BST R1-R3 HBI - 6: Cable assemblies: HV, LV, and data (5) 1st article testing - Labor | 2012-04-30 → 2011-03-16 A (-411d) | 2012-07-30 → 2012-05-14 A (-77d) | 64d → 290.5d | 0% → 100% | 187d → none | 9-120M FS+140d, 142211205 → 142211205 FS-100d |  |
| 142211020 | SVT-Production R1, R2, R3 Stave Barrel & Wedge Assy (Frozen by CR11-005) | 2011-02-09 → 2011-04-02 A (+52d) | 2011-07-29 → 2011-08-31 A (+33d) | 120d → 105.31d | 0% → 100% | 539d → none | 142211005a FS-40d, 142211005b FS-40d, 9-110M FS+63d, 142211005 FS-40d → 142211005p FS-242d, 9-110M FS+63d, 142211005b FS-40d, 142211005a FS-40d, 142211005 | resources PD UNIV STAFF [96 h]; MECH TECH [64 h]; MECH ENG [16 h]; COMP SCIENT [32 h]; ELEC ENG [64 h]; ELEC TECH [234.67 h]; CONTRB UNIV LBR [469.2 h]; MECH DES [16 h]; SCIENTIST [26.67 h]; VISTNG USERS [234.67 h]; ELEC DES [117.33 h] → ELEC DES [117.32 h]; MECH DES [16 h]; COMP SCIENT [32 h]; CONTRB UNIV LBR [469.2 h]; PD UNIV STAFF [96 h]; ELEC ENG [64 h]; MECH TECH [64 h]; ELEC TECH [234.68 h]; SCIENTIST [26.67 h]; VISTNG USERS [234.66 h]; MECH ENG [16 h] |
| 142211010a | Reverse Entry per CR11-005 | 2011-08-01 A | 2011-08-05 → 2011-08-29 A (+24d) | 5d → 21d | 0% → 100% | 39d → none | 9-110M FS+204d → 9-110M | resources VISTNG USERS [-352 h]; COMP SCIENT [-112 h]; SCIENTIST [-24 h]; PD UNIV STAFF [-160 h]; MSHOP; MECH TECH [-112 h]; ELEC ENG [-96 h]; ELEC TECH [-352 h]; MECH ENG [-56 h]; MECH DES [-56 h]; ELEC DES [-176 h] → PD UNIV STAFF [-160 h]; MSHOP; MECH TECH [-112 h]; ELEC ENG [-96 h]; ELEC TECH [-352 h]; MECH ENG [-56 h]; MECH DES [-56 h]; ELEC DES [-176 h]; VISTNG USERS [-352 h]; COMP SCIENT [-112 h]; SCIENTIST [-24 h] |
| 142211020a | Reverse Entry per CR11-005 | 2011-08-01 A | 2011-08-05 → 2011-08-31 A (+26d) | 5d → 23d | 0% → 100% | 39d → none | 9-110M FS+204d → 9-110M | resources ELEC DES [-117.33 h]; COMP SCIENT [-32 h]; PD UNIV STAFF [-96 h]; MECH TECH [-64 h]; MECH ENG [-16 h]; ELEC ENG [-64 h]; ELEC TECH [-234.67 h]; MECH DES [-16 h]; SCIENTIST [-26.67 h]; VISTNG USERS [-234.67 h] → COMP SCIENT [-32 h]; PD UNIV STAFF [-96 h]; MECH TECH [-64 h]; MECH ENG [-16 h]; ELEC ENG [-64 h]; ELEC TECH [-234.67 h]; MECH DES [-16 h]; SCIENTIST [-26.67 h]; VISTNG USERS [-234.67 h]; ELEC DES [-117.33 h] |
| 142211109M | HBI - 2011 Replan - Milestone | 2011-08-01 A | 2011-08-01 A |  | 0% → 100% | 20d → none | 9-110M FS+204d → 9-110M |  |
| 142211110 | BST R1-R3 Collab-MSU - Contract award for full chain test, 1st article - Proc | 2011-08-01 A | 2013-01-31 → 2013-02-11 A (+11d) |  | 0% → 100% | 168d → none |  |  |
| 142211120 | HBI - SVT Engineering and Construction Oversight FY11 | 2011-08-01 A | 2011-09-30 → 2011-10-03 A (+3d) | 44d → 44.85d | 0% → 100% | 20d → none |  |  |
| 142211140 | BST R1-R3 HBI - 1 ASIC: ASIC production: testing, and dicing - Proc | 2011-08-01 A | 2012-02-08 → 2011-08-31 A (-161d) | 128d → 23d | 0% → 100% | 197d → none |  |  |
| 142211145 | BST R1-R3 HBI - 2 Sensors: Sensors received and inspected by JLab (1st article and production) - Labor FY11 | 2011-08-01 A | 2011-09-30 → 2011-10-24 A (+24d) | 44d → 59.76d | 0% → 100% | 21d → none | 142211005j FS+42d, 142211005h, 142211005g → 142211005j, 142211005g, 142211005h | resources ELEC TECH [67.26 h]; SCIENTIST [33.63 h]; ELEC ENG [67.26 h] → SCIENTIST [33.63 h]; ELEC ENG [67.26 h]; ELEC TECH [67.26 h] |
| 142211145a | BST R1-R3 HBI - 2 Sensors: Sensors received and inspected by JLab (1st article and production) - Labor FY12 | 2011-10-03 → 2011-08-01 A (-63d) | 2012-09-28 → 2011-10-24 A (-340d) | 247d → 60d | 0% → 100% | 21d → none | 142211145 → 142211145 FS-275d | resources ELEC TECH [377.58 h]; SCIENTIST [188.79 h]; ELEC ENG [377.58 h] → SCIENTIST [188.79 h]; ELEC ENG [377.58 h]; ELEC TECH [377.58 h] |
| 142211145aa | BST R1-R3 HBI - 2 Sensors: Sensors received and inspected by JLab (1st article and production) - Labor FY13 | 2012-10-01 → 2011-08-01 A (-427d) | 2012-10-31 → 2011-10-24 A (-373d) | 23d → 60d | 0% → 100% | 21d → none |  |  |
| 142211155 | BST FNAL - Contract Preparations | 2011-08-01 A | 2011-09-29 → 2011-08-15 A (-45d) | 43d → 11d | 0% → 100% | 21d → none |  | resources ELEC ENG [160 h]; SCIENTIST [160 h] → SCIENTIST [160 h]; ELEC ENG [160 h] |
| 142211190 | BST R1-R3 HBI - 5 Electronics: HFCB validation tests (1st article) - Proc | 2011-08-01 A | 2012-02-08 → 2012-04-16 A (+68d) | 128d → 175d | 0% → 100% | 197d → none |  |  |
| 142211195 | BST R1-R3 HBI - 6: Cable assemblies: HV, LV, and data (1) specifications and procurement prep - Labor FY11 | 2011-08-01 A | 2011-09-30 → 2011-08-31 A (-30d) | 44d → 23d | 0% → 100% | 251d → none |  |  |
| 142211195a | BST R1-R3 HBI - 6: Cable assemblies: HV, LV, and data (1) specifications and procurement prep - Labor FY12 | 2011-10-03 → 2011-08-01 A (-63d) | 2011-10-21 → 2011-08-31 A (-51d) | 15d → 23d | 0% → 100% | 251d → none |  |  |
| 142211200 | BST R1-R3 HBI - 6: Cable assemblies: HV, LV, and data (3) assemble components for fabrication - Labor | 2011-10-24 → 2011-08-01 A (-84d) | 2012-01-27 → 2011-08-29 A (-151d) | 61d → 21d | 0% → 100% | 251d → none |  |  |
| 142211215 | BST R1-R3 HBI - 7 Sloco: HV, LV, PS (1) module components and crates specs and procurement prep - Labor FY11 | 2011-08-01 A | 2011-09-30 → 2012-01-16 A (+108d) | 44d → 111d | 0% → 100% | 83d → none |  | resources ELEC ENG [13.75 h]; MECH TECH [13.75 h] → MECH TECH [13.75 h]; ELEC ENG [13.75 h] |
| 142211215a | BST R1-R3 HBI - 7 Sloco: HV, LV, PS (1) module components and crates specs and procurement prep - Labor FY12 | 2011-10-03 → 2011-08-01 A (-63d) | 2012-02-08 → 2012-01-16 A (-23d) | 84d → 111d | 0% → 100% | 83d → none | 142211215 → 142211215 FS-90d |  |
| 142211235 | BST R1-R3 HBI - 8 DAq: VME: (1) specification and procurement preparation - Labor | 2011-08-01 A | 2011-08-31 → 2011-10-24 A (+54d) | 23d → 59d | 0% → 100% | 297d → none |  |  |
| 142211280 | BST R1-R3 MECH GRP - Modules: 1st article backing structure manufacturing drawing - Labor | 2011-08-01 A | 2011-09-28 → 2011-08-29 A (-30d) | 42d → 21d | 0% → 100% | 421d → none |  |  |
| 142211285 | BST R1-R3 MECH GRP - Modules: 1st article cold plate manufacturing drawing - Labor FY11 | 2011-08-01 A | 2011-09-30 → 2012-01-16 A (+108d) | 44d → 111d | 0% → 100% | 226d → none |  | resources MECH DES [125.71 h]; ELEC ENG [83.81 h]; MECH ENG [125.71 h] → MECH ENG [125.71 h]; MECH DES [125.71 h]; ELEC ENG [83.81 h] |
| 142211285a | BST R1-R3 MECH GRP - Modules: 1st article cold plate manufacturing drawing - Labor FY12 | 2011-10-03 → 2011-08-01 A (-63d) | 2011-11-29 → 2012-01-16 A (+48d) | 40d → 111d | 0% → 100% | 226d → none | 142211285 → 142211285 FS-41d |  |
| 142211305 | BST R1-R3 MECH GRP - Support structure for cold plate 1st article tests: Manufacturing Drawings - Labor | 2011-08-01 A | 2011-09-12 → 2012-01-16 A (+126d) | 30d → 111d | 0% → 100% | 286d → none |  | resources MECH DES [80 h]; MECH ENG [80 h] → MECH ENG [80 h]; MECH DES [80 h] |
| 142211010 | SVT-P-#2 Daq Production, Silicon Sensor Assys (Frozen by CR11-005) | 2011-04-07 → 2011-08-15 A (+130d) | 2011-07-29 → 2011-08-29 A (+31d) | 80d → 11d | 0% → 100% | 539d → none | 142211005, 142211005a, 142211005b, 142211004 → 9-120M, 142211005b, 142211005a, 142211004, 142211005p FS-202d, 142211005 | resources ELEC TECH [352 h]; MECH ENG [56 h]; MECH DES [56 h]; ELEC DES [176 h]; VISTNG USERS [352 h]; COMP SCIENT [112 h]; SCIENTIST [24 h]; PD UNIV STAFF [160 h]; MSHOP; CONTRB UNIV LBR [1408 h]; MECH TECH [112 h]; ELEC ENG [96 h] → COMP SCIENT [112 h]; ELEC DES [176 h]; VISTNG USERS [352 h]; MSHOP; CONTRB UNIV LBR [1408 h]; PD UNIV STAFF [160 h]; MECH ENG [56 h]; MECH DES [56 h]; MECH TECH [112 h]; ELEC ENG [96 h]; ELEC TECH [352 h]; SCIENTIST [24 h] |
| 142211115 | HBI - Hardware infrastructure: configuring and installing- Labor FY11 | 2011-08-30 → 2011-08-15 A (-15d) | 2011-09-30 → 2011-10-24 A (+24d) | 23d → 49.08d | 0% → 100% | 411d → none | 142211109M FS+21d → 142211109M FS+10d |  |
| 142211115a | HBI - Hardware infrastructure: configuring and installing- Labor FY12 | 2011-10-03 → 2011-08-15 A (-49d) | 2012-02-08 → 2011-10-24 A (-107d) | 84d → 50d | 0% → 100% | 411d → none | 142211115 → 142211115 FS-85d |  |
| 142211185 | BST R1-R3 HBI - 5 Electronics: Pitch Adapter - Proc (Full set for 1st article, R1-R3, R4) | 2011-08-01 → 2011-08-15 A (+14d) | 2012-02-08 → 2013-04-15 A (+432d) | 128d → 361d | 0% → 100% | 411d → none |  |  |
| 142211205 | BST R1-R3 HBI - 6: Cable assemblies: HV, LV, and data (4) 1st article - Proc | 2011-10-24 → 2011-08-15 A (-70d) | 2012-01-27 → 2012-02-13 A (+17d) | 61d → 121d | 0% → 100% | 251d → none |  |  |
| 142211505 | BST R4 HBI - 2 Sensors: Sensors for R4 - Proc | 2012-11-28 → 2011-08-15 A (-471d) | 2013-01-07 → 2012-09-17 A (-112d) | 23d → 272d | 0% → 100% | 128d → none | 142211500M, 142211005p FS-78d → 142211500M FS-170d, 142211005p FS-240d |  |
| 142211500M | Start of BST R4 Production | 2012-11-27 → 2011-08-15 A (-470d) | 2012-11-27 → 2011-08-15 A (-470d) |  | 0% → 100% | 128d → none | 142211005p, 9-130M FS+40d → 142211005p FS-170d |  |
| 142211165 | BST R1-R3 HBI - 3: Modules: DAq development front end electronics (1st article) - Labor FY11 | 2011-08-01 → 2011-08-29 A (+28d) | 2011-09-30 → 2012-05-14 A (+227d) | 44d → 175d | 0% → 100% | 20d → none |  | resources ELEC ENG [170.87 h]; SCIENTIST [170.87 h] → SCIENTIST [170.87 h]; ELEC ENG [170.87 h] |
| 142211165a | BST R1-R3 HBI - 3: Modules: DAq development front end electronics (1st article) - Labor FY12 | 2011-10-03 → 2011-08-29 A (-35d) | 2012-05-30 → 2012-05-14 A (-16d) | 162d → 175d | 0% → 100% | 20d → none | 142211165 → 142211165 FS-165d | resources SCIENTIST [629.13 h]; ELEC ENG [629.13 h] → ELEC ENG [629.13 h]; SCIENTIST [629.13 h] |
| 142211170 | BST R1-R3 HBI - 4: DAq: 1st article software - Labor FY11 | 2011-08-01 → 2011-08-29 A (+28d) | 2011-09-30 → 2012-07-16 A (+290d) | 44d → 217.53d | 0% → 100% | 20d → none |  |  |
| 142211170a | BST R1-R3 HBI - 4: DAq: 1st article software - Labor FY12 | 2011-10-03 → 2011-08-29 A (-35d) | 2012-05-25 → 2012-07-16 A (+52d) | 160d → 218d | 0% → 100% | 20d → none | 142211170 → 142211170 FS-165d |  |
| 142211160 | FNAL/Jlab/MSU Testing of 1st article sensors | 2011-09-01 A | 2011-12-30 A |  | 0% → 100% | 21d → none |  |  |
| 142211160a | FNAL Module Design Review | 2011-09-01 A | 2011-10-31 → 2011-10-24 A (-7d) | 42d → 37d | 0% → 100% | 21d → none |  |  |

| ID | Task | Start | Finish | Duration | Complete | Total float | Predecessors | Other |
| --- | --- | --- | --- | --- | --- | --- | --- | --- |
| 142211160b | FNAL Module Design Report & Recommendations | 2011-09-01 A | 2011-10-31 → 2012-01-16 A (+77d) | 42d → 88d | 0% → 100% | 21d → none |  |  |
| 142211160c | FNAL/Jlab Develop Module Construction, Assembly, & QA/QC procedures | 2011-09-01 A | 2011-11-30 → 2012-02-13 A (+75d) | 62d → 108d | 0% → 100% | 21d → none |  |  |
| 142211160d | FNAL Construction & Testing (FNAL/Jlab) of 1st article electrical grade modules | 2011-09-01 A | 2011-11-30 → 2012-01-16 A (+47d) | 62d → 88d | 0% → 100% | 21d → none | 142211150 FS-2d, 142211160c FS-62d → 142211150 FS-20d, 142211160c FS-62d |  |
| 142211160f | FNAL Design of Assembly Fixtures (6.5 months) | 2011-09-01 A | 2012-09-28 → 2012-10-15 A (+17d) | 268d → 279d | 0% → 100% | 21d → none |  |  |
| 142211160g | FNAL Receive & test (Jlab/FNAL) R1-R3 Production Sensors (4 batches) Part A | 2011-09-01 A | 2012-12-31 → 2012-08-20 A (-133d) | 327d → 240d | 0% → 100% | 31d → none | 142211005k FS-250d, 142211160f FS-268d → 142211005k FS-170d, 142211160f FS-268d |  |
| 142211150 | BST R1-R3 HBI - 2 Sensors: Sensors shipped to FNAL (1st article) | 2011-08-05 → 2011-09-12 A (+38d) | 2011-09-02 → 2011-09-26 A (+24d) | 21d → 10d | 0% → 100% | 21d → none | 142211145aa FS-310d, 142211005j → 142211145a FS-310d, 142211145aa FS-310d, 142211005j |  |
| 142211245 | BST R1-R3 HBI - 8 DAq: VME: (3) 1st article testing - Labor | 2011-10-03 A | 2012-02-10 → 2011-10-24 A (-109d) | 86d → 15d | 0% → 100% | 297d → none |  |  |
| 142211260 | BST R1-R3 HBI - 9 DAq-SCM (1) components and PCBs: specification and procurement prep - Labor | 2011-10-03 A | 2011-12-30 → 2011-12-26 A (-4d) | 58d → 56d | 0% → 100% | 168d → none |  |  |
| 142211310 | BST R1-R3 MECH GRP - Support structure for cold plate 1st article tests: procurement prep - Labor FY11 | 2011-09-13 → 2011-10-03 A (+20d) | 2011-09-30 → 2012-01-16 A (+108d) | 14d → 67d | 0% → 100% | 286d → none | 142211305 → 142211305 FS-20d |  |
| 142211310a | BST R1-R3 MECH GRP - Support structure for cold plate 1st article tests: procurement prep - Labor FY12 | 2011-10-03 A | 2011-10-11 → 2012-01-16 A (+97d) | 7d → 67d | 0% → 100% | 286d → none | 142211310 → 142211310 FS-60d |  |
| 142211012E | SVT-FY12 Travel | 2011-10-03 A | 2012-09-28 A |  | 0% → 100% | 20d → none |  |  |
| 142211125 | HBI - SVT Engineering and Construction Oversight FY12 | 2011-10-03 A | 2012-09-28 A |  | 0% → 100% | 20d → none |  |  |
| 142211158M | BST FNAL - 1st article & production SOW Agreement signed (milestone) | 2011-09-01 → 2011-10-03 A (+32d) | 2011-09-01 → 2011-10-03 A (+32d) |  | 0% → 100% | 21d → none |  |  |
| 142211240 | BST R1-R3 HBI - 8 DAq: VME: (2) crates and cards - Proc | 2011-09-01 → 2011-10-17 A (+46d) | 2011-09-30 → 2013-01-28 A (+486d) | 21d → 328d | 0% → 100% | 297d → none |  |  |
| 142211160h | FNAL Receive & test (Jlab/FNAL) R1-R3 Production Sensors (4 batches) Part B | 2012-01-31 → 2011-11-01 A (-91d) | 2012-12-31 → 2012-08-20 A (-133d) | 229d → 198d | 0% → 100% | 20d → none | 142211160g FS-240d, 142211005k FS-151d → 142211160g FS-240d, 142211005k FS-170d |  |
| 142211160j | FNAL QA/QC and Assembly of Fixtures | 2012-01-31 → 2011-11-01 A (-91d) | 2013-01-31 → 2013-01-28 A (-3d) | 250d → 306d | 0% → 100% | 20d → none | 142211160h FS-229d, 142211255a FS-151d, 142211255 FS-151d → 142211160h FS-229d, 142211255a FS-170d, 142211255 FS-170d |  |
| 142211160k | FNAL Construction of 1st article (mechanical grade) modules | 2012-01-31 → 2011-11-01 A (-91d) | 2013-01-31 → 2013-02-11 A (+11d) | 250d → 306d | 0% → 100% | 20d → none | 142211160j FS-250d → 142211160j FS-269d |  |
| 142211160n | FNAL design and construct module shipping containers | 2012-01-31 → 2011-11-01 A (-91d) | 2013-01-31 → 2012-11-12 A (-80d) | 250d → 257d | 0% → 100% | 20d → none | 142211160k FS-250d → 142211160k FS-270d |  |
| 142211160p | FNAL/Jlab/MSU Testing of 1st article (mechanical grade) modules | 2012-01-31 → 2011-11-01 A (-91d) | 2013-01-31 → 2013-02-11 A (+11d) | 250d → 306d | 0% → 100% | 20d → none | 142211180 FS-127d, 142211160n FS-250d, 142211165a FS-85d → 142211160n FS-270d, 142211165 FS-145d, 142211180 FS-185d, 142211165a FS-145d |  |
| 142211160q | FNAL/Jlab review of module testing | 2012-01-31 → 2011-11-01 A (-91d) | 2013-01-31 → 2013-04-15 A (+74d) | 250d → 306d | 0% → 100% | 20d → none | 142211160p FS-250d → 142211160p FS-270d |  |
| 142211160r | FNAL/Jlab revise module construction & assembly & QA/QC procedures | 2012-01-31 → 2011-11-01 A (-91d) | 2013-01-31 → 2013-04-15 A (+74d) | 250d → 306d | 0% → 100% | 20d → none | 142211160q FS-250d → 142211160q FS-270d |  |
| 142211160s | FNAL QA/QC and assembly of production fixtures | 2012-01-31 → 2011-11-01 A (-91d) | 2013-01-31 → 2013-02-22 A (+22d) | 250d → 306d | 0% → 100% | 20d → none | 142211160r FS-250d → 142211160r FS-270d |  |
| 142211160t | FNAL Construction and test (Jlab/FNAL) of R1-R3 production modules (60 modules) Part A | 2012-01-31 → 2011-11-01 A (-91d) | 2013-08-30 A | 398d → 474d | 0% → 100% | 20d → none | 142211160s FS-250d → 142211185 FS-70d, 142211160s FS-365d, 142211360 FS-250d |  |
| 142211325 | BST R1-R3 MECH GRP - Modules:for assy 1st article BST, mounting, and alignment fixture -mfg dwgs | 2011-10-31 → 2011-11-01 A (+1d) | 2012-01-09 → 2012-02-13 A (+35d) | 43d → 66d | 0% → 100% | 237d → none | 142211285a FS-20d, 142211280 FS-162d → 142211285a FS-40d, 142211280 FS-162d |  |
| 142211265 | BST R1-R3 HBI - 9 DAq-SCM (2) system for 1st article - Proc | 2011-10-03 → 2011-12-03 A (+61d) | 2011-12-30 → 2012-02-13 A (+45d) | 58d → 44d | 0% → 100% | 168d → none |  |  |
| 142211405 | BST R1-R3 MECH GRP - Protective enclosure system (1) Manufacturing Drawings - Labor | 2011-12-16 → 2011-12-03 A (-13d) | 2012-02-08 → 2013-08-30 A (+569d) | 32d → 325d | 0% → 100% | 371d → none |  |  |
| 142211450 | BST R1-R3 MECH GRP - Cooling system: preparation, manufacturing drawings - Labor | 2011-12-29 → 2011-12-03 A (-26d) | 2012-03-12 → 2013-07-15 A (+490d) | 50d → 284d | 0% → 100% | 217d → none |  | resources ELEC ENG [80 h]; MECH ENG [120 h]; MECH TECH [40 h]; MECH DES [80 h] → MECH TECH [40 h]; MECH DES [80 h]; ELEC ENG [80 h]; MECH ENG [120 h] |
| 142211290 | BST R1-R3 MECH GRP - Cold plate 1st article model: procurement prep - Labor | 2011-11-30 → 2012-01-16 A (+47d) | 2012-01-05 → 2012-01-23 A (+18d) | 21d → 5d | 0% → 100% | 226d → none | 142211285a → 142211285a FS-20d |  |
| 142211315 | BST R1-R3 MECH GRP - Support structure to hold 1st article tests for cold plate: (1) procurement - Proc | 2011-10-12 → 2012-01-16 A (+96d) | 2011-12-14 → 2012-01-23 A (+40d) | 44d → 5d | 0% → 100% | 286d → none | 142211310a → 142211310a, 142211310 |  |
| 142211320 | BST R1-R3 MECH GRP - Support structure to hold 1st art. tests for cold plate (2) constr/assem (for burn-in tests) - Lab | 2011-12-15 → 2012-01-16 A (+32d) | 2012-02-28 → 2012-01-23 A (-36d) | 46d → 5d | 0% → 100% | 286d → none |  |  |
| 142211330 | BST R1-R3 MECH GRP - Modules:for assy 1st article BST, mounting, and alignment fixture - proc prep - Labor | 2012-04-10 → 2012-01-16 A (-85d) | 2012-05-08 → 2012-07-16 A (+69d) | 21d → 127d | 0% → 100% | 174d → none | 142211325, 9-120M FS+126d → 142211325 FS-20d, 9-120M |  |
| 142211175 | BST R1-R3 HBI - 4: DAq: readout card 1st article - Proc | 2012-05-29 → 2012-02-06 A (-113d) | 2012-06-29 → 2012-02-13 A (-137d) | 23d → 6d | 0% → 100% | 20d → none |  |  |
| 142211270 | BST R1-R3 HBI - 9 DAq-SCM (3) 1st article testing - Labor | 2012-04-03 → 2012-03-03 A (-31d) | 2012-05-29 → 2012-09-17 A (+111d) | 40d → 138d | 0% → 100% | 105d → none |  | was named BST R1-R3 HBI - 9 DAq-SCM (3) custom crate fabrication and 1st article testing - Labor |
| 142211385 | BST R1-R3 HBI - 7 Sloco: Slow controls and charge calibration system: (1) specification and procurement prep - Labor | 2012-02-09 → 2012-03-19 A (+39d) | 2012-05-01 → 2012-04-16 A (-15d) | 58d → 21d | 0% → 100% | 253d → none | 142211160, 142211190 → 142211190 FS-15d, 142211160 |  |
| 142211295 | BST R1-R3 MECH GRP - Cold plate 1st article tests: (1) procurement - Proc | 2012-04-06 → 2012-04-02 A (-4d) | 2012-06-28 → 2012-04-16 A (-73d) | 58d → 11d | 0% → 100% | 163d → none |  |  |
| 142211300 | BST R1-R3 MECH GRP - Cold plate 1st article tests: (2) construct and assemble - Labor | 2012-06-29 → 2012-04-09 A (-81d) | 2012-08-21 → 2012-04-16 A (-127d) | 38d → 6d | 0% → 100% | 163d → none |  |  |
| 142211370 | BST R1-R3 HBI - 6: Cable assemblies: HV, LV, and data fabrication and testing - Labor | 2012-10-02 → 2012-04-16 A (-169d) | 2013-01-03 → 2013-08-30 A (+239d) | 60d → 178d | 0% → 100% | 187d → none | 142211365a, 142211365 → 142211365a FS-250d, 142211365 FS-120d |  |
| 142211400 | BST R1-R3 HBI - 7Sloco:Slow controls for monitor and charge calib system: (4) develop sloco software (1/2) - Labor FY12 | 2012-09-07 → 2012-04-16 A (-144d) | 2012-09-28 → 2012-10-15 A (+17d) | 16d → 127.6d | 0% → 100% | 164d → none | 142211395 FS-121d → 142211395 FS-250d | was named BST R1-R3 HBI - 7Sloco:Slow controls for monitor and charge calib system: (4) develop sloco software (1/2) - Labor |
| 142211400a | BST R1-R3 HBI - 7Sloco:Slow controls for monitor and charge calib system: (4) develop sloco software (1/2) - Labor FY13 | 2012-10-01 → 2012-04-16 A (-168d) | 2013-02-06 → 2013-08-30 A (+205d) | 84d → 208d | 0% → 100% | 164d → none | 142211400 → 142211400 FS-145d |  |
| 142211410 | BST R1-R3 MECH GRP - Protective enclosure system (1) specifications and procurement prep - Labor | 2012-02-09 → 2012-04-16 A (+67d) | 2012-04-05 → 2013-08-30 A (+512d) | 40d → 270d | 0% → 100% | 371d → none | 142211405 → 142211405 FS-150d |  |
| 142211430 | BST R1-R3 HBI - 7 Sloco-Slow controls charge calibration system: develop slow controls (2/2) - Labor | 2012-05-02 → 2012-04-16 A (-16d) | 2012-09-21 → 2012-09-17 A (-4d) | 100d → 108d | 0% → 100% | 253d → none |  |  |
| 142211455 | BST R1-R3 MECH GRP - Cooling system: preparation, procurement prep- Labor | 2012-03-13 → 2012-04-16 A (+34d) | 2012-04-09 → 2013-08-30 A (+508d) | 20d → 208d | 0% → 100% | 217d → none | 142211450 → 142211450 FS-130d |  |
| 142211535 | BST R4 HBI - 6: Cable assemblies: HV, LV, and data (2) R4 - Labor | 2013-02-01 → 2012-04-16 A (-291d) | 2013-05-24 → 2013-08-30 A (+98d) | 80d → 277d | 0% → 100% | 88d → none | 142211530 → 142211530 FS-210d |  |
| 142211220 | BST R1-R3 HBI - 7 Sloco: HV, LV, PS (2) modules 1st article - Proc | 2012-05-09 → 2012-05-01 A (-8d) | 2012-08-09 → 2012-05-14 A (-87d) | 65d → 10d | 0% → 100% | 20d → none |  |  |
| 142211225 | BST R1-R3 HBI - 7 Sloco: HV, LV, PS (3) modules components: 1st article testing - Labor | 2012-08-10 → 2012-05-01 A (-101d) | 2012-09-24 → 2012-08-20 A (-35d) | 31d → 78d | 0% → 100% | 20d → none |  | resources ELEC ENG [40 h]; ELEC TECH [160 h] → ELEC TECH [160 h]; ELEC ENG [40 h] |
| 142211255 | BST JLab - Tooling Production Part A | 2012-06-01 → 2012-05-01 A (-31d) | 2012-08-31 → 2012-12-17 A (+108d) | 65d → 186d | 0% → 100% | 20d → none |  |  |
| 142211275 | BST R1-R3 HBI - 9 DAq-SCM (4) develop program and test (1/2) - Labor FY12 | 2012-04-03 → 2012-05-01 A (+28d) | 2012-09-28 → 2013-01-25 A (+119d) | 126d → 186d | 0% → 100% | 105d → none |  |  |
| 142211275a | BST R1-R3 HBI - 9 DAq-SCM (4) develop program and test (1/2) - Labor FY13 | 2012-10-01 → 2012-05-01 A (-153d) | 2012-11-30 → 2013-01-25 A (+56d) | 43d → 186d | 0% → 100% | 105d → none | 142211275 → 142211275 FS-65d |  |
| 142211365 | BST R1-R3 HBI - 6: Cable assemblies: HV, LV, and data (6) R1 R2 R3 - Proc Part A | 2012-07-31 → 2012-05-01 A (-91d) | 2012-10-01 → 2012-10-13 A (+12d) | 44d → 116d | 0% → 100% | 187d → none |  |  |
| 142211530 | BST R4 HBI - 6: Cable assemblies: HV, LV, and data (1) R4 - Proc | 2012-10-01 → 2012-05-01 A (-153d) | 2013-01-31 → 2013-08-30 A (+211d) | 80d → 186d | 0% → 100% | 88d → none | 9-130M → 9-130M FS-90d |  |
| 142211355M | Start of R1-R3 Production | 2012-09-26 → 2012-07-02 A (-86d) | 2012-09-26 → 2012-07-02 A (-86d) |  | 0% → 100% | 37d → none | 142211350M FS-140d → 142211350M FS-250d |  |
| 142211375 | BST R1-R3 HBI - 7 Sloco: HV, LV, PS (1) modules R1 R2 R3 - Proc | 2012-09-25 → 2012-07-02 A (-85d) | 2012-12-17 → 2013-02-11 A (+56d) | 58d → 144d | 0% → 100% | 74d → none | 142211230, 142211109M → 142211109M, 142211230 FS-120d |  |
| 142211510 | BST R4 HBI - 5 Electronics: HFCB production modules R4 - Proc | 2012-12-19 → 2012-07-02 A (-170d) | 2013-03-21 → 2013-08-30 A (+162d) | 59d → 179d | 0% → 100% | 37d → none | 9-130M, 142211360 → 142211360 FS-275d |  |
| 142211360 | BST R1-R3 HBI - Electronics 5: HFCB modules R1 R2 R3 - Proc | 2012-09-26 → 2012-07-20 A (-68d) | 2012-12-18 → 2013-08-30 A (+255d) | 58d → 141d | 0% → 100% | 37d → none |  |  |
| 142211515 | BST R4 HBI - 5 Electronics: HFCB production modules assembly R4 - Proc | 2013-03-22 → 2012-08-01 A (-233d) | 2013-04-15 → 2013-08-30 A (+137d) | 17d → 157d | 0% → 100% | 37d → none | 142211510 → 142211510 FS-250d |  |
| 142211550 | BST R4 HBI - 9 DAq- SCM custom crate system components R4 - Proc | 2012-10-01 → 2012-08-01 A (-61d) | 2012-10-31 → 2013-02-11 A (+103d) | 23d → 133d | 0% → 100% | 225d → none | 9-130M → 9-130M FS-20d |  |
| 142211180 | BST R1-R3 HBI - 4: DAq: readout card ALTERNATE | 2012-07-02 → 2012-09-03 A (+63d) | 2012-07-30 → 2012-09-10 A (+42d) | 21d → 5d | 0% → 100% | 20d → none | 142211175 → 9-120M FS+225d, 142211175 | was named BST R1-R3 HBI - 4: DAq: readout card R1 R2 R3 - Proc |
| 142211160v | FNAL Receive & test (Jlab/FNAL) R4 Production Sensors (3 batches) | 2012-11-01 → 2012-09-10 A (-52d) | 2013-03-29 → 2012-10-15 A (-165d) | 97d → 26d | 0% → 100% | 128d → none | 142211505 FS-40d → 142211505 |  |
| 142211230 | BST R1-R3 HBI - 7 Sloco: HV, LV, PS (4) crates - Proc (1st Articles and Production) | 2012-08-10 → 2012-09-10 A (+31d) | 2012-09-24 → 2013-05-13 A (+231d) | 31d → 106d | 0% → 100% | 74d → none | 142211220 → 142211220 FS+60d |  |
| 142211540 | BST R4 HBI - 7 Sloco: HV, LV, PS (1) modules R4 - Proc | 2012-10-01 → 2012-09-10 A (-21d) | 2013-01-31 → 2013-07-15 A (+165d) | 80d → 95d | 0% → 100% | 168d → none |  |  |
| 142211013E | SVT-FY13 Travel | 2012-10-01 A | 2013-08-30 A |  | 0% → 100% | 20d → none |  |  |
| 142211130 | HBI - SVT Engineering and Construction Oversight FY13 | 2012-10-01 A | 2013-08-30 A | 228d → 248d | 0% → 100% | 20d → none |  | resources SCIENTIST [1241.13 h] → SCIENTIST [1241.12 h] |
| 142211365a | BST R1-R3 HBI - 6: Cable assemblies: HV, LV, and data (6) R1 R2 R3 - Proc Part B | 2012-07-31 → 2012-10-01 A (+62d) | 2012-10-01 → 2013-04-15 A (+196d) | 44d → 121d | 0% → 100% | 187d → none | 142211210 → 9-130M, 142211210 |  |
| 142211390 | BST R1-R3 HBI - 7 Sloco: Slow controls for monitoring and charge calibration system: (2) component procurement - Proc | 2012-07-12 → 2012-10-01 A (+81d) | 2013-01-31 → 2013-08-30 A (+211d) | 136d → 80d | 0% → 100% | 164d → none | 9-120M FS+191d, 142211385 FS-115d → 142211385 FS+60d, 9-120M FS+250d |  |
| 142211875 | Installation MECH GRP - Transport box BST: (1) manufacturing drawings - Labor | 2012-10-01 → 2012-11-03 A (+33d) | 2013-01-02 → 2012-11-12 A (-51d) | 60d → 6d | 0% → 100% | 155d → none |  |  |
| 142211840 | Installation MECH GRP - Installation cart: (1) MFG Drawings - Labor | 2012-10-01 → 2012-11-05 A (+35d) | 2013-03-29 → 2013-08-30 A (+154d) | 120d → 95d | 0% → 100% | 95d → none |  | resources MECH DES [240 h]; MECH ENG [80 h] → MECH ENG [80 h]; MECH DES [240 h] |
| 142211880 | Installation MECH GRP - Transport box BST: (2) procurement prep - Labor | 2012-11-09 → 2012-11-12 A (+3d) | 2012-12-11 → 2012-11-19 A (-22d) | 21d → 6d | 0% → 100% | 155d → none |  |  |
| 142211885 | Installation MECH GRP - Transport box BST: (3) construct and assemble - Proc | 2012-12-12 → 2012-11-12 A (-30d) | 2013-01-17 → 2012-11-19 A (-59d) | 21d → 6d | 0% → 100% | 155d → none |  |  |
| 142211890 | Installation MECH GRP - Transport box BST: (4) construct and assemble - Labor | 2013-01-18 → 2012-11-12 A (-67d) | 2013-02-20 → 2013-01-18 A (-33d) | 22d → 35d | 0% → 100% | 155d → none |  |  |
| 142211255a | BST JLab - Tooling Production Part B | 2012-06-01 → 2012-12-03 A (+185d) | 2012-08-31 → 2012-12-17 A (+108d) | 65d → 41d | 0% → 100% | 20d → none |  |  |

| ID | Task | Start | Finish | Duration | Complete | Total float | Predecessors | Other |
| --- | --- | --- | --- | --- | --- | --- | --- | --- |
| 142211435 | BST R1-R3 HBI - 9 DAq-SCM (1) custom crate system components R1 R2 R3 - Proc | 2012-12-03 → 2013-01-02 A (+30d) | 2013-03-05 → 2013-02-11 A (-22d) | 59d → 54d | 0% → 100% | 105d → none | 142211275a → 142211275a FS-40d |  |
| 142211465 | BST R1-R3 MECH GRP - Support, cooling, and alignment (1) of stave: manufacturing Drawings - Labor | 2013-04-24 → 2013-01-02 A (-112d) | 2013-07-18 → 2013-08-30 A (+43d) |  | 0% → 100% | 30d → none | 142211350 → 142211350 FS-175d |  |
| 142211395 | BST R1-R3 HBI - 7Sloco:Slow controls for monitoring and charge calib system: (3) assemble, test, and debug - Labor FY12 | 2012-10-08 → 2013-01-15 A (+99d) | 2013-03-08 → 2013-08-30 A (+175d) |  | 0% → 100% | 164d → none | 142211390 FS-75d → 142211390 FS-115d | was named BST R1-R3 HBI - 7Sloco:Slow controls for monitoring and charge calib system: (3) assemble, test, and debug - Labor |
| 142211470 | BST R1-R3 MECH GRP - Support, cooling, and alignment (2) of stave: procurement prep - Labor | 2013-07-19 → 2013-01-31 A (-169d) | 2013-08-16 → 2013-08-30 A (+14d) |  | 0% → 100% | 30d → none | 142211465 → 142211465 FS-90d |  |
| 142211440 | BST R1-R3 HBI - 9 DAq-SCM (2) custom crate fabrication and test - Labor | 2013-03-06 → 2013-02-06 A (-28d) | 2013-05-30 → 2013-02-22 A (-97d) | 61d → 54d | 0% → 100% | 105d → none | 142211435 → 142211435 FS-30d |  |
| 142211520 | BST R4 HBI - 5 Electronics: HFCB assemble electronics for modules - Labor | 2013-04-16 → 2013-02-11 A (-64d) | 2013-08-07 → 2013-08-30 A (+23d) | 80d → 228d | 0% → 100% | 37d → none | 142211515 → 142211515 FS-300d |  |
| 142211380 | BST R1-R3 HBI - 7 Sloco: HV, LV, PS (3) distribution system (fabricate) - Labor | 2012-12-18 → 2013-04-01 A (+104d) | 2013-06-14 → 2013-08-30 A (+77d) | 120d → 116d | 0% → 100% | 74d → none | 142211375 → 142211375 FS+19d |  |
| 142211445 | BST R1-R3 HBI - 9 DAq-SCM (3) develop program and test (2/2) - Labor | 2012-12-03 → 2013-05-03 A (+151d) | 2013-05-01 → 2013-08-30 A (+121d) | 100d → 208d | 0% → 100% | 105d → none | 142211440 FS-120d → 142211440 FS-33d |  |
| 142211335 | BST R1-R3 MECH GRP - Modules: Granite table, mounting, and alignment fixture (1) procurement - Proc | 2012-05-09 → 2013-07-01 A (+418d) | 2012-09-28 → 2013-08-30 A (+336d) | 100d → 45d | 0% → 100% | 174d → none | 142211330 → 142211330, 9-130M FS+120d | was named BST R1-R3 MECH GRP - Modules: round table, mounting, and alignment fixture (1) procurement - Proc |
| 142211340 | BST R1-R3 MECH GRP - 3: Modules: round table, mounting, and alignment fixture (2) construction - Labor | 2012-07-06 → 2013-07-08 A (+367d) | 2012-08-06 → 2013-08-30 A (+389d) | 22d → 10d | 0% → 100% | 174d → none | 9-120M FS+76d, 142211335 FS-60d → 9-120M FS+76d, 142211335 FS-45d |  |
| 142211350 | BST R1-R3 MECH GRP - 3: Modules 1st article stave tests mount & aligning of modules in model of cold plate - Labor FY12 | 2013-03-26 → 2013-08-30 A (+157d) | 2013-04-23 → 2013-08-30 A (+129d) | 21d → 24d | 0% → 100% | 20d → none | 142211340, 142211245, 142211230, 142211320, 142211300, 142211225 FS+120d, 142211460 → 142211460 FS-130d, 142211225 FS+144d, 142211300, 142211245, 142211230 FS+18d, 142211340, 142211320 | was named BST R1-R3 MECH GRP - 3: Modules 1st article stave tests mount & aligning of modules in model of cold plate - Labor |
| 142211350M | End of 1st Article Program | 2013-04-23 → 2013-08-30 A (+129d) | 2013-04-23 → 2013-08-30 A (+129d) |  | 0% → 100% | 37d → none | 142211350 → 142211160p |  |
| 142211460 | BST R1-R3 MECH GRP - Cooling system: procurement - proc | 2012-04-10 → 2013-08-30 A (+507d) | 2012-06-06 → 2013-08-30 A (+450d) | 40d → 54d | 0% → 100% | 217d → none |  |  |
| 142211800 | Installation MECH GRP - Support and alignment tube (1) to mount solenoid, MFG Drawings (incl. alignment system) - Labor | 2013-04-24 → 2013-08-30 A (+128d) | 2013-08-30 A | 91d → 97d | 0% → 100% | 20d → none |  |  |
| 142211845 | Installation MECH GRP - Installation cart: (2) procurement prep - Labor | 2013-02-14 → 2013-08-30 A (+197d) | 2013-03-15 → 2013-08-30 A (+168d) |  | 0% → 100% | 95d → none |  |  |
| 142211850 | Installation MECH GRP - Installation cart: (3) construction - Proc | 2013-03-18 → 2013-08-30 A (+165d) | 2013-04-16 → 2013-08-30 A (+136d) |  | 0% → 100% | 95d → none |  |  |
| 142211855 | Installation MECH GRP - Installation cart: (4) construction - Labor | 2013-04-17 → 2013-08-30 A (+135d) | 2013-05-15 → 2013-08-30 A (+107d) |  | 0% → 100% | 95d → none |  |  |
| 142211860 | Installation MECH GRP - Purging system: (1) procurement prep - Labor | 2012-10-01 → 2013-08-30 A (+333d) | 2012-10-29 → 2013-08-30 A (+305d) |  | 0% → 100% | 184d → none | 9-130M → 9-130M, 9-140M |  |
| 142211865 | Installation MECH GRP - Purging system: (2) installation - Proc | 2012-10-30 → 2013-08-30 A (+304d) | 2012-11-30 → 2013-08-30 A (+273d) | 22d → 21d | 0% → 100% | 184d → none |  |  |
| 142211870 | Installation MECH GRP - Purging system: (3) installation - Labor | 2012-12-03 → 2013-08-30 A (+270d) | 2013-01-08 → 2013-08-30 A (+234d) |  | 0% → 100% | 184d → none |  |  |
| 142211950 | Re-Baseline Actuals Adjustment | 2013-08-30 A | 2013-08-30 A |  | 0% → 100% | 20d → none | 9-130M FS+227d → none |  |
| 242211013E | SVT-FY13 Travel | 2013-09-03 A | 2013-09-30 A |  | 0% → 100% | 719d → none |  |  |
| 242211130 | HBI - SVT Engineering and Construction Oversight FY13 | 2013-09-03 A | 2013-09-30 A |  | 0% → 100% | 719d → none |  |  |
| 242211160t | FNAL Construction and test (Jlab/FNAL) of R1-R3 production modules (60 modules) Part A | 2013-09-03 A | 2014-05-30 → 2014-03-11 (-80d) |  | 0% → 85% | 229d → 329d |  | resources PROCUREMENT<$50K 60 NO ESCALATION → PROCUREMENT>$50K 69 NO ESCALATION |
| 242211160u | FNAL Construction and test (Jlab/FNAL) of R1-R3 production modules (60 modules) Part B | 2013-09-03 A |  |  |  | 233.75d → 276.75d |  |  |
| 242211160w | FNAL Construction and test (Jlab/FNAL) of R4 production modules Phase 1 | 2013-09-03 A |  |  |  | 262d → 305d |  |  |
| 242211335 | MECH GRP - Modules: asssembly table, mounting, and alignment fixture procurement - Proc | 2013-09-03 A | 2013-09-13 → 2013-09-10 A (-3d) |  | 0% → 100% | 255d → none |  |  |
| 242211360 | HBI - Electronics HFCB R1-R4 - Proc | 2013-09-03 A |  |  |  | 329d → 305d |  |  |
| 242211361 | HBI - Electronics HFCB R1-R4 - Proc First Article 6 cables | 2013-09-03 A | 2013-09-20 → 2013-12-20 (+91d) |  |  | 527d → 470d |  | resources PROCUREMENT<$50K 60 NO ESCALATION → PROCUREMENT>$50K 69 |
| 242211365a | HBI - Cable assemblies: HV, LV, and data - Proc | 2013-09-03 A | 2014-01-31 → 2014-03-05 (+33d) |  | 0% → 13% | 322.75d → 299.75d |  | resources PROCUREMENT<$50K 60 NO ESCALATION; PROCUREMENT>$50K 69 NO ESCALATION → PROCUREMENT<$50K 60 NO ESCALATION FY14 |
| 242211367 | HBI - Cable assemblies: Pulser | 2013-09-03 A | 2014-03-31 → 2014-05-01 (+31d) |  |  | 281.75d → 258.75d |  |  |
| 242211370 | HBI - Cable assemblies: HV, LV, and data fabrication and testing R1-R4 - Labor FY13 | 2013-09-03 A | 2013-09-30 → 2014-05-30 (+242d) | 20d → 182d | 0% → 12% |  |  |  |
| 242211370a | HBI - Cable assemblies: HV, LV, and data fabrication and testing R1-R4 - Labor FY14 | 2013-10-01 → 2013-09-03 A (-28d) |  |  | 0% → 12% |  | 9-130M FS+228d, 242211370 → 242211370 FS-162d |  |
| 242211380 | HBI - Sloco: HV, LV, PS distribution system (fabricate) - Labor | 2013-11-01 → 2013-09-03 A (-59d) | 2013-11-15 → 2013-10-21 A (-25d) |  | 0% → 100% | 255d → none | 9-140M FS+23d → 9-140M |  |
| 242211405a | Obligated Procured Labor for Activity 242211405 | 2013-09-03 A | 2014-02-03 → 2013-09-23 A (-133d) |  | 0% → 100% | 299d → none |  |  |
| 242211465 | MECH GRP - Support, cooling, coldplate, and alignment of stave: manufacturing Drawings - Labor | 2013-09-03 A | 2013-09-20 A |  | 0% → 100% | 255d → none |  |  |
| 242211490 | HBI - Module R1-R4 : quality assurance, test, and burn-in at FNAL - Labor FY13 | 2013-09-03 A | 2013-09-30 → 2014-09-30 (+365d) | 20d → 267d | 0% → 8% |  |  |  |
| 242211490a | HBI - Module R1-R4 : quality assurance, test, and burn-in at FNAL - Labor FY14 | 2013-10-01 → 2013-09-03 A (-28d) |  |  | 0% → 8% |  | 242211160w5 FS-300d, 242211490, 242211160w FS-300d, 242211160u FS-186.75d, 242211160t FS-182d → 242211490 FS-247d | resources ELEC ENG [823.33 h]; ELEC TECH [823.33 h]; VISTNG USERS [1665.17 h] → ELEC TECH [823.33 h]; VISTNG USERS [1665.17 h]; ELEC ENG [823.33 h] |
| 242211515 | HBI - Electronics: HFCB Population - Proc Part A | 2013-09-03 A |  |  | 0% → 9% | 393d → 512d |  | was named HBI - Electronics: HFCB assembly - Proc Part A |
| 242211530 | HBI - Compunetics HFCB Bend Test - Proc | 2013-09-03 A | 2013-09-30 → 2013-09-23 A (-7d) |  | 0% → 100% | 527d → none |  |  |
| 242211605 | HBI - Bus cable PCB production - Proc | 2013-09-03 A |  |  | 0% → 21% | 266d → 450d |  |  |
| 242211610 | HBI - Bus cable PCB receive and Test - Labor FY13 | 2013-09-05 → 2013-09-03 A (-2d) | 2013-09-30 → 2013-12-20 (+81d) | 18d → 75d | 0% → 50% | 266d → 409d |  |  |
| 242211610a | HBI - Bus cable PCB receive and Test - Labor FY14 | 2013-10-01 → 2013-09-03 A (-28d) |  |  | 0% → 50% | 266d → 409d | 242211610, 242211605 FS-60d → 242211610 FS-60d |  |
| 242211620 | FNAL Tooling | 2013-09-03 A | 2013-09-30 → 2013-09-23 A (-7d) |  | 0% → 100% | 551d → none |  |  |
| 242211670 | INFRA STR - Integrated Humidity Reduction System for SVT Control room - Proc | 2013-09-03 A | 2013-10-31 → 2013-12-20 (+50d) |  | 0% → 82% | 453d → 419d |  |  |
| 242211705 | MECH GRP - Tooling for assembly and repairs: manufacturing Drawings - Labor/Expenses FY13 | 2013-09-03 A | 2013-09-30 → 2013-10-21 A (+21d) | 20d → 31d | 0% → 100% | 256.5d → none |  |  |
| 242211705a | MECH GRP - Tooling for assembly and repairs: manufacturing Drawings - Labor/Expenses FY14 | 2013-10-01 → 2013-09-03 A (-28d) | 2013-10-15 → 2013-10-21 A (+6d) |  | 0% → 100% | 256.5d → none | 9-130M FS+228d, 242211705 → 242211705 FS-10d |  |
| 242211755 | HBI - Additional HFCB - Proc | 2013-09-03 A |  |  |  |  |  |  |
| 242211885 | MECH GRP - Module inserts Copper/PEEK Part A | 2013-10-01 → 2013-09-03 A (-28d) | 2013-12-17 → 2013-09-23 A (-85d) |  | 0% → 100% | 530d → none |  |  |
| 242211470 | MECH GRP - Support, cooling, coldplate, and alignment of stave: procurement prep - Labor | 2013-09-23 → 2013-09-16 A (-7d) | 2013-09-30 → 2013-10-21 A (+21d) |  | 0% → 100% | 255d → none |  |  |
| 242211875 | MECH GRP - Construct silicon module shipping containers -Proc Part A | 2013-10-01 → 2013-09-16 A (-15d) |  |  | 0% → 20% |  |  |  |
| 242211014E | SVT-FY14 Travel | 2013-10-01 A |  |  | 0% → 9% |  |  |  |
| 242211140 | HBI - SVT Engineering and Construction Oversight FY14 | 2013-10-01 A |  |  | 0% → 9% |  |  |  |
| 242211340 | MECH GRP - Modules: assembly table, mounting, and alignment fixture construction - Labor | 2013-10-04 → 2013-10-01 A (-3d) | 2013-10-31 → 2013-10-21 A (-10d) |  | 0% → 100% | 255d → none |  |  |
| 242211390 | HBI - Sloco: Slow controls for monitoring and charge calibration system: component procurement - Proc | 2013-10-01 A | 2013-12-20 → 2014-02-04 (+46d) |  | 0% → 2% | 377d → 354d | 9-140M → 9-140M FS+23d |  |
| 242211405 | MECH GRP - Faraday cage protective enclosure system Manufacturing Drawings - Labor | 2013-10-01 A |  |  | 0% → 15% | 299d → 312d |  |  |
| 242211410 | MECH GRP - Faraday cage protective enclosure system specifications and procurement prep - Labor FY13 | 2013-09-03 → 2013-10-01 A (+28d) | 2013-09-30 → 2014-02-13 (+136d) |  | 0% → 50% |  | 242211405a FS-99d, 242211405 FS-99d → 242211405a FS-69d, 242211405 FS-69d |  |
| 242211410a | MECH GRP - Faraday cage protective enclosure system specifications and procurement prep - Labor FY14 | 2013-10-01 A |  | 87d → 57d | 0% → 50% |  | 242211405a FS-99d, 242211405 FS-99d, 242211410 → 242211410 FS-64d |  |
| 242211460 | MECH GRP - Cooling system: procurement - proc | 2013-10-04 → 2013-10-01 A (-3d) |  |  | 0% → 5% |  |  |  |
| 242211635 | HBI - LV cards - Proc | 2013-10-01 A |  | 119d → 118d |  |  | 9-140M → 9-140M FS+23d |  |
| 242211655 | HBI - VXS crate - Proc | 2013-10-01 A |  | 119d → 118d |  |  | 9-140M → 9-140M FS+23d |  |
| 242211685 | MECH GRP - Region 4 Support, cooling, coldplate, and alignment structure: manufacturing Drawings - Labor | 2013-10-15 → 2013-10-01 A (-14d) |  |  | 0% → 15% |  |  |  |
| 242211710 | MECH GRP - Tooling for assembly and repairs: procurement prep - Labor FY13 | 2013-09-03 → 2013-10-01 A (+28d) | 2013-09-30 → 2013-12-19 (+80d) |  | 0% → 50% | 256.5d → 214d | 242211705 FS-31d, 242211705a FS-31d → 242211705a, 242211705 |  |
| 242211710a | MECH GRP - Tooling for assembly and repairs: procurement prep - Labor FY14 | 2013-10-01 A | 2013-11-01 → 2013-12-19 (+48d) |  | 0% → 50% | 256.5d → 214.5d | 242211705 FS-31d, 242211705a FS-31d, 242211710 → 242211710 FS-40d, 242211705a FS-31d |  |
| 242211445 | HBI - DAq-VSCM develop program and test - Labor | 2013-10-17 → 2013-10-15 A (-2d) |  |  | 0% → 8% |  |  |  |
| 242211715 | MECH GRP - Tooling for assembly and repairs - Proc | 2013-09-03 → 2013-11-01 (+59d) | 2013-12-02 → 2014-02-11 (+71d) |  |  | 256.5d → 214d | 242211710 FS-43d, 242211710a FS-43d → 242211710 FS-33d, 242211710a FS-33d |  |
| 242211475 | MECH GRP - Support, cooling, coldplate, and alignment of stave - Proc | 2013-10-01 → 2013-11-15 (+45d) | 2013-10-31 → 2014-01-31 (+92d) | 23d → 45d |  | 255d → 200d | 242211470 → 242211470 FS+18d |  |
| 242211520 | HBI - Electronics: HFCB Population - Proc Part B |  |  |  |  | 329d → 305d |  | was named HBI - Electronics: HFCB assembly - Proc Part B |
| 242211400a | HBI - Sloco:Slow controls for monitor and charge calib system: develop sloco software (1/2) - Labor | 2014-01-07 → 2014-01-03 (-4d) | 2014-06-10 → 2014-06-06 (-4d) |  |  | 307d → 309d |  |  |
| 242211890 | MECH GRP - Module inserts Copper/PEEK Part B | 2014-01-07 → 2014-01-03 (-4d) | 2014-03-24 → 2014-03-20 (-4d) |  |  | 470d → 615d |  |  |

| ID | Task | Start | Finish | Duration | Complete | Total float | Predecessors | Other |
| --- | --- | --- | --- | --- | --- | --- | --- | --- |
| 242211825 | Installation MECH GRP - AC Distribution - proc prep - Labor | 2014-01-09 → 2014-01-07 (-2d) | 2014-01-23 → 2014-01-21 (-2d) |  |  | 434d → 436d |  |  |
| 242211830 | Installation MECH GRP - AC Distribution - Proc | 2014-01-24 → 2014-01-22 (-2d) | 2014-02-21 → 2014-02-19 (-2d) |  |  | 434d → 436d |  |  |
| 242211800 | Installation MECH GRP - Support and alignment tube, MFG Drawings - Labor | 2014-02-03 → 2014-01-30 (-4d) | 2014-04-01 → 2014-03-28 (-4d) |  |  | 294d → 296d |  |  |
| 242211480 | MECH GRP - Support, cooling, coldplate, and alignment of stave Faraday Cage inner: construct and assemble - Labor | 2013-11-01 → 2014-02-03 (+94d) | 2013-11-15 → 2014-02-17 (+94d) |  |  | 255d → 200d |  |  |
| 242211745 | MECH GRP - Environmental Control System - Proc | 2014-02-05 → 2014-02-03 (-2d) | 2014-09-22 → 2014-09-18 (-4d) |  |  | 235d → 237d |  |  |
| 242211395 | HBI - Sloco:Slow controls for monitoring and charge calib system: assemble, test, and debug ADC's- Labor | 2014-01-02 → 2014-02-05 (+34d) | 2014-03-03 → 2014-04-03 (+31d) |  |  | 377d → 354d |  |  |
| 242211720 | MECH GRP - Tooling for assembly and repairs construct and assemble - Labor | 2013-12-02 → 2014-02-12 (+72d) | 2014-01-02 → 2014-03-04 (+61d) |  |  | 256.5d → 214d |  |  |
| 242211485 | MECH GRP - Mounting and aligning on support structure in lab, R1-R3 - Labor | 2013-11-18 → 2014-02-18 (+92d) | 2014-05-15 → 2014-08-04 (+81d) |  |  | 255d → 200d |  |  |
| 242211615 | HBI - Full system R1-R3, test and burn-in in Cleanroom EEL 121 - Labor | 2013-12-10 → 2014-02-28 (+80d) | 2014-06-02 → 2014-08-11 (+70d) |  |  | 249d → 200d |  |  |
| 242211875a | MECH GRP - Construct silicon module shipping containers -Proc Part B | 2014-03-05 → 2014-03-04 (-1d) | 2014-07-22 → 2014-07-21 (-1d) |  |  | 247d → 248d |  |  |
| 242211805 | Installation MECH GRP - Support & alignment tube - Proc - prep - Labor | 2014-04-02 → 2014-03-31 (-2d) | 2014-04-15 → 2014-04-11 (-4d) |  |  | 294d → 296d |  |  |
| 242211660 | INFRA STR - Backup Environmental and power system for SVT Clean Room - Proc | 2014-04-02 → 2014-04-01 (-1d) | 2014-06-02 → 2014-05-30 (-3d) |  |  | 313d → 314d |  |  |
| 242211675 | INFRA STR - Integrated Humidity Reduction System for SVT Control room - Proc | 2014-04-02 → 2014-04-01 (-1d) | 2014-06-02 → 2014-05-30 (-3d) |  |  | 313d → 314d |  |  |
| 242211810 | Installation MECH GRP - Support and alignment tube - Proc | 2014-04-16 → 2014-04-14 (-2d) | 2014-06-02 → 2014-05-29 (-4d) |  |  | 294d → 296d |  |  |
| 242211160w5 | FNAL Construction and test (Jlab/FNAL) of R4 production modules Phase 2 | 2013-09-03 → 2014-04-23 (+232d) |  | 267d → 112d |  | 262d → 305d | 242211515 FS-325d, 242211520 FS-325d, 242211160u FS-182d → 242211520 FS-70d, 242211515 FS-325d, 242211160u FS-182d |  |
| 242211860 | Installation MECH GRP - Purging system: procurement prep - Labor | 2014-05-14 → 2014-05-13 (-1d) | 2014-05-28 → 2014-05-27 (-1d) |  |  | 275d → 276d |  |  |
| 242211865 | Installation MECH GRP - Purging system: installation - Proc | 2014-05-29 → 2014-05-28 (-1d) | 2014-06-26 → 2014-06-25 (-1d) |  |  | 275d → 276d |  |  |
| 242211815 | Installation MECH GRP - Support and alignment (construction) - Labor | 2014-06-03 → 2014-05-30 (-4d) | 2014-06-27 → 2014-06-25 (-2d) |  |  | 294d → 296d |  |  |
| 242211545 | MECH GRP - Mounting and aligning on support structure in lab, R4 - Labor | 2014-05-19 → 2014-07-29 (+71d) | 2014-08-04 → 2014-10-13 (+70d) |  |  | 249d → 200d |  |  |
| 242211600 | HBI - Full system R4, test and burn-in in Cleanroom EEL 121 - Labor | 2014-07-22 → 2014-09-30 (+70d) | 2014-08-18 → 2014-10-27 (+70d) |  |  | 259d → 210d |  |  |
| 242211870 | Installation MECH GRP - Purging system: installation in clean room- Labor | 2014-08-05 → 2014-10-14 (+70d) | 2014-09-02 → 2014-11-10 (+69d) |  |  | 249d → 200d |  |  |
| 242211680 | MECH GRP - Full system test Integration of SVT R3/R4 - Labor | 2014-10-01 → 2014-11-11 (+41d) | 2014-12-12 → 2015-02-04 (+54d) |  |  | 229d → 200d |  |  |
| 242211918M | SVT Ready for Installation | 2014-12-12 → 2015-02-04 (+54d) | 2014-12-12 → 2015-02-04 (+54d) |  |  | 229d → 200d |  |  |
| 3 | **1.4.2.2.1.3 FORWARD DRIFT CHAMBERS** | 2008-10-01 → 2009-01-02 (+93d) |  |  |  |  |  |  |
| 142213009E | FY09 Travel (FWD Chambers) | 2009-01-02 A | 2009-09-30 A |  | 0% → 100% | 248d → none |  |  |
| 142213000M | DC-P-#1 Constrction Start P-#1 (F DRFT CHAM) | 2008-10-01 → 2009-04-01 A (+182d) | 2008-10-01 → 2009-04-01 A (+182d) |  | 0% → 100% | 392d → none |  |  |
| 142213017 | P-#1 Proc Endplates & Frames LABOR Initial | 2009-01-05 → 2009-05-01 A (+116d) | 2009-04-30 → 2009-06-30 A (+61d) | 82d → 42d | 0% → 100% | 60d → none | 9-090M FS+60d → 9-090M FS+60d, 142213000M | resources SCIENTIST [60.55 h]; CONTRB UNIV LBR [121.11 h]; PD UNIV STAFF [565.17 h]; MECH DES [141.3 h]; MECH ENG [80.74 h]; MECH TECH [222.03 h] → MECH DES [141.3 h]; MECH ENG [80.74 h]; MECH TECH [222.03 h]; SCIENTIST [60.55 h]; CONTRB UNIV LBR [121.11 h]; PD UNIV STAFF [565.17 h] |
| 142213020 | P-#1 Proc Box Assy. & Fixtures LABOR | 2009-05-06 A | 2009-07-30 → 2010-02-26 A (+211d) | 60d → 200d | 0% → 100% | 196d → none |  | was named P-#1 Proc Box Assy. Fixtures LABOR |
| 142213022 | P-#1 Proc Wires, Pins and Feedthroughs LABOR | 2009-05-06 A | 2009-09-30 → 2010-03-15 A (+166d) | 103d → 211d | 0% → 100% | 247d → none | 142213000M, 9-090M FS+145d → 9-090M FS+145d |  |
| 142213022P | P-#1 Proc Wires, Pins and Feedthroughs | 2009-05-06 A | 2010-03-08 → 2010-06-30 A (+114d) | 206d → 287d | 0% → 100% | 144d → none |  |  |
| 142213030 | P-#1 Proc Circuit Boards LABOR | 2009-05-06 A | 2009-09-09 → 2009-10-12 A (+33d) | 88d → 111d | 0% → 100% | 262d → none |  | resources ELEC DES [704 h]; ELEC ENG [40 h]; ELEC TECH [40 h] → ELEC ENG [40 h]; ELEC TECH [40 h]; ELEC DES [704 h] |
| 142213030P | P-#1 Proc Circuit Boards | 2009-07-31 → 2009-05-06 A (-86d) | 2009-12-08 → 2009-09-29 A (-70d) | 90d → 102d | 0% → 100% | 200d → none | 9-090M FS+205d → 9-090M |  |
| 142213017P | P-#1 Proc Frames/Endplates | 2009-05-13 A | 2009-10-20 → 2010-02-26 A (+129d) | 112d → 195d | 0% → 100% | 139d → none |  |  |
| 142213020P | P-#1 Proc Box Assy. & Fixtures | 2009-05-20 → 2009-05-13 A (-7d) | 2009-08-13 → 2010-01-29 A (+169d) | 60d → 175.99d | 0% → 100% | 186d → none |  | was named P-#1 Proc Box Assy. Fixtures |
| 142213035 | P-#1 Build Stringing Fixtures, Machines and Platforms | 2009-05-06 → 2009-06-01 A (+26d) | 2009-09-30 → 2010-03-19 A (+170d) | 103d → 198d | 0% → 100% | 247d → none | 9-090M FS+145d → 9-090M | resources MECH ENG [206 h]; PLABOR; SKLLD TRADE [64 h]; CONTRB UNIV LBR [360 h]; MECH TECH [218.4 h] → PLABOR; SKLLD TRADE [64 h]; CONTRB UNIV LBR [360 h]; MECH TECH [218.4 h]; MECH ENG [206 h] |
| 142213035P | P-#1 Proc Cleanroom Fixtures and Equipment | 2009-06-11 → 2009-06-01 A (-10d) | 2009-07-23 → 2009-12-21 A (+151d) | 30d → 141d | 0% → 100% | 295d → none |  |  |
| 142213017A | P-#1 Proc Endplates & Frames LABOR Final FY09 | 2009-05-01 → 2009-07-01 A (+61d) | 2009-09-30 → 2010-02-22 A (+145d) | 106d → 157d | 0% → 100% | 60d → none |  | resources MECH TECH [199.89 h]; CONTRB UNIV LBR [59.64 h] → CONTRB UNIV LBR [59.64 h]; MECH TECH [199.89 h] |
| 142213017Ab | P-#1 Proc Endplates & Frames LABOR Final FY10 | 2009-10-01 → 2009-09-30 A (-1d) | 2009-10-28 → 2010-02-22 A (+117d) | 20d → 93d | 0% → 100% | 60d → none | 142213017A → 142213017A FS-300d | resources MECH TECH [37.71 h]; CONTRB UNIV LBR [11.25 h] → CONTRB UNIV LBR [11.25 h]; MECH TECH [37.71 h] |
| 142213010E | FY10 Travel (FWD Chambers) | 2009-10-01 A | 2010-09-30 A |  | 0% → 100% | 248d → none |  |  |
| 142213100M | P-#2 Constrction Start P-#2 | 2009-10-01 A | 2009-10-01 A |  | 0% → 100% | 184d → none |  |  |
| 142213122P | P-#2 Proc Wires, Pins and Feedthroughs | 2009-10-15 → 2009-10-01 A (-14d) | 2010-02-02 → 2010-06-15 A (+133d) | 70d → 173d | 0% → 100% | 352d → none |  |  |
| 142213042 | P-#1 String Chambers Initial | 2010-03-16 → 2009-10-12 A (-155d) | 2010-05-28 → 2010-06-28 A (+31d) | 54d → 174d | 0% → 100% | 139d → none | 142213032, 142213035, 9-100M FS+108d, 142213030, 142213035P, 142213022, 142213022P, 142213030P → 142213035, 142213030 FS-175d, 9-100M, 142213035P FS-175d, 142213030P FS-175d, 142213022 FS-150d, 142213022P FS-100d, 142213032 | resources PLABOR; PD UNIV STAFF [493.79 h]; SCIENTIST [9.26 h]; CONTRB UNIV LBR [123.45 h]; MECH TECH [437.02 h]; MECH ENG [108.02 h] → CONTRB UNIV LBR [123.45 h]; MECH TECH [437.02 h]; MECH ENG [108.02 h]; PLABOR; PD UNIV STAFF [493.79 h]; SCIENTIST [9.26 h] |
| 142213122 | P-#2 Proc Wires, Pins and Feedthroughs LABOR | 2009-10-01 → 2009-10-15 A (+14d) | 2010-03-31 → 2010-03-15 A (-16d) | 120d → 98d | 0% → 100% | 312d → none |  |  |
| 142213117 | P-#2 Proc Endplates & Frames LABOR Initial | 2009-10-29 → 2009-10-28 A (-1d) | 2010-06-25 A | 161d → 162d | 0% → 100% | 60d → none | 142213017Ab → 142213017Ab FS-250d |  |
| 142213135 | P-#2 Build Stringing Fixtures, Machines and Platforms | 2009-10-01 → 2009-12-14 A (+74d) | 2010-05-28 → 2011-03-31 A (+307d) | 162d → 317.4d | 0% → 100% | 270d → none |  | resources SKLLD TRADE [128.8 h]; MECH ENG [324 h]; PLABOR; MECH TECH [272.4 h] → PLABOR; MECH TECH [272.4 h]; MECH ENG [324 h]; SKLLD TRADE [128.8 h] |
| 142213117P | P-#2 Proc Frames/Endplates | 2009-11-06 → 2009-12-21 A (+45d) | 2010-04-22 → 2012-03-19 A (+697d) | 110d → 551d | 0% → 100% | 255d → none |  |  |
| 142213120 | P-#2 Proc Box Assy. Fixtures LABOR | 2009-12-08 → 2009-12-21 A (+13d) | 2010-03-11 → 2010-08-20 A (+162d) | 60d → 165d | 0% → 100% | 285d → none |  |  |
| 142213120P | P-#2 Proc Box Assy. Fixtures | 2010-01-14 → 2009-12-21 A (-24d) | 2010-03-04 → 2011-11-21 A (+627d) | 34d → 477d | 0% → 100% | 290d → none |  |  |
| 142213135P | P-#2 Proc Cleanroom Fixtures and Equipment | 2009-12-08 → 2009-12-21 A (+13d) | 2010-03-11 → 2011-02-21 A (+347d) | 60d → 285d | 0% → 100% | 326d → none | 142213100M FS+46d → 142213100M FS+24d |  |
| 142213032 | P-#1 Build Boxes and Associated Hardware | 2009-10-21 → 2010-01-29 A (+100d) | 2010-03-15 → 2010-03-19 A (+4d) | 94d → 35d | 0% → 100% | 139d → none | 142213020, 142213017P, 142213020P, 9-100M, 142213017Ab FS-20d → 142213017P FS-200d, 142213020P FS-120d, 142213020 FS-100d, 142213017Ab FS-120d, 9-100M | resources PD UNIV STAFF [80 h]; SKLLD TRADE [120 h]; PLABOR; MECH ENG [188 h]; MECH TECH [284.4 h] → MECH ENG [188 h]; MECH TECH [284.4 h]; PD UNIV STAFF [80 h]; SKLLD TRADE [120 h]; PLABOR |
| 142213130 | P-#2 Proc Circuit Boards LABOR | 2010-03-04 → 2010-02-26 A (-6d) | 2010-09-30 → 2012-02-13 A (+501d) | 148d → 487d | 0% → 100% | 184d → none | 142213100M FS+100d → 142213100M FS+80d |  |
| 142213042M | First Wire Strung | 2009-11-02 → 2010-04-22 A (+171d) | 2009-11-02 → 2010-04-22 A (+171d) |  | 0% → 100% | 969d → none | 142213042 FS-140d → 142213042 FS-150d |  |
| 142213130P | P-#2 Proc Circuit Boards Initial | 2010-03-25 → 2010-04-26 A (+32d) | 2010-06-30 A | 69d → 47d | 0% → 100% | 184d → none | 142213100M FS+115d → 142213100M SS+90d |  |
| 142213042B | P-#1 String Chambers Final FY10 | 2010-06-01 A | 2010-09-30 → 2010-10-29 A (+29d) | 86d → 106d | 0% → 100% | 139d → none |  | resources PD UNIV STAFF [516.13 h]; SCIENTIST [9.68 h]; CONTRB UNIV LBR [129.03 h]; MECH TECH [456.31 h]; MECH ENG [112.9 h]; PLABOR → MECH ENG [112.9 h]; PLABOR; PD UNIV STAFF [516.13 h]; SCIENTIST [9.68 h]; CONTRB UNIV LBR [129.03 h]; MECH TECH [456.31 h] |
| 142213042Ba | P-#1 String Chambers Final FY11 | 2010-10-01 → 2010-06-01 A (-122d) | 2010-12-06 → 2011-01-24 A (+49d) | 45d → 159d | 0% → 100% | 139d → none | 142213042B → 142213042B FS-131d | resources SCIENTIST [5.06 h]; CONTRB UNIV LBR [67.52 h]; MECH ENG [59.08 h]; PLABOR; PD UNIV STAFF [270.07 h]; MECH TECH [238.77 h] → PLABOR; PD UNIV STAFF [270.07 h]; SCIENTIST [5.06 h]; CONTRB UNIV LBR [67.52 h]; MECH TECH [238.77 h]; MECH ENG [59.08 h] |
| 142213045 | ODU Contract Preperations | 2010-06-01 A | 2010-09-07 → 2010-07-16 A (-53d) | 69d → 33d | 0% → 100% | 106d → none |  | resources MECH TECH [49.6 h]; CONTRB UNIV LBR [200 h] → CONTRB UNIV LBR [200 h]; MECH TECH [49.6 h] |
| 142213070 | ISU Contract Preperations FY10 | 2010-06-01 A | 2010-09-30 → 2010-11-22 A (+53d) | 86d → 122.26d | 0% → 100% | 42d → none |  |  |
| 142213070a | ISU Contract Preperations FY11 | 2010-10-01 → 2010-06-01 A (-122d) | 2010-10-04 → 2010-11-22 A (+49d) | 2d → 123d | 0% → 100% | 42d → none |  | resources CONTRB UNIV LBR [4.55 h]; MECH TECH [1.13 h] → MECH TECH [1.13 h]; CONTRB UNIV LBR [4.55 h] |
| 142213117B | P-#2/3 Proc Endplates & Frames LABOR Final FY10 | 2010-06-28 A | 2010-09-30 → 2012-05-21 A (+599d) | 67d → 470d | 0% → 100% | 60d → none |  | was named P-#2 Proc Endplates & Frames LABOR Final FY10 |
| 142213117Ba | P-#2/3 Proc Endplates & Frames LABOR Final FY11 | 2010-10-01 → 2010-06-28 A (-95d) | 2011-09-30 → 2012-05-21 A (+234d) | 248d → 471d | 0% → 100% | 60d → none | 142213117B → 142213017Ab, 142213117 | was named P-#2 Proc Endplates & Frames LABOR Final FY11 |
| 142213117Bb | P-#2 Proc Endplates & Frames LABOR Final FY12 | 2011-10-03 → 2010-06-28 A (-462d) | 2012-08-01 → 2012-05-21 A (-72d) | 206d → 471d | 0% → 100% | 60d → none | 142213117Ba → 142213117Ba FS-210d |  |
| 142213130Pb | P-#2 Proc Circuit Boards Final | 2010-07-01 → 2010-08-02 A (+32d) | 2010-09-30 → 2012-02-13 A (+501d) | 64d → 378d | 0% → 100% | 184d → none |  | resources PROCUREMENT<$50K 60; PROCUREMENT>$50K 69 → PROCUREMENT>$50K 69; PROCUREMENT<$50K 60 |
| 142213132 | P-#2 Build Boxes and Associated Hardware Part A | 2010-10-01 → 2010-08-23 A (-39d) | 2011-02-28 → 2011-07-26 A (+148d) | 97d → 229d | 0% → 100% | 143d → none | 142213120, 142213117 FS-70d, 142213100M, 142213120P, 9-110M, 142213117P → 142213120P FS-160d, 142213100M, 142213117P FS-100d, 9-110M FS-20d, 142213120, 142213117 FS-170d | resources CONTRB UNIV LBR [64.13 h]; MECH TECH [1795.64 h]; PLABOR; SKLLD TRADE [145.36 h]; MECH ENG [149.64 h] → MECH TECH [1795.64 h]; PLABOR; SKLLD TRADE [145.36 h]; MECH ENG [149.64 h]; CONTRB UNIV LBR [64.13 h] |
| 142213230P | P-#3 Proc Circuit Boards | 2010-10-01 → 2010-09-27 A (-4d) | 2012-06-29 → 2012-10-15 A (+108d) | 431d → 510d | 0% → 100% | 127d → none |  | resources PROCUREMENT>$50K 69 NO ESCALATION FY12; PROCUREMENT<$50K 60 NO ESCALATION FY12 → PROCUREMENT<$50K 60 NO ESCALATION FY12; PROCUREMENT>$50K 69 NO ESCALATION FY12 |
| 142213011E | FY11 Travel (FWD Chambers) | 2010-10-01 A | 2011-09-30 A |  | 0% → 100% | 248d → none |  |  |
| 142213200M | P-#3 Constrction Start P-#3 | 2010-10-01 A | 2010-10-01 A |  | 0% → 100% | 127d → none |  |  |
| 142213330P | P-#4 Proc Circuit Boards | 2011-10-03 → 2010-10-03 A (-365d) | 2012-07-31 → 2013-02-11 A (+195d) | 205d → 551d | 0% → 100% | 62d → none | 142213300M → 142213300M FS-225d | resources PROCUREMENT<$50K 60; PROCUREMENT>$50K 69 → PROCUREMENT>$50K 69; PROCUREMENT<$50K 60 |
| 142213230 | P-#3 Proc Circuit Boards LABOR | 2010-10-01 → 2010-10-04 A (+3d) | 2011-02-16 → 2012-10-15 A (+607d) | 90d → 505d | 0% → 100% | 438d → none |  | resources MECH TECH [40 h]; CONTRB UNIV LBR [144 h] → CONTRB UNIV LBR [144 h]; MECH TECH [40 h] |
| 142213050 | ODU Contract Peg Point #1 Boxes Built & Ready to String | 2010-12-01 → 2010-10-15 A (-47d) | 2011-09-30 A | 207d → 238d | 0% → 100% | 106d → none |  | resources PROCUREMENT<$50K 60 NO ESCALATION; PROCUREMENT>$50K 69 NO ESCALATION → PROCUREMENT>$50K 69 NO ESCALATION; PROCUREMENT<$50K 60 NO ESCALATION |
| 142213055 | ODU Contract Peg Point #2 Hire and Train First two Stringers | 2010-12-01 A | 2011-05-31 → 2011-04-15 A (-46d) | 121d → 90d | 0% → 100% | 106d → none |  |  |

| ID | Task | Start | Finish | Duration | Complete | Total float | Predecessors | Other |
| --- | --- | --- | --- | --- | --- | --- | --- | --- |
| 142213222 | P-#3 Proc Wires, Pins and Feedthroughs LABOR | 2010-10-01 → 2010-12-01 A (+61d) | 2011-04-14 → 2011-04-29 A (+15d) | 130d → 100d | 0% → 100% | 398d → none |  |  |
| 142213060 | ODU Contract Peg Point #3 Hire and Train Second two Stringers | 2011-02-01 → 2011-03-01 A (+28d) | 2011-10-31 → 2011-07-25 A (-98d) | 191d → 103d | 0% → 100% | 106d → none |  |  |
| 142213062 | ODU Contract Peg Point #4 String and Test all wires on RII chamber #2 | 2011-07-01 → 2011-03-01 A (-122d) | 2011-12-30 → 2011-12-02 A (-28d) | 122d → 194d | 0% → 100% | 106d → none | 142213060 FS-85d → 142213060 FS-170d |  |
| 142213064 | ODU Contract Peg Point #5 String and Test all wires on RII chamber #3 | 2011-07-01 → 2011-03-01 A (-122d) | 2012-04-30 → 2012-08-13 A (+105d) | 205d → 365d | 0% → 100% | 106d → none | 142213062 FS-122d → 142213062 FS-210d |  |
| 142213133 | P-#2 Build Boxes and Associated Hardware Part B (Frozen by Administrative CR 11-38) | 2011-03-01 A | 2011-04-29 → 2011-05-02 A (+3d) | 44d → 44.61d | 0% → 100% | 661d → none | 142213132 → 142213132 FS-60d | resources MECH ENG [38.24 h]; CONTRB UNIV LBR [16.39 h]; MECH TECH [458.88 h]; PLABOR; SKLLD TRADE [9.2 h] → PLABOR; SKLLD TRADE [9.2 h]; MECH ENG [38.24 h]; CONTRB UNIV LBR [16.39 h]; MECH TECH [458.88 h] |
| 142213142 | P-#2 String Chambers Part A | 2010-12-07 → 2011-04-01 A (+115d) | 2011-02-28 → 2012-04-16 A (+413d) | 52d → 259d | 0% → 100% | 139d → none | 142213122, 142213130Pb, 142213130, 142213135P, 142213135, 142213042Ba, 142213100M, 142213122P, 142213130P → 142213130P, 142213122P, 142213042Ba, 142213130 FS-120d, 142213135, 142213100M, 142213122, 142213135P, 142213130Pb FS-120d |  |
| 142213235P | P-#3 Proc Cleanroom Fixtures and Equipment | 2011-10-03 → 2011-04-01 A (-185d) | 2012-09-28 → 2011-11-21 A (-312d) | 247d → 164d | 0% → 100% | 280d → none | 9-120M → 9-120M FS-110d |  |
| 142213220P | P-#3 Proc Box Assy. Fixtures | 2010-11-03 → 2011-04-02 A (+150d) | 2010-12-16 → 2012-01-16 A (+396d) | 30d → 194d | 0% → 100% | 504d → none |  |  |
| 142213222P | P-#3 Proc Wires, Pins and Feedthroughs | 2010-10-01 → 2011-04-02 A (+183d) | 2011-02-16 → 2012-01-16 A (+334d) | 90d → 194d | 0% → 100% | 438d → none |  |  |
| 142213235 | P-#3 Build Stringing Fixtures, Machines and Platforms FY11 | 2011-03-04 → 2011-04-02 A (+29d) | 2011-09-30 → 2013-02-11 A (+500d) | 148d → 621d | 0% → 100% | 429d → none |  | resources MECH DES [300.81 h]; MECH TECH [150.41 h]; MECH ENG [138.37 h] → MECH TECH [150.41 h]; MECH DES [300.81 h]; MECH ENG [138.37 h] |
| 142213235a | P-#3 Build Stringing Fixtures, Machines and Platforms FY12 | 2011-10-03 → 2011-04-02 A (-184d) | 2012-02-29 → 2013-02-11 A (+348d) | 98d → 621d | 0% → 100% | 429d → none | 142213235 → 142213235 FS-290d |  |
| 142213075 | ISU Contract Phase 1a - Hire lead stringer, complete cleanroom, Readiness Review | 2010-10-05 → 2011-04-11 A (+188d) | 2011-02-28 → 2011-08-31 A (+184d) | 95d → 101d | 0% → 100% | 42d → none | 142213070a → 142213070a FS-9d |  |
| 142213080 | ISU Contract Phase 1b - Hire and train first 2 stringers, install and tension chamber 2 | 2011-04-11 A | 2011-10-31 → 2011-08-29 A (-63d) | 143d → 99d | 0% → 100% | 42d → none | 142213075 FS+29d → 142213075 FS-110d |  |
| 142213133C | P-#2 Build Boxes and Associated Hardware Part B FY12 (Revised by Administrative CR 11-38) | 2011-10-03 → 2011-05-02 A (-154d) | 2012-09-28 → 2013-08-30 A (+336d) | 247d → 701d | 0% → 100% | 99d → none | 142213133b → 142213133b FS-625d | resources MECH ENG [57.29 h]; CONTRB UNIV LBR [24.55 h]; MECH TECH [687.54 h]; PLABOR; SKLLD TRADE [55.66 h] → MECH TECH [687.54 h]; PLABOR; SKLLD TRADE [55.66 h]; MECH ENG [57.29 h]; CONTRB UNIV LBR [24.55 h] |
| 142213133Ca | P-#2 Build Boxes and Associated Hardware Part B FY13 | 2012-10-01 → 2011-05-02 A (-518d) | 2013-08-02 → 2013-08-30 A (+28d) | 208d → 701d | 0% → 100% | 99d → none | 142213133C → 142213133C FS-370d |  |
| 142213133a | Reverse Entry per Administrative CR 11-38 | 2011-05-02 A | 2011-05-06 → 2011-05-02 A (-4d) | 5d → 1d | 0% → 100% | 102d → none |  | resources MECH ENG [-38.24 h]; CONTRB UNIV LBR [-16.39 h]; MECH TECH [-458.88 h]; PLABOR; SKLLD TRADE [-9.2 h] → SKLLD TRADE [-9.2 h]; MECH ENG [-38.24 h]; CONTRB UNIV LBR [-16.39 h]; MECH TECH [-458.8 h]; PLABOR |
| 142213133b | P-#2 Build Boxes and Associated Hardware Part B FY11 (Revised by Administrative CR 11-38) | 2011-05-02 A | 2011-09-30 → 2013-08-30 A (+700d) | 107d → 701d | 0% → 100% | 99d → none | 142213132, 9-110M FS+141d → 142213132 FS-70d, 9-110M FS+141d | resources PLABOR; SKLLD TRADE [24.11 h]; MECH ENG [24.82 h]; CONTRB UNIV LBR [10.64 h]; MECH TECH [297.84 h] → SKLLD TRADE [24.11 h]; MECH ENG [24.82 h]; CONTRB UNIV LBR [10.64 h]; MECH TECH [297.84 h]; PLABOR |
| 142213220 | P-#3 Proc Box Assy. Fixtures LABOR | 2010-10-01 → 2011-05-02 A (+213d) | 2010-11-18 → 2011-06-30 A (+224d) | 35d → 43d | 0% → 100% | 708d → none |  |  |
| 142213217P | P-#3 Proc Frames/Endplates | 2010-05-11 → 2011-06-01 A (+386d) | 2011-02-28 → 2012-04-16 A (+413d) | 196d → 217d | 0% → 100% | 460.5d → none | 142213117P FS+12.5d → 142213117P FS-45d |  |
| 142213300M | P-#4 Constrction Start P-#4 | 2011-10-03 → 2011-09-19 A (-14d) | 2011-10-03 → 2011-09-19 A (-14d) |  | 0% → 100% | 62d → none |  |  |
| 142213085 | ISU Contract Phase 1c - Hire and train last 2 stringers, string wires and test chamber 2 | 2011-10-03 → 2011-09-30 A (-3d) | 2012-02-29 → 2012-07-09 A (+131d) | 98d → 190d | 0% → 100% | 42d → none |  | resources PROCUREMENT<$50K 60 NO ESCALATION; PROCUREMENT>$50K 69 NO ESCALATION → PROCUREMENT>$50K 69 NO ESCALATION; PROCUREMENT<$50K 60 NO ESCALATION |
| 142213012E | FY12 Travel (FWD Chambers) | 2011-10-03 A | 2012-09-28 A |  | 0% → 100% | 248d → none |  |  |
| 142213065 | ODU Contract Peg Point #6 String and Test all wires on RII chamber #4 | 2012-01-03 → 2011-10-03 A (-92d) | 2012-07-31 → 2012-08-13 A (+13d) | 147d → 214d | 0% → 100% | 106d → none | 142213064 FS-83d → 142213064 FS-60d | was named ODU Contract Peg Point #6String and Test all wires on RII chamber #4 |
| 142213066 | ODU Contract Peg Point #7 String and Test all wires on RII chamber #5 | 2012-01-03 → 2011-11-01 A (-63d) | 2012-10-31 → 2012-10-15 A (-16d) | 212d → 237d | 0% → 100% | 106d → none | 142213065 FS-147d → 142213065 FS-165d |  |
| 142213087 | ISU Contract Phase 2 - Install, tension, string wires and test chamber 3 | 2012-01-11 → 2011-11-01 A (-71d) | 2012-07-31 → 2013-02-21 A (+205d) | 141d → 306d | 0% → 100% | 42d → none | 142213085 FS-34d → 142213085 FS-85d |  |
| 142213089 | ISU Contract Phase 3 - Install, tension, string wires and test chamber 4 | 2012-01-11 → 2011-11-01 A (-71d) | 2012-08-31 → 2013-08-30 A (+364d) | 164d → 346d | 0% → 100% | 42d → none | 142213087 FS-141d → 142213087 FS-171d |  |
| 142213090 | ISU Contract Phase 4a - Install and tension chamber 5 | 2012-07-12 → 2011-11-01 A (-254d) | 2012-09-28 → 2013-02-04 A (+129d) | 56d → 432d | 0% → 100% | 42d → none | 142213089 FS-37d → 142213089 FS-195d |  |
| 142213095 | ISU Contract Phase 5a - Install and tension chamber 6 | 2012-07-12 → 2011-11-01 A (-254d) | 2012-09-28 → 2013-02-12 A (+137d) | 56d → 371d | 0% → 100% | 42d → none | 142213092 FS-136d → 142213092 FS-285d |  |
| 142213232 | P-#3 Build Boxes and Associated Hardware FY12 | 2011-10-03 → 2011-11-01 A (+29d) | 2012-09-28 → 2013-08-30 A (+336d) | 247d → 573d | 0% → 100% | 309d → none | 9-120M, 142213217P, 142213220P → 9-120M, 142213217P FS-100d, 142213220P FS-60d | resources SCIENTIST [29.06 h]; MECH DES [25.83 h]; MECH ENG [69.42 h]; MECH TECH [104.61 h] → MECH ENG [69.42 h]; MECH TECH [104.61 h]; SCIENTIST [29.06 h]; MECH DES [25.83 h] |
| 142213232a | P-#3 Build Boxes and Associated Hardware FY13 | 2012-10-01 → 2011-11-01 A (-335d) | 2012-12-31 → 2013-08-30 A (+242d) | 59d → 573d | 0% → 100% | 309d → none | 142213232 → 142213232 FS-350d |  |
| 142213330 | P-#4 Proc Circuit Boards LABOR | 2011-10-03 → 2011-11-01 A (+29d) | 2011-10-31 → 2011-11-14 A (+14d) | 21d → 10d | 0% → 100% | 288d → none |  | resources CONTRB UNIV LBR [33.6 h]; MECH TECH [1.87 h] → MECH TECH [1.87 h]; CONTRB UNIV LBR [33.6 h] |
| 142213320 | P-#4 Proc Box Assy. Fixtures LABOR | 2011-10-03 → 2012-01-02 A (+91d) | 2012-04-02 → 2012-01-30 A (-63d) | 121d → 19d | 0% → 100% | 374d → none |  |  |
| 142213322P | P-#4 Proc Wires, Pins and Feedthroughs | 2011-10-03 → 2012-01-02 A (+91d) | 2012-02-16 → 2012-01-17 A (-30d) | 90d → 10d | 0% → 100% | 405d → none |  |  |
| 142213067 | ODU Contract Peg Point #8 String and Test all wires on RII chamber #6 | 2012-07-02 → 2012-01-03 A (-181d) | 2013-01-31 → 2013-01-30 A (-1d) | 144d → 269d | 0% → 100% | 106d → none | 142213066 FS-87d → 142213066 FS-325d |  |
| 142213068 | ODU Contract Peg Point #9 Five RII Chambers fully tested | 2012-07-02 → 2012-01-03 A (-181d) | 2013-03-29 → 2013-01-30 A (-58d) | 184d → 309d | 0% → 100% | 106d → none | 142213067 FS-144d → 142213067 FS-250d |  |
| 142213069 | ODU Contract Peg Point #10 Ship Final chamber to JLab | 2012-07-02 → 2012-01-03 A (-181d) | 2013-04-30 → 2013-02-01 A (-88d) | 206d → 331d | 0% → 100% | 106d → none | 142213068 FS-184d → 142213068 FS-300d |  |
| 142213317 | P-#4 Proc Endplates & Frames LABOR | 2011-10-03 → 2012-01-03 A (+92d) | 2012-05-29 → 2012-01-16 A (-134d) | 161d → 9d | 0% → 100% | 105d → none |  |  |
| 142213320P | P-#4 Proc Box Assy. Fixtures | 2011-10-03 → 2012-01-03 A (+92d) | 2012-04-30 → 2012-01-16 A (-105d) | 141d → 9d | 0% → 100% | 354d → none |  |  |
| 142213322 | P-#4 Proc Wires, Pins and Feedthroughs LABOR | 2011-10-03 → 2012-01-03 A (+92d) | 2012-04-13 → 2012-01-24 A (-80d) | 130d → 15d | 0% → 100% | 365d → none |  |  |
| 142213335 | P-#4 Build Stringing Fixtures, Machines and Platforms | 2011-10-03 → 2012-01-03 A (+92d) | 2012-09-28 → 2012-01-16 A (-256d) | 247d → 9d | 0% → 100% | 309d → none |  |  |
| 142213144 | P-#2 String Chambers Part B FY11 | 2011-03-01 → 2012-01-09 A (+314d) | 2011-09-30 → 2012-04-16 A (+199d) | 151d → 69d | 0% → 100% | 139d → none | 142213142 → 142213142 FS-40d | resources PLABOR; MECH TECH [524.86 h] → MECH TECH [524.86 h]; PLABOR |
| 142213144a | P-#2 String Chambers Part B FY12 | 2011-10-03 → 2012-01-09 A (+98d) | 2012-04-30 → 2012-04-16 A (-14d) | 141d → 69d | 0% → 100% | 139d → none | 142213144 → 142213144 FS-90d | resources PLABOR; MECH TECH [490.1 h] → MECH TECH [490.1 h]; PLABOR |
| 142213330a | P-#4 Proc Circuit Boards LABOR Revised FY12 | 2012-01-05 → 2012-02-01 A (+27d) | 2012-09-28 → 2013-01-14 A (+108d) | 187d → 232d | 0% → 100% | 20d → none |  | resources ELEC TECH [1503.2 h]; CONTRB UNIV LBR [110.4 h] → CONTRB UNIV LBR [110.4 h]; ELEC TECH [1503.2 h] |
| 142213242 | P-#3 String Chambers FY12 | 2012-05-17 → 2012-02-13 A (-94d) | 2012-09-28 → 2012-10-15 A (+17d) | 94d → 171d | 0% → 100% | 127d → none | 9-120M, 142213144a, 142213230P FS-30d, 142213230, 142213222P, 142213235a FS-247d, 142213232a FS-335d, 142213222, 142213235P FS-247d → 142213222, 142213232a FS-345d, 142213230P FS-160d, 142213235P FS-247d, 142213144a FS-110d, 142213222P, 142213235a FS-275d, 142213230 FS-75d, 9-120M, 142213232 FS-345d | resources PLABOR; MECH TECH [635.35 h] → MECH TECH [635.35 h]; PLABOR |
| 142213242a | P-#3 String Chambers FY13 | 2012-10-01 → 2012-02-13 A (-231d) | 2013-04-01 → 2012-10-15 A (-168d) | 121d → 172d | 0% → 100% | 127d → none | 142213242 → 142213242 FS-145d | resources PLABOR; MECH TECH [817.85 h] → MECH TECH [817.85 h]; PLABOR |
| 142213332 | P-#4 Build Boxes and Associated Hardware FY12 | 2012-08-02 → 2012-03-12 A (-143d) | 2012-09-28 → 2012-12-17 A (+80d) | 41d → 223d | 0% → 100% | 60d → none | 142213117Bb, 142213317 → 142213317, 142213117B FS-110d, 142213117Bb FS-110d | resources MECH ENG [7.63 h]; MECH TECH [7.63 h] → MECH TECH [7.63 h]; MECH ENG [7.63 h] |
| 142213332a | P-#4 Build Boxes and Associated Hardware FY13 | 2012-10-01 → 2012-03-12 A (-203d) | 2012-10-02 → 2012-12-17 A (+76d) | 2d → 236d | 0% → 100% | 60d → none | 142213332 → 142213332 FS-50d |  |
| 142213335P | P-#4 Proc Cleanroom Fixtures and Equipment Part A | 2012-04-02 A | 2012-09-28 → 2012-09-17 A (-11d) | 127d → 118d | 0% → 100% | 309d → none | 142213300M FS+120d → 142213300M FS+20d |  |
| 142213330b | P-#4 Proc Circuit Boards LABOR Revised FY13 | 2012-10-01 → 2012-07-02 A (-91d) | 2013-08-30 → 2013-01-22 A (-220d) | 228d → 127d | 0% → 100% | 20d → none | 142213330a → 142213330a FS-250d | resources ELEC TECH [830.36 h] → ELEC TECH [903.2 h] |
| 142213092 | ISU Contract Phase 4b - String wires and test chamber 5 | 2012-10-01 A | 2013-01-31 → 2013-08-30 A (+211d) | 80d → 203d | 0% → 100% | 42d → none | 142213090 → 142213090 FS-165d |  |
| 142213097 | ISU Contract Phase 5b - String wires and test chamber 6 | 2012-10-01 A | 2013-02-28 → 2013-08-30 A (+183d) | 99d → 307d | 0% → 100% | 42d → none | 142213095 → 142213095 FS-140d |  |
| 142213100 | ISU Contract Phase 6 - Ship chambers, fixtures and equipment to JLab | 2012-10-01 A | 2013-07-31 → 2013-08-30 A (+30d) | 206d → 394d | 0% → 100% | 42d → none | 142213097 FS-99d → 142213097 FS-260d |  |
| 142213342 | P-#4 String Chambers | 2012-11-30 → 2012-11-12 A (-18d) | 2013-08-30 A | 186d → 214d | 0% → 100% | 20d → none | 142213133Ca FS-245d, 142213332a, 142213300M, 142213132, 142213133 FS-245d, 142213330P, 142213335P FS-247d, 142213330, 142213330PA FS-120d, 142213335 FS-247d → 142213132, 142213332a FS-80d, 142213300M, 142213133Ca FS-500d, 142213330PA FS-235d, 9-130M, 142213335P FS-247d, 142213330, 142213330P FS-500d, 142213133 FS-245d, 142213335 FS-247d |  |
| 142213330PA | P-#5 Proc LVHV Distribution Cables and Boxes | 2012-10-01 → 2013-01-07 A (+98d) | 2013-05-29 → 2013-08-30 A (+93d) | 162d → 122d | 0% → 100% | 20d → none | 9-130M, 142213330P → 9-130M, 142213330P FS-250d | was named P-#5 Proc Circuit Boards; resources PROCUREMENT>$50K 69; PROCUREMENT<$50K 60 → PROCUREMENT<$50K 60; PROCUREMENT>$50K 69 |
| 142213360 | Re-Baseline Actuals Adjustment | 2013-08-30 A | 2013-08-30 A |  | 0% → 100% | 20d → none | 9-130M FS+227d → none |  |
| 242213073 | ODU Contract Mount Electronics on Chambers | 2013-09-03 A | 2014-09-30 → 2014-02-28 (-214d) |  | 0% → 12% | 285d → 749d |  |  |
| 242213092 | ISU Contract Phase 4b - String wires and test chamber 5 | 2013-09-03 A |  |  | 0% → 25% | 384d → 470d |  |  |
| 242213097 | ISU Contract Phase 5b - String wires and test chamber 6 | 2013-09-03 A |  |  | 0% → 25% | 384d → 427d |  |  |
| 242213100 | ISU Contract Phase 6 - Ship chambers, fixtures and equipment to JLab | 2013-09-03 A |  |  |  |  |  |  |
| 242213133C | P-#2 Build Boxes and Associated Hardware FY13 | 2013-09-03 A | 2013-09-30 → 2014-05-29 (+241d) |  | 0% → 50% | 337d → 695d |  |  |
| 242213133Ca | P-#2 Build Boxes and Associated Hardware FY14 | 2013-10-01 → 2013-09-03 A (-28d) | 2014-05-29 → 2014-05-28 (-1d) |  | 0% → 50% | 337d → 696d | 9-130M FS+228d, 242213133C → 242213133C FS-160d |  |
| 242213232 | P-#3 Build Boxes and Associated Hardware FY13 | 2013-09-03 A | 2013-09-30 → 2014-04-02 (+184d) | 20d → 141d | 0% → 50% | 411d → 726d |  |  |
| 242213232a | P-#3 Build Boxes and Associated Hardware FY14 | 2013-10-01 → 2013-09-03 A (-28d) | 2014-04-02 → 2014-04-01 (-1d) |  | 0% → 50% | 411d → 727d | 242213232, 9-130M FS+228d → 242213232 FS-120d |  |
| 242213330PA | Proc LVHV Distribution Cables and Boxes | 2013-09-03 A |  |  | 0% → 25% | 165d → 480d |  | resources PROCUREMENT>$50K 69 NO ESCALATION FY14; PROCUREMENT<$50K 60 NO ESCALATION FY14 → PROCUREMENT<$50K 60 NO ESCALATION FY14; PROCUREMENT>$50K 69 NO ESCALATION FY14 |
| 242213331 | HV Dist Box Construction and Testing Labor | 2013-09-03 A |  |  | 0% → 50% | 165d → 480d |  |  |
| 242213335Pa | P-#4 Proc Cleanroom Fixtures and Equipment Part B | 2013-09-03 A | 2013-09-27 → 2013-09-24 A (-3d) |  | 0% → 100% | 457d → none |  | resources PROCUREMENT<$50K 60 → PROCUREMENT<$50K 60; PROCUREMENT>$50K 69 |
| 242213342 | P-#4 String Chambers FY13 | 2013-09-03 A | 2013-09-30 → 2013-09-23 A (-7d) | 20d → 81d | 0% → 100% | 229d → none |  |  |
| 242213342a | P-#4 String Chambers FY14 | 2013-10-01 → 2013-09-03 A (-28d) | 2014-01-07 → 2013-09-23 A (-106d) |  | 0% → 100% | 229d → none | 242213133C FS-289d, 242213133Ca FS-289d, 9-130M FS+228d, 242213335Pa FS-247d, 242213342 → 242213133Ca FS-289d, 242213342 |  |
| 242213347 | P-#5 String Chambers | 2014-01-08 → 2013-09-03 A (-127d) |  |  | 0% → 24% | 229d → 544d |  |  |
| 242213078 | De-Obligation of ODU Contract | 2013-10-15 → 2013-10-01 A (-14d) | 2013-10-15 → 2014-02-28 (+136d) |  | 0% → 56% | 521d → 749d | 9-140M FS+10d → 242213073 FS-75d |  |

| ID | Task | Start | Finish | Duration | Complete | Total float | Predecessors | Other |
| --- | --- | --- | --- | --- | --- | --- | --- | --- |
| 2 | **1.4.2.2.2 CALORIMETRY** | 2009-10-01 → 2009-08-03 (-59d) | 2014-11-04 → 2014-11-03 (-1d) |  |  |  |  |  |
| 3 | **1.4.2.2.2.3 FORWARD CALORIMETER** | 2009-10-01 → 2009-08-03 (-59d) | 2014-11-04 → 2014-11-03 (-1d) |  |  |  |  |  |
| 142223000M | EC-P-#1 Constr Start (FWD CAL) | 2009-10-01 → 2009-08-03 A (-59d) | 2009-10-01 → 2009-08-03 A (-59d) |  | 0% → 100% | 621d → none |  |  |
| 142223015 | EC-P-#1 Prcrmnt Prep for PMTs (FWD CAL) | 2009-10-01 → 2009-08-03 A (-59d) | 2009-10-28 → 2009-08-05 A (-84d) | 20d → 3d | 0% → 100% | 846d → none |  |  |
| 142223017 | EC-P-#1 Vend Fab of PMTs (FWD CAL) | 2010-01-05 → 2009-08-03 A (-155d) | 2010-07-01 → 2009-08-28 A (-307d) | 125d → 20d | 0% → 100% | 806d → none |  | resources MECH DES [40 h]; MECH ENG [40 h]; MECH TECH [40 h]; SCIENTIST [100 h]; ELEC TECH [320 h] → SCIENTIST [100 h]; ELEC TECH [320 h]; MECH DES [40 h]; MECH ENG [40 h]; MECH TECH [40 h] |
| 142223005 | EC-P-#1 Prcrmnt Prep for Assy box (FWD CAL) | 2009-10-01 → 2009-09-07 A (-24d) | 2009-10-28 → 2010-02-26 A (+121d) | 20d → 114d | 0% → 100% | 621d → none |  | resources MECH DES [40 h]; MECH ENG [40 h]; MECH TECH [120 h]; SCIENTIST [40 h] → MECH ENG [40 h]; MECH DES [40 h]; MECH TECH [120 h]; SCIENTIST [40 h] |
| 142223010 | EC-P-#1 Prcrmnt Prep for Wave Shifting Fibers (FWD CAL) | 2009-10-01 → 2009-09-07 A (-24d) | 2009-10-28 → 2010-02-26 A (+121d) | 20d → 114d | 0% → 100% | 621d → none |  |  |
| 142223020 | EC-P-#1 Prcrmnt Prep for Light Guides & Accessr's (FWD CAL) | 2009-10-01 → 2009-09-07 A (-24d) | 2009-10-28 → 2009-09-07 A (-51d) |  | 0% → 100% | 891d → none |  |  |
| 142223022 | EC-P-#1 Vend Fab of Light Guides & Accessr's (FWD CAL) | 2010-01-05 → 2009-11-02 A (-64d) | 2010-04-28 → 2010-06-28 A (+61d) | 80d → 160d | 0% → 100% | 851d → none | 9-100M FS+60d, 142223020 → 9-100M FS+60d, 142223020 FS-500d |  |
| 142223012 | EC-P-#1 Vend Fab of Wave Shifting Fibers (FWD CAL) | 2010-01-05 → 2009-11-23 A (-43d) | 2010-09-13 → 2010-01-18 A (-238d) | 175d → 32d | 0% → 100% | 581d → none | 9-100M FS+60d, 142223010 → 9-100M, 142223010 FS-200d |  |
| 142223037 | EC-P-#2 Vend Fab of Wave Shifting Fibers (FWD CAL) | 2011-01-05 → 2010-01-18 A (-352d) | 2011-09-13 → 2010-03-19 A (-543d) | 175d → 43d | 0% → 100% | 508d → none | 142223012, 9-110M FS+60d → 142223012, 9-110M FS-250d |  |
| 142223105 | Scintillator Procurement | 2010-04-01 A | 2010-07-02 → 2010-07-23 A (+21d) | 66d → 80d | 0% → 100% | 560d → none |  |  |
| 142223185 | Complete Manufacturing Drawings for Box Assy | 2010-04-15 → 2010-04-01 A (-14d) | 2010-06-01 → 2010-07-15 A (+44d) | 33d → 74d | 0% → 100% | 190d → none |  |  |
| 142223100M | PCAL Manufacturing Preparation - Milestone | 2010-04-01 → 2010-05-03 A (+32d) | 2010-04-01 → 2010-05-03 A (+32d) |  | 0% → 100% | 560d → none |  |  |
| 142223195 | Prepare workspace | 2010-05-03 A | 2010-06-01 → 2010-06-28 A (+27d) | 21d → 40d | 0% → 100% | 317d → none |  | resources MECH TECH [160 h]; VISTNG USERS [160 h]; PD UNIV STUDNT [40 h]; CONTRB UNIV LBR [400 h] → PD UNIV STUDNT [40 h]; CONTRB UNIV LBR [400 h]; MECH TECH [160 h]; VISTNG USERS [160 h] |
| 142223110 | W&M - Prepare workspace | 2010-05-06 → 2010-05-17 A (+11d) | 2010-05-20 → 2010-05-18 A (-2d) | 11d → 2d | 0% → 100% | 560d → none |  |  |
| 142223115 | Scintillator Processing | 2010-05-21 → 2010-05-18 A (-3d) | 2010-09-27 → 2010-12-20 A (+84d) | 89d → 150d | 0% → 100% | 560d → none |  |  |
| 142223320 | Prepare workspace | 2010-06-30 → 2010-05-28 A (-33d) | 2010-08-12 → 2010-06-28 A (-45d) | 31d → 21d | 0% → 100% | 317d → none | 142223195 FS+20d → 142223195 |  |
| 142223316 | JMU PMT and Divider assembly and test | 2010-06-03 → 2010-06-01 A (-2d) | 2012-01-03 → 2011-01-24 A (-344d) | 391d → 159d | 0% → 100% | 278d → none |  |  |
| 142223318 | Procurement- PMT Housing Components | 2010-05-03 → 2010-06-01 A (+29d) | 2011-01-06 → 2010-11-15 A (-52d) | 168d → 118d | 0% → 100% | 278d → none |  |  |
| 142223120 | W&M NSF - Fiber procurement | 2010-06-02 → 2010-06-23 A (+21d) | 2011-07-11 → 2010-11-15 A (-238d) | 275d → 102d | 0% → 100% | 553d → none | 142223115 FS-89d, 9-100M FS+163d → 142223115, 9-100M FS+163d |  |
| 142223193 | Procurement of lead sheets | 2010-05-14 → 2010-07-01 A (+48d) | 2012-01-03 → 2011-12-01 A (-33d) | 404d → 354d | 0% → 100% | 248d → none |  | resources PROCUREMENT<$50K 60 NO ESCALATION FY11; PROCUREMENT>$50K 69 NO ESCALATION FY11 → PROCUREMENT>$50K 69 NO ESCALATION FY11; PROCUREMENT<$50K 60 NO ESCALATION FY11 |
| 142223194 | FCAL Prepare EEL 125 Room & Floors | 2010-07-01 A | 2010-09-30 → 2010-07-05 A (-87d) | 64d → 2d | 0% → 100% | 190d → none |  |  |
| 142223186 | Issue PRs and Review Bids | 2010-06-02 → 2010-07-16 A (+44d) | 2010-06-30 → 2010-11-15 A (+138d) | 21d → 86d | 0% → 100% | 190d → none |  |  |
| 142223191 | Procurement of box sidewalls | 2010-10-01 → 2010-09-20 A (-11d) | 2011-04-14 → 2011-11-21 A (+221d) | 130d → 293d | 0% → 100% | 190d → none | 142223186 FS+64d → 142223186 FS-30d |  |
| 142223200 | Prepare Components Module 1 FY10 | 2010-09-02 → 2010-10-04 A (+32d) | 2010-09-30 → 2011-01-24 A (+116d) | 20d → 72d | 0% → 100% | 190d → none | 142223194 FS-20d, 142223193 FS-385d, 142223192 FS-150d, 142223191 FS-150d, 142223190 FS-150d → 142223192 FS-170d, 142223190 FS-190d, 142223191 FS-170d, 142223194 FS-40d, 142223193 FS-385d | resources VISTNG USERS [48.89 h]; MECH TECH [48.89 h]; SUPPLIES & MATERIALS; CONTRB UNIV LBR [222.22 h]; PD UNIV STUDNT [22.22 h] → PD UNIV STUDNT [22.22 h]; VISTNG USERS [48.89 h]; MECH TECH [48.89 h]; SUPPLIES & MATERIALS; CONTRB UNIV LBR [222.22 h] |
| 142223200a | Prepare Components Module 1 FY11 | 2010-10-01 → 2010-10-04 A (+3d) | 2010-10-22 → 2011-01-24 A (+94d) | 16d → 72d | 0% → 100% | 190d → none | 142223200 → 142223200 FS-60d | resources MECH TECH [39.11 h]; SUPPLIES & MATERIALS; CONTRB UNIV LBR [177.78 h]; PD UNIV STUDNT [17.78 h]; VISTNG USERS [39.11 h] → VISTNG USERS [39.11 h]; MECH TECH [39.11 h]; SUPPLIES & MATERIALS; CONTRB UNIV LBR [177.78 h]; PD UNIV STUDNT [17.78 h] |
| 142223192 | Procurement of box windows | 2010-10-01 → 2010-10-11 A (+10d) | 2011-04-14 → 2011-10-24 A (+193d) | 130d → 258d | 0% → 100% | 190d → none | 142223186 FS+64d → 142223186 FS-30d | resources PROCUREMENT>$50K 69; PROCUREMENT<$50K 60 → PROCUREMENT<$50K 60; PROCUREMENT>$50K 69 |
| 142223190 | Procurement of retainers and PMT supports | 2010-10-01 → 2010-12-01 A (+61d) | 2011-04-14 → 2011-08-15 A (+123d) | 130d → 174d | 0% → 100% | 190d → none | 142223186 FS+64d, 142223185 → 142223186 FS+32d, 142223185 FS-10d |  |
| 142223565 | Procurement of PMT's and Dividers | 2012-05-01 → 2011-01-03 A (-484d) | 2012-11-01 → 2011-01-24 A (-647d) | 130d → 14d | 0% → 100% | 189d → none |  |  |
| 142223205 | Assembly of box 1 | 2010-10-25 → 2011-03-01 A (+127d) | 2010-11-05 → 2011-04-25 A (+171d) | 10d → 40d | 0% → 100% | 190d → none | 142223200a → 142223200, 142223200a | resources VISTNG USERS [80 h]; PD UNIV STUDNT [40 h]; CONTRB UNIV LBR [400 h]; MECH TECH [80 h] → MECH TECH [80 h]; VISTNG USERS [80 h]; PD UNIV STUDNT [40 h]; CONTRB UNIV LBR [400 h] |
| 142223280 | Prepare Components Module 5 | 2012-01-09 → 2011-03-14 A (-301d) | 2012-01-24 → 2012-09-17 A (+237d) | 11d → 380d | 0% → 100% | 20d → none | 142223275 FS-165d → 142223275 FS-300d | resources VISTNG USERS [88 h]; MECH TECH [88 h]; PD UNIV STUDNT [40 h]; SUPPLIES & MATERIALS; CONTRB UNIV LBR [60 h] → CONTRB UNIV LBR [60 h]; VISTNG USERS [88 h]; MECH TECH [88 h]; PD UNIV STUDNT [40 h]; SUPPLIES & MATERIALS |
| 142223300 | Prepare Components Module 6 | 2012-04-24 → 2011-03-14 A (-407d) | 2012-05-08 → 2013-02-11 A (+279d) | 11d → 499d | 0% → 100% | 64d → none | 142223295 FS-210d → 142223295 FS-300d |  |
| 142223220 | Prepare Components Module 2 | 2011-01-31 → 2011-03-21 A (+49d) | 2011-02-11 → 2011-07-18 A (+157d) | 10d → 84d | 0% → 100% | 190d → none | 142223215 → 142223215 FS-70d | resources SUPPLIES & MATERIALS; CONTRB UNIV LBR [80 h]; PD UNIV STUDNT [40 h]; MECH TECH [80 h]; VISTNG USERS [80 h] → PD UNIV STUDNT [40 h]; MECH TECH [80 h]; VISTNG USERS [80 h]; SUPPLIES & MATERIALS; CONTRB UNIV LBR [80 h] |
| 142223240 | Prepare Components Module 3 | 2011-05-19 → 2011-03-21 A (-59d) | 2011-06-02 → 2012-02-13 A (+256d) | 10d → 224d | 0% → 100% | 190d → none | 142223235 FS+5d → 142223235 FS-130d | resources SUPPLIES & MATERIALS; PD UNIV STUDNT [40 h]; CONTRB UNIV LBR [60 h]; VISTNG USERS [80 h]; MECH TECH [80 h] → VISTNG USERS [80 h]; MECH TECH [80 h]; SUPPLIES & MATERIALS; CONTRB UNIV LBR [60 h]; PD UNIV STUDNT [40 h] |
| 142223260 | Prepare Components Module 4 | 2011-09-08 → 2011-03-21 A (-171d) | 2011-09-22 → 2012-05-14 A (+235d) | 11d → 288d | 0% → 100% | 190d → none | 142223255 FS+5d → 142223255 FS-225d | resources MECH TECH [88 h]; SUPPLIES & MATERIALS; CONTRB UNIV LBR [60 h]; PD UNIV STUDNT [40 h]; VISTNG USERS [88 h] → CONTRB UNIV LBR [60 h]; PD UNIV STUDNT [40 h]; VISTNG USERS [88 h]; MECH TECH [88 h]; SUPPLIES & MATERIALS |
| 142223210 | Stacking #1 | 2010-11-08 → 2011-04-04 A (+147d) | 2011-01-21 → 2011-07-18 A (+178d) | 46d → 73d | 0% → 100% | 190d → none |  |  |
| 142223215 | Close Module 1 | 2011-01-24 → 2011-07-18 A (+175d) | 2011-01-28 → 2011-08-10 A (+194d) | 5d → 18d | 0% → 100% | 190d → none |  |  |
| 142223317 | Fiber Polisher FY10 | 2010-09-03 → 2011-07-18 A (+318d) | 2010-09-30 → 2011-08-22 A (+326d) | 19d → 26d | 0% → 100% | 288d → none | 9-100M FS+229d → 9-100M FS+229d, 9-110M FS+205d |  |
| 142223317a | Fiber Polisher FY11 | 2010-10-01 → 2011-07-18 A (+290d) | 2010-10-01 → 2011-08-22 A (+325d) | 1d → 26d | 0% → 100% | 288d → none | 142223317 → 142223317 FS-20d, 9-100M FS+229d |  |
| 142223225 | Assembly of box 2 | 2011-02-14 → 2011-08-01 A (+168d) | 2011-02-28 → 2011-09-26 A (+210d) | 10d → 39d | 0% → 100% | 190d → none |  |  |
| 142223325 | Setup module1 | 2011-01-31 → 2011-09-19 A (+231d) | 2011-02-07 → 2011-11-21 A (+287d) | 6d → 46d | 0% → 100% | 206d → none |  |  |
| 142223330 | Prepare components | 2011-02-08 → 2011-09-19 A (+223d) | 2011-02-23 → 2012-01-09 A (+320d) | 11d → 73d | 0% → 100% | 206d → none | 142223317a, 142223325 → 142223317, 142223317a, 142223325 FS-20d |  |
| 142223230 | Stacking #2 | 2011-03-01 → 2011-10-03 A (+216d) | 2011-05-03 → 2012-01-16 A (+258d) | 46d → 67d | 0% → 100% | 190d → none |  |  |
| 142223232 | ETC Revision of Stacking #2 | 2011-11-01 A | 2011-12-30 → 2012-01-16 A (+17d) | 37d → 46d | 0% → 100% | 190d → none |  |  |
| 142223319 | WLS Fibers final set procurement | 2012-01-05 → 2012-01-03 A (-2d) | 2012-04-30 → 2012-04-16 A (-14d) | 81d → 73d | 0% → 100% | 354d → none |  |  |
| 142223335 | Fiber/PMT assembly Module #1 | 2011-02-24 → 2012-01-09 A (+319d) | 2011-04-07 → 2012-01-16 A (+284d) | 31d → 5d | 0% → 100% | 206d → none | 142223330, 142223318 FS-40d, 142223316 FS-285d → 142223330 FS-20d, 11022321000, 11022322000, 142223316 FS-285d, 142223318 FS-40d | resources CONTRB UNIV LBR [120 h]; VISTNG USERS [248 h]; PD UNIV STUDNT [120 h]; PD UNIV STAFF [248 h] → PD UNIV STUDNT [120 h]; PD UNIV STAFF [248 h]; CONTRB UNIV LBR [120 h]; VISTNG USERS [248 h] |
| 142223337 | ETC Revision of Fiber/PMT assembly Module #1 | 2011-12-02 → 2012-01-16 A (+45d) | 2012-01-24 → 2012-02-13 A (+20d) | 31d → 20d | 0% → 100% | 206d → none |  |  |
| 142223235 | Close Module 2 | 2011-05-04 → 2012-01-23 A (+264d) | 2011-05-11 → 2012-02-13 A (+278d) | 6d → 16d | 0% → 100% | 190d → none |  | resources PD UNIV STUDNT [40 h]; VISTNG USERS [48 h]; MECH TECH [48 h]; CONTRB UNIV LBR [40 h] → CONTRB UNIV LBR [40 h]; PD UNIV STUDNT [40 h]; VISTNG USERS [48 h]; MECH TECH [48 h] |
| 142223245 | Assembly of box 3 | 2011-06-03 → 2012-02-01 A (+243d) | 2011-06-16 → 2012-03-16 A (+274d) | 10d → 31d | 0% → 100% | 190d → none |  | resources PD UNIV STUDNT [40 h]; VISTNG USERS [80 h]; MECH TECH [80 h]; CONTRB UNIV LBR [40 h] → VISTNG USERS [80 h]; MECH TECH [80 h]; CONTRB UNIV LBR [40 h]; PD UNIV STUDNT [40 h] |
| 142223340 | Prepare #1 for test | 2011-04-08 → 2012-02-01 A (+299d) | 2011-04-22 → 2012-02-15 A (+299d) |  | 0% → 100% | 206d → none |  | resources PD UNIV STUDNT [40 h]; VISTNG USERS [88 h]; CONTRB UNIV LBR [40 h] → CONTRB UNIV LBR [40 h]; PD UNIV STUDNT [40 h]; VISTNG USERS [88 h] |
| 142223535 | Prepare the storage area | 2011-05-04 → 2012-02-01 A (+273d) | 2011-05-19 → 2012-03-17 A (+303d) | 12d → 32d | 0% → 100% | 571d → none |  |  |
| 142223345 | Testing #1 | 2011-04-25 → 2012-02-16 A (+297d) | 2011-05-09 → 2012-02-21 A (+288d) | 11d → 3d | 0% → 100% | 206d → none | 142223340 → 11022323000, 11022325000, 11022324000, 142223340 | resources CONTRB UNIV LBR [88 h]; PD UNIV STAFF [88 h]; VISTNG USERS [88 h] → PD UNIV STAFF [88 h]; VISTNG USERS [88 h]; CONTRB UNIV LBR [88 h] |
| 142223360 | Setup module2 | 2011-05-20 → 2012-02-19 A (+275d) | 2011-05-27 → 2012-03-17 A (+295d) | 6d → 19d | 0% → 100% | 206d → none | 142223235, 142223355 → 142223355 FS-15d, 142223235 | resources VISTNG USERS [48 h]; CONTRB UNIV LBR [40 h]; MECH TECH [24 h]; PD UNIV STUDNT [40 h] → PD UNIV STUDNT [40 h]; VISTNG USERS [48 h]; CONTRB UNIV LBR [40 h]; MECH TECH [24 h] |
| 142223350 | Disassemble #1 | 2011-05-10 → 2012-03-01 A (+296d) | 2011-05-17 → 2012-03-05 A (+293d) | 6d → 2d | 0% → 100% | 206d → none |  | resources PD UNIV STUDNT [40 h]; VISTNG USERS [48 h]; CONTRB UNIV LBR [40 h] → VISTNG USERS [48 h]; CONTRB UNIV LBR [40 h]; PD UNIV STUDNT [40 h] |
| 142223355 | Move #1 to storage | 2011-05-18 → 2012-03-05 A (+292d) | 2011-05-19 → 2012-03-08 A (+294d) | 2d → 3d | 0% → 100% | 206d → none |  |  |
| 142223365 | Prepare components | 2011-05-31 → 2012-03-12 A (+286d) | 2011-06-14 → 2012-03-19 A (+279d) | 11d → 5d | 0% → 100% | 206d → none |  | resources MECH TECH [44 h]; PD UNIV STUDNT [40 h]; VISTNG USERS [88 h]; CONTRB UNIV LBR [40 h] → VISTNG USERS [88 h]; CONTRB UNIV LBR [40 h]; MECH TECH [44 h]; PD UNIV STUDNT [40 h] |
| 142223370 | Fiber/PMT assembly Module #2 | 2011-06-15 → 2012-03-12 A (+271d) | 2011-07-28 → 2012-03-19 A (+235d) | 31d → 5d | 0% → 100% | 206d → none |  | resources VISTNG USERS [248 h]; PD UNIV STUDNT [120 h]; PD UNIV STAFF [248 h]; CONTRB UNIV LBR [120 h] → PD UNIV STUDNT [120 h]; PD UNIV STAFF [248 h]; CONTRB UNIV LBR [120 h]; VISTNG USERS [248 h] |
| 142223540 | Store module #1 | 2011-05-20 → 2012-03-12 A (+297d) | 2011-05-20 → 2012-03-19 A (+304d) | 1d → 5d | 0% → 100% | 571d → none |  |  |
| 142223250 | Stacking #3 | 2011-06-17 → 2012-03-17 A (+274d) | 2011-08-22 → 2012-05-14 A (+266d) | 46d → 41d | 0% → 100% | 190d → none |  | resources MECH TECH [240 h]; PD UNIV STAFF [240 h]; CONTRB UNIV LBR [80 h]; PD UNIV STUDNT [160 h]; VISTNG USERS [360 h] → CONTRB UNIV LBR [80 h]; PD UNIV STUDNT [160 h]; VISTNG USERS [360 h]; MECH TECH [240 h]; PD UNIV STAFF [240 h] |
| 142223252 | ETC Revision of Stacking #3 | 2012-01-09 → 2012-03-17 A (+68d) | 2012-03-14 → 2012-05-14 A (+61d) | 46d → 41d | 0% → 100% | 217d → none | 9-120M FS+62d → 9-120M FS+62d, 142223245 |  |
| 142223372 | ETC Revision of Fiber/PMT assembly Module #2 | 2012-04-02 → 2012-03-19 A (-14d) | 2012-05-14 → 2012-03-26 A (-49d) | 31d → 5d | 0% → 100% | 206d → none |  | resources PD UNIV STAFF [44 h]; VISTNG USERS [372 h] → VISTNG USERS [372 h]; PD UNIV STAFF [44 h] |
| 142223375 | Prepare #2 for test | 2011-07-29 → 2012-03-19 A (+234d) | 2011-08-12 → 2012-03-26 A (+227d) | 11d → 5d | 0% → 100% | 206d → none | 142223370, 142223372 FS-196d → 142223370 FS-25d, 142223372 FS-196d | resources PD UNIV STUDNT [40 h]; VISTNG USERS [88 h]; CONTRB UNIV LBR [80 h] → CONTRB UNIV LBR [80 h]; PD UNIV STUDNT [40 h]; VISTNG USERS [88 h] |
| 142223380 | Testing #2 | 2011-08-15 → 2012-03-26 A (+224d) | 2011-08-29 → 2012-04-16 A (+231d) | 11d → 16d | 0% → 100% | 206d → none |  |  |
| 142223385 | Disassemble #2 | 2011-08-30 → 2012-04-09 A (+223d) | 2011-09-07 → 2012-05-14 A (+250d) | 6d → 26d | 0% → 100% | 206d → none |  | resources CONTRB UNIV LBR [40 h]; VISTNG USERS [48 h]; PD UNIV STUDNT [40 h] → PD UNIV STUDNT [40 h]; CONTRB UNIV LBR [40 h]; VISTNG USERS [48 h] |
| 142223255 | Close Module 3 | 2011-08-23 → 2012-05-01 A (+252d) | 2011-08-30 → 2012-05-14 A (+258d) | 6d → 10d | 0% → 100% | 190d → none |  | resources MECH TECH [48 h]; CONTRB UNIV LBR [40 h]; PD UNIV STUDNT [40 h]; VISTNG USERS [48 h] → CONTRB UNIV LBR [40 h]; PD UNIV STUDNT [40 h]; VISTNG USERS [48 h]; MECH TECH [48 h] |
| 142223545 | Store module #2 | 2011-09-12 → 2012-05-01 A (+232d) | 2011-09-12 → 2012-05-14 A (+245d) | 1d → 10d | 0% → 100% | 494d → none |  |  |
| 142223390 | Move #2 to storage | 2011-09-08 → 2012-05-14 A (+249d) | 2011-09-09 → 2012-05-15 A (+249d) |  | 0% → 100% | 206d → none |  |  |
| 142223265 | Assembly of box 4 FY11 | 2011-09-23 → 2012-05-15 A (+235d) | 2011-09-30 → 2012-06-11 A (+255d) | 6d → 18d | 0% → 100% | 190d → none | 142223260 → 142223255, 142223260 | resources PD UNIV STUDNT [21.82 h]; MECH TECH [48 h]; CONTRB UNIV LBR [21.82 h]; VISTNG USERS [48 h] → CONTRB UNIV LBR [21.82 h]; VISTNG USERS [48 h]; PD UNIV STUDNT [21.82 h]; MECH TECH [48 h] |
| 142223265a | Assembly of box 4 FY12 | 2011-10-03 → 2012-05-15 A (+225d) | 2011-10-07 → 2012-06-11 A (+248d) | 5d → 18d | 0% → 100% | 190d → none | 142223265 → 142223265 FS-15d | resources CONTRB UNIV LBR [18.18 h]; VISTNG USERS [40 h]; PD UNIV STUDNT [18.18 h]; MECH TECH [40 h] → PD UNIV STUDNT [18.18 h]; MECH TECH [40 h]; CONTRB UNIV LBR [18.18 h]; VISTNG USERS [40 h] |

| ID | Task | Start | Finish | Duration | Complete | Total float | Predecessors | Other |
| --- | --- | --- | --- | --- | --- | --- | --- | --- |
| 142223395 | Setup module3 | 2011-09-12 → 2012-05-18 A (+249d) | 2011-09-19 → 2012-06-05 A (+260d) | 6d → 11d | 0% → 100% | 206d → none |  | resources MECH TECH [24 h]; CONTRB UNIV LBR [40 h]; VISTNG USERS [48 h]; PD UNIV STUDNT [40 h] → CONTRB UNIV LBR [40 h]; VISTNG USERS [48 h]; PD UNIV STUDNT [40 h]; MECH TECH [24 h] |
| 142223400 | Prepare components FY11 | 2011-09-20 → 2012-06-02 A (+256d) | 2011-09-30 → 2012-06-11 A (+255d) | 9d → 5d | 0% → 100% | 206d → none | 142223395 → 142223395 FS-10d |  |
| 142223400a | Prepare components FY12 | 2011-10-03 → 2012-06-09 A (+250d) | 2011-10-04 → 2012-06-18 A (+258d) | 2d → 6d | 0% → 100% | 206d → none |  |  |
| 142223270 | Stacking #4 | 2011-10-10 → 2012-06-11 A (+245d) | 2011-10-31 → 2012-08-16 A (+290d) | 16d → 49d | 0% → 100% | 190d → none |  |  |
| 142223272 | Stacking #4 Revised | 2012-07-12 → 2012-06-11 A (-31d) | 2012-08-22 → 2012-08-16 A (-6d) | 30d → 49d | 0% → 100% | 20d → none | 9-120M FS+191d, 142223270 → 142223270 FS-60d, 9-120M |  |
| 142223405 | Fiber/PMT assembly Module #3 | 2011-10-05 → 2012-06-11 A (+250d) | 2011-10-31 → 2012-06-22 A (+235d) | 19d → 10d | 0% → 100% | 206d → none |  | resources PD UNIV STUDNT [73.55 h]; VISTNG USERS [152 h]; PD UNIV STAFF [152 h]; CONTRB UNIV LBR [73.55 h] → PD UNIV STUDNT [73.55 h]; CONTRB UNIV LBR [73.55 h]; VISTNG USERS [152 h]; PD UNIV STAFF [152 h] |
| 142223410 | Prepare #3 for test | 2012-09-05 → 2012-06-18 A (-79d) | 2012-09-19 → 2012-06-25 A (-86d) | 11d → 6d | 0% → 100% | 29d → none |  |  |
| 142223415 | Testing #3 FY12 | 2012-09-20 → 2012-06-18 A (-94d) | 2012-09-28 → 2012-07-15 A (-75d) | 7d → 20d | 0% → 100% | 29d → none | 142223410 → 142223410 FS-10d | resources PD UNIV STAFF [56 h]; VISTNG USERS [56 h]; CONTRB UNIV LBR [56 h] → VISTNG USERS [56 h]; CONTRB UNIV LBR [56 h]; PD UNIV STAFF [56 h] |
| 142223415a | Testing #3 FY13 | 2012-10-01 → 2012-06-18 A (-105d) | 2012-10-04 → 2012-07-15 A (-81d) | 4d → 20d | 0% → 100% | 29d → none |  | resources PD UNIV STAFF [32 h]; VISTNG USERS [32 h]; CONTRB UNIV LBR [32 h] → VISTNG USERS [32 h]; CONTRB UNIV LBR [32 h]; PD UNIV STAFF [32 h] |
| 142223407 | Fiber/PMT assembly Revised Module #3 | 2012-07-23 → 2012-06-19 A (-34d) | 2012-09-04 → 2012-06-22 A (-74d) | 31d → 4d | 0% → 100% | 29d → none | 142223405, 9-120M FS+198d → 9-120M FS+198d, 142223405 FS-15d | resources PD UNIV STUDNT [46.45 h]; VISTNG USERS [468 h]; PD UNIV STAFF [140 h]; CONTRB UNIV LBR [46.45 h] → CONTRB UNIV LBR [46.45 h]; PD UNIV STUDNT [46.45 h]; VISTNG USERS [468 h]; PD UNIV STAFF [140 h] |
| 142223420 | Disassemble #3 | 2012-10-05 → 2012-07-16 A (-81d) | 2012-10-12 → 2012-08-14 A (-59d) | 6d → 22d | 0% → 100% | 29d → none |  |  |
| 142223425 | Move #3 to storage | 2012-10-15 → 2012-08-17 A (-59d) | 2012-10-16 → 2012-08-28 A (-49d) | 2d → 8d | 0% → 100% | 29d → none |  |  |
| 142223550 | Store module #3 | 2012-10-17 → 2012-08-20 A (-58d) | 2012-10-17 → 2012-08-27 A (-51d) | 1d → 6d | 0% → 100% | 221d → none |  |  |
| 142223275 | Close Module 4 | 2012-08-23 → 2012-09-03 A (+11d) | 2012-08-30 → 2012-09-17 A (+18d) | 6d → 10d | 0% → 100% | 20d → none |  | resources PD UNIV STUDNT [40 h]; CONTRB UNIV LBR [40 h]; VISTNG USERS [48 h]; MECH TECH [48 h] → CONTRB UNIV LBR [40 h]; VISTNG USERS [48 h]; MECH TECH [48 h]; PD UNIV STUDNT [40 h] |
| 142223430 | Setup module 4 | 2012-10-17 → 2012-09-03 A (-44d) | 2012-10-24 → 2012-09-10 A (-44d) | 6d → 5d | 0% → 100% | 29d → none | 142223275, 142223425 → 142223425, 142223275 FS-5d | resources CONTRB UNIV LBR [40 h]; MECH TECH [24 h]; PD UNIV STUDNT [40 h]; VISTNG USERS [48 h] → MECH TECH [24 h]; PD UNIV STUDNT [40 h]; VISTNG USERS [48 h]; CONTRB UNIV LBR [40 h] |
| 142223435 | Prepare components | 2012-10-25 → 2012-09-10 A (-45d) | 2012-11-08 → 2012-09-17 A (-52d) | 11d → 6d | 0% → 100% | 29d → none | 142223430 → 142223430 FS-5d | resources VISTNG USERS [88 h]; MECH TECH [44 h]; CONTRB UNIV LBR [40 h]; PD UNIV STUDNT [40 h] → CONTRB UNIV LBR [40 h]; PD UNIV STUDNT [40 h]; VISTNG USERS [88 h]; MECH TECH [44 h] |
| 142223285 | Assembly of box 5 FY12 | 2012-09-25 → 2012-09-17 A (-8d) | 2012-09-28 → 2012-10-12 A (+14d) | 4d → 20d | 0% → 100% | 20d → none | 142223280 FS+170d → 142223280 FS-10d |  |
| 142223285a | Assembly of box 5 FY13 | 2012-10-01 → 2012-09-17 A (-14d) | 2012-10-09 → 2012-10-12 A (+3d) | 7d → 20d | 0% → 100% | 20d → none | 142223285 → 142223285 FS-20d |  |
| 142223440 | Fiber/PMT assembly Module #4 | 2012-11-09 → 2012-09-17 A (-53d) | 2013-01-02 → 2012-10-12 A (-82d) | 31d → 20d | 0% → 100% | 29d → none |  | resources VISTNG USERS [620 h]; PD UNIV STUDNT [120 h]; PD UNIV STAFF [292 h]; CONTRB UNIV LBR [120 h] → CONTRB UNIV LBR [120 h]; VISTNG USERS [620 h]; PD UNIV STUDNT [120 h]; PD UNIV STAFF [292 h] |
| 142223445 | Prepare #4 for test | 2013-01-03 → 2012-10-13 A (-82d) | 2013-01-17 → 2012-10-29 A (-80d) |  | 0% → 100% | 29d → none |  | resources PD UNIV STUDNT [40 h]; VISTNG USERS [88 h]; CONTRB UNIV LBR [40 h] → CONTRB UNIV LBR [40 h]; PD UNIV STUDNT [40 h]; VISTNG USERS [88 h] |
| 142223290 | Stacking #5 | 2012-12-07 → 2012-10-15 A (-53d) | 2013-02-20 → 2013-01-31 A (-20d) | 46d → 83d | 0% → 100% | 20d → none | 142223285a FS+40d → 142223285a FS+12d | resources PD UNIV STAFF [388 h]; CONTRB UNIV LBR [80 h]; VISTNG USERS [812 h]; MECH TECH [240 h]; PD UNIV STUDNT [120 h] → PD UNIV STUDNT [120 h]; PD UNIV STAFF [388 h]; CONTRB UNIV LBR [80 h]; VISTNG USERS [812 h]; MECH TECH [240 h] |
| 142223450 | Testing #4 | 2013-01-18 → 2012-10-22 A (-88d) | 2013-02-04 → 2013-01-21 A (-14d) | 11d → 54d | 0% → 100% | 29d → none |  | resources CONTRB UNIV LBR [88 h]; PD UNIV STAFF [88 h]; VISTNG USERS [88 h] → PD UNIV STAFF [88 h]; VISTNG USERS [88 h]; CONTRB UNIV LBR [88 h] |
| 142223455 | Disassemble #4 | 2013-02-05 → 2013-01-14 A (-22d) | 2013-02-12 → 2013-01-24 A (-19d) | 6d → 7d | 0% → 100% | 29d → none |  |  |
| 142223570 | Repair Calorimeter PMT's | 2012-11-02 → 2013-01-14 A (+73d) | 2012-12-31 → 2013-05-13 A (+133d) |  | 0% → 100% | 189d → none | 142223565 → 142223565, 9-130M FS+24d | resources MECH TECH [480 h]; PD UNIV STAFF [120 h]; VISTNG USERS [160 h] → VISTNG USERS [160 h]; MECH TECH [480 h]; PD UNIV STAFF [120 h] |
| 142223295 | Close Module 5 | 2013-02-21 → 2013-01-16 A (-36d) | 2013-02-28 → 2013-01-21 A (-38d) |  | 0% → 100% | 20d → none |  | resources PD UNIV STUDNT [40 h]; CONTRB UNIV LBR [40 h]; VISTNG USERS [48 h]; MECH TECH [48 h] → MECH TECH [48 h]; PD UNIV STUDNT [40 h]; CONTRB UNIV LBR [40 h]; VISTNG USERS [48 h] |
| 142223460 | Move #4 to storage | 2013-02-13 → 2013-02-01 A (-12d) | 2013-02-14 → 2013-02-04 A (-10d) |  | 0% → 100% | 29d → none |  |  |
| 142223555 | Store module #4 | 2013-02-15 → 2013-02-01 A (-14d) | 2013-02-15 → 2013-02-01 A (-14d) |  | 0% → 100% | 144d → none |  |  |
| 142223475 | Fiber/PMT assembly Module #5 | 2013-03-26 → 2013-02-04 A (-50d) | 2013-05-07 → 2013-02-18 A (-78d) |  | 0% → 100% | 20d → none |  | resources PD UNIV STUDNT [120 h]; VISTNG USERS [620 h]; PD UNIV STAFF [292 h]; CONTRB UNIV LBR [120 h] → CONTRB UNIV LBR [120 h]; PD UNIV STUDNT [120 h]; VISTNG USERS [620 h]; PD UNIV STAFF [292 h] |
| 142223465 | Setup module5 | 2013-03-01 → 2013-02-05 A (-24d) | 2013-03-08 → 2013-02-12 A (-24d) |  | 0% → 100% | 20d → none |  | resources MECH TECH [24 h]; VISTNG USERS [48 h]; PD UNIV STUDNT [40 h]; CONTRB UNIV LBR [40 h] → CONTRB UNIV LBR [40 h]; MECH TECH [24 h]; VISTNG USERS [48 h]; PD UNIV STUDNT [40 h] |
| 142223305 | Assembly of box 6 | 2013-03-01 → 2013-02-11 A (-18d) | 2013-03-15 → 2013-03-12 A (-3d) | 11d → 10d | 0% → 100% | 35d → none | 142223295, 142223300 FS+170d → 142223300 FS-10d | resources VISTNG USERS [88 h]; MECH TECH [88 h]; PD UNIV STUDNT [40 h]; CONTRB UNIV LBR [40 h] → CONTRB UNIV LBR [40 h]; VISTNG USERS [88 h]; MECH TECH [88 h]; PD UNIV STUDNT [40 h] |
| 142223480 | Prepare #5 for test | 2013-05-08 → 2013-02-11 A (-86d) | 2013-05-22 → 2013-03-15 A (-68d) |  | 0% → 100% | 20d → none |  | resources PD UNIV STUDNT [40 h]; CONTRB UNIV LBR [40 h]; VISTNG USERS [88 h] → CONTRB UNIV LBR [40 h]; VISTNG USERS [88 h]; PD UNIV STUDNT [40 h] |
| 142223470 | Prepare components | 2013-03-11 → 2013-02-13 A (-26d) | 2013-03-25 → 2013-02-27 A (-26d) |  | 0% → 100% | 20d → none |  |  |
| 142223310 | Stacking #6 | 2013-03-18 → 2013-03-11 A (-7d) | 2013-05-20 → 2013-05-13 A (-7d) | 46d → 65d | 0% → 100% | 35d → none |  | resources VISTNG USERS [812 h]; CONTRB UNIV LBR [80 h]; MECH TECH [240 h]; PD UNIV STUDNT [88 h]; PD UNIV STAFF [388 h] → PD UNIV STUDNT [88 h]; PD UNIV STAFF [388 h]; CONTRB UNIV LBR [80 h]; VISTNG USERS [812 h]; MECH TECH [240 h] |
| 142223485 | Testing #5 | 2013-05-23 → 2013-03-16 A (-68d) | 2013-06-07 → 2013-05-13 A (-25d) |  | 0% → 100% | 20d → none |  | resources CONTRB UNIV LBR [88 h]; PD UNIV STAFF [88 h]; VISTNG USERS [88 h] → PD UNIV STAFF [88 h]; VISTNG USERS [88 h]; CONTRB UNIV LBR [88 h] |
| 142223490 | Disassemble #5 | 2013-06-10 → 2013-05-13 A (-28d) | 2013-06-17 → 2013-06-10 A (-7d) |  | 0% → 100% | 20d → none |  | resources PD UNIV STUDNT [40 h]; VISTNG USERS [48 h]; CONTRB UNIV LBR [40 h] → CONTRB UNIV LBR [40 h]; PD UNIV STUDNT [40 h]; VISTNG USERS [48 h] |
| 142223315 | Close Module 6 | 2013-05-21 A | 2013-05-29 → 2013-05-30 A (+1d) |  | 0% → 100% | 35d → none |  | resources VISTNG USERS [48 h]; MECH TECH [48 h]; PD UNIV STUDNT [40 h]; CONTRB UNIV LBR [33.6 h] → CONTRB UNIV LBR [33.6 h]; VISTNG USERS [48 h]; MECH TECH [48 h]; PD UNIV STUDNT [40 h] |
| 142223495 | Move #5 to storage | 2013-06-18 → 2013-06-17 A (-1d) | 2013-06-19 → 2013-06-21 A (+2d) |  | 0% → 100% | 20d → none |  |  |
| 142223500 | Setup module 6 | 2013-06-20 → 2013-06-17 A (-3d) | 2013-06-27 → 2013-06-21 A (-6d) |  | 0% → 100% | 20d → none | 142223495, 142223315 → 142223315, 142223495 FS-20d | resources PD UNIV STUDNT [40 h]; MECH TECH [24 h]; CONTRB UNIV LBR [40 h]; VISTNG USERS [48 h] → CONTRB UNIV LBR [40 h]; VISTNG USERS [48 h]; PD UNIV STUDNT [40 h]; MECH TECH [24 h] |
| 142223505 | Prepare components | 2013-06-28 → 2013-06-17 A (-11d) | 2013-07-15 → 2013-06-21 A (-24d) |  | 0% → 100% | 20d → none |  | resources VISTNG USERS [88 h]; PD UNIV STUDNT [40 h]; MECH TECH [44 h]; CONTRB UNIV LBR [40 h] → CONTRB UNIV LBR [40 h]; VISTNG USERS [88 h]; PD UNIV STUDNT [40 h]; MECH TECH [44 h] |
| 142223510 | Fiber/PMT assembly Module #6 | 2013-07-16 → 2013-06-17 A (-29d) | 2013-08-27 → 2013-06-21 A (-67d) |  | 0% → 100% | 20d → none |  | resources VISTNG USERS [620 h]; PD UNIV STUDNT [120 h]; PD UNIV STAFF [292 h]; CONTRB UNIV LBR [120 h] → CONTRB UNIV LBR [120 h]; VISTNG USERS [620 h]; PD UNIV STUDNT [120 h]; PD UNIV STAFF [292 h] |
| 142223515 | Prepare #6 for test | 2013-08-28 → 2013-06-17 A (-72d) | 2013-08-30 → 2013-06-21 A (-70d) | 3d → 11d | 0% → 100% | 20d → none |  | resources PD UNIV STUDNT [10.91 h]; VISTNG USERS [24 h]; CONTRB UNIV LBR [10.91 h] → CONTRB UNIV LBR [40 h]; PD UNIV STUDNT [40 h]; VISTNG USERS [88 h] |
| 142223530 | Move #6 to storage | 2013-08-30 → 2013-06-17 A (-74d) | 2013-08-30 → 2013-06-21 A (-70d) | 1d → 2d | 0% → 100% | 20d → none | 9-130M FS+227d → none | was named Move #6 to storage (Future Activity Complete prior to Rebaseline); resources MECH TECH → MECH TECH [16 h] |
| 142223560 | Store module #5 | 2013-06-20 → 2013-08-30 A (+71d) | 2013-06-20 → 2013-08-30 A (+71d) |  | 0% → 100% | 58d → none |  |  |
| 142223575 | Re-Baseline Actuals Adjustment | 2013-08-30 A | 2013-08-30 A |  | 0% → 100% | 20d → none | 9-130M FS+227d → none |  |
| 242223312 | Procured Labor for Modules 5 & 6 | 2013-09-03 A | 2013-10-25 → 2013-10-21 A (-4d) |  | 0% → 100% | 447d → none |  |  |
| 242223520 | Testing #6 FY13 | 2013-09-03 A | 2013-09-30 → 2013-10-21 A (+21d) | 20d → 30d | 0% → 100% | 447d → none |  |  |
| 242223520a | Testing #6 FY14 | 2013-10-01 → 2013-09-03 A (-28d) | 2013-10-14 → 2013-10-21 A (+7d) |  | 0% → 100% | 447d → none | 242223520, 9-130M FS+228d → 242223520 FS-20d |  |
| 242223575 | Forklift Rental for ESB | 2013-09-03 A | 2013-10-31 → 2013-12-05 (+35d) |  |  | 528d → 505d |  |  |
| 242223525 | Disassemble #6 | 2013-10-15 → 2013-10-01 A (-14d) | 2013-10-22 → 2013-10-21 A (-1d) |  | 0% → 100% | 447d → none |  |  |
| 242223530 | Move #6 to storage | 2013-10-23 → 2013-10-01 A (-22d) | 2013-10-24 → 2013-10-21 A (-3d) |  | 0% → 100% | 447d → none |  |  |
| 242223562 | Store module #6 | 2013-10-25 → 2013-10-01 A (-24d) | 2013-10-25 → 2013-10-21 A (-4d) |  | 0% → 100% | 447d → none |  |  |
| 242223563M | PCAL Complete | 2013-10-25 → 2013-10-21 A (-4d) | 2013-10-25 → 2013-10-21 A (-4d) |  | 0% → 100% | 447d → none |  |  |
| 242223570 | Repair Calorimeter PMT's | 2014-03-05 → 2014-03-04 (-1d) | 2014-11-04 → 2014-11-03 (-1d) |  |  | 279d → 280d |  |  |
| 3 | **1.4.2.2.3 TIME OF FLIGHT** | 2009-10-01 → 2009-10-06 (+5d) |  |  |  |  |  |  |
| 1 | **1.4.2.2.3.1 CENTRAL TOF** | 2010-07-01 → 2010-07-12 (+11d) |  |  |  |  |  |  |
| 142231014 | CTOF Prepare Mezzanine workspace | 2010-07-01 → 2010-07-12 A (+11d) | 2011-01-31 → 2010-12-20 A (-42d) | 142d → 113d | 0% → 100% | 665d → none |  |  |
| 142231005 | CTOF-P-#1 Prcrmnt of PMTs & Hi Voltage Dividers | 2010-10-01 → 2011-02-01 A (+123d) | 2010-10-28 → 2011-02-28 A (+123d) | 20d → 19d | 0% → 100% | 723d → none | 12222055, 9-110M, 12222055b, 12222045 → 12222045, 12222055, 9-110M, 12222055b, 1132905 |  |
| 142231015 | CTOF-P-#1 Prcrmnt of Scintillators & Readout Sys | 2010-10-01 → 2011-02-01 A (+123d) | 2010-10-28 → 2011-02-28 A (+123d) | 20d → 19d | 0% → 100% | 723d → none |  |  |
| 142231012E | CTOF-FY12 Travel | 2011-10-03 A | 2012-09-28 A |  | 0% → 100% | 20d → none |  |  |
| 142231018M | CTOF Start Milestone | 2011-11-01 A | 2011-11-01 A |  | 0% → 100% | 20d → none |  |  |
| 142231020 | Prepare ALL 30 PR-LETTERS/CONTRACTS | 2011-11-01 A | 2012-03-09 → 2012-03-16 A (+7d) | 84d → 88d | 0% → 100% | 61d → none |  |  |
| 142231140 | Final Drawings of Tooling for wrapping | 2011-11-01 A | 2012-02-27 → 2012-10-15 A (+231d) | 75d → 237d | 0% → 100% | 34d → none |  |  |
| 142231150 | Purchase Clamps for Storage/Transport Racks | 2011-11-01 A | 2012-01-13 → 2011-12-19 A (-25d) | 46d → 33d | 0% → 100% | 94d → none |  | resources SUPPLIES & MATERIALS; MECH DES [8 h]; SCIENTIST [16 h] → MECH DES [8 h]; SCIENTIST [16 h]; SUPPLIES & MATERIALS |
| 142231155 | Purchase parts for Storage/Transportation racks | 2011-11-01 A | 2011-12-19 A |  | 0% → 100% | 107d → none |  |  |
| 142231160 | Final Drawings of Storage-Transportation Rack-25 LG | 2011-11-01 A | 2011-12-14 → 2011-11-21 A (-23d) | 30d → 15d | 0% → 100% | 110d → none |  |  |
| 142231185 | Purchase/Test/Shipping Acr.Rods to Plastic Craft | 2011-11-01 A | 2011-12-19 → 2011-11-21 A (-28d) | 33d → 15d | 0% → 100% | 82d → none |  |  |
| 142231430 | Purchase incidentals/tools/material FY12 | 2011-11-01 A | 2012-09-28 → 2013-08-30 A (+336d) | 226d → 532d | 0% → 100% | 20d → none |  |  |
| 142231430a | Purchase incidentals/tools/material FY13 | 2012-10-01 → 2011-11-01 A (-335d) | 2013-08-30 A | 228d → 532d | 0% → 100% | 20d → none | 142231018M, 142231430 → 142231430 FS-340d |  |
| 142231170 | Fabricate Storage-Transportation Rack-25 DSLG | 2012-01-17 → 2011-11-21 A (-57d) | 2012-02-06 → 2012-01-16 A (-21d) | 15d → 32d | 0% → 100% | 142d → none | 142231160, 142231150, 142231155 → 142231150 FS-60d, 142231155 FS-20d, 142231160 |  |
| 142231105 | Specify the Scintillator Quality | 2011-12-15 → 2011-12-05 A (-10d) | 2012-02-14 A | 37d → 45d | 0% → 100% | 21d → none |  | resources SCIENTIST [16 h]; MECH DES [16 h] → MECH DES [16 h]; SCIENTIST [16 h] |

| ID | Task | Start | Finish | Duration | Complete | Total float | Predecessors | Other |
| --- | --- | --- | --- | --- | --- | --- | --- | --- |
| 142231110 | Purchase/Fabrication./Ship. Scintillators | 2012-02-15 → 2011-12-19 A (-58d) | 2012-09-28 → 2012-06-11 A (-109d) | 159d → 116d | 0% → 100% | 21d → none | 142231020 FS-57d, 142231105 → 142231020 FS-57d, 142231105 FS-40d |  |
| 142231190 | Purchase/Fabrication./Shipping Bent .LG's | 2011-12-20 → 2011-12-19 A (-1d) | 2012-04-18 → 2012-12-17 A (+243d) | 79d → 294d | 0% → 100% | 125d → none |  |  |
| 142231195 | Purchase/Fabrication./Shipping Straight .LG's | 2012-03-27 → 2011-12-19 A (-99d) | 2012-06-29 → 2012-08-20 A (+52d) | 67d → 166d | 0% → 100% | 75d → none | 142231018M FS+95d, 142231175, 142231185 → 142231185, 142231175 FS-80d, 142231018M |  |
| 142231375 | Purchase/Fabricate/Ship PMT+Inner.Magn. Shield | 2012-01-09 → 2011-12-19 A (-21d) | 2012-09-28 → 2012-09-17 A (-11d) |  | 0% → 100% | 97d → none |  |  |
| 142231130 | Final Drawings of Precision Gluing Frame-Table | 2012-01-06 → 2012-01-03 A (-3d) | 2012-03-26 → 2012-06-11 A (+77d) | 55d → 111d | 0% → 100% | 20d → none |  |  |
| 142231165 | Fabricate Storage-Transportation Rack-25 USLG | 2012-01-17 → 2012-01-03 A (-14d) | 2012-02-06 → 2012-02-13 A (+7d) | 15d → 29d | 0% → 100% | 94d → none |  |  |
| 142231225 | Final Drawings of Counter Support Arm Case | 2012-01-06 → 2012-01-03 A (-3d) | 2012-05-14 → 2012-10-15 A (+154d) | 90d → 200d | 0% → 100% | 101d → none |  |  |
| 142231280 | Final Drawings of Magnetic Shield Compensating Coil | 2012-01-06 → 2012-01-03 A (-3d) | 2012-03-16 → 2013-08-30 A (+532d) | 49d → 289d | 0% → 100% | 107d → none |  |  |
| 142231285 | Final Drawings of Magnetic Shield Components | 2012-01-06 → 2012-01-03 A (-3d) | 2012-05-01 → 2012-10-15 A (+167d) | 81d → 200d | 0% → 100% | 95d → none |  |  |
| 142231300 | Purchase/Fabricate/Ship Middle.Magn. Shield FY12 | 2012-05-02 → 2012-01-03 A (-120d) | 2012-09-28 → 2013-01-21 A (+115d) | 105d → 358d | 0% → 100% | 95d → none | 142231285 → 142231285 FS-80d |  |
| 142231300a | Purchase/Fabricate/Ship Middle.Magn. Shield FY13 | 2012-10-01 → 2012-01-03 A (-272d) | 2012-10-31 → 2013-01-21 A (+82d) | 23d → 358d | 0% → 100% | 95d → none | 142231300 → 142231300 FS-130d |  |
| 142231300b | Purchase/Fabricate/Ship Middle.Magn. Shield Procurement | 2012-05-02 → 2012-01-03 A (-120d) | 2012-10-31 → 2013-01-21 A (+82d) | 128d → 358d | 0% → 100% | 95d → none | 142231285 → 142231285 FS-80d |  |
| 142231305 | Purchase/Fabricate/Ship Middle. Magn. Disks FY12 | 2012-05-02 → 2012-01-03 A (-120d) | 2012-09-28 → 2013-01-21 A (+115d) | 105d → 358d | 0% → 100% | 95d → none | 142231285 → 142231285 FS-80d |  |
| 142231305a | Purchase/Fabricate/Ship Middle. Magn. Disks FY13 | 2012-10-01 → 2012-01-03 A (-272d) | 2012-10-31 → 2013-01-21 A (+82d) | 23d → 358d | 0% → 100% | 95d → none | 142231305 → 142231305 FS-130d |  |
| 142231305b | Purchase/Fabricate/Ship Middle. Magn. Disks Procurement | 2012-05-02 → 2012-01-03 A (-120d) | 2012-10-31 → 2013-01-21 A (+82d) | 128d → 358d | 0% → 100% | 95d → none | 142231285 → 142231285 FS-80d |  |
| 142231310 | Purchase/Fabricate/Ship Inner. Magn. Disks FY12 | 2012-05-02 → 2012-01-03 A (-120d) | 2012-09-28 → 2013-02-25 A (+150d) | 105d → 358d | 0% → 100% | 95d → none | 142231285 → 142231285 FS-80d |  |
| 142231310a | Purchase/Fabricate/Ship Inner. Magn. Disks FY13 | 2012-10-01 → 2012-01-03 A (-272d) | 2012-10-31 → 2013-02-25 A (+117d) | 23d → 358d | 0% → 100% | 95d → none | 142231310 → 142231310 FS-130d |  |
| 142231310b | Purchase/Fabricate/Ship Inner. Magn. Disks Procurement | 2012-05-02 → 2012-01-03 A (-120d) | 2012-10-31 → 2013-08-30 A (+303d) | 128d → 358d | 0% → 100% | 95d → none | 142231285 → 142231285 FS-80d |  |
| 142231330 | Purchase/Fabricate/Ship External Magnetic Shields FY12 | 2012-01-11 → 2012-01-03 A (-8d) | 2012-09-28 → 2012-11-12 A (+45d) | 183d → 219.39d | 0% → 100% | 225d → none |  |  |
| 142231330a | Purchase/Fabricate/Ship External Magnetic Shields FY13 | 2012-10-01 → 2012-01-03 A (-272d) | 2012-10-31 → 2012-11-12 A (+12d) | 23d → 220d | 0% → 100% | 225d → none | 142231330 → 142231330 FS-45d |  |
| 142231330b | Purchase/Fabricate/Ship External Magnetic Shields Procurement | 2012-01-11 → 2012-01-03 A (-8d) | 2012-10-31 → 2012-11-12 A (+12d) | 206d → 220d | 0% → 100% | 225d → none |  |  |
| 142231200 | Purchase buffing tools and materials | 2012-02-14 → 2012-01-14 A (-31d) | 2012-03-26 → 2013-08-30 A (+522d) | 29d → 345d | 0% → 100% | 20d → none | 142231018M FS+66d → 142231018M |  |
| 142231175 | Shipping Racks to Company USLG | 2012-02-07 → 2012-02-06 A (-1d) | 2012-02-28 → 2012-02-20 A (-8d) | 15d → 10d | 0% → 100% | 94d → none |  | resources SCIENTIST [3 h]; SKLLD TRADE [16 h]; MECH TECH [16 h]; SUPPLIES & MATERIALS → MECH TECH [16 h]; SUPPLIES & MATERIALS; SCIENTIST [3 h]; SKLLD TRADE [16 h] |
| 142231180 | Shipping Racks to Company DSLG | 2012-02-07 → 2012-02-06 A (-1d) | 2012-02-28 → 2012-02-20 A (-8d) | 15d → 10d | 0% → 100% | 142d → none |  |  |
| 142231145 | Fabricate Tooling for Wrapping | 2012-02-28 → 2012-02-13 A (-15d) | 2012-05-31 → 2013-08-30 A (+456d) | 67d → 261d | 0% → 100% | 34d → none | 142231140 → 142231140 FS-30d |  |
| 142231210 | Purchase TEDLAR for wrapping | 2012-03-27 → 2012-03-02 A (-25d) | 2012-05-10 → 2012-03-19 A (-52d) | 33d → 11d | 0% → 100% | 21d → none |  |  |
| 142231235 | Final Drawings of Counter Storage-25 Armed Counters | 2012-01-06 → 2012-03-02 A (+56d) | 2012-03-09 → 2012-03-26 A (+17d) | 44d → 16d | 0% → 100% | 110d → none | 142231018M FS+40d → 142231018M FS+40d, 9-120M FS+100d |  |
| 142231260 | Final Drawings of CTOF Support and Solenoid Harness | 2012-01-06 → 2012-03-02 A (+56d) | 2012-06-15 → 2013-08-30 A (+441d) | 112d → 248d | 0% → 100% | 20d → none | 142231018M FS+40d → 142231018M FS+80d |  |
| 142231270 | Final Drawings of Counter installation Arm-Cart | 2012-01-06 → 2012-03-02 A (+56d) | 2012-09-13 → 2013-08-30 A (+351d) | 175d → 248d | 0% → 100% | 20d → none | 142231018M FS+40d → 142231018M FS+80d |  |
| 142231120 | Purchase OMNICURE S2000 UV Curing system | 2012-06-15 → 2012-04-09 A (-67d) | 2012-09-14 → 2012-05-14 A (-123d) | 65d → 26d | 0% → 100% | 21d → none | 142231018M FS+151d → 142231018M |  |
| 142231240 | Fabricate Storage Racks-25 Armed Counters FY12 | 2012-03-12 → 2012-04-09 A (+28d) | 2012-09-28 → 2012-07-16 A (-74d) | 142d → 69d | 0% → 100% | 110d → none |  |  |
| 142231240a | Fabricate Storage Racks-25 Armed Counters FY13 | 2012-10-01 → 2012-04-09 A (-175d) | 2012-10-01 → 2012-07-16 A (-77d) | 1d → 69d | 0% → 100% | 110d → none |  |  |
| 142231380 | Testing the PMT timing performance FY12 | 2012-07-06 → 2012-04-09 A (-88d) | 2012-09-28 → 2012-11-12 A (+45d) | 60d → 152.5d | 0% → 100% | 97d → none | 142231375 FS-60d → 142231375 FS-110d |  |
| 142231380a | Testing the PMT timing performance FY13 | 2012-10-01 → 2012-04-09 A (-175d) | 2012-11-02 → 2012-11-12 A (+10d) | 25d → 153d | 0% → 100% | 97d → none | 142231375 FS-60d, 142231380 → 142231380 FS-25d |  |
| 142231125 | Purchase UV Glue, Tooling and Materials | 2012-06-15 → 2012-05-01 A (-45d) | 2012-09-14 → 2013-08-30 A (+350d) | 65d → 271d | 0% → 100% | 21d → none | 142231018M FS+151d → 142231018M | resources SCIENTIST [4 h]; SUPPLIES & MATERIALS → SUPPLIES & MATERIALS; SCIENTIST [4 h] |
| 142231205 | Purchase 900 shts, 12 sqin, VM2002, for wrapping | 2012-03-27 → 2012-05-01 A (+35d) | 2012-05-30 → 2013-08-30 A (+457d) | 46d → 271d | 0% → 100% | 21d → none |  |  |
| 142231230 | Fabricate Counter-Support-Arm -Case FY12 | 2012-05-15 → 2012-05-01 A (-14d) | 2012-09-28 → 2013-08-30 A (+336d) | 96d → 206d | 0% → 100% | 101d → none | 142231225 → 142231225 FS-30d |  |
| 142231230a | Fabricate Counter-Support-Arm -Case FY13 | 2012-10-01 → 2012-05-01 A (-153d) | 2012-10-12 → 2013-08-30 A (+322d) | 10d → 206d | 0% → 100% | 101d → none | 142231230 → 142231230 FS-60d | resources SCIENTIST [3.77 h]; SKLLD TRADE [24.53 h]; MECH DES [3.77 h]; MSHOP; MECH TECH [7.55 h] → MECH DES [3.77 h]; MSHOP; MECH TECH [7.55 h]; SCIENTIST [3.77 h]; SKLLD TRADE [24.53 h] |
| 142231290 | Purchase Coil components and materials | 2012-03-19 → 2012-05-01 A (+43d) | 2012-05-10 → 2013-08-30 A (+477d) | 39d → 271d | 0% → 100% | 107d → none | 142231280 → 142231280 FS-65d | resources SUPPLIES & MATERIALS; SCIENTIST [6 h] → SCIENTIST [6 h]; SUPPLIES & MATERIALS |
| 142231295 | Fabricate Compensating Coil FY12 | 2012-05-11 → 2012-05-01 A (-10d) | 2012-09-28 → 2013-08-30 A (+336d) | 98d → 275d | 0% → 100% | 107d → none | 142231280, 142231290 → 142231280 FS-60d, 142231290 FS-125d | resources SCIENTIST [12.35 h]; MSHOP; MECH TECH [12.35 h]; SKLLD TRADE [41.18 h] → MECH TECH [12.35 h]; SKLLD TRADE [41.18 h]; SCIENTIST [12.35 h]; MSHOP |
| 142231295a | Fabricate Compensating Coil FY13 | 2012-10-01 → 2012-05-01 A (-153d) | 2012-10-29 → 2013-08-30 A (+305d) | 21d → 275d | 0% → 100% | 107d → none | 142231295 → 142231295 FS-130d |  |
| 142231320 | Purchase DCPS 200V/17A Ext.Magn. Shield | 2012-10-01 → 2012-05-01 A (-153d) | 2013-03-15 → 2013-08-30 A (+168d) | 110d → 216d | 0% → 100% | 25d → none | 9-130M, 142231018M FS+10d → 142231018M FS+10d | was named Purchase DCPS 6030A 200V/17A Ext.Magn. Shield |
| 142231115 | Refurbish Laser Calibration System FY12 | 2012-04-16 → 2012-06-02 A (+47d) | 2012-09-28 → 2013-08-30 A (+336d) | 117d → 214d | 0% → 100% | 107d → none | 142231105 FS+42d → 142231105 FS+42d, 9-120M FS+164d | resources SCIENTIST [23.59 h]; MECH DES [18.87 h]; MECH TECH [23.59 h]; SKLLD TRADE [9.44 h]; SUPPLIES & MATERIALS → SUPPLIES & MATERIALS; SKLLD TRADE [9.44 h]; SCIENTIST [23.59 h]; MECH DES [18.87 h]; MECH TECH [23.59 h] |
| 142231115a | Refurbish Laser Calibration System FY13 | 2012-10-01 → 2012-06-02 A (-121d) | 2013-04-15 → 2013-08-30 A (+137d) | 131d → 214d | 0% → 100% | 107d → none | 142231115 → 142231115 FS-160d |  |
| 142231415 | Assemble the DAQ system FY12 | 2012-04-11 → 2012-06-03 A (+53d) | 2012-09-28 → 2013-08-30 A (+336d) | 120d → 213d | 0% → 100% | 108d → none | 142231375 FS-120d → 9-120M FS+184d, 142231375 FS-120d |  |
| 142231415a | Assemble the DAQ system FY13 | 2012-10-01 → 2012-06-03 A (-120d) | 2013-04-12 → 2013-08-30 A (+140d) | 130d → 213d | 0% → 100% | 108d → none | 142231415 → 142231415 FS-160d | resources MECH TECH [20.8 h]; SCIENTIST [41.6 h] → SCIENTIST [41.6 h]; MECH TECH [20.8 h] |
| 142231135 | Fabricate Precision Gluing-Frame-Table | 2012-03-27 → 2012-06-05 A (+70d) | 2012-09-17 → 2012-10-05 A (+18d) | 122d → 88d | 0% → 100% | 20d → none | 142231130 → 142231130 FS-20d |  |
| 142231325 | Assemble the Setup for Magnetic Shields Tests | 2013-03-04 → 2012-06-05 A (-272d) | 2013-08-23 → 2013-08-30 A (+7d) | 123d → 306d | 0% → 100% | 25d → none | 142231320 FS-10d, 142231315 FS-75d → 142231315 FS-220d, 142231320 FS-190d |  |
| 142231215 | Polishing/finishing LG | 2012-03-27 → 2012-07-09 A (+104d) | 2012-09-17 → 2013-08-30 A (+347d) | 122d → 139d | 0% → 100% | 20d → none | 142231200, 142231205 FS-47d, 142231210 FS-34d, 142231185 → 142231185, 142231200 FS-125d, 142231205 FS-125d, 142231210 FS-34d | resources SCIENTIST [40 h]; SUPPLIES & MATERIALS; MECH TECH [320 h] → SCIENTIST [40 h]; MECH TECH [320 h]; SUPPLIES & MATERIALS |
| 142231245 | Two-side glue Counters in Support Arm FY12 | 2012-09-18 → 2012-07-09 A (-71d) | 2012-09-28 → 2013-08-30 A (+336d) | 9d → 161d | 0% → 100% | 20d → none | 142231195, 142231110 FS-10d, 142231220, 142231125, 142231215, 142231135, 142231190, 142231120 → 142231190 FS-60d, 142231135 FS-120d, 142231110 FS-10d, 142231125 FS-125d, 142231220 FS-80d, 142231120, 142231195 FS-20d, 142231215 FS-120d | resources SCIENTIST [12.97 h]; MECH TECH [12.97 h] → MECH TECH [12.97 h]; SCIENTIST [12.97 h] |
| 142231245a | Two-side glue Counters in Support Arm FY13 | 2012-10-01 → 2012-07-09 A (-84d) | 2013-03-05 → 2013-08-30 A (+178d) | 102d → 161d | 0% → 100% | 20d → none | 142231190, 142231120, 142231245, 142231110 FS-10d, 142231220, 142231215, 142231125, 142231135, 142231195 → 142231245 FS-125d |  |
| 142231220 | Wrapping and Transmittance test of LG | 2012-06-01 → 2012-08-13 A (+73d) | 2012-08-27 → 2013-08-30 A (+368d) | 61d → 134d | 0% → 100% | 34d → none | 142231200, 142231205 FS-31d, 142231210 FS-20d, 142231145 → 142231200 FS-125d, 142231145 FS-80d, 142231210 FS-20d, 142231205 FS-125d |  |
| 142231013E | CTOF-FY13 Travel | 2012-10-01 A | 2013-08-30 A | 228d → 247d | 0% → 100% | 20d → none |  |  |
| 142231315 | Purchase Magnet for Magnetic Shields Tests | 2013-01-10 → 2013-03-01 A (+50d) | 2013-06-17 → 2013-03-18 A (-91d) |  | 0% → 100% | 25d → none |  | resources SCIENTIST [48 h]; PROCUREMENT>$50K 69; PROCUREMENT<$50K 60 → SCIENTIST [48 h]; PROCUREMENT<$50K 60; PROCUREMENT>$50K 69 |
| 142231345 | Final Drawings of Patch Panels for LV & HV;200 ch | 2012-03-20 → 2013-03-04 A (+349d) | 2012-05-23 → 2013-08-30 A (+464d) |  | 0% → 100% | 95d → none | 142231018M FS+90d → 9-120M FS+240d, 142231018M FS+90d, 9-130M FS+81d |  |
| 142231350 | Final Drawings of Splitter to TDC and ADC; 100 ch | 2012-03-20 → 2013-03-04 A (+349d) | 2012-05-23 → 2013-08-30 A (+464d) |  | 0% → 100% | 95d → none | 142231018M FS+90d → 142231018M FS+90d, 9-120M FS+240d, 9-130M FS+81d |  |
| 142231250 | Counter-in-rack storage and wrapping | 2012-10-15 → 2013-08-30 A (+319d) | 2013-03-13 → 2013-08-30 A (+170d) |  | 0% → 100% | 101d → none |  | resources SCIENTIST [26 h]; MECH TECH [104 h] → MECH TECH [104 h]; SCIENTIST [26 h] |
| 142231255 | Transmittance test of assembled Counters in Rack | 2012-10-15 → 2013-08-30 A (+319d) | 2013-03-13 → 2013-08-30 A (+170d) |  | 0% → 100% | 101d → none |  |  |
| 142231265 | Fabricate Solenoid Harness FY12 | 2012-06-18 → 2013-08-30 A (+438d) | 2012-09-28 → 2013-08-30 A (+336d) |  | 0% → 100% | 20d → none |  |  |
| 142231265a | Fabricate Solenoid Harness FY13 | 2012-10-01 → 2013-08-30 A (+333d) | 2013-08-30 A | 228d → 238d | 0% → 100% | 20d → none |  | resources MSHOP; MECH TECH [21.92 h]; SKLLD TRADE [175.39 h] → MSHOP; MECH TECH [22.88 h]; SKLLD TRADE [183.08 h] |
| 142231275 | Fabricate Counter-Installation-Arm -Cart | 2013-03-15 → 2013-08-30 A (+168d) | 2013-08-30 A | 119d → 190d | 0% → 100% | 20d → none |  | resources MECH TECH [23.99 h]; SCIENTIST [4.8 h]; SKLLD TRADE [23.99 h]; MSHOP → MECH TECH [50 h]; SCIENTIST [10 h]; SKLLD TRADE [50 h]; MSHOP |
| 142231335 | Purchase Cables and Connectors | 2012-03-09 → 2013-08-30 A (+539d) | 2012-07-31 → 2013-08-30 A (+395d) | 101d → 80d | 0% → 100% | 94d → none | 142231018M FS+83d → 142231018M FS+83d, 9-130M FS+184d, 9-120M FS+205d |  |
| 142231340 | Fabricate Cables LV&HV FY12 | 2012-08-01 → 2013-08-30 A (+394d) | 2012-09-28 → 2013-08-30 A (+336d) |  | 0% → 100% | 94d → none |  |  |
| 142231340a | Fabricate Cables LV&HV FY13 | 2012-10-01 → 2013-08-30 A (+333d) | 2012-11-15 → 2013-08-30 A (+288d) |  | 0% → 100% | 94d → none |  |  |
| 142231355 | Fabricate Patch Panels for LV&HV FY12 | 2012-05-24 → 2013-08-30 A (+463d) | 2012-09-28 → 2013-08-30 A (+336d) | 89d → 24d | 0% → 100% | 95d → none |  | resources ELEC TECH [15.91 h]; SKLLD TRADE [7.96 h] → SKLLD TRADE [7.96 h]; ELEC TECH [15.91 h] |
| 142231355a | Fabricate Patch Panels for LV&HV FY13 | 2012-10-01 → 2013-08-30 A (+333d) | 2013-02-14 → 2013-08-30 A (+197d) |  | 0% → 100% | 95d → none |  |  |
| 142231360 | Fabricate Splitter Parts FY12 | 2012-05-24 → 2013-08-30 A (+463d) | 2012-09-28 → 2013-08-30 A (+336d) | 89d → 24d | 0% → 100% | 95d → none |  |  |
| 142231360a | Fabricate Splitter Parts FY13 | 2012-10-01 → 2013-08-30 A (+333d) | 2012-11-21 → 2013-08-30 A (+282d) |  | 0% → 100% | 95d → none |  |  |
| 142231365 | Assembling of the CTOF patch panels | 2013-02-15 → 2013-08-30 A (+196d) | 2013-05-01 → 2013-08-30 A (+121d) |  | 0% → 100% | 95d → none |  | resources MECH TECH [8 h]; SCIENTIST [8 h] → SCIENTIST [8 h]; MECH TECH [8 h] |
| 142231370 | Assembling of the CTOF splitters | 2012-11-26 → 2013-08-30 A (+277d) | 2013-05-01 → 2013-08-30 A (+121d) |  | 0% → 100% | 95d → none |  |  |

| ID | Task | Start | Finish | Duration | Complete | Total float | Predecessors | Other |
| --- | --- | --- | --- | --- | --- | --- | --- | --- |
| 142231390 | Install PMT and check the orientation | 2013-03-06 → 2013-08-30 A (+177d) | 2013-08-16 → 2013-08-30 A (+14d) |  | 0% → 100% | 20d → none | 142231380, 142231245a, 142231380a → 142231380a, 142231245a |  |
| 142231395 | Install shield disks onto the Light guides | 2013-03-06 → 2013-08-30 A (+177d) | 2013-08-06 → 2013-08-30 A (+24d) |  | 0% → 100% | 28d → none | 142231300a, 142231305b, 142231305a, 142231310a, 142231310b, 142231245a, 142231300b → 142231300b, 142231310, 142231305b, 142231310b, 142231300a, 142231310a, 142231245a, 142231305a |  |
| 142231400 | Install compensation coils and check polarity | 2013-03-06 → 2013-08-30 A (+177d) | 2013-08-08 → 2013-08-30 A (+22d) |  | 0% → 100% | 26d → none |  | resources MECH TECH [52 h]; SCIENTIST [52 h] → SCIENTIST [52 h]; MECH TECH [52 h] |
| 142231405 | Install Middle. Mag. Shields onto PMT | 2013-03-06 → 2013-08-30 A (+177d) | 2013-08-08 → 2013-08-30 A (+22d) |  | 0% → 100% | 26d → none | 142231305b, 142231310b, 142231300b, 142231300a, 142231245a, 142231305a, 142231310a → 142231245a, 142231300a, 142231310, 142231305b, 142231310b, 142231310a, 142231300b, 142231305a |  |
| 142231410 | CTOF in Storage Rack cabling | 2013-03-06 → 2013-08-30 A (+177d) | 2013-08-08 → 2013-08-30 A (+22d) | 110d → 29d | 0% → 100% | 26d → none | 142231310b FS+10d, 142231380, 142231300b FS+10d, 142231340a, 142231380a, 142231310a FS+10d, 142231335, 142231300a FS+10d, 142231305a FS+10d, 142231305b FS+10d, 142231245a → 142231310b FS+10d, 142231300a FS+10d, 142231300b FS+10d, 142231305a FS+10d, 142231340a, 142231335, 142231305b FS+10d, 142231310 FS+10d, 142231245a, 142231380a, 142231310a FS+10d |  |
| 142231420 | Standalone CTOF testing/optimizing | 2013-08-19 → 2013-08-30 A (+11d) | 2013-08-30 A | 10d → 108d | 0% → 100% | 20d → none | 142231370, 142231115a, 142231405, 142231410, 142231400, 142231395, 142231245a FS+29d, 142231415a, 142231245 FS+29d, 142231250 FS+29d, 142231255 FS+29d, 142231390, 142231365 → 142231250 FS+29d, 142231410, 142231365, 142231395, 142231415a, 142231405, 142231255 FS+29d, 142231115a, 142231400, 142231245a FS+29d, 142231390, 142231370 |  |
| 142231475 | Re-Baseline Actuals Adjustment | 2013-08-30 A | 2013-08-30 A |  | 0% → 100% | 20d → none | 9-130M FS+227d → none |  |
| 242231013E | CTOF-FY13 Travel | 2013-09-03 A | 2013-09-30 A |  | 0% → 100% | 498d → none |  |  |
| 242231120 | Refurbish Laser Calibration System FY 13 Obligated Procurement | 2013-09-03 A | 2013-09-30 → 2013-09-23 A (-7d) |  | 0% → 100% | 499d → none |  |  |
| 242231125 | Purchase UV Glue, Tooling and Materials | 2013-10-03 → 2013-10-01 A (-2d) |  |  | 0% → 5% |  |  |  |
| 242231140 | Final Drawings of Tooling for wrapping | 2013-10-01 A |  |  | 0% → 50% |  |  |  |
| 242231215 | Polishing/finishing LG | 2013-10-01 A |  |  | 0% → 15% | 133d → 138d |  |  |
| 242231220 | Wrapping and Transmittance test of LG | 2013-10-04 A |  |  | 0% → 5% |  |  |  |
| 242231115 | Refurbish Laser Calibration System | 2013-10-03 → 2013-11-01 (+29d) | 2014-09-02 → 2014-10-01 (+29d) |  |  | 272d → 251d |  |  |
| 242231145 | Fabricate Tooling for Wrapping | 2013-10-29 → 2013-11-01 (+3d) | 2014-01-28 → 2014-01-31 (+3d) |  |  | 121d → 118d |  |  |
| 242231200 | Purchase buffing tools and materials | 2013-10-03 → 2013-11-01 (+29d) | 2014-02-03 → 2014-03-04 (+29d) |  |  | 194d → 201d |  |  |
| 242231205 | Purchase 900 shts, 12 sqin, VM2002, for wrapping | 2013-10-03 → 2013-11-01 (+29d) | 2014-02-03 → 2014-03-04 (+29d) |  |  | 183d → 162d |  |  |
| 242231260 | Final Drawings of CTOF Support and Solenoid Harness | 2013-10-03 → 2013-11-01 (+29d) | 2014-05-23 → 2014-06-24 (+32d) |  |  | 172d → 151d |  |  |
| 242231270 | Final drawings for counter installation arm - cart and transport rack | 2013-10-28 → 2013-11-26 (+29d) | 2014-10-07 → 2014-11-05 (+29d) |  |  | 172d → 151d |  |  |
| 242231250 | Counter-in-rack storage and wrapping | 2014-01-29 → 2014-02-03 (+5d) | 2014-07-01 → 2014-07-07 (+6d) |  |  | 121d → 118d |  |  |
| 242231262 | CTOF Support and Solenoid Harness Engineer analysis | 2014-01-10 → 2014-02-11 (+32d) | 2014-06-25 → 2014-07-25 (+30d) |  |  | 188d → 167d |  |  |
| 242231430 | Purchase incidentals/tools/material | 2014-02-25 → 2014-02-24 (-1d) | 2014-05-29 → 2014-05-28 (-1d) |  |  | 337d → 338d |  |  |
| 242231435 | Purchase/Fabricate/Ship Middle Mag. Disks-2 Procurement | 2014-02-25 → 2014-02-24 (-1d) | 2014-05-29 → 2014-05-28 (-1d) |  |  | 212d → 213d |  |  |
| 242231440 | Purchase/Fabricate/Ship Extern. Mag. Disks-1 Procurement | 2014-02-25 → 2014-02-24 (-1d) | 2014-05-29 → 2014-05-28 (-1d) |  |  | 212d → 213d |  |  |
| 242231445 | Purchase/Fabricate/Ship Extern. Mag. Disks-2 Procurement | 2014-02-25 → 2014-02-24 (-1d) | 2014-05-29 → 2014-05-28 (-1d) |  |  | 212d → 213d |  |  |
| 242231290 | Purchase Coil components and materials |  |  |  |  |  | 242231280, 242231285, 9-130M FS+99d → 242231285, 242231280 |  |
| 242231305 | Purchase/Fabricate/Ship Inner Mag. Cylinder Procurement |  |  |  |  |  | 242231287 FS+8d, 242231285 FS+8d, 9-130M FS+99d → 242231287 FS+8d, 242231285 FS+8d |  |
| 242231450 | Purchase/Fabricate/Ship Inner Mag. Cylinder #1 | 2014-04-10 → 2014-04-09 (-1d) | 2014-05-29 → 2014-05-28 (-1d) |  |  | 212d → 213d |  |  |
| 242231455 | Purchase/Fabricate/Ship Inner Non-mag. Cylinder #2 | 2014-04-10 → 2014-04-09 (-1d) | 2014-05-29 → 2014-05-28 (-1d) |  |  | 212d → 213d |  |  |
| 242231272 | Counter installation arm - cart and transport rack Engineering Analysis | 2014-03-20 → 2014-04-18 (+29d) | 2014-07-02 → 2014-08-01 (+30d) |  |  | 172d → 151d |  |  |
| 242231255 | Transmittance test of assembled Counters in Rack | 2014-06-04 → 2014-06-09 (+5d) | 2014-11-20 → 2014-11-25 (+5d) |  |  | 121d → 118d |  |  |
| 242231395 | Install shield disks onto the Light guides |  |  |  |  |  | 242231285 FS-110d, 242231440 FS-9d, 242231305 FS-41d, 242231245 FS+25d, 242231435 FS-9d, 242231445 FS-9d, 9-130M FS+99d → 242231285 FS-110d, 242231245 FS+25d, 242231445 FS-9d, 242231440 FS-9d, 242231435 FS-9d, 242231305 FS-41d |  |
| 242231405 | Install Middle. Mag. Shields onto PMT |  |  |  |  |  | 242231245 FS+25d, 9-130M FS+99d, 242231285 FS-110d, 242231305 FS-41d → 242231285 FS-110d, 242231245 FS+25d, 242231305 FS-41d |  |
| 242231275 | CTOF procure installation tooling and transport rack | 2014-08-15 → 2014-09-16 (+32d) | 2015-02-03 → 2015-03-04 (+29d) |  |  | 172d → 151d |  |  |
| 242231325 | Assemble the Setup for Magnetic Shields Tests | 2014-09-18 → 2014-09-17 (-1d) | 2014-12-17 → 2014-12-16 (-1d) |  |  | 172d → 173d |  |  |
| 242231320 | Purchase DCPS 6030A 200V/17A Ext.Magn. Shield | 2014-09-19 → 2014-09-18 (-1d) | 2015-01-05 → 2014-12-23 (-13d) |  |  | 172d → 173d |  |  |
| 242231385 | Testing External magnetic shields | 2014-12-18 → 2014-12-17 (-1d) | 2015-02-03 → 2015-02-02 (-1d) |  |  | 172d → 173d | 242231285 FS-120d, 242231325, 9-130M FS+89d → 242231325, 242231285 FS-120d |  |
| 242231410 | CTOF in Storage Rack cabling |  |  |  |  |  | 242231285 FS-100d, 9-130M FS+109d, 242231340, 242231335 FS-10d, 242231245, 242231305 FS+10d → 242231335 FS-10d, 242231285 FS-100d, 242231305 FS+10d, 242231245, 242231340 |  |
| 2 | **1.4.2.2.3.2 FORWARD TOF** | 2009-10-01 → 2009-10-06 (+5d) | 2014-03-31 → 2014-05-30 (+60d) |  |  |  |  |  |
| 142232005 | FTOF-P-#1 Prcrmnt of Scintillator Matrl & Light Guides | 2009-10-01 → 2009-10-06 A (+5d) | 2010-01-04 → 2009-10-12 A (-84d) | 60d → 5d | 0% → 100% | 806d → none |  |  |
| 142232010 | FTOF-P-#1 Prcrmnt of PMTs & Hi Voltage Dividers | 2009-10-01 → 2009-10-06 A (+5d) | 2010-01-04 → 2009-10-12 A (-84d) | 60d → 5d | 0% → 100% | 931d → none |  |  |
| 142232015 | FTOF-P-#1 Vend Fab of Scintillator Matrl & Light Guides Original Labor | 2010-01-05 → 2010-06-01 A (+147d) | 2010-07-01 → 2010-06-30 A (-1d) | 125d → 22d | 0% → 100% | 806d → none |  |  |
| 142232025 | FTOF - P#1 QA of Scintillators and PMTs (Original Labor) | 2010-05-03 → 2010-06-01 A (+29d) | 2010-05-28 → 2010-06-30 A (+33d) | 20d → 22d | 0% → 100% | 829d → none |  | resources VISTNG USERS [40 h]; PD UNIV STUDNT [13.33 h]; MECH DES [1.35 h]; ELEC TECH [4 h]; MECH TECH [14.65 h]; SCIENTIST [8 h] → PD UNIV STUDNT [13.33 h]; MECH DES [1.35 h]; ELEC TECH [4 h]; MECH TECH [14.65 h]; VISTNG USERS [40 h]; SCIENTIST [8 h] |
| 142232165 | FTOF Travel FY10 | 2010-06-01 A | 2010-09-30 A |  | 0% → 100% | 20d → none |  |  |
| 142232205 | PMT /Divider Procurement Prep FY10 | 2010-06-01 A | 2010-09-30 → 2010-10-29 A (+29d) | 86d → 106.2d | 0% → 100% | 248d → none | 142232200M → 142232200M FS-20d |  |
| 142232205a | PMT /Divider Procurement Prep FY11 | 2010-10-01 → 2010-06-01 A (-122d) | 2010-11-01 → 2010-10-29 A (-3d) | 22d → 106.08d | 0% → 100% | 248d → none | 142232205 → 142232200M FS-20d, 142232205 |  |
| 142232310 | Preparation of USC construction contract | 2010-06-01 A | 2010-09-30 → 2011-01-24 A (+116d) | 86d → 159d | 0% → 100% | 20d → none | 142232200M → 142232200M FS-10d |  |
| 142232330 | Complete design of panel-1b support FY10 | 2010-06-01 A | 2010-09-30 → 2011-02-21 A (+144d) | 86d → 178d | 0% → 100% | 722d → none | 142232200M → 142232200M FS-100d |  |
| 142232330a | Complete design of panel-1b support FY11 | 2010-10-01 → 2010-06-01 A (-122d) | 2010-10-29 → 2011-06-30 A (+244d) | 21d → 269.93d | 0% → 100% | 722d → none |  |  |
| 142232340 | Finalize panel-1b scintillator lengths | 2010-06-01 A | 2010-08-30 → 2010-10-29 A (+60d) | 64d → 107d | 0% → 100% | 840d → none | 142232200M → 142232200M FS-50d |  |
| 142232365 | PMT Study Procurement | 2010-06-01 A | 2010-09-30 → 2010-08-31 A (-30d) | 86d → 65d | 0% → 100% | 685d → none | 142232200M → 142232200M FS-10d |  |
| 142232370 | PMT Studies at JLAB FY10 | 2010-06-01 A | 2010-09-30 → 2010-09-27 A (-3d) | 86d → 83d | 0% → 100% | 685d → none |  |  |
| 142232370a | PMT Studies at JLAB FY11 | 2010-10-01 → 2010-06-01 A (-122d) | 2010-12-30 → 2010-09-27 A (-94d) | 58d → 83d | 0% → 100% | 685d → none |  |  |
| 142232160 | Final Drawings | 2010-06-01 → 2010-06-28 A (+27d) | 2010-06-14 → 2011-03-31 A (+290d) | 10d → 187d | 0% → 100% | 20d → none |  |  |
| 142232230 | Scintillator Procurement Prep - Labor FY10 | 2010-07-01 → 2010-06-28 A (-3d) | 2010-09-30 → 2010-12-20 A (+81d) | 64d → 121.45d | 0% → 100% | 312d → none | 142232200M FS+22d → 142232200M FS-10d |  |
| 142232230a | Scintillator Procurement Prep - Labor FY11 | 2010-10-01 → 2010-06-28 A (-95d) | 2010-11-01 → 2010-12-20 A (+49d) | 22d → 122d | 0% → 100% | 312d → none |  |  |
| 142232350 | Complete panel-1b manufacturing drawings | 2010-08-02 A | 2010-09-15 → 2011-06-30 A (+288d) | 32d → 227d | 0% → 100% | 207d → none |  |  |
| 142232170 | FTOF Travel FY11 | 2010-10-01 A | 2011-09-30 A |  | 0% → 100% | 20d → none |  |  |
| 142232200M | FTOF Construction Milestone | 2010-06-01 → 2010-12-01 A (+183d) | 2010-06-01 → 2010-12-01 A (+183d) |  | 0% → 100% | 20d → none | 142232160 FS-10d, 9-100M FS+162d → 9-100M FS+162d, 142232160 FS-40d |  |
| 142232220 | Vend Fab PMT /Divider Peg Point #1 First Articles (Qty. 6) | 2010-12-01 A | 2011-01-31 → 2011-01-24 A (-7d) | 37d → 32d | 0% → 100% | 248d → none |  |  |
| 142232221 | Vend Fab PMT /Divider Peg Point #2 Production Delivery #1 (Qty. 133) | 2010-12-01 A | 2011-07-29 → 2011-09-01 A (+34d) | 163d → 186d | 0% → 100% | 248d → none |  |  |
| 142232222 | Vend Fab PMT /Divider Peg Point #3 Production Delivery #2 (Qty. 133) | 2010-12-01 A | 2011-10-31 → 2011-11-01 A (+1d) | 228d → 229d | 0% → 100% | 248d → none |  |  |
| 142232223 | Vend Fab PMT /Divider Peg Point #4 Production Delivery #3 (Qty. 134) | 2010-12-01 A | 2011-12-30 → 2012-01-24 A (+25d) | 265d → 280d | 0% → 100% | 248d → none |  |  |
| 142232270 | Backing Support Procurement Prep - Labor FY10 | 2010-09-01 → 2010-12-20 A (+110d) | 2010-09-30 → 2011-02-21 A (+144d) | 21d → 38d | 0% → 100% | 189d → none | 142232200M FS+65d → 142232200M |  |
| 142232270a | Backing Support Procurement Prep - Labor FY11 | 2010-10-01 → 2010-12-20 A (+80d) | 2010-10-22 → 2011-02-28 A (+129d) | 16d → 43d | 0% → 100% | 189d → none | 142232270 → 142232270 FS-100d, 142232200M |  |
| 142232355 | Complete Design of Panel-1a Frame Modification Pieces | 2011-01-04 → 2011-02-01 A (+28d) | 2011-05-31 → 2011-08-24 A (+85d) | 103d → 144d | 0% → 100% | 39d → none | 142232200M FS+145d → 142232200M |  |
| 142232315M | Award USC Contract | 2011-04-01 → 2011-02-14 A (-46d) | 2011-04-01 → 2011-02-14 A (-46d) |  | 0% → 100% | 20d → none |  |  |
| 142232360 | Complete design of panel-2 support | 2011-11-01 → 2011-02-21 A (-253d) | 2012-07-31 → 2012-04-16 A (-106d) | 184d → 287d | 0% → 100% | 188d → none | 9-120M FS+21d, 142232200M → 142232200M |  |
| 142232320 | Peg Point #1 - Set up Assembly Space at USC | 2011-04-01 → 2011-03-01 A (-31d) | 2011-04-29 → 2011-04-25 A (-4d) | 21d → 40d | 0% → 100% | 20d → none |  |  |
| 142232320A | Peg Point #2 - Readiness review at USC | 2011-04-01 A | 2011-04-29 → 2011-04-25 A (-4d) | 21d → 17d | 0% → 100% | 20d → none |  |  |

| ID | Task | Start | Finish | Duration | Complete | Total float | Predecessors | Other |
| --- | --- | --- | --- | --- | --- | --- | --- | --- |
| 142232320B | Peg Point #3 - PMT/divider testing start | 2011-04-01 → 2011-04-02 A (+1d) | 2011-04-29 → 2011-04-25 A (-4d) | 21d → 16d | 0% → 100% | 20d → none |  |  |
| 142232320C | Peg Point #4 - Scintillator testing start | 2011-04-01 → 2011-04-02 A (+1d) | 2011-05-31 → 2011-08-20 A (+81d) | 42d → 98d | 0% → 100% | 20d → none |  | resources PROCUREMENT<$50K 60 NO ESCALATION; PROCUREMENT>$50K 69 NO ESCALATION → PROCUREMENT>$50K 69 NO ESCALATION; PROCUREMENT<$50K 60 NO ESCALATION |
| 142232320D | Peg Point #5 - Phase 1 assembly start (first 5units) | 2011-04-01 → 2011-04-02 A (+1d) | 2011-11-30 → 2011-11-21 A (-9d) | 169d → 163d | 0% → 100% | 20d → none | 142232320C FS-42d → 142232320C FS-70d |  |
| 142232320F | Peg Point #6A - Phase 2 assembly start (next 42 units) Part 1 | 2011-04-01 → 2011-04-02 A (+1d) | 2012-01-31 → 2012-01-23 A (-8d) | 206d → 199d | 0% → 100% | 20d → none | 142232320D FS-169d → 142232320D FS-189d |  |
| 142232240 | Phase 1a FRT (BC-404) first article (3 ea) | 2011-04-14 A | 2011-05-31 A |  | 0% → 100% | 312d → none | 142232340 FS-377d, 142232230a FS+107d → 142232230a, 142232340 FS-400d |  |
| 142232241 | Phase 1b LAL (BC-408) first article (3 ea) | 2011-04-14 A | 2011-05-31 A |  | 0% → 100% | 312d → none |  |  |
| 142232242 | Phase 1c FRT (BC-404) 72 bars | 2011-04-14 A | 2011-08-31 → 2011-07-18 A (-44d) | 98d → 66d | 0% → 100% | 312d → none |  |  |
| 142232243 | Phase 1d FRT (BC-404) 90 bars | 2011-04-14 A | 2011-10-31 → 2011-09-12 A (-49d) | 140d → 104d | 0% → 100% | 312d → none |  | resources PROCUREMENT<$50K 60 NO ESCALATION; PROCUREMENT>$50K 69 NO ESCALATION → PROCUREMENT>$50K 69 NO ESCALATION; PROCUREMENT<$50K 60 NO ESCALATION |
| 142232244 | Phase 1e FRT (BC-404) 24 bars | 2011-04-14 A | 2011-12-30 → 2011-09-26 A (-95d) | 177d → 114d | 0% → 100% | 312d → none |  |  |
| 142232280 | Backing Support Phase 1 Delivery | 2011-05-02 A | 2012-06-29 → 2011-09-30 A (-273d) | 290d → 106d | 0% → 100% | 189d → none | 142232270a FS+125d → 142232270, 142232270a | resources PROCUREMENT<$50K 60 NO ESCALATION FY12; PROCUREMENT>$50K 69 NO ESCALATION FY12 → PROCUREMENT>$50K 69 NO ESCALATION FY12; PROCUREMENT<$50K 60 NO ESCALATION FY12 |
| 142232352 | Panel 1-a/1-b Installation tooling labor | 2011-06-01 A | 2011-06-14 → 2011-08-04 A (+51d) | 10d → 46d | 0% → 100% | 207d → none | 142232350 FS+173d → 142232350 FS-5d | resources MECH ENG [20 h]; MECH DES [40 h] → MECH DES [40 h]; MECH ENG [20 h] |
| 142232356 | Final Panel 1-a/1-b manufacturing support FY11 | 2011-05-10 → 2011-07-18 A (+69d) | 2011-09-30 → 2011-08-24 A (-37d) | 101d → 28d | 0% → 100% | 39d → none | 142232355 FS-15d → 142232355 FS-44d | was named Final Panel 1-1/1-b manufacturing support FY11 |
| 142232356a | Final Panel 1-1/1-b manufacturing support FY12 | 2011-10-03 → 2011-07-18 A (-77d) | 2011-10-04 → 2011-08-24 A (-41d) | 2d → 28d | 0% → 100% | 39d → none |  | resources MECH DES [2.9 h]; MECH ENG [1.21 h] → MECH ENG [1.21 h]; MECH DES [2.9 h] |
| 142232380 | PMT/Divider Procurement Prep - Labor | 2012-01-03 → 2011-09-12 A (-113d) | 2012-02-03 → 2011-09-26 A (-130d) | 23d → 10d | 0% → 100% | 325d → none |  |  |
| 142232281 | Backing Support 1st Article Test | 2011-09-15 → 2011-09-14 A (-1d) | 2011-09-21 → 2011-09-26 A (+5d) | 5d → 8d | 0% → 100% | 264d → none |  | resources MECH TECH [40 h]; MECH ENG [20 h] → MECH ENG [20 h]; MECH TECH [40 h] |
| 142232175 | FTOF Travel FY12 | 2011-10-03 A | 2012-09-28 A |  | 0% → 100% | 20d → none |  |  |
| 142232245 | Phase 2a LAL (BC-408) 64 bars | 2011-10-03 A | 2012-02-29 → 2012-06-11 A (+103d) | 98d → 169d | 0% → 100% | 312d → none |  |  |
| 142232246 | Phase 2b LAL (BC-408) 64 bars | 2011-10-03 A | 2012-04-30 → 2012-06-11 A (+42d) | 141d → 169d | 0% → 100% | 312d → none |  |  |
| 142232247 | Phase 2c LAL (BC-408) 64 bars | 2011-10-03 A | 2012-06-29 → 2012-09-17 A (+80d) | 183d → 238d | 0% → 100% | 312d → none |  |  |
| 142232225 | Vend Fab PMT /Divider Peg Point #5 Production Delivery #4 (Qty. 133) | 2011-12-15 → 2011-11-01 A (-44d) | 2012-03-30 → 2012-04-09 A (+10d) | 69d → 105d | 0% → 100% | 248d → none | 142232223 FS-7d → 142232223 FS-40d | resources PROCUREMENT<$50K 60 NO ESCALATION; PROCUREMENT>$50K 69 NO ESCALATION → PROCUREMENT>$50K 69 NO ESCALATION; PROCUREMENT<$50K 60 NO ESCALATION |
| 142232226 | Vend Fab PMT /Divider Peg Point #6 Production Delivery #5 (Qty. 133) | 2011-12-15 → 2011-11-01 A (-44d) | 2012-06-29 → 2012-06-11 A (-18d) | 132d → 148d | 0% → 100% | 248d → none | 142232225 FS-69d → 142232225 FS-80d |  |
| 142232227 | Vend Fab PMT /Divider Peg Point #7 Production Delivery #6 (Qty. 134) | 2011-12-15 → 2011-11-01 A (-44d) | 2012-09-28 → 2012-09-17 A (-11d) | 196d → 217d | 0% → 100% | 248d → none | 142232226 FS-132d → 142232226 FS-143d |  |
| 142232285 | Backing Support Phase 2 Delivery | 2012-01-18 → 2011-11-01 A (-78d) | 2012-12-31 → 2011-12-19 A (-378d) | 238d → 33d | 0% → 100% | 189d → none |  |  |
| 142232306 | Panel-1b magnetic shields procurement prep. | 2011-11-01 A | 2011-12-30 → 2011-11-07 A (-53d) | 37d → 5d | 0% → 100% | 20d → none |  |  |
| 142232307 | Panel-1b magnetic shields procurement | 2012-01-03 → 2011-11-01 A (-63d) | 2012-11-30 → 2012-08-20 A (-102d) | 232d → 198d | 0% → 100% | 20d → none |  |  |
| 142232320G | Peg Point #6B - Phase 2 assembly start (next 42 units) Part 2 | 2011-11-01 A | 2013-01-31 A |  | 0% → 100% | 20d → none |  |  |
| 142232361 | FTOF storage/work shelves final drawings | 2011-11-01 A | 2012-01-31 → 2012-02-13 A (+13d) | 57d → 66d | 0% → 100% | 25d → none |  |  |
| 142232371 | Panel-1a/2 magnetic shield first article testing | 2011-11-01 A | 2011-12-30 → 2011-12-19 A (-11d) | 37d → 33d | 0% → 100% | 20d → none |  |  |
| 142232375M | Panel 1a Preparation | 2012-01-03 → 2011-11-01 A (-63d) | 2012-01-03 → 2011-11-01 A (-63d) |  | 0% → 100% | 20d → none | 142232200M FS+392d → 142232200M FS+265d |  |
| 142232385 | PMT/Divider Procurement | 2012-02-03 → 2011-11-01 A (-94d) | 2012-06-12 → 2012-05-12 A (-31d) | 90d → 129d | 0% → 100% | 325d → none | 142232380 FS-1d → 142232380 |  |
| 142232353 | Panel 1-a/1-b Installation tooling Proc | 2011-06-01 → 2011-12-12 A (+194d) | 2011-06-30 → 2012-04-16 A (+291d) | 22d → 83d | 0% → 100% | 207d → none | 142232352 FS-10d → 9-120M FS+50d, 142232352 |  |
| 142232372 | Panel-1a/2 magnetic shields procurement prep. | 2012-01-03 → 2011-12-12 A (-22d) | 2012-05-31 → 2011-12-19 A (-164d) | 105d → 6d | 0% → 100% | 20d → none |  |  |
| 142232395 | Set up FTOF DAQ and Test Station | 2012-01-03 A | 2012-07-03 → 2013-02-28 A (+240d) | 127d → 288d | 0% → 100% | 66.88d → none | 142232375M → 142232375M FS+40d |  |
| 142232362 | FTOF storage/work shelves - procurement prep. | 2012-01-17 → 2012-02-01 A (+15d) | 2012-02-29 → 2012-03-16 A (+16d) |  | 0% → 100% | 25d → none |  |  |
| 142232390 | Misc. Counter Repair Parts | 2012-01-03 → 2012-02-01 A (+29d) | 2012-06-13 → 2013-03-11 A (+271d) | 113d → 353d | 0% → 100% | 324d → none | 142232375M → 142232375M FS+40d |  |
| 142232396 | Calibration test equipment Procurement | 2012-01-03 → 2012-02-01 A (+29d) | 2012-04-30 → 2013-08-30 A (+487d) | 83d → 251d | 0% → 100% | 354d → none | 142232375M → 142232375M FS+40d |  |
| 142232655 | Panel 2 Support Frame Procurement | 2012-07-03 → 2012-02-01 A (-153d) | 2013-01-02 → 2013-08-30 A (+240d) | 123d → 229d | 0% → 100% | 188d → none | 142232565 FS-55d, 142232360 FS-21d, 142232654 → 142232654 FS-90d, 142232565 FS-185d, 142232360 FS-110d |  |
| 142232654 | Support frame procurement prep | 2012-06-19 → 2012-03-01 A (-110d) | 2012-07-02 → 2012-03-19 A (-105d) | 10d → 13d | 0% → 100% | 188d → none |  |  |
| 142232549M | Panel 2 preparation | 2012-01-03 → 2012-03-02 A (+59d) | 2012-01-03 → 2012-03-02 A (+59d) |  | 0% → 100% | 312d → none | 9-120M FS+58d → 9-120M FS+120d |  |
| 142232550 | PMT/Divider Procurement Prep - Labor | 2012-01-03 → 2012-03-02 A (+59d) | 2012-03-30 → 2012-06-11 A (+73d) | 62d → 70d | 0% → 100% | 312d → none | 142232549M, 142232200M FS+392d → 142232200M, 142232549M |  |
| 142232363 | FTOF storage/work shelves - procurement | 2012-03-01 → 2012-03-12 A (+11d) | 2012-05-31 → 2012-05-14 A (-17d) | 65d → 46d | 0% → 100% | 25d → none |  |  |
| 142232373 | Panel-1a/2 magnetic shields procurement | 2012-05-01 → 2012-04-16 A (-15d) | 2012-10-31 → 2012-08-20 A (-72d) | 129d → 89d | 0% → 100% | 20d → none | 142232372 FS-22d → 142232372 FS+85d |  |
| 142232520 | Frame Modification Support Piece Procurement | 2013-01-02 → 2012-04-16 A (-261d) | 2013-02-28 → 2012-10-15 A (-136d) | 40d → 128d | 0% → 100% | 139d → none | 142232355, 142232356a, 142232375M FS+248d → 142232375M, 142232356a, 142232355 |  |
| 142232354 | Installation tooling load testing | 2012-04-02 → 2012-07-02 A (+91d) | 2012-05-31 → 2012-07-16 A (+46d) | 43d → 11d | 0% → 100% | 23d → none | 142232353, 9-120M FS+120d → 9-120M FS+204d, 142232353 |  |
| 142232555 | PMT/Divider Procurement | 2012-10-01 → 2012-07-02 A (-91d) | 2013-01-07 → 2013-02-07 A (+31d) | 63d → 127d | 0% → 100% | 185d → none | 142232550, 9-130M → 142232550 |  |
| 142232231 | Forward carriage patch panels procurement prep. | 2012-11-01 → 2012-08-01 A (-92d) | 2012-12-31 → 2012-08-20 A (-133d) | 36d → 14d | 0% → 100% | 42d → none | 9-130M FS+23d, 142232160 → 142232160, 9-130M |  |
| 142232233 | Patch panel to electronics cables procurement prep. | 2012-11-01 → 2012-08-01 A (-92d) | 2012-12-31 → 2012-08-20 A (-133d) | 36d → 14d | 0% → 100% | 106d → none | 9-130M FS+23d, 142232160 → 9-130M, 142232160 |  |
| 142232250 | Signal Cable Procurement Prep - Labor | 2012-11-01 → 2012-08-01 A (-92d) | 2013-01-31 → 2012-08-20 A (-164d) | 57d → 14d | 0% → 100% | 105d → none | 142232200M FS+604d → 142232200M FS+477d |  |
| 142232260 | High Voltage Cable Procurement Prep - Labor | 2012-11-01 → 2012-08-01 A (-92d) | 2013-01-31 → 2012-08-20 A (-164d) | 57d → 14d | 0% → 100% | 105d → none | 142232200M FS+604d → 142232200M FS+477d |  |
| 142232290 | Support Frame Procurement Prep - Labor | 2012-11-01 → 2012-08-01 A (-92d) | 2013-01-31 → 2012-11-12 A (-80d) | 57d → 73d | 0% → 100% | 84d → none | 142232200M FS+604d → 142232200M |  |
| 142232300 | Divider adaptor Procurement Prep - Labor | 2012-11-01 → 2012-08-01 A (-92d) | 2013-01-31 → 2012-08-20 A (-164d) | 57d → 14d | 0% → 100% | 105d → none | 142232200M FS+604d → 142232200M FS+477d |  |
| 142232400 | Deinstallation S1 | 2012-06-07 → 2012-08-04 A (+58d) | 2012-06-08 → 2012-08-06 A (+59d) | 2d → 1d | 0% → 100% | 20d → none |  |  |
| 142232420 | Deinstallation S2 | 2012-06-08 → 2012-08-04 A (+57d) | 2012-06-11 → 2012-08-06 A (+56d) | 2d → 1d | 0% → 100% | 20d → none |  |  |
| 142232565 | Deinstallation | 2012-06-15 → 2012-08-04 A (+50d) | 2012-07-12 → 2013-01-09 A (+181d) | 20d → 104d | 0% → 100% | 20d → none |  |  |
| 142232440 | Deinstallation S3 | 2012-06-11 → 2012-08-05 A (+55d) | 2012-06-11 → 2012-08-06 A (+56d) |  | 0% → 100% | 20d → none |  |  |
| 142232460 | Deinstallation S4 | 2012-06-11 → 2012-08-05 A (+55d) | 2012-06-12 → 2012-08-06 A (+55d) | 2d → 1d | 0% → 100% | 20d → none |  |  |
| 142232405 | Move S1 to storage | 2012-06-11 → 2012-08-06 A (+56d) | 2012-06-12 → 2012-08-07 A (+56d) |  | 0% → 100% | 20d → none |  |  |
| 142232425 | Move S2 to storage | 2012-06-08 → 2012-08-06 A (+59d) | 2012-06-11 → 2012-08-08 A (+58d) | 2d → 3d | 0% → 100% | 20d → none |  |  |
| 142232445 | Move S3 to storage | 2012-06-11 → 2012-08-06 A (+56d) | 2012-06-11 → 2012-08-08 A (+58d) | 1d → 3d | 0% → 100% | 20d → none |  |  |
| 142232465 | Move S4 to storage | 2012-06-11 → 2012-08-06 A (+56d) | 2012-06-12 → 2012-08-08 A (+57d) | 2d → 3d | 0% → 100% | 20d → none |  |  |
| 142232480 | Deinstallation S5 | 2012-06-12 → 2012-08-06 A (+55d) | 2012-06-12 → 2012-08-07 A (+56d) | 1d → 2d | 0% → 100% | 20d → none |  |  |
| 142232570 | Move Panel 2 to storage | 2012-06-15 → 2012-08-06 A (+52d) | 2012-07-12 → 2013-01-15 A (+187d) | 20d → 104d | 0% → 100% | 20d → none | 142232565 FS-20d → 142232565 FS-25d |  |
| 142232485 | Move S5 to storage | 2012-06-12 → 2012-08-07 A (+56d) | 2012-06-12 → 2012-08-08 A (+57d) | 1d → 2d | 0% → 100% | 20d → none |  |  |
| 142232500 | Deinstallation S6 | 2012-06-13 → 2012-08-07 A (+55d) | 2012-06-13 → 2012-08-07 A (+55d) |  | 0% → 100% | 20d → none |  |  |
| 142232505 | Move S6 to storage | 2012-06-14 → 2012-08-10 A (+57d) | 2012-06-14 → 2012-08-10 A (+57d) |  | 0% → 100% | 20d → none |  |  |
| 142232510 | S6 Counter QA and baseline measurements | 2013-07-25 → 2012-08-13 A (-346d) | 2013-08-22 → 2012-08-27 A (-360d) | 21d → 11d | 0% → 100% | 20d → none | 142232495 → 142232495 FS-185d |  |
| 142232410 | S1 Counter QA and baseline measurements | 2012-07-02 → 2012-08-20 A (+49d) | 2012-07-30 → 2012-08-27 A (+28d) | 21d → 6d | 0% → 100% | 86d → none |  |  |
| 142232305 | Divider adaptor procurement | 2013-02-01 → 2012-09-03 A (-151d) | 2013-05-01 → 2012-12-10 A (-142d) | 63d → 69d | 0% → 100% | 105d → none |  |  |
| 142232415 | S1 repair | 2012-11-01 → 2012-09-03 A (-59d) | 2012-12-03 → 2012-11-12 A (-21d) | 21d → 50d | 0% → 100% | 20d → none | 142232373, 142232410 → 142232410, 142232373 FS-20d | resources MECH TECH [171.43 h]; SCIENTIST [28.57 h] → SCIENTIST [28.57 h]; MECH TECH [171.43 h] |
| 142232575 | Extract panel-2 counters from CLAS6 FY12 | 2012-07-13 → 2012-09-03 A (+52d) | 2012-09-28 → 2013-01-15 A (+109d) | 55d → 84d | 0% → 100% | 20d → none | 142232570 → 142232570 FS-25d |  |

| ID | Task | Start | Finish | Duration | Complete | Total float | Predecessors | Other |
| --- | --- | --- | --- | --- | --- | --- | --- | --- |
| 142232575a | Extract panel-2 counters from CLAS6 FY13 | 2012-10-01 → 2012-09-03 A (-28d) | 2012-10-25 → 2013-01-15 A (+82d) | 19d → 84d | 0% → 100% | 20d → none | 142232575 → 142232575 FS-70d |  |
| 142232232 | Forward carriage patch panels procurement | 2013-01-02 → 2012-09-10 A (-114d) | 2013-07-31 → 2013-07-15 A (-16d) | 147d → 74d | 0% → 100% | 42d → none |  |  |
| 142232234 | Patch panel to electronics cables procurement | 2013-01-02 → 2012-09-10 A (-114d) | 2013-04-30 → 2012-11-12 A (-169d) | 83d → 46d | 0% → 100% | 106d → none |  |  |
| 142232255 | Signal Cable Procurement | 2013-02-01 → 2012-09-10 A (-144d) | 2013-05-01 → 2012-12-17 A (-135d) | 63d → 78d | 0% → 100% | 105d → none |  |  |
| 142232265 | High Voltage Cable Procurement | 2013-02-01 → 2012-09-10 A (-144d) | 2013-05-01 → 2013-08-30 A (+121d) | 63d → 78d | 0% → 100% | 105d → none |  |  |
| 142232515 | S6 repair | 2013-08-23 → 2012-09-10 A (-347d) | 2013-08-30 → 2013-03-15 A (-168d) | 6d → 257d | 0% → 100% | 20d → none |  | resources MECH TECH [51.43 h]; SCIENTIST [8.57 h] → SCIENTIST [28.57 h]; MECH TECH [171.43 h] |
| 142232660 | Panel 1-a and Panel 2 signal cables and connectors (672) - proc | 2013-08-30 → 2012-09-10 A (-354d) | 2013-08-30 → 2012-12-17 A (-256d) | 1d → 83d | 0% → 100% | 20d → none | 9-130M FS+227d → 142232650 FS-500d | was named Panel 1-a and Panel 2 signal cables and connectors (672) - proc (Future Activity Complete prior to Rebaseline) |
| 142232180 | FTOF Travel FY13 | 2012-10-01 A | 2013-08-30 A | 228d → 248d | 0% → 100% | 20d → none |  |  |
| 142232320H | Peg Point #6C - Phase 2 assembly start (next 42 units) Part 3 | 2012-11-01 → 2012-10-08 A (-24d) | 2013-01-31 A | 57d → 75d | 0% → 100% | 20d → none |  |  |
| 142232320J | Peg Point #7 - Phase 3 assembly start (last 17 units) | 2012-11-01 → 2012-10-08 A (-24d) | 2013-06-28 → 2013-03-11 A (-109d) | 161d → 179d | 0% → 100% | 20d → none |  |  |
| 142232320K | Peg Point #8 - JLab Acceptance Test preparation start | 2012-11-01 → 2012-10-08 A (-24d) | 2013-06-28 → 2013-07-15 A (+17d) | 161d → 179d | 0% → 100% | 20d → none |  |  |
| 142232320N | Peg Point #9 - Panel-1b counters delivered to JLab | 2012-11-01 → 2012-10-08 A (-24d) | 2013-06-28 → 2013-07-15 A (+17d) | 161d → 179d | 0% → 100% | 20d → none |  |  |
| 142232320P | Peg Point #10 - Sector assembly start | 2012-11-01 → 2012-10-08 A (-24d) | 2013-08-30 → 2013-07-15 A (-46d) | 205d → 223d | 0% → 100% | 20d → none |  |  |
| 142232490 | S5 Counter QA and baseline measurements | 2013-05-24 → 2012-10-08 A (-228d) | 2013-06-24 → 2013-05-13 A (-42d) | 21d → 175d | 0% → 100% | 20d → none | 142232475 → 142232475 FS-150d |  |
| 142232495 | S5 repair | 2013-06-25 → 2012-10-08 A (-260d) | 2013-07-24 → 2013-03-15 A (-131d) | 21d → 196d | 0% → 100% | 20d → none | 142232490 → 142232490 FS-170d | resources MECH TECH [171.43 h]; SCIENTIST [28.57 h] → SCIENTIST [28.57 h]; MECH TECH [171.43 h] |
| 142232560 | Misc. Repair Parts | 2012-08-01 → 2012-11-05 A (+96d) | 2013-06-05 → 2013-08-30 A (+86d) | 209d → 227d | 0% → 100% | 81d → none | 142232200M FS+539d → 142232200M FS+412d |  |
| 142232430 | S2 Counter QA and baseline measurements | 2012-12-04 → 2012-11-12 A (-22d) | 2013-01-08 → 2012-11-19 A (-50d) | 20d → 6d | 0% → 100% | 20d → none | 142232425, 142232415 → 142232425, 142232415 FS-50d |  |
| 142232435 | S2 repair | 2013-01-09 → 2012-11-12 A (-58d) | 2013-02-07 → 2012-11-19 A (-80d) | 21d → 6d | 0% → 100% | 20d → none | 142232430 → 142232430 FS-60d | resources MECH TECH [171.43 h]; SCIENTIST [28.57 h] → SCIENTIST [28.57 h]; MECH TECH [171.43 h] |
| 142232450 | S3 Counter QA and baseline measurements | 2013-02-08 → 2012-11-12 A (-88d) | 2013-03-07 → 2012-11-19 A (-108d) | 19d → 6d | 0% → 100% | 20d → none | 142232435 → 142232435 FS-40d |  |
| 142232455 | S3 repair | 2013-03-08 → 2012-11-12 A (-116d) | 2013-04-04 → 2012-11-19 A (-136d) | 20d → 6d | 0% → 100% | 20d → none | 142232450 → 142232450 FS-60d | resources MECH TECH [171.43 h]; SCIENTIST [28.57 h] → SCIENTIST [28.57 h]; MECH TECH [171.43 h] |
| 142232470 | S4 Counter QA and baseline measurements | 2013-04-05 → 2012-11-12 A (-144d) | 2013-04-25 → 2013-04-15 A (-10d) | 15d → 109d | 0% → 100% | 20d → none | 142232455 → 142232455 FS-90d |  |
| 142232475 | S4 repair | 2013-04-26 → 2012-11-12 A (-165d) | 2013-05-23 → 2013-03-14 A (-70d) | 20d → 129d | 0% → 100% | 20d → none | 142232470 → 142232470 FS-110d |  |
| 142232680 | Panel 1-a and panel 2 HV cable testing | 2013-08-30 → 2012-12-03 A (-270d) | 2013-08-30 → 2013-03-11 A (-172d) | 1d → 10d | 0% → 100% | 20d → none | 9-130M FS+227d → none | was named Panel 1-a and panel 2 HV cable testing (Future Activity Complete prior to Rebaseline) |
| 142232525 | Install Frame Support Pieces | 2013-03-01 → 2012-12-10 A (-81d) | 2013-03-14 → 2013-08-26 A (+165d) | 10d → 29d | 0% → 100% | 139d → none |  |  |
| 142232585 | Counter QA and baseline measurements | 2013-01-09 A | 2013-03-25 → 2013-05-13 A (+49d) |  | 0% → 100% | 20d → none | 142232580a, 142232575a FS+45d → 142232575a, 142232580a FS-47d |  |
| 142232295 | Support Frame Procurement | 2013-02-01 → 2013-01-16 A (-16d) | 2013-05-31 → 2013-04-29 A (-32d) |  | 0% → 100% | 84d → none |  |  |
| 142232590 | Counter repair | 2013-03-26 → 2013-01-31 A (-54d) | 2013-08-30 → 2013-03-11 A (-172d) | 112d → 120d | 0% → 100% | 20d → none | 142232585 → 142232585 FS-50d | resources MECH TECH [888.6 h] → MECH TECH [960 h] |
| 142232580 | Set up FTOF DAQ + Test Station FY12 | 2012-07-05 → 2013-02-11 A (+221d) | 2012-09-28 → 2013-04-15 A (+199d) | 61d → 17d | 0% → 100% | 66.88d → none | 142232395 FS+1d → 142232395 |  |
| 142232580a | Set up FTOF DAQ + Test Station FY13 | 2012-10-01 → 2013-02-11 A (+133d) | 2012-10-24 → 2013-04-15 A (+173d) |  | 0% → 100% | 66.88d → none | 142232580 → 142232580 FS-30d |  |
| 142232535 | Set up FTOF DAQ + Test Station | 2013-04-01 → 2013-03-04 A (-28d) | 2013-06-21 → 2013-08-30 A (+70d) |  | 0% → 100% | 20d → none |  |  |
| 142232595 | Mount S1 counters to frame | 2013-07-30 → 2013-03-11 A (-141d) | 2013-08-12 → 2013-03-15 A (-150d) |  | 0% → 100% | 20d → none | 142232590 FS-24d → 142232590 FS-33d |  |
| 142232605 | Mount S2 counters to frames | 2013-08-20 → 2013-03-11 A (-162d) | 2013-08-30 → 2013-03-18 A (-165d) | 9d → 10d | 0% → 100% | 20d → none | 142232600 → 142232600 FS-20d |  |
| 142232615 | Mount S3 counters to frames | 2013-08-30 → 2013-03-11 A (-172d) | 2013-08-30 → 2013-03-18 A (-165d) | 1d → 9d | 0% → 100% | 20d → none | 9-130M FS+227d → 142232610 FS-20d | was named Mount S3 counters to frames (Future Activity Complete prior to Rebaseline) |
| 142232625 | Mount S4 counters to frames | 2013-08-30 → 2013-03-11 A (-172d) | 2013-08-30 → 2013-03-18 A (-165d) | 1d → 10d | 0% → 100% | 20d → none | 9-130M FS+227d → 142232620 FS-20d | was named Mount S4 counters to frames (Future Activity Complete prior to Rebaseline) |
| 142232635 | Mount S5 counters to frames | 2013-08-30 → 2013-03-11 A (-172d) | 2013-08-30 → 2013-03-15 A (-168d) | 1d → 10d | 0% → 100% | 20d → none | 9-130M FS+227d → 142232630 FS-20d | was named Mount S5 counters to frames (Future Activity Complete prior to Rebaseline) |
| 142232645 | Mount S6 counters to frames | 2013-08-30 → 2013-03-11 A (-172d) | 2013-08-30 → 2013-03-15 A (-168d) | 1d → 10d | 0% → 100% | 20d → none | 9-130M FS+227d → 142232640 FS-20d | was named Mount S6 counters to frames (Future Activity Complete prior to Rebaseline) |
| 142232665 | Panel 1-a and Panel 2 signal cables and connectors (672) - assy&test | 2013-08-30 → 2013-03-11 A (-172d) | 2013-08-30 → 2013-03-25 A (-158d) | 1d → 15d | 0% → 100% | 20d → none | 9-130M FS+227d → 142232660 FS+263d | was named Panel 1-a and Panel 2 signal cables and connectors (672) - assy&test (Future Activity Complete prior to Rebaseline) |
| 142232600 | S1 panel-2 QA | 2013-08-13 → 2013-04-01 A (-134d) | 2013-08-19 → 2013-05-13 A (-98d) |  | 0% → 100% | 20d → none |  |  |
| 142232610 | S2 panel-2 QA | 2013-08-30 → 2013-04-01 A (-151d) | 2013-08-30 → 2013-05-13 A (-109d) | 1d → 5d | 0% → 100% | 20d → none | 9-130M FS+227d → 142232605 FS-10d | was named S2 panel-2 QA (Future Activity Complete prior to Rebaseline) |
| 142232620 | S3 panel-2 QA | 2013-08-30 → 2013-04-01 A (-151d) | 2013-08-30 → 2013-05-13 A (-109d) | 1d → 5d | 0% → 100% | 20d → none | 9-130M FS+227d → 142232615 FS-10d | was named S3 panel-2 QA (Future Activity Complete prior to Rebaseline) |
| 142232630 | S4 panel-2 QA | 2013-08-30 → 2013-04-01 A (-151d) | 2013-08-30 → 2013-05-13 A (-109d) | 1d → 4d | 0% → 100% | 20d → none | 9-130M FS+227d → 142232625 FS-20d | was named S4 panel-2 QA (Future Activity Complete prior to Rebaseline) |
| 142232640 | S5 panel-2 QA | 2013-08-30 → 2013-04-01 A (-151d) | 2013-08-30 → 2013-05-13 A (-109d) | 1d → 5d | 0% → 100% | 20d → none | 9-130M FS+227d → 142232635 FS-20d | was named S5 panel-2 QA (Future Activity Complete prior to Rebaseline) |
| 142232650 | S6 panel-2 QA | 2013-08-30 → 2013-04-01 A (-151d) | 2013-08-30 → 2013-05-13 A (-109d) | 1d → 5d | 0% → 100% | 20d → none | 9-130M FS+227d → 142232645 FS-30d | was named S6 panel-2 QA (Future Activity Complete prior to Rebaseline) |
| 142232530 | Prepare JLAB construction space | 2013-05-13 → 2013-05-06 A (-7d) | 2013-06-27 → 2013-06-17 A (-10d) |  | 0% → 100% | 20d → none | 142232320N FS-34d → 142232320N FS-50d |  |
| 142232540 | Unload counters | 2013-06-24 → 2013-06-10 A (-14d) | 2013-06-27 → 2013-06-17 A (-10d) |  | 0% → 100% | 20d → none | 142232535 → 142232535 FS-60d |  |
| 142232545 | Mount counters to support frame | 2013-07-29 → 2013-06-10 A (-49d) | 2013-08-30 → 2013-08-26 A (-4d) | 25d → 87d | 0% → 100% | 20d → none | 142232540 FS+20d → 142232540 FS-40d | resources MECH TECH [45.98 h] → MECH TECH [160 h] |
| 142232546 | Panel 1-b QA and baseline measurements | 2013-08-01 → 2013-08-30 A (+29d) | 2013-08-30 A | 22d → 101d | 0% → 100% | 20d → none | 142232545 FS-22d → 142232545 FS-84d | resources MECH TECH [156.83 h] → MECH TECH [720 h] |
| 142232690 | Re-Baseline Actuals Adjustment | 2013-08-30 A | 2013-08-30 A |  | 0% → 100% | 20d → none | 9-130M FS+227d → none |  |
| 242232180 | FTOF Travel FY13 | 2013-09-03 A | 2013-09-30 A |  | 0% → 100% | 494d → none |  |  |
| 242232232 | Forward carriage patch panels procurement | 2013-10-30 → 2013-09-03 A (-57d) |  |  | 0% → 41% |  | 9-140M FS+21d → 9-140M |  |
| 242232265a | High Voltage Cable Procurement (Patch Panel Plates/Brackets) | 2013-10-30 → 2013-09-03 A (-57d) | 2014-02-28 → 2013-09-23 A (-158d) |  | 0% → 100% | 453d → none |  |  |
| 242232320Q | Peg Point #11 - Counter baseline measurements complete | 2013-09-03 A | 2013-12-20 → 2014-03-31 (+101d) |  | 0% → 64% | 456d → 398d |  | resources PROCUREMENT<$50K 60 NO ESCALATION; PROCUREMENT>$50K 69 NO ESCALATION → PROCUREMENT>$50K 69 NO ESCALATION |
| 242232320R | Peg Point #12 - Panel-1b assembly and testing complete | 2013-09-03 A | 2013-12-20 → 2014-03-31 (+101d) |  |  | 456d → 394d | 242232320Q FS-77d → 242232320Q FS-100d |  |
| 242232546 | Panel 1-b QA and baseline measurements FY13 | 2013-09-03 A | 2013-09-30 → 2014-02-28 (+151d) |  |  |  |  |  |
| 242232546a | Panel 1-b QA and baseline measurements FY14 | 2013-10-01 → 2013-09-03 A (-28d) |  |  |  |  | 9-130M FS+228d, 242232546 → 242232546 FS-130d |  |
| 242232185 | FTOF Travel FY14 | 2013-10-01 A |  |  | 0% → 40% |  |  |  |
| 242232320S | De-Obligation of USC Contract | 2013-12-20 → 2013-10-01 A (-80d) | 2013-12-20 → 2014-03-31 (+101d) |  | 0% → 21% | 456d → 394d | 242232320R FS-1d → 242232320R FS-96d |  |
| 242232560 | Misc. Repair Parts | 2013-10-23 → 2013-11-01 (+9d) | 2014-02-21 → 2014-03-04 (+11d) |  |  | 458d → 451d |  |  |
| 242232655 | Panel 2 Support Frame Procurement | 2013-09-03 → 2013-11-01 (+59d) | 2014-03-31 → 2014-05-30 (+60d) |  |  | 453d → 410d | 9-130M FS+228d → 9-140M FS+20d, 9-130M FS+245d |  |
| 242232396 | Calibration test equipment Procurement | 2013-10-30 → 2013-12-05 (+36d) | 2014-02-28 → 2014-04-03 (+34d) |  |  | 453d → 429d | 9-140M FS+21d → 9-140M FS+45d |  |
| 242232685M | FTOF Complete | 2014-03-03 → 2014-05-01 (+59d) | 2014-03-03 → 2014-05-01 (+59d) |  |  | 453d → 410d |  |  |
| 4 | **1.4.2.2.4 CERENKOV** | 2009-07-23 → 2009-08-10 (+18d) | 2015-04-17 → 2015-06-19 (+63d) |  |  |  |  |  |
| 1 | **1.4.2.2.4.1 HIGH THRESHOLD CC** | 2009-07-23 → 2009-08-10 (+18d) | 2015-04-17 → 2015-06-19 (+63d) |  |  |  |  |  |
| 142241000M | HTCC-P-#1 Start Procurement Prep PMTs | 2009-07-23 → 2009-08-10 A (+18d) | 2009-07-23 → 2009-08-10 A (+18d) |  | 0% → 100% | 486d → none | 1222241035M, 9-100M FS-60d → 9-100M FS-60d, 1222241035M FS+39d | was named HTCC-P-#1 Start Constr |
| 142241002 | HTCC-P-#1 Procumnt Prep for Mirror Compnts, Tooling and PMTs FY09 | 2009-07-23 → 2009-08-17 A (+25d) | 2009-09-30 → 2010-02-26 A (+149d) | 49d → 128.15d | 0% → 100% | 486d → none |  | was named HTCC-P-#1 Procumnt Prep for Mirror Compnts & Tooling FY09 |
| 142241002b | HTCC-P-#1 Procumnt Prep for Mirror Compnts, Tooling and PMTs FY10 | 2009-10-01 → 2009-09-30 A (-1d) | 2009-10-15 → 2010-02-26 A (+134d) | 11d → 97.57d | 0% → 100% | 486d → none | 142241002 → 142241002 FS-300d | was named HTCC-P-#1 Procumnt Prep for Mirror Compnts & Tooling FY10 |
| 142241026M | HTCC-P-#2 Start Construction | 2009-10-01 A | 2009-10-01 A |  | 0% → 100% | 70d → none |  | was named HTCC-P-#2 Start Constr |
| 142241102 | HTCC-P-#2 Procumnt Prep for Mirror Compnts & Tooling | 2009-10-01 A | 2009-10-14 → 2010-03-19 A (+156d) | 10d → 112d | 0% → 100% | 70d → none |  |  |
| 142241005 | HTCC-P-#1 Vend Manufacturing of Mirror Compnts & Tooling | 2010-01-05 → 2009-12-01 A (-35d) | 2010-02-26 → 2010-03-19 A (+21d) | 37d → 71d | 0% → 100% | 437d → none | 142241002b, 9-100M FS+60d → 142241002b, 9-100M |  |
| 142241105 | HTCC-P-#2 Vend Manufacturing of Mirror Compnts & Tooling | 2010-01-05 → 2010-03-01 A (+55d) | 2010-02-26 → 2010-04-14 A (+47d) | 37d → 33d | 0% → 100% | 20d → none | 9-100M FS+60d, 142241102 → 9-100M FS+55d, 142241102 |  |

| ID | Task | Start | Finish | Duration | Complete | Total float | Predecessors | Other |
| --- | --- | --- | --- | --- | --- | --- | --- | --- |
| 142241580 | Procurement of miscellaneous parts - Proc | 2013-08-30 → 2010-03-08 A (-1271d) | 2013-08-30 A | 1d → 913d | 0% → 100% | 20d → none | 9-130M FS+227d → 9-100M FS+103d |  |
| 142241250 | Assembly of the mirror #1 substrate - Lab | 2010-04-23 → 2010-04-13 A (-10d) | 2010-07-15 → 2011-04-25 A (+284d) | 58d → 257d | 0% → 100% | 20d → none | 142241105 FS+39d → 142241105 FS-14d |  |
| 142241210 | Manufacturing of the 5" PMT ET-9823QB and HV dividers - Proc | 2010-06-07 → 2010-04-14 A (-54d) | 2011-06-07 → 2011-06-30 A (+23d) | 249d → 303d | 0% → 100% | 437d → none | 142241005 FS+69d → 142241005 FS-50d | resources PROCUREMENT>$50K 69 NO ESCALATION FY11; PROCUREMENT<$50K 60 NO ESCALATION FY11 → PROCUREMENT<$50K 60 NO ESCALATION FY11; PROCUREMENT>$50K 69 NO ESCALATION FY11 |
| 142241350M | Space required for HTCC construction | 2010-03-01 → 2010-05-24 A (+84d) | 2010-03-01 → 2010-05-24 A (+84d) |  | 0% → 100% | 137d → none |  |  |
| 142241465 | Procurement Prep for magnetic shields - Lab | 2010-03-31 → 2010-05-24 A (+54d) | 2010-05-05 → 2011-12-19 A (+593d) | 26d → 393d | 0% → 100% | 521d → none |  |  |
| 142241360 | Transport of all necessary equipment from Test area (room 125, EEL) to the HTCC assembly area | 2010-04-19 → 2010-05-25 A (+36d) | 2010-09-30 → 2010-09-29 A (-1d) | 116d → 89d | 0% → 100% | 246d → none | 142241350M FS+35d → 142241350M |  |
| 142241365 | Installation of all equipment for all the HTCC equipment and safety review | 2010-04-19 → 2010-05-25 A (+36d) | 2010-09-30 → 2010-09-29 A (-1d) | 116d → 89d | 0% → 100% | 246d → none |  |  |
| 142241265 | Tooling manufacturing for mirror segments construction - Lab | 2010-07-29 → 2010-07-05 A (-24d) | 2010-08-19 → 2010-08-31 A (+12d) | 16d → 41d | 0% → 100% | 20d → none | 142241260 FS-1d → 142241260 FS-30d |  |
| 142241354 | HTCC Prepare Mezzanine workspace | 2010-07-01 → 2010-07-12 A (+11d) | 2011-01-31 → 2010-12-20 A (-42d) | 142d → 113d | 0% → 100% | 238d → none |  |  |
| 142241310 | Procurement Prep of ROHACELL foam sheets for substrates manufacturing - Lab | 2010-07-29 → 2010-08-23 A (+25d) | 2010-08-12 → 2010-10-18 A (+67d) | 11d → 40d | 0% → 100% | 590d → none | 142241260 FS-1d → 142241260 FS-60d |  |
| 142241260 | Quality control of the mirror #1 substrate - Lab | 2010-07-16 → 2010-08-30 A (+45d) | 2010-07-29 → 2011-05-23 A (+298d) | 10d → 180d | 0% → 100% | 20d → none | 142241250 → 142241250 FS-60d |  |
| 142241320 | Procurement Prep of plastic monomers (acrylic and / or epoxy with low vapor pressure) - Lab | 2010-07-29 → 2010-08-30 A (+32d) | 2010-08-12 → 2011-03-25 A (+225d) | 11d → 139d | 0% → 100% | 237d → none | 142241260 FS-1d → 142241260 FS-60d |  |
| 142241330 | Procurement prep of plastic films/sheets of optical quality - Lab | 2010-07-29 → 2010-08-30 A (+32d) | 2010-08-12 → 2010-09-30 A (+49d) | 11d → 23d | 0% → 100% | 590d → none | 142241260 FS-1d → 142241260 FS-60d |  |
| 142241270 | Manufacturing of tooling for mirror segments construction - Expenses FY10 | 2010-07-30 → 2010-09-06 A (+38d) | 2010-09-30 → 2012-01-16 A (+473d) | 44d → 333d | 0% → 100% | 228d → none | 142241265 FS-15d → 142241265 FS-30d |  |
| 142241270a | Manufacturing of tooling for mirror segments construction - Expenses FY11 | 2010-10-01 → 2010-09-06 A (-25d) | 2010-10-28 → 2012-01-16 A (+445d) | 20d → 333d | 0% → 100% | 228d → none | 142241270 → 142241265 FS-185d, 142241270 FS-155d |  |
| 142241435 | Procurement prep of CV construction parts - Lab FY10 | 2010-08-02 → 2010-09-06 A (+35d) | 2010-09-30 → 2012-10-19 A (+750d) | 43d → 527.65d | 0% → 100% | 259d → none | 142241430M → 142241430M FS-70d |  |
| 142241435a | Procurement prep of CV construction parts - Lab FY11 | 2010-10-01 → 2010-09-06 A (-25d) | 2011-03-15 → 2012-10-19 A (+584d) | 108d → 528d | 0% → 100% | 259d → none | 142241435 → 142241435 FS-70d | resources MECH ENG [28.61 h]; SCIENTIST [28.61 h]; MECH DES [28.61 h] → SCIENTIST [28.61 h]; MECH ENG [28.61 h]; MECH DES [28.61 h] |
| 142241325 | Procurement of plastic monomers (acrylic and / or epoxy with low vapor pressure) - Proc | 2010-08-13 → 2010-09-08 A (+26d) | 2010-09-30 → 2011-03-25 A (+176d) | 34d → 133d | 0% → 100% | 237d → none | 142241320 → 142241320 FS-40d |  |
| 142241315 | Procurement of ROHACELL foam sheets for substrates manufacturing - Proc | 2010-08-13 → 2010-09-13 A (+31d) | 2010-09-30 → 2011-01-24 A (+116d) | 34d → 87d | 0% → 100% | 590d → none | 142241310 → 142241310 FS-40d |  |
| 142241335 | Procurement of plastic films/sheets of optical quality - Proc | 2010-08-13 → 2010-09-13 A (+31d) | 2010-09-30 → 2010-11-22 A (+53d) | 34d → 51d | 0% → 100% | 590d → none | 142241330 → 142241330 FS-40d |  |
| 142241355 | Procurement of Granite Tables - Proc | 2010-05-28 → 2010-09-13 A (+108d) | 2010-10-11 → 2010-12-20 A (+70d) | 94d → 69d | 0% → 100% | 137d → none | 142241350M FS+64d → 142241350M |  |
| 142241475 | Tests of up to 10% of magnetic shields - Lab FY10 | 2010-07-12 → 2010-09-14 A (+64d) | 2010-09-30 → 2012-04-16 A (+564d) | 58d → 391.58d | 0% → 100% | 521d → none | 142241470 FS-120d → 142241470 FS-225d |  |
| 142241475a | Tests of up to 10% of magnetic shields - Lab FY11 | 2010-10-01 → 2010-09-14 A (-17d) | 2011-02-07 → 2012-04-16 A (+434d) | 83d → 392d | 0% → 100% | 521d → none | 142241475 → 142241475 FS-183d | resources CONTRB UNIV LBR [23.55 h]; PD UNIV STUDNT [47.09 h] → PD UNIV STUDNT [47.09 h]; CONTRB UNIV LBR [23.55 h] |
| 142241480 | Procurement Prep of Light Collectors (WC) - Lab | 2010-11-24 → 2011-02-14 A (+82d) | 2011-01-05 → 2011-06-30 A (+176d) | 23d → 97d | 0% → 100% | 317d → none |  |  |
| 142241255 | Trimming of the mirror #1 substrate -Expenses | 2010-07-16 → 2011-03-21 A (+248d) | 2010-07-22 → 2011-05-16 A (+298d) | 5d → 41d | 0% → 100% | 792d → none | 142241250 → 142241250 FS-20d |  |
| 142241340 | Manufacturing of foam mirror substrates - Expenses FY10 | 2010-09-30 → 2011-04-01 A (+183d) | 2010-09-30 → 2011-07-18 A (+291d) | 1d → 74.5d | 0% → 100% | 590d → none | 142241275a FS-51.5d, 142241335 FS-1d, 142241315 FS-1d → 142241315 FS-1d, 142241275a FS-110d, 142241275 FS-110d, 142241335 FS-1d |  |
| 142241345 | Quality control of cut mirror substrates - Lab FY10 | 2010-09-30 → 2011-04-04 A (+186d) | 2010-09-30 → 2011-07-18 A (+291d) | 1d → 74d | 0% → 100% | 590d → none | 142241340a FS-154d → 142241340a FS-154d, 142241340 FS-154d |  |
| 142241345a | Quality control of cut mirror substrates - Lab FY11 | 2010-10-01 → 2011-04-04 A (+185d) | 2011-05-17 → 2012-07-16 A (+426d) | 153d → 321d | 0% → 100% | 590d → none | 142241345 → 142241340a FS-180d, 142241345 |  |
| 142241340a | Manufacturing of foam mirror substrates - Expenses FY11 | 2010-10-01 → 2011-04-04 A (+185d) | 2011-05-17 → 2012-07-16 A (+426d) | 153d → 320.5d | 0% → 100% | 590d → none | 142241340 → 142241275a FS-140d, 142241275 FS-140d |  |
| 142241370 | Assembly of 12 identical sets and QA of 5 substrates (60 substrates total) - Lab FY11 | 2010-10-14 → 2011-05-02 A (+200d) | 2011-09-30 → 2012-01-16 A (+108d) | 239d → 174d | 0% → 100% | 237d → none | 142241354 FS-70d, 142241325 FS+9d, 142241365, 142241270a FS-40d → 142241365, 142241354 FS-70d, 142241270a FS-150d, 142241325 FS+9d, 142241270 FS-150d | was named Assembly of 12 indentical sets and QA of 5 substrates (60 substrates total) - Lab FY11; resources MECH ENG [15.62 h]; VISTNG USERS [1099.71 h]; SCIENTIST [328.04 h]; MECH TECH [999.74 h] → SCIENTIST [328.04 h]; MECH ENG [15.62 h]; MECH TECH [999.74 h]; VISTNG USERS [1099.71 h] |
| 142241370a | Assembly of 12 identical sets and QA of 5 substrates (60 substrates total) - Lab FY12 | 2011-10-03 → 2011-05-02 A (-154d) | 2011-10-31 → 2012-01-16 A (+77d) | 21d → 174d | 0% → 100% | 237d → none | 142241370 → 142241370 FS-230d | was named Assembly of 12 indentical sets and QA of 5 substrates (60 substrates total) - Lab FY12; resources MECH ENG [1.37 h]; MECH TECH [87.84 h]; VISTNG USERS [96.63 h]; SCIENTIST [28.82 h] → SCIENTIST [28.82 h]; MECH ENG [1.37 h]; MECH TECH [87.84 h]; VISTNG USERS [96.63 h] |
| 142241375 | Tests of assembled substrates - Lab FY11 | 2010-10-14 → 2011-05-02 A (+200d) | 2011-09-30 → 2012-10-15 A (+381d) | 239d → 365d | 0% → 100% | 418d → none | 142241270a FS-11d, 142241365 FS-10d → 142241365 FS-10d, 142241270a FS-150d, 142241270 FS-150d |  |
| 142241375a | Tests of assembled substrates - Lab FY12 | 2011-10-03 → 2011-05-02 A (-154d) | 2012-01-30 → 2012-10-15 A (+259d) | 77d → 365d | 0% → 100% | 418d → none | 142241375 → 142241375 FS-210d | resources SCIENTIST [9.75 h]; VISTNG USERS [48.73 h]; MECH TECH [9.75 h] → VISTNG USERS [48.73 h]; MECH TECH [9.75 h]; SCIENTIST [9.75 h] |
| 142241275 | Quality Control of tooling for mirror segments construction - Lab FY10 | 2010-07-30 → 2011-06-01 A (+306d) | 2010-09-30 → 2012-10-15 A (+746d) | 44d → 344d | 0% → 100% | 619.5d → none | 142241265 FS-15d → 142241265, 9-110M FS+153d |  |
| 142241275a | Quality Control of tooling for mirror segments construction - Lab FY11 | 2010-10-01 → 2011-06-01 A (+243d) | 2010-10-29 → 2012-10-15 A (+717d) | 21d → 344d | 0% → 100% | 619.5d → none | 142241275 → 142241265 FS-30d, 142241275 FS-142d |  |
| 142241380 | Precision trimming of 12 identical sets of 5 substrates (60 substrates total) - Expenses FY11 | 2010-11-08 → 2011-06-01 A (+205d) | 2011-09-30 → 2012-11-12 A (+409d) | 222d → 364d | 0% → 100% | 228d → none | 142241365, 142241270a FS+6d → 142241270a FS-150d, 142241270 FS-150d, 142241365 |  |
| 142241380a | Precision trimming of 12 identical sets of 5 substrates (60 substrates total) - Expenses FY12 | 2011-10-03 → 2011-06-01 A (-124d) | 2012-01-30 → 2012-11-12 A (+287d) | 77d → 364d | 0% → 100% | 228d → none | 142241380 → 142241380 FS-250d |  |
| 142241385 | Quality control of trimmed substrates before deposition of coating - Labor FY11 | 2010-11-09 → 2011-06-01 A (+204d) | 2011-09-30 → 2012-11-19 A (+416d) | 221d → 368.53d | 0% → 100% | 353d → none | 142241370a FS-415d, 142241365, 142241270a FS+7d, 142241380a FS-447.5d → 142241370a FS-415d, 142241370 FS-415d, 142241380a FS-447.5d, 142241270 FS-150d, 142241365, 142241270a FS-150d | resources SCIENTIST [25.85 h]; MECH ENG [25.85 h] → MECH ENG [25.85 h]; SCIENTIST [25.85 h] |
| 142241385a | Quality control of trimmed substrates before deposition of coating - Labor FY12 | 2011-10-03 → 2011-06-01 A (-124d) | 2012-04-02 → 2012-11-19 A (+231d) | 121d → 369d | 0% → 100% | 353d → none | 142241385 → 142241385 FS-250d |  |
| 142241485 | Manufacturing of Light Collectors (WC) - Proc | 2011-01-06 → 2011-06-01 A (+146d) | 2011-10-25 → 2012-07-16 A (+265d) | 204d → 280d | 0% → 100% | 317d → none |  |  |
| 142241495 | Procurement support of cables and gas systems - Lab FY10 | 2010-08-02 → 2011-06-01 A (+303d) | 2010-09-30 → 2012-02-13 A (+501d) | 43d → 173d | 0% → 100% | 505d → none |  | was named Procurement prep of cables and gas systems - Lab FY10; resources SCIENTIST [38.22 h]; MECH TECH [76.44 h] → MECH TECH [76.44 h]; SCIENTIST [38.22 h] |
| 142241495a | Procurement support of cables and gas systems - Lab FY11 | 2010-10-01 → 2011-06-01 A (+243d) | 2010-10-04 → 2012-02-13 A (+497d) | 2d → 172d | 0% → 100% | 505d → none | 142241495 → 142241495 FS-464d | was named Procurement prep of cables and gas systems - Lab FY11 |
| 142241280 | Tooling Design for mirror half-sectors assembly - Lab FY10 | 2010-09-17 → 2011-07-18 A (+304d) | 2010-09-30 → 2011-09-26 A (+361d) | 10d → 49d | 0% → 100% | 20d → none | 142241265 FS+19d → 9-110M FS+153d, 142241265 FS+19d | was named Tooling manufacturing for mirror half-sectors assembly - Lab FY10 |
| 142241280a | Tooling Design for mirror half-sectors assembly - Lab FY11 | 2010-10-01 → 2011-07-18 A (+290d) | 2010-10-20 → 2011-09-26 A (+341d) | 14d → 49d | 0% → 100% | 20d → none | 142241280 → 142241280 FS-140d, 142241265 FS-90d | was named Tooling manufacturing for mirror half-sectors assembly - Lab FY11 |
| 142241430M | Start Manufacturing of the Containment Vessel | 2010-08-02 → 2011-08-15 A (+378d) | 2010-08-02 → 2011-08-15 A (+378d) |  | 0% → 100% | 259d → none | 9-100M FS+205d → 9-100M FS+205d, 9-110M FS+230d |  |
| 142241285 | Manufacturing of tooling for mirror half sectors assembly - Expenses | 2010-10-21 → 2011-09-24 A (+338d) | 2011-03-23 → 2013-01-21 A (+670d) | 100d → 333d | 0% → 100% | 30d → none | 142241280a → 142241280a, 142241280 |  |
| 142241290 | Quality Control of tooling for mirror half-sectors assembly - Lab | 2010-10-21 → 2011-10-03 A (+347d) | 2011-04-06 → 2013-01-21 A (+656d) | 110d → 328d | 0% → 100% | 20d → none | 142241280a → 142241280 FS+20d, 142241280a FS+20d |  |
| 142241295 | Tooling manufacturing for combined mirror assembly - Lab | 2011-04-07 → 2011-10-03 A (+179d) | 2011-08-17 → 2013-05-13 A (+635d) | 93d → 346d | 0% → 100% | 482d → none | 142241290 → 142241290 FS-79d |  |
| 142241300 | Manufacturing of tooling for combined mirror assembly - Expenses FY11 | 2011-08-18 → 2011-10-03 A (+46d) | 2011-09-30 → 2012-02-13 A (+136d) | 31d → 87d | 0% → 100% | 500.5d → none | 142241295 → 142241295 FS-170d |  |
| 142241300a | Manufacturing of tooling for combined mirror assembly - Expenses FY12 | 2011-10-03 A | 2011-10-18 → 2012-02-13 A (+118d) | 12d → 87d | 0% → 100% | 500.5d → none | 142241300 → 142241300 FS-70d |  |
| 142241305 | Quality Control of tooling for combined mirror assembly - Lab FY11 | 2011-08-18 → 2011-10-03 A (+46d) | 2011-09-30 → 2013-05-13 A (+591d) | 31d → 347d | 0% → 100% | 482d → none | 142241295, 142241300a FS-61.5d → 142241300a FS-140d, 142241295 FS-170d |  |
| 142241305a | Quality Control of tooling for combined mirror assembly - Lab FY12 | 2011-10-03 A | 2011-10-19 → 2013-05-13 A (+572d) | 13d → 347d | 0% → 100% | 482d → none | 142241305 → 142241305 FS-150d |  |
| 142241270b | Manufacturing of tooling for mirror segments construction - Expenses FY12 | 2011-11-01 A | 2012-04-16 → 2012-10-15 A (+182d) | 110d → 237d | 0% → 100% | 234d → none |  |  |
| 142241570 | Procurement Prep of the composite exit window - Lab | 2011-07-01 → 2011-11-01 A (+123d) | 2011-09-02 → 2011-12-19 A (+108d) | 45d → 33d | 0% → 100% | 106d → none | 9-110M FS+184d → 9-120M |  |
| 142241487 | Manufacturing of Additional Light Collectors (WC) - Proc | 2011-11-02 → 2011-12-01 A (+29d) | 2012-06-29 → 2013-06-17 A (+353d) | 161d → 287d | 0% → 100% | 345d → none | 142241485 FS+5d → 142241485 FS-237d |  |
| 142241490 | Quality control of Light Collectors (WC) - Lab | 2011-02-23 → 2011-12-19 A (+299d) | 2011-11-28 → 2013-08-30 A (+641d) | 194d → 294d | 0% → 100% | 317d → none |  |  |
| 142241302 | Procurement of Lab Equipment for Clean Rooms | 2012-01-05 → 2012-01-03 A (-2d) | 2012-04-02 → 2012-09-17 A (+168d) | 61d → 180d | 0% → 100% | 374d → none |  |  |
| 142241440 | Manufacturing of parts for the CV construction - Proc Part A | 2012-03-12 → 2012-01-03 A (-69d) | 2013-05-24 → 2013-05-13 A (-11d) | 302d → 349d | 0% → 100% | 20d → none | 9-120M FS+105d, 142241435a → 9-120M, 142241435a FS-70d |  |
| 142241445 | Manufacturing of Central Dish for the containment vessel - FY12 | 2012-01-23 → 2012-01-03 A (-20d) | 2012-09-28 → 2012-10-15 A (+17d) | 176d → 200d | 0% → 100% | 49d → none | 9-120M FS+71d, 142241435a FS+1d → 9-120M, 142241435a FS-70d | was named Manufacturing of Central Dish for the containment vessel FY12 |
| 142241445a | Manufacturing of Central Dish for the containment vessel FY13 | 2012-10-01 → 2012-01-03 A (-272d) | 2013-05-31 → 2012-10-15 A (-228d) | 164d → 200d | 0% → 100% | 49d → none | 142241445 → 142241445 FS-190d |  |
| 142241575 | Manufacturing of the composite exit window - Proc | 2012-04-03 → 2012-01-03 A (-91d) | 2013-04-30 → 2012-02-13 A (-442d) | 268d → 29d | 0% → 100% | 106d → none | 142241570 FS+140d → 142241570 FS+25d |  |
| 142241370b | Assembly of 12 identical sets and QA of 5 substrates (60 substrates total) - Revised Lab FY12 | 2011-11-01 → 2012-01-16 A (+76d) | 2012-08-31 → 2012-10-15 A (+45d) | 207d → 191d | 0% → 100% | 237d → none |  | was named Assembly of 12 indentical sets and QA of 5 substrates (60 substrates total) - Revised Lab FY12 |
| 142241470 | Manufacturing of magnetic shields - Proc | 2010-05-06 → 2012-01-16 A (+620d) | 2011-01-06 → 2012-04-16 A (+466d) | 165d → 64d | 0% → 100% | 521d → none | 142241465 → 142241465 FS+15d | resources PROCUREMENT<$50K 60 NO ESCALATION FY11; PROCUREMENT>$50K 69 NO ESCALATION FY11 → PROCUREMENT>$50K 69 NO ESCALATION FY11; PROCUREMENT<$50K 60 NO ESCALATION FY11 |
| 142241527 | Procurement of components for the HTCC Gas System construction | 2012-02-03 → 2012-02-01 A (-2d) | 2013-08-30 → 2012-08-20 A (-375d) | 395d → 141d | 0% → 100% | 20d → none |  |  |
| 142241647 | Proc. Prep of components for the HTCC Light Monitoring System | 2011-11-01 → 2012-02-01 A (+92d) | 2011-12-12 → 2012-06-11 A (+182d) | 28d → 91d | 0% → 100% | 208d → none | 9-120M FS+21d → 9-120M FS+80d |  |
| 142241530 | Manufacturing of Pump EW-07061-42 - Proc | 2010-10-05 → 2012-02-01 A (+484d) | 2011-03-02 → 2012-02-13 A (+348d) | 97d → 8d | 0% → 100% | 644d → none | 142241495a → 142241495a FS-380d |  |
| 142241545 | Manufacturing of Transformer FF-108U Proc | 2010-10-05 → 2012-02-01 A (+484d) | 2011-03-02 → 2012-02-13 A (+348d) | 97d → 8d | 0% → 100% | 644d → none | 142241495a → 142241495a FS-380d |  |
| 142241550 | Manufacturing of Utility Chasis CHA-5X21 - Proc | 2010-10-05 → 2012-02-01 A (+484d) | 2011-03-02 → 2012-02-13 A (+348d) | 97d → 8d | 0% → 100% | 644d → none | 142241495a → 142241495a FS-380d |  |
| 142241555 | Manufacturing of Controller DP25B-EAR - Proc | 2010-10-05 → 2012-02-01 A (+484d) | 2011-03-02 → 2012-02-13 A (+348d) | 97d → 8d | 0% → 100% | 644d → none | 142241495a → 142241495a FS-380d |  |
| 142241565 | Procurement of 1/2 Stainless Steel Tubing - Proc | 2010-10-05 → 2012-02-01 A (+484d) | 2011-03-02 → 2012-02-13 A (+348d) | 97d → 8d | 0% → 100% | 644d → none | 142241495a → 142241495a FS-380d |  |

| ID | Task | Start | Finish | Duration | Complete | Total float | Predecessors | Other |
| --- | --- | --- | --- | --- | --- | --- | --- | --- |
| 142241300b | Purchase of Pumps and Plumbing for Combined Mirror Assembly | 2012-02-03 → 2012-03-02 A (+28d) | 2012-04-30 → 2012-04-16 A (-14d) | 61d → 32d | 0% → 100% | 21d → none |  |  |
| 142241500 | Manufacturing of high voltage (HV) cable RG8X - Proc | 2010-10-05 → 2012-03-02 A (+514d) | 2011-03-02 → 2012-03-19 A (+383d) | 97d → 12d | 0% → 100% | 505d → none | 142241495a → 142241495a FS-380d |  |
| 142241505 | Manufacturing of signal cable PE-B319 - Proc | 2010-10-05 → 2012-03-02 A (+514d) | 2011-03-02 → 2012-03-19 A (+383d) | 97d → 12d | 0% → 100% | 505d → none | 142241495a → 142241495a FS-380d |  |
| 142241510 | Manufacturing of HV connectors PE-4193 - Proc | 2010-10-05 → 2012-03-02 A (+514d) | 2011-03-02 → 2012-03-19 A (+383d) | 97d → 12d | 0% → 100% | 505d → none | 142241495a → 142241495a FS-380d |  |
| 142241515 | Manufacturing of HV connectors PE-4493 - Proc | 2010-10-05 → 2012-03-02 A (+514d) | 2011-03-02 → 2012-03-19 A (+383d) | 97d → 12d | 0% → 100% | 505d → none | 142241495a → 142241495a FS-380d |  |
| 142241520 | Manufacturing of BNC connectors PE-4386 - Proc | 2010-10-05 → 2012-03-02 A (+514d) | 2011-03-02 → 2012-03-19 A (+383d) | 97d → 12d | 0% → 100% | 505d → none | 142241495a → 142241495a FS-380d |  |
| 142241525 | Manufacturing of BNC connectors PE-4014 - Proc | 2010-10-05 → 2012-03-02 A (+514d) | 2011-03-02 → 2012-03-19 A (+383d) | 97d → 12d | 0% → 100% | 505d → none | 142241495a → 142241495a FS-380d |  |
| 142241560 | Manufacturing of Cable 1255/8BK002 - Proc | 2010-10-05 → 2012-03-02 A (+514d) | 2011-03-02 → 2012-03-19 A (+383d) | 97d → 12d | 0% → 100% | 644d → none | 142241495a → 142241495a FS-380d |  |
| 142241647a | Proc of components for the HTCC Light Monitoring System | 2012-10-01 → 2012-06-01 A (-122d) | 2013-03-07 → 2013-08-30 A (+176d) | 104d → 188d | 0% → 100% | 20d → none | 142241647 FS+10d, 9-130M → 142241647 |  |
| 142241472 | Procurement of PS for Compensation Coils | 2012-10-01 → 2012-07-02 A (-91d) | 2013-05-31 → 2012-10-15 A (-228d) | 164d → 75d | 0% → 100% | 84d → none | 9-130M → 9-130M FS-40d |  |
| 142241535 | Manufacturing of Power Supply S-240-15 - Proc | 2010-10-05 → 2012-09-03 A (+699d) | 2011-03-02 → 2012-09-17 A (+565d) | 97d → 10d | 0% → 100% | 644d → none | 142241495a → 142241495a FS-380d, 9-130M |  |
| 142241540 | Manufacturing of Controller 250E-4-D - Proc | 2010-10-05 → 2012-09-03 A (+699d) | 2011-03-02 → 2012-09-17 A (+565d) | 97d → 10d | 0% → 100% | 644d → none | 142241495a → 142241495a FS-380d, 9-130M |  |
| 142241395 | Quality control of 60 coated substrates - Lab FY11 | 2010-11-15 → 2012-10-01 A (+686d) | 2011-09-30 → 2013-08-30 A (+700d) | 217d → 143d | 0% → 100% | 353d → none | 9-110M FS+31d → 9-120M FS+80d |  |
| 142241395a | Quality control of 60 coated substrates - Lab FY12 | 2011-10-03 → 2012-10-01 A (+364d) | 2012-05-01 → 2013-08-30 A (+486d) | 142d → 143d | 0% → 100% | 353d → none | 142241395 → 142241395 FS-200d |  |
| 142241440a | Manufacturing of parts for the CV construction - Proc Part B | 2012-03-12 → 2012-10-01 A (+203d) | 2013-05-24 → 2013-04-15 A (-39d) | 302d → 160d | 0% → 100% | 20d → none | 9-120M FS+105d, 142241435a → 142241435a FS-70d, 9-120M | resources PROCUREMENT>$50K 69 NO ESCALATION FY13; PROCUREMENT<$50K 60 NO ESCALATION FY13 → PROCUREMENT<$50K 60 NO ESCALATION FY13; PROCUREMENT>$50K 69 NO ESCALATION FY13 |
| 142241382 | Precision trimming of 12 identical sets of 5 substrates (60 substrates total) - Additional Expenses FY12 | 2012-01-31 → 2012-11-03 A (+277d) | 2012-09-28 → 2012-11-12 A (+45d) | 170d → 6d | 0% → 100% | 228d → none | 142241270b FS-60d, 142241380a, 142241370b FS-160d → 142241370b FS-200d, 142241380a FS-15d, 142241270b FS-60d |  |
| 142241382a | Precision trimming of 12 identical sets of 5 substrates (60 substrates total) - Additional Expenses FY13 | 2012-10-01 → 2012-11-05 A (+35d) | 2012-10-26 → 2012-11-19 A (+24d) | 20d → 11d | 0% → 100% | 228d → none |  |  |
| 142241450 | Assembly of the CV - Lab FY11 | 2011-09-15 → 2013-05-06 A (+599d) | 2011-09-30 → 2013-08-30 A (+700d) | 12d → 40d | 0% → 100% | 316d → none | 142241440a FS-423d, 142241445a FS-423d, 142241440 FS-423d → 9-130M FS+5d, 9-120M, 142241440a FS-40d, 142241440 FS-40d, 142241445a FS-329d |  |
| 142241450a | Assembly of the CV - Lab FY12 | 2011-10-03 → 2013-05-06 A (+581d) | 2011-10-31 → 2013-08-30 A (+669d) | 21d → 40d | 0% → 100% | 316d → none | 142241450 → 142241450 FS-220d |  |
| 142241450b | Assembly of the CV - Lab Revised | 2013-01-17 → 2013-05-06 A (+109d) | 2013-08-01 → 2013-08-30 A (+29d) |  | 0% → 100% | 20d → none | 142241440 FS-90d, 142241445a FS-123d, 142241440a FS-90d, 142241450a → 142241445a FS-123d, 142241450a FS-220d, 142241440a FS-90d, 142241440 FS-90d |  |
| 142241455 | Quality control fo the CV construction - Lab | 2013-04-22 → 2013-05-06 A (+14d) | 2013-08-30 A | 93d → 118d | 0% → 100% | 52d → none | 142241450b FS-72d → 142241450b FS-220d |  |
| 142241600 | Assembly of the composite carbon cone - Lab | 2013-08-30 → 2013-05-06 A (-116d) | 2013-08-30 A | 1d → 10d | 0% → 100% | 20d → none | 9-130M FS+227d → 9-130M | was named Assembly of the composite carbon cone - Lab (Future Activity Complete prior to Rebaseline); resources MECH TECH → MECH TECH [80 h] |
| 142241400 | Tests for coated substrates - Lab FY11 | 2010-12-01 → 2013-08-30 A (+1003d) | 2011-09-30 → 2013-08-30 A (+700d) | 207d → 69d | 0% → 100% | 353d → none | 142241385a FS-328d → 142241385a FS-450d, 9-120M FS+80d, 142241385 FS-450d |  |
| 142241400a | Tests for coated substrates - Lab FY12 | 2011-10-03 → 2013-08-30 A (+697d) | 2012-05-01 → 2013-08-30 A (+486d) |  | 0% → 100% | 353d → none |  |  |
| 142241405 | Dry Fit of Preformed Mirror facets into sectors - Lab FY11 | 2011-04-07 → 2013-08-30 A (+876d) | 2011-09-30 → 2013-08-30 A (+700d) | 124d → 21d | 0% → 100% | 20d → none | 142241290, 142241355, 142241285 → 142241285, 142241355, 142241290 FS+15d, 142241295 | was named Dry Fit of Preformed Mirror facets into rings - Lab FY11; resources MECH DES [15.95 h]; MECH TECH [382.77 h]; VISTNG USERS [478.46 h]; SCIENTIST [139.55 h] → VISTNG USERS [478.46 h]; SCIENTIST [139.55 h]; MECH DES [15.95 h]; MECH TECH [382.77 h] |
| 142241405a | Dry Fit of Preformed Mirror facets into sectors - Lab FY12 | 2011-10-03 → 2013-08-30 A (+697d) | 2011-10-31 → 2013-08-30 A (+669d) |  | 0% → 100% | 20d → none | 142241405 → 142241405 FS-21d | was named Dry Fit of Preformed Mirror facets into rings - Lab FY12; resources SCIENTIST [23.63 h]; MECH DES [2.7 h]; MECH TECH [64.82 h]; VISTNG USERS [81.03 h] → MECH DES [2.7 h]; MECH TECH [64.82 h]; VISTNG USERS [81.03 h]; SCIENTIST [23.63 h] |
| 142241405b | Assembly of the mirror with rings - Lab FY12 | 2012-05-02 → 2013-08-30 A (+485d) | 2012-09-28 → 2013-08-30 A (+336d) | 105d → 32d | 0% → 100% | 20d → none | 142241300b, 142241405a FS+121d → 142241300b, 142241405a | resources SCIENTIST [128.78 h]; MECH DES [6.44 h]; MECH TECH [820.69 h]; VISTNG USERS [193.26 h]; MECH ENG [24.14 h] → SCIENTIST [128.78 h]; MECH TECH [820.69 h]; VISTNG USERS [193.26 h]; MECH ENG [24.14 h]; MECH DES [6.44 h] |
| 142241405ba | Assembly of the mirror with rings - Lab FY13 | 2012-10-01 → 2013-08-30 A (+333d) | 2013-08-30 A | 228d → 160d | 0% → 100% | 20d → none |  | resources SCIENTIST [279.62 h]; MECH DES [13.99 h]; MECH TECH [1782.07 h]; VISTNG USERS [419.64 h]; MECH ENG [52.41 h] → SCIENTIST [298.02 h]; MECH DES [14.91 h]; MECH TECH [1899.31 h]; VISTNG USERS [447.25 h]; MECH ENG [55.86 h] |
| 142241410 | Quality control of assembled mirror sectors- Lab FY11 | 2011-05-20 → 2013-08-30 A (+833d) | 2011-09-30 → 2013-08-30 A (+700d) | 93d → 81d | 0% → 100% | 474d → none | 142241405a FS-114d → 142241405a, 9-120M FS+80d | was named Quality control of assembled mirror half-sectors - Lab FY11; resources PD UNIV STUDNT [24.72 h]; CONTRB UNIV LBR [24.72 h]; SCIENTIST [30.9 h]; MECH ENG [12.36 h] → SCIENTIST [30.9 h]; MECH ENG [12.36 h]; PD UNIV STUDNT [24.72 h]; CONTRB UNIV LBR [24.72 h] |
| 142241410a | Quality control of assembled mirror sectors - Lab FY12 | 2011-10-03 → 2013-08-30 A (+697d) | 2011-10-31 → 2013-08-30 A (+669d) |  | 0% → 100% | 474d → none |  | was named Quality control of assembled mirror half-sectors - Lab FY12 |
| 142241415 | Checks of geometry of mirror sectors - Lab FY11 | 2011-05-20 → 2013-08-30 A (+833d) | 2011-09-30 → 2013-08-30 A (+700d) | 93d → 59d | 0% → 100% | 474d → none | 142241405a FS-114d → 142241405a, 9-120M FS+80d | was named Checks of geometry of mirror half-sectors - Lab FY11 |
| 142241415a | Checks of geometry of mirror rings - Lab FY12 | 2011-10-03 → 2013-08-30 A (+697d) | 2011-10-31 → 2013-08-30 A (+669d) |  | 0% → 100% | 474d → none |  | was named Checks of geometry of mirror half-sectors - Lab FY12; resources CONTRB UNIV LBR [5.2 h]; SCIENTIST [10.4 h]; PD UNIV STUDNT [5.2 h] → SCIENTIST [10.4 h]; PD UNIV STUDNT [5.2 h]; CONTRB UNIV LBR [5.2 h] |
| 142241460 | Test of the CV on structural stability - Lab | 2013-08-05 → 2013-08-30 A (+25d) | 2013-08-30 A | 20d → 45d | 0% → 100% | 52d → none | 142241455 FS-20d → 142241455 FS-45d | resources SCIENTIST [17.78 h]; MECH DES [17.78 h]; MECH ENG [17.78 h] → MECH DES [17.78 h]; MECH ENG [17.78 h]; SCIENTIST [17.78 h] |
| 142241585 | Assembly of the photo tube housing unit (PMT, HV divider, Winston Cone, Magnetic Shield) - Lab | 2012-12-21 → 2013-08-30 A (+252d) | 2013-03-29 → 2013-08-30 A (+154d) |  | 0% → 100% | 52d → none | 142241525, 142241460 FS-171d, 142241515, 142241520, 142241500, 142241505, 142241210, 142241475a, 142241510, 142241490 → 142241525 FS-95d, 142241520 FS-95d, 142241510 FS-95d, 142241460 FS-196d, 142241210, 142241475a, 142241500 FS-95d, 142241515 FS-95d, 142241505 FS-95d, 142241490 FS-42d |  |
| 142241590 | Installation of 48 housing units - Lab | 2013-05-15 → 2013-08-30 A (+107d) | 2013-08-30 A | 76d → 80d | 0% → 100% | 20d → none |  |  |
| 142241595 | Quality control of the housing unit assembly and installation - Lab | 2013-05-15 → 2013-08-30 A (+107d) | 2013-08-30 A | 76d → 80d | 0% → 100% | 20d → none | 142241590 FS-76d, 142241585 → 142241585, 142241590 FS-80d |  |
| 142241647b | Assembly of optical components and reference detectors in the Aluminum box | 2013-03-12 → 2013-08-30 A (+171d) | 2013-08-30 A | 122d → 260d | 0% → 100% | 20d → none |  | resources PD UNIV STUDNT [54.37 h]; PD UNIV STAFF [20.71 h] → PD UNIV STAFF [20.71 h]; PD UNIV STUDNT [54.37 h] |
| 142241647c | Tests of optical components and reference detectors in the Aluminum box | 2013-03-15 → 2013-08-30 A (+168d) | 2013-08-30 A | 119d → 263d | 0% → 100% | 20d → none | 142241647b FS-119d → 142241647b FS-257d | resources PD UNIV STUDNT [24.13 h]; PD UNIV STAFF [12.07 h] → PD UNIV STAFF [12.07 h]; PD UNIV STUDNT [24.13 h] |
| 142241655 | Re-Baseline Actuals Adjustment | 2013-08-30 A | 2013-08-30 A |  | 0% → 100% | 20d → none | 9-130M FS+227d → none |  |
| 242241370 | Assembly, tests and QA of additional substrates (up to 10 substrates total) FY13 | 2013-09-03 A | 2013-09-30 → 2013-09-23 A (-7d) | 20d → 42d | 0% → 100% | 526.5d → none |  |  |
| 242241370a | Assembly, tests and QA of additional substrates (up to 10 substrates total) FY14 | 2013-10-01 → 2013-09-03 A (-28d) | 2013-10-14 → 2013-09-23 A (-21d) |  | 0% → 100% | 526.5d → none | 242241370, 9-130M FS+228d → 242241370 |  |
| 242241372 | Precision trimming of additional substrates (up to 10 substrates total) - Labor/Expenses FY13 | 2013-09-03 A | 2013-09-30 → 2013-10-21 A (+21d) | 20d → 62d | 0% → 100% | 494d → none |  |  |
| 242241372a | Precision trimming of additional substrates (up to 10 substrates total) - Labor/Expenses FY14 | 2013-10-01 → 2013-09-03 A (-28d) | 2013-11-27 → 2013-10-21 A (-37d) |  | 0% → 100% | 494d → none | 242241372, 9-130M FS+228d → 242241372 FS-50d |  |
| 242241390 | Coating of 60 substrates with Al + MgF2 - Proc | 2013-09-03 A |  |  |  | 159d → 180d |  |  |
| 242241400 | UCONN Quality control of 60 coated substrates - Lab | 2013-09-03 A |  |  | 0% → 2% |  |  |  |
| 242241450aa | Manufacturing of top level assembly parts of the CV construction FY13 | 2013-09-03 A | 2013-09-30 → 2013-10-21 A (+21d) |  | 0% → 100% | 273d → none |  |  |
| 242241450aaa | Manufacturing of top level assembly parts of the CV construction FY14 | 2013-10-01 → 2013-09-03 A (-28d) | 2013-11-15 → 2013-10-21 A (-25d) |  | 0% → 100% | 273d → none | 9-130M FS+228d, 242241450aa → 242241450aa FS-40d |  |
| 242241450b | Assembly of the CV FY13 | 2013-09-03 A | 2013-09-30 → 2014-03-18 (+169d) |  |  | 257d → 237d | 242241450aaa FS-70d, 9-130M FS+228d, 242241450aa FS-70d → 242241450aa FS-45d, 242241450aaa FS-45d, 9-130M FS+228d |  |
| 242241450ba | Assembly of the CV FY14 | 2013-10-01 → 2013-09-03 A (-28d) |  |  |  | 257d → 237d | 242241450aaa FS-70d, 9-130M FS+228d, 242241450aa FS-70d, 242241450b → 242241450b FS-140d, 242241450aaa FS-70d |  |
| 242241452 | Vend Fab HTCC Support Cart | 2013-09-03 A | 2013-09-30 → 2013-09-23 A (-7d) |  | 0% → 100% | 551d → none |  |  |
| 242241457 | HTCC Winston Cone Fabricate finals | 2013-09-03 A | 2013-09-30 → 2013-09-23 A (-7d) |  | 0% → 100% | 551d → none |  | resources PROCUREMENT>$50K 69; PROCUREMENT<$50K 60 → PROCUREMENT<$50K 60 |
| 242241462 | HTCC Consumables | 2013-09-03 A | 2013-09-30 → 2013-09-23 A (-7d) |  | 0% → 100% | 551d → none |  |  |
| 242241395 | Quality control of 60 coated substrates - Proc | 2013-10-03 → 2013-10-01 A (-2d) | 2014-04-15 → 2013-10-21 A (-176d) |  | 0% → 100% | 243d → none |  |  |
| 242241395a | Quality control of 60 coated substrates - Lab | 2013-10-03 → 2013-10-01 A (-2d) |  |  |  |  |  |  |
| 242241415 | Checks of geometry of mirror half-sectors - Expenses FY13 | 2013-09-03 → 2013-11-01 (+59d) | 2013-09-30 → 2013-12-02 (+63d) |  |  | 168d → 125d | 9-130M FS+228d → 9-140M FS+23d, 9-130M FS+228d |  |
| 242241455 | Quality control fo the CV construction - Lab FY13 | 2013-09-17 → 2013-11-01 (+45d) | 2013-09-30 → 2013-11-14 (+45d) |  |  | 257d → 224d | 242241450b FS-120d, 242241450ba FS-120d → 242241450b FS-100d, 242241450ba FS-100d |  |
| 242241580 | Procurement of miscellaneous parts - Proc | 2013-09-03 → 2013-11-01 (+59d) |  | 107d → 64d |  |  | 9-130M FS+228d → 9-130M FS+228d, 9-140M FS+23d |  |
| 242241580a | Procurement of miscellaneous parts - Expenses FY13 | 2013-09-03 → 2013-11-01 (+59d) | 2013-09-30 → 2013-12-02 (+63d) |  |  | 157d → 114d | 9-130M FS+228d → 9-140M FS+23d |  |
| 242241455a | Quality control fo the CV construction - Lab FY14 | 2013-10-01 → 2013-11-15 (+45d) | 2014-04-14 → 2014-05-30 (+46d) |  |  | 257d → 224d | 242241450ba FS-120d, 242241455, 242241450b FS-120d → 242241455, 242241450ba FS-120d |  |
| 242241415a | Checks of geometry of mirror half-sectors - Expenses FY14 | 2013-10-01 → 2013-12-03 (+63d) | 2014-06-30 → 2014-08-29 (+60d) |  |  | 168d → 125d | 9-130M FS+228d, 242241415 → 242241415 |  |
| 242241580b | Procurement of miscellaneous parts - Expenses FY14 | 2013-10-01 → 2013-12-03 (+63d) | 2014-02-13 → 2014-04-15 (+61d) |  |  | 157d → 114d | 242241580a, 9-130M FS+228d → 242241580a |  |
| 242241430 | Procurement of HEPA filters for the HTCC Clean Room | 2014-02-05 → 2014-02-03 (-2d) | 2015-04-06 → 2015-04-02 (-4d) |  |  | 166d → 168d |  |  |
| 242241435 | Change Out of HEPA filters for the HTCC Clean Room | 2014-02-05 → 2014-02-03 (-2d) | 2015-04-07 → 2015-04-03 (-4d) |  |  | 165d → 167d |  |  |
| 242241528 | Assembly of the HTCC Gas System | 2014-03-04 → 2014-03-03 (-1d) | 2014-06-03 → 2014-06-02 (-1d) |  |  | 372d → 373d |  |  |
| 242241600 | Assembly of the composite carbon cone - Lab | 2014-02-17 → 2014-04-03 (+45d) | 2014-03-14 → 2014-04-30 (+47d) |  |  | 301d → 268d |  |  |
| 242241585 | Assembly of the photo tube housing unit (PMT, HV divider, Winston Cone, Magnetic Shield) - Lab | 2014-02-14 → 2014-04-16 (+61d) | 2014-10-03 → 2014-12-05 (+63d) |  |  | 157d → 114d | 242241580a, 242241580, 242241455 FS-260d, 242241455a FS-260d, 242241580b → 242241580, 242241455a FS-260d, 242241580b, 242241455 FS-260d |  |
| 242241605 | Installation of the assembled carbon cone - Lab | 2014-04-14 → 2014-05-30 (+46d) | 2014-09-12 → 2014-10-29 (+47d) |  |  | 301d → 268d |  | resources MECH ENG [20 h]; SCIENTIST [20 h]; MECH TECH [80 h] → MECH TECH [80 h]; MECH ENG [20 h]; SCIENTIST [20 h] |
| 242241610 | Installation of the composite exit window - Lab | 2014-04-14 → 2014-05-30 (+46d) | 2014-09-12 → 2014-10-29 (+47d) |  |  | 301d → 268d |  |  |
| 242241630 | Installation of a temporary CO2 gas supply system - Lab | 2014-06-17 → 2014-06-16 (-1d) | 2014-08-18 → 2014-08-15 (-3d) |  |  | 319d → 320d |  |  |
| 242241417 | Manufacturing of modified HV-dividers for the 5" PMTs (50 units)-Lab | 2014-05-05 → 2014-07-07 (+63d) | 2014-07-31 → 2014-10-01 (+62d) |  |  | 168d → 125d |  |  |

| ID | Task | Start | Finish | Duration | Complete | Total float | Predecessors | Other |
| --- | --- | --- | --- | --- | --- | --- | --- | --- |
| 242241425 | Quality control of the final mirror assembly - Lab | 2014-08-14 → 2014-10-02 (+49d) | 2014-10-15 → 2014-12-04 (+50d) |  |  | 159d → 125d |  | resources PD UNIV STAFF [352 h]; SCIENTIST [352 h]; MECH TECH [352 h] → MECH TECH [352 h]; PD UNIV STAFF [352 h]; SCIENTIST [352 h] |
| 242241590 | Installation of 48 housing units - Lab | 2014-10-06 → 2014-12-08 (+63d) | 2014-12-05 → 2015-02-17 (+74d) |  |  | 157d → 114d |  |  |
| 242241595 | Quality control of the housing unit assembly and installation - Lab | 2014-10-06 → 2014-12-08 (+63d) | 2014-12-05 → 2015-02-17 (+74d) |  |  | 157d → 114d |  |  |
| 242241647d5 | Quality control of the installed items | 2014-11-06 → 2015-01-21 (+76d) | 2015-04-17 → 2015-06-19 (+63d) |  |  | 157d → 114d |  |  |
| 242241647d | Installation of LMS | 2014-12-04 → 2015-02-16 (+74d) | 2015-02-16 → 2015-04-16 (+59d) |  |  | 157d → 114d |  |  |
| 242241640 | Installation ofthe ellipsoidal mirror - Lab | 2015-01-20 → 2015-03-09 (+48d) | 2015-03-16 → 2015-05-01 (+46d) |  |  | 159d → 125d |  |  |
| 242241645 | Optical tests of mirror geometry in situ - Lab | 2015-03-18 → 2015-05-05 (+48d) | 2015-04-15 → 2015-06-04 (+50d) |  |  | 159d → 125d |  |  |
| 242241650M | HTCC Ready for Installation in the Hall | 2015-04-17 → 2015-06-19 (+63d) | 2015-04-17 → 2015-06-19 (+63d) |  |  | 157d → 114d |  |  |
| 2 | **1.4.2.2.4.2 LOW THRESHOLD CC** |  | 2015-02-10 → 2015-04-24 (+73d) |  |  |  |  |  |
| 142242120 | Build Scale Model of Box | 2011-11-01 A | 2012-03-05 → 2012-02-13 A (-21d) | 80d → 66d | 0% → 100% | 126d → none |  |  |
| 142242005 | Procure Shelving/Desk/Oscilliscope and Computers for LTCC | 2012-01-12 → 2012-01-03 A (-9d) | 2012-03-05 → 2012-06-11 A (+98d) | 36d → 111d | 0% → 100% | 380d → none | 12222080, 142242000M → 142242000M FS-40d |  |
| 142242125 | Gas Window Test on Scale Model | 2012-03-12 → 2012-01-09 A (-63d) | 2012-05-11 → 2012-07-16 A (+66d) | 45d → 132d | 0% → 100% | 345d → none | 142242120 FS+4d → 142242120 FS-25d |  |
| 142242035 | Final Manufacturing Drawings of Alignment Tool | 2012-01-18 A | 2012-04-16 → 2013-08-30 A (+501d) | 63d → 279d | 0% → 100% | 99d → none |  | resources VISTNG USERS [36 h]; SCIENTIST [36 h]; MECH DES [48 h] → SCIENTIST [36 h]; MECH DES [48 h]; VISTNG USERS [36 h] |
| 142242130 | Gas Window Simulation | 2012-01-20 → 2012-01-18 A (-2d) | 2012-05-18 → 2013-06-17 A (+395d) | 85d → 300d | 0% → 100% | 236d → none | 9-120M FS+70d, 142242120 FS-31d → 142242120 FS-31d |  |
| 142242140 | Box Walls Simulation | 2012-01-20 → 2012-01-18 A (-2d) | 2012-05-18 → 2013-08-15 A (+454d) | 85d → 300d | 0% → 100% | 126d → none | 9-120M FS+70d, 142242120 FS-31d → 142242120 FS-31d |  |
| 142242030 | Quality Control of PMTs | 2012-04-12 → 2012-02-01 A (-71d) | 2012-06-05 → 2012-02-14 A (-112d) | 37d → 9d | 0% → 100% | 330d → none |  |  |
| 142242135 | Gas Window Design FY12 | 2012-06-18 → 2012-02-01 A (-138d) | 2012-09-28 → 2013-08-30 A (+336d) | 74d → 290d | 0% → 100% | 236d → none | 142242130 FS+18d → 142242130 FS-100d |  |
| 142242135a | Gas Window Design FY13 | 2012-10-01 → 2012-02-01 A (-243d) | 2012-10-16 → 2013-08-15 A (+303d) | 12d → 290d | 0% → 100% | 236d → none | 142242135 → 142242135 FS-80d |  |
| 142242000M | Space Ready | 2012-01-12 → 2012-03-02 A (+50d) | 2012-01-12 → 2012-03-02 A (+50d) |  | 0% → 100% | 330d → none | 9-120M FS+65d → 9-120M FS+120d |  |
| 142242060 | Alignment Tool and Lasers Quality Control | 2013-02-14 → 2012-03-12 A (-339d) | 2013-03-19 → 2013-08-30 A (+164d) | 23d → 254d | 0% → 100% | 136d → none | 142242055 FS+4d → 142242055 FS-300d |  |
| 142242010 | Prepare electronics for new space | 2012-03-06 → 2012-05-01 A (+56d) | 2012-03-23 → 2012-09-12 A (+173d) | 14d → 94d | 0% → 100% | 380d → none | 142242005, 142242000M → 142242005 FS-60d, 142242000M |  |
| 142242015 | Transport PMTs to new space | 2012-01-12 → 2012-05-01 A (+110d) | 2012-02-13 → 2012-05-18 A (+95d) | 22d → 14d | 0% → 100% | 330d → none |  |  |
| 142242045 | Procurement Lasers | 2012-10-01 → 2012-05-01 A (-153d) | 2013-01-30 → 2013-08-30 A (+212d) | 79d → 185d | 0% → 100% | 20d → none | 142242040 FS+2d, 9-130M → 142242040 FS-70d |  |
| 142242040 | Procurement Prep of Lasers | 2012-05-07 → 2012-05-09 A (+2d) | 2012-06-06 → 2012-05-14 A (-23d) | 21d → 4d | 0% → 100% | 99d → none | 142242035 FS+14d → 142242035 FS-80d |  |
| 142242020 | Transport HV Electronics from Hall B to new space | 2012-02-06 → 2012-07-02 A (+147d) | 2012-03-07 → 2012-09-12 A (+189d) | 22d → 52d | 0% → 100% | 330d → none | 142242015 FS-6d → 142242015 FS+50d |  |
| 142242025 | Installation of Electronics, Black Box for PMTS Quality Control | 2012-03-08 → 2012-07-02 A (+116d) | 2012-04-11 → 2013-08-30 A (+506d) | 25d → 144d | 0% → 100% | 330d → none | 142242020 → 142242020 FS-10d |  |
| 142242180 | Gas Line Design FY12 | 2012-09-04 → 2012-07-02 A (-64d) | 2012-09-28 → 2013-08-30 A (+336d) | 19d → 131d | 0% → 100% | 54d → none | 142242070 FS+43d → 142242070 FS-70d | resources MECH DES [35.35 h]; SCIENTIST [8.84 h]; VISTNG USERS [8.84 h] → SCIENTIST [8.84 h]; VISTNG USERS [8.84 h]; MECH DES [35.35 h] |
| 142242180a | Gas Line Design FY13 | 2012-10-01 → 2012-07-02 A (-91d) | 2013-01-11 → 2013-08-30 A (+231d) | 67d → 131d | 0% → 100% | 54d → none | 142242180 → 142242180 FS-100d |  |
| 142242185 | Procure Gas Line | 2013-01-22 → 2012-07-02 A (-204d) | 2013-05-31 → 2013-08-30 A (+91d) | 92d → 228d | 0% → 100% | 54d → none | 142242180a FS+5d → 142242180a FS-120d |  |
| 142242210 | Transport of FADC, DAQ, Computer, Electronics for 1 Sector | 2012-11-05 → 2012-07-02 A (-126d) | 2013-01-04 → 2013-08-30 A (+238d) | 37d → 126d | 0% → 100% | 139d → none | 9-130M FS+25d → 9-130M FS-60d |  |
| 142242065M | Space Ready For LTCC Refurb | 2012-06-01 → 2012-08-01 A (+61d) | 2012-06-01 → 2012-08-01 A (+61d) |  | 0% → 100% | 54d → none |  |  |
| 142242070 | Transport 6 CC Sectors to Work Space | 2012-06-01 → 2012-08-06 A (+66d) | 2012-07-03 → 2012-09-17 A (+76d) | 22d → 30d | 0% → 100% | 54d → none |  |  |
| 142242075 | Transport Aligment Frame Support to Work Space | 2012-07-09 → 2012-08-13 A (+35d) | 2012-08-08 → 2013-08-30 A (+387d) | 23d → 134d | 0% → 100% | 178d → none | 142242070 FS+3d → 142242070 FS-25d |  |
| 142242170 | Procure PMTs | 2012-10-01 → 2012-08-13 A (-49d) | 2013-06-11 → 2013-01-02 A (-160d) | 171d → 205d | 0% → 100% | 53d → none | 9-130M → 9-130M FS-20d | resources PROCUREMENT<$50K 60; PROCUREMENT>$50K 69; SCIENTIST [40 h]; VISTNG USERS [40 h] → SCIENTIST [40 h]; VISTNG USERS [40 h]; PROCUREMENT<$50K 60; PROCUREMENT>$50K 69 |
| 142242085 | Quality Control of Elliptical/Hyperbolic mirrors | 2012-07-09 → 2012-09-10 A (+63d) | 2012-08-07 → 2013-08-30 A (+388d) | 22d → 179d | 0% → 100% | 99d → none | 142242070 FS+3d → 142242070 |  |
| 142242090 | Dimensions check of Elliptical/Hyperbolic mirrors | 2012-08-01 → 2012-09-10 A (+40d) | 2012-09-05 → 2013-08-30 A (+359d) | 25d → 86d | 0% → 100% | 99d → none | 142242085 FS-5d, 142242070 FS+20d → 142242070, 142242085 FS-125d |  |
| 142242105 | Al/Mg Deposit Procurement Prep | 2013-05-10 → 2012-10-01 A (-221d) | 2013-07-11 → 2012-10-15 A (-269d) | 43d → 11d | 0% → 100% | 20d → none |  |  |
| 142242095 | Create Manufacturing Drawings | 2013-01-03 → 2012-11-12 A (-52d) | 2013-04-04 → 2013-08-30 A (+148d) | 64d → 94d | 0% → 100% | 42d → none | 9-130M FS+60d, 142242090 FS+7d → 9-130M, 142242090 FS-125d |  |
| 142242145 | Complete Design Box Walls FY12 | 2012-06-11 → 2012-12-03 A (+175d) | 2012-09-28 → 2013-08-30 A (+336d) |  | 0% → 100% | 126d → none | 142242140 FS+13d → 142242140 FS-75d |  |
| 142242145a | Complete Design Box Walls FY13 | 2012-10-01 → 2012-12-03 A (+63d) | 2012-10-08 → 2013-08-30 A (+326d) |  | 0% → 100% | 126d → none | 142242145 → 142242145 FS-80d | resources VISTNG USERS [1.91 h]; MECH DES [7.48 h]; SCIENTIST [1.91 h] → SCIENTIST [1.91 h]; VISTNG USERS [1.91 h]; MECH DES [7.48 h] |
| 142242215 | Installation of FADC, DAQ, Computer, Electronics for 1 Sector | 2013-01-23 → 2013-02-01 A (+9d) | 2013-03-14 → 2013-08-30 A (+169d) |  | 0% → 100% | 139d → none | 142242210 FS+11d → 142242210 FS-50d |  |
| 142242100 | Removal of mirrors | 2013-01-03 → 2013-03-04 A (+60d) | 2013-04-30 → 2013-07-15 A (+76d) | 82d → 56d | 0% → 100% | 20d → none | 9-130M FS+60d, 142242090 FS-2d → 9-130M FS+60d, 142242090 FS-122d | resources VISTNG USERS [20 h]; MECH TECH [40 h]; SCIENTIST [20 h] → MECH TECH [40 h]; SCIENTIST [20 h]; VISTNG USERS [20 h] |
| 142242150 | PMTs Removal | 2013-03-04 A | 2013-06-19 → 2013-07-15 A (+26d) |  | 0% → 100% | 41d → none | 142242145a FS+9d, 9-130M FS+100d → 142242145a FS-15d |  |
| 142242175 | PMTs Quality Control | 2013-02-26 → 2013-03-04 A (+6d) | 2013-07-16 → 2013-08-30 A (+45d) |  | 0% → 100% | 53d → none |  |  |
| 142242080 | Installation and Aligment of Lasers, Tools and Frame Support | 2012-08-13 → 2013-05-06 A (+266d) | 2012-09-12 → 2013-08-30 A (+352d) | 22d → 59d | 0% → 100% | 178d → none | 142242075 FS+2d → 142242075 FS-20d |  |
| 142242050 | Alignment Tool Manufacturing | 2012-06-25 → 2013-08-30 A (+431d) | 2012-09-28 → 2013-08-30 A (+336d) | 69d → 53d | 0% → 100% | 99d → none | 142242040 FS+12d, 142242035 FS+47d → 142242040 FS+12d, 142242035 FS-27d |  |
| 142242055 | Alignment Tool and Lasers Installation | 2013-01-16 → 2013-08-30 A (+226d) | 2013-02-07 → 2013-08-30 A (+204d) |  | 0% → 100% | 20d → none |  | resources MECH TECH [20 h]; SCIENTIST [20 h] → SCIENTIST [20 h]; MECH TECH [20 h] |
| 142242110 | Al/Mg Deposit Procurement | 2013-07-26 → 2013-08-30 A (+35d) | 2013-08-30 A | 26d → 101d | 0% → 100% | 20d → none |  | resources PROCUREMENT>$50K 69 NO ESCALATION FY14; MECH TECH [10.3 h]; PROCUREMENT<$50K 60 NO ESCALATION FY14 → MECH TECH [10.3 h]; PROCUREMENT<$50K 60 NO ESCALATION FY14; PROCUREMENT>$50K 69 NO ESCALATION FY14 |
| 142242155 | Walls Manufacturing and Installation | 2013-04-11 → 2013-08-30 A (+141d) | 2013-08-01 → 2013-08-30 A (+29d) |  | 0% → 100% | 41d → none |  |  |
| 142242165 | Procure Cables FY12 | 2012-06-11 → 2013-08-30 A (+445d) | 2012-09-28 → 2013-08-30 A (+336d) | 79d → 93d | 0% → 100% | 190d → none | 9-120M FS+168d → 9-130M FS+165d, 9-120M FS+205d |  |
| 142242165a | Procure Cables FY13 | 2012-10-01 → 2013-08-30 A (+333d) | 2012-12-21 → 2013-08-30 A (+252d) | 58d → 35d | 0% → 100% | 190d → none | 142242165 → 142242165 FS-95d, 9-130M FS+165d |  |
| 142242165b | Procure Cables Procurement | 2012-06-11 → 2013-08-30 A (+445d) | 2012-12-21 → 2013-08-30 A (+252d) |  | 0% → 100% | 190d → none | 9-120M FS+168d → 9-130M FS+165d, 9-120M FS+205d |  |
| 142242190 | Install Gas Line | 2013-05-20 → 2013-08-30 A (+102d) | 2013-06-10 → 2013-08-30 A (+81d) |  | 0% → 100% | 54d → none |  |  |
| 142242195 | Gas Line Quality Control | 2013-06-24 → 2013-08-30 A (+67d) | 2013-07-15 → 2013-08-30 A (+46d) |  | 0% → 100% | 54d → none |  |  |
| 142242200 | Elliptical Mirror Tool/Frame Alignment | 2013-05-07 → 2013-08-30 A (+115d) | 2013-06-06 → 2013-08-30 A (+85d) |  | 0% → 100% | 20d → none |  |  |
| 142242205 | Mirrors Laser Alignments | 2013-06-12 → 2013-08-30 A (+79d) | 2013-08-30 A | 57d → 102d | 0% → 100% | 20d → none | 142242200 FS+3d → 142242200 |  |
| 142242220 | Online Calibration Design FY12 | 2012-06-11 → 2013-08-30 A (+445d) | 2012-09-28 → 2013-08-30 A (+336d) | 79d → 58d | 0% → 100% | 20d → none |  |  |
| 142242220a | Online Calibration Design FY13 | 2012-10-01 → 2013-08-30 A (+333d) | 2013-04-05 → 2013-08-30 A (+147d) | 125d → 105d | 0% → 100% | 20d → none |  |  |
| 142242225 | Online Calibration Test | 2013-05-20 → 2013-08-30 A (+102d) | 2013-08-30 A | 73d → 84d | 0% → 100% | 20d → none |  |  |
| 142242245 | Re-Baseline Actuals Adjustment | 2013-08-30 A | 2013-08-30 A |  | 0% → 100% | 20d → none | 9-130M FS+227d → none |  |
| 242242036 | Wavelength Shifting tests Labor/Expenses FY13 | 2013-09-03 A | 2013-09-30 → 2013-11-15 (+46d) |  | 0% → 50% | 252d → 229d |  |  |
| 242242036a | Wavelength Shifting tests Labor/Expenses FY14 | 2013-10-01 → 2013-09-03 A (-28d) | 2013-10-15 → 2013-11-15 (+31d) |  | 0% → 50% | 252d → 229d | 9-130M FS+228d, 242242036 → 242242036 FS-20d |  |
| 242242310 | PMTS, Mirrors Holes Drill | 2013-10-08 → 2013-09-03 A (-35d) |  |  | 0% → 50% | 249d → 232d | 242242305 FS-200d → 242242305 FS-260d |  |
| 242242031 | Quality Control of Existing PMTs FY13 | 2013-09-10 → 2013-10-01 A (+21d) | 2013-09-30 → 2014-06-10 (+253d) |  | 0% → 5% | 248d → 231d |  |  |
| 242242031a | Quality Control of Existing PMTs FY14 | 2013-10-01 A |  |  | 0% → 5% | 248d → 231d | 9-130M FS+233d, 242242031 → 242242031 FS-146d |  |
| 242242045 | Procurement Lasers - Procurement | 2013-09-03 → 2013-10-01 A (+28d) | 2014-01-28 → 2013-10-21 A (-99d) |  | 0% → 100% | 216d → none | 9-130M FS+228d → 9-130M FS+228d, 9-140M FS+33d |  |
| 242242045a | Procurement Lasers - Labor FY13 | 2013-09-03 → 2013-10-01 A (+28d) | 2013-09-30 → 2013-10-21 A (+21d) |  | 0% → 100% | 216d → none | 9-130M FS+228d → 9-140M FS+33d |  |
| 242242045b | Procurement Lasers - Labor FY14 | 2013-10-01 A | 2014-01-28 → 2013-10-21 A (-99d) |  | 0% → 100% | 216d → none | 9-130M FS+228d, 242242045a → 242242045a |  |
| 242242095 | Create Manufacturing Drawings FY13 | 2013-09-03 → 2013-10-01 A (+28d) | 2013-09-30 → 2013-12-12 (+73d) |  | 0% → 50% | 249d → 243d | 9-130M FS+228d → 9-130M FS+228d, 9-140M FS+23d |  |
| 242242095a | Create Manufacturing Drawings FY14 | 2013-10-01 A | 2013-10-10 → 2013-12-12 (+63d) |  | 0% → 50% | 249d → 243d | 242242095, 9-130M FS+228d → 242242095 FS-30d |  |

| ID | Task | Start | Finish | Duration | Complete | Total float | Predecessors |
| --- | --- | --- | --- | --- | --- | --- | --- |
| 242242105 | Al/Mg Deposit Procurement Prep FY13 | 2013-09-03 → 2013-10-01 A (+28d) | 2013-09-30 → 2014-01-03 (+95d) |  | 0% → 50% | 220d → 167d | 9-130M FS+228d → 9-130M FS+228d, 9-140M |
| 242242105a | Al/Mg Deposit Procurement Prep FY14 | 2013-10-01 A | 2013-10-08 → 2014-01-03 (+87d) |  | 0% → 50% | 220d → 190d | 242242105, 9-130M FS+228d → 242242105 FS-36d |
| 242242145a | Complete Design Box Walls FY13 | 2013-09-03 → 2013-10-01 A (+28d) | 2013-09-30 → 2014-01-03 (+95d) |  | 0% → 50% | 467d → 424d | 9-130M FS+228d → 9-130M FS+228d, 9-140M FS+23d |
| 242242145aa | Complete Design Box Walls FY14 | 2013-10-01 A | 2013-10-22 → 2014-01-03 (+73d) |  | 0% → 50% | 467d → 424d | 242242145a, 9-130M FS+228d → 242242145a FS-36d |
| 242242220a | Online Calibration Design FY13 | 2013-09-03 → 2013-10-01 A (+28d) | 2013-09-30 → 2014-06-27 (+270d) |  |  |  | 9-130M FS+228d → 9-140M FS+23d, 9-130M FS+228d |
| 242242220aa | Online Calibration Design FY14 | 2013-10-01 A |  |  |  |  | 242242220a, 9-130M FS+228d → 242242220a FS-159d |
| 242242222 | Online HV Matching Design FY13 | 2013-09-03 → 2013-10-01 A (+28d) | 2013-09-30 → 2014-06-27 (+270d) |  |  |  |  |
| 242242222a | Online HV Matching Design FY14 | 2013-10-01 A |  |  |  |  | 242242220aa FS-202d, 242242222, 242242220a FS-202d → 242242220aa FS-202d, 242242222 FS-159d |
| 242242245 | Simulation of Sagging Test | 2013-10-01 A |  |  | 0% → 50% |  |  |
| 242242290 | Cut Line Mark | 2013-09-03 → 2013-10-01 A (+28d) | 2013-09-30 → 2014-01-06 (+98d) | 20d → 37d | 0% → 50% | 382d → 349d | 9-130M FS+228d → 9-130M FS+228d, 9-140M |
| 242242161 | HV Cables Catalog and Tagging | 2013-11-12 → 2013-10-12 A (-31d) |  |  | 0% → 50% |  | 9-140M FS+30d → 9-140M |
| 242242030 | Quality Control of PMTs | 2013-10-10 → 2013-11-01 (+22d) | 2014-06-10 → 2014-07-02 (+22d) |  |  | 347d → 331d |  |
| 242242085 | Quality Control of Elliptical/Hyperbolic mirrors | 2013-10-31 → 2013-11-01 (+1d) | 2014-07-24 → 2014-07-25 (+1d) |  |  | 348d → 347d |  |
| 242242325 | Spine Refusrbish FY13 | 2013-09-03 → 2013-11-01 (+59d) | 2013-09-30 → 2013-12-02 (+63d) |  |  | 255d → 212d | 242242320 FS-289d, 242242315 FS-289d → 242242320 FS-265d, 242242315 FS-265d |
| 242242340 | Sector 2 Box Refurbish | 2013-10-30 → 2013-11-01 (+2d) | 2013-12-10 → 2013-12-12 (+2d) |  |  | 185d → 183d |  |
| 242242162 | Divider Modifications Design and Test |  |  |  |  |  | 9-130M FS+228d, 9-140M FS+30d → 9-140M FS+30d |
| 242242295 | Wall Cut-Off FY13 | 2013-09-30 → 2013-11-14 (+45d) | 2013-09-30 → 2013-11-14 (+45d) |  |  | 382d → 349d | 242242290 FS-1d → 242242290 FS-28d |
| 242242050 | Alignment Tool Manufacturing Labor/Expenses FY13 | 2013-09-20 → 2013-11-15 (+56d) | 2013-09-30 → 2013-11-25 (+56d) |  |  | 217d → 177d | 9-130M FS+241d → 9-140M FS+33d, 9-130M FS+241d |
| 242242107 | Al/Mg Laxon/Acrylic Re-Coating Test Procurement Labor FY13 | 2013-09-10 → 2013-11-15 (+66d) | 2013-09-30 → 2013-12-09 (+70d) |  |  | 236d → 193d | 9-130M FS+233d → 9-140M FS+33d, 9-130M FS+233d |
| 242242152 | Window Procurement | 2013-09-03 → 2013-11-15 (+73d) | 2014-03-31 → 2014-06-13 (+74d) |  |  | 185d → 132d | 9-130M FS+228d → 9-130M FS+228d, 9-140M FS+33d |
| 242242152a | Window Procurement - Labor FY13 | 2013-09-03 → 2013-11-15 (+73d) | 2013-09-30 → 2013-12-16 (+77d) |  |  | 185d → 132d | 9-130M FS+228d → 9-140M FS+33d |
| 242242295a | Wall Cut-Off FY14 | 2013-10-01 → 2013-11-15 (+45d) | 2014-04-21 → 2014-06-06 (+46d) |  |  | 382d → 349d | 242242295, 242242290 FS-1d → 242242295 |
| 242242050a | Alignment Tool Manufacturing Labor/Expenses FY14 | 2013-10-01 → 2013-11-26 (+56d) | 2013-12-13 → 2014-02-20 (+69d) |  |  | 217d → 177d | 242242050, 9-130M FS+241d → 242242050 |
| 242242280 | Frame Support FY13 | 2013-09-18 → 2013-12-02 (+75d) | 2013-09-30 → 2013-12-12 (+73d) |  |  | 470d → 419d | 9-130M FS+239d → 9-140M FS+42d, 9-130M FS+239d |
| 242242325a | Spine Refusrbish FY14 | 2013-10-01 → 2013-12-03 (+63d) | 2014-10-20 → 2014-12-22 (+63d) |  |  | 255d → 212d | 242242325, 242242320 FS-289d, 242242315 FS-289d → 242242325 |
| 242242107a | Al/Mg Laxon/Acrylic Re-Coating Test Procurement Labor FY14 | 2013-10-01 → 2013-12-10 (+70d) | 2013-11-11 → 2014-01-31 (+81d) |  |  | 236d → 193d | 9-130M FS+233d, 242242107 → 242242107 |
| 242242280a | Frame Support FY14 | 2013-10-01 → 2013-12-13 (+73d) | 2013-12-05 → 2014-02-27 (+84d) |  |  | 470d → 419d | 9-130M FS+239d, 242242280 → 242242280 |
| 242242152b | Window Procurement -Labor FY14 | 2013-10-01 → 2013-12-17 (+77d) | 2014-03-31 → 2014-06-13 (+74d) |  |  | 185d → 132d | 9-130M FS+228d, 242242152a → 242242152a |
| 242242155 | Walls Manufacturing and Installation | 2013-10-15 → 2013-12-17 (+63d) | 2013-12-10 → 2014-02-20 (+72d) |  |  | 467d → 424d |  |
| 242242076 | Support Frame Fabrication for 1S in TED | 2014-01-07 → 2014-01-03 (-4d) | 2014-04-02 → 2014-03-31 (-2d) |  |  | 395d → 397d |  |
| 242242077 | Infrastructure Consumables | 2014-01-07 → 2014-01-03 (-4d) | 2014-08-25 → 2014-08-21 (-4d) |  |  | 294d → 296d |  |
| 242242090 | Dimensions check of Elliptical/Hyperbolic mirrors | 2014-01-07 → 2014-01-03 (-4d) | 2014-10-01 → 2014-09-29 (-2d) |  |  | 268d → 270d |  |
| 242242055 | Alignment Tool and Lasers Installation | 2013-11-01 → 2014-01-09 (+69d) | 2014-03-18 → 2014-05-12 (+55d) |  |  | 216d → 177d | 242242050a FS-30d, 242242045 FS-52d, 242242050 FS-30d, 242242045a FS-52d, 242242045b FS-52d → 242242045b FS-52d, 242242045 FS-52d, 242242050a FS-30d, 242242050 FS-30d |
| 242242300 | Rear Brace Manufacture | 2013-11-04 → 2014-01-16 (+73d) | 2014-02-28 → 2014-04-30 (+61d) |  |  | 249d → 267d |  |
| 242242320 | Nose Extension Installation | 2014-01-21 → 2014-01-16 (-5d) | 2014-10-30 → 2014-10-28 (-2d) |  |  | 255d → 233d |  |
| 242242365 | Sector 3 Box Refurbish | 2014-01-21 → 2014-01-23 (+2d) | 2014-02-18 → 2014-02-20 (+2d) |  |  | 293d → 291d |  |
| 242242108 | Lexan/Acrylic/Over- Coating Procurement (all sectors) | 2013-11-11 → 2014-01-31 (+81d) | 2014-10-31 → 2015-01-22 (+83d) |  |  | 246d → 198d |  |
| 242242092 | Al/Mg Deposit Procurement WC | 2013-11-19 → 2014-02-03 (+76d) | 2014-11-14 → 2015-01-29 (+76d) |  |  | 236d → 193d | 242242107a FS+5d, 242242107 FS+5d → 242242107 FS-13d, 242242107a |
| 242242110 | Al/Mg Deposit Procurement | 2013-11-11 → 2014-02-07 (+88d) | 2014-11-26 → 2015-02-24 (+90d) |  |  | 220d → 167d | 242242105 FS+23d, 242242105a FS+23d → 242242105 FS+23d, 242242105a |
| 242242040 | Wavelength Shifting Procurement | 2014-01-08 → 2014-02-11 (+34d) | 2014-10-23 → 2014-11-25 (+33d) |  |  | 252d → 229d |  |
| 242242390 | Sector 4 Box Refurbish | 2014-03-03 → 2014-03-05 (+2d) | 2014-04-08 → 2014-04-10 (+2d) |  |  | 301d → 299d |  |
| 242242305 | Rear Brace Installation | 2014-01-17 → 2014-03-20 (+62d) | 2014-07-31 → 2014-10-01 (+62d) |  |  | 249d → 267d |  |
| 242242205 | Mirrors Laser Alignments | 2014-02-03 → 2014-03-28 (+53d) | 2014-12-16 → 2015-02-20 (+66d) |  |  | 216d → 177d |  |
| 242242115 | Installation of Elliptical mirrors | 2014-01-21 → 2014-04-04 (+73d) | 2014-12-10 → 2015-03-06 (+86d) |  |  | 220d → 167d |  |
| 242242415 | Sector 5 Box Refurbish | 2014-04-14 → 2014-04-16 (+2d) | 2014-05-13 → 2014-05-15 (+2d) |  |  | 302d → 300d |  |
| 242242350 | Sector 2 Mirrors Alignment | 2014-04-15 → 2014-04-17 (+2d) | 2014-06-24 → 2014-06-26 (+2d) |  |  | 185d → 183d |  |
| 242242330 | Gas Line Refurbish | 2014-02-27 → 2014-04-29 (+61d) | 2014-10-20 → 2014-12-22 (+63d) |  |  | 255d → 212d |  |
| 242242235 | Windows Installation 6 sectors | 2014-03-04 → 2014-05-16 (+73d) | 2014-12-10 → 2015-03-06 (+86d) |  |  | 185d → 132d | 242242152 FS-20d, 242242230 FS-252d, 242242152b FS-20d, 242242152a FS-20d → 242242230 FS-252d, 242242152b FS-20d, 242242152 FS-20d |
| 242242440 | Sector 6 Box Refurbish | 2014-05-27 → 2014-05-29 (+2d) | 2014-06-17 → 2014-06-19 (+2d) |  |  | 300d → 298d |  |
| 242242355 | Sector 2 Windows Installation | 2014-06-30 → 2014-07-02 (+2d) | 2014-07-15 → 2014-07-17 (+2d) |  |  | 185d → 183d |  |
| 242242375 | Sector 3 Mirrors Alignment | 2014-07-22 → 2014-07-24 (+2d) | 2014-08-26 → 2014-08-28 (+2d) |  |  | 185d → 183d |  |
| 242242360 | Sector 2 Gas Leaks Checks | 2014-08-04 → 2014-08-06 (+2d) | 2014-09-09 → 2014-09-11 (+2d) |  |  | 293d → 291d |  |
| 242242240 | Gas Leak Check 6 sectors | 2014-05-23 → 2014-08-08 (+77d) | 2015-02-10 → 2015-04-24 (+73d) |  |  | 185d → 132d |  |
| 242242380 | Sector 3 Windows Installation | 2014-08-27 → 2014-08-29 (+2d) | 2014-09-16 → 2014-09-18 (+2d) |  |  | 185d → 183d |  |
| 242242400 | Sector 4 Mirrors Alignment | 2014-09-23 → 2014-09-25 (+2d) | 2014-10-28 → 2014-10-30 (+2d) |  |  | 185d → 183d |  |
| 242242385 | Sector 3 Gas Leaks Checks | 2014-09-30 → 2014-10-02 (+2d) | 2014-10-29 → 2014-10-31 (+2d) |  |  | 301d → 299d |  |
| 242242405 | Sector 4 Windows Installation | 2014-10-29 → 2014-10-31 (+2d) | 2014-11-18 → 2014-11-20 (+2d) |  |  | 302d → 300d |  |
| 242242425 | Sector 5 Mirrors Alignment | 2014-10-29 → 2014-10-31 (+2d) | 2014-11-11 → 2014-11-13 (+2d) |  |  | 185d → 183d |  |
| 242242410 | Sector 4 Gas Leaks Checks | 2014-11-26 → 2014-12-02 (+6d) | 2014-12-16 → 2014-12-18 (+2d) |  |  | 302d → 300d |  |
| 242242430 | Sector 5 Windows Installation | 2014-11-26 → 2014-12-02 (+6d) | 2014-12-16 → 2014-12-18 (+2d) |  |  | 300d → 298d |  |
| 242242450 | Sector 6 Mirrors Alignment | 2014-11-26 → 2014-12-02 (+6d) | 2014-12-16 → 2014-12-18 (+2d) |  |  | 185d → 183d |  |
| 242242435 | Sector 5 Gas Leaks Checks | 2014-12-17 → 2014-12-19 (+2d) | 2015-01-20 → 2015-01-22 (+2d) |  |  | 300d → 298d |  |
| 242242455 | Sector 6 Windows Installation | 2014-12-17 → 2014-12-19 (+2d) | 2015-01-20 → 2015-01-22 (+2d) |  |  | 185d → 183d |  |
| 242242460 | Sector 6 Gas Leaks Checks | 2015-01-20 → 2015-01-22 (+2d) | 2015-02-10 → 2015-02-12 (+2d) |  |  | 185d → 183d |  |
| 242242500M | LTCC Complete | 2015-02-10 → 2015-04-24 (+73d) | 2015-02-10 → 2015-04-24 (+73d) |  |  | 185d → 132d | 242242036, 242242215, 242242335, 242242340, 242242460, 242242031, 242242161, 242242280, 242242330, 242242165b, 242242225, 242242169, 242242170, 242242295, 242242195, 242242107a, 242242295a, 242242077, 242242240, 242242030, 242242155, 242242205, 242242095a, 242242280a, 242242040, 242242270, 242242076, 242242090, 242242092, 242242095, 242242115, 242242036a, 242242164, 242242137, 242242107, 242242108, 242242031a → 242242335, 242242076, 242242077, 242242090, 242242169, 242242280, 242242225, 242242092, 242242165b, 242242295a, 242242036, 242242040, 242242137, 242242280a, 242242460, 242242295, 242242330, 242242036a, 242242340, 242242030, 242242164, 242242108, 242242155, 242242031, 242242161, 242242170, 242242107, 242242115, 242242031a, 242242195, 242242215, 242242240, 242242270, 242242095, 242242205 |
| 3 | **1.4.2.3 COMPUTING** | 2010-10-01 → 2011-04-01 (+182d) |  |  |  |  |  |
| 1 | **1.4.2.3.1 TRIGGER SYSTEM (Scintillators)** | 2011-12-01 → 2011-11-01 (-30d) |  |  |  |  |  |
| 14231055 | SD procurement prep | 2012-04-02 → 2011-11-01 A (-153d) | 2012-04-09 A | 6d → 105d | 0% → 100% | 20d → none | 9-120M FS+120d → 9-120M |
| 14231015 | SSP single board tests | 2011-12-01 → 2011-12-03 A (+2d) | 2011-12-30 → 2011-12-19 A (-11d) | 17d → 11d | 0% → 100% | 183d → none |  |
| 14231035 | GTP single board tests | 2011-12-01 → 2011-12-03 A (+2d) | 2011-12-30 → 2013-08-30 A (+609d) | 17d → 266d | 0% → 100% | 209d → none |  |

| ID | Task | Start | Finish | Duration | Complete | Total float | Predecessors | Other |
| --- | --- | --- | --- | --- | --- | --- | --- | --- |
| 14231070 | TI procurement prep | 2012-05-01 → 2011-12-12 A (-141d) | 2012-05-08 → 2012-05-14 A (+6d) | 6d → 103d | 0% → 100% | 20d → none | 9-120M FS+141d → 9-120M |  |
| 14231085 | TD procurement prep | 2012-06-01 → 2011-12-12 A (-172d) | 2012-06-11 → 2012-04-16 A (-56d) | 6d → 83d | 0% → 100% | 20d → none | 9-120M FS+163d → 9-120M |  |
| 14231075 | TI procurement (52 boards) | 2012-05-09 → 2012-03-12 A (-58d) | 2012-12-31 → 2012-12-17 A (-14d) | 159d → 252d | 0% → 100% | 20d → none | 14231070 → 14231070 FS-50d |  |
| 14231090 | TD procurement (10 boards) | 2012-06-12 → 2012-03-12 A (-92d) | 2012-12-31 → 2012-08-13 A (-140d) | 137d → 109d | 0% → 100% | 20d → none | 14231085 → 14231085 FS-50d |  |
| 14231100 | TS single board tests | 2011-12-01 → 2012-04-16 A (+137d) | 2011-12-30 → 2012-12-17 A (+353d) | 17d → 179d | 0% → 100% | 306d → none | 9-120M FS+41d → 9-120M FS+80d |  |
| 14231065 | SD testing of 24 boards | 2013-01-02 → 2012-04-23 A (-254d) | 2013-08-30 → 2012-10-15 A (-319d) | 169d → 123d | 0% → 100% | 20d → none | 14231060 → 14231060 FS-160d | resources SCIENTIST [54.52 h] → SCIENTIST [80 h] |
| 14231060 | SD procurement (24 boards) | 2012-04-10 → 2012-05-07 A (+27d) | 2012-12-31 → 2012-09-17 A (-105d) | 180d → 93d | 0% → 100% | 20d → none |  |  |
| 14231020 | SSP procurement prep | 2012-02-01 → 2012-06-05 A (+125d) | 2012-02-08 → 2012-06-18 A (+131d) | 6d → 10d | 0% → 100% | 183d → none | 14231015 FS+20d → 14231015 FS+20d, 9-120M FS+210d |  |
| 14231025 | SSP procurement (15 boards) | 2012-10-01 → 2012-06-18 A (-105d) | 2013-04-12 → 2013-01-25 A (-77d) | 130d → 150d | 0% → 100% | 20d → none | 14231020, 9-130M → 14231020 |  |
| 14231005 | CTP Procurement Prep | 2012-01-03 → 2012-07-02 A (+181d) | 2012-01-09 → 2012-12-17 A (+343d) | 5d → 179d | 0% → 100% | 204d → none | 12223040M, 12223045, 9-120M FS+58d → 12223045, 9-120M, 12223040M |  |
| 14231030 | SSP testing of 15 boards | 2013-08-30 → 2013-02-15 A (-196d) | 2013-08-30 A | 1d → 130d | 0% → 100% | 20d → none | 9-130M FS+227d → 14231025, 18223005 FS-175d | was named SSP testing of 15 boards (Future Activity Complete prior to Rebaseline) |
| 14231105 | TS procurement prep | 2013-04-08 → 2013-02-15 A (-52d) | 2013-04-15 → 2013-08-30 A (+137d) |  | 0% → 100% | 117d → none | 9-130M FS+125d, 14231100 FS+125d → 14231100, 9-130M |  |
| 14231095 | TD testing of 10 boards | 2013-08-30 → 2013-03-04 A (-179d) | 2013-08-30 → 2013-03-18 A (-165d) | 1d → 59d | 0% → 100% | 20d → none | 9-130M FS+227d → 14231090, 18223020 | was named TD testing of 10 boards (Future Activity Complete prior to Rebaseline) |
| 14231007 | CTP procurement (22 boards) | 2012-10-01 → 2013-08-30 A (+333d) | 2013-02-28 → 2013-08-30 A (+183d) | 99d → 80d | 0% → 100% | 20d → none | 14231005, 9-130M → 9-130M, 9-120M FS+60d, 9-140M, 14231005 |  |
| 14231040 | GTP procurement prep | 2012-11-28 → 2013-08-30 A (+275d) | 2013-02-08 → 2013-08-30 A (+203d) | 46d → 11d | 0% → 100% | 20d → none | 9-130M FS+40d, 14231035 FS+40d → 9-130M, 14231035 FS-20d |  |
| 14231045 | GTP procurement (2 boards) | 2013-02-11 → 2013-08-30 A (+200d) | 2013-06-21 → 2013-08-30 A (+70d) | 93d → 9d | 0% → 100% | 20d → none | 9-130M, 14231040 → 9-130M, 14231040 FS+10d |  |
| 14231125 | Re-Baseline Actuals Adjustment | 2013-08-30 A | 2013-08-30 A |  | 0% → 100% | 20d → none | 9-130M FS+227d → none |  |
| 24231000 | AVAGO QSFP OPTIC TRANS | 2013-09-03 A | 2013-10-31 → 2013-12-05 (+35d) |  |  | 528d → 505d |  |  |
| 24231045 | GTP procurement (2 boards) | 2013-10-01 → 2013-11-01 (+31d) | 2014-01-31 → 2014-03-05 (+33d) |  |  | 351d → 328d | 9-140M → 9-140M FS+23d |  |
| 14232010 | CLAS12 DAQ/online software updates FY12 | 2012-01-03 A | 2012-09-28 A |  | 0% → 100% | 20d → none |  | resources SCIENTIST [533.47 h]; PD UNIV STUDNT [1066.94 h]; VISTNG USERS [533.47 h] → PD UNIV STUDNT [1066.94 h]; VISTNG USERS [533.47 h]; SCIENTIST [533.47 h] |
| 14232030 | Re-Baseline Actuals Adjustment | 2013-08-30 A | 2013-08-30 A |  | 0% → 100% | 20d → none | 9-130M FS+227d → none |  |
| 3 | **1.4.2.3.3 ONLINE COMPUTING** | 2011-10-03 → 2011-11-01 (+29d) | 2015-07-23 → 2015-07-21 (-2d) |  |  |  |  |  |
| 14233005 | ONLINE COMP-P-#1 Contsruction Setup Historical Contributed Labor | 2011-10-03 → 2011-11-01 A (+29d) | 2011-10-31 → 2011-11-14 A (+14d) | 21d → 10d | 0% → 100% | 474d → none |  |  |
| 14233007 | CLAS12 Online and Monitoring software updates | 2012-01-06 → 2012-01-03 A (-3d) | 2012-09-28 A | 186d → 189d | 0% → 100% | 248d → none |  |  |
| 14233075 | Re-Baseline Actuals Adjustment | 2013-08-30 A | 2013-08-30 A |  | 0% → 100% | 20d → none | 9-130M FS+227d → none |  |
| 24233010 | Ethernet wiring inside Hall B (10Gbit) | 2015-01-07 → 2015-01-05 (-2d) | 2015-04-27 → 2015-04-23 (-4d) |  |  | 166d → 168d |  |  |
| 24233015 | Trigger system fibers wiring | 2015-01-07 → 2015-01-05 (-2d) | 2015-04-27 → 2015-04-23 (-4d) |  |  | 166d → 168d |  |  |
| 24233020 | Procure CISCO 2960S switches (24 Cu ports) (15) | 2015-01-07 → 2015-01-05 (-2d) | 2015-04-27 → 2015-04-23 (-4d) |  |  | 125d → 127d |  |  |
| 24233030 | Procure 4-port 10GBit Blades for BigIron | 2015-01-07 → 2015-01-05 (-2d) | 2015-04-27 → 2015-04-23 (-4d) |  |  | 146d → 148d |  |  |
| 24233040 | Procure Ethernet fibers/Cu wires | 2015-01-07 → 2015-01-05 (-2d) | 2015-04-27 → 2015-04-23 (-4d) |  |  | 125d → 127d |  |  |
| 24233050 | Procure Terminal servers (Etherlite32) (10) | 2015-01-07 → 2015-01-05 (-2d) | 2015-04-27 → 2015-04-23 (-4d) |  |  | 125d → 127d |  |  |
| 24233060 | Procure daq/online computers | 2015-01-07 → 2015-01-05 (-2d) | 2015-05-26 → 2015-05-21 (-5d) |  |  | 106d → 108d |  |  |
| 24233025 | Install CISCO 2960S switches (24 Cu ports) (15) | 2015-04-28 → 2015-04-24 (-4d) | 2015-06-25 → 2015-06-23 (-2d) |  |  | 125d → 127d |  |  |
| 24233035 | Install 4-port 10GBit Blades for BigIron | 2015-04-28 → 2015-04-24 (-4d) | 2015-05-26 → 2015-05-21 (-5d) |  |  | 146d → 148d |  |  |
| 24233045 | Install Ethernet fibers/Cu wires | 2015-04-28 → 2015-04-24 (-4d) | 2015-06-25 → 2015-06-23 (-2d) |  |  | 125d → 127d |  |  |
| 24233055 | Install Terminal servers (Etherlite32) (10) | 2015-04-28 → 2015-04-24 (-4d) | 2015-06-25 → 2015-06-23 (-2d) |  |  | 125d → 127d |  |  |
| 24233065 | Install daq/online computers | 2015-05-27 → 2015-05-22 (-5d) | 2015-07-23 → 2015-07-21 (-2d) |  |  | 106d → 108d |  |  |
| 24233070M | Online computing infrastructure complete | 2015-07-23 → 2015-07-21 (-2d) | 2015-07-23 → 2015-07-21 (-2d) |  |  | 106d → 108d |  |  |
| 4 | **1.4.2.3.4 OFFLINE COMPUTING** | 2011-10-03 → 2011-12-01 (+59d) |  |  |  |  |  |  |
| 14234020LOE | Contributed Labor Effort | 2011-12-01 A | 2013-08-30 A | 434d → 702d | 0% → 100% | 640d → none |  |  |
| 14234005 | OFFLINE COMP- Constrctn Setup (P-#1) Historical | 2011-10-03 → 2011-12-03 A (+61d) | 2011-10-31 → 2011-12-12 A (+42d) | 21d → 6d | 0% → 100% | 1027d → none |  | resources SCIENTIST [13.71 h]; COMP SCIENT [13.71 h]; CONTRB UNIV LBR [287.99 h]; VISTNG USERS [89.14 h] → VISTNG USERS [89.14 h]; SCIENTIST [13.71 h]; CONTRB UNIV LBR [287.99 h]; COMP SCIENT [13.71 h] |
| 14234025 | Re-Baseline Actuals Adjustment | 2013-08-30 A | 2013-08-30 A |  | 0% → 100% | 20d → none | 9-130M FS+227d → none |  |
| 5 | **1.4.2.3.5 SLOW CONTROLS** | 2010-10-01 → 2011-04-01 (+182d) | 2015-03-19 → 2015-03-17 (-2d) |  |  |  |  |  |
| 14235005 | SLOW CNTL- Constrctn Setup (P-#1) | 2010-10-01 → 2011-04-01 A (+182d) | 2011-09-27 → 2013-08-30 A (+703d) | 245d → 438d | 0% → 100% | 573d → none |  |  |
| 14235010 | SLOW CNTL- Constrctn Setup (P-#2) FY11 | 2011-09-28 → 2013-08-30 A (+702d) | 2011-09-30 → 2013-08-30 A (+700d) |  | 0% → 100% | 573d → none |  |  |
| 14235010a | SLOW CNTL- Constrctn Setup (P-#2) FY12 | 2011-10-03 → 2013-08-30 A (+697d) | 2012-09-28 → 2013-08-30 A (+336d) | 247d → 224d | 0% → 100% | 573d → none | 14235005, 14235010 → 14235010 | resources VISTNG USERS [1224.82 h]; SCIENTIST [632.16 h] → SCIENTIST [632.16 h]; VISTNG USERS [1224.82 h] |
| 14235015 | SLOW CNTL- Constrctn Setup (P-#3) | 2012-10-01 → 2013-08-30 A (+333d) | 2013-08-30 A | 228d → 245d | 0% → 100% | 573d → none | 14235010, 14235010a → 14235010a | resources VISTNG USERS [1153.96 h]; PROCUREMENT<$50K 60; SCIENTIST [558.37 h] → VISTNG USERS [1153.96 h]; SCIENTIST [558.37 h]; PROCUREMENT<$50K 60 |
| 14235020 | Re-Baseline Actuals Adjustment | 2013-08-30 A | 2013-08-30 A |  | 0% → 100% | 20d → none | 9-130M FS+227d → none |  |
| 24235005 | SLOW CNTL (EPICS software development) | 2013-10-01 A | 2013-10-28 → 2013-12-20 (+53d) | 20d → 34d | 0% → 50% | 232d → 195d | 9-140M → 9-140M FS+23d |  |
| 24235010a | SLOW CNTL (EPICS device drivers development) | 2014-01-06 → 2014-01-02 (-4d) | 2014-10-01 → 2014-09-29 (-2d) |  |  | 193d → 195d |  |  |
| 24235015 | SLOW CNTL (EPICS software development) | 2014-10-02 → 2014-09-30 (-2d) | 2015-03-19 → 2015-03-17 (-2d) |  |  | 193d → 195d |  |  |
| 4 | **1.4.2.4 ELECTRONICS** | 2010-09-30 → 2010-09-13 (-17d) |  |  |  |  |  |  |
| 1 | **1.4.2.4.1 ADC** | 2011-10-03 → 2011-11-01 (+29d) |  |  |  |  |  |  |
| 14241005 | ADC Prcrmnt prep | 2011-10-03 → 2011-11-01 A (+29d) | 2011-10-28 → 2011-11-21 A (+24d) | 20d → 15d | 0% → 100% | 699d → none |  | was named ADC Prcrmnt |
| 14241010 | FADC-250 (275) procurement | 2012-01-04 → 2012-01-03 A (-1d) | 2012-11-30 → 2012-11-12 A (-18d) | 231d → 220d | 0% → 100% | 681d → none |  |  |
| 14241015 | UMASS - FADC-250 testing (275) | 2012-10-31 → 2012-09-10 A (-51d) | 2013-03-29 → 2013-02-25 A (-32d) | 98d → 135d | 0% → 100% | 681d → none | 12224005, 14241010 FS-21d → 14241010 FS-60d, 12224005 |  |
| 14241020 | Re-Baseline Actuals Adjustment | 2013-08-30 A | 2013-08-30 A |  | 0% → 100% | 20d → none | 9-130M FS+227d → none |  |
| 2 | **1.4.2.4.2 TDC AND DISCRIMINATORS** | 2012-01-04 → 2012-01-03 (-1d) |  |  |  |  |  |  |
| 14242033 | JLab Discriminator First Article and Non-Recurring Engineering | 2012-01-04 → 2012-01-03 A (-1d) | 2012-05-31 → 2012-02-13 A (-108d) | 104d → 29d | 0% → 100% | 641d → none |  |  |
| 14242035 | JLab Discriminator (275) procurement | 2012-01-04 → 2012-01-03 A (-1d) | 2012-08-31 → 2012-12-17 A (+108d) | 169d → 270d | 0% → 100% | 641d → none | 14242033 FS-104d, 9-120M FS+59d → 14242033 FS-104d |  |
| 14242020 | JLab TDC Fanout procurement prep | 2012-10-01 → 2012-07-02 A (-91d) | 2012-10-09 → 2012-07-16 A (-85d) | 7d → 11d | 0% → 100% | 615d → none | 9-130M → 9-120M FS+120d |  |
| 14242050 | ORTEC 935F discr. (25) procurement | 2012-10-10 → 2012-07-02 A (-100d) | 2013-04-09 → 2013-01-25 A (-74d) | 120d → 191d | 0% → 100% | 615d → none | 14242045 → 14242045 FS-45d |  |
| 14242025 | JLab TDC Fanout (25) procurement | 2012-10-10 → 2012-08-01 A (-70d) | 2013-04-09 → 2012-12-17 A (-113d) | 120d → 169d | 0% → 100% | 615d → none |  |  |
| 14242040 | JLab Discriminator (275) test/install | 2013-03-05 → 2012-09-03 A (-183d) | 2013-05-24 → 2013-08-30 A (+98d) | 59d → 179d | 0% → 100% | 641d → none | 14242035 FS+120d → 14242035 FS-60d |  |
| 14242005 | CAEN v1190 TDCs (reuse) (31) installation | 2012-06-01 → 2012-10-01 A (+122d) | 2012-07-31 → 2012-10-15 A (+76d) | 42d → 11d | 0% → 100% | 843d → none |  |  |
| 14242010 | CAEN v1290 TDCs (reuse) (24) installation | 2012-06-01 → 2012-10-01 A (+122d) | 2012-07-31 → 2012-10-15 A (+76d) | 42d → 11d | 0% → 100% | 843d → none |  |  |
| 14242015 | CAEN v1290N TDCs (reuse) (7) installation | 2012-06-01 → 2012-10-01 A (+122d) | 2012-07-31 → 2012-10-15 A (+76d) | 42d → 11d | 0% → 100% | 843d → none |  |  |
| 14242055 | ORTEC 935F discr. (25) test/install | 2013-04-10 → 2013-01-02 A (-98d) | 2013-07-02 → 2013-01-31 A (-152d) |  | 0% → 100% | 615d → none |  |  |
| 14242045 | ORTEC 935F discr. procurement prep | 2012-10-01 → 2013-01-08 A (+99d) | 2012-10-09 → 2013-01-16 A (+99d) |  | 0% → 100% | 615d → none |  |  |
| 14242030 | JLab TDC Fanout (25) test/install | 2013-04-10 → 2013-08-30 A (+142d) | 2013-07-02 → 2013-08-30 A (+59d) |  | 0% → 100% | 615d → none |  |  |

| ID | Task | Start | Finish | Duration | Complete | Total float | Predecessors | Other |
| --- | --- | --- | --- | --- | --- | --- | --- | --- |
| 14242065 | Re-Baseline Actuals Adjustment | 2013-08-30 A | 2013-08-30 A |  | 0% → 100% | 20d → none | 9-130M FS+227d → none |  |
| 14242060M | TDC and Discriminators Complete | 2013-07-02 → 2013-08-30 A (+59d) | 2013-07-02 → 2013-08-30 A (+59d) |  | 0% → 100% | 615d → none |  |  |
| 24242040a | JLab Discriminator (12) and Flash FADC (12) test/install (SF) | 2014-04-01 → 2014-03-31 (-1d) | 2014-09-30 → 2014-09-29 (-1d) |  |  | 304d → 305d |  |  |
| 24242055 | ORTEC 935F Discriminators (24) Test/Install (SF) | 2014-04-01 → 2014-03-31 (-1d) | 2014-09-30 → 2014-09-29 (-1d) |  |  | 304d → 305d |  |  |
| 24242040 | JLab Discriminator (240) and Flash FADC (240) test/install (FC) |  |  |  |  |  | 9-130M FS+228d, 9-155M → 9-155M |  |
| 3 | **1.4.2.4.3 SCALERS** | 2012-01-05 → 2012-01-09 (+4d) | 2015-07-09 → 2015-07-07 (-2d) |  |  |  |  |  |
| 14243005 | SCALERS- Prcrmnt Prep | 2012-01-05 → 2012-01-09 A (+4d) | 2012-02-02 → 2013-04-15 A (+438d) | 20d → 235d | 0% → 100% | 415d → none |  | was named SCALERS- Prcrmnt; resources ELEC TECH [80 h]; SCIENTIST [40 h] → SCIENTIST [40 h]; ELEC TECH [80 h] |
| 14243015 | Re-Baseline Actuals Adjustment | 2013-08-30 A | 2013-08-30 A |  | 0% → 100% | 20d → none | 9-130M FS+227d → none |  |
| 24243010 | SCALERS - Procurement/Install (SF) | 2015-01-07 → 2015-01-05 (-2d) | 2015-07-09 → 2015-07-07 (-2d) |  |  | 116d → 118d |  |  |
| 4 | **1.4.2.4.4 HIGH VOLTAGE** | 2012-01-05 → 2011-11-01 (-65d) | 2014-09-30 → 2015-07-02 (+275d) |  |  |  |  |  |
| 14244020 | Vend Fab - H.V Channels +3.5 KV 3 MA Floating (QTY13) | 2012-01-05 → 2011-11-01 A (-65d) | 2012-07-10 → 2012-09-17 A (+69d) | 130d → 217d | 0% → 100% | 858d → none | 14244015 FS-130d → 14244015 FS-150d |  |
| 14244025 | Vend Fab - H.V Channels -3.5 KV 3 MA Floating (QTY87) | 2012-01-05 → 2011-11-01 A (-65d) | 2012-07-10 → 2012-09-17 A (+69d) | 130d → 217d | 0% → 100% | 858d → none |  |  |
| 14244005 | Hi Voltage Prcrmnt Prep | 2012-01-05 → 2011-12-05 A (-31d) | 2012-02-02 → 2011-12-19 A (-45d) | 20d → 11d | 0% → 100% | 858d → none |  | was named Hi Voltage Prcrmnt |
| 14244010 | Vend Fab - Universal Multichannel Power Supply System 750W (QTY 5) | 2012-01-05 → 2011-12-05 A (-31d) | 2012-07-10 → 2012-09-17 A (+69d) | 130d → 195d | 0% → 100% | 858d → none |  |  |
| 14244015 | Vend Fab - Optional Power Supply 750W (QTY5) | 2012-01-05 → 2011-12-05 A (-31d) | 2012-07-10 → 2012-09-17 A (+69d) | 130d → 195d | 0% → 100% | 858d → none |  |  |
| 14244040 | Re-Baseline Actuals Adjustment | 2013-08-30 A | 2013-08-30 A |  | 0% → 100% | 20d → none | 9-130M FS+227d → none |  |
| 24244030 | CAEN 1527 HV mainframes install (12) (FC), (2) (SF)installation | 2014-04-01 → 2014-10-01 (+183d) | 2014-09-30 → 2015-04-13 (+195d) |  |  | 304d → 176d | 9-140M FS+119d → 9-155M |  |
| 24244035 | HV mainframes SY4525 (5) Procurements | 2013-10-01 → 2014-10-01 (+365d) | 2014-07-01 → 2015-07-02 (+366d) |  |  | 367d → 120d | 9-140M → 9-155M |  |
| 7 | **1.4.2.4.7 CRATES, RACKS** | 2010-09-30 → 2010-09-13 (-17d) | 2014-12-17 → 2014-12-15 (-2d) |  |  |  |  |  |
| 14247005 | Crates & Racks Prcrmnt | 2012-10-01 → 2010-09-13 A (-749d) | 2012-10-31 → 2010-09-22 A (-770d) | 23d → 8d | 0% → 100% | 225d → none | 9-130M, 12224005 → 12224005, 9-120M FS+40d |  |
| 14247008 | Vend Fab Crates and Racks Phase 1 Peg Point #2 VME64X Qty 5 | 2010-09-30 A | 2011-02-28 → 2011-03-25 A (+25d) | 98d → 117d | 0% → 100% | 1116d → none |  | was named Vend Fab Crates and Racks Phase 1 Peg Point #2 VME64 Qty 5; resources PROCUREMENT>$50K 69 NO ESCALATION FY11; PROCUREMENT<$50K 60 NO ESCALATION FY11 → PROCUREMENT<$50K 60 NO ESCALATION FY11; PROCUREMENT>$50K 69 NO ESCALATION FY11 |
| 14247009 | Vend Fab Crates and Racks Phase 1 Peg Point #4 VXS Qty 5 | 2010-09-30 A | 2011-03-31 → 2011-05-28 A (+58d) | 121d → 162d | 0% → 100% | 1116d → none |  |  |
| 14247010 | Vend Fab Crates and Racks Phase 2 VXS | 2012-01-05 → 2011-11-01 A (-65d) | 2012-03-30 → 2012-12-17 A (+262d) | 60d → 285d | 0% → 100% | 928d → none | 9-120M FS+60d, 14247009 → 9-120M FS+41d, 14247009 |  |
| 14247015 | Vend Fab Crates and Racks Phase 2 VME64X | 2012-01-05 → 2011-11-01 A (-65d) | 2012-03-30 → 2012-04-16 A (+17d) | 60d → 110d | 0% → 100% | 928d → none | 9-120M FS+60d, 14247009 → 9-120M FS+41d, 14247009 |  |
| 14247020 | NIM crates (10) procurement | 2012-10-01 → 2012-07-02 A (-91d) | 2012-10-31 → 2013-02-11 A (+103d) | 23d → 130d | 0% → 100% | 62d → none | 9-130M → 9-130M FS-50d |  |
| 14247030 | Racks FC Level-0 (10) procurement | 2012-10-01 → 2012-07-02 A (-91d) | 2012-10-31 → 2012-08-20 A (-72d) | 23d → 36d | 0% → 100% | 62d → none | 9-130M → 9-130M FS-50d |  |
| 14247006 | Wiener VME64x crates install (20) | 2013-05-31 → 2013-08-30 A (+91d) | 2013-06-27 → 2013-08-30 A (+64d) |  | 0% → 100% | 65d → none |  |  |
| 14247025 | NIM crates (10) install | 2013-06-05 → 2013-08-30 A (+86d) | 2013-07-02 → 2013-08-30 A (+59d) |  | 0% → 100% | 62d → none | 14247020 FS+143d → 14247020 FS+123d |  |
| 14247035 | Racks FC Level-0 (10) install | 2013-06-05 → 2013-08-30 A (+86d) | 2013-07-02 → 2013-08-30 A (+59d) |  | 0% → 100% | 62d → none | 14247030 FS+143d → 14247030 FS+194d |  |
| 14247065 | Re-Baseline Actuals Adjustment | 2013-08-30 A | 2013-08-30 A |  | 0% → 100% | 20d → none | 9-130M FS+227d → none |  |
| 24247040 | Uninterruptible PowerSupply (16kVA) | 2013-09-03 A |  |  |  |  |  |  |
| 24247005 | Wiener VME64x crates install (20) (FC) | 2014-01-07 → 2014-01-03 (-4d) | 2014-06-24 → 2014-06-20 (-4d) |  |  | 250d → 252d |  |  |
| 24247025 | NIM crates (10) install (FC) | 2014-01-07 → 2014-01-03 (-4d) | 2014-07-08 → 2014-07-03 (-5d) |  |  | 363.5d → 365.5d |  |  |
| 24247030 | NIM crates (2) install (SF) | 2014-04-01 → 2014-03-31 (-1d) | 2014-09-30 → 2014-09-29 (-1d) |  |  | 304.5d → 305.5d |  |  |
| 24247005a | Wiener VME64x crates install (2) (SF) | 2014-06-25 → 2014-06-23 (-2d) | 2014-12-17 → 2014-12-15 (-2d) |  |  | 250d → 252d |  |  |
| 24247060M | Crates and Racks Complete | 2014-12-17 → 2014-12-15 (-2d) | 2014-12-17 → 2014-12-15 (-2d) |  |  | 250d → 252d |  |  |
| 5 | **1.4.2.5 BEAMLINE** | 2011-10-03 → 2012-02-01 (+121d) |  |  |  |  |  |  |
| 1 | **1.4.2.5.1 FARADAY CUP UPGRADE** | 2013-01-03 → 2013-08-30 (+239d) |  |  |  |  |  |  |
| 14251005 | Refurb CLAS Faraday Cup | 2013-01-03 → 2013-08-30 A (+239d) | 2013-04-26 → 2013-08-30 A (+126d) |  | 0% → 100% | 661d → none | 9-130M FS+60d → 9-140M, 9-130M FS+60d |  |
| 14251010 | Re-Baseline Actuals Adjustment | 2013-08-30 A | 2013-08-30 A |  | 0% → 100% | 20d → none | 9-130M FS+227d → none |  |
| 2 | **1.4.2.5.2 MOLLER POLARIMETER UPGRADE** | 2013-01-03 → 2013-08-30 (+239d) |  |  |  |  |  |  |
| 14252005 | Fab a Moller Polarimeter Supprt Struct | 2013-01-03 → 2013-08-30 A (+239d) | 2013-06-24 → 2013-08-30 A (+67d) |  | 0% → 100% | 573d → none | 12225020, 9-130M FS+60d → 9-140M, 12225020, 9-130M FS+60d | resources MSHOP; MECH TECH [220 h]; SCIENTIST [20 h]; ELEC TECH [120 h]; CONTRB UNIV LBR [880 h] → MECH TECH [220 h]; ELEC TECH [120 h]; SCIENTIST [20 h]; MSHOP; CONTRB UNIV LBR [880 h] |
| 14252010 | Fab a Moller Polarimeter Supprt Struct | 2013-06-25 → 2013-08-30 A (+66d) | 2013-08-30 A | 48d → 120d | 0% → 100% | 573d → none | 9-110M, 14252005 → 9-140M, 14252005, 9-110M | resources MSHOP; MECH TECH [88 h]; ELEC TECH [48 h]; CONTRB UNIV LBR [352 h]; SCIENTIST [8 h] → ELEC TECH [48 h]; CONTRB UNIV LBR [352 h]; MSHOP; SCIENTIST [8 h]; MECH TECH [88 h] |
| 14252015 | Re-Baseline Actuals Adjustment | 2013-08-30 A | 2013-08-30 A |  | 0% → 100% | 20d → none | 9-130M FS+227d → none |  |
| 4 | **1.4.2.5.4 BEAMLINE COMPONENTS** | 2011-10-03 → 2012-02-01 (+121d) |  |  |  |  |  |  |
| 14254005 | P-#1 Constrctn of Beam Line Monitoring Sys | 2011-10-03 → 2012-02-01 A (+121d) | 2012-03-30 → 2012-03-19 A (-11d) | 120d → 32d | 0% → 100% | 820d → none |  |  |
| 14254007 | Beamline Studies and Drawings | 2012-03-01 → 2013-08-30 A (+547d) | 2012-09-28 → 2013-08-30 A (+336d) |  | 0% → 100% | 801d → none | 9-120M FS+98d → 9-120M FS+184d, 9-130M FS+60d, 9-140M |  |
| 14254008 | MOU with FIU on Moller Polarimeter | 2012-03-01 → 2013-08-30 A (+547d) | 2012-09-28 → 2013-08-30 A (+336d) |  | 0% → 100% | 801d → none | 9-120M FS+98d → 9-140M, 9-130M FS+60d, 9-120M FS+184d |  |
| 14254010 | Constrctn of Beam Line Shielding | 2013-01-03 → 2013-08-30 A (+239d) | 2013-06-24 → 2013-08-30 A (+67d) |  | 0% → 100% | 621d → none | 12225050, 9-130M FS+60d → 9-130M FS+60d, 9-140M, 12225050 | resources MSHOP; PROCUREMENT<$50K 60 → PROCUREMENT<$50K 60; MSHOP |
| 14254015 | Constrctn of Beam Line Vac Sys | 2013-01-03 → 2013-08-30 A (+239d) | 2013-06-24 → 2013-08-30 A (+67d) |  | 0% → 100% | 573d → none | 9-130M FS+60d → 9-130M FS+60d, 9-140M | resources ELEC DES [181 h]; MSHOP; SCIENTIST [65.8 h]; PROCUREMENT<$50K 60; VISTNG USERS [378.3 h]; MECH TECH [181 h] → MSHOP; PROCUREMENT<$50K 60; MECH TECH [181 h]; ELEC DES [181 h]; SCIENTIST [65.8 h]; VISTNG USERS [378.3 h] |
| 14254020 | P-#2 Constrctn of Beam Line Monitoring Sys | 2013-04-01 → 2013-08-30 A (+151d) | 2013-08-30 A | 108d → 120d | 0% → 100% | 573d → none | 9-130M FS+120d, 14254005 → 9-130M FS+120d, 9-140M, 14254005 |  |
| 14254025 | Constrctn of Beam Line Vac Sys | 2013-06-25 → 2013-08-30 A (+66d) | 2013-08-30 A | 48d → 120d | 0% → 100% | 573d → none | 9-110M, 14254015 → 14254015, 9-110M, 9-140M | resources SCIENTIST [18.28 h]; VISTNG USERS [133.94 h]; ELEC DES [66.96 h]; MECH TECH [66.96 h] → VISTNG USERS [133.94 h]; MECH TECH [66.96 h]; ELEC DES [66.96 h]; SCIENTIST [18.28 h] |
| 14254030 | Re-Baseline Actuals Adjustment | 2013-08-30 A | 2013-08-30 A |  | 0% → 100% | 20d → none | 9-130M FS+227d → none |  |
| 6 | **1.4.2.6 INFRASTRUCTURE** |  | 2016-01-28 → 2016-05-12 (+105d) |  |  |  |  |  |
| 14261000 | Re-Baseline Actuals Adjustment | 2013-08-30 A | 2013-08-30 A |  | 0% → 100% | 20d → none | 9-130M FS+227d → none |  |
| 14263000 | Re-Baseline Actuals Adjustment | 2013-08-30 A | 2013-08-30 A |  | 0% → 100% | 20d → none | 9-130M FS+227d → none |  |
| 4 | **1.4.2.6.4 INSTALLATION** |  | 2016-01-28 → 2016-05-12 (+105d) |  |  |  |  |  |
| 14264007x | Subway Addition Procurement Prep | 2011-07-05 → 2011-07-01 A (-4d) | 2011-09-30 → 2011-10-24 A (+24d) | 63d → 80d | 0% → 100% | 865d → none |  | resources MECH DES [80 h]; PLANT ENG [160 h] → PLANT ENG [160 h]; MECH DES [80 h] |
| 14264009 | Electrical Utilities Mods of Spaceframe | 2011-08-02 → 2011-07-06 A (-27d) | 2011-08-29 → 2011-07-18 A (-42d) | 20d → 9d | 0% → 100% | 888d → none |  |  |
| 14264001LOE | Installation Procurement Support | 2011-10-03 A | 2012-09-28 A |  | 0% → 100% | 1010d → none |  | was named Installation Procurement Support FY12 |
| 14264008a | Spaceframe Motion System | 2011-07-01 → 2011-10-03 A (+94d) | 2011-12-30 → 2011-10-24 A (-67d) | 122d → 16d | 0% → 100% | 985d → none | 9-110M FS+184d → 9-110M FS+290d |  |
| 14264000aLOE | Installation Engineering Oversight A FY12 | 2011-12-01 A | 2012-09-28 A |  | 0% → 100% | 1158d → none |  |  |
| 14264000cLOE | Installation Engineering Oversight B FY12 | 2012-02-01 A | 2012-09-28 A |  | 0% → 100% | 1158d → none |  |  |
| 14264000 | CLAS 6 Removal | 2012-05-14 → 2012-05-18 A (+4d) | 2013-02-06 → 2013-01-31 A (-6d) | 181d → 177d | 0% → 100% | 65d → none |  |  |
| 14264008 | Vend Fab Subway Addition with rails and Spaceframe Mod | 2012-09-11 A | 2013-05-31 → 2013-04-15 A (-46d) |  | 0% → 100% | 632d → none | 9-120M FS+233d, 14264007x, 14264009 → 9-120M FS+240d, 14264009, 14264007x |  |
| 14264000bLOE | Installation Engineering Oversight A FY13 | 2012-10-01 A | 2013-01-31 A |  | 0% → 100% | 1158d → none |  |  |
| 14264000dLOE | Installation Engineering Oversight B FY13 | 2012-10-01 A | 2013-01-31 A |  | 0% → 100% | 1158d → none |  |  |
| 14264002LOE | Installation Procurement Support | 2012-10-01 A | 2013-08-30 A | 228d → 247d | 0% → 100% | 1010d → none |  | was named Installation Procurement Support FY13 |
| 14264240 | Manufacturing Design of Fwd. Carriage Mods | 2012-12-03 A | 2012-12-18 → 2013-02-21 A (+65d) |  | 0% → 100% | 70d → none |  |  |
| 14264269 | Manufacturing Design of Motion System | 2013-01-03 → 2012-12-03 A (-31d) | 2013-03-22 → 2013-02-21 A (-29d) |  | 0% → 100% | 20d → none |  |  |

| ID | Task | Start | Finish | Duration | Complete | Total float | Predecessors | Other |
| --- | --- | --- | --- | --- | --- | --- | --- | --- |
| 14264271 | Procurement Prep of Motion System | 2013-03-25 → 2013-02-01 A (-52d) | 2013-04-30 → 2013-02-22 A (-67d) |  | 0% → 100% | 20d → none |  |  |
| 14264245 | Procurement Prep of Fwd. Carriage Mods | 2012-12-19 → 2013-02-05 A (+48d) | 2013-01-31 → 2013-02-22 A (+22d) |  | 0% → 100% | 70d → none |  |  |
| 14264315M | Start Installation of Hardware for DAQ | 2013-03-01 → 2013-04-08 A (+38d) | 2013-03-01 → 2013-04-08 A (+38d) |  | 0% → 100% | 118d → none |  |  |
| 14264316 | Removal of unused cables (DAQ) | 2013-03-01 → 2013-04-08 A (+38d) | 2013-03-14 → 2013-04-22 A (+39d) |  | 0% → 100% | 118d → none |  |  |
| 14264013 | Vend Fab Fwd. carriage Mods and install hangers and mount | 2012-06-01 → 2013-04-15 A (+318d) | 2013-03-29 → 2013-08-30 A (+154d) | 204d → 141d | 0% → 100% | 69d → none | 14264245 FS-165d, 9-120M FS+163d → 9-130M, 14264245 FS-165d, 9-120M FS+163d |  |
| 14264362 | Vend Fab Fwd. Detector Installation Tooling | 2012-10-01 → 2013-08-01 A (+304d) | 2013-06-28 → 2013-08-28 A (+61d) | 184d → 141d | 0% → 100% | 52d → none | 9-130M → 9-130M FS+110d |  |
| 14264278 | Install Motion system | 2013-06-19 → 2013-08-26 A (+68d) | 2013-06-25 → 2013-08-30 A (+66d) |  | 0% → 100% | 20d → none |  |  |
| 14264290 | Weld PCAL and LTCC brackets | 2013-07-02 → 2013-08-26 A (+55d) | 2013-07-16 → 2013-08-30 A (+45d) |  | 0% → 100% | 20d → none | 14264285 → 14264285 FS-228d |  |
| 14264002M | Hall Cleared and Cleaned for CLAS12 installation | 2013-02-07 → 2013-08-30 A (+204d) | 2013-02-07 → 2013-08-30 A (+204d) |  | 0% → 100% | 65d → none |  |  |
| 14264202M | R2 Drift Chambers Ready for Installation | 2013-05-01 → 2013-08-30 A (+121d) | 2013-05-01 → 2013-08-30 A (+121d) |  | 0% → 100% | 106d → none |  |  |
| 14264204M | R1 Drift Chambers Ready for Installation | 2013-08-01 → 2013-08-30 A (+29d) | 2013-08-01 → 2013-08-30 A (+29d) |  | 0% → 100% | 42d → none |  |  |
| 14264206M | ToF Panel 1a - First 3 units Ready for Installation | 2013-04-05 → 2013-08-30 A (+147d) | 2013-04-05 → 2013-08-30 A (+147d) |  | 0% → 100% | 666d → none | 142232455 → 142232455 FS+80d |  |
| 14264220M | PCAL - First 5 units Ready for Installation | 2013-06-21 → 2013-08-30 A (+70d) | 2013-06-21 → 2013-08-30 A (+70d) |  | 0% → 100% | 58d → none |  |  |
| 14264228M | Subway Steel Delivered | 2013-05-31 → 2013-08-30 A (+91d) | 2013-05-31 → 2013-08-30 A (+91d) |  | 0% → 100% | 632d → none |  |  |
| 14264230 | Subway Level 1 addition wiring Power Dist. | 2013-06-03 → 2013-08-30 A (+88d) | 2013-06-07 → 2013-08-30 A (+84d) |  | 0% → 100% | 632d → none |  |  |
| 14264235 | Hall B Control Survey | 2013-06-03 → 2013-08-30 A (+88d) | 2013-06-07 → 2013-08-30 A (+84d) |  | 0% → 100% | 632d → none |  |  |
| 14264238M | Start Mods of FWD Carriage | 2013-02-07 → 2013-08-30 A (+204d) | 2013-02-07 → 2013-08-30 A (+204d) |  | 0% → 100% | 702d → none |  |  |
| 14264260 | Reinforce Fwd Carriage, add motion sysytem mounts and detector mounts | 2013-02-07 → 2013-08-30 A (+204d) | 2013-04-10 → 2013-08-30 A (+142d) |  | 0% → 100% | 65d → none |  |  |
| 14264265 | Add Hand rails and stairs to FC level 0 | 2013-04-11 → 2013-08-30 A (+141d) | 2013-04-15 → 2013-08-30 A (+137d) |  | 0% → 100% | 65d → none |  |  |
| 14264267 | Add AC power to Level 0 FC | 2013-04-16 → 2013-08-30 A (+136d) | 2013-04-18 → 2013-08-30 A (+134d) |  | 0% → 100% | 652d → none |  |  |
| 14264273 | Vend Fab Motion System | 2013-05-01 → 2013-08-30 A (+121d) | 2013-06-18 → 2013-08-30 A (+73d) |  | 0% → 100% | 20d → none |  |  |
| 14264280 | Modify LTCC gas piping | 2013-04-19 → 2013-08-30 A (+133d) | 2013-05-09 → 2013-08-30 A (+113d) |  | 0% → 100% | 652d → none |  |  |
| 14264285 | Modify Lead nose | 2013-06-26 → 2013-08-30 A (+65d) | 2013-07-01 → 2013-08-30 A (+60d) |  | 0% → 100% | 20d → none |  |  |
| 14264295 | Install panel 2 TOF brackets | 2013-07-16 → 2013-08-30 A (+45d) | 2013-07-29 → 2013-08-30 A (+32d) |  | 0% → 100% | 20d → none |  |  |
| 14264297M | Start Forward Carriage Precabling | 2013-07-30 → 2013-08-30 A (+31d) | 2013-07-30 → 2013-08-30 A (+31d) |  | 0% → 100% | 20d → none |  |  |
| 14264300 | Install 10 electronics racks level 0 | 2013-07-30 → 2013-08-30 A (+31d) | 2013-08-01 → 2013-08-30 A (+29d) |  | 0% → 100% | 20d → none |  |  |
| 14264305 | Install 2 electronics racks level 2 | 2013-08-02 → 2013-08-30 A (+28d) | 2013-08-05 → 2013-08-30 A (+25d) |  | 0% → 100% | 20d → none |  |  |
| 14264308 | Reroute EC, CC, TOF HV/signal cables | 2013-08-06 → 2013-08-30 A (+24d) | 2013-08-30 A | 19d → 52d | 0% → 100% | 20d → none |  |  |
| 14264318 | Relocate PMT signals/HV/network patch panels | 2013-08-02 → 2013-08-30 A (+28d) | 2013-08-08 → 2013-08-30 A (+22d) |  | 0% → 100% | 20d → none |  |  |
| 14264328 | Relocate electronic crates | 2013-08-09 → 2013-08-30 A (+21d) | 2013-08-30 A | 16d → 30d | 0% → 100% | 20d → none |  | resources ELEC TECH [256 h] → ELEC TECH [480 h] |
| 14264340M | Start Beamline Modifications | 2013-03-01 → 2013-08-30 A (+182d) | 2013-03-01 → 2013-08-30 A (+182d) |  | 0% → 100% | 677d → none |  |  |
| 14264345 | Install New Tagger Window | 2013-06-03 → 2013-08-30 A (+88d) | 2013-06-05 → 2013-08-30 A (+86d) |  | 0% → 100% | 634d → none |  |  |
| 14264350 | Move Moeller Quads and Table | 2013-03-01 → 2013-08-30 A (+182d) | 2013-03-21 → 2013-08-30 A (+162d) |  | 0% → 100% | 677d → none |  |  |
| 14264355 | Move GONI | 2013-03-22 → 2013-08-30 A (+161d) | 2013-04-01 → 2013-08-30 A (+151d) |  | 0% → 100% | 677d → none |  |  |
| 14264360 | Align Goni and Moeller Quads | 2013-04-02 → 2013-08-30 A (+150d) | 2013-04-04 → 2013-08-30 A (+148d) |  | 0% → 100% | 677d → none |  |  |
| 14264364M | Start Installation of FWD Detectors | 2013-07-01 → 2013-08-30 A (+60d) | 2013-07-01 → 2013-08-30 A (+60d) |  | 0% → 100% | 52d → none |  |  |
| 14264365 | Transport and install first 5 sectors PCAL | 2013-07-01 → 2013-08-30 A (+60d) | 2013-07-22 → 2013-08-30 A (+39d) |  | 0% → 100% | 52d → none |  | resources MECH TECH [400 h]; PLABOR → PLABOR; MECH TECH [400 h] |
| 14264370 | Check PCAL positions | 2013-07-23 → 2013-08-30 A (+38d) | 2013-07-25 → 2013-08-30 A (+36d) |  | 0% → 100% | 588d → none |  |  |
| 14264375 | Cable/test/repair Preshower calorimeters | 2013-07-05 → 2013-08-30 A (+56d) | 2013-07-17 → 2013-08-30 A (+44d) |  | 0% → 100% | 52d → none |  |  |
| 14264400 | Transport and Install ToF 1a - First 3 sectors | 2013-07-26 → 2013-08-30 A (+35d) | 2013-08-02 → 2013-08-30 A (+28d) |  | 0% → 100% | 588d → none |  |  |
| 14264405 | Survey (as found location) TOF 1a positions | 2013-08-05 → 2013-08-30 A (+25d) | 2013-08-05 → 2013-08-30 A (+25d) |  | 0% → 100% | 588d → none |  |  |
| 14264410 | Cable/test/repair 1a's TOF's | 2013-08-06 → 2013-08-30 A (+24d) | 2013-08-09 → 2013-08-30 A (+21d) |  | 0% → 100% | 588d → none |  |  |
| 14264545 | Install and wire up Torus PS (G0) | 2013-04-05 → 2013-08-30 A (+147d) | 2013-04-11 → 2013-08-30 A (+141d) |  | 0% → 100% | 119d → none |  |  |
| 14264882 | Install DC signal cable trays and gas lines | 2013-02-07 → 2013-08-30 A (+204d) | 2013-02-21 → 2013-08-30 A (+190d) |  | 0% → 100% | 129d → none |  |  |
| 14264884 | Route DC Signal Cables | 2013-02-22 → 2013-08-30 A (+189d) | 2013-03-21 → 2013-08-30 A (+162d) |  | 0% → 100% | 129d → none |  |  |
| 14264886 | Install DC HV/LV Racks and cable trays | 2013-03-21 → 2013-08-30 A (+162d) | 2013-03-28 → 2013-08-30 A (+155d) |  | 0% → 100% | 129d → none |  | resources PLABOR; MECH TECH [95.66 h]; PROCUREMENT<$50K 60 → MECH TECH [95.66 h]; PROCUREMENT<$50K 60; PLABOR |
| 14264998 | Re-Baseline Actuals Adjustment | 2013-08-30 A | 2013-08-30 A |  | 0% → 100% | 20d → none | 9-130M FS+227d → none |  |
| 24264002LOE | Installation Procurement Support FY13 | 2013-09-03 A | 2013-09-30 A |  | 0% → 100% | 742d → none |  |  |
| 24264140 | PCAL - Procure PCAL installation stand | 2013-09-03 A | 2013-10-28 → 2014-01-09 (+73d) |  |  | 446d → 403d |  |  |
| 24264278 | Install Fwd Carriage Mods | 2013-09-03 A | 2013-09-30 → 2013-09-23 A (-7d) |  | 0% → 100% | 304d → none |  | resources PROCUREMENT>$50K 69; PROCUREMENT<$50K 60 → PROCUREMENT<$50K 60 |
| 24264362 | Vend Fab Fwd. Detector Installation Tooling | 2013-09-03 A | 2013-10-28 → 2013-09-23 A (-35d) |  | 0% → 100% | 446d → none |  |  |
| 24264395 | Cable/test/repair EC | 2013-10-29 → 2013-09-09 A (-50d) | 2014-03-11 → 2014-04-11 (+31d) |  | 0% → 55% | 446d → 423d | 24264365 FS-142d, 9-140M FS+20d → 9-140M, 24264365 FS-142d |  |
| 24264035M | ToF Panel 1a - First 3 units Ready for Installation | 2013-09-03 → 2013-09-16 A (+13d) | 2013-09-03 → 2013-09-16 A (+13d) |  | 0% → 100% | 561d → none |  |  |
| 24264045M | ToF Panel 2 Ready for Installation | 2013-09-03 → 2013-09-16 A (+13d) | 2013-09-03 → 2013-09-16 A (+13d) |  | 0% → 100% | 556d → none |  |  |
| 24264300 | Precable forward carriage FY13 | 2013-09-24 → 2013-09-16 A (-8d) | 2013-09-30 → 2014-02-05 (+128d) |  | 0% → 16% |  |  |  |
| 24264300a | Precable forward carriage FY14 | 2013-10-01 → 2013-09-16 A (-15d) |  |  | 0% → 16% |  | 24264297M, 24264300 → 24264300 FS-100d |  |
| 24264297M | Start Forward Carriage Precabling | 2013-09-24 → 2013-09-22 A (-2d) | 2013-09-24 → 2013-09-22 A (-2d) |  | 0% → 100% | 385d → none |  |  |
| 24264003LOE | Installation Enginering Support FY14 | 2013-10-01 A |  |  | 0% → 9% |  |  |  |
| 24264050M | ToF Panel 1b - First 3 units Ready for Installation | 2014-01-02 → 2013-10-21 A (-73d) | 2014-01-02 → 2013-10-21 A (-73d) |  | 0% → 100% | 456d → none |  |  |
| 24264055M | ToF Panel 1b - Last 3 units Ready for Installation | 2014-01-02 → 2013-10-21 A (-73d) | 2014-01-02 → 2013-10-21 A (-73d) |  | 0% → 100% | 470d → none |  |  |
| 24264025M | R2 Drift Chambers Ready for Installation | 2013-09-03 → 2013-11-01 (+59d) | 2013-09-03 → 2013-11-01 (+59d) |  |  | 530d → 487d |  |  |
| 24264515 | Mods to CRYO transfer lines | 2013-10-01 → 2013-11-01 (+31d) | 2013-11-25 → 2014-01-09 (+45d) |  |  | 339d → 316d |  |  |
| 24264270 | Add AC power to Level 0 FC | 2013-09-03 → 2013-11-15 (+73d) | 2013-10-02 → 2013-12-16 (+75d) | 22d → 20d |  | 476d → 425d | 9-130M FS+228d → 9-130M FS+228d, 9-140M FS+33d |  |
| 24264935 | Widen the corners of the Hall access walls to allow R3 to pass through horizontal | 2013-10-01 → 2013-11-15 (+45d) | 2014-02-07 → 2014-03-26 (+47d) |  |  | 427d → 394d | 9-140M → 9-140M FS+33d |  |
| 24264020M | R3 Drift Chambers Ready for Installation | 2015-04-02 → 2013-12-16 (-472d) | 2015-04-02 → 2013-12-16 (-472d) |  |  | 165d → 480d | 242213355M → 242213355M FS-315d |  |
| 24264888 | Reroute DC gas lines to the distribution pannel | 2014-01-06 → 2014-01-02 (-4d) | 2014-07-15 → 2014-07-11 (-4d) |  |  | 358d → 360d |  |  |
| 24264364M | Start Installation of FWD Detectors | 2013-10-29 → 2014-01-10 (+73d) | 2013-10-29 → 2014-01-10 (+73d) |  |  | 446d → 403d |  |  |
| 24264517 | Modify Space Frame For Cryo Can | 2013-09-09 → 2014-02-03 (+147d) | 2013-11-05 → 2014-04-01 (+147d) |  |  | 334d → 240d | 9-130M FS+232d → 9-130M FS+232d, 9-140M FS+80d |  |
| 24264280 | Modify LTCC gas piping | 2013-11-13 → 2014-02-07 (+86d) | 2014-01-27 → 2014-04-08 (+71d) |  |  | 476d → 425d |  |  |
| 24264790 | Solenoid - design adjustment system for solenoid and HTCC rails | 2014-03-05 → 2014-03-04 (-1d) | 2014-04-08 → 2014-04-07 (-1d) |  |  | 177d → 178d |  |  |

| ID | Task | Start | Finish | Total float |
| --- | --- | --- | --- | --- |
| 24264281 | Install new gas lines from gas sched to the hall | 2014-01-14 → 2014-03-27 (+72d) | 2014-01-28 → 2014-04-09 (+71d) | 476d → 425d |
| 24264105 | SVT - Design mounts for SVT to solenoid cart | 2014-04-02 → 2014-04-01 (-1d) | 2014-05-27 → 2014-05-23 (-4d) | 252d → 253d |
| 24264520 | Modify Space Frame Level 3 deck For Torus Cryo | 2013-11-06 → 2014-04-02 (+147d) | 2013-12-05 → 2014-04-29 (+145d) | 334d → 240d |
| 24264793 | Solenoid - design motion system | 2014-04-09 → 2014-04-08 (-1d) | 2014-05-12 → 2014-05-09 (-3d) | 213d → 214d |
| 24264795 | Solenoid - design cart | 2014-04-09 → 2014-04-08 (-1d) | 2014-05-12 → 2014-05-09 (-3d) | 177d → 178d |
| 24264905 | DC - design cable trays and gas system mounts | 2014-04-11 → 2014-04-10 (-1d) | 2014-10-09 → 2014-10-08 (-1d) | 49d → 50d |
| 24264796 | Solenoid - cart Engineering Analysis | 2014-04-29 → 2014-04-28 (-1d) | 2014-05-29 → 2014-05-28 (-1d) | 177d → 178d |
| 24264791 | Solenoid - procure rails and adjustment components for solenoid and HTCC rails | 2014-05-06 → 2014-05-05 (-1d) | 2014-08-04 → 2014-08-01 (-3d) | 177d → 178d |
| 24264794 | Solenoid - procure motion system | 2014-05-06 → 2014-05-05 (-1d) | 2014-07-03 → 2014-07-02 (-1d) | 213d → 214d |
| 24264545 | Install and wire up Torus PS (G0) | 2014-05-07 → 2014-05-06 (-1d) | 2014-05-13 → 2014-05-12 (-1d) | 82d → 83d |
| 24264085M | First Torus Cryostat Ready | 2014-06-30 → 2014-05-13 (-48d) | 2014-06-30 → 2014-05-13 (-48d) | 50d → 83d |
| 24264110 | SVT - Design Insertion/service cart and installation arm | 2014-05-28 → 2014-05-27 (-1d) | 2014-07-22 → 2014-07-21 (-1d) | 252d → 253d |
| 24264797 | Solenoid - procure cart | 2014-06-03 → 2014-06-02 (-1d) | 2014-09-02 → 2014-08-29 (-4d) | 175d → 176d |
| 24264900 | DC - procure mounts and adjusters for DC to Torus | 2014-06-03 → 2014-06-02 (-1d) | 2014-09-30 → 2014-09-29 (-1d) | 190d → 191d |
| 24264282 | Design modifications to Lead Nose | 2014-06-05 → 2014-06-04 (-1d) | 2014-06-25 → 2014-06-24 (-1d) | 330d → 331d |
| 24264285 | Modify Lead nose | 2014-06-26 → 2014-06-25 (-1d) | 2014-07-15 → 2014-07-14 (-1d) | 330d → 331d |
| 24264115 | SVT - Design transportation cart/skid | 2014-07-23 → 2014-07-22 (-1d) | 2014-10-03 → 2014-10-02 (-1d) | 252d → 253d |
| 24264550 | Install 3 Torus Base support and adjustment Stands | 2014-09-02 → 2014-07-22 (-42d) | 2014-09-08 → 2014-07-28 (-42d) | 25d → 54d |
| 24264090M | Last Torus Cryostat Ready | 2014-10-01 → 2014-07-29 (-64d) | 2014-10-01 → 2014-07-29 (-64d) | 72d → 117d |
| 24264910 | DC - cable trays and gas system mounts Engineering Analysis | 2014-08-01 → 2014-07-31 (-1d) | 2014-09-03 → 2014-09-02 (-1d) | 74d → 75d |
| 24264792 | Solenoid - Install and Align rails and adjustment components for solenoid and HTCC rails | 2014-08-05 → 2014-08-04 (-1d) | 2014-08-25 → 2014-08-22 (-3d) | 177d → 178d |
| 24264548M | Start Torus Installation | 2014-06-30 → 2014-08-04 (+35d) | 2014-06-30 → 2014-08-04 (+35d) | 50d → 25d |
| 24264565 | Attach cold hub to Coil D | 2014-07-09 → 2014-08-05 (+27d) | 2014-07-17 → 2014-08-13 (+27d) | 44d → 25d |
| 24264570 | Attach Center Base Legs to Coil D | 2014-07-18 → 2014-08-14 (+27d) | 2014-07-28 → 2014-08-22 (+25d) | 44d → 25d |
| 24264575 | Install Temporary Braces to Hall Floor for Coil D and Beam left and right Cold Rings | 2014-07-29 → 2014-08-25 (+27d) | 2014-08-11 → 2014-09-08 (+28d) | 44d → 25d |
| 24264794a | Solenoid - Install motion system | 2014-08-26 → 2014-08-25 (-1d) | 2014-09-02 → 2014-08-29 (-4d) | 177d → 178d |
| 24264120 | SVT - Cart/Skid Engineering analysis | 2014-08-27 → 2014-08-26 (-1d) | 2014-09-12 → 2014-09-11 (-1d) | 267d → 268d |
| 24264230 | Subway Level 1 addition wiring Power Dist. | 2014-09-04 → 2014-09-03 (-1d) | 2014-09-10 → 2014-09-09 (-1d) | 190d → 191d |
| 24264125 | SVT - Procure SVT mounts and cart | 2014-10-06 → 2014-10-03 (-3d) | 2014-12-15 → 2014-12-12 (-3d) | 252d → 253d |
| 24264525 | Distribution Can - Transport and position distribution box | 2014-09-02 → 2014-10-03 (+31d) | 2014-09-03 → 2014-10-06 (+33d) | 153d → 130d |
| 24264527 | Distribution Can - Connect cold piping with fittings and welding | 2014-09-04 → 2014-10-07 (+33d) | 2014-09-10 → 2014-10-13 (+33d) | 153d → 130d |
| 24264915 | DC - procure cable trays and gas system mounts | 2014-10-09 → 2014-10-08 (-1d) | 2014-12-23 → 2014-12-22 (-1d) | 49d → 50d |
| 24264529 | Distribution Can - Connect Instrumentation and valves | 2014-09-11 → 2014-10-14 (+33d) | 2014-09-17 → 2014-10-20 (+33d) | 153d → 130d |
| 24264531 | Distribution Can - leak test system | 2014-09-18 → 2014-10-21 (+33d) | 2014-09-23 → 2014-10-24 (+31d) | 153d → 130d |
| 24264095M | Torus Control System Ready for Installation | 2015-01-07 → 2014-10-22 (-77d) | 2015-01-07 → 2014-10-22 (-77d) | 137d → 182d |
| 24264555 | Install Torus Control System | 2015-01-07 → 2014-10-22 (-77d) | 2015-02-04 → 2014-11-18 (-78d) | 137d → 182d |
| 24264533 | Distribution Can - pressure test system | 2014-09-24 → 2014-10-27 (+33d) | 2014-09-25 → 2014-10-28 (+33d) | 153d → 130d |
| 24264535 | Distribution Can - final leak test system | 2014-09-26 → 2014-10-29 (+33d) | 2014-09-30 → 2014-10-31 (+31d) | 153d → 130d |
| 24264540 | Distribution Can - purify system | 2014-10-01 → 2014-11-03 (+33d) | 2014-10-03 → 2014-11-05 (+33d) | 153d → 130d |
| 24264605 | Install Coil F and B assemblies | 2014-11-18 → 2014-11-11 (-7d) | 2014-12-04 → 2014-11-25 (-9d) | 20d → 25d |
| 24264610 | Install Top four Cold Ring beams and temporary braces | 2014-12-05 → 2014-11-26 (-9d) | 2014-12-15 → 2014-12-08 (-7d) | 20d → 25d |
| 24264615 | Install Coil A | 2014-12-19 → 2014-12-09 (-10d) | 2015-01-07 → 2014-12-16 (-22d) | 17d → 25d |
| 24264620 | Survey all CCM and Cold Hub relative locations adjust as necessary | 2015-01-08 → 2014-12-17 (-22d) | 2015-01-12 → 2014-12-19 (-24d) | 17d → 25d |
| 24264625 | Mount the Torus Service Module on Level 3 | 2015-01-13 → 2014-12-22 (-22d) | 2015-01-13 → 2014-12-22 (-22d) | 17d → 25d |
| 24264630 | Splice all Coil Leads and Leads to Service Module | 2015-01-14 → 2014-12-23 (-22d) | 2015-01-20 → 2015-01-07 (-13d) | 17d → 25d |
| 24264635 | Weld/Braze all cooling lines (He) | 2015-01-21 → 2015-01-08 (-13d) | 2015-01-22 → 2015-01-09 (-13d) | 17d → 25d |
| 24264640 | Pressure and Leak test all 4K cooling lines | 2015-01-23 → 2015-01-12 (-11d) | 2015-01-26 → 2015-01-13 (-13d) | 17d → 25d |
| 24264880 | Vend Fab Drift Chambers Installation tooling | 2015-01-14 → 2015-01-12 (-2d) | 2015-06-05 → 2015-06-03 (-2d) | 98d → 100d |
| 24264645 | Secure and Heat Station the Splices and coil leads | 2015-01-27 → 2015-01-14 (-13d) | 2015-01-29 → 2015-01-16 (-13d) | 17d → 25d |
| 24264650 | Connect all instrumentation including voltage taps | 2015-01-30 → 2015-01-20 (-10d) | 2015-02-06 → 2015-01-27 (-10d) | 17d → 25d |
| 24264655 | Insulate all 4K Surfaces | 2015-02-09 → 2015-01-28 (-12d) | 2015-02-20 → 2015-02-10 (-10d) | 17d → 25d |
| 24264010M | SVT Ready For Installation | 2014-12-15 → 2015-02-05 (+52d) | 2014-12-15 → 2015-02-05 (+52d) | 229d → 200d |
| 24264660 | Complete Central hub heat shield | 2015-02-23 → 2015-02-11 (-12d) | 2015-02-26 → 2015-02-16 (-10d) | 17d → 25d |
| 24264762 | TORUS CRYO WARM PIPING-Design Gas Panel and Piping | 2015-02-24 → 2015-02-12 (-12d) | 2015-03-16 → 2015-03-04 (-12d) | 29d → 37d |
| 24264665 | Install Cold to warm supports on vertical Cold ring beams | 2015-02-27 → 2015-02-17 (-10d) | 2015-02-27 → 2015-02-17 (-10d) | 17d → 25d |
| 24264670 | Install Heat shield on Cold Ring vertical Beams | 2015-03-02 → 2015-02-18 (-12d) | 2015-03-05 → 2015-02-23 (-10d) | 17d → 25d |
| 24264675 | Insulate 80K surfaces on Cold Ring vertical beams | 2015-03-06 → 2015-02-24 (-10d) | 2015-03-11 → 2015-02-27 (-12d) | 17d → 25d |
| 24264680 | Install Outer Legs N & S on Adjusters (includes 1/2 of CS VJ) | 2015-03-12 → 2015-03-02 (-10d) | 2015-03-13 → 2015-03-03 (-10d) | 17d → 25d |
| 24264685 | Attach cold to warm support to VJ (2 places) | 2015-03-16 → 2015-03-04 (-12d) | 2015-03-16 → 2015-03-04 (-12d) | 17d → 25d |
| 24264690 | Complete Vertical Cold Ring VJ | 2015-03-17 → 2015-03-05 (-12d) | 2015-03-20 → 2015-03-10 (-10d) | 17d → 25d |
| 24264762A | TORUS CRYO WARM PIPING-Cut Back Piping | 2015-03-17 → 2015-03-05 (-12d) | 2015-03-17 → 2015-03-05 (-12d) | 29d → 37d |
| 24264762B | TORUS CRYO WARM PIPING-Procure valves and fitting | 2015-03-18 → 2015-03-06 (-12d) | 2015-04-14 → 2015-04-02 (-12d) | 29d → 37d |
| 24264695 | Transfer load from Temporary legs to Outer Legs and Remove Temp legs | 2015-03-23 → 2015-03-11 (-12d) | 2015-03-24 → 2015-03-12 (-12d) | 17d → 25d |
| 24264700 | Install Heat Shield on other 8 Hex Ring beams | 2015-03-25 → 2015-03-13 (-12d) | 2015-04-03 → 2015-03-24 (-10d) | 17d → 25d |
| 24264705 | Connect all Heat Shield cooling tubes | 2015-04-06 → 2015-03-25 (-12d) | 2015-04-08 → 2015-03-27 (-12d) | 17d → 25d |
| 24264710 | Pressure and Leak test all 80K cooling lines | 2015-04-09 → 2015-03-30 (-10d) | 2015-04-10 → 2015-03-31 (-10d) | 17d → 25d |
| 24264715 | Insulate All 80K Surfaces | 2015-04-13 → 2015-04-01 (-12d) | 2015-04-20 → 2015-04-08 (-12d) | 17d → 25d |
| 24264762C | TORUS CRYO WARM PIPING-Install New Piping | 2015-04-15 → 2015-04-03 (-12d) | 2015-04-28 → 2015-04-16 (-12d) | 29d → 37d |
| 24264868 | Design and install HTCC gas system | 2015-04-08 → 2015-04-07 (-1d) | 2015-08-14 → 2015-08-13 (-1d) | 77d → 78d |
| 24264720 | Install VJ on other 8 Hex Ring Beams | 2015-04-21 → 2015-04-09 (-12d) | 2015-04-30 → 2015-04-20 (-10d) | 17d → 25d |

| ID | Task | Start | Finish | Duration | Complete | Total float | Predecessors |
| --- | --- | --- | --- | --- | --- | --- | --- |
| 24264762D | TORUS CRYO WARM PIPING-Leak Test new Piping | 2015-04-29 → 2015-04-17 (-12d) | 2015-05-04 → 2015-04-22 (-12d) |  |  | 29d → 37d |  |
| 24264723 | Install insulation and shield and VJ at central Hub | 2015-05-01 → 2015-04-21 (-10d) | 2015-05-06 → 2015-04-24 (-12d) |  |  | 17d → 25d |  |
| 24264762F | TORUS CRYO WARM PIPING-Pressure Test Piping | 2015-05-05 → 2015-04-23 (-12d) | 2015-05-05 → 2015-04-23 (-12d) |  |  | 29d → 37d |  |
| 24264762G | TORUS CRYO WARM PIPING-Final Leak Test system | 2015-05-06 → 2015-04-24 (-12d) | 2015-05-11 → 2015-04-29 (-12d) |  |  | 29d → 37d |  |
| 24264065M | LTCC - Last 3 units Ready for Installation | 2015-02-11 → 2015-04-27 (+75d) | 2015-02-11 → 2015-04-27 (+75d) |  |  | 185d → 132d |  |
| 24264725 | Install VJ between Coils at Hub | 2015-05-07 → 2015-04-27 (-10d) | 2015-05-14 → 2015-05-04 (-10d) |  |  | 17d → 25d |  |
| 24264762H | TORUS CRYO WARM PIPING-Purify System | 2015-05-12 → 2015-04-30 (-12d) | 2015-05-14 → 2015-05-04 (-10d) |  |  | 29d → 37d |  |
| 24264730 | Transfer All Cold Mass Loads to VJ | 2015-05-15 → 2015-05-05 (-10d) | 2015-05-18 → 2015-05-06 (-12d) |  |  | 17d → 25d |  |
| 24264460 | Transport and Install LTCC | 2015-02-20 → 2015-05-06 (+75d) | 2015-03-05 → 2015-05-19 (+75d) |  |  | 185d → 132d |  |
| 24264735 | Align VJ to Beam Line | 2015-05-19 → 2015-05-07 (-12d) | 2015-05-20 → 2015-05-08 (-12d) |  |  | 17d → 25d |  |
| 24264740 | Align Cold Mass to VJ and Beam Line | 2015-05-21 → 2015-05-11 (-10d) | 2015-05-22 → 2015-05-12 (-10d) |  |  | 17d → 25d |  |
| 24264755 | Close up all cold mass view ports and temporary CCM support ports | 2015-05-26 → 2015-05-13 (-13d) | 2015-05-29 → 2015-05-18 (-11d) |  |  | 17d → 25d |  |
| 24264760 | TORUS CRYO WARM PIPING-Install Vacuum pumping system | 2015-06-02 → 2015-05-19 (-14d) | 2015-06-03 → 2015-05-20 (-14d) |  |  | 17d → 25d |  |
| 24264465 | Survey (as found location) LTCC positions | 2015-03-06 → 2015-05-20 (+75d) | 2015-03-10 → 2015-05-22 (+73d) |  |  | 185d → 132d |  |
| 24264765 | Pump VJ, leak and pressure test | 2015-06-04 → 2015-05-21 (-14d) | 2015-06-17 → 2015-06-05 (-12d) |  |  | 17d → 25d |  |
| 24264470 | Cable/test/repair LTCC's | 2015-03-10 → 2015-05-22 (+73d) | 2015-03-17 → 2015-06-02 (+77d) |  |  | 195d → 142d |  |
| 24264490 | Transport and Install TOF Panel 2 and align relative to panel 1a | 2015-03-11 → 2015-05-26 (+76d) | 2015-03-18 → 2015-06-03 (+77d) |  |  | 185d → 132d |  |
| 24264495 | Final Survey TOF panel 2's Positions | 2015-03-19 → 2015-06-04 (+77d) | 2015-03-23 → 2015-06-08 (+77d) |  |  | 185d → 132d |  |
| 24264770 | Install mounting adapters for drift chambers | 2015-06-18 → 2015-06-08 (-10d) | 2015-07-01 → 2015-06-19 (-12d) |  |  | 17d → 25d |  |
| 24264500 | Cable/test/repair Panel 2 TOFs | 2015-03-24 → 2015-06-09 (+77d) | 2015-03-31 → 2015-06-16 (+77d) |  |  | 185d → 132d |  |
| 24264080M | HTCC Ready for Installation | 2015-04-20 → 2015-06-22 (+63d) | 2015-04-20 → 2015-06-22 (+63d) |  |  | 157d → 114d |  |
| 24264775 | Connect instrumentation and Leads | 2015-07-02 → 2015-06-22 (-10d) | 2015-07-09 → 2015-06-26 (-13d) |  |  | 17d → 25d |  |
| 24264780 | Connect Torus cryo lines | 2015-07-10 → 2015-06-29 (-11d) | 2015-07-13 → 2015-06-30 (-13d) |  |  | 17d → 25d |  |
| 24264886 | Install DC HV/LV Racks and cable trays | 2015-07-16 → 2015-07-15 (-1d) | 2015-08-14 → 2015-08-13 (-1d) |  |  | 49d → 50d |  |
| 24264882 | Install DC signal cable trays and gas lines | 2015-09-03 → 2015-09-02 (-1d) | 2015-10-22 → 2015-10-21 (-1d) |  |  | 49d → 50d |  |
| 24264884 | Route DC Signal Cables | 2015-09-03 → 2015-09-02 (-1d) | 2015-10-22 → 2015-10-21 (-1d) |  |  | 49d → 50d |  |
| 24264788M | Torus Assembled and Tested | 2015-10-01 → 2015-09-21 (-10d) | 2015-10-01 → 2015-09-21 (-10d) |  |  | 17d → 25d |  |
| 24264960M | Start Installation of Drift Chambers | 2015-10-01 → 2015-09-21 (-10d) | 2015-10-01 → 2015-09-21 (-10d) |  |  | 17d → 25d |  |
| 24264965 | Install Region 2 Drift Chamber | 2015-10-09 → 2015-09-29 (-10d) | 2015-10-22 → 2015-10-12 (-10d) |  |  | 17d → 25d |  |
| 24264798M | Start Installation of Solenoid | 2015-01-13 → 2015-10-05 (+265d) | 2015-01-13 → 2015-10-05 (+265d) |  |  | 91d → -93d |  |
| 24264800 | Receive and inspect solenoid magnet from Vendor | 2015-01-13 → 2015-10-05 (+265d) | 2015-01-15 → 2015-10-07 (+265d) |  |  | 91d → -93d |  |
| 24264805 | Install Solenoid cart | 2015-01-13 → 2015-10-05 (+265d) | 2015-01-13 → 2015-10-05 (+265d) |  |  | 93d → -91d |  |
| 24264970 | Survey/align R2 Drift chambers | 2015-10-16 → 2015-10-06 (-10d) | 2015-10-22 → 2015-10-12 (-10d) |  |  | 17d → 25d |  |
| 24264810 | Assemble Solenoid and Piping | 2015-01-16 → 2015-10-08 (+265d) | 2015-02-27 → 2015-11-18 (+264d) |  |  | 91d → -93d |  |
| 24264975 | Install Region 1 Drift Chamber | 2015-10-22 → 2015-10-12 (-10d) | 2015-11-04 → 2015-10-23 (-12d) |  |  | 17d → 25d |  |
| 24264980 | Survey/align R1 Drift chambers | 2015-10-27 → 2015-10-15 (-12d) | 2015-11-02 → 2015-10-21 (-12d) |  |  | 17d → 25d |  |
| 24264985 | Install Region 3 Drift Chamber | 2015-11-02 → 2015-10-21 (-12d) | 2015-11-13 → 2015-11-03 (-10d) |  |  | 17d → 25d |  |
| 24264870 | Rig and Transport HTCC to Hall | 2015-11-03 → 2015-10-22 (-12d) | 2015-11-04 → 2015-10-23 (-12d) |  |  | 20d → 28d |  |
| 24264872 | Install HTCC cart | 2015-11-05 → 2015-10-26 (-10d) | 2015-11-10 → 2015-10-29 (-12d) |  |  | 20d → 28d |  |
| 24264990 | Survey/align R3 Drift chambers | 2015-11-06 → 2015-10-27 (-10d) | 2015-11-12 → 2015-11-02 (-10d) |  |  | 17d → 25d |  |
| 24264995 | Connect / Cable Drift Chambers | 2015-11-13 → 2015-11-03 (-10d) | 2015-11-30 → 2015-11-16 (-14d) |  |  | 17d → 25d |  |
| 24264815 | Solenoid instrumentation and current leads | 2015-07-06 → 2015-11-18 (+135d) | 2015-07-17 → 2015-12-03 (+139d) |  |  | 3d → -93d |  |
| 24264820 | Align Solenoid | 2015-07-17 → 2015-12-03 (+139d) | 2015-07-20 → 2015-12-04 (+137d) |  |  | 3d → -93d |  |
| 24264825 | Connect Solenoid Cryo lines | 2015-07-21 → 2015-12-07 (+139d) | 2015-08-17 → 2016-01-12 (+148d) |  |  | 3d → -93d |  |
| 24264874 | Install HTCC | 2015-11-11 → 2016-01-11 (+61d) | 2015-11-12 → 2016-01-12 (+61d) |  |  | 20d → -14d |  |
| 24264876 | HTCC verify mirror alignment and align detector to beam | 2015-11-13 → 2016-01-13 (+61d) | 2015-11-17 → 2016-01-15 (+59d) |  |  | 20d → -14d |  |
| 24264878 | Cable HTCC | 2015-11-18 → 2016-01-19 (+62d) | 2015-11-23 → 2016-01-22 (+60d) |  |  | 20d → -14d |  |
| 24264845 | Mount, assemble and cable CTOF system | 2015-10-05 → 2016-03-01 (+148d) | 2015-11-06 → 2016-04-04 (+150d) |  |  | 3d → -93d |  |
| 24264850 | Align CTOF | 2015-11-09 → 2016-04-05 (+148d) | 2015-11-13 → 2016-04-11 (+150d) |  |  | 3d → -93d |  |
| 24264855 | Mount, cable and check SVT system | 2015-11-13 → 2016-04-11 (+150d) | 2015-12-07 → 2016-04-29 (+144d) |  |  | 3d → -93d |  |
| 24264860 | Align SVT | 2015-12-07 → 2016-04-29 (+144d) | 2015-12-18 → 2016-05-12 (+146d) |  |  | 3d → -93d |  |
| 24264860M | Central Detector Ready | 2015-12-18 → 2016-05-12 (+146d) | 2015-12-18 → 2016-05-12 (+146d) |  |  | 3d → -93d |  |
| 7 | **1.4.2.7 HALL B MAGNETS** | 2011-12-01 → 2011-12-03 (+2d) | 2015-09-30 → 2015-11-02 (+33d) |  |  |  |  |
| 1 | **1.4.2.7.1 TOROIDAL MAGNET NEW VENDOR** | 2011-12-01 → 2011-12-03 (+2d) | 2014-09-30 → 2014-10-31 (+31d) |  |  |  |  |
| 14271000 | Procure Replacement Copper | 2011-12-01 → 2011-12-03 A (+2d) | 2012-02-03 → 2011-12-19 A (-46d) | 40d → 11d | 0% → 100% | 662d → none |  |
| 14271005 | JLab Design and Support Labor FY12 | 2012-06-01 A | 2012-09-28 A |  | 0% → 100% | 397d → none |  |
| 14271015 | FNAL: Kickoff Meeting | 2012-06-01 A | 2012-06-05 A |  | 0% → 100% | 20d → none |  |
| 14271020 | FNAL: Discussions on Manufacturing possibilities | 2012-06-01 A | 2012-06-18 → 2012-06-17 A (-1d) | 11d → 10d | 0% → 100% | 20d → none | 14273003 FS-86d, 14273012 FS-270d, 14273010 FS-86d, 14271015 FS-2d, 14273014B FS-135d, 9-120M FS+77d, 14273010K FS-270d → 14273010 FS-86d, 14271015 FS-10d, 14273014B FS-135d, 14273010K FS-270d, 14273012 FS-270d |
| 14271025 | FNAL: Acceptance of Proposal for fabrication | 2012-06-01 A | 2012-06-19 → 2012-08-13 A (+55d) | 12d → 51d | 0% → 100% | 20d → none |  |
| 14271025A | FNAL: Overview of Wang NMR CCM Design | 2012-06-01 A | 2012-06-19 → 2012-08-20 A (+62d) | 12d → 56d | 0% → 100% | 20d → none |  |
| 14271025B | FNAL: Develop CCM fabrication and QA/QC plans | 2012-06-01 A | 2012-07-18 → 2013-02-18 A (+215d) | 33d → 148d | 0% → 100% | 20d → none |  |
| 14271025C | FNAL: Design of CCM Tooling | 2012-06-01 A | 2012-08-31 → 2013-02-18 A (+171d) | 65d → 182d | 0% → 100% | 20d → none |  |
| 14271025D | FNAL: Tooling Installation at FNAL | 2012-06-01 A | 2012-09-28 → 2013-08-30 A (+336d) | 84d → 224d | 0% → 100% | 20d → none | 14271025C FS-65d, 14271026 FS-90d → 14271025C FS-65d, 14271026 FS-105d |
| 14271025F | FNAL: Manufacturing Readiness Review | 2012-06-01 A | 2012-09-28 → 2013-08-30 A (+336d) | 84d → 213d | 0% → 100% | 20d → none | 14271025D FS-84d → 14271025D FS-100d |
| 14271025G | FNAL: Prototype CCM winding and tests | 2012-06-01 A | 2012-12-31 → 2013-08-30 A (+242d) | 143d → 242d | 0% → 100% | 20d → none | 14271025F FS-84d → 14271025F FS-90d |
| 14271025H | FNAL: Update design with lessons learned from prototype | 2012-06-01 A | 2013-01-31 → 2013-08-30 A (+211d) | 164d → 285d | 0% → 100% | 20d → none |  |
| 14271025J | FNAL: Production CCM readiness review | 2012-06-01 A | 2013-01-31 → 2013-08-30 A (+211d) | 164d → 286d | 0% → 100% | 20d → none |  |
| 14271025K | FNAL: Production final CCM#1 and test | 2012-06-01 A | 2013-04-30 → 2013-08-30 A (+122d) | 226d → 312d | 0% → 100% | 20d → none |  |
| 14271025L | FNAL: Production final CCM#2 and test | 2012-06-01 A | 2013-05-31 → 2013-08-30 A (+91d) | 248d → 343d | 0% → 100% | 20d → none |  |
| 14271025N | FNAL: Production final CCM#3 and test | 2012-06-01 A | 2013-07-31 → 2013-08-30 A (+30d) | 290d → 379d | 0% → 100% | 20d → none |  |

| ID | Task | Start | Finish | Duration | Complete | Total float | Predecessors | Other |
| --- | --- | --- | --- | --- | --- | --- | --- | --- |
| 14271025P | FNAL: Production final CCM#4 and test | 2012-06-01 A | 2013-07-31 → 2013-08-30 A (+30d) | 290d → 394d | 0% → 100% | 20d → none |  |  |
| 14271025Q | FNAL: Production final CCM#5 and test | 2012-06-01 A | 2013-08-30 A | 312d → 413d | 0% → 100% | 20d → none |  |  |
| 14271027LOE | JLab support of FNAL Torus CCM effort FY12 | 2012-06-01 A | 2012-09-28 A |  | 0% → 100% | 573d → none |  |  |
| 14271010 | JLab Design and Support Labor FY13 Original | 2012-10-01 A | 2012-12-31 A | 59d → 248d | 0% → 100% | 397d → none |  | resources MECH ENG [587.13 h] → MECH ENG [587.1 h] |
| 14271028LOE | JLab support of FNAL Torus CCM effort FY13 Original | 2012-10-01 A | 2012-12-31 A | 59d → 248d | 0% → 100% | 573d → none |  |  |
| 14271012 | JLab Design and Support Labor FY13 Revised | 2013-01-02 → 2012-12-03 A (-30d) | 2013-02-28 → 2013-02-27 A (-1d) |  | 0% → 100% | 397d → none |  |  |
| 14271028LOEA | JLab support of FNAL Torus CCM effort FY13 Revised | 2013-01-02 A | 2013-08-30 A | 169d → 189d | 0% → 100% | 573d → none |  |  |
| 14271026 | JLab Fabrication of Tooling | 2012-06-22 → 2013-02-04 A (+227d) | 2012-09-28 → 2013-08-30 A (+336d) |  | 0% → 100% | 26d → none | 9-120M FS+177d → 9-130M FS+10d, 9-120M FS+240d |  |
| 14271030 | Machine Shop Effort FY13 | 2012-10-01 → 2013-03-01 A (+151d) | 2013-08-30 A | 228d → 205d | 0% → 100% | 20d → none |  |  |
| 14271040 | Cryostat Factory Phase 1 | 2013-01-03 → 2013-03-01 A (+57d) | 2013-03-29 → 2013-08-30 A (+154d) |  | 0% → 100% | 20d → none |  | resources MECH ENG [1850.95 h]; MECH DES [1347.19 h]; MECH TECH [1460.26 h] → MECH TECH [1460.26 h]; MECH ENG [1850.95 h]; MECH DES [1347.19 h] |
| 14271045 | Cryostat Factory Phase 2 | 2013-04-01 → 2013-08-30 A (+151d) | 2013-08-30 A | 108d → 128d | 0% → 100% | 20d → none |  |  |
| 14271085 | Re-Baseline Actuals Adjustment | 2013-08-30 A | 2013-08-30 A |  | 0% → 100% | 20d → none | 9-130M FS+227d → none |  |
| 24271665 | FNAL: Tooling Fabrication and Installation at FNAL Part B | 2013-09-03 A | 2013-09-16 → 2013-10-21 A (+35d) |  | 0% → 100% | 20d → none |  | resources PROCUREMENT<$50K 60 → PROCUREMENT>$50K 69 NO ESCALATION; PROCUREMENT<$50K 60 |
| 24271680 | FNAL: Prototype CCM winding and tests | 2013-09-03 A | 2013-10-21 → 2013-11-27 (+37d) |  | 0% → 90% | 20d → 159d | 24271665 FS-10d, 242751020 FS-80d → 24271665 FS-20d, 242751020 FS-80d | resources PROCUREMENT<$50K 60 NO ESCALATION → PROCUREMENT>$50K 69 NO ESCALATION |
| 24271685 | FNAL: Update design with lessons learned from prototype | 2013-09-03 A | 2013-11-27 → 2013-12-04 (+7d) |  | 0% → 25% | 20d → 144d | 24271680 FS-35d → 24271680 FS-45d | resources PROCUREMENT<$50K 60 NO ESCALATION; PROCUREMENT>$50K 69 NO ESCALATION → PROCUREMENT>$50K 69 NO ESCALATION |
| 24271690 | FNAL: Production CCM readiness review | 2013-09-03 A | 2013-11-27 → 2013-12-04 (+7d) |  |  | 20d → 104d |  |  |
| 24271695 | FNAL: Production final CCM#1 and test | 2013-09-03 A | 2014-04-30 → 2014-04-03 (-27d) |  |  | 20d → 64d |  |  |
| 24271725 LOE | Consultant Fees WS LQ | 2013-09-03 A |  |  | 0% → 16% |  |  |  |
| 24271730 | Existing Coil Case Storage | 2013-09-03 A | 2014-09-30 → 2014-10-31 (+31d) |  |  | 304d → 281d |  |  |
| 24271730LOE | JLab support of FNAL Torus CCM effort FY13 | 2013-09-03 A | 2013-09-30 A |  | 0% → 100% | 72d → none |  |  |
| 24271735 | Contractor Training TW | 2013-09-03 A | 2014-09-30 → 2013-10-21 A (-344d) |  | 0% → 100% | 304d → none |  |  |
| 24271740 | Additional Torus Copper Stabilizer and SSC Cable tests for Coil #7 | 2013-09-03 A | 2013-11-25 → 2014-01-09 (+45d) |  |  | 58d → 96d |  |  |
| 24271735LOE | JLab support of FNAL Torus CCM effort FY14 | 2013-10-01 A |  |  | 0% → 12% |  |  |  |
| 24271700 | FNAL: Production final CCM#2 and test | 2013-10-01 → 2013-11-01 (+31d) | 2014-05-30 → 2014-03-31 (-60d) | 162d → 96d |  | 0d → 80d |  |  |
| 24271705 | FNAL: Production final CCM#3 and test | 2013-10-01 → 2013-11-01 (+31d) | 2014-06-30 → 2014-04-30 (-61d) | 183d → 118d |  | 0d → 77d |  |  |
| 24271710 | FNAL: Production final CCM#4 and test | 2013-10-01 → 2013-11-01 (+31d) | 2014-07-31 → 2014-05-30 (-62d) | 205d → 139d |  | 0d → 73d |  |  |
| 24271715 | FNAL: Production final CCM#5 and test | 2013-10-01 → 2013-11-01 (+31d) | 2014-08-29 → 2014-06-30 (-60d) | 226d → 160d |  | 0d → 63d |  |  |
| 24271720 | FNAL: Production final CCM#6 and test | 2013-10-01 → 2013-11-01 (+31d) | 2014-09-30 → 2014-07-28 (-64d) | 247d → 179d |  | 0d → 45d |  |  |
| 24271740M | FNAL Torus work complete | 2014-09-30 → 2014-07-28 (-64d) | 2014-09-30 → 2014-07-28 (-64d) |  |  | 0d → 45d |  |  |
| 2 | **1.4.2.7.2 SOLENOID MAGNET NEW VENDOR** |  | 2015-09-30 → 2015-11-02 (+33d) |  |  |  |  |  |
| 14271055 | JLab Design and Support Labor FY12 | 2012-06-01 A | 2012-09-28 A |  | 0% → 100% | 20d → none |  |  |
| 14271060 | JLab Design and Support Labor FY13 | 2012-10-01 A | 2013-08-30 A | 228d → 248d | 0% → 100% | 20d → none |  |  |
| 14271068M | Award Solenoid Contract | 2012-11-27 A | 2012-11-27 A |  | 0% → 100% | 20d → none |  |  |
| 14271070 | Vend Fab Solenoid - Peg Point #1 - Preliminary Design Review | 2012-11-27 A | 2013-03-29 → 2013-03-18 A (-11d) |  | 0% → 100% | 20d → none |  |  |
| 14271075 | Vend Fab Solenoid - Peg Point #2 - Intermediate Design Review | 2012-11-27 A | 2013-05-31 → 2013-08-30 A (+91d) |  | 0% → 100% | 20d → none |  |  |
| 14271075a | Vend Fab Solenoid - Peg Point #3 - Final Design Review | 2012-11-27 A | 2013-06-28 → 2013-08-30 A (+63d) |  | 0% → 100% | 20d → none |  |  |
| 14271075c | Vend Fab Solenoid - Peg Point #4 - Winding and Potting Tooling | 2012-11-27 A | 2013-08-30 A |  | 0% → 100% | 20d → none |  |  |
| 14271075b | Vend Fab Solenoid - Final Design Review Incetive Fee | 2012-12-20 → 2013-01-14 A (+25d) | 2013-06-28 → 2013-08-30 A (+63d) | 128d → 112d | 0% → 100% | 20d → none |  |  |
| 14271080 | Machine Shop Effort | 2013-03-04 → 2013-08-30 A (+179d) | 2013-08-30 A | 128d → 148d | 0% → 100% | 324d → none |  |  |
| 14271090 | Re-Baseline Actuals Adjustment | 2013-08-30 A | 2013-08-30 A |  | 0% → 100% | 20d → none | 9-130M FS+227d → none |  |
| 24272075 | Vend Fab Solenoid - Peg Point #2 - Intermediate Design Review | 2013-09-03 A | 2013-10-31 → 2013-09-23 A (-38d) |  | 0% → 100% | 17d → none |  |  |
| 24272075a | Vend Fab Solenoid - Peg Point #3 - Final Design Review | 2013-09-03 A | 2013-12-20 → 2014-03-25 (+95d) |  | 0% → 75% | 17d → 21d |  | resources PROCUREMENT<$50K 60 NO ESCALATION; PROCUREMENT>$50K 69 NO ESCALATION → PROCUREMENT>$50K 69 NO ESCALATION |
| 24272075b | Vend Fab Solenoid - Final Design Review Incetive Fee | 2013-09-03 A | 2013-12-20 → 2014-02-04 (+46d) |  |  | 17d → 38d | 24272075a FS-77d → 24272075a FS-95d | resources PROCUREMENT<$50K 60 NO ESCALATION; PROCUREMENT>$50K 69 NO ESCALATION → PROCUREMENT>$50K 69 NO ESCALATION |
| 24272075c | Vend Fab Solenoid - Peg Point #4 - Winding and Potting Tooling | 2013-09-03 A | 2014-02-28 → 2014-04-02 (+33d) |  |  | 17d → 18d | 24272075b FS-77d, 24272075ba FS-77d → 24272075ba FS-95d, 24272075b FS-77d |  |
| 24272075d | Vend Fab Solenoid - Peg Point #5 - PSMM Fabrication and Testing | 2013-09-03 A | 2014-06-30 → 2014-07-02 (+2d) |  |  | 17d → -2d |  |  |
| 24272075f | Vend Fab Solenoid - MRR Incentive Fee | 2013-09-03 A |  |  |  | 17d → -43d |  |  |
| 24272075g | Vend Fab Solenoid - Peg Point #6 - Coils Wound | 2013-09-03 A | 2014-08-29 → 2014-12-23 (+116d) |  |  | 17d → -86d |  |  |
| 24272075h | Vend Fab Solenoid - Peg Point #7 - Cryostat Materials and Components | 2013-09-03 A |  |  |  | 17d → -104d | 24272075g FS-246d → 24272075g FS-300d |  |
| 24272075j | Vend Fab Solenoid - Peg Point #8 - Cold Mass Materials and Components | 2013-09-03 A | 2014-10-31 → 2014-12-05 (+35d) |  |  | 17d → -147d |  |  |
| 24272075k | Vend Fab Solenoid - Peg Point #9 - Assembly and Test | 2013-09-03 A | 2014-11-26 → 2015-08-31 (+278d) |  |  | 17d → -167d |  |  |
| 24272075n | Vend Fab Solenoid - Delivery Incentive Fee | 2013-09-03 A | 2014-11-26 → 2015-01-12 (+47d) |  |  | 17d → -6d | 24272075k FS-308d → 24272075k FS-500d |  |
| 24272075p | Vend Fab Solenoid - Peg Point #10 - Commissioning and Acceptance Test | 2013-09-03 A | 2015-06-30 → 2015-09-30 (+92d) |  |  | 58d → 55d | 24272075n FS-308d → 24272075n FS-500d |  |
| 24272075q | Vend Fab Solenoid - Peg Point #11 - Final Report and Closeout | 2013-09-03 A | 2015-09-30 → 2015-11-02 (+33d) |  |  | 58d → 55d | 24272075p FS-449d → 24272075p FS-470d |  |
| 24272075r | Vend Fab Solenoid - Peg Point #12 - Shipping Costs | 2013-09-03 A | 2015-09-30 → 2015-11-02 (+33d) |  |  | 58d → 35d |  |  |
| 24272080 | Solenoid Outside Consulting FY13 | 2013-09-03 A |  |  | 0% → 80% |  |  |  |
| 24272405 | Solenoid - Cable Testing | 2013-09-03 A | 2014-02-28 → 2014-04-02 (+33d) |  |  | 453d → 430d |  |  |
| 24272410 | Consultant Fees WS | 2013-09-03 A | 2014-09-30 → 2014-10-31 (+31d) |  | 0% → 70% | 304d → 281d |  |  |
| 24272075ba | De-Obligation of Vend Fab Solenoid - Final Design Review Incetive Fee | 2013-12-20 → 2014-03-25 (+95d) | 2013-12-20 → 2014-03-25 (+95d) |  |  | 17d → 21d |  |  |
| 3 | **1.4.2.7.3 MAGNET INFRASTRUCTURE** | 2011-12-01 → 2011-12-05 (+4d) | 2014-03-31 → 2014-05-01 (+31d) |  |  |  |  |  |
| 14273005 | Set up Solder Production line Procurements | 2011-12-01 → 2011-12-05 A (+4d) | 2012-02-29 → 2012-05-31 A (+92d) | 57d → 120d | 0% → 100% | 645d → none |  |  |
| 14273000 | Set up Solder Production line Labor Original | 2011-12-01 → 2012-01-03 A (+33d) | 2012-01-31 → 2012-03-19 A (+48d) | 37d → 52d | 0% → 100% | 22d → none |  |  |
| 14273003 | Set up Solder Production line Labor Revised | 2012-02-01 → 2012-05-01 A (+90d) | 2012-06-29 → 2012-05-31 A (-29d) | 105d → 22d | 0% → 100% | 22d → none |  |  |
| 14273014 | Design/Build/Install guides and rollers for inlet/outlet of process | 2012-08-01 → 2012-08-06 A (+5d) | 2012-09-28 → 2012-09-17 A (-11d) | 42d → 30d | 0% → 100% | 21d → none |  |  |
| 14273011 | Wave Solder of Torus and Solenoid Magnets Travel FY12 | 2012-08-17 → 2012-08-14 A (-3d) | 2012-09-28 → 2013-02-18 A (+143d) | 30d → 95d | 0% → 100% | 22d → none |  | resources SCIENTIST [84 h]; MECH TECH [168 h]; TRAVEL → TRAVEL; SCIENTIST [84 h]; MECH TECH [168 h] |
| 14273010 | Vend Fab Wave Solder of Torus and Solenoid Magnets Peg Point #1A-Soldering Setup Part A | 2012-07-02 → 2012-08-17 A (+46d) | 2012-07-31 → 2012-10-15 A (+76d) | 22d → 41d | 0% → 100% | 22d → none |  |  |
| 14273010A | Vend Fab Wave Solder of Torus and Solenoid Magnets Peg Point #1-Soldering Setup Part B | 2012-08-17 A | 2012-09-28 → 2013-02-11 A (+136d) | 30d → 92d | 0% → 100% | 22d → none | 14273008 FS-125d, 14273010 FS+12d, 14273007 FS-70d → 14273008 FS-125d, 14273007 FS-65d, 14273010 FS-20d |  |
| 14273010B | Vend Fab Wave Solder of Torus and Solenoid Magnets Peg Point #2-Procurement of Materials and Start of Production | 2012-08-17 A | 2012-10-31 → 2013-03-18 A (+138d) | 53d → 115d | 0% → 100% | 22d → none |  |  |
| 14273010C | Vend Fab Wave Solder of Torus and Solenoid Magnets Peg Point #3-Delivery of Torus Conductor 001 | 2012-08-17 A | 2012-11-30 → 2013-03-18 A (+108d) | 73d → 93d | 0% → 100% | 22d → none |  |  |
| 14273010D | Vend Fab Wave Solder of Torus and Solenoid Magnets Peg Point #4-Delivery of Torus Conductor 002-006 | 2012-08-17 A | 2013-01-31 → 2013-06-17 A (+137d) | 110d → 130d | 0% → 100% | 22d → none |  |  |
| 14273010G | Vend Fab Wave Solder of Torus and Solenoid Magnets Peg Point #5-Delivery of 1st set of Solenoid Conductor Lengths 1-9 | 2012-08-17 A | 2013-03-29 → 2013-08-30 A (+154d) | 150d → 170d | 0% → 100% | 22d → none |  |  |

| ID | Task | Start | Finish | Duration | Complete | Total float | Predecessors | Other |
| --- | --- | --- | --- | --- | --- | --- | --- | --- |
| 14273010H | Vend Fab Wave Solder of Torus and Solenoid Magnets Peg Point #6-Delivery of 2nd set of Solenoid Conductor Lengths 1-9 | 2012-08-17 A | 2013-03-29 → 2013-08-30 A (+154d) | 150d → 170d | 0% → 100% | 22d → none |  |  |
| 14273010J | Vend Fab Wave Solder of Torus and Solenoid Magnets Peg Point #7-Delivery of 3rd set of Solenoid Conductor Lengths 1-9 | 2012-08-17 A | 2013-04-30 → 2013-08-30 A (+122d) | 172d → 192d | 0% → 100% | 22d → none |  |  |
| 14273010K | Vend Fab Wave Solder of Torus and Solenoid Magnets Peg Point #8-Delivery of 4th set of Solenoid Conductor Lengths 1-9 | 2012-08-17 A | 2013-06-28 → 2013-08-30 A (+63d) | 214d → 234d | 0% → 100% | 22d → none |  |  |
| 14273008 | Additional Cu Channel and Wagon wheel spools for Torus | 2012-10-15 → 2012-09-10 A (-35d) | 2013-01-31 → 2012-10-22 A (-101d) | 70d → 31d | 0% → 100% | 37d → none | 9-130M FS+10d → 9-130M |  |
| 14273014B | Unspool/Measure/Respool/Inspect | 2012-10-29 → 2012-09-10 A (-49d) | 2012-12-11 → 2012-12-17 A (+6d) | 30d → 88d | 0% → 100% | 21d → none | 14273014A → 14273014A FS-40d |  |
| 14273007 | Shipping of Coductor to AES | 2012-10-29 → 2012-10-01 A (-28d) | 2012-11-27 → 2013-08-30 A (+276d) | 20d → 63d | 0% → 100% | 22d → none | 9-130M FS+20d → 9-130M |  |
| 14273014A | Dial in the process settings - spooling and traverse speeds, manual control | 2012-10-01 → 2012-12-03 A (+63d) | 2012-10-26 → 2012-12-17 A (+52d) |  | 0% → 100% | 21d → none |  | resources ELEC ENG [10 h]; SR STAFF [16 h]; ELEC TECH [20 h] → ELEC TECH [20 h]; ELEC ENG [10 h]; SR STAFF [16 h] |
| 14273015 | Cryostat Factory Setup | 2012-10-01 → 2012-12-03 A (+63d) | 2012-12-31 → 2012-12-17 A (-14d) | 59d → 16d | 0% → 100% | 189d → none |  |  |
| 14273012 | Wave Solder of Torus and Solenoid Magnets Travel FY13 | 2012-10-01 → 2013-02-11 A (+133d) | 2013-06-28 → 2013-08-30 A (+63d) |  | 0% → 100% | 22d → none |  | resources MECH TECH [576 h]; SCIENTIST [288 h]; TRAVEL → TRAVEL; MECH TECH [576 h]; SCIENTIST [288 h] |
| 14273020 | Re-Baseline Actuals Adjustment | 2013-08-30 A | 2013-08-30 A |  | 0% → 100% | 20d → none | 9-130M FS+227d → none |  |
| 24273010B | Vend Fab Wave Solder of Torus and Solenoid Magnets Peg Point #2-Procurement of Materials and | 2013-09-03 A | 2013-10-31 → 2013-12-05 (+35d) |  |  | 17d → -6d |  | resources PROCUREMENT<$50K 60 NO ESCALATION → PROCUREMENT>$50K 69 NO ESCALATION |
| 24273010H | Vend Fab Wave Solder of Torus and Solenoid Magnets Peg Point #6-Delivery of 2nd set of Solenoid Conductor Lengths 1-9 | 2013-09-03 A | 2014-01-31 → 2014-03-05 (+33d) |  |  | 17d → -26d |  | resources PROCUREMENT<$50K 60 NO ESCALATION; PROCUREMENT>$50K 69 NO ESCALATION → PROCUREMENT>$50K 69 NO ESCALATION |
| 24273010J | Vend Fab Wave Solder of Torus and Solenoid Magnets Peg Point #7-Delivery of 3rd set of Solenoid Conductor Lengths 1-9 | 2013-09-03 A | 2014-02-28 → 2014-04-02 (+33d) |  |  | 17d → -46d |  |  |
| 24273010K | Vend Fab Wave Solder of Torus and Solenoid Magnets Peg Point #8-Delivery of 4th set of Solenoid Conductor Lengths 1-9 | 2013-09-03 A | 2014-03-31 → 2014-05-01 (+31d) |  |  | 17d → -66d |  |  |
| 24273010N | Vend Fab Wave Solder of Torus and Solenoid Magnets Peg Point #9-Additional length and splicing required for Solenoid | 2013-09-03 A | 2014-03-17 → 2014-04-17 (+31d) |  |  | 17d → -26d |  |  |
| 24273010P | Vend Fab Wave Solder of Torus and Solenoid Magnets Peg Point #10-Additional Reels for Solenoid | 2013-09-03 A | 2013-11-27 → 2014-01-13 (+47d) |  |  | 17d → -46d |  |  |
| 24273010Q | Vend Fab Wave Solder of Torus and Solenoid Magnets Peg Point #10-Conductor Cleaning | 2014-02-13 → 2013-09-03 A (-163d) | 2014-03-17 → 2013-09-23 A (-175d) |  | 0% → 100% | 138d → none | 24273010N FS-23d → 24273010N FS-300d |  |
| 24273010R | Vend Fab Wave Solder of Torus and Solenoid Magnets New Scope | 2013-09-03 A | 2014-03-31 → 2014-05-01 (+31d) |  | 0% → 45% | 17d → -66d |  |  |
| 24273012 | Wave Solder of Torus and Solenoid Magnets Travel FY13 | 2013-09-03 A | 2013-09-30 → 2013-12-02 (+63d) |  | 0% → 40% | 452d → 409d |  |  |
| 24273017 | Twente Cable Testing | 2013-09-03 A | 2013-12-20 → 2014-02-04 (+46d) |  |  | 494d → 471d |  |  |
| 24273022 | Additional Cu for solenoid conductor - Procurment | 2013-09-03 A | 2014-03-14 → 2014-04-16 (+33d) |  |  | 443d → 420d |  |  |
| 24273027 | Consultant Fees WS | 2013-09-03 A | 2013-12-20 → 2013-10-21 A (-60d) |  | 0% → 100% | 932d → none |  |  |
| 24273007 | Shipping of Coductor to AES | 2013-09-03 → 2013-10-01 A (+28d) | 2013-10-31 → 2013-10-21 A (-10d) |  | 0% → 100% | 528d → none |  |  |
| 24273012a | Wave Solder of Torus and Solenoid Magnets Travel FY14 | 2013-10-01 → 2013-12-03 (+63d) | 2014-03-03 → 2014-05-01 (+59d) |  |  | 452d → 409d | 9-130M FS+228d, 24273012 → 24273012 |  |
| 4 | **1.4.2.7.4 TORUS CRYOSTAT FACTORY** |  | 2015-07-14 → 2015-08-14 (+31d) |  |  |  |  |  |
| 1 | **1.4.2.7.4.1 DESIGN AND PROCEDURES** |  | 2013-11-15 → 2014-09-30 (+319d) |  |  |  |  |  |
| 142741000 | Re-Baseline Actuals Adjustment | 2013-08-30 A | 2013-08-30 A |  | 0% → 100% | 20d → none | 9-130M FS+227d → none |  |
| 242741010 | Cryostat Factory - Design lifting Fixtures and Procurement Prep (Historical) | 2013-09-03 A | 2013-09-05 → 2013-09-06 A (+1d) |  | 0% → 100% | 199d → none |  |  |
| 242741020 | Cryostat Factory - Perform tests for Torus Design - labor | 2013-09-03 A | 2013-09-16 → 2013-09-14 A (-2d) |  | 0% → 100% | 192d → none |  |  |
| 242741030 | Cryostat Factory - Write, review and sign welding Procedures | 2013-09-03 A | 2013-09-16 → 2013-10-21 A (+35d) |  | 0% → 100% | 192d → none |  |  |
| 242741035 | Cryostat Factory - Write, review and sign Incoming material QA Procedures FY13 | 2013-09-03 A | 2013-09-30 → 2013-10-21 A (+21d) |  | 0% → 100% | 170d → none |  |  |
| 242741035a | Cryostat Factory - Write, review and sign Incoming material QA Procedures FY14 | 2013-10-01 → 2013-09-03 A (-28d) | 2013-10-16 → 2013-10-21 A (+5d) |  | 0% → 100% | 170d → none | 242741035, 9-130M FS+228d → 242741035 FS-20d |  |
| 242741040 | Cryostat Factory - Write, review and sign material handling Procedures FY13 | 2013-09-03 A | 2013-09-30 → 2013-10-21 A (+21d) |  | 0% → 100% | 170d → none |  |  |
| 242741040a | Cryostat Factory - Write, review and sign material handling Procedures FY14 | 2013-10-01 → 2013-09-03 A (-28d) | 2013-10-16 → 2013-10-21 A (+5d) |  | 0% → 100% | 170d → none | 242741040, 9-130M FS+228d → 242741040 FS-20d |  |
| 242741045 | Cryostat Factory - Write, review and sign MLI application Procedures | 2013-09-03 A | 2013-09-16 → 2013-09-14 A (-2d) |  | 0% → 100% | 192d → none |  |  |
| 242741050 | Cryostat Factory - Write, review and sign OSP FY13 | 2013-09-03 A | 2013-09-30 → 2013-11-26 (+57d) |  | 0% → 33% | 148d → 141d |  |  |
| 242741050a | Cryostat Factory - Write, review and sign OSP FY14 | 2013-10-01 → 2013-09-03 A (-28d) | 2013-11-15 → 2013-11-26 (+11d) |  | 0% → 33% | 148d → 141d | 242741050, 9-130M FS+228d → 242741050 FS-40d |  |
| 242741055 | Cryostat Factory - Write, review and sign assembly procedures FY13 | 2013-09-03 A | 2013-09-30 → 2013-11-18 (+49d) |  |  | 170d → 147d |  |  |
| 242741055a | Cryostat Factory - Write, review and sign assembly procedures FY14 | 2013-10-01 → 2013-09-03 A (-28d) | 2013-10-16 → 2013-11-18 (+33d) |  |  | 170d → 147d | 242741055, 9-130M FS+228d → 242741055 FS-20d |  |
| 242741065 | Cryostat Factory - Orderfixtures, tables, tools, etc. for assembly Procurement | 2013-09-03 A | 2013-10-16 → 2014-09-30 (+349d) |  | 0% → 95% | 166d → 208d |  |  |
| 242741070 | Cryostat Stand and Axle | 2013-09-03 A | 2013-10-30 → 2013-10-21 A (-9d) |  | 0% → 100% | 156d → none |  |  |
| 242741070M | Cryostat factory fixtures and tooling in-house | 2013-10-30 → 2013-11-01 (+2d) | 2013-10-30 → 2013-11-01 (+2d) |  |  | 156d → 184d | 242741070, 242741065 → 242741065 FS-248d, 242741070 |  |
| 242741075M | Torus Cryostat Factory Procedures In-place | 2013-11-15 → 2013-11-26 (+11d) | 2013-11-15 → 2013-11-26 (+11d) |  |  | 148d → 141d |  |  |
| 2 | **1.4.2.7.4.2 PROTOTYPE** |  | 2014-07-08 → 2014-06-16 (-22d) |  |  |  |  |  |
| 242742000 | Cryostat Factory - Test Lifting Fixtures and Procedures with Wang Coil Case FY13 | 2013-09-03 A | 2013-09-30 → 2013-10-21 A (+21d) |  | 0% → 100% | 132d → none |  |  |
| 242742015 | Cryostat Factory - Test Lifting Fixtures and Procedures with Wang Coil Case FY14 | 2013-10-01 → 2013-09-03 A (-28d) | 2013-10-16 → 2013-10-21 A (+5d) |  | 0% → 100% | 132d → none | 242742000, 9-130M FS+228d → 242742000 FS-20d |  |
| 242742020 | Cryostat Factory - Engineering oversight (Legg) FY13 | 2013-09-03 A | 2013-09-30 A |  | 0% → 100% | 452d → none |  |  |
| 242742030 | Cryostat Factory - Pre-assembly of CCM using Wang Coil case FY13 | 2013-09-03 A | 2013-09-30 → 2013-10-21 A (+21d) |  | 0% → 100% | 528.5d → none |  |  |
| 242742030a | Cryostat Factory - Pre-assembly of CCM using Wang Coil case FY14 | 2013-10-01 → 2013-09-03 A (-28d) | 2013-10-31 → 2013-11-26 (+26d) |  | 0% → 80% | 528.5d → 510.5d | 242742030, 9-130M FS+228d → 242742030 FS-25d |  |
| 242742005 | Cryostat Factory - Layout Assembly area for equipment and fixtures | 2013-10-03 → 2013-09-16 A (-17d) | 2013-10-09 → 2013-11-11 (+33d) |  | 0% → 40% | 156d → 162d | 242741070M FS-20d → 242741070M FS-25d |  |
| 242742010 | Cryostat Factory - Install equipment and fixtures in factory area | 2013-10-03 → 2013-09-16 A (-17d) | 2013-11-05 → 2013-10-21 A (-15d) |  | 0% → 100% | 156d → none | 242741070M FS-20d, 242742005 FS-5d → 242741070M FS-25d, 242742005 FS-10d |  |
| 242742025 | Cryostat Factory - Mock-up of one quarter CCM | 2013-10-04 → 2013-09-16 A (-18d) | 2014-01-17 → 2014-03-03 (+45d) |  |  | 482d → 452d | 9-140M FS+3d → 9-140M FS-5d |  |
| 242742020a | Cryostat Factory - Engineering oversight (Legg) FY14 | 2013-10-01 A |  |  | 0% → 23% |  | 242742020, 9-130M FS+228d → 242742020 |  |
| 242742080 | Cryostat Factory - Rewrite procedures and lessons learned from Proto | 2013-10-17 A |  |  | 0% → 12% |  | 242742000, 242742015 → 242742000 FS-40d, 242742015 FS-40d |  |
| 242742040 | Cryostat Factory - Initial receipt inspection (QA) of Coil case shields | 2013-11-18 → 2013-11-01 (-17d) | 2014-03-19 → 2014-03-04 (-15d) |  |  | 114d → 125d |  |  |
| 242742045 | Cryostat Factory - Pre-Assemble Seven Coil case shields | 2013-11-18 → 2013-11-01 (-17d) | 2014-04-01 → 2014-03-17 (-15d) |  |  | 114d → 125d |  |  |
| 242742050 | Cryostat Factory - Initial receipt inspection (QA) of Vacuum Vessel Parts | 2013-12-18 → 2013-11-25 (-23d) | 2014-04-21 → 2014-03-31 (-21d) |  |  | 44d → 59d |  |  |
| 242742055 | Cryostat Factory - Pre-Assemble Seven Vacuum Jackets | 2013-12-18 → 2013-11-25 (-23d) | 2014-06-13 → 2014-05-22 (-22d) |  |  | 44d → 59d |  |  |
| 242742015M | Cryostat Factory - Receive parts for proto cryostat | 2014-03-19 → 2014-02-28 (-19d) | 2014-03-19 → 2014-02-28 (-19d) |  |  | 106d → 118d |  |  |
| 242742060M | Cryostat Factory - Receive 1st Article (CCM #1) coil cold case | 2014-04-25 → 2014-03-31 (-25d) | 2014-04-25 → 2014-03-31 (-25d) |  |  | 45d → 64d |  |  |
| 242742065 | Cryostat Factory - Assemble 1st Article (CCM #1) Coil Cryostat with cold mass (Receive, QA and Pre-assembly) | 2014-04-25 → 2014-03-31 (-25d) | 2014-05-19 → 2014-04-22 (-27d) |  |  | 45d → 64d |  |  |
| 242742070 | Cryostat Factory - Assemble 1st Article (CCM #1) Coil Cryostat with cold mass (MLI and LN2 shield assembly) | 2014-05-20 → 2014-04-23 (-27d) | 2014-06-12 → 2014-05-15 (-28d) |  |  | 45d → 64d |  |  |
| 242742075 | Cryostat Factory - Assemble 1st Article (CCM #1) Coil Cryostat with cold mass (Vac jacket weld up) | 2014-06-16 → 2014-05-23 (-24d) | 2014-07-08 → 2014-06-16 (-22d) |  |  | 44d → 59d |  |  |
| 3 | **1.4.2.7.4.3 PRODUCTION** |  | 2015-07-14 → 2015-08-14 (+31d) |  |  |  |  |  |
| 142743000 | Re-Baseline Actuals Adjustment | 2013-08-30 A | 2013-08-30 A |  | 0% → 100% | 20d → none | 9-130M FS+227d → none |  |
| 242743125 | Cryostat Factory - Rework | 2014-02-14 → 2014-01-17 (-28d) | 2015-05-07 → 2015-04-10 (-27d) |  |  | 117d → 136d |  |  |
| 242743005 | Cryostat Factory - Assemble Coil Cryostat #2 with cold mass (Receive, QA and Pre-assembly) | 2014-05-29 → 2014-04-11 (-48d) | 2014-06-27 → 2014-05-12 (-46d) |  |  | 37d → 70d |  | resources SR STAFF [117.33 h]; MECH ENG [234.67 h]; SUPPLIES & MATERIALS; MECH TECH [528 h] → MECH ENG [234.67 h]; SUPPLIES & MATERIALS; MECH TECH [528 h]; SR STAFF [117.33 h] |
| 242743000M | Cryostat Factory - Receive production coil case #2 | 2014-05-30 → 2014-04-14 (-46d) | 2014-05-30 → 2014-04-14 (-46d) |  |  | 37d → 70d |  |  |
| 242743020M | Cryostat Factory - Receive production coil case #3 | 2014-07-03 → 2014-05-05 (-59d) | 2014-07-03 → 2014-05-05 (-59d) |  |  | 35d → 77d |  |  |
| 242743010 | Cryostat Factory - Assemble Coil Cryostat #2 with cold mass (MLI and LN2 shield assembly) | 2014-06-30 → 2014-05-13 (-48d) | 2014-07-23 → 2014-06-05 (-48d) |  |  | 37d → 70d |  |  |

| ID | Task | Start | Finish | Complete | Total float | Predecessors |
| --- | --- | --- | --- | --- | --- | --- |
| 242743025 | Cryostat Factory - Assemble Coil Cryostat #3 with cold mass (Receive, QA and Pre-assembly) | 2014-07-03 → 2014-05-13 (-51d) | 2014-07-28 → 2014-06-05 (-53d) |  | 35d → 71d |  |
| 242743015 | Cryostat Factory - Assemble Coil Cryostat #2 with cold mass (Vac jacket weld up) | 2014-07-24 → 2014-06-06 (-48d) | 2014-08-18 → 2014-07-01 (-48d) |  | 37d → 70d |  |
| 242743030 | Cryostat Factory - Assemble Coil Cryostat #3 with cold mass (MLI and LN2 shield assembly) | 2014-07-29 → 2014-06-06 (-53d) | 2014-08-20 → 2014-06-30 (-51d) |  | 35d → 71d |  |
| 242743040M | Cryostat Factory - Receive production coil case #4 | 2014-08-11 → 2014-06-10 (-62d) | 2014-08-11 → 2014-06-10 (-62d) |  | 30d → 73d |  |
| 242743045 | Cryostat Factory - Assemble Coil Cryostat #4 with cold mass (Receive, QA and Pre-assembly) | 2014-08-11 → 2014-06-10 (-62d) | 2014-08-29 → 2014-06-30 (-60d) |  | 30d → 73d |  |
| 242743050 | Cryostat Factory - Assemble Coil Cryostat #4 with cold mass (MLI and LN2 shield assembly) | 2014-09-02 → 2014-07-01 (-63d) | 2014-09-22 → 2014-07-22 (-62d) |  | 30d → 73d |  |
| 242743035 | Cryostat Factory - Assemble Coil Cryostat #3 with cold mass (Vac jacket weld up) | 2014-08-21 → 2014-07-02 (-50d) | 2014-09-15 → 2014-07-25 (-52d) |  | 35d → 70d |  |
| 242743060M | Cryostat Factory - Receive production coil case #5 | 2014-09-16 → 2014-07-16 (-62d) | 2014-09-16 → 2014-07-16 (-62d) |  | 20d → 63d |  |
| 242743065 | Cryostat Factory - Assemble Coil Cryostat #5 with cold mass (Receive, QA and Pre-assembly) | 2014-09-16 → 2014-07-16 (-62d) | 2014-10-06 → 2014-08-05 (-62d) |  | 20d → 63d |  |
| 242743055 | Cryostat Factory - Assemble Coil Cryostat #4 with cold mass (Vac jacket weld up) | 2014-09-23 → 2014-07-28 (-57d) | 2014-10-13 → 2014-08-15 (-59d) |  | 30d → 70d |  |
| 242743070 | Cryostat Factory - Assemble Coil Cryostat #5 with cold mass (MLI and LN2 shield assembly) | 2014-10-07 → 2014-08-06 (-62d) | 2014-10-27 → 2014-08-26 (-62d) |  | 20d → 63d |  |
| 242743080M | Cryostat Factory - Receive production coil case #6 | 2014-10-15 → 2014-08-12 (-64d) | 2014-10-15 → 2014-08-12 (-64d) |  | 17d → 62d |  |
| 242743085 | Cryostat Factory - Assemble Coil Cryostat #6 with cold mass (Receive, QA and Pre-assembly) | 2014-10-15 → 2014-08-12 (-64d) | 2014-11-04 → 2014-09-02 (-63d) |  | 17d → 62d |  |
| 242743075 | Cryostat Factory - Assemble Coil Cryostat #5 with cold mass (Vac jacket weld up) | 2014-10-28 → 2014-08-27 (-62d) | 2014-11-17 → 2014-09-17 (-61d) |  | 20d → 63d |  |
| 242743090 | Cryostat Factory - Assemble Coil Cryostat #6 with cold mass (MLI and LN2 shield assembly) | 2014-11-05 → 2014-09-03 (-63d) | 2014-11-25 → 2014-09-23 (-63d) |  | 17d → 62d |  |
| 242743095 | Cryostat Factory - Assemble Coil Cryostat #6 with cold mass (Vac jacket weld up) | 2014-11-26 → 2014-09-24 (-63d) | 2014-12-18 → 2014-10-14 (-65d) |  | 17d → 62d |  |
| 242743100M | Cryostat Factory - Receive production coil case #7 | 2015-04-10 → 2015-05-13 (+33d) | 2015-04-10 → 2015-05-13 (+33d) |  | 72d → 49d |  |
| 242743105 | Cryostat Factory - Assemble Coil Cryostat #7 with cold mass (Receive, QA and Pre-assembly) | 2015-04-10 → 2015-05-13 (+33d) | 2015-04-30 → 2015-06-04 (+35d) |  | 72d → 49d |  |
| 242743110 | Cryostat Factory - Assemble Coil Cryostat #7 with cold mass (MLI and LN2 shield assembly) | 2015-05-01 → 2015-06-05 (+35d) | 2015-05-21 → 2015-06-25 (+35d) |  | 72d → 49d |  |
| 242743120 | Cryostat Factory - Clean up And ship to site | 2015-05-15 → 2015-06-19 (+35d) | 2015-07-14 → 2015-08-14 (+31d) |  | 72d → 49d |  |
| 242743115 | Cryostat Factory - Assemble Coil Cryostat #7 with cold mass (Vac jacket weld up) | 2015-05-22 → 2015-06-26 (+35d) | 2015-06-15 → 2015-07-17 (+32d) |  | 72d → 49d |  |
| 142751000 | Re-Baseline Actuals Adjustment | 2013-08-30 A | 2013-08-30 A | 0% → 100% | 20d → none | 9-130M FS+227d → none |
| 242751000LOE | Torus - Engineering Oversight FY13 | 2013-09-03 A | 2013-09-30 A | 0% → 100% | 420d → none |  |
| 242751010 | Vend Fab Additional Coil Case for Coil # 7 | 2013-09-03 A | 2014-03-31 → 2014-05-01 (+31d) |  | 326d → 303d |  |
| 242751020 | Torus - 1st Article Coil Case Procurement | 2013-09-03 A | 2013-09-16 A | 0% → 100% | 90d → none |  |
| 242751045 | Torus - 6 Production Coil Cases Procurement | 2013-09-03 A | 2014-03-31 → 2014-05-01 (+31d) | 0% → 55% | 20d → 84d |  |
| 242751050 | Torus - 4K MLI Modeling and Drafting | 2013-09-03 A | 2013-09-16 → 2013-10-21 A (+35d) | 0% → 100% | 101d → none |  |
| 242751080 | Torus - Vacuum Vessel Instrumentation Drafting | 2013-09-03 A | 2013-09-30 → 2013-12-13 (+74d) | 0% → 50% | 44d → 70d |  |
| 242751110 | Torus - Coil Case Shields Procurement Prep FY13 | 2013-09-03 A | 2013-09-30 → 2013-10-21 A (+21d) | 0% → 100% | 114d → none |  |
| 242751110a | Torus - Coil Case Shields Procurement Prep FY14 | 2013-10-01 → 2013-09-03 A (-28d) | 2013-11-01 → 2013-10-21 A (-11d) | 0% → 100% | 114d → none | 9-130M FS+228d, 242751110 → 242751110 FS-30d |
| 242751120 | Torus - Coil Case MLI Procurement Prep FY13 | 2013-09-17 → 2013-09-03 A (-14d) | 2013-09-30 → 2013-11-15 (+46d) | 0% → 50% |  | 242751050 → 242751050 FS-10d |
| 242751120a | Torus - Coil Case MLI Procurement Prep FY14 | 2013-10-01 → 2013-09-03 A (-28d) |  | 0% → 50% |  | 242751050, 242751120 → 242751120 FS-35d |
| 242751155 | Torus - Cold Hub - Hub analysis with off design loads | 2013-09-03 A | 2013-09-16 → 2013-09-23 A (+7d) | 0% → 100% | 59d → none |  |
| 242751160 | Torus - Cold Hub - Hub Shield Modeling FY13 | 2013-09-03 A | 2013-09-30 → 2013-11-15 (+46d) | 0% → 50% | 70d → 113d |  |
| 242751160a | Torus - Cold Hub - Hub Shield Modeling FY14 | 2013-10-01 → 2013-09-03 A (-28d) |  | 0% → 50% | 70d → 113d | 242751160, 242751155 FS-10d → 242751160 FS-40d |
| 242751165 | Torus - Cold Hub - Hub Shield straping for cooling design FY13 | 2013-09-03 A | 2013-09-30 → 2013-11-27 (+58d) | 0% → 50% |  |  |
| 242751165a | Torus - Cold Hub - Hub Shield straping for cooling design FY14 | 2013-10-01 → 2013-09-03 A (-28d) |  | 0% → 50% |  | 242751160 FS-54d, 242751165, 242751160a FS-54d → 242751165 FS-45d, 242751160a FS-54d |
| 242751185 | Torus - Upstream Hex - 4K Beam Stress Analysis | 2013-09-03 A | 2013-09-13 → 2013-10-21 A (+38d) | 0% → 100% | 91d → none |  |
| 242751190 | Torus - Upstream Hex - Piping mounting design FY13 | 2013-09-17 → 2013-09-03 A (-14d) | 2013-09-30 → 2014-01-31 (+123d) | 0% → 50% | 59d → 25d |  |
| 242751190a | Torus - Upstream Hex - Piping mounting design FY14 | 2013-10-01 → 2013-09-03 A (-28d) | 2013-10-21 → 2014-01-31 (+102d) | 0% → 50% | 59d → 25d | 242751190, 242751155 → 242751190 FS-60d |
| 242751195 | Torus - Upstream Hex - Coil to Coil lead force analysis and flexibility analysis | 2013-09-03 A | 2013-09-27 → 2013-09-16 A (-11d) | 0% → 100% | 91d → none | 242751190a FS-35d, 242751190 FS-35d, 242751185 FS-9d → 242751190 FS-80d, 242751185 FS-9d, 242751190a FS-80d |
| 242751200 | Torus - Upstream Hex - Recooler final design FY13 | 2013-09-03 A | 2013-09-30 → 2013-11-15 (+46d) | 0% → 50% | 91d → 95d | 242751195 FS-19d → 242751195 FS-60d |
| 242751200a | Torus - Upstream Hex - Recooler final design FY14 | 2013-10-01 → 2013-09-03 A (-28d) | 2013-11-01 → 2013-11-15 (+14d) | 0% → 50% | 91d → 95d | 242751200, 242751195 FS-19d → 242751200 FS-45d |
| 242751205 | Torus - Upstream Hex - Recooler Mounting FY13 | 2013-09-03 A | 2013-09-30 → 2013-11-15 (+46d) | 0% → 50% | 91d → 72d |  |
| 242751205a | Torus - Upstream Hex - Recooler Mounting FY14 | 2013-10-01 → 2013-09-03 A (-28d) | 2013-11-01 → 2013-11-15 (+14d) | 0% → 50% | 91d → 72d | 242751200 FS-44d, 242751205, 242751200a FS-44d → 242751205 FS-40d, 242751200a FS-44d |
| 242751215 | Torus - Upstream Hex - Splice design and tooling design FY13 | 2013-09-03 A | 2013-09-30 → 2013-11-15 (+46d) | 0% → 50% | 91d → 39d |  |
| 242751215a | Torus - Upstream Hex - Splice design and tooling design FY14 | 2013-10-01 → 2013-09-03 A (-28d) |  | 0% → 50% | 91d → 39d | 242751205a FS-44d, 242751205 FS-44d, 242751215 → 242751215 FS-40d, 242751205a FS-44d |
| 242751220 | Torus - Upstream Hex - Piping flexibility analysis | 2013-09-03 A | 2013-09-27 → 2013-09-23 A (-4d) | 0% → 100% | 59d → none |  |
| 242751345 | Torus - Main Cold mass support system - Supports Analyses | 2013-09-03 A | 2013-09-30 → 2013-09-23 A (-7d) | 0% → 100% | 25d → none |  |
| 242751350 | Torus - Main Cold mass support system - Supports Modeling FY13 | 2013-09-03 A | 2013-09-30 → 2013-12-02 (+63d) | 0% → 50% | 25d → 137d |  |
| 242751350a | Torus - Main Cold mass support system - Supports Modeling FY14 | 2013-10-01 → 2013-09-03 A (-28d) | 2013-10-28 → 2013-12-02 (+35d) | 0% → 50% | 25d → 137d | 242751345 FS-20d, 242751350 → none |
| 242751355 | Torus - Main Cold mass support system - Supports Drafting FY13 | 2013-09-03 A | 2013-09-30 → 2013-12-02 (+63d) | 0% → 50% | 25d → 117d |  |
| 242751355a | Torus - Main Cold mass support system - Supports Drafting FY14 | 2013-10-01 → 2013-09-03 A (-28d) | 2013-10-28 → 2013-12-02 (+35d) | 0% → 50% | 25d → 117d | 242751350 FS-40d, 242751355, 242751350a FS-40d → 242751355 FS-20d, 242751350a FS-40d |
| 242751425 | Torus - LOV analyses - 4K piping analysis FY13 | 2013-09-03 A | 2013-09-30 → 2013-12-13 (+74d) | 0% → 50% | 521d → 523d |  |
| 242751425a | Torus - LOV analyses - 4K piping analysis FY14 | 2013-10-01 → 2013-09-03 A (-28d) | 2013-11-08 → 2013-12-13 (+35d) | 0% → 50% | 521d → 523d | 9-130M FS+228d, 242751425 → 242751425 FS-30d |
| 242751430 | Torus - LOV analyses - LN2 Piping FY13 | 2013-09-10 → 2013-09-03 A (-7d) | 2013-09-30 → 2013-12-16 (+77d) | 0% → 50% | 521d → 508d |  |
| 242751430a | Torus - LOV analyses - LN2 Piping FY14 | 2013-10-01 → 2013-09-03 A (-28d) | 2013-11-11 → 2013-12-16 (+35d) | 0% → 50% | 521d → 508d | 242751430, 242751425a FS-44d, 242751425 FS-44d → 242751425a FS-44d, 242751430 FS-30d |
| 242751435 | Torus - LOV analyses - Service module FY13 | 2013-09-17 → 2013-09-03 A (-14d) | 2013-09-30 → 2013-12-16 (+77d) | 0% → 50% | 521d → 498d |  |
| 242751435a | Torus - LOV analyses - Service module FY14 | 2013-10-01 → 2013-09-03 A (-28d) | 2013-11-11 → 2013-12-16 (+35d) | 0% → 50% | 521d → 498d | 242751430a FS-40d, 242751435, 242751430 FS-40d → 242751435 FS-30d, 242751430a FS-40d |
| 242751445 | Torus - Engineering Procured Labor Phase 1 | 2013-09-03 A | 2013-09-30 → 2013-12-02 (+63d) | 0% → 10% | 410d → 367d |  |
| 242751150 | Torus - Cold Hub - Magnet construction analysis | 2013-10-15 → 2013-09-09 A (-36d) |  |  |  | 9-140M FS+10d → 9-140M |
| 242751360 | Torus - Main Cold mass support system - Attachment to Floor Engineering | 2013-12-12 → 2013-09-16 A (-87d) | 2014-01-13 → 2013-11-21 (-53d) | 0% → 50% | 25d → 97d | 242751355a FS+30d, 242751355 FS+30d → 242751355 FS-40d, 242751355a FS-40d |
| 242751365 | Torus - Main Cold mass support system - Attachment to Floor Modeling and Drafting | 2014-01-14 → 2013-09-16 A (-120d) | 2014-02-03 → 2013-11-20 (-75d) | 0% → 50% | 25d → 92d | 242751360 → 242751360 FS-20d |
| 242751390 | Torus - Installation Design - Develop Installation Tooling Design | 2014-01-02 → 2013-09-16 A (-108d) | 2014-02-28 → 2014-01-10 (-49d) |  | 25d → 84d |  |
| 242751395 | Torus - Installation Design - Model Installation Tooling | 2014-02-03 → 2013-09-16 A (-140d) | 2014-02-28 → 2013-12-02 (-88d) |  | 25d → 80d | 242751390 FS-20d → 242751390 FS-45d |
| 242751400 | Torus - Installation Design - Analyze Installation Tooling | 2014-02-03 → 2013-09-16 A (-140d) | 2014-03-14 → 2013-12-16 (-88d) | 0% → 50% | 25d → 80d |  |
| 242751005LOE | Torus - Engineering Oversight FY14 | 2013-10-01 A |  | 0% → 9% |  |  |
| 242751090 | Torus - Vacuum Vessel Assembly Parts Procurement | 2013-10-02 → 2013-10-21 A (+19d) | 2014-04-29 → 2014-04-08 (-21d) |  | 44d → 59d | 242751080 FS+1d → 242751080 FS-40d |
| 242751115 | Torus - Coil Case Shields Procurement | 2013-11-04 → 2013-10-21 A (-14d) | 2014-03-31 → 2014-02-03 (-56d) |  | 114d → 154d |  |
| 242751145 | Torus - Out Of Plane Supports - OOPS Procurement | 2013-10-16 → 2013-10-21 A (+5d) | 2014-02-28 → 2014-02-14 (-14d) |  | 118d → 128d |  |

| ID | Task | Start | Finish | Duration | Complete | Total float | Predecessors |
| --- | --- | --- | --- | --- | --- | --- | --- |
| 242751265 | Torus - Downstream Hex - 4K beam Stress Analysis | 2013-10-14 → 2013-11-01 (+18d) | 2013-10-25 → 2013-11-14 (+20d) |  |  | 91d → 25d |  |
| 242751210 | Torus - Upstream Hex - Recooler Drafting | 2013-11-04 → 2013-11-18 (+14d) | 2013-11-27 → 2013-12-13 (+16d) |  |  | 105d → 95d |  |
| 242751370 | Torus - CM Support Assembly Parts Procurement Prep | 2014-02-04 → 2013-11-21 (-75d) | 2014-03-14 → 2014-01-14 (-59d) |  |  | 88d → 130d |  |
| 242751380 | Torus - Torus Support to Hall floor Assembly Procurement Prep | 2014-02-06 → 2013-11-25 (-73d) | 2014-03-10 → 2014-01-08 (-61d) |  |  | 89d → 131d |  |
| 242751275 | Torus - Downstream Hex - Shield final design and Drafting | 2013-11-08 → 2013-12-02 (+24d) | 2013-12-16 → 2014-01-15 (+30d) |  |  | 91d → 25d |  |
| 242751225 | Torus - Upstream Hex - Shield final design and Drafting | 2013-11-04 → 2013-12-03 (+29d) | 2013-11-27 → 2014-01-07 (+41d) |  |  | 59d → 25d |  |
| 242751230 | Torus - Upstream Hex - VJ final design and Drafting | 2013-11-04 → 2013-12-03 (+29d) | 2014-01-15 → 2014-02-12 (+28d) |  |  | 59d → 25d |  |
| 242751270 | Torus - Downstream Hex - 4K piping analysis | 2013-11-11 → 2013-12-03 (+22d) | 2013-11-15 → 2013-12-09 (+24d) |  |  | 91d → 25d |  |
| 242751450 | Torus - Engineering Procured Labor Phase 2 | 2013-10-01 → 2013-12-03 (+63d) | 2014-04-30 → 2014-07-01 (+62d) |  |  | 410d → 367d |  |
| 242751245 | Torus - Recooler Procurement Prep | 2013-12-02 → 2013-12-16 (+14d) | 2014-01-13 → 2014-01-28 (+15d) |  |  | 105d → 95d |  |
| 242751280 | Torus - Downstream Hex - VJ final design and Drafting | 2013-11-25 → 2013-12-17 (+22d) | 2013-12-13 → 2014-01-14 (+32d) |  |  | 91d → 25d |  |
| 242751405 | Torus - Installation Design - Installation Tooling Drafting | 2014-03-17 → 2013-12-17 (-90d) | 2014-04-04 → 2014-01-16 (-78d) |  |  | 25d → 80d |  |
| 242751235 | Torus - Upstream Hex Assembly Parts Procurement Prep | 2013-12-02 → 2014-01-08 (+37d) | 2014-01-22 → 2014-02-18 (+27d) |  |  | 59d → 25d |  |
| 242751385 | Torus - Torus Support to Hall floor Assembly Procurement | 2014-03-11 → 2014-01-09 (-61d) | 2014-05-30 → 2014-04-01 (-59d) |  |  | 89d → 131d |  |
| 242751415 | Torus - Installation Design - Develop procedures and safety documentation | 2014-03-03 → 2014-01-13 (-49d) | 2014-04-07 → 2014-02-18 (-48d) |  |  | 108d → 142d |  |
| 242751285 | Torus - Downstream Hex Assembly Parts Procurement Prep | 2013-12-16 → 2014-01-15 (+30d) | 2014-01-22 → 2014-02-11 (+20d) |  |  | 91d → 25d |  |
| 242751375 | Torus - CM Support Assembly Parts Procurement | 2014-03-17 → 2014-01-15 (-61d) | 2014-06-30 → 2014-04-30 (-61d) |  |  | 88d → 130d |  |
| 242751410 | Torus - Installation Design - Develop Scaffolding Design | 2014-04-07 → 2014-01-17 (-80d) | 2014-04-18 → 2014-01-31 (-77d) |  |  | 45d → 100d |  |
| 242751420 | Torus - Installation Parts Procurement Prep | 2014-04-07 → 2014-01-17 (-80d) | 2014-05-12 → 2014-02-24 (-77d) |  |  | 25d → 80d |  |
| 242751250 | Torus - Recooler Procurement | 2014-01-14 → 2014-01-29 (+15d) | 2014-04-10 → 2014-04-24 (+14d) |  |  | 105d → 95d |  |
| 242751315 | Torus - Supply-Return Header to DS ring - Modeling | 2014-01-17 → 2014-02-07 (+21d) | 2014-02-21 → 2014-03-13 (+20d) |  |  | 145d → 131d |  |
| 242751320 | Torus - Supply-Return Header to DS ring - Piping flexibility analysis | 2014-01-17 → 2014-02-07 (+21d) | 2014-02-21 → 2014-03-13 (+20d) |  |  | 145d → 131d |  |
| 242751440 | Torus - Installation Parts Procurement (90K Accounted for Cryo Jumpers) | 2014-05-13 → 2014-02-25 (-77d) | 2014-08-29 → 2014-06-12 (-78d) |  |  | 25d → 80d |  |
| 242751295 | Torus - Downstream Hex MLI Procurement Prep | 2014-02-10 → 2014-02-28 (+18d) | 2014-03-07 → 2014-03-27 (+20d) |  |  | 184d → 170d |  |
| 242751305 | Torus - Misc Hex MLI Procurement Prep | 2014-02-10 → 2014-02-28 (+18d) | 2014-03-07 → 2014-03-27 (+20d) |  |  | 184d → 170d |  |
| 242751255 | Torus - Upstream Hex MLI Procurement Prep | 2014-02-10 → 2014-03-07 (+25d) | 2014-03-07 → 2014-04-03 (+27d) |  |  | 184d → 165d |  |
| 242751240 | Torus - Upstream Hex Assembly Parts Procurement | 2014-01-23 → 2014-03-12 (+48d) | 2014-06-16 → 2014-08-04 (+49d) |  |  | 59d → 25d | 242751235 → 242751235 FS+15d |
| 242751290 | Torus - Downstream Hex Assembly Parts Procurement | 2013-11-25 → 2014-03-12 (+107d) | 2014-04-30 → 2014-08-04 (+96d) |  |  | 91d → 25d | 242751285 FS-32d → 242751285 FS+20d |
| 242751325 | Torus - Supply-Return Header to DS ring - Modeling/Drafting | 2014-02-24 → 2014-03-14 (+18d) | 2014-03-14 → 2014-04-03 (+20d) |  |  | 145d → 131d |  |
| 242751300 | Torus - Downstream Hex MLI Procurement | 2014-03-07 → 2014-03-27 (+20d) | 2014-05-30 → 2014-06-19 (+20d) |  |  | 184d → 170d |  |
| 242751310 | Torus - Misc Hex MLI Procurement | 2014-03-10 → 2014-03-28 (+18d) | 2014-05-30 → 2014-06-19 (+20d) |  |  | 184d → 170d |  |
| 242751260 | Torus - Upstream Hex MLI Procurement | 2014-03-10 → 2014-04-04 (+25d) | 2014-05-30 → 2014-06-26 (+27d) |  |  | 184d → 165d |  |
| 242751330 | Torus - Supply-Return Header Procurement Prep | 2014-03-17 → 2014-04-04 (+18d) | 2014-05-02 → 2014-05-22 (+20d) |  |  | 145d → 131d |  |
| 242751335 | Torus - Supply-Return Header Procurement | 2014-05-05 → 2014-05-23 (+18d) | 2014-06-30 → 2014-07-21 (+21d) |  |  | 145d → 131d |  |
| 1 | **1.4.2.7.6.1 CRYO DISTRIBUTION CAN** |  | 2014-08-29 → 2014-10-02 (+34d) |  |  |  |  |
| 142761000 | Re-Baseline Actuals Adjustment | 2013-08-30 A | 2013-08-30 A |  | 0% → 100% | 20d → none | 9-130M FS+227d → none |
| 242761010 | Torus - Distribution Can - ProjectMgt FY13 | 2013-09-30 → 2013-09-03 A (-27d) | 2013-09-30 → 2013-11-18 (+49d) | 1d → 13d | 0% → 50% | 153d → 130d | 242761005 → 242761005 FS-20d |
| 242761010a | Torus - Distribution Can - ProjectMgt FY14 | 2013-10-01 → 2013-09-03 A (-28d) | 2013-10-16 → 2013-11-18 (+33d) |  | 0% → 50% | 153d → 130d | 242761005, 242761010 → 242761010 FS-40d |
| 242761020 | Torus - Distribution Can - Write Specs | 2013-11-05 → 2013-09-16 A (-50d) | 2013-11-25 → 2014-01-09 (+45d) |  | 0% → 50% | 153d → 130d | 242761015 → 242761015 FS-25d |
| 242761000 | Torus - Distribution Can - Drafting Mechanical | 2013-09-03 → 2013-11-01 (+59d) | 2013-09-17 → 2013-11-15 (+59d) |  |  | 153d → 131d |  |
| 242761005 | Torus - Distribution Can - Drafting Structural | 2013-09-18 → 2013-11-18 (+61d) | 2013-09-27 → 2013-11-27 (+61d) |  |  | 153d → 131d |  |
| 242761015 | Torus - Distribution Can - QA | 2013-10-17 → 2013-11-19 (+33d) | 2013-11-04 → 2013-12-09 (+35d) |  |  | 153d → 130d |  |
| 242761025 | Torus - Distribution Can - Bid and select vendor | 2013-11-26 → 2014-01-10 (+45d) | 2014-02-04 → 2014-03-07 (+31d) |  |  | 153d → 130d |  |
| 242761030 | Torus - Cryogenic Distribution Can Procurement | 2014-03-03 → 2014-04-03 (+31d) | 2014-08-29 → 2014-10-02 (+34d) |  |  | 153d → 130d |  |
| 142762000 | Re-Baseline Actuals Adjustment | 2013-08-30 A | 2013-08-30 A |  | 0% → 100% | 20d → none | 9-130M FS+227d → none |
| 242762000 | Torus - Cryogenic Tower - Mechanical Engineering FY13 | 2013-09-03 A | 2013-09-30 → 2013-12-18 (+79d) |  |  | 38d → 105d |  |
| 242762000a | Torus - Cryogenic Tower - Mechanical Engineering FY14 | 2013-10-01 → 2013-09-03 A (-28d) |  |  |  | 38d → 105d | 9-130M FS+228d, 242762000 → 242762000 FS-60d |
| 242762010 | Torus - Cryogenic Tower - Electrical/Instrumentation Engineering | 2014-01-14 → 2013-09-16 A (-120d) |  |  | 0% → 50% | 38d → 69d | 242762005 → 242762005 FS-70d |
| 242762015 | Torus - Cryogenic Tower - Drafting Mechanical | 2014-01-22 → 2013-09-16 A (-128d) |  |  |  | 38d → 41d | 242762010 → 242762010 FS-75d |
| 242762005 | Torus - Cryogenic Tower - Structural Engineering | 2013-12-19 → 2013-10-01 A (-79d) |  |  | 0% → 50% | 38d → 97d | 242762000a, 242762000 → 242762000 FS-40d, 242762000a FS-40d |
| 242762020 | Torus - Cryogenic Tower - Drafting Structural | 2014-05-14 → 2013-10-17 A (-209d) |  |  | 0% → 50% |  | 242762015 → 242762015 FS-130d |
| 242762025 | Torus - Cryogenic Tower - ProjectMgt | 2014-06-05 → 2013-10-17 A (-231d) |  |  | 0% → 50% |  | 242762020 → 242762020 FS-142d |
| 142771000 | Re-Baseline Actuals Adjustment | 2013-08-30 A | 2013-08-30 A |  | 0% → 100% | 20d → none | 9-130M FS+227d → none |
| 242771000 | Torus - Instrumentation Controls Design | 2013-10-02 → 2013-11-01 (+30d) | 2013-12-19 → 2014-01-31 (+43d) |  |  | 236d → 214d |  |
| 242771010 | Torus - Instrumentation Sensors Procurement | 2013-09-03 → 2013-12-05 (+93d) | 2013-11-25 → 2014-03-11 (+106d) |  |  | 142d → 77d | 9-130M FS+228d → 9-130M FS+228d, 9-140M FS+45d |
| 242771005 | Torus - Instrumentation Magnet Protection System Design | 2013-12-20 → 2014-02-03 (+45d) | 2014-06-19 → 2014-07-22 (+33d) |  |  | 236d → 214d |  |
| 142781000 | Re-Baseline Actuals Adjustment | 2013-08-30 A | 2013-08-30 A |  | 0% → 100% | 20d → none | 9-130M FS+227d → none |
| 242781000LOE | Solenoid - Technical Support & Oversite FY13 | 2013-09-03 A | 2013-09-30 A |  | 0% → 100% | 58d → none |  |
| 242781005LOE | Solenoid - Technical Support & Oversite FY14 | 2013-10-01 A |  |  | 0% → 9% |  |  |
| 242781015 | Solenoid - Magent Installation Design | 2013-10-01 A |  |  | 0% → 20% |  |  |
| 242781025 | Solenoid Commissioning - Design & Documentation | 2014-03-05 → 2014-03-04 (-1d) | 2014-12-01 → 2014-11-26 (-5d) |  |  | 262d → 263d |  |
| 9 | **1.4.2.7.9 SOLENOID CRYOGENICS** |  | 2015-07-06 → 2015-04-15 (-82d) |  |  |  |  |
| 1 | **1.4.2.7.9.1 SOLENOID CRYOGENICS** |  | 2015-07-06 → 2015-04-15 (-82d) |  |  |  |  |
| 142791000 | Re-Baseline Actuals Adjustment | 2013-08-30 A | 2013-08-30 A |  | 0% → 100% | 20d → none | 9-130M FS+227d → none |
| 242791000 | Solenoid - Thermal Analysis FY13 | 2013-09-03 A | 2013-09-30 → 2014-01-24 (+116d) |  |  | 3d → 90d |  |
| 242791000a | Solenoid - Thermal Analysis FY14 | 2013-10-01 → 2013-09-03 A (-28d) | 2013-12-11 → 2014-01-24 (+44d) |  |  | 3d → 90d | 242791000, 9-130M FS+228d → 242791000 FS-60d |
| 242791010 | Solenoid - Cryogenic Modes of Operation | 2014-01-14 → 2013-09-09 A (-127d) | 2014-02-04 → 2013-11-21 (-75d) |  | 0% → 50% | 3d → 90d | 242791005 → 242791005 FS-30d |
| 242791020 | Solenoid - Evaluation of Process Components | 2014-02-03 → 2013-09-09 A (-147d) | 2014-02-28 → 2013-12-02 (-88d) |  | 0% → 50% | 3d → 58d | 242791015 FS-5d → 242791015 FS-50d |
| 242791005 | Solenoid - Process P&Is | 2013-11-19 → 2013-11-01 (-18d) | 2014-01-13 → 2013-12-16 (-28d) |  |  | 3d → 90d | 242791000a FS-15d, 242791000 FS-15d → 242791000 FS-50d, 242791000a FS-50d |
| 242791015 | Solenoid - PDR | 2014-02-05 → 2013-11-22 (-75d) | 2014-02-07 → 2013-11-26 (-73d) |  |  | 3d → 90d |  |

| ID | Task | Start | Finish | Duration | Complete | Total float | Predecessors | Other |
| --- | --- | --- | --- | --- | --- | --- | --- | --- |
| 242791025 | Solenoid - Current Leads | 2014-03-03 → 2013-12-03 (-90d) | 2014-04-02 → 2014-01-14 (-78d) |  |  | 3d → 58d |  |  |
| 242791030 | Solenoid - Mechanical Design of the cryogenic can | 2014-04-03 → 2014-01-15 (-78d) | 2014-09-22 → 2014-07-03 (-81d) |  |  | 3d → 58d |  |  |
| 242791035 | Solenoid - FDR | 2014-09-23 → 2014-07-07 (-78d) | 2014-09-23 → 2014-07-07 (-78d) |  |  | 3d → 58d |  |  |
| 242791040 | Solenoid Cryogenics - Write Specifications | 2014-09-24 → 2014-07-08 (-78d) | 2014-10-14 → 2014-07-28 (-78d) |  |  | 3d → 58d |  |  |
| 242791045 | Solenoid Cryogenics - Bid cycle, review and award | 2014-10-15 → 2014-07-29 (-78d) | 2014-12-11 → 2014-09-23 (-79d) |  |  | 3d → 58d |  |  |
| 242791050 | Solenoid Cryogenics - Procurement | 2014-12-12 → 2014-09-24 (-79d) | 2015-05-13 → 2015-02-25 (-77d) |  |  | 3d → 58d |  |  |
| 242791055 | Solenoid cryogenics - Installation and Commissioning | 2015-05-14 → 2015-02-26 (-77d) | 2015-06-05 → 2015-03-18 (-79d) |  |  | 3d → 58d |  |  |
| 242791060 | Solenoid cryogenics - Test of system | 2015-06-08 → 2015-03-19 (-81d) | 2015-07-06 → 2015-04-15 (-82d) |  |  | 3d → 58d |  |  |
| 10 | **1.4.2.7.10 SOLENOID INSTRUMENTATION AND CONTROLS** |  | 2015-02-17 → 2015-04-17 (+59d) |  |  |  |  |  |
| 1 | **1.4.2.7.10.1 SOLENOID INSTRUMENTATION AND CONTROLS** |  | 2015-02-17 → 2015-04-17 (+59d) |  |  |  |  |  |
| 1427.10000 | Re-Baseline Actuals Adjustment | 2013-08-30 A | 2013-08-30 A |  | 0% → 100% | 20d → none | 9-130M FS+227d → none |  |
| 242710.1015 | Solenoid - Instrumentation Controls Design FY13 | 2013-09-03 → 2013-11-01 (+59d) | 2013-09-30 → 2013-12-02 (+63d) |  |  | 98d → 55d |  | resources ELEC ENG [11.11 h]; ELEC DES [111.11 h] → ELEC ENG [11.11 h]; ELEC DES [111.09 h] |
| 242710.1015a | Solenoid - Instrumentation Controls Design FY14 | 2013-10-01 → 2013-12-03 (+63d) | 2013-12-13 → 2014-02-25 (+74d) |  |  | 98d → 55d | 242710.1015, 9-130M FS+228d → 242710.1015 |  |
| 242710.1000 | Solenoid - Instrumentation Magnet Protection System Design | 2013-12-16 → 2014-02-26 (+72d) | 2014-06-13 → 2014-08-14 (+62d) |  |  | 187d → 144d |  |  |
| 242710.1020 | Solenoid - Instrumentation Controls Procurement Prep | 2013-12-16 → 2014-02-26 (+72d) | 2013-12-20 → 2014-03-04 (+74d) |  |  | 98d → 55d |  |  |
| 242710.1025 | Solenoid - Instrumentation Controls Procurement | 2014-01-02 → 2014-03-05 (+62d) | 2014-04-23 → 2014-06-24 (+62d) |  |  | 98d → 55d |  |  |
| 242710.1005 | Solenoid - Instrumentation Magnet Protection System Procurement Prep | 2014-06-16 → 2014-08-15 (+60d) | 2014-06-20 → 2014-08-21 (+62d) |  |  | 187d → 144d |  |  |
| 242710.1030 | Solenoid - Instrumentation Controls Assembly | 2014-06-20 → 2014-08-21 (+62d) | 2015-02-17 → 2015-04-17 (+59d) |  |  | 98d → 55d |  |  |
| 242710.1010 | Solenoid - Instrumentation Magnet Protection System Procurement | 2014-06-23 → 2014-08-22 (+60d) | 2014-09-16 → 2014-11-14 (+59d) |  |  | 187d → 144d |  |  |
| 11 | **1.4.2.7.11 TORUS RISK MITIGATION** |  | 2015-04-09 → 2015-05-12 (+33d) |  |  |  |  |  |
| 1 | **1.4.2.7.11.1 ADDITIONAL FNAL COILS FOR TORUS RISK MITIGATION** | 2013-10-01 → 2013-11-01 (+31d) | 2014-11-26 → 2015-01-12 (+47d) |  |  |  |  |  |
| 242711.1010 | FNAL - Fabricate CCM #7 | 2013-10-01 → 2013-11-01 (+31d) | 2014-11-26 → 2015-01-12 (+47d) |  |  | 72d → 49d |  |  |
| 242711.1005 | FNAL - Fabricate Prototype CCM | 2013-10-01 → 2013-12-03 (+63d) | 2014-03-31 → 2014-03-05 (-26d) | 119d → 58d |  | 58d → 76d | 242711.4005a FS-25d, 242711.4005b FS-25d, 242711.4005 FS-25d → 242711.4005 FS-25d, 242711.4005b FS-25d |  |
| 2 | **1.4.2.7.11.2 ADDITIONAL COIL CASE AND HARDWARE FOR TORUS RISK MITIGATION** | 2013-09-03 → 2013-10-01 (+28d) | 2013-12-20 → 2014-03-04 (+74d) |  |  |  |  |  |
| 242711.2005 | Vend Fab 1 Set of Additional Hardware for Cryostat (Cold Mass Shiled, OOPS, Axial Support, MLI, Vacuum Jacket) | 2013-09-03 → 2013-10-01 A (+28d) | 2013-12-20 → 2014-03-04 (+74d) |  |  | 453d → 410d |  |  |
| 3 | **1.4.2.7.11.3 COIL LN2 TESTING FOR TORUS RISK MITIGATION** | 2013-09-03 → 2013-11-01 (+59d) | 2014-11-26 → 2015-01-12 (+47d) |  |  |  |  |  |
| 242711.3000 | LN2 TEST - Procurements Preperation FY13 | 2013-09-03 → 2013-11-01 (+59d) | 2013-09-30 → 2013-12-02 (+63d) |  |  | 110.5d → 67.5d |  |  |
| 242711.3000a | LN2 TEST - Procurements Preperation FY14 | 2013-10-01 → 2013-12-03 (+63d) | 2013-11-01 → 2014-01-15 (+75d) |  |  | 110.5d → 67.5d | 9-130M FS+228d, 242711.3000 → 242711.3000 |  |
| 242711.3005 | LN2 TEST - Preliminary system set up and integration (One coil LN2 Test) Procurements | 2013-10-01 → 2013-12-03 (+63d) | 2013-11-26 → 2014-02-10 (+76d) |  |  | 121.5d → 78.5d |  |  |
| 242711.3010 | LN2 TEST - Mounting of Q heaters and wiring | 2013-10-01 → 2013-12-03 (+63d) | 2013-10-23 → 2014-01-06 (+75d) |  |  | 110.5d → 67.5d |  |  |
| 242711.3015 | LN2 TEST - Instrumentation general and wiring layout and cabling | 2013-10-23 → 2014-01-06 (+75d) | 2013-11-07 → 2014-01-22 (+76d) |  |  | 110.5d → 67.5d |  |  |
| 242711.3025 | LN2 TEST - Preliminary system set up and integration (One coil LN2 Test) Labor | 2013-10-23 → 2014-01-06 (+75d) | 2013-12-05 → 2014-02-17 (+74d) |  |  | 116.5d → 73.5d |  |  |
| 242711.3020 | LN2 TEST - HV/LV Feedthrough and wirng | 2013-11-07 → 2014-01-22 (+76d) | 2013-12-13 → 2014-02-25 (+74d) |  |  | 110.5d → 67.5d |  |  |
| 242711.3030 | LN2 TEST - LN2 Testing of Prototype Coil | 2014-03-11 → 2014-02-25 (-14d) | 2014-03-24 → 2014-03-11 (-13d) |  |  | 58d → 67.5d |  |  |
| 242711.3035 | LN2 TEST - LN2 Testing of CCM #1 | 2014-04-11 → 2014-03-17 (-25d) | 2014-04-24 → 2014-03-28 (-27d) |  |  | 45d → 64d |  |  |
| 242711.3040 | LN2 TEST - LN2 Testing of CCM #2 | 2014-05-15 → 2014-03-31 (-45d) | 2014-05-29 → 2014-04-11 (-48d) |  |  | 37d → 70d |  |  |
| 242711.3045 | LN2 TEST - LN2 Testing of CCM #3 | 2014-06-19 → 2014-04-21 (-59d) | 2014-07-02 → 2014-05-02 (-61d) |  |  | 35d → 77d |  |  |
| 242711.3050 | LN2 TEST - LN2 Testing of CCM #4 | 2014-07-28 → 2014-05-27 (-62d) | 2014-08-08 → 2014-06-09 (-60d) |  |  | 30d → 73d |  |  |
| 242711.3055 | LN2 TEST - LN2 Testing of CCM #5 | 2014-09-02 → 2014-07-01 (-63d) | 2014-09-15 → 2014-07-15 (-62d) |  |  | 20d → 63d |  |  |
| 242711.3060 | LN2 TEST - LN2 Testing of CCM #6 | 2014-10-01 → 2014-07-29 (-64d) | 2014-10-14 → 2014-08-11 (-64d) |  |  | 17d → 62d |  |  |
| 242711.3065 | LN2 TEST - LN2 Testing of CCM #7 | 2014-11-13 → 2014-12-18 (+35d) | 2014-11-26 → 2015-01-12 (+47d) |  |  | 72d → 49d |  |  |
| 4 | **1.4.2.7.11.4 ADDITIONAL COPPER SSC AND SOLDERING FOR TORUS RISK MITIGATION** | 2013-09-03 → 2013-11-01 (+59d) | 2014-02-06 → 2014-02-04 (-2d) |  |  |  |  |  |
| 242711.4005 | Solder conductor for Torus Coil #7 Coil - Procurement | 2013-09-03 → 2013-11-01 (+59d) | 2013-11-04 → 2014-01-16 (+73d) |  |  | 58d → 76d |  | was named Solder condutor for Prototype Coil - Procurement |
| 242711.4005a | Solder conductor for Torus Coil #7 and #8 Coil Labor FY13 | 2013-09-03 → 2013-11-01 (+59d) | 2013-09-30 → 2013-12-02 (+63d) |  |  | 58d → 76d |  | was named Solder condutor for Prototype Coil Labor FY13 |
| 242711.4010 | Solder conductor for Torus Coil #8 | 2013-11-05 → 2013-11-01 (-4d) | 2014-02-06 → 2014-02-04 (-2d) |  |  | 77d → 79d | 242711.4005b, 242711.4005, 242711.4005a → 242711.4005 FS-70d, 242711.4005b FS-70d | was named Solder condutor for Coil #7 |
| 242711.4005b | Solder conductor for Torus Coil #7 and #8 Coil Labor FY14 | 2013-10-01 → 2013-12-03 (+63d) | 2013-11-04 → 2014-01-16 (+73d) |  |  | 58d → 76d | 242711.4005a, 24271740 FS-60d → 242711.4005a | was named Solder condutor for Prototype Coil Labor FY14 |
| 5 | **1.4.2.7.11.5 SECLAY COIL COLD TESTING FOR TORUS RISK MITIGATION** |  | 2015-04-09 → 2015-05-12 (+33d) |  |  |  |  |  |
| 242711.5010 | Saclay Cold Tests - Oversight Expenses and Labor FY13 | 2013-09-03 A | 2013-09-30 A |  | 0% → 100% | 229d → none |  |  |
| 242711.5010a | Saclay Cold Tests - Oversight Expenses and Labor FY14 | 2013-10-01 A |  |  | 0% → 9% |  | 242711.5000 FS-9d, 242711.5010 → 242711.5010 |  |
| 242711.5000 | Saclay Cold Tests - Contract Preperation | 2013-09-03 → 2013-11-01 (+59d) | 2013-09-13 → 2013-11-13 (+61d) |  |  |  |  |  |
| 242711.5010b | Saclay Cold Tests - Oversight Expenses and Labor FY15 |  |  |  |  |  | 242711.5000 FS-9d, 242711.5010a → 242711.5010a |  |
| 242711.5030 | Saclay Cold Tests - Cryogenic Tests of Coil #7 | 2014-12-01 → 2015-01-13 (+43d) | 2015-04-09 → 2015-05-12 (+33d) |  |  | 72d → 49d |  |  |
| 143118P1LOE | HB Contract Mngmnt for HB Mag | 2009-10-14 A | 2010-09-30 A |  | 0% → 100% | 20d → none | 14311000M → 14311000M FS-500d | resources MECH ENG [400 h]; TRAVEL; MECH DES [240 h] → TRAVEL; MECH DES [240 h]; MECH ENG [400 h] |
| 14311000M | HB- Award Contract for HB Mag | 2009-10-14 → 2010-06-07 A (+236d) | 2009-10-14 → 2010-06-07 A (+236d) |  | 0% → 100% | 0d → none | 9-100M → 122312095 FS+85d | constraint mandatory start 2009-10-14 → none |
| 14311002 | HB- Contractor Expenses (FROZEN by CR10-063) | 2009-10-14 → 2010-07-02 A (+261d) | 2009-11-10 → 2010-07-19 A (+251d) | 20d → 11d | 0% → 100% | 195d → none |  |  |
| 14311005 | HB- Finalize Dsgn for HB Mag (FROZEN by CR10-063) | 2009-10-14 → 2010-07-02 A (+261d) | 2010-04-27 → 2010-07-19 A (+83d) | 130d → 11d | 0% → 100% | 85d → none |  | was named HB- Finalise Dsgn for HB Mag (FROZEN by CR10-063); resources PROCUREMENT<$50K 60; TRAVEL; PROCUREMENT>$50K 69 → TRAVEL; PROCUREMENT>$50K 69; PROCUREMENT<$50K 60 |
| 14311010 | HB- Dsgn Review of HB Mag (FROZEN by CR10-063) | 2010-04-28 → 2010-07-02 A (+65d) | 2010-05-04 → 2010-07-19 A (+76d) | 5d → 11d | 0% → 100% | 85d → none |  |  |
| 14311015 | HB- Insulate Superconductor (FROZEN by CR10-063) | 2010-05-05 → 2010-07-02 A (+58d) | 2010-06-02 → 2010-07-19 A (+47d) | 20d → 11d | 0% → 100% | 85d → none |  |  |
| 14311080 | Reverse Entry - Change Request 10-063 | 2010-07-01 → 2010-07-02 A (+1d) | 2010-07-01 → 2010-07-19 A (+18d) | 1d → 11d | 0% → 100% | 65d → none | 14311000M FS+175d → 14311000M | resources PROCUREMENT<$50K 60; MECH ENG [-40 h]; TRAVEL; PROCUREMENT>$50K 69 → PROCUREMENT<$50K 60; PROCUREMENT>$50K 69; MECH ENG [-40 h]; TRAVEL |
| 14311082 | Vend Fab HB Magnet Peg Point #1 Preliminary Design Review | 2010-07-02 A | 2010-10-29 A |  | 0% → 100% | 64d → none | 14311080 FS-1d, 14311000M FS+176d → 14311080 FS-1d, 14311000M |  |
| 14311082a | Vend Fab HB Magnet Peg Point #2 HB Analysis Complete | 2010-07-02 A | 2011-02-28 A |  | 0% → 100% | 64d → none |  |  |
| 14311082b | Vend Fab HB Magnet Peg Point #3 Intermediate Design Review | 2010-07-02 A | 2011-06-30 → 2011-08-29 A (+60d) | 247d → 288d | 0% → 100% | 64d → none |  |  |
| 14311084 | Vend Fab HB Magnet Peg Point #4 Final Design Review | 2010-07-02 A | 2011-10-31 → 2013-01-31 A (+458d) | 332d → 617d | 0% → 100% | 64d → none |  |  |
| 14311086 | Vend Fab HB Magnet Peg Point #5a HB Cold Mass Complete | 2010-07-02 A | 2012-02-29 → 2013-08-30 A (+548d) | 409d → 678d | 0% → 100% | 64d → none |  |  |
| 143118P2LOE | HB Contract Mngmnt for HB Mag | 2010-10-01 A | 2011-09-30 A |  | 0% → 100% | 20d → none |  |  |
| 14311086a | Vend Fab HB Magnet Peg Point #5b HB Cold Mass Complete | 2011-07-01 → 2011-06-30 A (-1d) | 2012-02-29 → 2013-08-30 A (+548d) | 162d → 432d | 0% → 100% | 64d → none | 9-110M FS+184d, 14311086 FS-163d → 14311086 FS-275d, 9-110M FS+184d |  |
| 14311086b | Vend Fab HB Magnet Peg Point #6 Cryostat and Materials Certifications Complete | 2011-07-01 → 2011-06-30 A (-1d) | 2012-06-29 → 2013-08-30 A (+427d) | 247d → 454d | 0% → 100% | 64d → none | 14311086a FS-162d → 14311086a FS-275d | resources PROCUREMENT<$50K 60 NO ESCALATION; PROCUREMENT>$50K 69 NO ESCALATION → PROCUREMENT>$50K 69 NO ESCALATION; PROCUREMENT<$50K 60 NO ESCALATION |
| 14311086c | Vend Fab HB Magnet Peg Point #7a HB Magnet Cryostated | 2011-07-01 → 2011-06-30 A (-1d) | 2012-10-31 → 2013-08-30 A (+303d) | 334d → 540d | 0% → 100% | 64d → none | 14311086b FS-247d → 14311086b FS-315d |  |
| 14311073 | HB Design Reviews FY11 | 2011-05-05 → 2011-08-24 A (+111d) | 2011-09-30 → 2012-08-20 A (+325d) | 104d → 245.31d | 0% → 100% | 64d → none |  | resources MECH ENG [33.28 h]; TRAVEL → TRAVEL; MECH ENG [33.28 h] |
| 14311073a | HB Design Reviews FY12 | 2011-10-03 → 2011-08-24 A (-40d) | 2011-10-31 → 2012-08-20 A (+294d) | 21d → 246d | 0% → 100% | 64d → none | 14311073 → 14311073 FS-185d | resources TRAVEL; MECH ENG [6.72 h] → MECH ENG [6.72 h]; TRAVEL |

| ID | Task | Start | Finish | Duration | Complete | Total float | Predecessors | Other |
| --- | --- | --- | --- | --- | --- | --- | --- | --- |
| 143118P3LOE | HB Contract Mngmnt for HB Mag | 2011-10-03 A | 2011-12-30 → 2012-01-02 A (+3d) |  | 0% → 100% | 20d → none |  | resources MECH ENG [93.93 h]; MECH DES [18.79 h]; TRAVEL → TRAVEL; MECH ENG [93.93 h]; MECH DES [18.79 h] |
| 14311086d | Vend Fab HB Magnet Peg Point #7b HB Magnet Cryostated | 2012-04-02 → 2011-11-01 A (-153d) | 2012-10-31 → 2013-08-30 A (+303d) | 150d → 454d | 0% → 100% | 64d → none | 14311086c FS-150d, 9-120M FS+120d → 14311086c FS-370d, 9-120M |  |
| 14311086f | Vend Fab HB Magnet Peg Point #8 Magnet Complete | 2012-04-02 → 2011-11-01 A (-153d) | 2013-02-28 → 2013-08-30 A (+183d) | 226d → 554d | 0% → 100% | 64d → none | 14311086d FS-150d → 14311086d FS-370d |  |
| 14311086g | Vend Fab HB Magnet Peg Point #9 HB Tested and Mapped at MSU and delivery to JLab | 2012-04-02 → 2011-11-01 A (-153d) | 2013-06-28 → 2013-08-30 A (+63d) | 311d → 628d | 0% → 100% | 64d → none | 14311086f FS-226d → 14311086f FS-435d |  |
| 143118P3LOE5 | HB Contract Mngmnt for HB Mag | 2012-01-03 A | 2012-09-28 A |  | 0% → 100% | 20d → none |  |  |
| 143118P4LOE | HB Contract Mngmnt for HB Mag | 2012-10-01 A | 2013-08-30 A | 228d → 248d | 0% → 100% | 20d → none |  |  |
| 14311072 | HB Site Inspections FY12 | 2012-01-03 → 2013-05-06 A (+489d) | 2012-09-28 → 2013-08-30 A (+336d) |  | 0% → 100% | 64d → none | 14311086 FS-40d → 9-130M, 14311086 FS-130d |  |
| 14311072a | HB Site Inspections FY13 | 2012-10-01 → 2013-08-30 A (+333d) | 2013-06-28 → 2013-08-30 A (+63d) |  | 0% → 100% | 64d → none |  |  |
| 14311950 | Re-Baseline Actuals Adjustment | 2013-08-30 A | 2013-08-30 A |  | 0% → 100% | 20d → none | 9-130M FS+227d → none |  |
| 24311072 | HB Site Inspections FY13 | 2013-09-03 A | 2013-09-30 A |  | 0% → 100% | 368d → none |  |  |
| 24311110 | Vend Fab HB Magnet Peg Point #10 Weld back He Vessel Plate; Shield Preassembly; Fab Vac Wall Parts | 2013-09-03 A | 2013-10-31 → 2013-09-23 A (-38d) |  | 0% → 100% | 49d → none |  |  |
| 24311115 | Vend Fab HB Magnet Peg Point #11 Close He Vessel; Preassemble Cryostat Vac Wall | 2013-09-03 A | 2013-11-27 → 2013-12-20 (+23d) |  | 0% → 25% | 49d → 261d |  |  |
| 24311120 | Vend Fab HB Magnet Peg Point #12 NDT & Warm Testing; Assemble Shield to He Vessel | 2013-09-03 A | 2013-12-20 → 2014-01-15 (+26d) |  |  | 49d → 233d |  |  |
| 24311125 | Vend Fab HB Magnet Peg Point #13 Shield Support Assy, Instrumentation & Insulation | 2013-09-03 A | 2013-12-20 → 2014-01-31 (+42d) |  |  | 49d → 200d |  |  |
| 24311130 | Vend Fab HB Magnet Peg Point #14 Suspend He Vessel/Shield; Complete Vac. Walls 2,3 | 2013-09-03 A |  |  |  | 49d → 178d |  |  |
| 24311135 | Vend Fab HB Magnet Peg Point #15 Finish Vac Wall & Support Links | 2013-09-03 A |  |  |  | 49d → 135d |  |  |
| 24311140 | Vend Fab HB Magnet Peg Point #16 Finish & Leak Check Cryo Header | 2013-09-03 A |  |  |  | 49d → 92d |  | resources PROCUREMENT<$50K 60 NO ESCALATION → PROCUREMENT>$50K 69 NO ESCALATION; PROCUREMENT<$50K 60 NO ESCALATION |
| 24311145 | Vend Fab HB Magnet Peg Point #17 Assemble CCR to Magnet | 2013-09-03 A |  |  |  |  |  | resources PROCUREMENT<$50K 60 NO ESCALATION; PROCUREMENT>$50K 69 NO ESCALATION → PROCUREMENT>$50K 69 NO ESCALATION |
| 243118P4LOE | HB Contract Mngmnt for HB Mag | 2013-09-03 A | 2013-09-30 A |  | 0% → 100% | 683d → none |  |  |
| 24311072a | HB Site Inspections FY14 | 2013-10-01 A |  |  |  |  |  |  |
| 243118P5LOE | HB Contract Mngmnt for HB Mag | 2013-10-01 A |  |  | 0% → 9% |  |  |  |
| 24311170 | HB- Factory Mag Test of HB Mag | 2014-05-02 → 2014-05-16 (+14d) | 2014-06-30 → 2014-07-15 (+15d) |  |  | 368d → 358d |  |  |
| 24311077 | Finducialize Magnet CL of SHMS HB Magnet | 2014-10-01 → 2014-10-28 (+27d) | 2014-10-01 → 2014-10-28 (+27d) |  |  | 323d → 304d |  |  |
| 14312909LOE | Q1- FY09 Proj Mngmnt H-C upgrade | 2009-01-02 A | 2009-09-30 A |  | 0% → 100% | 20d → none |  |  |
| 143128P1LOE | Q1- P-1 Contract Mngmnt for Q1 | 2009-03-16 A | 2009-09-30 A |  | 0% → 100% | 573d → none |  | resources TRAVEL; MECH ENG [108 h]; MECH DES [72 h] → MECH ENG [108 h]; MECH DES [72 h]; TRAVEL |
| 14312002 | Q1- Contractor Expenses (Frozen and Reversed by Activity 14312011 per CR 09-041) | 2009-03-16 → 2009-08-03 A (+140d) | 2009-04-10 → 2009-08-03 A (+115d) | 20d → 1d | 0% → 100% | 120d → none |  |  |
| 14312011 | Reverse Entry for Activities 14312002, 14312010 and 14312010a per CR 09-041 | 2009-08-03 A | 2009-08-03 A |  | 0% → 100% | 41d → none |  |  |
| 14312015 | Vend Fab Q1 Procure Materials | 2009-08-03 A | 2009-08-14 A |  | 0% → 100% | 1023d → none |  |  |
| 14312020 | Vend Fab Q1 Completion of Magnetic and Stress Analysis | 2009-08-03 A | 2010-02-12 → 2010-03-31 A (+47d) | 130d → 162d | 0% → 100% | 903d → none |  |  |
| 14312025 | Vend Fab Q1 Completion of Trial Wind | 2009-08-03 A | 2010-03-15 → 2011-01-28 A (+319d) | 150d → 367d | 0% → 100% | 883d → none |  |  |
| 14312032 | Vend Fab Q1 Completion of Preliminary Design Review | 2009-08-03 A | 2010-07-14 → 2010-07-07 A (-7d) | 235d → 230d | 0% → 100% | 798d → none |  |  |
| 14312036 | Vend Fab Q1 Completion of Cold Mass Components (Frozen Per CR12-003) | 2009-08-03 A | 2011-04-29 → 2011-11-01 A (+186d) | 431d → 560d | 0% → 100% | 602d → none |  |  |
| 14312040 | Vend Fab Q1 Completion of Cold Mass Assembly (Frozen Per CR12-003) | 2009-08-03 A | 2011-07-29 → 2011-11-01 A (+95d) | 494d → 560d | 0% → 100% | 500d → none |  |  |
| 14312041 | Vend Fab Q1 Warm Testing Complete (Frozen Per CR12-003) | 2009-08-03 A | 2011-08-31 → 2011-11-01 A (+62d) | 517d → 560d | 0% → 100% | 511d → none |  |  |
| 14312042 | Vend Fab Q1 Completion of Final Design Review | 2009-08-03 A | 2011-03-31 → 2011-09-26 A (+179d) | 410d → 534d | 0% → 100% | 623d → none | 9-090M FS+206d → 9-090M |  |
| 14312045 | Vend Fab Q1 Completion of Cryostat Components (Frozen Per CR12-003) | 2009-08-03 A | 2011-06-30 → 2011-11-01 A (+124d) | 474d → 560d | 0% → 100% | 559d → none | 9-090M FS+206d → 9-090M |  |
| 14312046 | Vend Fab Q1 Completion of Cryostat Assembly | 2009-08-03 A | 2013-02-28 → 2013-08-30 A (+183d) | 884d → 1075d | 0% → 100% | 20d → none |  |  |
| 14312047 | Vend Fab Q1 Completion of Magnet Assembly | 2009-08-03 A | 2013-04-30 → 2013-08-30 A (+122d) | 927d → 1113d | 0% → 100% | 20d → none |  |  |
| 14312048 | Vend Fab Q1 Completion of Factory Tests by Vendor | 2009-08-03 A | 2013-06-28 → 2013-08-30 A (+63d) | 969d → 1113d | 0% → 100% | 20d → none |  |  |
| 14312050 | Vend Fab Q1 Magnet System Delivery | 2009-08-03 A | 2013-07-31 → 2013-08-30 A (+30d) | 991d → 1117d | 0% → 100% | 20d → none |  |  |
| 14312050c | Vend Fab Q1 Magnet Acceptance | 2011-12-19 → 2009-08-03 A (-868d) | 2013-08-30 A | 422d → 1175d | 0% → 100% | 20d → none | 14312050 FS-400d → 14312050 FS-991d |  |
| 14312010a | Q1- Finalize Dsgn of Q1 " Final Phase" (Frozen and Reversed by Activity 14312011 per CR 09-041) | 2009-06-17 → 2009-08-10 A (+54d) | 2009-07-31 → 2009-08-10 A (+10d) | 32d → 1d | 0% → 100% | 42d → none |  |  |
| 14312010 | Q1- Finalize Dsgn of Q1 First Phase (Frozen and Reversed by Activity 14312011 per CR 09-041) | 2009-03-16 → 2009-08-17 A (+154d) | 2009-04-30 → 2009-08-17 A (+109d) | 33.25d → 0.25d | 0% → 100% | 106.75d → none |  |  |
| 14312000M | Q1- Award Contract for Q1 | 2009-03-16 → 2009-09-01 A (+169d) | 2009-03-16 → 2009-09-01 A (+169d) |  | 0% → 100% | 0d → none |  |  |
| 143128P2LOE | Q1- P-2 Contract Mngmnt for Q1 | 2009-10-01 A | 2010-09-30 A |  | 0% → 100% | 573d → none |  |  |
| 14312910LOE | Q1- FY10 Proj Mngmnt H-C upgrade | 2009-10-01 A | 2010-09-30 A |  | 0% → 100% | 20d → none |  |  |
| 143128P3LOE | Q1- P-3 Contract Mngmnt for Q1 | 2010-10-01 A | 2011-09-30 A |  | 0% → 100% | 573d → none |  | resources TRAVEL; MECH DES [80 h]; MECH ENG [360 h] → MECH ENG [360 h]; TRAVEL; MECH DES [80 h] |
| 14312911LOE | Q1- FY11 Proj Mngmnt H-C upgrade | 2010-10-01 A | 2011-09-30 A |  | 0% → 100% | 20d → none |  |  |
| 14312005 | Q1- Final Dsgn Review | 2011-09-19 → 2011-09-12 A (-7d) | 2011-09-23 → 2011-09-26 A (+3d) | 5d → 11d | 0% → 100% | 500d → none | 14312052M, 14312040 FS+34d → 14312040 FS-60d, 14312052M FS-70d |  |
| 143128P4LOE | Q1- P-4 Contract Mngmnt for Q1 | 2011-10-03 A | 2012-09-28 A |  | 0% → 100% | 573d → none |  | resources MECH ENG [360 h]; MECH DES [80 h]; TRAVEL → TRAVEL; MECH ENG [360 h]; MECH DES [80 h] |
| 14312912LOE | Q1- FY12 Proj Mngmnt H-C upgrade | 2011-10-03 A | 2012-09-28 A |  | 0% → 100% | 20d → none |  |  |
| 14312034 | Reverse Entry for activities 14312036,14312040,14312041 and 14312045 per CR12-003) | 2011-11-01 A | 2011-11-07 → 2011-11-01 A (-6d) | 5d → 1d | 0% → 100% | 221d → none | 9-120M FS+21d → 9-120M |  |
| 14312038 | Vend Fab Q1 Completion of Cold Mass Components (Revised Per CR12-003) | 2011-11-01 A | 2011-12-30 → 2011-11-14 A (-46d) | 37d → 10d | 0% → 100% | 255d → none |  |  |
| 14312040a | Vend Fab Q1 Completion of Cold Mass Assembly (Revised Per CR12-003) | 2011-11-01 A | 2012-05-31 → 2013-08-30 A (+456d) | 142d → 390d | 0% → 100% | 255d → none |  |  |
| 14312040d | Vend Fab Q1 Completion of Cold Mass Testing | 2011-11-01 A | 2012-09-28 → 2013-08-30 A (+336d) | 226d → 390d | 0% → 100% | 255d → none | 14312040a FS-142d → 14312040a FS-155d |  |
| 14312041a | Vend Fab Q1 Warm Testing Complete (Revised Per CR12-003) | 2011-11-01 A | 2012-06-29 → 2013-08-30 A (+427d) | 162d → 390d | 0% → 100% | 255d → none |  |  |
| 14312045a | Vend Fab Q1 Completion of Cryostat Components (Revised Per CR12-003) | 2011-11-01 A | 2012-05-31 → 2013-06-17 A (+382d) | 142d → 390d | 0% → 100% | 255d → none |  |  |
| 143128P5LOE | Q1- P-5 Contract Mngmnt for Q1 | 2012-10-01 A | 2013-08-30 A | 228d → 248d | 0% → 100% | 573d → none |  | resources MECH ENG [330.97 h]; TRAVEL; MECH DES [73.55 h] → TRAVEL; MECH ENG [330.97 h]; MECH DES [73.55 h] |
| 14312913LOE | Q1- FY13 Proj Mngmnt H-C upgrade | 2012-10-01 A | 2013-08-30 A | 228d → 248d | 0% → 100% | 20d → none |  |  |
| 143128P5TLOE | Q1- P-5 Extra Travel for Q1 Contract Mgmt | 2013-01-02 A | 2013-08-30 A | 169d → 189d | 0% → 100% | 573d → none | 143128P5LOE FS-169d → 143128P5LOE FS-189d |  |
| 143128PC13LOE | Q1- Contract Oversight Consultant FY13 | 2013-01-02 A | 2013-08-30 A | 169d → 189d | 0% → 100% | 573d → none |  |  |
| 14312950 | Re-Baseline Actuals Adjustment | 2013-08-30 A | 2013-08-30 A |  | 0% → 100% | 20d → none | 9-130M FS+227d → none |  |
| 24312040d | Vend Fab Q1 Completion of Cold Mass Testing | 2013-09-03 A |  |  |  | 472d → 567d |  |  |
| 24312041a | Vend Fab Q1 Warm Testing Complete | 2013-09-03 A |  |  |  |  | 24312040d FS-98d → 24312040d FS-150d |  |
| 24312046 | Vend Fab Q1 Completion of Cryostat Assembly | 2013-09-03 A | 2014-04-30 → 2014-05-30 (+30d) |  |  | 87d → 126d |  |  |
| 24312047 | Vend Fab Q1 Completion of Magnet Assembly | 2013-09-03 A |  |  |  | 87d → 108d | 24312046 FS-161d → 24312046 FS-260d |  |
| 24312048 | Vend Fab Q1 Completion of Factory Tests by Vendor | 2013-09-03 A |  |  |  |  | 24312047 FS-182d → 24312047 FS-280d |  |
| 24312050 | Vend Fab Q1 Magnet System Delivery | 2013-09-03 A | 2014-06-30 → 2014-07-15 (+15d) |  |  | 87d → 77d | 24312048 FS-203d → 24312048 FS-300d |  |
| 24312050c | Vend Fab Q1 Magnet Acceptance | 2013-09-03 A | 2014-08-29 → 2014-09-30 (+32d) |  |  | 271d → 250d | 24312050 FS-203d → 24312050 FS-250d |  |
| 24312060 | Q1 Schedule Acceleration Incentives | 2013-09-03 A | 2014-06-30 → 2014-08-01 (+32d) |  |  | 367d → 344d |  |  |

| ID | Task | Start | Finish | Duration | Complete | Total float | Predecessors | Other |
| --- | --- | --- | --- | --- | --- | --- | --- | --- |
| 243128P5LOE | Q1- P-5 Contract Mngmnt for Q1 | 2013-09-03 A | 2013-09-30 A |  | 0% → 100% | 249d → none |  |  |
| 243128P5TLOE | Q1- P-5 Extra Travel for Q1 Contract Mgmt | 2013-09-03 A | 2013-09-30 A |  | 0% → 100% | 249d → none |  |  |
| 243128PC13LOE | Q1- Contract Oversight Consultant | 2013-09-03 A |  |  | 0% → 44% |  |  |  |
| 24312913LOE | Q1- FY13 Proj Mngmnt H-C upgrade | 2013-09-03 A | 2013-09-30 A |  | 0% → 100% | 439d → none |  |  |
| 243128P6LOE | Q1- P-6 Contract Mngmnt for Q1 | 2013-10-01 A |  |  | 0% → 9% |  |  |  |
| 24312914LOE | Q1- FY14 Proj Mngmnt H-C upgrade | 2013-10-01 A |  |  | 0% → 9% |  |  |  |
| 14312052M | Factory Low Current Mag Test of Q1 Complete | 2011-08-31 → 2013-11-01 (+793d) | 2011-08-31 → 2013-11-01 (+793d) |  |  | 511d → 967d | 14312040, 14312041 → 14312041, 14312048, 14312040 |  |
| 243128PC13LOE5 | Q1- Contract Oversight Consultant |  |  |  |  |  | 243128PC13LOE, 9-130M FS+228d → 243128PC13LOE |  |
| 24312053M | Q1 Delivered to JLab | 2014-06-30 → 2014-07-15 (+15d) | 2014-06-30 → 2014-07-15 (+15d) |  |  | 87d → 77d |  |  |
| 24312050d | Q1 Drawing Validation | 2014-07-01 → 2014-07-16 (+15d) | 2014-11-19 → 2014-12-05 (+16d) |  |  | 268d → 258d |  |  |
| 24312051M | Q1 Acceptance Test Complete | 2014-08-25 → 2014-09-22 (+28d) | 2014-08-25 → 2014-09-22 (+28d) |  |  | 294d → 275d |  |  |
| 24312055 | Pay Profit on Q1 | 2014-08-26 → 2014-09-23 (+28d) | 2014-08-26 → 2014-09-23 (+28d) |  |  | 328d → 309d |  |  |
| 14313P1LOE | Q2&3- P-1 Contract Mngmnt for Q2-3 | 2009-12-14 A | 2010-09-30 A |  | 0% → 100% | 20d → none |  |  |
| 14313P2LOE | Q2&3- P-2 Contract Mngmnt for Q2-3 | 2010-10-01 A | 2011-09-30 A |  | 0% → 100% | 20d → none |  | resources MECH ENG [440 h]; MECH DES [80 h]; TRAVEL → TRAVEL; MECH ENG [440 h]; MECH DES [80 h] |
| 14313000M | Q2&3- Award Contract for SHMS Q2/Q3 quadrupoles | 2010-10-18 → 2010-12-01 A (+44d) | 2010-10-18 → 2010-12-01 A (+44d) |  | 0% → 100% | 0d → none |  |  |
| 14313002 | Q2&3- Contractor Expenses | 2010-10-18 → 2010-12-01 A (+44d) | 2010-11-12 → 2010-12-30 A (+48d) | 20d → 17d | 0% → 100% | 433d → none |  |  |
| 14313005 | Q2&3- Finalize Dsgn for Q2/Q3 Mags Original Expenses | 2010-11-15 → 2010-12-01 A (+16d) | 2010-11-30 → 2010-12-09 A (+9d) | 10d → 7d | 0% → 100% | 433d → none |  |  |
| 14313006 | Vend Fab Q2&3 Peg Point #1 Intermediate Design Review | 2010-12-07 A | 2011-06-30 → 2013-07-15 A (+746d) | 139d → 592d | 0% → 100% | 354d → none | 14313000M FS+34d → 14313000M |  |
| 14313010 | Vend Fab Q2&3 Peg Point #2a Final Design Review | 2010-12-07 A | 2011-12-30 → 2013-08-30 A (+609d) | 261d → 634d | 0% → 100% | 354d → none | 14313006 FS-139d, 14313020 FS-139d → 14313020 FS-195d, 14313006 FS-195d, 14315016 FS-195d |  |
| 14313002a | Reverse Entry per CR 11-017 | 2010-12-01 → 2010-12-21 A (+20d) | 2010-12-07 → 2010-12-30 A (+23d) | 5d → 3d | 0% → 100% | 458d → none |  |  |
| 14313015 | Vend Fab Q2&3 Peg Point #2b Final Design Review | 2011-04-01 → 2011-02-01 A (-59d) | 2011-12-30 → 2013-08-30 A (+609d) | 186d → 601d | 0% → 100% | 354d → none | 14313005, 14313010 FS-186d → 14313005, 14313010 FS-230d |  |
| 14313017 | Vend Fab Q2&3 Peg Point #3 Cryostat Component Complete | 2011-04-01 → 2011-02-01 A (-59d) | 2012-04-30 → 2013-08-30 A (+487d) | 269d → 688d | 0% → 100% | 354d → none | 14315029 FS-225d, 14313030 FS-186d, 14313015 FS-186d → 14315029 FS-265d, 14313030 FS-230d, 14313015 FS-230d |  |
| 14313018 | Vend Fab Q2&3 Peg Point #4a Cold Mass Fiducialitzation | 2011-04-01 → 2011-02-01 A (-59d) | 2012-09-28 → 2013-08-30 A (+336d) | 375d → 954d | 0% → 100% | 518d → none | 14315027, 14313017 FS-269d → 14313017 FS-355d, 14315027 |  |
| 14313020 | PDR/IDR Site Inspection | 2011-06-03 → 2011-08-01 A (+59d) | 2011-06-30 → 2013-07-15 A (+746d) | 20d → 433d | 0% → 100% | 354d → none | 14313006 FS-20d → 14313006 FS-124d |  |
| 14313P3LOE | Q2&3- P-3 Contract Mngmnt for Q2-3 | 2011-10-03 A | 2012-09-28 A |  | 0% → 100% | 20d → none |  |  |
| 14313019 | Vend Fab Q2&3 Peg Point #4b Cold Mass Fiducialitzation | 2012-04-02 → 2012-03-05 A (-28d) | 2012-09-28 → 2013-08-30 A (+336d) | 127d → 684d | 0% → 100% | 518d → none | 14313018 FS-127d → 14313018 FS-500d |  |
| 14313019a | Vend Fab Q2&3 Peg Point #5 Shipment | 2012-04-02 → 2012-03-05 A (-28d) | 2013-07-31 → 2013-08-30 A (+30d) | 333d → 702d | 0% → 100% | 518d → none | 14313019 FS-127d → 14313019 FS-500d |  |
| 14313P4LOE | Q2&3- P-4 Contract Mngmnt for Q2-3 | 2012-10-01 A | 2013-08-30 A | 228d → 248d | 0% → 100% | 20d → none |  | resources MECH DES [73.55 h]; MECH ENG [404.51 h]; TRAVEL → TRAVEL; MECH DES [73.55 h]; MECH ENG [404.51 h] |
| 14313030 | FDR Site Inspection | 2011-11-28 → 2013-08-30 A (+641d) | 2011-12-30 → 2013-08-30 A (+609d) |  | 0% → 100% | 354d → none |  | resources TRAVEL; MECH ENG [40 h] → MECH ENG [40 h]; TRAVEL |
| 14313220 | Q2 and Q3 Coil Inspection | 2012-04-03 → 2013-08-30 A (+514d) | 2012-04-30 → 2013-08-30 A (+487d) | 20d → 53d | 0% → 100% | 354d → none | 14313017 FS-20d → 14313017 FS-45d | resources TRAVEL; MECH ENG [40 h] → MECH ENG [40 h]; TRAVEL |
| 14313280 | Re-Baseline Actuals Adjustment | 2013-08-30 A | 2013-08-30 A |  | 0% → 100% | 20d → none | 9-130M FS+227d → none |  |
| 24313015 | Vend Fab Q2&3 Peg Point #2 Final Design Review | 2013-09-03 A | 2013-10-31 → 2013-10-21 A (-10d) |  | 0% → 100% | 1d → none |  |  |
| 24313017 | Vend Fab Q2&3 Peg Point #3 Cryostat Component Complete | 2013-09-03 A |  |  |  |  | 24313015 FS-43d, 24313030a FS-186d, 24313030 FS-186d → 24313030 FS-186d, 24313030a FS-20d, 24313015 FS-43d |  |
| 24313019 | Vend Fab Q2&3 Peg Point #4 Cold Mass Fiducialitzation | 2013-09-03 A |  |  |  | 6d → 49d |  |  |
| 24313019a | Vend Fab Q2&3 Peg Point #5 Shipment | 2013-09-03 A |  |  |  |  |  |  |
| 24313019b | Vend Fab Q2&3 Peg Point #6 Final Acceptance | 2013-09-03 A |  |  |  |  |  |  |
| 24313030a | FDR Site Inspection FY14 | 2013-10-01 → 2013-09-03 A (-28d) | 2013-10-03 → 2013-10-21 A (+18d) |  | 0% → 100% | 164d → none | 24313015 FS-40d, 24313030 → 24313030 FS-60d |  |
| 24313280 | Planning Package SigmaPhi Quads (second winding station) | 2013-09-03 A | 2014-04-30 → 2013-10-21 A (-191d) |  | 0% → 100% | 460d → none |  |  |
| 24313P4LOE | Q2&3- P-4 Contract Mngmnt for Q2-3 | 2013-09-03 A | 2013-09-30 A |  | 0% → 100% | 354d → none |  |  |
| 24313030 | FDR Site Inspection FY13 | 2013-09-06 A | 2013-09-30 → 2013-10-21 A (+21d) | 17d → 20d | 0% → 100% | 164d → none |  | resources MECH ENG [34 h]; TRAVEL → TRAVEL; MECH ENG [34 h] |
| 24313P5LOE | Q2&3- P-5 Contract Mngmnt for Q2-3 | 2013-10-01 A |  |  | 0% → 9% |  |  |  |
| 14314P1LOE | Dipole- P-1 Contract Mngmnt for Dipole | 2009-12-14 A | 2010-09-30 A |  | 0% → 100% | 573d → none |  | resources MECH DES [120 h]; MECH ENG [280 h]; TRAVEL → TRAVEL; MECH DES [120 h]; MECH ENG [280 h] |
| 14314000M5 | Dipole- Award Contract for SHMS Dipole Mag | 2010-08-02 → 2010-09-30 A (+59d) | 2010-08-02 → 2010-09-30 A (+59d) |  | 0% → 100% | 0d → none | 9-090M FS+63d, 122312070 → 122312070, 9-100M | constraint mandatory start 2010-08-02 → none |
| 14314002 | Dipole- Finalize Dsgn for Dipole Mag (Original Expenses) | 2010-08-02 → 2010-09-30 A (+59d) | 2010-08-31 → 2010-10-25 A (+55d) | 22d → 18d | 0% → 100% | 139d → none |  |  |
| 14314003 | Dipole- Contractor Expenses | 2010-08-02 → 2010-09-30 A (+59d) | 2010-08-27 → 2010-09-30 A (+34d) | 20d → 1d | 0% → 100% | 119d → none |  |  |
| 14314003a | Dipole Contractor Expenses Reverse Entry | 2010-09-30 A | 2010-09-30 A |  | 0% → 100% | 119d → none |  | was named Dipole Contractor Expenses - Reverse Entry |
| 14314004 | Vend Fab Dipole Intermediate Design Review Peg Point #1 | 2010-09-30 A | 2011-05-31 → 2011-11-28 A (+181d) | 163d → 288d | 0% → 100% | 119d → none | 9-110M FS-1d, 14314003, 14314002, 14314003a FS-1d → 14314003, 9-110M FS-1d, 14314003a, 14314002 FS-220d |  |
| 14314010 | Vend Fab Dipole Coil Tooling Delivered Peg Point #2 | 2010-09-30 A | 2011-09-30 → 2012-08-13 A (+318d) | 249d → 463d | 0% → 100% | 119d → none |  |  |
| 14314012 | Vend Fab Dipole Final Design Review Peg Point #3 | 2010-09-30 A | 2011-10-28 → 2013-08-30 A (+672d) | 269d → 576d | 0% → 100% | 119d → none | 14314010 FS-249d, 14315020 FS-182d → 14315020 FS-500d, 14314010 FS-249d |  |
| 14314015 | Vend Fab Dipole Second Coil Wind Peg Point #4a | 2010-09-30 A | 2012-03-30 → 2013-08-30 A (+518d) | 369d → 702d | 0% → 100% | 119d → none | 14314045 FS-269d, 14314012 FS-269d → 14314012 FS-269d, 14314045 FS-309d |  |
| 14314P2LOE | Dipole- P-2 Contract Mngmnt for Dipole | 2010-10-01 A | 2011-09-30 A |  | 0% → 100% | 573d → none |  | resources TRAVEL; MECH DES [80 h]; MECH ENG [440 h] → MECH DES [80 h]; MECH ENG [440 h]; TRAVEL |
| 14314020 | Vend Fab Dipole Second Coil Wind Peg Point #4b | 2011-04-01 → 2011-02-01 A (-59d) | 2012-03-30 → 2013-08-30 A (+518d) | 248d → 623d | 0% → 100% | 119d → none | 9-110M FS+120d, 14314015 FS-248d → 9-110M, 14314015 FS-275d |  |
| 14314025 | Vend Fab Dipole Outer Vessel Completed Peg Point #5a | 2011-04-01 → 2011-02-01 A (-59d) | 2012-05-31 → 2013-08-30 A (+456d) | 291d → 665d | 0% → 100% | 119d → none | 14314047 FS-487d, 14314020 FS-248d → 14314020 FS-275d, 14314047 FS-487d |  |
| 14314P3LOE | Dipole- P-3 Contract Mngmnt for Dipole | 2011-10-03 A | 2012-09-28 A |  | 0% → 100% | 573d → none |  | resources MECH ENG [440 h]; TRAVEL; MECH DES [80 h] → TRAVEL; MECH DES [80 h]; MECH ENG [440 h] |
| 14314036 | Dipole- Intermediate Design Review | 2011-05-03 → 2011-11-01 A (+182d) | 2011-05-31 → 2011-11-28 A (+181d) | 20d → 18d | 0% → 100% | 119d → none |  |  |
| 14314027 | Vend Fab Dipole Outer Vessel Completed Peg Point #5b | 2012-04-02 → 2012-03-05 A (-28d) | 2012-05-31 → 2013-08-30 A (+456d) | 43d → 395d | 0% → 100% | 119d → none | 14314020 FS-20d, 14314047 FS-245d, 14314025 FS-43d, 9-120M FS+120d → 14314047 FS-245d, 14314025 FS-460d, 9-070M, 9-120M, 14314020 FS-245d |  |
| 14314030 | Vend Fab Dipole Factory Test Completed Peg Point #6 | 2012-04-02 → 2012-03-05 A (-28d) | 2013-02-28 → 2013-08-30 A (+183d) | 226d → 558d | 0% → 100% | 119d → none | 14314027 FS-43d → 14314027 FS-475d |  |
| 14314045 | Dipole- Final Design Review | 2011-10-03 → 2012-05-01 A (+211d) | 2011-10-28 → 2012-09-10 A (+318d) | 20d → 92d | 0% → 100% | 119d → none | 14314012 FS-20d → 14314012 FS-500d |  |
| 14314P4LOE | Dipole- P-4 Contract Mngmnt for Dipole | 2012-10-01 A | 2013-08-30 A | 228d → 248d | 0% → 100% | 573d → none |  | resources MECH ENG [294.19 h]; TRAVEL; MECH DES [73.55 h] → TRAVEL; MECH DES [73.55 h]; MECH ENG [294.19 h] |
| 14314P4TLOE | Dipole- P-4 Contract Extra Travel | 2013-01-02 A | 2013-08-30 A | 169d → 189d | 0% → 100% | 573d → none | 14314P4LOE FS-169d → 14314P4LOE FS-189d |  |
| 14314100 | Planning Package SigmaPhi Phase 1 (Coil Developement) | 2013-01-02 → 2013-03-11 A (+68d) | 2013-03-29 → 2013-04-15 A (+17d) |  | 0% → 100% | 128d → none | 9-130M FS+59d → 9-130M FS+120d |  |
| 14314030a | Dipole Magnet Shipping | 2013-03-01 → 2013-08-30 A (+182d) | 2013-04-11 → 2013-08-30 A (+141d) | 30d → 54d | 0% → 100% | 119d → none |  |  |
| 14314047 | Dipole Inspect Coil | 2012-03-05 → 2013-08-30 A (+543d) | 2012-03-30 → 2013-08-30 A (+518d) |  | 0% → 100% | 358d → none |  |  |
| 14314115 | Re-Baseline Actuals Adjustment | 2013-08-30 A | 2013-08-30 A |  | 0% → 100% | 20d → none | 9-130M FS+227d → none |  |
| 24314012 | Vend Fab Dipole Final Design Review Peg Point #3 | 2013-09-03 A | 2013-10-31 → 2013-10-21 A (-10d) |  | 0% → 100% | 0d → none |  | resources PROCUREMENT<$50K 60 NO ESCALATION; PROCUREMENT>$50K 69 NO ESCALATION → PROCUREMENT>$50K 69 NO ESCALATION |
| 24314020 | Vend Fab Dipole Second Coil Wind Peg Point #4 | 2013-09-03 A |  |  |  | 0d → 86d |  |  |
| 24314027 | Vend Fab Dipole Outer Vessel Completed Peg Point #5 (F-12) | 2013-09-03 A |  |  |  | 0d → 43d |  |  |
| 24314028 | Vend Fab Dipole Conductor 4K Testing Peg Point #5a | 2013-09-03 A |  |  |  | 0d → 43d |  | was named Vend Fab Dipole 4K Testing Peg Point #5a; resources PROCUREMENT<$50K 60 NO ESCALATION → PROCUREMENT<$50K 60 NO ESCALATION; PROCUREMENT>$50K 69 NO ESCALATION |
| 24314030 | Vend Fab Dipole Factory Test Completed Peg Point #6 | 2013-09-03 A |  |  |  |  |  |  |
| 24314035 | Vend Fab Dipole Magnet Accepted Peg Point #7 | 2013-09-03 A |  |  |  |  |  |  |

| ID | Task | Start | Finish | Duration | Complete | Total float | Predecessors | Other |
| --- | --- | --- | --- | --- | --- | --- | --- | --- |
| 24314P4LOE | Dipole- P-4 Contract Mngmnt for Dipole | 2013-09-03 A | 2013-09-30 A |  | 0% → 100% | 495d → none |  |  |
| 24314P4TLOE | Dipole- P-4 Contract Extra Travel | 2013-09-03 A | 2013-09-30 A |  | 0% → 100% | 495d → none |  |  |
| 24314P5LOE | Dipole- P-5 Contract Mngmnt for Dipole | 2013-10-01 A |  |  | 0% → 9% |  |  |  |
| 24314110 | Planning Package SigmaPhi Phase 2 ( Coil Development, VPI ) | 2013-10-01 → 2014-02-03 (+125d) | 2014-04-11 → 2014-08-01 (+112d) |  |  | 861d → 783d | 9-140M → 9-140M FS+80d |  |
| 5 | **1.4.3.1.5 MAGNET COMPONENTS PROCURED BY JLAB** |  | 2014-08-25 → 2014-08-27 (+2d) |  |  |  |  |  |
| 14315010 | Design Superconductor for Q2/3 and Dipole | 2009-01-02 A | 2009-01-30 → 2009-04-24 A (+84d) | 20d → 79d | 0% → 100% | 1093d → none |  | resources MECH DES [72 h]; MECH ENG [140 h] → MECH ENG [140 h]; MECH DES [72 h] |
| 14315012 | Bidding Process Superconductor for Q2/3 and Dipole | 2009-06-10 → 2009-04-21 A (-50d) | 2009-08-05 → 2009-09-16 A (+42d) | 40d → 104d | 0% → 100% | 300d → none |  |  |
| 14315050LOE | Procurement Oversight | 2009-05-01 A | 2009-09-30 A |  | 0% → 100% | 1010d → none |  | resources MECH DES [80 h]; TRAVEL; MECH ENG [240 h] → TRAVEL; MECH ENG [240 h]; MECH DES [80 h] |
| 14315030 | Design Instruments & Controls for All Mag FY09 | 2009-07-02 → 2009-05-29 A (-34d) | 2009-09-30 → 2011-02-28 A (+516d) | 63d → 431.54d | 0% → 100% | 251d → none |  |  |
| 14315000 | Design DC Pwr Sys for All Mag (IPL) | 2009-12-15 → 2009-06-01 A (-197d) | 2010-01-20 → 2009-11-23 A (-58d) | 20d → 124d | 0% → 100% | 101d → none | 9-100M FS+51d → 9-100M | resources MECH ENG [220 h]; MECH DES [120 h] → MECH DES [120 h]; MECH ENG [220 h] |
| 14315022 | Bidding Process Cryo Reservoirs for All Mag | 2009-05-26 → 2009-06-15 A (+20d) | 2009-08-04 → 2009-11-23 A (+111d) | 50d → 114d | 0% → 100% | 346d → none |  |  |
| 14315030b | Design Instruments & Controls for All Mag FY10 | 2009-10-01 → 2009-09-30 A (-1d) | 2010-05-21 → 2011-02-28 A (+283d) | 157d → 346d | 0% → 100% | 251d → none | 14315030 → 14315030 FS-400d | resources MECH DES [302.58 h]; MECH ENG [570.91 h] → MECH ENG [570.91 h]; MECH DES [302.58 h] |
| 14315050LOEb | Procurement Oversight | 2009-10-01 A | 2010-09-30 A |  | 0% → 100% | 1010d → none |  | resources MECH ENG [240 h]; MECH DES [80 h]; TRAVEL → TRAVEL; MECH ENG [240 h]; MECH DES [80 h] |
| 14315002 | Bidding Process DC Pwr Sys for HB & Q1 Mag | 2010-08-30 → 2009-12-21 A (-252d) | 2010-12-29 → 2010-07-23 A (-159d) | 80d → 145d | 0% → 100% | 101d → none | 14315000 FS+154d → 14315000 |  |
| 14315003 | Bidding Process DC Pwr Sys forQ2/Q3/Dipole Mag | 2010-08-30 → 2009-12-21 A (-252d) | 2010-12-29 → 2010-07-23 A (-159d) | 80d → 145d | 0% → 100% | 101d → none | 14315000 FS+154d → 14315000 |  |
| 14315025 | Vend Fab Cryo Reservoirs Receipt of Materials less Electric Cylinders and LVDTs | 2010-01-04 A | 2010-01-29 A |  | 0% → 100% | 247d → none |  | resources PROCUREMENT>$50K 69 NO ESCALATION; PROCUREMENT<$50K 60 NO ESCALATION → PROCUREMENT<$50K 60 NO ESCALATION; PROCUREMENT>$50K 69 NO ESCALATION |
| 14315026 | Vend Fab Cryo Reservoirs Receipt of Electric Cylinders and LVDTs | 2010-01-04 A | 2010-03-31 → 2010-03-29 A (-2d) | 61d → 59d | 0% → 100% | 247d → none |  |  |
| 14315027 | Vend Fab Cryo Reservoirs CCR#2 & 3 JT Valves and Bayonets Complete | 2010-01-04 A | 2010-08-31 → 2010-06-01 A (-91d) | 168d → 104d | 0% → 100% | 247d → none |  |  |
| 14315027A | Vend Fab Cryo Reservoirs CCR#2 & 3 Complete | 2010-01-04 A | 2010-12-30 → 2011-01-24 A (+25d) | 247d → 262d | 0% → 100% | 247d → none |  |  |
| 14315027B | Vend Fab Cryo Reservoirs CCR#2 & 3 Approved Acceptance Test/Shipment | 2010-01-04 A | 2011-01-31 → 2011-02-28 A (+28d) | 267d → 286d | 0% → 100% | 247d → none |  |  |
| 14315027C | Vend Fab Cryo Reservoirs CCR#1 Test and Fabrication Documentation | 2010-01-04 A | 2011-02-28 A |  | 0% → 100% | 354d → none |  |  |
| 14315027D | Vend Fab Cryo Reservoirs CCR#4 5 & 6 JT Valves and Bayonets Complete | 2010-01-04 A | 2010-08-31 → 2010-06-01 A (-91d) | 168d → 104d | 0% → 100% | 354d → none |  |  |
| 14315027F | Vend Fab Cryo Reservoirs CCR#4 5 & 6 Complete | 2010-01-04 A | 2011-10-31 → 2011-12-19 A (+49d) | 458d → 491d | 0% → 100% | 354d → none |  |  |
| 14315027G | Vend Fab Cryo Reservoirs CCR#4 5 & 6 Approved Acceptance Test/Shipment | 2010-01-04 A | 2011-12-29 → 2012-01-27 A (+29d) | 494d → 513d | 0% → 100% | 354d → none |  |  |
| 14315027H | Vend Fab Cryo Reservoirs CCR#4 5 & 6 Test and Fabrication Documentation | 2010-01-04 A | 2012-01-31 → 2012-02-20 A (+20d) | 515d → 528d | 0% → 100% | 354d → none |  |  |
| 14315032 | Bidding Process Instruments & Controls for All Mag | 2010-05-24 → 2010-03-01 A (-84d) | 2010-05-28 → 2010-03-01 A (-88d) | 5d → 1d | 0% → 100% | 251d → none | 14315030b → 14315030b FS-30d |  |
| 14315035 | Proc Instruments & Controls for HB and Q1 magnets | 2010-06-01 → 2010-03-01 A (-92d) | 2010-12-03 → 2011-04-29 A (+147d) | 130d → 292d | 0% → 100% | 251d → none | 14315032 → 14315032 FS-70d |  |
| 14315015 | Procure and Extrude Copper Stabilizer | 2010-05-03 → 2010-04-26 A (-7d) | 2010-12-21 → 2011-03-28 A (+97d) | 162d → 228d | 0% → 100% | 119d → none | 14314000M5 FS-63d, 14315012 → 14315012, 14314000M5 FS-64d |  |
| 14315038 | Assemble & Test Instruments & Controls Phase 1 (FY10) | 2010-12-06 → 2010-04-26 A (-224d) | 2011-05-04 → 2010-09-24 A (-222d) | 100d → 107d | 0% → 100% | 251d → none | 14315035 → 14315035 FS-160d | resources ELEC TECH [800 h]; MECH ENG [520 h] → MECH ENG [520 h]; ELEC TECH [800 h] |
| 14315055 | Procure Burnout Resistant Current Leads | 2010-05-03 → 2010-05-24 A (+21d) | 2010-05-28 → 2010-05-24 A (-4d) | 20d → 1d | 0% → 100% | 269d → none |  |  |
| 14315015A | Solder SC Cable to Extrusion | 2010-08-06 → 2010-09-13 A (+38d) | 2011-01-25 → 2012-03-30 A (+430d) | 113d → 382d | 0% → 100% | 129d → none | 14315015 FS-95d → 14315015 FS-75d |  |
| 14315027J | Vend Fab Cryo Reservoirs CCR#4 5 & 6 Vendor Change Order | 2010-09-01 → 2010-09-20 A (+19d) | 2010-09-01 → 2010-09-20 A (+19d) |  | 0% → 100% | 700d → none |  |  |
| 14315060 | Vend Fab DCPS - Peg Point #1 Design & Approval | 2010-09-30 A | 2011-02-28 → 2011-02-25 A (-3d) | 98d → 97d | 0% → 100% | 101d → none |  | was named Vend Fab DCPS - Design & Approval |
| 14315065 | Vend Fab DCPS - Peg Point #2 Materials in-house to start prod: Items 1&2 | 2010-09-30 A | 2011-04-29 → 2011-08-15 A (+108d) | 142d → 216d | 0% → 100% | 101d → none |  | was named Vend Fab DCPS - Materials in-house to start prod: Items 1&2 |
| 14315070 | Vend Fab DCPS - Peg Point #3 Materials in-house to start prod: Items 3,4,&5 | 2010-09-30 A | 2011-11-30 → 2012-01-31 A (+62d) | 290d → 327d | 0% → 100% | 101d → none |  | was named Vend Fab DCPS - Materials in-house to start prod: Items 3,4,&5 |
| 14315075 | Vend Fab DCPS - Peg Point #4 Shipment of Items 1&2 | 2010-09-30 A | 2012-02-29 → 2012-12-17 A (+292d) | 347d → 572d | 0% → 100% | 101d → none |  | was named Vend Fab DCPS - Shipment of Items 1&2 |
| 14315080 | Vend Fab DCPS - Peg Point #5 Arrival Test of Items 1&2 | 2010-09-30 A | 2012-05-31 → 2013-08-30 A (+456d) | 412d → 638d | 0% → 100% | 101d → none |  | was named Vend Fab DCPS - Arrival Test of Items 1&2 |
| 14315085 | Vend Fab DCPS - Peg Point #6 Shipment of Items 3,4,&5 | 2010-09-30 A | 2012-10-30 → 2013-05-10 A (+192d) | 518d → 594d | 0% → 100% | 101d → none |  | was named Vend Fab DCPS - Shipment of Items 3,4,&5 |
| 14315090 | Vend Fab DCPS - Peg Point #7 Arrival Test of Items 3,4,&5 | 2010-09-30 A | 2013-03-29 → 2013-08-30 A (+154d) | 616d → 659d | 0% → 100% | 683d → none |  | was named Vend Fab DCPS - Arrival Test of Items 3,4,&5 |
| 14315095 | Vend Fab DCPS - Peg Point #8 Delivery of Spare Parts & Maintenance Inventory | 2010-09-30 A | 2013-03-29 → 2013-05-10 A (+42d) | 616d → 659d | 0% → 100% | 683d → none |  | was named Vend Fab DCPS -Delivery of Spare Parts & Maintenance Inventory |
| 14315050LOEc | Procurement Oversight | 2010-10-01 A | 2011-09-29 A |  | 0% → 100% | 1010d → none |  |  |
| 14315037a | Assemble & Test Instruments & Controls Phase 2 (FY11) | 2011-05-05 → 2010-11-01 A (-185d) | 2011-09-26 → 2013-06-17 A (+630d) | 100d → 589d | 0% → 100% | 251d → none |  |  |
| 14315042 | Bidding Process Iron Yoke for Q2/3 and Dipole | 2009-03-05 → 2011-01-03 A (+669d) | 2009-06-25 → 2012-01-09 A (+928d) | 80d → 252d | 0% → 100% | 692d → none | 14315055x → 9-110M FS+30d, 14315055x |  |
| 14315016 | Inspect & Ship Superconductor for Q2/3 and Dipole to ReRolling Facility | 2011-01-26 → 2011-02-01 A (+6d) | 2011-03-09 → 2011-11-14 A (+250d) | 30d → 201d | 0% → 100% | 119d → none | 14315015Ba, 14315015B → 14315015Ba FS-215d, 14315015B FS-115d | resources MECH ENG [200 h]; MECH DES [240 h]; SUPPLIES & MATERIALS → SUPPLIES & MATERIALS; MECH ENG [200 h]; MECH DES [240 h] |
| 14315028 | Inspect & Ship Cryo Reservoirs for HB & Q1 magnets | 2011-02-01 A | 2011-04-29 → 2013-07-15 A (+808d) | 63d → 547d | 0% → 100% | 247d → none |  | resources MECH ENG [360 h]; MECH DES [160 h]; MECH TECH [320 h]; SUPPLIES & MATERIALS → MECH TECH [320 h]; MECH DES [160 h]; SUPPLIES & MATERIALS; MECH ENG [360 h] |
| 14315018 | ReRoll Superconductor Prototype Run | 2011-05-02 → 2011-06-01 A (+30d) | 2011-05-27 → 2011-12-19 A (+206d) | 20d → 140d | 0% → 100% | 119d → none | 14315016 FS+37d → 14315016 FS-60d |  |
| 14315015A5 | Completion of Solder SC Cable to Extrusion Part A | 2011-05-02 → 2011-07-01 A (+60d) | 2011-05-13 → 2012-10-15 A (+521d) | 10d → 322d | 0% → 100% | 129d → none | 14315015A FS+67d → 14315015A FS-88d |  |
| 14315050LOEd | Procurement Oversight FY11 | 2011-09-30 → 2011-10-03 A (+3d) | 2011-09-30 → 2011-10-03 A (+3d) |  | 0% → 100% | 1010d → none |  |  |
| 14315050LOEf | Procurement Oversight FY12 | 2011-10-03 A | 2012-09-27 A |  | 0% → 100% | 1010d → none |  |  |
| 14315019 | ReDraw Superconductor Production Run | 2012-01-04 → 2012-01-03 A (-1d) | 2012-02-15 → 2012-02-16 A (+1d) | 30d → 32d | 0% → 100% | 143d → none |  |  |
| 14315045 | Vend Fab Yoke Steel Planning for Dipole, Q2, Q3 Delivered & Accepted | 2012-01-12 A | 2012-03-30 A |  | 0% → 100% | 64d → none |  |  |
| 14315045A | Vend Fab Yoke Steel Receipt of Steel Material Inspected | 2012-01-12 A | 2012-05-31 A |  | 0% → 100% | 64d → none |  |  |
| 14315045B | Vend Fab Yoke Steel 1st Article: 1st Dipole/Yoke/Casting Inspt/Accept | 2012-01-12 A | 2012-06-29 → 2012-05-14 A (-46d) | 118d → 86d | 0% → 100% | 64d → none |  |  |
| 14315045C | Vend Fab Yoke Steel SHMS Dipole Casting/ Annealing Comp. Casting Delv/Accept | 2012-01-12 A | 2012-08-31 → 2012-08-20 A (-11d) | 163d → 154d | 0% → 100% | 149d → none |  |  |
| 14315045D | Vend Fab Yoke Steel SHMS Q3 Cast/Annel Comp. Cast Deliv.Accept | 2012-01-12 A | 2012-10-31 → 2012-08-20 A (-72d) | 205d → 154d | 0% → 100% | 149d → none |  |  |
| 14315045F | Vend Fab Yoke Steel SHMS Q2 Cast/Annel Comp. Cast Deliv/Accept | 2012-01-12 A | 2013-02-28 → 2012-10-15 A (-136d) | 281d → 193d | 0% → 100% | 149d → none |  |  |
| 14315020 | Ship Superconductor for Q2/3 and Dipole to Magnet Vendor | 2011-05-31 → 2012-01-16 A (+230d) | 2011-06-27 → 2013-07-15 A (+749d) | 20d → 340d | 0% → 100% | 119d → none | 14315015A5a, 14315018, 14315019 FS-200d, 14315015A5, 14315019B FS-473d → 14315018, 14315019B FS-473d, 14315015A5a FS-85d, 14315015A5 FS-85d, 14315019 FS-240d |  |
| 14315036 | Proc Instruments & Controls for Q2/3 and Dipole magnets Part A | 2012-03-05 → 2012-02-01 A (-33d) | 2012-09-05 → 2012-10-15 A (+40d) | 130d → 180d | 0% → 100% | 117d → none |  |  |
| 14315044LOE | Travel Expenses to Yoke Steel Casting Vendor FY12 | 2012-02-01 A | 2012-09-28 A |  | 0% → 100% | 149d → none |  |  |
| 14315046b | Procure Yoke Hardware | 2012-07-25 → 2012-02-09 A (-167d) | 2012-10-17 → 2012-04-06 A (-194d) | 60d → 41d | 0% → 100% | 235d → none | 14315046a → 14315046a FS-110d |  |
| 14315046 | Large Magnet Yoke Machining | 2012-07-16 → 2012-02-13 A (-154d) | 2013-06-28 → 2013-06-24 A (-4d) | 238d → 345d | 0% → 100% | 64d → none | 14315045B FS+10d, 9-120M FS+45d, 14315042 → 14315042, 9-120M FS+45d, 14315045B FS-150d |  |
| 14315015B | Obtain RRR Measurement of Copper Part A | 2010-08-06 → 2012-02-15 A (+558d) | 2011-01-25 → 2012-09-28 A (+612d) | 113d → 158d | 0% → 100% | 119d → none | 14315015 FS-95d → 14315015 FS+5d, 14315015A FS-50d |  |
| 14315029 | Inspect & Ship Cryo Reservoirs for Q2/3 & Dipole magnets | 2011-12-30 → 2012-03-02 A (+63d) | 2012-02-28 → 2012-05-14 A (+76d) | 40d → 52d | 0% → 100% | 354d → none |  |  |
| 14315043 | Dipole Top and Bottom Plates | 2012-01-12 → 2012-03-02 A (+50d) | 2012-07-03 → 2012-06-11 A (-22d) | 120d → 70d | 0% → 100% | 310d → none | 9-120M FS+65d → 9-120M FS+95d |  |
| 14315046a | Vend Fab Yoke supports and cylinders | 2012-02-03 → 2012-04-02 A (+59d) | 2012-07-24 → 2012-10-22 A (+90d) | 120d → 143d | 0% → 100% | 235d → none | 9-120M FS+80d, 14315042 → 9-120M FS+5d, 14315042 | resources PROCUREMENT>$50K 69; PROCUREMENT<$50K 60 → PROCUREMENT<$50K 60; PROCUREMENT>$50K 69 |
| 14315037 | Assemble & Test Instruments & Controls Phase 3 FY12 | 2012-04-16 → 2012-07-02 A (+77d) | 2012-09-28 → 2013-08-30 A (+336d) | 117d → 269d | 0% → 100% | 117d → none | 14315037a, 14315036 FS-100d → 14315036 FS-100d, 14315037a FS-130d | resources MECH ENG [754.84 h]; ELEC TECH [735.97 h]; ELEC ENG [75.48 h]; MECH DES [301.94 h]; MECH TECH [226.45 h] → ELEC TECH [735.97 h]; MECH ENG [754.84 h]; ELEC ENG [75.48 h]; MECH DES [301.94 h]; MECH TECH [226.45 h] |
| 14315037b | Assemble & Test Instruments & Controls Phase 3 FY13 | 2012-10-01 → 2012-07-02 A (-91d) | 2013-04-15 → 2013-08-30 A (+137d) | 131d → 269d | 0% → 100% | 117d → none | 14315037 → 14315037 FS-230d |  |
| 14315044LOEa | Travel Expenses to Yoke Steel Casting Vendor FY13 | 2012-10-01 → 2012-09-10 A (-21d) | 2013-02-28 → 2012-09-17 A (-164d) | 99d → 6d | 0% → 100% | 149d → none | 14315044LOE, 14315045 FS-42d → 14315044LOE |  |
| 14315015A5a | Completion of Solder SC Cable to Extrusion Part B | 2011-05-02 → 2012-10-01 A (+518d) | 2011-05-13 → 2012-10-15 A (+521d) | 10d → 11d | 0% → 100% | 129d → none | 14315015A FS+67d → 14315015A FS-88d |  |
| 14315019A | Dimensional Inspection of Soldered Conductor at Vendor | 2013-01-02 → 2013-01-01 A (-1d) | 2013-04-25 → 2013-01-31 A (-84d) |  | 0% → 100% | 119d → none |  |  |

| ID | Task | Start | Finish | Duration | Complete | Total float | Predecessors | Other |
| --- | --- | --- | --- | --- | --- | --- | --- | --- |
| 14315019B | Materials to support Conductor Inspection at Vendor | 2013-01-02 → 2013-01-01 A (-1d) | 2013-04-25 → 2013-01-28 A (-87d) |  | 0% → 100% | 119d → none |  |  |
| 14315050LOEg | Procurement Oversight FY13 | 2013-01-02 A | 2013-08-30 A | 169d → 189d | 0% → 100% | 1010d → none |  |  |
| 14315015Ba | Obtain RRR Measurement of Copper Part B | 2010-08-06 → 2013-07-01 A (+1060d) | 2011-01-25 → 2013-08-30 A (+948d) | 113d → 55d | 0% → 100% | 119d → none | 14315015 FS-95d → 14315015 FS+5d, 14315015A FS-50d, 9-130M FS+200d |  |
| 14315031M | Q1 Magnet Vendor Receipt of Cryoresevoir | 2011-04-29 → 2013-07-15 A (+808d) | 2011-04-29 → 2013-07-15 A (+808d) |  | 0% → 100% | 247d → none |  |  |
| 14315100 | Install Moeller Quad #2 (6GEV) | 2013-06-27 → 2013-08-01 A (+35d) | 2013-06-27 → 2013-08-01 A (+35d) |  | 0% → 100% | 65d → none |  |  |
| 14315105 | Re-Baseline Actuals Adjustment | 2013-08-30 A | 2013-08-30 A |  | 0% → 100% | 20d → none | 9-130M FS+227d → none |  |
| 24315015Ba | Obtain Short-Sample SC Measurements | 2013-09-03 A | 2014-01-31 → 2013-09-23 A (-130d) |  | 0% → 100% | 473d → none |  | resources PROCUREMENT<$50K 60 NO ESCALATION FY14 → PROCUREMENT<$50K 60 |
| 24315015Bb | Obtain RRR Measurement of Copper Part B FY13 | 2013-09-03 A | 2013-09-30 → 2013-11-15 (+46d) | 20d → 44d | 0% → 50% | 527d → 517d |  |  |
| 24315015Bba | Obtain RRR Measurement of Copper Part B FY14 | 2013-10-01 → 2013-09-03 A (-28d) | 2013-11-01 → 2013-11-15 (+14d) |  | 0% → 50% | 527d → 955d | 9-130M FS+228d, 24315015Bb → 24315015Bb FS-60d |  |
| 24315036a5 | Proc Instruments & Controls for Q2/3 and Dipole magnets Part B | 2013-09-03 A | 2014-01-31 → 2013-09-23 A (-130d) |  | 0% → 100% | 287d → none |  |  |
| 24315037b | Assemble & Test Instruments & Controls Phase 3 FY13 | 2013-09-03 A | 2013-09-30 → 2014-03-13 (+164d) | 20d → 127d |  |  |  |  |
| 24315037ba | Assemble & Test Instruments & Controls Phase 3 FY14 | 2013-10-01 → 2013-09-03 A (-28d) |  |  |  | 245d → 882d | 9-130M FS+228d, 24315037b → 24315037b FS-110d |  |
| 24315050LOEg | Procurement Oversight FY13 | 2013-09-03 A | 2013-09-30 A |  | 0% → 100% | 989d → none |  |  |
| 24315080 | Vend Fab DCPS - Arrival Test of Items 1&2 | 2013-09-03 A | 2013-11-27 → 2014-03-03 (+96d) |  |  | 509d → 456d |  |  |
| 24315090 | Vend Fab DCPS - Arrival Test of Items 3,4,&5 | 2013-09-03 A | 2013-11-27 → 2014-03-03 (+96d) |  |  | 509d → 452d | 24315080 FS-62d → 24315080 FS-80d |  |
| 24315007 | Test & Integrate DC Pwr Sys for all magnets | 2014-06-02 → 2014-06-04 (+2d) | 2014-08-25 → 2014-08-27 (+2d) |  |  | 331d → 329d |  |  |
| 243161030LOE | Oversight of Spare Coil Winding |  |  |  |  |  |  | resources TRAVEL; MECH ENG [952 h] → MECH ENG [952 h]; TRAVEL |
| 2 | **1.4.3.2 DETECTOR** | 2009-10-01 → 2009-08-05 (-57d) | 2014-09-03 → 2014-09-02 (-1d) |  |  |  |  |  |
| 1 | **1.4.3.2.1 WIRE CHAMBERS** | 2009-10-01 → 2009-09-14 (-17d) | 2014-09-03 → 2014-09-02 (-1d) |  |  |  |  |  |
| 14321000M | Award Contract for Wire Chambs | 2009-10-01 → 2009-09-14 A (-17d) | 2009-10-01 → 2009-09-14 A (-17d) |  | 0% → 100% | 249d → none |  |  |
| 14321005 | Fab Wire Chambers at University | 2009-10-01 → 2009-09-14 A (-17d) | 2011-09-28 → 2013-08-26 A (+698d) | 494d → 839d | 0% → 100% | 249d → none |  |  |
| 143218P1LOE | P-1 Supervise Fab of Wire Chambs | 2009-10-01 → 2009-09-14 A (-17d) | 2010-09-30 A | 248d → 261d | 0% → 100% | 498d → none |  |  |
| 143218P2LOE | P-2 Supervise Fab of Wire Chambs | 2010-10-01 A | 2011-09-27 A |  | 0% → 100% | 498d → none |  |  |
| 14321007 | Procure Connectors and Components | 2010-07-01 → 2010-10-22 A (+113d) | 2010-09-30 → 2013-08-30 A (+1065d) | 64d → 563d | 0% → 100% | 743d → none |  |  |
| 14321900 | Proc Prep and Fab of Drift Gas Manifold Parts Original | 2012-01-30 → 2012-02-01 A (+2d) | 2012-01-31 → 2012-02-06 A (+6d) | 2d → 4d | 0% → 100% | 417d → none |  |  |
| 14321900a | Reverse Entry per CR12-022 | 2012-02-03 → 2012-02-01 A (-2d) | 2012-02-06 A | 2d → 4d | 0% → 100% | 165d → none |  |  |
| 14321905 | Refurbish LVPS | 2012-02-03 → 2012-03-02 A (+28d) | 2012-07-24 → 2012-03-30 A (-116d) | 120d → 21d | 0% → 100% | 295d → none |  |  |
| 14321900b | Proc Prep and Fab of Drift Gas Manifold Parts Revised per CR12-022 | 2013-01-03 → 2012-11-12 A (-52d) | 2013-05-31 → 2013-02-18 A (-102d) | 104d → 134d | 0% → 100% | 84d → none | 9-130M FS+60d, 14324001a → 14324001a, 9-130M | resources PROCUREMENT<$50K 60; MECH DES [80 h] → MECH DES [80 h]; PROCUREMENT<$50K 60 |
| 14321910 | Re-Baseline Actuals Adjustment | 2013-08-30 A | 2013-08-30 A |  | 0% → 100% | 20d → none | 9-130M FS+227d → none |  |
| 14321015M | Test Wire Chambers at University | 2012-09-27 → 2013-08-30 A (+337d) | 2012-09-27 → 2013-08-30 A (+337d) |  | 0% → 100% | 249d → none | 14321007, 14321005 FS+248d, 143218P2LOE → 14321005, 143218P2LOE, 14321007 |  |
| 24321007 | Procure Connectors and Components | 2013-09-03 A | 2013-09-30 A |  | 0% → 100% | 504d → none |  |  |
| 24321015M | Test Wire Chambers at University | 2014-09-03 → 2014-09-02 (-1d) | 2014-09-03 → 2014-09-02 (-1d) |  |  | 276d → 277d |  |  |
| 2 | **1.4.3.2.2 HODOSCOPE (Trigger Hodoscopes)** | 2009-10-01 → 2009-08-05 (-57d) |  |  |  |  |  |  |
| 14322000M | Award Contract for Scintillator Hodoscope Planes | 2009-10-01 → 2009-08-05 A (-57d) | 2009-10-01 → 2009-08-05 A (-57d) |  | 0% → 100% | 495d → none |  |  |
| 14322005M | Award Contract for Quartz Hodoscope Planes | 2009-10-01 → 2009-08-27 A (-35d) | 2009-10-01 → 2009-08-27 A (-35d) |  | 0% → 100% | 495d → none |  |  |
| 14322010 | Fab 3 Scintillator Planes (incl Supprt) (HODOSCP) | 2009-10-01 → 2009-09-08 A (-23d) | 2011-09-30 → 2013-01-28 A (+486d) | 496d → 836d | 0% → 100% | 495d → none |  |  |
| 14322015 | Fab 1 Quartz Hodoscope Plane | 2009-10-01 → 2009-09-08 A (-23d) | 2011-09-30 → 2013-01-28 A (+486d) | 496d → 836d | 0% → 100% | 495d → none |  |  |
| 14322013 | Detail Quartz Hodoscope Mounts | 2011-03-04 → 2011-08-18 A (+167d) | 2011-08-08 → 2012-02-13 A (+189d) | 110d → 118d | 0% → 100% | 533d → none | 14322005M, 9-110M FS+100d → 9-110M FS+170d, 14322005M |  |
| 14322020 | Re-Baseline Actuals Adjustment | 2013-08-30 A | 2013-08-30 A |  | 0% → 100% | 20d → none | 9-130M FS+227d → none |  |
| 143238P1LOE | P-1 Supervise Constrctn of Noble Gas Cerenkov FY12 | 2012-01-05 A | 2012-09-28 A | 187d → 186.63d | 0% → 100% | 1010d → none | 122323015, 14323000M → 14323000M FS-40d, 122323015 |  |
| 14323010 | Design & Build Vacuum Box | 2012-01-05 → 2012-04-02 A (+88d) | 2012-07-10 → 2013-08-30 A (+416d) | 130d → 223d | 0% → 100% | 45d → none |  |  |
| 14323000M | Award Contract for Noble Gas Cerenkov to University | 2012-01-05 → 2012-04-27 A (+113d) | 2012-01-05 → 2012-04-27 A (+113d) |  | 0% → 100% | 45d → none | 9-120M FS+60d → 9-120M FS+120d |  |
| 14323005 | Fab Noble Gas Cerenkov FY12 | 2012-01-05 → 2012-04-27 A (+113d) | 2012-09-28 → 2013-08-30 A (+336d) | 187d → 335d | 0% → 100% | 168d → none |  | resources PLABOR; CONTRB UNIV LBR [364.19 h]; MECH DES [280.15 h]; PD UNIV STAFF [672.36 h] → MECH DES [280.15 h]; PLABOR; PD UNIV STAFF [672.36 h]; CONTRB UNIV LBR [364.19 h] |
| 14323005a | Fab Noble Gas Cerenkov FY13 | 2012-10-01 → 2012-04-27 A (-157d) | 2013-01-31 → 2013-08-30 A (+211d) | 80d → 335d | 0% → 100% | 168d → none | 14323005 → 14323005 FS-185d |  |
| 14323005b | Fab Noble Gas Cerenkov Procurement | 2012-01-05 → 2012-04-27 A (+113d) | 2013-01-31 → 2013-08-30 A (+211d) | 267d → 335d | 0% → 100% | 168d → none |  |  |
| 143238P1LOEa | P-1 Supervise Constrctn of Noble Gas Cerenkov FY13 | 2012-10-01 A | 2013-01-31 A |  | 0% → 100% | 1010d → none |  |  |
| 143238P1LOEb | P-2 Supervise Constrctn of Noble Gas Cerenkov | 2013-02-01 A | 2013-08-30 A | 148d → 168d | 0% → 100% | 1010d → none |  |  |
| 14323015 | Detailing Cerenkov-to-Magnet Interface | 2013-01-23 → 2013-04-08 A (+75d) | 2013-07-26 → 2013-06-17 A (-39d) |  | 0% → 100% | 45d → none | 14323010 FS+130d → 14323010 FS-80d |  |
| 14323020 | Re-Baseline Actuals Adjustment | 2013-08-30 A | 2013-08-30 A |  | 0% → 100% | 20d → none | 9-130M FS+227d → none |  |
| 24323005b | Fab Noble Gas Cerenkov Procurement | 2013-09-03 A |  |  | 0% → 20% |  |  |  |
| 24323012 | Build Vacuum Box | 2013-09-03 A |  |  |  |  |  |  |
| 243238P1LOEb | P-2 Supervise Constrctn of Noble Gas Cerenkov | 2013-09-03 A | 2013-09-30 A |  | 0% → 100% | 551d → none |  |  |
| 4 | **1.4.3.2.4 HEAVY GAS CERENKOV** | 2011-06-06 → 2011-05-06 (-31d) | 2014-07-31 → 2014-07-30 (-1d) |  |  |  |  |  |
| 14324000 | Engineering & Design Oversite FY11 | 2011-06-06 → 2011-05-06 A (-31d) | 2011-09-30 → 2012-05-14 A (+227d) | 83d → 253.18d | 0% → 100% | 1160d → none |  |  |
| 14324000a | Engineering & Design Oversite FY12 | 2011-10-03 → 2011-05-06 A (-150d) | 2011-12-30 → 2012-05-14 A (+136d) | 58d → 254d | 0% → 100% | 1160d → none | 14324000 → 14324000 FS-60d |  |
| 14324001 | Engineering & Design - Gas System FY11 | 2011-06-06 → 2011-08-01 A (+56d) | 2011-09-30 → 2012-10-15 A (+381d) | 83d → 302d | 0% → 100% | 291d → none |  |  |
| 14324001a | Engineering & Design - Gas System FY12 | 2011-10-03 → 2011-08-01 A (-63d) | 2012-01-27 → 2012-10-15 A (+262d) | 76d → 301.69d | 0% → 100% | 291d → none | 14324001 → 14324001 FS-120d |  |
| 14324010 | Ship and Aluminize Mirrors | 2012-01-05 → 2011-11-01 A (-65d) | 2013-01-31 → 2012-08-20 A (-164d) | 267d → 198d | 0% → 100% | 168d → none | 9-120M FS+60d → 9-120M |  |
| 143248P1LOE | P-1 Supervise Constrctn of Heavy Gas Cerenkov FY12 | 2012-01-05 A | 2012-09-28 A | 187d → 186.63d | 0% → 100% | 1158d → none | 9-120M FS+60d, 14324000a, 122324015 → 14324000a FS-50d, 9-120M FS+60d, 122324015 |  |
| 14324003 | Fab Gas System Original | 2012-01-30 → 2012-02-01 A (+2d) | 2012-01-31 → 2012-02-06 A (+6d) | 2d → 4d | 0% → 100% | 417d → none |  |  |
| 14324003a | Reverse Entry per CR12-022 | 2012-02-03 → 2012-02-01 A (-2d) | 2012-02-06 A | 2d → 4d | 0% → 100% | 165d → none |  |  |
| 143248P1LOE5 | P-1 Supervise Constrctn of Heavy Gas Cerenkov FY13 | 2012-10-01 A | 2013-01-31 A |  | 0% → 100% | 1158d → none |  |  |
| 14324003b | Fab Gas System Revised per CR12-022-- Procurement | 2013-03-04 → 2013-04-01 A (+28d) | 2013-05-24 → 2013-08-30 A (+98d) |  | 0% → 100% | 20d → none |  |  |
| 14324005 | ASSEMBLE Gas System | 2013-05-28 → 2013-08-27 A (+91d) | 2013-08-30 A | 68d → 147d | 0% → 100% | 20d → none |  |  |
| 14324015 | Re-Baseline Actuals Adjustment | 2013-08-30 A | 2013-08-30 A |  | 0% → 100% | 20d → none | 9-130M FS+227d → none |  |
| 24324005 | Assemble HGC Gas System & Leak-check tank | 2014-07-03 → 2014-07-02 (-1d) | 2014-07-31 → 2014-07-30 (-1d) |  |  | 281d → 282d |  |  |
| 5 | **1.4.3.2.5 SHOWER COUNTER** | 2011-05-31 → 2010-06-01 (-364d) | 2013-12-20 → 2014-02-04 (+46d) |  |  |  |  |  |
| 14325005 | Buy Lead Glass Blocks (SHOWER COUNTER) | 2011-10-03 → 2010-06-01 A (-489d) | 2012-04-13 → 2010-06-30 A (-653d) | 130d → 21d | 0% → 100% | 305d → none |  |  |
| 14325010 | Buy PMTs & Bases (SHOWER COUNTER) | 2012-04-16 → 2010-06-01 A (-685d) | 2012-07-10 → 2010-06-30 A (-741d) | 60d → 22d | 0% → 100% | 305d → none |  |  |
| 14325027 | Procure F250 ADCs (SHOWER COUNTER) | 2012-01-04 → 2012-01-03 A (-1d) | 2012-11-30 → 2012-10-15 A (-46d) | 231d → 200d | 0% → 100% | 128d → none |  |  |

| ID | Task | Start | Finish | Duration | Complete | Total float | Predecessors | Other |
| --- | --- | --- | --- | --- | --- | --- | --- | --- |
| 14325027b | Procure TI for Calorimeter Ref. Hall D 1543040 | 2011-09-08 → 2012-01-16 A (+130d) | 2011-10-17 → 2012-11-12 A (+392d) | 28d → 211d | 0% → 100% | 484d → none | 9-110M FS+231d → 9-110M FS+231d, 9-120M FS+65d |  |
| 14325027c | Procure SD for Calorimeter Ref. Hall D 1543055 | 2011-05-31 → 2012-02-01 A (+246d) | 2011-08-31 → 2012-10-15 A (+411d) | 66d → 180d | 0% → 100% | 516d → none | 9-110M FS+161d → 9-120M FS+90d, 9-110M FS+161d |  |
| 14325027a | Procure CTP for Calorimeter Ref. Hall D 1543025 | 2011-07-12 → 2012-09-17 A (+433d) | 2011-08-31 → 2013-08-30 A (+730d) | 37d → 217d | 0% → 100% | 516d → none | 9-110M FS+190d → 9-130M, 9-110M FS+190d, 9-120M FS+185d |  |
| 14325028 | UMASS - Testing of F250 ADCs by University (SHOWER COUNTER) REFERENCE 1541057 | 2012-10-31 → 2012-09-17 A (-44d) | 2013-03-29 → 2013-01-28 A (-60d) | 98d → 130d | 0% → 100% | 128d → none | 14325027 FS-21d → 14325027 FS-40d |  |
| 14325015 | Fab Supprt Sys (SHOWER COUNTER) | 2013-04-01 → 2013-04-08 A (+7d) | 2013-04-12 → 2013-05-13 A (+31d) |  | 0% → 100% | 118d → none | 14363030, 14363030a, 14325005 → 14325005, 14363030a FS-100d, 14363030 FS-40d |  |
| 14325030 | Re-Baseline Actuals Adjustment | 2013-08-30 A | 2013-08-30 A |  | 0% → 100% | 20d → none | 9-130M FS+227d → none |  |
| 24325027a | Procure CTP for Calorimeter Ref. Hall D 1543025 | 2013-09-03 A | 2013-09-30 → 2013-12-02 (+63d) |  |  | 401d → 358d |  | resources PROCUREMENT>$50K 69; PROCUREMENT<$50K 60 → PROCUREMENT<$50K 60 |
| 24325030 | Fiducialize SHMS Shower Counter (Frame) | 2013-10-01 → 2013-11-01 (+31d) | 2013-12-20 → 2014-02-04 (+46d) |  |  | 342d → 319d |  |  |
| 8 | **1.4.3.2.8 DETECTOR FRAME** |  | 2014-03-31 → 2014-06-20 (+81d) |  |  |  |  |  |
| 14328015 | Procure Support Frame | 2010-06-01 A | 2010-09-30 → 2010-10-04 A (+4d) | 86d → 88d | 0% → 100% | 743d → none |  |  |
| 14328010 | Fab Supprt for individual Detctr's FY12 | 2011-11-02 → 2011-05-09 A (-177d) | 2012-09-28 → 2012-12-17 A (+80d) | 225d → 465d | 0% → 100% | 171d → none | 9-120M FS+22d, 122325020 → 122325020 | resources MECH DES [238.41 h]; MECH TECH [298.01 h]; MSHOP; MECH ENG [119.21 h] → MECH ENG [119.21 h]; MECH DES [238.41 h]; MECH TECH [298.01 h]; MSHOP |
| 14328010a | Fab Supprt for individual Detctr's FY13 | 2012-10-01 → 2011-05-09 A (-511d) | 2013-01-28 → 2012-12-17 A (-42d) | 77d → 465d | 0% → 100% | 171d → none | 14328010 → 14328010 FS-100d | resources MECH ENG [40.79 h]; MECH DES [81.59 h]; MECH TECH [101.99 h]; MSHOP → MECH DES [81.59 h]; MECH TECH [101.99 h]; MSHOP; MECH ENG [40.79 h] |
| 14328010b | Fab Supprt for individual Detctr's Procurement Part A | 2011-11-02 → 2011-05-09 A (-177d) | 2013-01-28 → 2012-09-28 A (-122d) | 302d → 349d | 0% → 100% | 171d → none | 9-120M FS+22d, 122325020 → 122325020 |  |
| 14328005 | Fab General Struct for Detector Frame FY12 | 2011-11-02 → 2011-10-03 A (-30d) | 2012-09-28 → 2013-02-11 A (+136d) | 225d → 329d | 0% → 100% | 228d → none | 9-120M FS+22d, 122325020 → 122325020, 9-120M | resources MECH DES [257.14 h]; TRAVEL; SUPPLIES & MATERIALS; MECH ENG [110.2 h]; MECH TECH [367.35 h]; PLABOR; MSHOP → SUPPLIES & MATERIALS; MECH ENG [110.2 h]; MECH TECH [367.35 h]; PLABOR; MSHOP; MECH DES [257.14 h]; TRAVEL |
| 14328005a | Fab General Struct for Detector Frame FY13 | 2012-10-01 → 2011-10-03 A (-364d) | 2012-10-26 → 2013-02-11 A (+108d) | 20d → 329d | 0% → 100% | 228d → none | 14328005 → 14328005 FS-45d |  |
| 14328005b | Fab General Struct for Detector Frame Procurement Part A | 2011-11-02 → 2011-10-03 A (-30d) | 2012-10-26 → 2013-02-11 A (+108d) | 245d → 329d | 0% → 100% | 228d → none | 9-120M FS+22d, 122325020 → 122325020, 9-120M |  |
| 14328010ba | Fab Supprt for individual Detctr's Procurement Part B | 2011-11-02 → 2013-04-01 A (+516d) | 2013-01-28 → 2013-08-30 A (+214d) | 302d → 115d | 0% → 100% | 171d → none | 9-120M FS+22d, 122325020 → 9-130M FS+80d, 122325020 |  |
| 14328005ba | Fab General Struct for Detector Frame Procurement Part B | 2011-11-02 → 2013-06-01 A (+577d) | 2012-10-26 → 2013-08-26 A (+304d) | 245d → 39d | 0% → 100% | 228d → none | 9-120M FS+22d, 122325020 → 9-120M, 122325020, 9-130M FS+50d |  |
| 14328020 | Re-Baseline Actuals Adjustment | 2013-08-30 A | 2013-08-30 A |  | 0% → 100% | 20d → none | 9-130M FS+227d → none |  |
| 24328005 | Calorimeter Support Frame TBP | 2013-09-03 A | 2013-10-31 → 2013-12-20 (+50d) |  |  | 370d → 373d |  |  |
| 24328010ba | Fab Supprt for individual Detctr's Procurement Part B | 2013-10-01 → 2014-01-03 (+94d) | 2014-03-31 → 2014-06-20 (+81d) |  |  | 350d → 292d | 24328005 FS-43d, 9-140M → 9-140M FS+60d, 24328005 FS-80d |  |
| 1433015 | Re-Baseline Actuals Adjustment | 2013-08-30 A | 2013-08-30 A |  | 0% → 100% | 20d → none | 9-130M FS+227d → none |  |
| 2433000 | Buy 5 Fast PC's for Data Acq & Processing (COMP) |  |  |  |  |  | 9-140M FS+250d → 9-155M FS+3d |  |
| 2433005 | Buy File Servers for Data Acq System (COMP) |  |  |  |  |  | 9-140M FS+250d → 9-155M FS+3d |  |
| 2433010 | Buy 8 Workstations/Monitors (COMP) |  |  |  |  |  | 9-140M FS+250d → 9-155M FS+3d |  |
| 4 | **1.4.3.4 ELECTRONICS** | 2010-11-12 → 2011-04-02 (+141d) |  |  |  |  |  |  |
| 1 | **1.4.3.4.1 FAST ELECTRONICS** | 2011-05-13 → 2011-05-09 (-4d) |  |  |  |  |  |  |
| 14341007 | SOS Signal Cable Prepare for Installation (FAST Electrnc's) | 2011-05-13 → 2011-05-09 A (-4d) | 2011-08-08 → 2011-06-30 A (-39d) | 60d → 38d | 0% → 100% | 68d → none |  | resources ELEC TECH [400 h]; SUPPLIES & MATERIALS → SUPPLIES & MATERIALS; ELEC TECH [400 h] |
| 14341010 | Proc Discriminators for Wire Chambers (FAST Electrnc's) | 2012-01-05 → 2011-09-05 A (-122d) | 2012-07-10 → 2011-09-10 A (-304d) | 130d → 4d | 0% → 100% | 305d → none |  |  |
| 14341015 | Proc ADCs for Hodoscopes (FAST Electrnc's) | 2012-01-04 → 2012-01-03 A (-1d) | 2012-11-30 → 2012-10-15 A (-46d) | 231d → 200d | 0% → 100% | 205d → none |  | resources PROCUREMENT>$50K 69 NO ESCALATION; PROCUREMENT<$50K 60 NO ESCALATION → PROCUREMENT<$50K 60 NO ESCALATION; PROCUREMENT>$50K 69 NO ESCALATION |
| 14341005 | Proc TDCs for Wire Chambers (FAST Electrnc's) | 2012-01-05 → 2012-01-09 A (+4d) | 2012-12-21 → 2012-01-24 A (-332d) | 245d → 11d | 0% → 100% | 190d → none |  |  |
| 14341020 | Proc ADCs for Calorimeter (FAST Electrnc's) FY12 | 2012-01-05 → 2012-02-01 A (+27d) | 2012-09-28 → 2012-10-15 A (+17d) | 187d → 180d | 0% → 100% | 190d → none |  |  |
| 14341020a | Proc ADCs for Calorimeter (FAST Electrnc's) FY13 | 2012-10-01 → 2012-02-01 A (-243d) | 2012-12-21 → 2012-10-15 A (-67d) | 58d → 180d | 0% → 100% | 190d → none | 14341020 → 14341020 FS-80d |  |
| 14341025 | Proc TDCs for Hodoscopes (FAST Electrnc's) | 2012-01-05 → 2012-02-01 A (+27d) | 2012-12-21 → 2012-02-13 A (-312d) | 245d → 9d | 0% → 100% | 190d → none |  |  |
| 14341030 | Proc Discriminators for Hodoscopes (FAST Electrnc's) | 2012-01-05 → 2012-02-01 A (+27d) | 2012-12-21 → 2012-02-13 A (-312d) | 245d → 9d | 0% → 100% | 190d → none |  |  |
| 14341035 | Proc HV for All Detctr's (FAST Electrnc's) | 2012-01-05 → 2012-02-01 A (+27d) | 2012-12-21 → 2012-02-13 A (-312d) | 245d → 9d | 0% → 100% | 190d → none |  |  |
| 14341040 | Proc CAMAC Controller & Crate (FAST Electrnc's) | 2012-01-05 → 2012-02-01 A (+27d) | 2012-12-21 → 2012-02-13 A (-312d) | 245d → 9d | 0% → 100% | 190d → none |  |  |
| 14341045 | Proc NIM Crates (FAST Electrnc's) | 2012-01-05 → 2012-02-01 A (+27d) | 2012-12-21 → 2012-02-13 A (-312d) | 245d → 9d | 0% → 100% | 190d → none |  |  |
| 14341050 | Proc NIM & CAMAC Logic (FAST Electrnc's) | 2012-01-05 → 2012-02-01 A (+27d) | 2012-12-21 → 2012-02-13 A (-312d) | 245d → 9d | 0% → 100% | 190d → none |  |  |
| 14341055 | Proc scalers (FAST Electrnc's) | 2012-01-05 → 2012-02-01 A (+27d) | 2012-12-21 → 2012-02-13 A (-312d) | 245d → 9d | 0% → 100% | 190d → none |  |  |
| 14341065 | Proc VME Crates (FAST Electrnc's) REF. HallD 1544006 | 2012-01-05 → 2012-02-01 A (+27d) | 2012-06-29 → 2013-01-31 A (+216d) | 123d → 252d | 0% → 100% | 71.5d → none |  |  |
| 14341070 | Proc High-Power 21-slot VME64x/VXS crate for DF2 | 2012-01-05 → 2012-02-01 A (+27d) | 2012-12-21 → 2012-12-17 A (-4d) | 245d → 252d | 0% → 100% | 190d → none | 9-120M FS+60d → 9-120M FS+85d |  |
| 14341115 | Recondition 1 existing VME64x crate (w/o VXS) FY12 | 2012-01-05 → 2012-02-01 A (+27d) | 2012-09-28 → 2012-12-17 A (+80d) | 187d → 252d | 0% → 100% | 190d → none | 9-120M FS+60d → 9-120M FS+85d | resources SCIENTIST [44.27 h]; ELEC ENG [42.74 h] → ELEC ENG [42.74 h]; SCIENTIST [44.27 h] |
| 14341115a | Recondition 1 existing VME64x crate (w/o VXS) FY13 | 2012-10-01 → 2012-02-01 A (-243d) | 2012-12-21 → 2012-12-17 A (-4d) | 58d → 252d | 0% → 100% | 190d → none | 14341115 → 14341115 FS-80d | resources SCIENTIST [13.73 h]; ELEC ENG [13.26 h] → ELEC ENG [13.26 h]; SCIENTIST [13.73 h] |
| 14341095 | Proc 2 TI Modules for DF2 | 2012-01-05 → 2012-03-12 A (+67d) | 2012-12-21 → 2012-11-12 A (-39d) | 245d → 173d | 0% → 100% | 190d → none | 9-120M FS+60d → 9-120M FS+85d |  |
| 14341097 | Proc TD Module for DF2 | 2012-01-05 → 2012-03-12 A (+67d) | 2012-12-21 → 2012-11-12 A (-39d) | 245d → 173d | 0% → 100% | 190d → none | 9-120M FS+60d → 9-120M FS+85d |  |
| 14341075 | Proc 2 single-board PC's for DCs, Hodoscopes, Cerenkovs for DF2 | 2012-01-05 → 2012-04-02 A (+88d) | 2012-12-21 → 2012-06-11 A (-193d) | 245d → 49d | 0% → 100% | 190d → none | 9-120M FS+60d → 9-120M FS+85d |  |
| 14341090 | Proc SD Module for DF2 | 2012-01-05 → 2012-04-02 A (+88d) | 2012-12-21 → 2012-10-15 A (-67d) | 245d → 138d | 0% → 100% | 190d → none | 9-120M FS+60d → 9-120M FS+85d |  |
| 14341110 | Proc positive high-voltage modules | 2012-01-05 → 2012-05-11 A (+127d) | 2012-12-21 → 2012-09-17 A (-95d) | 245d → 89d | 0% → 100% | 190d → none | 9-120M FS+60d → 9-120M FS+85d |  |
| 14341060 | Proc Cables & Connectors (FAST Electrnc's) | 2012-01-05 → 2012-08-01 A (+209d) | 2012-12-21 → 2012-09-17 A (-95d) | 245d → 33d | 0% → 100% | 190d → none | 9-120M FS+60d → 9-120M FS+210d |  |
| 14341100 | Proc SSP Module for DF2 | 2012-10-01 A | 2013-08-30 → 2013-02-11 A (-200d) | 228d → 142d | 0% → 100% | 20d → none |  |  |
| 14341105 | Proc 11 TDC modules with CAEN 1190 specs for DC, Cerenkovs, Hodoscopes - for DF2 | 2012-10-01 A | 2013-08-30 → 2013-02-11 A (-200d) | 228d → 245d | 0% → 100% | 20d → none |  | resources PROCUREMENT>$50K 69; PROCUREMENT<$50K 60 → PROCUREMENT<$50K 60; PROCUREMENT>$50K 69 |
| 14341000 | DAQ Trigger Development | 2012-10-29 → 2013-01-02 A (+65d) | 2013-08-30 A | 208d → 220d | 0% → 100% | 20d → none | 14341067, 9-130M FS+20d → 9-130M, 14341067 FS-30d |  |
| 14341067 | Assemble and Test VME Crates (FAST Electrnc's) REF. HallD 1544025 | 2012-07-02 → 2013-02-01 A (+214d) | 2012-08-15 → 2013-02-16 A (+185d) |  | 0% → 100% | 71.5d → none |  |  |
| 14341120 | Re-Baseline Actuals Adjustment | 2013-08-30 A | 2013-08-30 A |  | 0% → 100% | 20d → none | 9-130M FS+227d → none |  |
| 24341000 | DAQ Trigger Development FY13 | 2013-09-03 A | 2013-09-30 → 2014-02-10 (+133d) | 20d → 104d | 0% → 30% |  |  |  |
| 24341000a | DAQ Trigger Development FY14 | 2013-10-01 → 2013-09-03 A (-28d) |  |  | 0% → 30% |  | 9-130M FS+228d, 24341000 → 24341000 FS-100d |  |
| 24341085 | Proc CTP Module for DF2 | 2013-09-03 A | 2013-10-31 → 2013-12-05 (+35d) |  |  | 378d → 355d |  | resources PROCUREMENT>$50K 69 NO ESCALATION FY14; PROCUREMENT<$50K 60 NO ESCALATION FY14 → PROCUREMENT<$50K 60 NO ESCALATION FY14 |
| 2 | **1.4.3.4.2 POWER SUPPLIES & PROBES (Power Supply Infrastructure)** | 2010-11-12 → 2011-04-02 (+141d) | 2014-01-02 → 2014-02-05 (+34d) |  |  |  |  |  |
| 14342005 | Proc 4 Pwr Supplies for 480V (PWR SUP) | 2010-11-12 → 2011-04-02 A (+141d) | 2010-11-12 → 2011-04-18 A (+157d) | 1d → 11d | 0% → 100% | 707d → none |  |  |
| 14342010 | Proc LCW Sys for Pwr Supplies (PWR SUP) | 2010-11-15 → 2011-04-02 A (+138d) | 2010-11-15 → 2011-04-11 A (+147d) | 1d → 6d | 0% → 100% | 707d → none |  |  |
| 14342030 | Proc 5000A Flexible Lines (PWR SUP) | 2011-12-02 → 2011-04-02 A (-244d) | 2011-12-02 → 2011-04-11 A (-235d) | 1d → 6d | 0% → 100% | 450d → none |  |  |
| 14342035 | Fab Stand for Pwr Supplies (PWR SUP) | 2011-12-02 → 2011-04-02 A (-244d) | 2011-12-02 → 2011-04-11 A (-235d) | 1d → 6d | 0% → 100% | 450d → none |  |  |
| 14342020 | Proc 5000A Rigid Water Cooled Bus (PWR SUP) | 2010-11-16 → 2011-04-03 A (+138d) | 2010-11-16 → 2011-04-11 A (+146d) | 1d → 6d | 0% → 100% | 707d → none |  |  |
| 14342040 | Fab Catwalk (PWR SUP) | 2011-12-05 → 2011-04-05 A (-244d) | 2011-12-05 → 2011-04-11 A (-238d) | 1d → 5d | 0% → 100% | 450d → none |  |  |
| 14342045 | Fab Cable Tray & Bus Supprt (PWR SUP) | 2011-12-06 → 2011-04-06 A (-244d) | 2011-12-06 → 2011-04-18 A (-232d) | 1d → 9d | 0% → 100% | 450d → none |  |  |
| 14342050 | Proc 5000A Flexible Lines Revised by 2012 ETC | 2013-01-03 → 2012-10-01 A (-94d) | 2013-06-24 → 2012-11-12 A (-224d) | 120d → 31d | 0% → 100% | 68d → none | 9-130M FS+60d → 9-130M |  |
| 14342060 | Re-Baseline Actuals Adjustment | 2013-08-30 A | 2013-08-30 A |  | 0% → 100% | 20d → none | 9-130M FS+227d → none |  |
| 24342055 | Fab Cable Tray & Bus Support | 2013-10-01 → 2013-11-01 (+31d) | 2014-01-02 → 2014-02-05 (+34d) |  |  | 294d → 271d |  |  |
| 5 | **1.4.3.5 BEAMLINE** | 2011-01-05 → 2011-04-04 (+89d) |  |  |  |  |  |  |

| ID | Task | Start | Finish | Duration | Complete | Total float | Predecessors | Other |
| --- | --- | --- | --- | --- | --- | --- | --- | --- |
| 1 | **1.4.3.5.1 MOELLER POLARIMETER** | 2012-05-14 → 2012-06-02 (+19d) | 2014-03-31 → 2014-04-14 (+14d) |  |  |  |  |  |
| 14351005 | Proc Pwr Supply for Additional quad for Moeller polarimeter | 2012-05-14 → 2012-06-02 A (+19d) | 2012-11-14 → 2012-06-18 A (-149d) | 130d → 10d | 0% → 100% | 215d → none |  |  |
| 14351010 | Proc Cables/Stand for Additional quad for Moeller polarimeter | 2013-05-01 → 2013-05-03 A (+2d) | 2013-06-26 → 2013-05-29 A (-28d) |  | 0% → 100% | 65d → none | 2-02M, 9-100M, 9-130M FS+142d → 2-02M, 9-130M FS+142d |  |
| 14351020 | Modify Moeller Collimator- Manufacturing Drawings | 2013-05-01 → 2013-08-30 A (+121d) | 2013-05-29 → 2013-08-30 A (+93d) | 20d → 18d | 0% → 100% | 641d → none | 2-02M, 9-130M FS+142d → 9-140M FS+13d, 2-02M, 9-130M FS+235d | resources SCIENTIST; PROCUREMENT<$50K 60 NO ESCALATION FY14; MECH DES [160 h] → PROCUREMENT<$50K 60 NO ESCALATION FY14; MECH DES [160 h]; SCIENTIST |
| 14351025 | Re-Baseline Actuals Adjustment | 2013-08-30 A | 2013-08-30 A |  | 0% → 100% | 20d → none | 9-130M FS+227d → none |  |
| 24351020 | Modify Moeller Collimator- Manufacturing Drawings | 2013-10-18 → 2013-11-01 (+14d) | 2014-01-31 → 2014-02-14 (+14d) |  |  | 468d → 458d |  |  |
| 24351030 | Modify Moeller Collimator - FAB/PROCURE | 2014-02-03 → 2014-02-17 (+14d) | 2014-03-31 → 2014-04-14 (+14d) |  |  | 526d → 516d |  |  |
| 2 | **1.4.3.5.2 COMPTON POLARIMETER** | 2012-01-20 → 2011-04-04 (-291d) |  |  |  |  |  |  |
| 14352005 | Procure QR Magnets for Compton | 2012-01-20 → 2011-04-04 A (-291d) | 2012-05-15 → 2011-04-25 A (-386d) | 82d → 16d | 0% → 100% | 846d → none |  |  |
| 14352000 | Produce Compton Elevation Layout FY12 | 2012-05-14 → 2012-07-02 A (+49d) | 2012-09-28 → 2013-04-15 A (+199d) | 97d → 164d | 0% → 100% | 245d → none |  |  |
| 14352000a | Produce Compton Elevation Layout FY13 | 2012-10-01 → 2012-07-02 A (-91d) | 2012-10-03 → 2013-04-15 A (+194d) | 3d → 164d | 0% → 100% | 245d → none | 14352000 → 14352000 FS-100d |  |
| 14352010 | Re-Baseline Actuals Adjustment | 2013-08-30 A | 2013-08-30 A |  | 0% → 100% | 20d → none | 9-130M FS+227d → none |  |
| 3 | **1.4.3.5.3 MAPPING** | 2013-04-01 → 2013-08-30 (+151d) | 2014-04-30 → 2014-04-28 (-2d) |  |  |  |  |  |
| 14353010 | Fabricate and Use New ARC Mapper | 2013-06-25 → 2013-08-30 A (+66d) | 2013-08-30 A | 48d → 77d | 0% → 100% | 573d → none | 9-130M FS+180d → 9-130M FS+228d | resources MECH ENG; PROCUREMENT<$50K 60; SCIENTIST [288 h]; ELEC TECH; MECH DES; MECH TECH [320 h] → ELEC TECH; MECH DES; MECH TECH [320 h]; MECH ENG; SCIENTIST [288 h]; PROCUREMENT<$50K 60 |
| 14353015 | Refurb Existing Harmonic Coil for SHMS Mags | 2013-04-01 → 2013-08-30 A (+151d) | 2013-08-20 → 2013-08-30 A (+10d) |  | 0% → 100% | 28d → none | 9-130M FS+120d → 9-130M FS+120d, 9-140M | resources PROCUREMENT<$50K 60; MECH DES [200 h]; ELEC TECH [200 h]; SCIENTIST [160 h]; TRAVEL; MECH ENG [200 h]; SUPPLIES & MATERIALS; MSHOP → SUPPLIES & MATERIALS; MSHOP; MECH DES [200 h]; ELEC TECH [200 h]; SCIENTIST [160 h]; TRAVEL; MECH ENG [200 h]; PROCUREMENT<$50K 60 |
| 14353020 | Re-Baseline Actuals Adjustment | 2013-08-30 A | 2013-08-30 A |  | 0% → 100% | 20d → none | 9-130M FS+227d → none |  |
| 24353010 | Fabricate and Use New ARC Mapper FY13 | 2013-09-03 A | 2013-09-30 → 2013-12-20 (+81d) | 20d → 77d | 0% → 41% |  |  |  |
| 24353010a | Fabricate and Use New ARC Mapper FY14 | 2013-10-01 → 2013-09-03 A (-28d) |  |  | 0% → 41% |  | 9-130M FS+228d, 24353010 → 24353010 FS-60d |  |
| 24353015 | Refurb Existing Harmonic Coil for SHMS Mags | 2014-01-15 → 2014-01-13 (-2d) | 2014-04-30 → 2014-04-28 (-2d) |  |  | 370d → 372d |  |  |
| 4 | **1.4.3.5.4 SCATTERING CHAMBER** | 2011-01-05 → 2011-08-01 (+208d) | 2014-09-05 → 2014-09-04 (-1d) |  |  |  |  |  |
| 14354005 | Modify Existing Chamb Cylinder (SCATTER CHAMB) | 2011-01-05 → 2011-08-01 A (+208d) | 2011-04-07 → 2011-08-31 A (+146d) | 65d → 23d | 0% → 100% | 417d → none |  | resources MECH TECH [80 h]; TRAVEL; PROCUREMENT<$50K 60; MECH ENG [40 h] → PROCUREMENT<$50K 60; MECH ENG [40 h]; MECH TECH [80 h]; TRAVEL |
| 14354025 | Proc Turbo Pump Sys (SCATTER CHAMB) | 2013-02-01 → 2012-10-01 A (-123d) | 2013-08-06 → 2013-03-11 A (-148d) | 130d → 79d | 0% → 100% | 38d → none | 9-130M FS+80d, 14354005 → 14354005 |  |
| 14354008 | Proc & Fab Chamb Flanges (SCATTER CHAMB) | 2013-04-15 → 2013-08-30 A (+137d) | 2013-08-06 → 2013-08-30 A (+24d) |  | 0% → 100% | 437d → none | 9-130M FS+130d → 9-140M FS+100d, 9-130M FS+130d |  |
| 14354010 | Proc & Install Chamb Flanges (SCATTER CHAMB) | 2011-04-08 → 2013-08-30 A (+875d) | 2011-08-01 → 2013-08-30 A (+760d) | 80d → 130d | 0% → 100% | 417d → none | 9-110M, 14354005, 14354008 FS-600d → 9-120M FS+210d, 9-110M, 14354008 FS-600d, 14354005, 9-130M FS+130d, 9-140M FS+100d | resources MECH ENG [40 h]; MECH TECH [40 h] → MECH TECH [40 h]; MECH ENG [40 h] |
| 14354015 | Proc & Install HMS & SHMS Window Frames (SCATTER CHAMB) FY11 | 2011-08-02 → 2013-08-30 A (+759d) | 2011-09-30 → 2013-08-30 A (+700d) | 43d → 130d | 0% → 100% | 417d → none | 14354010 → 14354010 FS-130d | resources MECH ENG [21.5 h]; MECH TECH [86 h]; MECH DES [43 h] → MECH DES [43 h]; MECH ENG [21.5 h]; MECH TECH [86 h] |
| 14354015a | Proc & Install HMS & SHMS Window Frames (SCATTER CHAMB) FY12 | 2011-10-03 → 2013-08-30 A (+697d) | 2011-11-22 → 2013-08-30 A (+647d) | 37d → 130d | 0% → 100% | 417d → none | 14354015 → 14354015 FS-130d |  |
| 14354020 | Proc & Install HMS & SHMS Blank Covers (SCATTER CHAMB) | 2011-11-23 → 2013-08-30 A (+646d) | 2011-12-29 → 2013-08-30 A (+610d) | 20d → 130d | 0% → 100% | 417d → none | 14354015a → 14354015a FS-130d |  |
| 14354030 | Proc & Install Gate Valves,BL adaptors & Vac Gauges (SCATTER CHAMB) Original Labor | 2011-12-30 → 2013-08-30 A (+609d) | 2012-01-31 → 2013-08-30 A (+577d) | 21d → 130d | 0% → 100% | 417d → none | 14354020 → 14354020 FS-180d, 9-140M FS+100d, 9-130M FS+130d | resources SUPPLIES & MATERIALS; TRAVEL; MECH ENG [22.4 h]; PLABOR; MECH TECH [33.6 h]; MECH DES [89.6 h] → TRAVEL; MECH ENG [22.4 h]; MECH TECH [33.6 h]; MECH DES [89.6 h]; PLABOR; SUPPLIES & MATERIALS |
| 14354035 | Re-Baseline Actuals Adjustment | 2013-08-30 A | 2013-08-30 A |  | 0% → 100% | 20d → none | 9-130M FS+227d → none |  |
| 24354008 | Proc & Fab Chamb Flanges (SCATTER CHAMB) | 2014-03-05 → 2014-03-04 (-1d) | 2014-06-25 → 2014-06-24 (-1d) |  |  | 809d → 810d |  |  |
| 24354010 | Procure and Install Chamb Flanges (SCATTER CHAMB) | 2014-03-05 → 2014-03-04 (-1d) | 2014-09-05 → 2014-09-04 (-1d) |  |  | 341d → 342d |  |  |
| 24354015a | Proc & Install HMS & SHMS Window Frames (SCATTER CHAMB) | 2014-03-05 → 2014-03-04 (-1d) | 2014-09-05 → 2014-09-04 (-1d) |  |  | 341d → 342d |  |  |
| 24354020 | Proc & Install HMS & SHMS Blank Covers (SCATTER CHAMB) | 2014-03-05 → 2014-03-04 (-1d) | 2014-09-05 → 2014-09-04 (-1d) |  |  | 341d → 342d |  |  |
| 24354022 | Modify Seal on Scattering Chamber | 2014-03-05 → 2014-03-04 (-1d) | 2014-08-21 → 2014-08-20 (-1d) |  |  | 321d → 322d |  |  |
| 24354030 | Proc & Install Gate Valves,BL adaptors & Vac Gauges (SCATTER CHAMB) Labor | 2014-03-05 → 2014-03-04 (-1d) | 2014-06-18 → 2014-06-17 (-1d) |  |  | 341d → 342d |  |  |
| 24354030b | Proc & Install Gate Valves,BL adaptors & Vac Gauges (SCATTER CHAMB) Procurement | 2014-03-05 → 2014-03-04 (-1d) | 2014-06-18 → 2014-06-17 (-1d) |  |  | 341d → 342d |  |  |
| 5 | **1.4.3.5.5 BEAM PIPE & STANDS** | 2013-08-28 → 2013-08-30 (+2d) |  |  |  |  |  |  |
| 14355010 | Proc 2nd Section of Beam Pipe (Beam Pipe) | 2013-08-28 → 2013-08-30 A (+2d) | 2013-08-30 A | 3d → 130d | 0% → 100% | 20d → none |  |  |
| 14355015 | Proc 3rd Section of Beam Pipe (Beam Pipe) | 2013-08-28 → 2013-08-30 A (+2d) | 2013-08-30 A | 3d → 130d | 0% → 100% | 20d → none |  | resources MECH ENG [1.85 h]; MECH TECH [1.85 h]; MECH DES [6.46 h]; TRAVEL; PROCUREMENT<$50K 60 NO ESCALATION FY14; PROCUREMENT>$50K 69 NO ESCALATION FY14 → PROCUREMENT>$50K 69; PROCUREMENT<$50K 60; MECH ENG [1.85 h]; MECH TECH [1.85 h]; MECH DES [6.46 h]; TRAVEL; PROCUREMENT<$50K 60 NO ESCALATION FY14; PROCUREMENT>$50K 69 NO ESCALATION FY14 |
| 14355035 | Re-Baseline Actuals Adjustment | 2013-08-30 A | 2013-08-30 A |  | 0% → 100% | 20d → none | 9-130M FS+227d → none |  |
| 24355000 | Produce Manufacturing Drawings for Beam Pipe, Stands, Fittings | 2014-07-01 → 2014-06-30 (-1d) | 2014-10-01 → 2014-09-30 (-1d) |  |  | 270d → 271d |  |  |
| 6 | **1.4.3.6 INFRASTUCTURE** | 2009-01-05 → 2009-07-01 (+177d) |  |  |  |  |  |  |
| 2 | **1.4.3.6.2 SUPPORT STRUCTURE** | 2009-11-02 → 2010-02-01 (+91d) | 2013-09-30 → 2013-09-16 (-14d) |  |  |  |  |  |
| 14362005 | Finalize Dsgn of Supprt Struct | 2009-11-02 → 2010-02-01 A (+91d) | 2010-09-30 A | 226d → 169.5d | 0% → 100% | 296d → none |  | resources MECH ENG [184.5 h]; PROCUREMENT<$50K 60; PROCUREMENT>$50K 69; MECH DES [184.5 h] → MECH DES [184.5 h]; PROCUREMENT<$50K 60; PROCUREMENT>$50K 69; MECH ENG [184.5 h] |
| 14362012 | Produce Drawings - Rails & Base of Supprt Struct | 2010-12-02 → 2010-04-01 A (-245d) | 2011-01-05 → 2010-06-15 A (-204d) | 19d → 53d | 0% → 100% | 306d → none | 14362046a → 14362046a FS-225d |  |
| 14362046 | Produce Drawings - Bogies | 2010-12-02 → 2010-04-01 A (-245d) | 2011-01-11 → 2010-07-15 A (-180d) | 23d → 74d | 0% → 100% | 347d → none | 14362046a → 14362046a FS-150d |  |
| 14362046a | Produce Drawings - Wheels | 2010-10-28 → 2010-04-01 A (-210d) | 2010-12-01 → 2010-07-15 A (-139d) | 23d → 74d | 0% → 100% | 306d → none | 14362010M → 14362010M FS-150d | resources MECH ENG [200 h]; MECH DES [400 h] → MECH DES [400 h]; MECH ENG [200 h] |
| 14362000M | Award Contract to Dsgn the Supprt Struct | 2009-11-02 → 2010-04-26 A (+175d) | 2009-11-02 → 2010-04-26 A (+175d) |  | 0% → 100% | 296d → none | 12236040, 9-100M FS+22d, 12236830LOE → 9-100M FS+142d, 12236830LOE, 12236040 |  |
| 14362075 | Fab Main Bearing of Supprt Struct Labor FY11 | 2010-10-01 → 2010-04-29 A (-155d) | 2011-09-30 → 2011-04-25 A (-158d) | 248d → 245d | 0% → 100% | 381d → none | 14362005 → 14362005 FS-40d | resources MECH DES [79.36 h]; MECH ENG [79.36 h] → MECH ENG [79.36 h]; MECH DES [79.36 h] |
| 14362075a | Fab Main Bearing of Supprt Struct Labor FY12 | 2011-10-03 → 2010-04-29 A (-522d) | 2011-10-04 → 2011-04-25 A (-162d) | 2d → 245d | 0% → 100% | 381d → none |  |  |
| 14362075b | Fab Main Bearing of Supprt Struct Procurement | 2010-10-01 → 2010-04-29 A (-155d) | 2011-10-04 → 2011-04-25 A (-162d) | 250d → 245d | 0% → 100% | 381d → none | 14362005 → 14362005 FS-40d |  |
| 14362016 | Produce Drawings - Pivot Sections of Supprt Struct | 2011-01-06 → 2010-06-14 A (-206d) | 2011-02-03 → 2010-11-29 A (-66d) | 20d → 117d | 0% → 100% | 306d → none |  | resources MECH ENG [160 h]; MECH DES [320 h] → MECH DES [320 h]; MECH ENG [160 h] |
| 14362047 | Procurement Prep - Bogies | 2011-01-12 → 2010-07-15 A (-181d) | 2011-02-09 → 2010-09-24 A (-138d) | 20d → 51d | 0% → 100% | 347d → none | 14362046, 9-110M → 14362046, 9-110M FS-20d |  |
| 14362047a | Procurement Prep - Wheels | 2010-12-02 → 2010-08-02 A (-122d) | 2011-01-06 → 2010-09-30 A (-98d) | 20d → 43d | 0% → 100% | 424d → none | 14362046a, 9-110M → 9-110M FS-20d, 14362046a |  |
| 14362006 | SS/SH Engineering Support FY10 | 2010-09-01 A | 2010-09-30 A |  | 0% → 100% | 296d → none |  |  |
| 14362007 | SS/SH Engineering Support FY11 | 2010-10-01 A | 2011-09-30 A |  | 0% → 100% | 296d → none |  |  |
| 14362811LOE | Overlook Various Subcontracts of Supprt Struct | 2010-10-01 A | 2011-09-30 A |  | 0% → 100% | 1238d → none |  |  |
| 14362010M | Review Final Dsgn of Supprt Struct | 2010-10-27 A | 2010-10-27 A |  | 0% → 100% | 306d → none |  |  |
| 14362036 | Produce Drawings - Mag Mounts of Supprt Struct | 2011-03-08 → 2010-11-01 A (-127d) | 2011-04-05 → 2011-02-21 A (-43d) | 21d → 71d | 0% → 100% | 306d → none | 14362041 → 14362041 FS-80d |  |
| 14362013 | Procurement Prep - Rails & Base of Supprt Struct | 2011-02-10 → 2010-12-01 A (-71d) | 2011-03-08 → 2010-12-23 A (-75d) | 18d → 15d | 0% → 100% | 347d → none |  |  |
| 14362017 | Procurement Prep - Pivot Sections of Supprt Struct | 2011-03-09 → 2011-01-03 A (-65d) | 2011-04-05 → 2011-01-21 A (-74d) | 20d → 13d | 0% → 100% | 374d → none |  |  |
| 14362041 | Produce Drawings - Access Platforms of Supprt Struct | 2011-02-04 → 2011-02-01 A (-3d) | 2011-03-07 → 2011-07-18 A (+133d) | 21d → 117d | 0% → 100% | 306d → none |  | resources MECH ENG [160 h]; MECH DES [320 h] → MECH DES [320 h]; MECH ENG [160 h] |
| 14362021 | Produce Drawings - Mag Section of Supprt Struct | 2011-07-11 → 2011-02-07 A (-154d) | 2011-08-10 → 2011-02-28 A (-163d) | 23d → 15d | 0% → 100% | 306d → none | 14362031 → 14362031 FS-70d |  |
| 14362026 | Produce Drawings - Detector Section of Supprt Struct | 2011-04-06 → 2011-02-07 A (-58d) | 2011-05-02 → 2011-02-21 A (-70d) | 19d → 10d | 0% → 100% | 306d → none |  |  |
| 14362037 | Procurement Prep - Mag Mounts of Supprt Struct | 2011-05-04 → 2011-02-07 A (-86d) | 2011-05-31 → 2011-02-28 A (-92d) | 19d → 15d | 0% → 100% | 374d → none | 14362042, 14362036 → 14362042, 14362036 FS+20d |  |
| 14362022 | Procurement Prep - Mag Section of Supprt Struct | 2011-08-11 → 2011-03-01 A (-163d) | 2011-09-06 → 2011-04-29 A (-130d) | 18d → 44d | 0% → 100% | 306d → none | 14362032, 14362021 → 14362032 FS-90d, 14362021 FS-60d |  |
| 14362027 | Procurement Prep - Detector Section of Supprt Struct | 2011-05-03 → 2011-03-01 A (-63d) | 2011-05-27 → 2011-04-28 A (-29d) | 19d → 43d | 0% → 100% | 318d → none |  |  |
| 14362031 | Produce Drawings - Wheel Section of Supprt Struct | 2011-06-06 → 2011-03-01 A (-97d) | 2011-07-08 → 2011-06-30 A (-8d) | 24d → 87d | 0% → 100% | 306d → none | 14362051 → 14362051 FS-40d | resources MECH ENG [200 h]; MECH DES [400 h] → MECH DES [400 h]; MECH ENG [200 h] |
| 14362051 | Produce Drawings - Other Compnts of Supprt Struct | 2011-05-03 → 2011-03-01 A (-63d) | 2011-06-03 → 2011-06-30 A (+27d) | 23d → 87d | 0% → 100% | 306d → none |  | resources MECH DES [400 h]; MECH ENG [200 h] → MECH ENG [200 h]; MECH DES [400 h] |
| 14362032 | Procurement Prep - Wheel Section of Supprt Struct | 2011-07-11 → 2011-04-11 A (-91d) | 2011-08-04 → 2011-08-15 A (+11d) | 19d → 89d | 0% → 100% | 310d → none | 14362052, 14362031 → 14362052 FS-60d, 14362031 FS-45d |  |

| ID | Task | Start | Finish | Duration | Complete | Total float | Predecessors | Other |
| --- | --- | --- | --- | --- | --- | --- | --- | --- |
| 14362052 | Procurement Prep - Other Compnts of Supprt Struct | 2011-06-06 → 2011-06-30 A (+24d) | 2011-07-01 → 2011-10-10 A (+101d) | 20d → 71d | 0% → 100% | 314d → none |  |  |
| 14362042 | Procurement Prep - Access Platforms of Supprt Struct | 2011-04-06 → 2011-07-15 A (+100d) | 2011-05-03 → 2011-08-14 A (+103d) | 20d → 21d | 0% → 100% | 374d → none |  |  |
| 14362015 | PreFab Rails & Base of Supprt Struct | 2011-12-07 → 2011-08-01 A (-128d) | 2012-05-04 → 2011-12-19 A (-137d) | 100d → 98d | 0% → 100% | 157d → none | 9-120M FS+45d, 14362010M FS-130d, 14362013 → 14362010M FS-130d, 14362013 |  |
| 14362060 | Proc Drive Motors & Reducers of Supprt Struct | 2012-01-12 → 2011-08-01 A (-164d) | 2012-04-06 → 2011-08-31 A (-219d) | 60d → 23d | 0% → 100% | 293d → none |  |  |
| 14362020 | PreFab Pivot Sections of Supprt Struct | 2011-12-07 → 2011-08-22 A (-107d) | 2012-06-19 → 2012-06-11 A (-8d) | 130d → 198d | 0% → 100% | 213d → none | 14362010M, 9-120M FS+45d, 14362017 → 14362010M, 14362017 |  |
| 14362025 | PreFab Mag Section #20 of Supprt Struct | 2011-12-07 → 2011-09-13 A (-85d) | 2012-05-04 → 2012-07-09 A (+66d) | 100d → 203d | 0% → 100% | 243d → none | 14362010M, 14362022, 9-120M FS+45d → 14362022, 14362010M | resources TRAVEL; MECH DES [320 h]; PROCUREMENT>$50K 69; MECH ENG [240 h]; PROCUREMENT<$50K 60 → TRAVEL; MECH DES [320 h]; PROCUREMENT<$50K 60; PROCUREMENT>$50K 69; MECH ENG [240 h] |
| 14362030 | PreFab Detector Section #30 of Supprt Struct | 2012-01-05 → 2011-09-13 A (-114d) | 2012-05-25 → 2012-07-16 A (+52d) | 100d → 208d | 0% → 100% | 228d → none | 9-120M FS+60d, 14362037, 14362027 → 14362037, 14362027 | resources MECH DES [40 h]; MECH ENG [80 h]; PROCUREMENT>$50K 69 → MECH ENG [80 h]; MECH DES [40 h]; PROCUREMENT>$50K 69 |
| 14362035 | PreFab Wheel Section of Supprt Struct | 2012-01-05 → 2011-09-13 A (-114d) | 2012-05-25 → 2012-02-27 A (-88d) | 100d → 110d | 0% → 100% | 228d → none | 14362010M, 9-120M FS+60d, 14362032 → 14362032, 14362010M | resources TRAVEL; MECH DES [40 h]; PROCUREMENT>$50K 69; PROCUREMENT<$50K 60; MECH ENG [80 h] → PROCUREMENT<$50K 60; MECH ENG [80 h]; TRAVEL; MECH DES [40 h]; PROCUREMENT>$50K 69 |
| 14362011 | SS/SH Engineering Support FY12 | 2011-10-03 A | 2012-09-28 A |  | 0% → 100% | 296d → none |  | resources PROCUREMENT<$50K 60; PROCUREMENT>$50K 69 → PROCUREMENT>$50K 69; PROCUREMENT<$50K 60 |
| 14362050 | PreFab Double Bogies of Supprt Struct | 2011-10-03 A | 2012-05-11 → 2013-02-11 A (+276d) | 150d → 309d | 0% → 100% | 238d → none |  | resources MECH DES [80 h]; PROCUREMENT>$50K 69; MECH ENG [160 h]; PROCUREMENT<$50K 60 → MECH ENG [160 h]; MECH DES [80 h]; PROCUREMENT>$50K 69; PROCUREMENT<$50K 60 |
| 14362050a | PreFab Wheels of Supprt Struct | 2011-10-03 A | 2012-05-11 → 2013-02-11 A (+276d) | 150d → 309d | 0% → 100% | 238d → none |  | resources MECH ENG [80 h]; MECH DES [80 h]; PROCUREMENT>$50K 69 → PROCUREMENT>$50K 69; MECH ENG [80 h]; MECH DES [80 h] |
| 14362055 | PreFab Other Compnts of Supprt Struct | 2012-01-12 → 2011-10-03 A (-101d) | 2012-06-05 → 2012-01-18 A (-139d) | 100d → 69d | 0% → 100% | 223d → none | 14362052, 9-120M FS+65d, 14362010M → 9-120M, 14362052, 14362010M | resources MECH ENG [80 h]; PROCUREMENT<$50K 60; MECH DES [80 h] → PROCUREMENT<$50K 60; MECH ENG [80 h]; MECH DES [80 h] |
| 14362812LOE | Overlook Various Subcontracts of Supprt Struct | 2011-10-03 A | 2012-09-28 A |  | 0% → 100% | 1238d → none |  |  |
| 14362065 | Electrical System Final Drawings | 2012-01-05 → 2012-01-03 A (-2d) | 2012-06-26 → 2012-07-09 A (+13d) | 120d → 131d | 0% → 100% | 315d → none |  |  |
| 14362035a | PreFab #100 section of Support STructure and Inner Race | 2012-01-04 A | 2012-06-25 → 2012-07-09 A (+14d) | 120d → 130d | 0% → 100% | 209d → none |  |  |
| 14362045 | PreFab Access Platforms of Supprt Struct | 2012-04-02 → 2012-01-10 A (-83d) | 2012-08-21 → 2012-03-19 A (-155d) | 100d → 48d | 0% → 100% | 168d → none | 14362042, 9-120M FS+120d → 9-120M, 14362042 | resources PROCUREMENT<$50K 60; MECH DES [40 h]; MECH ENG [40 h] → MECH DES [40 h]; MECH ENG [40 h]; PROCUREMENT<$50K 60 |
| 14362040 | PreFab Mag Mounts of Supprt Struct | 2012-02-03 → 2012-03-05 A (+31d) | 2012-06-26 → 2012-03-19 A (-99d) | 100d → 11d | 0% → 100% | 208d → none | 9-120M FS+80d, 14362037 → 9-120M FS+144d, 14362037 |  |
| 14362070 | Fire Safety and HVAC Final Drawings | 2012-01-05 → 2012-04-02 A (+88d) | 2012-06-26 → 2012-07-09 A (+13d) | 120d → 69d | 0% → 100% | 315d → none | 9-120M FS+60d → 9-120M FS+105d |  |
| 14362950 | Re-Baseline Actuals Adjustment | 2013-08-30 A | 2013-08-30 A |  | 0% → 100% | 20d → none | 9-130M FS+227d → none |  |
| 24362000 | Engineering Consulting | 2013-09-03 A | 2013-09-30 → 2013-09-16 A (-14d) |  | 0% → 100% | 551d → none |  | resources PROCUREMENT<$50K 60 → PROCUREMENT>$50K 69 NO ESCALATION FY14 |
| 3 | **1.4.3.6.3 SHIELD HOUSE** | 2009-11-02 → 2010-03-29 (+147d) |  |  |  |  |  |  |
| 14363010 | Finalize Dsgn of Shield House (SHIELD HOUSE) | 2010-04-26 → 2010-03-29 A (-28d) | 2010-09-30 A | 111d → 130d | 0% → 100% | 325d → none | 14363005M, 14362005 FS-111d → 14362005 FS-130d, 14363005M | resources MECH ENG [341.54 h]; MECH DES [341.54 h]; PROCUREMENT<$50K 60; TRAVEL → PROCUREMENT<$50K 60; TRAVEL; MECH ENG [341.54 h]; MECH DES [341.54 h] |
| 14363005M | Award Contract for Final Dsgn of Shield House (SHIELD HOUSE) | 2009-11-02 → 2010-04-29 A (+178d) | 2009-11-02 → 2010-04-29 A (+178d) |  | 0% → 100% | 440d → none | 12236060, 9-100M FS+22d → 12236060, 9-100M FS+142d |  |
| 14363021 | Produce Drawings - Steel (SHIELD HOUSE) FY11 | 2011-08-11 → 2011-04-25 A (-108d) | 2011-09-30 → 2012-10-15 A (+381d) | 36d → 369.4d | 0% → 100% | 344d → none |  | resources MECH ENG [301.94 h]; MECH DES [603.87 h] → MECH DES [603.87 h]; MECH ENG [301.94 h] |
| 14363021a | Produce Drawings - Steel (SHIELD HOUSE) FY12 | 2011-10-03 → 2011-04-25 A (-161d) | 2011-11-07 → 2012-10-15 A (+343d) | 26d → 370d | 0% → 100% | 344d → none | 14363021 → 14363021 FS-110d |  |
| 14363030 | Proc Boron and Lead Shielding (SHIELD HOUSE) Part A | 2013-01-03 → 2012-04-02 A (-276d) | 2013-03-29 → 2013-04-15 A (+17d) | 60d → 207d | 0% → 100% | 63d → none | 14363021a, 9-130M FS+60d → 14363021a FS-100d | resources PROCUREMENT>$50K 69; PROCUREMENT<$50K 60 → PROCUREMENT<$50K 60; PROCUREMENT>$50K 69 |
| 14363022 | Procurement Prep - Steel (SHIELD HOUSE) | 2011-11-08 → 2012-11-03 A (+361d) | 2011-12-07 → 2012-11-19 A (+348d) | 20d → 11d | 0% → 100% | 349d → none | 14363021a → 14363021a FS-20d |  |
| 14363025 | Fab Steel Supprt (SHIELD HOUSE) | 2011-12-08 → 2012-11-08 A (+336d) | 2012-05-07 → 2012-11-19 A (+196d) | 100d → 8d | 0% → 100% | 349d → none |  | resources MECH DES [160 h]; MECH ENG [160 h]; MECH TECH [160 h] → MECH DES [160 h]; MECH TECH [160 h]; MECH ENG [160 h] |
| 14363030a | Proc Boron and Lead Shielding (SHIELD HOUSE) Part B | 2013-01-03 → 2013-01-28 A (+25d) | 2013-03-29 → 2013-08-19 A (+143d) | 60d → 120d | 0% → 100% | 63d → none | 9-130M FS+60d, 14363021a → 14363021a |  |
| 14363021b | Produce Drawings FY13 | 2013-01-02 → 2013-04-01 A (+89d) | 2013-07-31 → 2013-08-26 A (+26d) |  | 0% → 100% | 42d → none | 9-130M FS+59d → 9-130M FS+110d, 14368325 FS+15d |  |
| 14363035 | Fab Doors and associated hardware for Shield House (SHIELD HOUSE) | 2013-08-30 → 2013-04-19 A (-133d) | 2013-08-30 A | 1d → 32d | 0% → 100% | 20d → none | 9-130M FS+227d → none | was named Fab Doors and associated hardware for Shield House (SHIELD HOUSE) (Future Activity Complete prior to Rebaseline); resources PROCUREMENT<$50K 60; PROCUREMENT>$50K 69; MECH DES; PROCUREMENT<$50K 60 NO ESCALATION FY14; PROCUREMENT>$50K 69 NO ESCALATION FY14 → PROCUREMENT>$50K 69; PROCUREMENT<$50K 60; MECH DES; PROCUREMENT<$50K 60 NO ESCALATION FY14; PROCUREMENT>$50K 69 NO ESCALATION FY14 |
| 14363060 | Fab Various Small Components (SHIELD HOUSE) | 2013-04-01 → 2013-08-30 A (+151d) | 2013-07-01 → 2013-08-30 A (+60d) |  | 0% → 100% | 63d → none |  | resources PROCUREMENT<$50K 60; MECH ENG [80 h]; MSHOP → MECH ENG [80 h]; MSHOP; PROCUREMENT<$50K 60 |
| 14363065 | Re-Baseline Actuals Adjustment | 2013-08-30 A | 2013-08-30 A |  | 0% → 100% | 20d → none | 9-130M FS+227d → none |  |
| 24363030aa | Assemble Cast Panels and Lead Sheets (SHIELD HOUSE) | 2013-09-03 A | 2013-12-20 → 2013-10-21 A (-60d) |  | 0% → 100% | 186d → none |  | resources PROCUREMENT<$50K 60 NO ESCALATION FY14 → PROCUREMENT>$50K 69 NO ESCALATION FY14 |
| 24363035 | Fab Doors and associated hardware for Shield House (SHIELD HOUSE) Part A | 2013-09-03 A |  |  | 0% → 34% |  | 9-130M FS+228d → 9-130M SS+228d |  |
| 24363036 | Fab Doors and associated hardware for Shield House (SHIELD HOUSE) Part B | 2013-09-03 A | 2013-12-20 → 2013-10-21 A (-60d) |  | 0% → 100% | 209d → none | 9-130M FS+228d → 9-130M SS+228d |  |
| 24363041 | Plastic Pellets | 2013-09-03 A | 2013-09-30 → 2013-10-21 A (+21d) |  | 0% → 100% | 551d → none | 9-130M FS+228d → 9-130M SS+228d | resources PROCUREMENT<$50K 60 → PROCUREMENT<$50K 60 NO ESCALATION FY14 |
| 24363046 | Rental Containers for Plastic Pellets | 2013-09-03 A | 2013-09-30 → 2013-12-20 (+81d) |  |  | 551d → 494d |  | resources PROCUREMENT<$50K 60 → PROCUREMENT<$50K 60 NO ESCALATION FY14 |
| 24363037 | Fab Doors and associated hardware for Shield House (SHIELD HOUSE) Part C Procurement | 2013-09-03 → 2013-10-01 A (+28d) |  | 97d → 19d | 0% → 16% |  | 9-130M FS+228d → 9-130M SS+228d | resources MECH DES; PROCUREMENT<$50K 60 NO ESCALATION FY14 → PROCUREMENT<$50K 60 NO ESCALATION FY14 |
| 24363037a | Fab Doors and associated hardware for Shield House (SHIELD HOUSE) Part C Labor FY13 | 2013-09-03 → 2013-10-01 A (+28d) | 2013-09-30 → 2014-01-30 (+122d) | 20d → 19d | 0% → 16% |  | 9-130M FS+228d → 9-130M |  |
| 24363037b | Fab Doors and associated hardware for Shield House (SHIELD HOUSE) Part C Labor FY14 | 2013-10-01 A |  |  | 0% → 16% |  | 9-130M FS+228d, 24363037a → 24363037a FS-54d |  |
| 24363060 | Fab Various Small Components (SHIELD HOUSE) | 2013-10-01 → 2013-11-18 (+48d) | 2014-01-13 → 2014-01-16 (+3d) | 65d → 34d |  | 404d → 401d | 24363030aa FS-57d → 24363030aa FS+20d |  |
| 4 | **1.4.3.6.4 CRYOGENIC SYSTEM** | 2010-10-01 → 2010-06-01 (-122d) |  |  |  |  |  |  |
| 14364005 | Update Overall Cryo Flow Sheet (CRYO SYS) | 2010-10-01 → 2010-06-01 A (-122d) | 2010-11-29 → 2010-08-30 A (-91d) | 40d → 64d | 0% → 100% | 393d → none | 12236015b, 9-110M → 12236015b, 9-110M FS-65d | resources MECH ENG [80 h]; MECH DES [160 h] → MECH DES [160 h]; MECH ENG [80 h] |
| 14364035 | Fab Jlab U-tubes (CRYO SYS) | 2012-05-29 → 2010-11-01 A (-575d) | 2012-09-19 → 2012-04-16 A (-156d) | 80d → 358d | 0% → 100% | 255d → none | 9-120M, 14364030 → 9-110M, 14364030 FS-500d |  |
| 14364025 | Fab SHMS Distrbtn Transfer Line (CRYO SYS) | 2011-11-30 → 2010-12-06 A (-359d) | 2012-03-02 → 2012-04-16 A (+45d) | 60d → 335d | 0% → 100% | 185d → none | 14364010 → 14364020a FS-305d, 14364020b FS-300d | resources MECH ENG [160 h]; PLABOR; MECH TECH [320 h] → PLABOR; MECH TECH [320 h]; MECH ENG [160 h] |
| 14364040 | Fab Jlab L tubes (CRYO SYS) | 2012-05-29 → 2011-03-01 A (-455d) | 2012-09-19 → 2012-04-16 A (-156d) | 80d → 282d | 0% → 100% | 255d → none | 14364030 → 14364030 FS-500d | resources MECH DES [160 h]; MECH ENG [40 h]; PROCUREMENT>$50K 69 → MECH ENG [40 h]; MECH DES [160 h]; PROCUREMENT>$50K 69 |
| 14364020 | Proc SHMS Distrbtn Transfer Line and Relief Stacks (CRYO SYS) FY12 | 2012-03-05 → 2012-02-13 A (-21d) | 2012-09-28 → 2012-12-17 A (+80d) | 147d → 220d | 0% → 100% | 185d → none | 14364025 → 14364010 FS-225d |  |
| 14364020a | Proc SHMS Distrbtn Transfer Line and Relief Stacks (CRYO SYS) FY13 | 2012-10-01 → 2012-02-13 A (-231d) | 2012-11-14 → 2012-12-17 A (+33d) | 33d → 220d | 0% → 100% | 185d → none | 14364020 → 14364020 FS-160d |  |
| 14364020b | Proc SHMS Distrbtn Transfer Line and Relief Stacks (CRYO SYS) Procurement | 2012-03-05 → 2012-02-13 A (-21d) | 2012-11-14 → 2012-12-17 A (+33d) | 180d → 220d | 0% → 100% | 185d → none | 14364025 → 14364010 FS-225d |  |
| 14364015 | Detail Mods of G0 Transfer Line | 2011-11-30 → 2012-04-09 A (+131d) | 2011-12-30 → 2012-09-17 A (+262d) | 18d → 113d | 0% → 100% | 380d → none | 14364010 → 14364010 FS-120d | resources MECH TECH [48 h]; MECH DES [48 h]; MECH ENG [24 h] → MECH DES [48 h]; MECH ENG [24 h]; MECH TECH [48 h] |
| 14364045 | Proc Valves & Controllers (CRYO SYS) | 2013-03-29 → 2012-10-01 A (-179d) | 2013-05-23 → 2013-03-11 A (-73d) |  | 0% → 100% | 89d → none | 14364030, 14364043, 9-130M FS+80d → 14364030 FS-160d, 9-130M, 14364043 FS-110d |  |
| 14364055 | Proc Vac Gauges (CRYO SYS) | 2013-03-29 → 2012-10-01 A (-179d) | 2013-05-23 → 2012-11-12 A (-192d) |  | 0% → 100% | 89d → none | 9-130M FS+80d, 14364030, 14364043 → 14364030 FS-160d, 14364043, 9-130M |  |
| 14364060 | Fab Stand & Catwalk (CRYO SYS) | 2012-05-29 → 2012-11-05 A (+160d) | 2013-01-07 → 2012-11-26 A (-42d) | 150d → 14d | 0% → 100% | 185d → none |  |  |
| 14364010 | Proc Equipmnt for Mod of G0 Transfer Line (CRYO SYS) | 2011-10-03 → 2012-11-12 A (+406d) | 2011-11-29 → 2013-08-30 A (+640d) | 40d → 88d | 0% → 100% | 185d → none | 9-120M, 14364005 → 9-130M FS+25d, 9-120M FS+215d, 14364005 |  |
| 14364050 | Proc Boom Supprt (CRYO SYS) | 2013-03-29 → 2013-01-28 A (-60d) | 2013-06-21 → 2013-04-15 A (-67d) |  | 0% → 100% | 67d → none | 14364030, 14364043, 9-130M FS+80d → 14364030 FS-85d, 14364043 FS-110d, 9-130M |  |
| 14364030 | Fab SHMS Gas Manifolds (CRYO SYS) | 2012-03-05 → 2013-04-01 A (+392d) | 2012-05-25 → 2013-08-30 A (+462d) |  | 0% → 100% | 185d → none | 14364020a FS-180d, 14364020b FS-180d → 14364025 FS+130d, 9-130M FS+120d | resources MECH ENG [80 h]; MECH DES [80 h]; PROCUREMENT<$50K 60; TRAVEL; MECH TECH [160 h] → TRAVEL; MECH ENG [80 h]; MECH DES [80 h]; MECH TECH [160 h]; PROCUREMENT<$50K 60 |
| 14364043 | Produce Drawings for Cryo System Connections & Controls | 2013-01-02 → 2013-06-01 A (+150d) | 2013-03-28 → 2013-08-30 A (+155d) | 60d → 39d | 0% → 100% | 67d → none | 9-130M FS+59d → 9-130M FS+163.15d |  |
| 14364065 | Proc Cables,panels & Pwr Supplies (CRYO SYS) | 2013-05-03 → 2013-06-01 A (+29d) | 2013-06-28 → 2013-08-30 A (+63d) |  | 0% → 100% | 64d → none |  | resources PROCUREMENT<$50K 60; MECH ENG [80 h]; MECH DES [80 h] → MECH DES [80 h]; PROCUREMENT<$50K 60; MECH ENG [80 h] |
| 14364016 | Modify G0 Transfer Line | 2013-06-12 → 2013-08-30 A (+79d) | 2013-08-30 A | 57d → 107d | 0% → 100% | 20d → none | 14368175 FS+20d, 14364015 → 14364015, 14368175 FS+48d |  |
| 14364075 | Proc & Fab Various Connections etc (CRYO SYS) | 2013-03-29 → 2013-08-30 A (+154d) | 2013-06-07 → 2013-08-30 A (+84d) |  | 0% → 100% | 79d → none |  |  |
| 14364080 | Re-Baseline Actuals Adjustment | 2013-08-30 A | 2013-08-30 A |  | 0% → 100% | 20d → none | 9-130M FS+227d → none |  |
| 24364030 | Fab SHMS Gas Manifolds (CRYO SYS) Part A - Procurement | 2013-09-03 A | 2013-10-24 → 2013-12-20 (+57d) |  | 0% → 88% | 282d → 288d |  | was named Fab SHMS Gas Manifolds (CRYO SYS) Part A Procurement; resources MECH ENG; MECH DES; TRAVEL; MECH TECH; PROCUREMENT<$50K 60 NO ESCALATION FY14 → PROCUREMENT<$50K 60 NO ESCALATION FY14; TRAVEL |
| 24364030a | Fab SHMS Gas Manifolds (CRYO SYS) Part A Labor FY13 | 2013-09-03 A | 2013-09-30 → 2013-12-20 (+81d) |  | 0% → 88% | 282d → 354d |  |  |
| 24364030b | Fab SHMS Gas Manifolds (CRYO SYS) Part A Labor FY14 | 2013-10-01 → 2013-09-03 A (-28d) | 2013-10-24 → 2013-12-20 (+57d) |  | 0% → 88% | 282d → 288d | 9-130M FS+228d, 24364030a → 24364030a FS-100d |  |
| 24364043 | Produce Drawings for Cryo System Connections & Controls FY13 | 2013-09-03 A | 2013-09-30 → 2013-11-27 (+58d) | 20d → 43d | 0% → 40% | 287d → 283d |  |  |
| 24364043a | Produce Drawings for Cryo System Connections & Controls FY14 | 2013-10-01 → 2013-09-03 A (-28d) | 2013-10-24 → 2013-11-27 (+34d) |  | 0% → 40% | 287d → 308d | 9-130M FS+228d, 24364043 → 24364043 FS-100d |  |
| 24364016 | Modify G0 Transfer Line | 2013-10-08 → 2013-10-01 A (-7d) |  |  | 0% → 18% |  |  |  |
| 24364065 | Proc Cables,panels & Pwr Supplies (CRYO SYS) | 2013-10-01 A |  |  | 0% → 20% |  |  |  |
| 24364075 | Proc & Fab Various Connections etc (CRYO SYS) | 2013-10-25 → 2013-10-01 A (-24d) |  |  | 0% → 3% |  | 24364043a FS-5d, 24364030b, 24364030, 24364043 FS-5d, 24364030a → 24364030b FS-40d, 24364043 FS-20d, 24364030 FS-40d |  |

| ID | Task | Start | Finish | Duration | Complete | Total float | Predecessors | Other |
| --- | --- | --- | --- | --- | --- | --- | --- | --- |
| 5 | **1.4.3.6.5 VACUUM SYSTEM** | 2009-01-05 → 2009-07-01 (+177d) | 2015-03-31 → 2015-07-15 (+106d) |  |  |  |  |  |
| 14365005 | Finalize Drawing for Comp Vac Sys | 2009-01-05 → 2009-07-01 A (+177d) | 2009-03-31 → 2009-09-24 A (+177d) |  | 0% → 100% | 88d → none | 12236025, 12236010b, 12236020 → 12236020, 9-130M FS-960d |  |
| 14365010 | Proc Turbo Pump systems | 2013-01-03 → 2012-10-01 A (-94d) | 2013-03-01 → 2013-06-17 A (+108d) | 40d → 62d | 0% → 100% | 88d → none | 14365005 FS+931d, 2-02M → 9-130M, 14365005, 2-02M | resources MECH TECH [40 h]; PROCUREMENT>$50K 69; MECH ENG [40 h]; PROCUREMENT<$50K 60 → MECH ENG [40 h]; PROCUREMENT<$50K 60; PROCUREMENT>$50K 69; MECH TECH [40 h] |
| 14365015 | Proc Roots Pump Sys | 2013-01-03 → 2012-10-01 A (-94d) | 2013-03-01 → 2013-06-17 A (+108d) | 40d → 62d | 0% → 100% | 88d → none | 2-02M, 14365005 FS+931d → 9-130M, 2-02M, 14365005 |  |
| 14365040 | Proc Shutter Exit Window | 2013-01-03 A | 2013-07-09 → 2013-03-11 A (-120d) |  | 0% → 100% | 58d → none | 9-130M FS+60d, 14365005 → 9-120M FS+125d, 14365005, 9-130M FS+60d |  |
| 14365023 | Manufacturing Drawings for Vacuum System Parts | 2013-01-02 → 2013-05-03 A (+121d) | 2013-06-21 → 2013-08-30 A (+70d) | 120d → 99d | 0% → 100% | 69d → none |  |  |
| 14365020 | Proc Valves & Plumbing | 2013-03-04 → 2013-05-06 A (+63d) | 2013-05-24 → 2013-08-30 A (+98d) |  | 0% → 100% | 88d → none | 14365010, 14365015 → 9-130M FS+100d, 14365015 FS-20d, 14365010 FS-20d |  |
| 14365025 | Proc Gauges for Vac Sys | 2013-03-04 → 2013-08-30 A (+179d) | 2013-05-24 → 2013-08-30 A (+98d) |  | 0% → 100% | 88d → none | 2-02M, 14365015, 14365010 → 14365010 FS-40d, 14365015 FS-40d, 2-02M, 9-130M |  |
| 14365035 | Proc Windows & Flanges | 2013-01-03 → 2013-08-30 A (+239d) | 2013-07-09 → 2013-08-30 A (+52d) | 130d → 70d | 0% → 100% | 58d → none | 14365005, 9-130M FS+60d → 9-130M FS+120d, 9-120M FS+125d, 14365005 |  |
| 14365055 | Re-Baseline Actuals Adjustment | 2013-08-30 A | 2013-08-30 A |  | 0% → 100% | 20d → none | 9-130M FS+227d → none |  |
| 24365020 | Proc Valves & Plumbing and Reliefs Part A | 2013-09-03 A |  |  |  |  |  | was named Proc Valves & Plumbing and Reliefs Part A Procurement; resources PROCUREMENT<$50K 60 NO ESCALATION FY14; MECH ENG → MECH ENG; PROCUREMENT>$50K 69 NO ESCALATION FY14 |
| 24365020a | Proc Valves & Plumbing and Reliefs Part A Labor FY13 | 2013-09-03 A | 2013-09-30 → 2014-01-08 (+100d) |  |  | 358d → 927d |  |  |
| 24365020b | Proc Valves & Plumbing and Reliefs Part A Labor FY14 | 2013-10-01 → 2013-09-03 A (-28d) | 2013-11-27 → 2014-01-08 (+42d) |  |  | 358d → 927d | 9-130M FS+228d, 24365020a → 24365020a FS-100d |  |
| 24365023 | Manufacturing Drawings for Vacuum System Parts FY13 | 2013-09-03 A | 2013-09-30 → 2014-01-31 (+123d) | 20d → 98d | 0% → 50% | 150d → 102d |  |  |
| 24365023a | Manufacturing Drawings for Vacuum System Parts FY14 | 2013-10-01 → 2013-09-03 A (-28d) |  |  | 0% → 50% | 150d → 102d | 24365023, 9-130M FS+228d → 24365023 FS-100d |  |
| 24365025 | Proc Valves & Plumbing and Reliefs Part B | 2013-09-03 A |  |  |  |  |  | resources PROCUREMENT<$50K 60 NO ESCALATION FY14 → PROCUREMENT<$50K 60 |
| 24365030 | Proc Spool & Bellows for All Magnets Part A | 2013-09-03 A |  |  | 0% → 38% |  | 24365023 FS-100d, 9-130M FS+228d, 24365023a FS-100d → 24365023 FS-100d, 9-130M FS+228d | resources PROCUREMENT<$50K 60 NO ESCALATION FY14 → PROCUREMENT>$50K 69 NO ESCALATION FY14 |
| 24365035 | Proc Windows & Flanges Part A | 2013-09-03 A |  |  | 0% → 12% |  |  | resources PROCUREMENT<$50K 60 NO ESCALATION FY14 → PROCUREMENT<$50K 60 |
| 24365045 | Proc Sieve Slit Sys Part A | 2013-09-03 A |  |  | 0% → 4% |  | 24365030 FS-203d, 24365035 FS-98d, 24365040 FS-140d, 24365032 FS-251d → 24365030 FS-203d, 24365032 FS-390d, 24365040 FS-140d, 24365035 FS-98d | resources PROCUREMENT<$50K 60 NO ESCALATION FY14 → PROCUREMENT<$50K 60 NO ESCALATION FY15; PROCUREMENT>$50K 69 NO ESCALATION FY15 |
| 24365032 | Proc Spool & Bellows for All Magnets Part B | 2013-11-08 → 2013-10-07 A (-32d) | 2014-09-08 → 2014-12-22 (+105d) |  | 0% → 33% | 150d → 77d | 9-130M FS+228d, 24365023a FS-50d, 24365023 FS-50d → 9-130M FS+228d, 24365023 FS-80d, 24365023a FS-80d |  |
| 24365047 | Proc Sieve Slit Sys Part B | 2014-06-13 → 2014-09-26 (+105d) | 2015-03-26 → 2015-07-10 (+106d) |  |  | 153d → 80d |  |  |
| 24365050 | Fab Slit Controls | 2014-06-13 → 2014-09-26 (+105d) | 2015-03-31 → 2015-07-15 (+106d) |  |  | 150d → 77d |  |  |
| 6 | **1.4.3.6.6 CABLING** | 2012-01-05 → 2012-02-01 (+27d) | 2014-07-28 → 2014-07-24 (-4d) |  |  |  |  |  |
| 14366005 | Proc HV Cables (CABLING) Original | 2012-01-05 → 2012-02-01 A (+27d) | 2012-01-31 → 2012-02-06 A (+6d) | 18d → 4d | 0% → 100% | 417d → none |  |  |
| 14366010 | Proc LV & Signal Cables (CABLING) Original | 2012-01-05 → 2012-02-01 A (+27d) | 2012-01-31 → 2012-02-06 A (+6d) | 18d → 4d | 0% → 100% | 417d → none |  |  |
| 14366020 | Reverse Entry Per CR12-022 | 2012-02-03 → 2012-02-01 A (-2d) | 2012-08-07 → 2012-02-06 A (-183d) | 130d → 4d | 0% → 100% | 285d → none |  |  |
| 14366007 | Proc HV Cables (CABLING) Revised per CR12-022 | 2012-10-01 → 2012-12-03 A (+63d) | 2013-04-12 → 2012-12-17 A (-116d) |  | 0% → 100% | 118d → none |  |  |
| 14366015 | Proc LV & Signal Cables (CABLING) Revised per CR12-022 | 2012-10-01 → 2012-12-03 A (+63d) | 2013-04-12 → 2012-12-17 A (-116d) |  | 0% → 100% | 20d → none |  |  |
| 14366025 | Terminate Cables | 2013-07-02 → 2013-08-30 A (+59d) | 2013-08-30 A | 43d → 127d | 0% → 100% | 20d → none | 14366015 FS+55d → 9-140M FS+80d, 14366015 FS+55d |  |
| 14366030 | Re-Baseline Actuals Adjustment | 2013-08-30 A | 2013-08-30 A |  | 0% → 100% | 20d → none | 9-130M FS+227d → none |  |
| 24366025 | Terminate Cables | 2014-02-05 → 2014-02-03 (-2d) | 2014-07-28 → 2014-07-24 (-4d) |  |  | 225d → 227d |  |  |
| 7 | **1.4.3.6.7 SOS PIVOT MODIFICATION** | 2011-11-02 → 2011-11-01 (-1d) |  |  |  |  |  |  |
| 14367005 | Proc Parts for SHMS Pivot Connection (SOS PIVOT MOD) | 2011-11-02 → 2011-11-01 A (-1d) | 2012-05-15 → 2011-11-30 A (-167d) | 130d → 20d | 0% → 100% | 231d → none |  | resources MECH ENG [40 h]; MECH DES [40 h] → MECH DES [40 h]; MECH ENG [40 h] |
| 14367010 | Re-Baseline Actuals Adjustment | 2013-08-30 A | 2013-08-30 A |  | 0% → 100% | 20d → none | 9-130M FS+227d → none |  |
| 14368171 | Strip Clean The SOS: Hoses, Cable & Shielding | 2011-05-13 A | 2011-10-18 → 2011-10-17 A (-1d) | 110d → 109d | 0% → 100% | 18d → none |  |  |
| 14368170 | Remove Remaining HKS/HES Components | 2011-05-13 → 2011-09-01 A (+111d) | 2011-07-25 → 2011-10-24 A (+91d) | 50d → 37d | 0% → 100% | 78d → none | 4A-01M → 4A-01M FS+60d |  |
| 14368005 | Prep for Safty Review for Installtn Plans (Installtn) | 2011-11-02 → 2012-01-31 A (+90d) | 2011-12-08 → 2012-04-16 A (+130d) | 25d → 54d | 0% → 100% | 157d → none | 9-120M FS+22d → 9-120M FS+60d | was named Prep for safety Review for Installtn Plans; resources ELEC ENG [160 h]; MECH DES [320 h]; MECH ENG [160 h] → MECH DES [320 h]; MECH ENG [160 h]; ELEC ENG [160 h] |
| 14368010M | Comp Sfty Review for Installtn Plans (Installtn) | 2011-12-08 → 2012-04-16 A (+130d) | 2011-12-08 → 2012-04-16 A (+130d) |  | 0% → 100% | 157d → none | 14368005 → 14368005 FS+20d | was named Comp safety Review for Installtn Plans |
| 14368176 | Reroute HMS Cableways to Clear SHMS | 2012-05-14 → 2012-05-01 A (-13d) | 2012-08-07 → 2013-06-17 A (+314d) | 60d → 176d | 0% → 100% | 178d → none | 2-07M, 2-02M → 2-02M, 2-07M FS-40d | resources MECH TECH [80 h]; PROCUREMENT<$50K 60; MECH DES [80 h] → PROCUREMENT<$50K 60; MECH DES [80 h]; MECH TECH [80 h] |
| 14368172 | Radiation Cooldown | 2012-05-14 → 2012-05-18 A (+4d) | 2012-06-12 → 2012-07-13 A (+31d) | 20d → 39d | 0% → 100% | 20d → none |  |  |
| 14368172a | Qweak Post Run Alignment Survey | 2012-05-29 → 2012-05-18 A (-11d) | 2012-06-12 → 2012-07-13 A (+31d) | 10d → 39d | 0% → 100% | 20d → none |  |  |
| 14368174 | Dismantle & Remove Qweak Electronics Bunker | 2012-06-13 → 2012-06-05 A (-8d) | 2012-06-19 → 2012-06-18 A (-1d) | 5d → 10d | 0% → 100% | 20d → none | 14368172a, 14368172 FS-20d → 14368172a FS-20d, 14368172 FS-20d |  |
| 14368174h | Remove HKS Dummy weight | 2012-06-20 → 2012-06-16 A (-4d) | 2012-06-21 → 2012-06-18 A (-3d) | 2d → 1d | 0% → 100% | 20d → none |  |  |
| 14368174j | Remove Qweak cableling and trays | 2012-06-22 → 2012-06-18 A (-4d) | 2012-06-28 → 2012-08-13 A (+46d) | 5d → 41d | 0% → 100% | 20d → none | 14368174h → 14368174h FS-20d |  |
| 14368174k | Remove Qweak Region 3 Shield Hut | 2012-06-29 → 2012-06-18 A (-11d) | 2012-07-16 → 2012-08-20 A (+35d) | 12d → 46d | 0% → 100% | 20d → none | 14368174j → 14368174j FS-25d |  |
| 14368174n | Remove Qweak Region 3 Detectors and support structures | 2012-07-17 → 2012-06-18 A (-29d) | 2012-08-06 → 2012-08-20 A (+14d) | 15d → 46d | 0% → 100% | 20d → none | 14368174k → 14368174k FS-20d |  |
| 14368174s | Remove Qweak cryo target complete | 2012-09-17 → 2012-06-18 A (-91d) | 2012-09-21 → 2012-09-10 A (-11d) | 5d → 60d | 0% → 100% | 20d → none | 14368174r → 14368174r FS-60d |  |
| 14368174t | Remove all remaining 9.5" concrete pads | 2012-09-24 → 2012-06-18 A (-98d) | 2012-10-05 → 2012-12-17 A (+73d) | 10d → 132d | 0% → 100% | 20d → none | 14368174s → 14368174s FS-60d |  |
| 14368173 | Disconnect & Remove Qweak Girder | 2012-06-13 → 2012-07-15 A (+32d) | 2012-06-19 → 2012-07-31 A (+42d) | 5d → 12d | 0% → 100% | 208d → none |  |  |
| 14368174p | Remove QTOR Magnet | 2012-08-07 → 2012-08-06 A (-1d) | 2012-08-20 → 2012-08-19 A (-1d) |  | 0% → 100% | 20d → none |  |  |
| 14368174q | Remove Qweak shield wall and beam dump sections | 2012-08-21 → 2012-08-06 A (-15d) | 2012-08-27 → 2012-08-20 A (-7d) | 5d → 11d | 0% → 100% | 20d → none |  |  |
| 14368174r | Remove Qweak regions 1 and 2 | 2012-08-28 → 2012-08-20 A (-8d) | 2012-09-14 → 2012-08-27 A (-18d) | 13d → 6d | 0% → 100% | 20d → none |  |  |
| 14368174a | Install SOS Rails, Move SOS and Remove doors and door frame | 2012-06-20 → 2012-11-03 A (+136d) | 2012-07-03 → 2012-11-14 A (+134d) | 10d → 8d | 0% → 100% | 58d → none | 14368174 → 14368174 FS+59d |  |
| 14368174d | Remove SOS Dipole | 2012-09-24 → 2012-11-12 A (+49d) | 2012-09-28 → 2012-11-19 A (+52d) | 5d → 6d | 0% → 100% | 26d → none |  |  |
| 14368174b | Remove SOS Hydraulic Cylinders and supports | 2012-07-04 → 2012-11-17 A (+136d) | 2012-07-17 → 2012-11-26 A (+132d) | 10d → 4d | 0% → 100% | 58d → none |  |  |
| 14368174c | Move SOS Back and Saw cut and remove concrete | 2012-07-18 → 2012-12-03 A (+138d) | 2012-08-07 → 2012-12-17 A (+132d) |  | 0% → 100% | 58d → none |  |  |
| 14368174f | Saw cut and remove remaining SOS concrete | 2013-02-15 → 2013-01-07 A (-39d) | 2013-02-20 → 2013-02-11 A (-9d) |  | 0% → 100% | 26d → none | 14368174d FS+90d → 14368174d FS+40d |  |
| 14368322 | Re-Establish Hall-C Alignment Network Prior to SHMS Assy | 2013-01-02 → 2013-01-14 A (+12d) | 2013-01-08 → 2013-01-31 A (+23d) |  | 0% → 100% | 31d → none |  |  |
| 14368325 | Install Rails of Supprt Struct | 2012-11-19 → 2013-01-14 A (+56d) | 2013-01-10 → 2013-02-11 A (+32d) |  | 0% → 100% | 20d → none | 14368174t FS+30d, 14368322 FS-40d, 14362015 → 14368174t FS+5d, 14362015, 14368322 FS-40d | resources PLABOR; MECH TECH [80 h]; SUPPLIES & MATERIALS; MSHOP → SUPPLIES & MATERIALS; MSHOP; PLABOR; MECH TECH [80 h] |
| 14368174g | Remove SOS Chassis , rails and pivot bearing | 2013-02-21 → 2013-02-06 A (-15d) | 2013-03-15 → 2013-02-11 A (-32d) |  | 0% → 100% | 26d → none |  |  |
| 14368180 | Restore HaLL C and ESR Cryo To Base Config. | 2012-05-14 → 2013-02-18 A (+280d) | 2012-05-25 → 2013-06-17 A (+388d) |  | 0% → 100% | 275d → none | 2-02M → 2-02M, 9-130M |  |
| 14368175 | Ccan and platform removal | 2013-04-02 → 2013-03-04 A (-29d) | 2013-05-13 → 2013-08-30 A (+109d) | 30d → 84d | 0% → 100% | 20d → none | 14368020 FS-3d → 14368020 FS-100d | resources MECH DES [240 h]; MECH TECH [880 h] → MECH TECH [880 h]; MECH DES [240 h] |
| 14368207 | Complete Readiness Review for SHMS DCPS Testing | 2013-01-02 → 2013-03-11 A (+68d) | 2013-02-13 → 2013-08-30 A (+198d) | 30d → 11d | 0% → 100% | 297d → none |  |  |
| 14368327 | Check Rail Alignment | 2013-02-21 → 2013-03-11 A (+18d) | 2013-02-21 → 2013-03-11 A (+18d) |  | 0% → 100% | 707d → none |  |  |
| 14368335M | Central Rails for SHMS Installed (SHIELD HOUSE) | 2013-02-22 → 2013-03-11 A (+17d) | 2013-02-22 → 2013-03-11 A (+17d) |  | 0% → 100% | 707d → none |  |  |
| 14368015 | Install Pivot for SHMS | 2013-03-26 → 2013-04-01 A (+6d) | 2013-04-01 → 2013-06-17 A (+77d) |  | 0% → 100% | 20d → none | 14367005, 14368173, 14368174g, 14362075a, 14368325 FS+50d, 14362075b, 3P-07M → 14362075a, 14367005, 14368325 FS+22d, 14368174g, 14368173, 3P-07M, 14362075b | resources MECH ENG [40 h]; MECH DES [40 h]; PROCUREMENT<$50K 60; MECH TECH [80 h]; PLABOR → MECH TECH [80 h]; PLABOR; MECH DES [40 h]; MECH ENG [40 h]; PROCUREMENT<$50K 60 |
| 14368020 | Move Pre-Fab Compnts into Hall with road crane | 2013-04-02 → 2013-04-01 A (-1d) | 2013-04-04 → 2013-08-23 A (+141d) |  | 0% → 100% | 20d → none | 14362050, 14368174t, 14362030, 14368176, 14362035, 14362055, 14362035a, 14362020, 14368015, 14362015, 14362040, 14362045, 14362025, 14362050a → 14362015, 14362025, 14362040, 14362050, 14362050a, 14362035, 14362030, 14368015 FS-100d, 14362055, 14368174t, 14362045, 14362035a, 14362020 | resources MECH DES [40 h]; MECH TECH [80 h]; PROCUREMENT<$50K 60; PROCUREMENT>$50K 69 → PROCUREMENT<$50K 60; PROCUREMENT>$50K 69; MECH DES [40 h]; MECH TECH [80 h] |
| 14368027 | Install Wheels and Bogies | 2013-08-08 → 2013-04-01 A (-129d) | 2013-08-21 → 2013-08-30 A (+9d) |  | 0% → 100% | 27d → none | 14362050, 14368330, 14362050a → 14368330 FS-100d, 14362050, 14362050a | resources MECH DES [160 h]; MECH ENG [80 h]; MECH TECH [216 h]; PROCUREMENT<$50K 60; PROCUREMENT>$50K 69 → MECH ENG [80 h]; MECH TECH [216 h]; MECH DES [160 h]; PROCUREMENT>$50K 69; PROCUREMENT<$50K 60 |
| 14368330 | Assemble Main Carriage of Supprt Struct | 2013-05-14 → 2013-04-01 A (-43d) | 2013-08-07 → 2013-08-30 A (+23d) |  | 0% → 100% | 20d → none | 14362060, 14368175, 14368020, 14362011 FS-125d → 14362011 FS-125d, 14368020 FS-100d, 14362060 | resources MECH ENG [200 h]; MSHOP; SUPPLIES & MATERIALS; PLABOR; MECH TECH [1040 h]; PROCUREMENT<$50K 60; MECH DES [320 h]; PROCUREMENT>$50K 69 → MECH TECH [1040 h]; PROCUREMENT<$50K 60; MECH ENG [200 h]; MSHOP; SUPPLIES & MATERIALS; PLABOR; MECH DES [320 h]; PROCUREMENT>$50K 69 |
| 14368280LOE | Installation Management P1 | 2013-07-01 A | 2013-08-30 A | 44d → 64d | 0% → 100% | 20d → none |  |  |

| ID | Task | Start | Finish | Duration | Complete | Total float | Predecessors | Other |
| --- | --- | --- | --- | --- | --- | --- | --- | --- |
| 14368028 | Construct REAR Access Platform & Shield Wall | 2013-08-08 → 2013-08-30 A (+22d) | 2013-08-30 A | 17d → 13d | 0% → 100% | 20d → none |  | resources MECH DES [90.67 h]; MECH TECH [113.33 h]; PROCUREMENT<$50K 60; MECH ENG [45.33 h] → MECH DES [160 h]; MECH TECH [200 h]; PROCUREMENT<$50K 60; MECH ENG [80 h] |
| 14368115 | Prep for Vac & pressure systems Safty Review | 2013-06-25 → 2013-08-30 A (+66d) | 2013-07-09 → 2013-08-30 A (+52d) |  | 0% → 100% | 58d → none | 9-130M FS+180d → 9-140M FS+310d | was named Prep for Vac & pressure systems Safety Review |
| 14368182M | Cryogens Available from ESR or CHL | 2012-05-29 → 2013-08-30 A (+458d) | 2012-05-29 → 2013-08-30 A (+458d) |  | 0% → 100% | 275d → none | 9-120M FS+160d → 9-130M FS+184d, 9-120M FS+160d |  |
| 14368185 | Cool Down HMS Dipole | 2012-05-29 → 2013-08-30 A (+458d) | 2012-06-05 → 2013-08-30 A (+451d) |  | 0% → 100% | 275d → none |  |  |
| 14368190 | Cool Down HMS Q1 | 2012-06-06 → 2013-08-30 A (+450d) | 2012-06-19 → 2013-08-30 A (+437d) |  | 0% → 100% | 275d → none |  |  |
| 14368195 | Cool Down HMS Q2 | 2012-06-20 → 2013-08-30 A (+436d) | 2012-07-03 → 2013-08-30 A (+423d) |  | 0% → 100% | 275d → none |  |  |
| 14368200 | Cool Down HMS Q3 | 2012-07-04 → 2013-08-30 A (+422d) | 2012-07-17 → 2013-08-30 A (+409d) |  | 0% → 100% | 275d → none |  |  |
| 14368205 | Comission HMS Dipole at 3000 amps | 2012-07-18 → 2013-08-30 A (+408d) | 2012-07-31 → 2013-08-30 A (+395d) |  | 0% → 100% | 275d → none |  |  |
| 14368210 | Prepare LCW for SHMS DCPS Testing | 2012-06-06 → 2013-08-30 A (+450d) | 2012-06-19 → 2013-08-30 A (+437d) |  | 0% → 100% | 297d → none | 14368185, 14368207 FS-171d → 14368185, 14368207 | resources SUPPLIES & MATERIALS; MECH TECH [160 h]; MECH ENG [80 h] → MECH TECH [160 h]; MECH ENG [80 h]; SUPPLIES & MATERIALS |
| 14368215 | Prepare AC Power for SHMS DCPS Testing | 2012-06-06 → 2013-08-30 A (+450d) | 2012-06-19 → 2013-08-30 A (+437d) |  | 0% → 100% | 297d → none |  |  |
| 14368220 | Connect HMS Q1 to SHMS DCPS #1 | 2012-06-20 → 2013-08-30 A (+436d) | 2012-06-21 → 2013-08-30 A (+435d) |  | 0% → 100% | 295d → none |  |  |
| 14368225 | Test Power Supply DCPS #1 | 2012-06-22 → 2013-08-30 A (+434d) | 2012-06-26 → 2013-08-30 A (+430d) |  | 0% → 100% | 295d → none |  |  |
| 14368230 | Connect HMS Q1 to SHMS DCPS #2 | 2012-06-27 → 2013-08-30 A (+429d) | 2012-06-28 → 2013-08-30 A (+428d) |  | 0% → 100% | 295d → none |  |  |
| 14368235 | Test Power Supply DCPS #2 | 2012-06-29 → 2013-08-30 A (+427d) | 2012-07-03 → 2013-08-30 A (+423d) |  | 0% → 100% | 295d → none |  |  |
| 14368240 | Connect HMS Dipole to SHMS DCPS #3 | 2013-04-17 → 2013-08-30 A (+135d) | 2013-04-18 → 2013-08-30 A (+134d) |  | 0% → 100% | 101d → none | 14315085 FS+110d, 14368235, 14368205 → 14368235, 14368205, 14315085 |  |
| 14368245 | Test Power Supply DCPS #3 | 2013-04-19 → 2013-08-30 A (+133d) | 2013-04-23 → 2013-08-30 A (+129d) |  | 0% → 100% | 101d → none |  |  |
| 14368250 | Connect HMS Dipole to SHMS DCPS #4 | 2013-04-24 → 2013-08-30 A (+128d) | 2013-04-25 → 2013-08-30 A (+127d) |  | 0% → 100% | 101d → none |  |  |
| 14368255 | Test Power Supply DCPS #4 | 2013-04-26 → 2013-08-30 A (+126d) | 2013-04-30 → 2013-08-30 A (+122d) |  | 0% → 100% | 101d → none |  |  |
| 14368260 | Connect HMS Dipole to SHMS DCPS #5 | 2013-05-01 → 2013-08-30 A (+121d) | 2013-05-02 → 2013-08-30 A (+120d) |  | 0% → 100% | 101d → none |  |  |
| 14368265 | Test Power Supply DCPS #5 | 2013-05-03 → 2013-08-30 A (+119d) | 2013-05-07 → 2013-08-30 A (+115d) |  | 0% → 100% | 101d → none |  |  |
| 14368333 | Install Cryo Boom Support | 2013-08-08 → 2013-08-30 A (+22d) | 2013-08-09 → 2013-08-30 A (+21d) |  | 0% → 100% | 35d → none |  | resources MECH DES [80 h]; MECH TECH [160 h]; PROCUREMENT<$50K 60 → PROCUREMENT<$50K 60; MECH TECH [160 h]; MECH DES [80 h] |
| 14368383 | Procure SHMS Platform Assembly Parts | 2012-12-03 → 2013-08-30 A (+270d) | 2013-04-30 → 2013-08-30 A (+122d) |  | 0% → 100% | 106d → none |  | was named Procure SHMS Steel Platforms and Stairs |
| 14368425 | Install QR Magnets (Notebook) | 2012-05-16 → 2013-08-30 A (+471d) | 2012-07-26 → 2013-08-30 A (+400d) |  | 0% → 100% | 846d → none | 14352005 → 9-130M FS+235d, 9-120M FS+150d, 14352005 |  |
| 14368510 | Re-Baseline Actuals Adjustment | 2013-08-30 A | 2013-08-30 A |  | 0% → 100% | 20d → none | 9-130M FS+227d → none |  |
| 14368120M | Comp safety Review of vacuum & pressure Vessel systems Implementn | 2013-07-09 → 2013-08-30 A (+52d) | 2013-07-09 → 2013-08-30 A (+52d) |  | 0% → 100% | 58d → none |  |  |
| 24368040 | Procure SHMS Steel Platforms and Stairs (Box O Parts) Part A | 2013-09-03 A | 2013-12-20 → 2013-10-21 A (-60d) |  | 0% → 100% | 285d → none |  | resources PROCUREMENT<$50K 60 NO ESCALATION FY14 → PROCUREMENT>$50K 69 |
| 24368050 | Install SHMS Steel Procurement | 2013-09-03 A | 2013-09-30 → 2013-11-01 (+32d) |  | 0% → 100% | 189d → 252d |  |  |
| 24368065 | Forming and Pouring Work for Concrete - Procurement | 2013-09-03 A |  |  | 0% → 50% | 189d → 232d |  | resources MECH DES; MECH ENG; PROCUREMENT<$50K 60 NO ESCALATION FY14; PROCUREMENT>$50K 69 NO ESCALATION FY14 → PROCUREMENT<$50K 60 NO ESCALATION FY14; PROCUREMENT>$50K 69 NO ESCALATION FY14 |
| 24368065a | Forming and Pouring Work for Concrete - Labor FY13 | 2013-09-03 A | 2013-09-30 → 2013-11-27 (+58d) |  | 0% → 50% | 189d → 391d | 9-130M FS+228d, 24368050 FS-20d → 9-130M FS+228d |  |
| 24368065b | Forming and Pouring Work for Concrete - Labor FY14 | 2013-10-01 → 2013-09-03 A (-28d) |  |  | 0% → 50% | 189d → 305d | 24368065a, 24368050 FS-20d, 9-130M FS+228d → 24368065a FS-105d |  |
| 24368070 | Procure Concrete for Shield House - Procurement | 2013-09-03 A |  |  | 0% → 50% |  | 24368065b FS-62d, 24368065a FS-62d, 24368065 FS-62d → 24368065 FS-62d | resources MECH TECH; PROCUREMENT<$50K 60 NO ESCALATION FY14; PROCUREMENT>$50K 69 NO ESCALATION FY14 → PROCUREMENT<$50K 60 NO ESCALATION FY14; PROCUREMENT>$50K 69 NO ESCALATION FY14 |
| 24368070a | Procure Concrete for Shield House - Labor FY13 | 2013-09-03 A | 2013-09-30 → 2013-11-27 (+58d) |  | 0% → 50% | 189d → 565d | 24368065 FS-62d, 24368065a FS-62d, 24368065b FS-62d → 24368065a FS-62d, 24368065b FS-62d |  |
| 24368070b | Procure Concrete for Shield House - Labor FY14 | 2013-10-01 → 2013-09-03 A (-28d) |  |  | 0% → 50% | 189d → 479d | 24368065 FS-62d, 24368065a FS-62d, 24368065b FS-62d, 24368070a → 24368070a FS-105d, 24368065a FS-62d, 24368065b FS-62d |  |
| 24368120 | Long-lead procurements for AC Pwr for Support Structure | 2013-09-03 A | 2013-09-30 → 2013-10-21 A (+21d) |  | 0% → 100% | 355d → none | 24368070 FS-62d, 9-130M FS+228d, 24368070a FS-62d, 24368070b FS-62d → 9-130M FS+228d, 24368070 FS-62d | resources PROCUREMENT<$50K 60 → PROCUREMENT>$50K 69 |
| 24368170 | Remove and Preserve C-Can and Lines | 2013-09-03 A | 2013-09-30 A |  | 0% → 100% | 238d → none |  |  |
| 24368190 | Complete Readiness Review for SHMS DCPS Testing FY13 | 2013-09-03 A | 2013-09-30 → 2014-01-15 (+107d) | 20d → 33d | 0% → 50% | 326d → 272d |  |  |
| 24368190a | Complete Readiness Review for SHMS DCPS Testing FY14 | 2013-10-01 → 2013-09-03 A (-28d) | 2013-10-17 → 2014-01-15 (+90d) |  | 0% → 50% | 326d → 272d | 24368190, 9-130M FS+228d → 24368190 FS-100d |  |
| 24368575LOE | Installation Management P1 | 2013-09-03 A | 2013-09-30 A |  | 0% → 100% | 439d → none |  |  |
| 24368052 | Align Wheels and Bogies on Support Structure | 2013-09-03 → 2013-09-16 A (+13d) | 2013-09-06 → 2013-09-30 A (+24d) |  | 0% → 100% | 567d → none |  |  |
| 24368580LOE | Installation Management P2 | 2013-10-01 A |  |  | 0% → 9% |  |  |  |
| 24368080 | Concrete Hardening Period |  |  |  |  |  | 24368070a FS-18d, 24368070b FS-18d, 24368070 FS-18d → 24368070 FS-18d |  |
| 24368180 | Pre-Alignment SHMS Cryo Supports |  |  |  |  |  | 24368065b, 24368065, 24368065a → 24368065, 24368065b |  |
| 24368060 | Construct REAR Access Platform & Shield Wall | 2013-11-01 → 2013-12-05 (+34d) | 2014-02-28 → 2014-04-01 (+32d) |  |  | 301d → 279d | 9-140M FS+23d → 9-140M FS+45d |  |
| 24368495 | Adjust Compton Elevation (Notebook) | 2013-12-17 → 2013-12-16 (-1d) | 2014-01-23 → 2014-01-22 (-1d) |  |  | 474d → 475d |  |  |
| 24368085M | Shield House Concrete Work Complete |  |  |  |  |  | 24368070a, 24368080, 24368070b, 24368070 → 24368070, 24368080 |  |
| 24368090 | Install Boron & Lead Shielding | 2014-01-02 → 2013-12-18 (-15d) | 2014-02-04 → 2014-01-30 (-5d) |  |  | 186d → 189d |  |  |
| 24368075 | Re-Establish Hall-C Alignment Network After SHMS Assy | 2013-11-04 → 2014-01-02 (+59d) | 2013-11-08 → 2014-01-06 (+59d) | 5d → 3d |  | 242d → 211d | 24368070b FS-18d, 24368070 FS-18d, 24368070a FS-18d → 24368070 FS+15d |  |
| 24368175 | Install Cryo Boom Support | 2013-12-02 → 2014-01-02 (+31d) |  | 27d → 12d |  |  | 24368170 FS+42d → 24368170 FS+57d |  |
| 24368015M | Cryogens Available from ESR or CHL | 2013-10-01 → 2014-01-03 (+94d) | 2013-10-01 → 2014-01-03 (+94d) |  |  | 309d → 251d | 9-140M → 9-140M FS+60d |  |
| 24368020 | Cool Down HMS Dipole | 2013-10-01 → 2014-01-03 (+94d) | 2013-10-07 → 2014-01-09 (+94d) |  |  | 309d → 251d |  |  |
| 24368115 | Install LCW for Supprt Struct | 2013-11-04 → 2014-01-06 (+63d) |  | 74d → 39d |  |  | 24368070 FS-18d, 24368070b FS-18d, 24368070a FS-18d → 24368070 FS+17d |  |
| 24368025 | Cool Down HMS Q1 | 2013-10-08 → 2014-01-10 (+94d) | 2013-10-15 → 2014-01-17 (+94d) |  |  | 309d → 251d |  |  |
| 24368195 | Prepare LCW for SHMS DCPS Testing | 2013-10-08 → 2014-01-10 (+94d) | 2013-10-15 → 2014-01-17 (+94d) |  |  | 321d → 263d |  |  |
| 24368200 | Prepare AC Power for SHMS DCPS Testing | 2013-10-08 → 2014-01-10 (+94d) | 2013-10-15 → 2014-01-17 (+94d) |  |  | 321d → 263d |  |  |
| 24368030 | Cool Down HMS Q2 | 2013-10-16 → 2014-01-21 (+97d) | 2013-10-29 → 2014-02-03 (+97d) |  |  | 309d → 251d |  |  |
| 24368205 | Connect HMS Q1 to SHMS DCPS #1 | 2013-10-16 → 2014-01-21 (+97d) | 2013-10-17 → 2014-01-22 (+97d) |  |  | 319d → 261d |  |  |
| 24368210 | Test Power Supply DCPS #1 | 2013-10-18 → 2014-01-23 (+97d) | 2013-10-22 → 2014-01-27 (+97d) |  |  | 319d → 261d |  |  |
| 24368500 | Install Beam Line upstream of Target (6GeV) | 2014-01-24 → 2014-01-23 (-1d) | 2014-01-24 → 2014-01-23 (-1d) |  |  | 536d → 537d |  |  |
| 24368215 | Connect HMS Q1 to SHMS DCPS #2 | 2013-10-23 → 2014-01-28 (+97d) | 2013-10-24 → 2014-01-29 (+97d) |  |  | 319d → 261d |  |  |
| 24368130 | Install Fire Protection & Detection Sys of Supprt Struct | 2014-02-03 → 2014-01-30 (-4d) | 2014-03-03 → 2014-02-27 (-4d) |  |  | 256d → 258d |  |  |
| 24368220 | Test Power Supply DCPS #2 | 2013-10-25 → 2014-01-30 (+97d) | 2013-10-29 → 2014-02-03 (+97d) |  |  | 319d → 261d |  |  |
| 24368095 | Install Doors in Shield House | 2014-02-05 → 2014-01-31 (-5d) | 2014-02-11 → 2014-02-06 (-5d) |  |  | 186d → 189d | 24363037, 24363036, 24368090, 24363035, 24363037a, 24363037b → 24368090, 24363035, 24363036, 24363037b, 24363037 |  |
| 24368122 | Install AC Pwr for Supprt Struct | 2014-02-04 → 2014-01-31 (-4d) | 2014-03-10 → 2014-03-06 (-4d) |  |  | 251d → 253d | 9-140M FS+79d, 24368070a FS-18d, 24368070b FS-18d, 24368070 FS-18d → 9-140M FS+79d, 24368070 FS-18d |  |
| 24368140 | Install Cable Tray & Conduits (SHIELD HOUSE) | 2014-02-05 → 2014-01-31 (-5d) | 2014-03-11 → 2014-03-06 (-5d) |  |  | 196d → 199d | 24368090, 24363036, 24363035, 24363037, 24363037a, 24363037b → 24363037, 24368090, 24363036, 24363035 |  |
| 24368045 | Procure SHMS Steel Platforms and Stairs (Box O Parts) Part B | 2013-10-01 → 2014-02-03 (+125d) | 2014-02-13 → 2014-03-04 (+19d) | 87d → 22d |  | 255d → 242d | 9-140M → 9-140M FS+80d |  |
| 24368035 | Cool Down HMS Q3 | 2013-10-30 → 2014-02-04 (+97d) | 2013-11-12 → 2014-02-17 (+97d) |  |  | 309d → 251d |  |  |
| 24368097 | Establish Alignment Network inside SHMS Shield House | 2014-02-12 → 2014-02-07 (-5d) | 2014-02-18 → 2014-02-13 (-5d) |  |  | 186d → 189d |  |  |
| 24368100 | Install and Align Detector Frames for DC and Rear Detectors | 2014-02-19 → 2014-02-14 (-5d) | 2014-02-25 → 2014-02-20 (-5d) |  |  | 186d → 189d |  |  |
| 24368505 | Install, Align, Leak-check Upstream Beam-Pipes & Girders (6GEV) | 2014-02-03 → 2014-02-17 (+14d) | 2014-02-07 → 2014-02-21 (+14d) |  |  | 468d → 458d |  |  |
| 24368225 | Connect HMS Dipole to SHMS DCPS #3 | 2013-11-13 → 2014-02-18 (+97d) | 2013-11-14 → 2014-02-19 (+97d) |  |  | 309d → 251d |  |  |

| ID | Task | Start | Finish | Duration | Complete | Total float | Predecessors | Other |
| --- | --- | --- | --- | --- | --- | --- | --- | --- |
| 24368230 | Test Power Supply DCPS #3 | 2013-11-15 → 2014-02-20 (+97d) | 2013-11-19 → 2014-02-24 (+97d) |  |  | 309d → 251d |  |  |
| 24368105 | Fab Raised Floor (SHIELD HOUSE) | 2014-02-26 → 2014-02-21 (-5d) | 2014-03-25 → 2014-03-20 (-5d) |  |  | 186d → 189d |  |  |
| 24368235 | Connect HMS Dipole to SHMS DCPS #4 | 2013-11-20 → 2014-02-25 (+97d) | 2013-11-21 → 2014-02-26 (+97d) |  |  | 309d → 251d |  |  |
| 24368240 | Test Power Supply DCPS #4 | 2013-11-22 → 2014-02-27 (+97d) | 2013-11-26 → 2014-03-03 (+97d) |  |  | 309d → 251d |  |  |
| 24368055 | Install SHMS Steel Platforms and Stairs | 2014-02-12 → 2014-03-03 (+19d) | 2014-03-04 → 2014-03-21 (+17d) |  |  | 255d → 242d | 24368040 FS-2d, 24368070b, 24368045 FS-2d, 24368070a, 24368070 → 24368045 FS-2d, 24368070, 24368040 FS-2d |  |
| 24368245 | Connect HMS Dipole to SHMS DCPS #5 | 2013-11-27 → 2014-03-04 (+97d) | 2013-12-02 → 2014-03-05 (+93d) |  |  | 309d → 251d |  |  |
| 24368250 | Test Power Supply DCPS #5 | 2013-12-03 → 2014-03-06 (+93d) | 2013-12-05 → 2014-03-10 (+95d) |  |  | 309d → 251d |  |  |
| 24368155 | Install Cables & Produce Final Drawings (CABLING) | 2014-03-12 → 2014-03-07 (-5d) | 2014-10-30 → 2014-10-27 (-3d) |  |  | 200d → 203d |  | resources ELEC ENG [120 h]; SUPPLIES & MATERIALS; MECH ENG [120 h]; MECH TECH [1680 h]; MECH DES [160 h] → MECH TECH [1680 h]; MECH DES [160 h]; ELEC ENG [120 h]; SUPPLIES & MATERIALS; MECH ENG [120 h] |
| 24368265 | Connect Mag Pwr Supplies & instrument Controls | 2014-03-14 → 2014-03-18 (+4d) | 2014-05-30 → 2014-06-03 (+4d) |  |  | 246d → 244d | 24342055, 24315036a5 FS-13d, 24315037ba, 24368135 FS-34d, 24315037b → 24368135 FS-34d, 24315037b, 24315036a5 FS-13d, 24342055 | resources MECH TECH [1000 h]; ELEC ENG [40 h]; PROCUREMENT<$50K 60; MECH ENG [520 h] → ELEC ENG [40 h]; PROCUREMENT<$50K 60; MECH ENG [520 h]; MECH TECH [1000 h] |
| 24368150 | Install Shield House Electrical Pwr (SHIELD HOUSE) | 2014-03-26 → 2014-03-21 (-5d) | 2014-07-17 → 2014-07-14 (-3d) |  |  | 186d → 189d |  |  |
| 24368185 | Construct & Connect Cryogenic Lines |  |  |  |  |  | 24368180, 24364075, 24368175, 24364065, 24364043, 24368070, 24364043a, 24368070b, 24368070a, 24364016 → 24364016, 24368070, 24364075, 24364043a, 24368175, 24364065, 24364043, 24368180 |  |
| 24368135 | Install Mag Pwr Supplies & Utilities on Platform | 2014-03-11 → 2014-03-24 (+13d) | 2014-04-21 → 2014-05-02 (+11d) |  |  | 252d → 243d |  |  |
| 24368255 | Pre-Align Magnet Stand Locations | 2014-03-05 → 2014-03-24 (+19d) | 2014-03-06 → 2014-03-25 (+19d) |  |  | 293d → 280d |  |  |
| 24368260 | Pre-Align, Install and Assemble Lower Iron Yokes and HB, Q1 Stands | 2014-03-07 → 2014-03-26 (+19d) | 2014-03-13 → 2014-04-01 (+19d) |  |  | 293d → 280d |  |  |
| 24368400 | Stack Calorimeter Blocks (SHOWER COUNTER) | 2014-03-05 → 2014-04-02 (+28d) | 2014-04-29 → 2014-05-28 (+29d) |  |  | 299d → 279d |  |  |
| 24368475 | Beam-Dump Modifications & Upgrades (6GEV) | 2014-03-03 → 2014-04-02 (+30d) | 2014-04-11 → 2014-05-13 (+32d) |  |  | 423d → 401d |  |  |
| 24368270 | Prep for Review of Hot Check-out & Mag Control systems | 2014-04-18 → 2014-04-22 (+4d) | 2014-05-30 → 2014-06-03 (+4d) |  |  | 246d → 244d |  |  |
| 24368460 | Install Moeller Quad #2 (6GEV) | 2014-05-14 → 2014-05-13 (-1d) | 2014-05-14 → 2014-05-13 (-1d) |  |  | 474d → 475d |  |  |
| 24368405 | Connect PMTs & Cables (SHOWER COUNTER) | 2014-04-30 → 2014-05-29 (+29d) | 2014-06-25 → 2014-07-24 (+29d) |  |  | 299d → 279d |  |  |
| 24368275M | Comp safety Review of Hot Chkout procedures & Mag control systems | 2014-05-30 → 2014-06-03 (+4d) | 2014-05-30 → 2014-06-03 (+4d) |  |  | 246d → 244d |  |  |
| 24368280 | Perform Hot Check-out of Mag Pwr Supplies | 2014-06-02 → 2014-06-04 (+2d) | 2014-10-31 → 2014-11-04 (+4d) |  |  | 246d → 244d |  |  |
| 24368485 | Connect Additional Quad for Moeller polarimeter | 2014-06-13 → 2014-06-12 (-1d) | 2014-08-14 → 2014-08-13 (-1d) |  |  | 474d → 475d |  |  |
| 24368160 | Install Fire Protection and Flamm Gas det. (SHIELD HOUSE) | 2014-06-19 → 2014-06-16 (-3d) | 2014-07-17 → 2014-07-14 (-3d) |  |  | 186d → 189d |  |  |
| 24368165 | Install Shield House HVAC (SHIELD HOUSE) | 2014-07-11 → 2014-07-08 (-3d) | 2014-07-17 → 2014-07-14 (-3d) |  |  | 186d → 189d |  |  |
| 24368415 | Install and Prep Electronics Room DAQ Racks (SHIELD HOUSE) | 2014-07-18 → 2014-07-15 (-3d) | 2014-08-14 → 2014-08-11 (-3d) |  |  | 186d → 189d |  |  |
| 24368285M | Receive First Mag from vendor | 2014-07-01 → 2014-07-16 (+15d) | 2014-07-01 → 2014-07-16 (+15d) |  |  | 217d → 207d |  |  |
| 24368290 | Mount Q1 on Supprt Carriage | 2014-07-01 → 2014-07-16 (+15d) | 2014-07-08 → 2014-07-22 (+14d) |  |  | 273d → 263d | 24315036a5 FS-13d, 24315037ba FS+1d, 24312053M, 24315037b FS+1d → 24315037b FS+1d, 24312053M, 24315036a5 FS-13d |  |
| 24368410 | Test Calorimeter (SHOWER COUNTER) | 2014-06-26 → 2014-07-25 (+29d) | 2014-08-18 → 2014-09-16 (+29d) |  |  | 299d → 279d |  |  |
| 24368145 | Install Drift Gas Manifold | 2014-08-01 → 2014-07-31 (-1d) | 2014-09-12 → 2014-09-11 (-1d) |  |  | 281d → 282d |  |  |
| 24368570 | Install Rotation Controls of Supprt Struct | 2014-08-15 → 2014-08-12 (-3d) | 2014-09-12 → 2014-09-09 (-3d) |  |  | 316d → 319d |  |  |
| 24368295 | Mount HB on Supprt Carriage | 2014-08-26 → 2014-09-23 (+28d) | 2014-09-02 → 2014-09-29 (+27d) |  |  | 269d → 250d | 28231005, 24368290 → 24368290, 28231005, 2-28M |  |
| 24368300 | Fiducialize Magnet CL of SHMS Q1 Magnet | 2014-08-26 → 2014-09-23 (+28d) | 2014-08-26 → 2014-09-23 (+28d) |  |  | 293d → 274d |  |  |
| 24368470 | Install Windows & Flanges | 2014-10-02 → 2014-10-29 (+27d) | 2014-11-12 → 2014-12-11 (+29d) |  |  | 323d → 304d |  |  |
| 24368510 | Install Target Scattering Chamber (6GEV) |  |  |  |  |  | 24354022, 24354030b, 9-140M FS+308d → 24354022, 24354030b, 9-155M FS+63d |  |
| 24368520 | Prep for Vac & pressure systems Safety Review |  |  |  |  |  | 9-140M FS+310d → 9-155M FS+65d |  |
| 24368560 | Install & Align SHMS Angle Scribe Plates |  |  |  |  |  | 24368070, 24368070b, 24368555, 24368070a → 24368555, 24368070b, 24368070 |  |
| 24368305 | Final Assemble & Mount Dipole on Supprt Carriage |  |  |  |  |  | 24368070b, 24368260, 24368070a, 24368097, 24368255, 24314050M, 24368070, 24368100, 24368285M → 24368260, 24368285M, 24314050M, 24368255, 24368097, 24368100, 24368070 |  |
| 24368310 | Install & Connect Magnet Insulating Vac system |  |  |  |  |  | 24365020b, 24365025, 24365020, 24368525M, 24365020a, 24368305 FS-20d → 24365025, 24365020, 24368525M, 24368305 FS-20d |  |
| 24368340 | Mount Q2 on Supprt Carriage |  |  |  |  |  | 24314035a FS-34d, 24315037ba FS+1d, 24368350 FS-34d, 24314035 FS-34d, 2-30M, 28236005 FS-34d, 24315037b FS+1d → 2-30M, 24314035 FS-34d, 28236005 FS-34d, 24315037b FS+1d, 24314035a FS-34d, 24368350 FS-34d |  |
| 24368370 | Mount Q3 on Supprt Carriage |  |  |  |  |  | 28236010, 2-31M, 24315037ba FS+1d, 24315037b FS+1d, 24368340 → 24368340, 28236010, 2-31M, 24315037b FS+1d |  |
| 24368390 | Finucialize Magnet CL of SHMS Q3 Magnet |  |  |  |  |  |  | resources MECH DES [8 h]; MECH TECH [32 h] → MECH TECH [32 h]; MECH DES [8 h] |
| 5 | **1.5 CONSTRUCTION HALL D** | 2008-10-01 → 2008-11-06 (+36d) |  |  |  |  |  |  |
| 1 | **1.5.1 SOLENOID** | 2008-10-01 → 2009-01-02 (+93d) | 2013-09-30 → 2013-10-21 (+21d) |  |  |  |  |  |
| 151009E | FY09 Travel (SOLENOID) | 2009-01-02 A | 2009-09-30 A |  | 0% → 100% | 431d → none |  |  |
| 151000 | Ship Iron to contractor (SOLENOID) | 2008-10-01 → 2009-01-05 A (+96d) | 2008-10-14 → 2009-01-12 A (+90d) | 10d → 6d | 0% → 100% | 925d → none |  |  |
| 151001 | Modify Iron Pole (SOLENOID) | 2008-10-15 → 2009-01-05 A (+82d) | 2008-12-11 → 2009-01-12 A (+32d) | 40d → 6d | 0% → 100% | 925d → none |  |  |
| 151002 | Ship Iron to Jlab (SOLENOID) | 2008-12-12 → 2009-01-05 A (+24d) | 2009-01-02 → 2009-01-12 A (+10d) | 10d → 6d | 0% → 100% | 925d → none |  |  |
| 151015 | Dsgn Ring Girders (SOLENOID) | 2010-01-05 → 2009-03-16 A (-295d) | 2010-03-03 → 2010-05-24 A (+82d) | 40d → 298d | 0% → 100% | 637d → none |  | resources MECH ENG [120 h]; MECH DES [320 h] → MECH DES [320 h]; MECH ENG [120 h] |
| 151023 | Design Iron Spacers (SOLENOID) | 2010-01-05 → 2009-03-16 A (-295d) | 2010-03-03 → 2009-08-17 A (-198d) | 40d → 109d | 0% → 100% | 517d → none |  |  |
| 151000c | Design Test Platform (SOLENOID) | 2009-06-01 → 2009-06-15 A (+14d) | 2009-09-01 → 2009-09-24 A (+23d) | 66d → 72d | 0% → 100% | 402d → none |  |  |
| 151030 | Dsgn Missing Mounts (SOLENOID) | 2010-01-05 → 2009-06-15 A (-204d) | 2010-02-02 → 2009-09-11 A (-144d) | 20d → 63d | 0% → 100% | 537d → none |  | resources MECH ENG [20 h]; MECH DES [120 h] → MECH DES [120 h]; MECH ENG [20 h] |
| 151000a | Labr/Exp to Proc/Assy/Test Rack for Coil Control + 1 Module (SOLENOIID) FY09 | 2009-06-01 → 2009-07-20 A (+49d) | 2009-09-30 → 2010-09-29 A (+364d) | 86d → 299d | 0% → 100% | 383d → none |  | resources COMP SCIENT [196.57 h]; ELEC TECH [196.57 h]; ELEC ENG [73.71 h]; SUPPLIES & MATERIALS → SUPPLIES & MATERIALS; COMP SCIENT [196.57 h]; ELEC ENG [73.71 h]; ELEC TECH [196.57 h] |
| 151000d | Design Yoke Baffles (SOLENOID) | 2009-07-01 → 2009-07-20 A (+19d) | 2009-09-30 → 2010-06-21 A (+264d) | 64d → 229d | 0% → 100% | 382d → none |  |  |
| 151000e | Write Controls for Solenoid (SOLENOID) | 2009-06-01 → 2009-07-20 A (+49d) | 2009-09-29 → 2010-07-26 A (+300d) | 85d → 253d | 0% → 100% | 383d → none |  |  |
| 151000b | Procure Rack for Coil Control + 1 Module Set for 1 Coil (SOLENOIID) | 2009-07-14 → 2009-07-27 A (+13d) | 2009-10-06 → 2010-06-21 A (+258d) | 60d → 224d | 0% → 100% | 383d → none |  |  |
| 151025 | Fab Iron Spacers (SOLENOID) | 2010-03-04 → 2009-09-04 A (-181d) | 2010-08-20 → 2011-07-25 A (+339d) | 120d → 466d | 0% → 100% | 517d → none |  |  |
| 151000f | Prepare Procurements/Fabrication Packages 2010 (SOLENOID) | 2009-10-01 → 2009-09-14 A (-17d) | 2010-01-04 → 2011-04-29 A (+480d) | 60d → 402d | 0% → 100% | 382d → none |  | resources MECH ENG [200 h]; MECH DES [560 h] → MECH DES [560 h]; MECH ENG [200 h] |
| 151033 | Fabricate Missing Mounts (SOLENOID) | 2010-02-03 → 2009-09-14 A (-142d) | 2010-03-31 → 2009-11-23 A (-128d) | 40d → 51d | 0% → 100% | 537d → none |  | resources MECH ENG [40 h]; PROCUREMENT>$50K 69 → PROCUREMENT>$50K 69; MECH ENG [40 h] |
| 151000aB | Labr/Exp to Proc/Assy/Test Rack for Coil Control + 1 Module (SOLENOIID) FY10 | 2009-10-01 → 2009-09-30 A (-1d) | 2009-12-17 → 2010-09-29 A (+286d) | 54d → 248d | 0% → 100% | 383d → none |  | resources ELEC ENG [46.29 h]; ELEC TECH [123.43 h]; SUPPLIES & MATERIALS; COMP SCIENT [123.43 h] → SUPPLIES & MATERIALS; COMP SCIENT [123.43 h]; ELEC ENG [46.29 h]; ELEC TECH [123.43 h] |
| 151010E | FY10 Travel (SOLENOID) | 2009-10-01 A | 2010-09-30 A |  | 0% → 100% | 431d → none |  |  |
| 151040 | Fab Stands (SOLENOID) | 2010-01-05 → 2009-10-30 A (-67d) | 2010-04-28 → 2010-08-30 A (+124d) | 80d → 205d | 0% → 100% | 597d → none |  | resources MECH TECH [40 h]; PROCUREMENT<$50K 60; MECH ENG [40 h] → MECH ENG [40 h]; MECH TECH [40 h]; PROCUREMENT<$50K 60 |
| 151020 | Control Cabling fab (SOLENOID) | 2009-10-01 → 2010-01-11 A (+102d) | 2010-01-04 → 2010-05-24 A (+140d) | 60d → 94d | 0% → 100% | 517d → none |  | resources MECH ENG [20 h]; PROCUREMENT<$50K 60; MECH TECH [160 h]; MECH DES [20 h] → MECH DES [20 h]; MECH ENG [20 h]; PROCUREMENT<$50K 60; MECH TECH [160 h] |
| 151000g | Evaluate Procurements 2010 (SOLENOID) | 2010-02-02 → 2010-01-25 A (-8d) | 2010-04-02 → 2010-06-21 A (+80d) | 43d → 104d | 0% → 100% | 382d → none | 151000f FS+19d → 151000f FS-100d |  |
| 151000h | Track Fabrication 2010 (SOLENOID) | 2010-05-03 → 2010-04-19 A (-14d) | 2010-08-04 → 2010-06-28 A (-37d) | 66d → 50d | 0% → 100% | 382d → none |  |  |
| 151000j | Labor for Procurmnt Prep of 3 Module Sets for 3 Coils (SOLENOID) | 2010-12-14 → 2010-05-24 A (-204d) | 2011-01-04 → 2010-09-30 A (-96d) | 10d → 91d | 0% → 100% | 309d → none |  |  |
| 151000k | Procurmnt of 3 Module Sets for 3 Coils / Controls (SOLENOID) Part A | 2011-01-05 → 2010-05-24 A (-226d) | 2011-04-07 → 2012-10-15 A (+557d) | 65d → 597d | 0% → 100% | 309d → none | 151000j → 151000j FS-240d | was named Procurmnt of 3 Module Sets for 3 Coils (SOLENOID) Part A |
| 151000i | Acceptance Checks/Documentation 2010 (SOLENOID) | 2010-05-28 → 2010-06-21 A (+24d) | 2010-08-27 → 2010-09-30 A (+34d) | 64d → 72d | 0% → 100% | 382d → none |  |  |
| 151011E | FY11 Travel (SOLENOID) | 2010-10-01 A | 2011-09-30 A |  | 0% → 100% | 431d → none |  |  |
| 151171 | Prepare Procurement Packages for Cladding | 2011-01-04 → 2011-04-02 A (+88d) | 2011-04-01 → 2011-09-26 A (+178d) | 62d → 123d | 0% → 100% | 208d → none |  | was named Prpare Procurement Packages for Cladding |
| 151050 | Move Solenoid to H-D (SOLENOID) | 2011-10-03 → 2011-04-11 A (-175d) | 2011-10-21 → 2011-10-17 A (-4d) | 15d → 133d | 0% → 100% | 241d → none | 151030, 151015, 16331032, 151025, 3P-23M, 16331030, 151035, 151020, 151040, 151002, 151045 FS+1d → 151025 FS-120d, 151015, 151045 FS-110d, 151020, 16331032, 16331030, 151040, 151002, 151030, 151035 FS-110d, 3P-23M FS-35d | was named Move Solenoid to H-D (SOLENOID) (IPL 551360) |

| ID | Task | Start | Finish | Duration | Complete | Total float | Predecessors | Other |
| --- | --- | --- | --- | --- | --- | --- | --- | --- |
| 151035 | Fab Ring Girders (SOLENOID) | 2010-04-01 → 2011-06-01 A (+426d) | 2010-07-23 → 2011-09-19 A (+423d) | 80d → 77d | 0% → 100% | 537d → none |  | resources PROCUREMENT<$50K 60; MECH DES [40 h]; MECH ENG [20 h] → MECH ENG [20 h]; MECH DES [40 h]; PROCUREMENT<$50K 60 |
| 151045 | Set Up Solenoid Test Area (SOLENOID) | 2011-08-30 → 2011-06-30 A (-61d) | 2011-09-29 → 2011-10-17 A (+18d) | 22d → 76d | 0% → 100% | 112d → none | 9-110M FS+225d, 2-16M, 2-10M FS+12d → 2-10M, 2-16M, 9-110M | was named Set Up Solenoid Test Area (SOLENOID) (IPL 551400LOE); resources MECH DES [320 h]; MECH ENG [240 h]; MECH TECH [480 h]; PROCUREMENT<$50K 60 → MECH TECH [480 h]; PROCUREMENT<$50K 60; MECH DES [320 h]; MECH ENG [240 h] |
| 151085 | Install Yoke mounts (SOLENOID) | 2011-10-03 → 2011-09-01 A (-32d) | 2011-10-21 → 2011-09-19 A (-32d) | 15d → 12d | 0% → 100% | 148d → none | 151045 FS+1d → 151045 FS-30d |  |
| 151147 | Safety Review (SOLENOID) | 2011-10-03 → 2011-09-01 A (-32d) | 2011-11-21 → 2011-10-28 A (-24d) | 36d → 41d | 0% → 100% | 149d → none | 151045 FS+1d → 151045 FS-20d |  |
| 151160 | Install US Pole (SOLENOID) | 2011-10-12 → 2011-09-10 A (-32d) | 2011-10-14 → 2011-09-26 A (-18d) | 3d → 11d | 0% → 100% | 148d → none | 151060 FS-8d, 151085 FS-8d → 151085 FS-8d, 151060 FS-30d | resources MECH DES [12 h]; MECH ENG [16 h]; PROCUREMENT<$50K 60; MECH TECH [40 h] → MECH TECH [40 h]; MECH DES [12 h]; MECH ENG [16 h]; PROCUREMENT<$50K 60 |
| 151090 | Install Yoke 1 (SOLENOID) | 2011-10-17 → 2011-09-12 A (-35d) | 2011-10-21 → 2011-09-19 A (-32d) | 5d → 6d | 0% → 100% | 148d → none |  | resources MECH DES [12 h]; MECH TECH [16 h]; PROCUREMENT<$50K 60; MECH ENG [8 h] → MECH ENG [8 h]; MECH DES [12 h]; MECH TECH [16 h]; PROCUREMENT<$50K 60 |
| 151060 | Install Solenoid Stands (SOLENOID) | 2011-10-03 → 2011-09-19 A (-14d) | 2011-10-21 → 2011-10-24 A (+3d) | 15d → 26d | 0% → 100% | 148d → none | 151045 FS+1d → 151045 FS-20d |  |
| 151095 | Install Coil 1 (SOLENOID) | 2011-10-24 → 2011-09-19 A (-35d) | 2011-10-26 → 2011-09-26 A (-30d) | 3d → 6d | 0% → 100% | 148d → none |  | resources MECH ENG [8 h]; MECH TECH [16 h]; PROCUREMENT<$50K 60 → MECH TECH [16 h]; MECH ENG [8 h]; PROCUREMENT<$50K 60 |
| 151100 | Install Iron Spacer/Ring Girder 1 (SOLENOID) | 2011-10-27 → 2011-09-19 A (-38d) | 2011-10-28 → 2011-09-26 A (-32d) | 2d → 6d | 0% → 100% | 148d → none |  | resources MECH TECH [32 h]; PROCUREMENT<$50K 60; MECH ENG [16 h] → MECH ENG [16 h]; MECH TECH [32 h]; PROCUREMENT<$50K 60 |
| 151105 | Install Yoke 2 (SOLENOID) | 2011-10-31 → 2011-10-10 A (-21d) | 2011-11-01 → 2011-10-11 A (-21d) |  | 0% → 100% | 148d → none | 151100 → 151100 FS-10d | resources MECH DES [12 h]; MECH ENG [8 h]; MECH TECH [16 h]; PROCUREMENT>$50K 69 → MECH ENG [8 h]; PROCUREMENT>$50K 69; MECH DES [12 h]; MECH TECH [16 h] |
| 151110 | Install Coil 2 (SOLENOID) | 2011-11-02 → 2011-10-17 A (-16d) | 2011-11-02 → 2011-10-18 A (-15d) | 1d → 2d | 0% → 100% | 148d → none |  | resources MECH TECH [16 h]; PROCUREMENT>$50K 69; MECH ENG [8 h] → MECH ENG [8 h]; MECH TECH [16 h]; PROCUREMENT>$50K 69 |
| 151145 | Install Iron Spacer/Ring Girder 4 (SOLENOID) | 2011-11-21 → 2011-10-22 A (-30d) | 2011-11-22 → 2011-10-27 A (-26d) | 2d → 4d | 0% → 100% | 148d → none |  |  |
| 151115 | Install Iron Spacer/Ring Girder 2 (SOLENOID) | 2011-11-03 → 2011-10-24 A (-10d) | 2011-11-04 → 2011-10-25 A (-10d) |  | 0% → 100% | 148d → none |  |  |
| 151130 | Install Iron Spacer/Ring Girder 3 (SOLENOID) | 2011-11-10 → 2011-10-24 A (-17d) | 2011-11-11 → 2011-10-27 A (-15d) | 2d → 4d | 0% → 100% | 148d → none |  | resources PROCUREMENT>$50K 69; MECH ENG [16 h]; MECH TECH [32 h] → MECH ENG [16 h]; MECH TECH [32 h]; PROCUREMENT>$50K 69 |
| 151140 | Install Coil 4 (SOLENOID) | 2011-11-16 → 2011-10-24 A (-23d) | 2011-11-18 → 2011-10-25 A (-24d) | 3d → 2d | 0% → 100% | 148d → none |  | resources MECH TECH [16 h]; PROCUREMENT>$50K 69; MECH ENG [8 h] → PROCUREMENT>$50K 69; MECH ENG [8 h]; MECH TECH [16 h] |
| 151120 | Install Yoke 3 (SOLENOID) | 2011-11-07 → 2011-10-25 A (-13d) | 2011-11-08 → 2011-10-26 A (-13d) |  | 0% → 100% | 148d → none |  | resources PROCUREMENT>$50K 69; MECH ENG [8 h]; MECH TECH [16 h]; MECH DES [12 h] → MECH TECH [16 h]; MECH DES [12 h]; PROCUREMENT>$50K 69; MECH ENG [8 h] |
| 151125 | Install Coil 3 (SOLENOID) | 2011-11-09 → 2011-10-25 A (-15d) | 2011-11-09 → 2011-10-27 A (-13d) | 1d → 3d | 0% → 100% | 148d → none |  |  |
| 151170 | Install DS Pole (SOLENOID) | 2011-11-23 → 2011-10-26 A (-28d) | 2011-11-23 → 2011-10-28 A (-26d) | 1d → 3d | 0% → 100% | 148d → none |  | was named Install DS Pole (SOLENOID) (IPL) |
| 151135 | Install Yoke 4 (SOLENOID) | 2011-11-14 → 2011-10-27 A (-18d) | 2011-11-15 → 2011-10-29 A (-17d) |  | 0% → 100% | 148d → none |  | resources MECH DES [12 h]; MECH ENG [8 h]; MECH TECH [16 h]; PROCUREMENT>$50K 69 → MECH TECH [16 h]; MECH DES [12 h]; MECH ENG [8 h]; PROCUREMENT>$50K 69 |
| 151150 | Elect Test Coils (SOLENOID) | 2011-11-28 → 2011-11-14 A (-14d) | 2011-12-02 → 2011-11-21 A (-11d) | 5d → 6d | 0% → 100% | 148d → none | 151000ka, 151000k, 151170, 151147 → 151000ka FS-150d, 151000k FS-150d, 151170, 151147 | resources PROCUREMENT<$50K 60; MECH ENG [8 h]; MECH TECH [120 h] → MECH ENG [8 h]; MECH TECH [120 h]; PROCUREMENT<$50K 60 |
| 151155 | Leak Test Coils (SOLENOID) | 2011-12-05 → 2011-11-21 A (-14d) | 2011-12-16 → 2012-02-13 A (+59d) | 10d → 52d | 0% → 100% | 148d → none | 151150 → 151150 FS-100d |  |
| 151070 | Install DC Buswork (SOLENOID) | 2012-05-04 → 2011-12-19 A (-137d) | 2012-06-01 → 2013-01-07 A (+220d) | 20d → 257d | 0% → 100% | 112d → none | 151055 FS+44d, 151050, 151065 FS+44d → 151050, 151055 FS-60d, 151065 FS-80d |  |
| 151171a | Procure Cladding | 2011-11-01 → 2012-01-16 A (+76d) | 2012-03-30 → 2012-06-11 A (+73d) | 99d → 102d | 0% → 100% | 60d → none | 151171, 9-120M FS+21d → 151171 FS+10d, 9-120M FS+41d |  |
| 151173 | Develop cryo/magnet elect/pipe interface | 2012-02-03 → 2012-02-01 A (-2d) | 2012-04-05 → 2012-09-17 A (+165d) | 44d → 160d | 0% → 100% | 190d → none |  |  |
| 151173a | Procure elec/piping interface hardware Part A | 2012-02-03 → 2012-02-01 A (-2d) | 2012-06-29 → 2012-10-15 A (+108d) | 103d → 180d | 0% → 100% | 190d → none | 151173 FS-44d → 151173 FS-70d |  |
| 151173c | Develop solenoid vacuum manifold | 2012-02-06 → 2012-02-01 A (-5d) | 2012-05-03 → 2012-07-16 A (+74d) | 63d → 116d | 0% → 100% | 217d → none |  | resources MECH ENG [102 h]; MECH DES [170 h] → MECH DES [170 h]; MECH ENG [102 h] |
| 151173g | FMEA for solenoid | 2012-02-06 → 2012-02-01 A (-5d) | 2012-02-22 → 2012-08-13 A (+173d) | 12d → 136d | 0% → 100% | 338d → none |  |  |
| 151173j | Develop shims and baffle support | 2012-02-03 → 2012-02-01 A (-2d) | 2012-04-23 → 2012-03-19 A (-35d) | 56d → 33d | 0% → 100% | 277d → none |  |  |
| 151173k | Procure shims and baffle support | 2012-03-06 → 2012-03-01 A (-5d) | 2012-05-31 → 2012-05-21 A (-10d) | 62d → 58d | 0% → 100% | 277d → none |  |  |
| 151055 | Install DC Sys (SOLENOID) | 2012-01-13 → 2012-03-03 A (+50d) | 2012-03-02 → 2012-09-17 A (+199d) | 34d → 138d | 0% → 100% | 112d → none | 151045 FS+67d → 151045 FS+110d | resources MECH ENG [40 h]; MECH TECH [320 h]; PROCUREMENT>$50K 69 → MECH TECH [320 h]; PROCUREMENT>$50K 69; MECH ENG [40 h] |
| 151173n | Install shims and baffle support | 2012-04-19 → 2012-03-19 A (-31d) | 2012-06-25 → 2012-05-21 A (-35d) |  | 0% → 100% | 277d → none | 151173k FS-30d → 151173k FS-45d |  |
| 151065 | Install Solenoid Controls (SOLENOID) | 2012-01-13 → 2012-05-07 A (+115d) | 2012-03-02 → 2012-12-17 A (+290d) | 34d → 165d | 0% → 100% | 112d → none | 151045 FS+67d → 151045 FS+47d, 9-120M FS+163d | was named Install Solenoid Controls (SOLENOID) (IPL); resources PROCUREMENT<$50K 60; MECH ENG [80 h]; MECH TECH [320 h] → MECH ENG [80 h]; MECH TECH [320 h]; PROCUREMENT<$50K 60 |
| 151080 | Install Controls Cabling (SOLENOID) | 2012-05-04 → 2012-06-05 A (+32d) | 2012-06-01 → 2012-08-20 A (+80d) | 20d → 55d | 0% → 100% | 112d → none | 151075 FS-20d → 151075 FS-40d |  |
| 151172 | Install Cladding (SOLENOID) | 2012-04-10 → 2012-06-11 A (+62d) | 2012-05-11 → 2012-07-16 A (+66d) | 24d → 26d | 0% → 100% | 60d → none |  | resources SUPPLIES & MATERIALS; MECH DES [2 h]; MECH ENG [2 h]; MECH TECH [480 h] → SUPPLIES & MATERIALS; MECH TECH [480 h]; MECH DES [2 h]; MECH ENG [2 h] |
| 151173d | Procure solenoid vacuum manifold Part A | 2012-03-05 → 2012-08-01 A (+149d) | 2012-06-29 → 2012-10-15 A (+108d) | 83d → 53d | 0% → 100% | 217d → none | 151173c FS-44d → 151173c |  |
| 151000ka | Procurmnt of 3 Module Sets for 3 Coils / Controls (SOLENOID) Part B | 2011-01-05 → 2012-10-01 A (+635d) | 2011-04-07 → 2013-01-31 A (+665d) | 65d → 86d | 0% → 100% | 309d → none | 151000j → 151000j FS-240d | was named Procurmnt of 3 Module Sets for 3 Coils (SOLENOID) Part B |
| 151173aa | Procure elec/piping interface hardware Part B | 2012-02-03 → 2012-10-01 A (+241d) | 2012-06-29 → 2012-12-17 A (+171d) | 103d → 54d | 0% → 100% | 190d → none | 151173 FS-44d → 151173 FS-70d |  |
| 151173d5 | Procure solenoid vacuum manifold Part B | 2012-03-05 → 2012-10-01 A (+210d) | 2012-06-29 → 2013-02-11 A (+227d) | 83d → 49d | 0% → 100% | 217d → none | 151173c FS-44d → 151173c |  |
| 151175 | Connect Coils (SOLENOID) | 2012-07-27 → 2012-10-15 A (+80d) | 2012-09-28 → 2012-11-19 A (+52d) | 45d → 26d | 0% → 100% | 8d → none | 151172, 13321070 FS-45d, 151170 → 151172, 151170, 13321070 | was named Connect Coils (SOLENOID) (IPL); resources PROCUREMENT<$50K 60; MECH ENG [40 h]; MECH TECH [320 h]; MECH DES [40 h] → MECH DES [40 h]; MECH TECH [320 h]; PROCUREMENT<$50K 60; MECH ENG [40 h] |
| 151173f | Install solenoid vacuum manifold | 2012-06-01 → 2012-11-12 A (+164d) | 2012-08-13 → 2013-08-30 A (+382d) | 51d → 34d | 0% → 100% | 217d → none |  |  |
| 151185 | Elect Test Solenoid (SOLENOID) | 2012-09-17 → 2012-11-12 A (+56d) | 2012-09-28 → 2012-11-19 A (+52d) | 10d → 23d | 0% → 100% | 8d → none |  |  |
| 151075 | Test DC Sys (SOLENOID) | 2012-05-04 → 2012-12-17 A (+227d) | 2012-06-01 → 2013-03-11 A (+283d) | 20d → 33d | 0% → 100% | 112d → none |  |  |
| 151255 | Re-Baseline Actuals Adjustment | 2013-08-30 A | 2013-08-30 A |  | 0% → 100% | 20d → none | 9-130M FS+227d → none |  |
| 151250M | Installtn of Solenoid Comptd (SOLENOID) | 2013-02-20 → 2013-08-30 A (+191d) | 2013-02-20 → 2013-08-30 A (+191d) |  | 0% → 100% | 91d → none |  |  |
| 251173f | Install solenoid vacuum manifold | 2013-09-03 A | 2013-09-16 A |  | 0% → 100% | 64d → none |  |  |
| 251195 | Repair Solenoid Vac Leaks | 2013-09-03 A | 2013-09-06 → 2013-09-09 A (+3d) |  | 0% → 100% | 0d → none |  |  |
| 251666 | Consultant Fee (Quench Study WS) | 2013-09-03 A | 2013-09-30 → 2013-10-21 A (+21d) |  | 0% → 100% | 247d → none |  |  |
| 251250M | Installtn of Solenoid Comptd (SOLENOID) | 2013-09-16 → 2013-09-09 A (-7d) | 2013-09-16 → 2013-09-09 A (-7d) |  | 0% → 100% | 64d → none |  |  |
| 2 | **1.5.2 DETECTORS** | 2008-12-01 → 2009-01-02 (+32d) |  |  |  |  |  |  |
| 15211009E | FY09 Travel (FWD Chambers) | 2009-01-02 A | 2009-09-30 A |  | 0% → 100% | 64d → none |  |  |
| 15211000a | Procurement for Testing the Assembly Proceedure (FWD Chambers) | 2009-06-01 → 2009-06-15 A (+14d) | 2009-08-31 → 2009-09-29 A (+29d) | 65d → 75d | 0% → 100% | 850d → none |  |  |
| 15211000b | Testing the Assembly Procedure (FWD Chambers) | 2009-06-01 → 2009-06-15 A (+14d) | 2009-09-30 → 2009-12-21 A (+82d) | 86d → 131d | 0% → 100% | 809d → none |  | resources MECH TECH [560 h]; ELEC TECH [160 h]; MECH ENG [160 h] → MECH ENG [160 h]; MECH TECH [560 h]; ELEC TECH [160 h] |
| 15211001a | Prepare Procurements/Fabrication Packages 2010 (FWD Chambers) | 2009-06-01 → 2009-07-03 A (+32d) | 2009-09-30 → 2010-09-30 A (+365d) | 86d → 310d | 0% → 100% | 755d → none |  |  |
| 15211002a | Engineering Support for Assembly FY10 (FWD Chambers) | 2010-01-05 → 2009-08-03 A (-155d) | 2010-09-30 A | 188d → 290d | 0% → 100% | 64d → none |  |  |
| 15211010E | FY10 Travel (FWD Chambers) | 2009-10-01 A | 2010-09-30 A |  | 0% → 100% | 146d → none |  |  |
| 15211025 | Proc Wire (Field, sense) (FWD Chambers) | 2010-01-05 → 2009-12-21 A (-15d) | 2010-07-09 → 2010-02-22 A (-137d) | 130d → 38d | 0% → 100% | 176d → none |  |  |
| 15211030 | Proc First Article On-Chamb Electrnc's (capacitors, resistors) (FWD Chambers) | 2010-01-05 → 2009-12-21 A (-15d) | 2010-05-28 → 2010-05-24 A (-4d) | 102d → 103d | 0% → 100% | 159d → none |  |  |
| 15211020 | ProcFirst Article PC Boards Cathode Kapton Foil (FWD Chambers) | 2010-01-05 → 2010-01-04 A (-1d) | 2010-05-28 → 2010-05-24 A (-4d) | 102d → 99d | 0% → 100% | 63d → none |  |  |
| 15211090 | Test Wire (Field, sense) (FWD Chambers) FY10 | 2010-07-12 → 2010-02-01 A (-161d) | 2010-09-30 → 2010-03-25 A (-189d) | 57.5d → 37.5d | 0% → 100% | 176d → none |  |  |
| 15211090a | Test Wire (Field, sense) (FWD Chambers) FY11 | 2010-09-30 → 2010-02-01 A (-241d) | 2010-10-22 → 2010-03-25 A (-211d) | 16.5d → 37.5d | 0% → 100% | 176d → none |  |  |
| 15211100 | Fab Setup (FWD Chambers) | 2010-01-05 → 2010-02-01 A (+27d) | 2010-06-10 → 2011-01-17 A (+221d) | 110d → 238d | 0% → 100% | 225.5d → none |  |  |
| 15211050 | Proc Cables,Connectors (HV, LV, Signal, Gas) (FWD Chambers) | 2011-01-05 → 2010-05-24 A (-226d) | 2011-07-11 → 2011-06-20 A (-21d) | 130d → 267d | 0% → 100% | 172d → none |  |  |
| 15211015 | Proc PC Boards (G10) (FWD Chambers) | 2010-05-14 → 2010-06-01 A (+18d) | 2010-09-20 → 2010-12-17 A (+88d) | 89d → 140d | 0% → 100% | 163.5d → none |  |  |
| 15211001c | Track Fabrication 2010 (FWD Chambers) | 2010-01-05 → 2010-06-07 A (+153d) | 2010-07-09 → 2010-06-14 A (-25d) | 130d → 6d | 0% → 100% | 745d → none |  |  |
| 15211001b | Evaluate Procurements 2010 (FWD Chambers) | 2009-12-18 → 2010-06-21 A (+185d) | 2010-01-04 → 2010-09-30 A (+269d) | 6d → 72d | 0% → 100% | 755d → none |  |  |
| 15211001d | Acceptance Checks/Documentation 2010 (FWD Chambers) | 2010-07-01 → 2010-07-19 A (+18d) | 2010-09-01 → 2010-09-30 A (+29d) | 44d → 53d | 0% → 100% | 709d → none |  |  |
| 15211030a | Proc Production On-Chamb Electrnc's (capacitors, resistors) (FWD Chambers) | 2010-05-14 → 2010-07-19 A (+66d) | 2010-11-16 → 2010-08-30 A (-78d) | 130d → 31d | 0% → 100% | 159d → none |  |  |
| 15211080 | Test PC Boards (G10) (FWD Chambers) FY10 | 2010-09-21 → 2010-07-26 A (-57d) | 2010-09-30 → 2010-12-17 A (+78d) | 7.5d → 101.5d | 0% → 100% | 163.5d → none |  |  |
| 15211080a | Test PC Boards (G10) (FWD Chambers) FY11 | 2010-09-30 → 2010-07-26 A (-66d) | 2010-11-10 → 2010-12-17 A (+37d) | 29d → 101.5d | 0% → 100% | 163.5d → none |  |  |
| 15211005 | Proc Chamb Frames (G10) (FWD Chambers) | 2010-05-14 → 2010-08-23 A (+101d) | 2010-11-23 → 2011-01-24 A (+62d) | 135d → 101d | 0% → 100% | 109.5d → none |  |  |

| ID | Task | Start | Finish | Duration | Complete | Total float | Predecessors | Other |
| --- | --- | --- | --- | --- | --- | --- | --- | --- |
| 15211002b | Engineering Support for Assembly FY11 (FWD Chambers) | 2010-10-01 A | 2011-09-30 A |  | 0% → 100% | 64d → none |  |  |
| 15211011E | FY11 Travel (FWD Chambers) | 2010-10-01 A | 2011-09-30 A |  | 0% → 100% | 146d → none |  |  |
| 15211020a | Proc Production PC Boards Cathode Kapton Foil (FWD Chambers) | 2010-05-14 → 2010-10-11 A (+150d) | 2010-11-16 → 2011-06-20 A (+216d) | 130d → 170d | 0% → 100% | 63d → none |  |  |
| 15211105 | Wire Chamb Frames Prep (FWD Chambers) | 2010-11-24 → 2010-11-15 A (-9d) | 2011-01-26 → 2011-01-17 A (-9d) | 36.5d → 37d | 0% → 100% | 109.5d → none | 15211100, 15211002a FS-55d, 15211005, 197111030M → 15211100 FS-30d, 15211002a FS-55d, 15211005, 197111030M FS-20d |  |
| 15211140 | G10 PC Board Prep (FWD Chambers) | 2010-11-10 → 2010-11-15 A (+5d) | 2011-01-11 → 2011-01-17 A (+6d) |  | 0% → 100% | 202d → none |  |  |
| 15211022 | Procuremnt of Rigid Flex Assemblies (FWD Chambers) | 2010-01-05 → 2010-11-22 A (+321d) | 2010-04-28 → 2011-07-25 A (+453d) | 80d → 164d | 0% → 100% | 300d → none |  |  |
| 15211035 | Proc Chamb Preamps (ASIC Dsgn) (FWD Chambers) Labor FY10 | 2010-06-25 → 2010-12-01 A (+159d) | 2010-09-30 → 2010-12-23 A (+84d) | 68d → 15d | 0% → 100% | 221d → none |  |  |
| 15211035a | Proc Chamb Preamps (ASIC Dsgn) (FWD Chambers) Labor FY11 | 2010-10-01 → 2011-01-01 A (+92d) | 2011-01-06 → 2011-01-31 A (+25d) | 62d → 19d | 0% → 100% | 221d → none |  |  |
| 15211155 | Mount on-Chamb Electrnc's (FWD Chambers) | 2010-11-17 → 2011-01-04 A (+48d) | 2010-12-31 → 2011-01-24 A (+24d) | 26d → 14d | 0% → 100% | 430d → none |  |  |
| 15211145 | Procurement of Consumables for Fab (2011) (FWD Chambers) | 2011-01-04 → 2011-01-05 A (+1d) | 2011-09-30 → 2011-09-26 A (-4d) | 189d → 183.5d | 0% → 100% | 198d → none |  |  |
| 15211085 | Test PC Boards (Flex) (FWD Chambers) | 2010-11-17 → 2011-01-17 A (+61d) | 2011-03-14 → 2011-06-30 A (+108d) | 73.5d → 116d | 0% → 100% | 63d → none | 15211020, 15211020a → 15211020, 15211020a FS-170d |  |
| 15211070 | Proc Gas Connections (FWD Chambers) | 2011-01-05 → 2011-02-01 A (+27d) | 2011-07-11 → 2011-02-21 A (-140d) | 130d → 14d | 0% → 100% | 236d → none |  |  |
| 15211163 | Manufacture All Cables & QA (FWD Chambers) | 2011-03-14 → 2011-02-08 A (-34d) | 2011-08-16 → 2011-07-25 A (-22d) | 110d → 117d | 0% → 100% | 172d → none | 15211050 FS-84d → 15211050 FS-100d | resources ELEC TECH [880 h]; MECH TECH [880 h] → MECH TECH [880 h]; ELEC TECH [880 h] |
| 15211102 | Set-up Clean Room for Production | 2011-01-04 → 2011-02-14 A (+41d) | 2011-02-22 → 2011-03-25 A (+31d) | 34d → 29d | 0% → 100% | 91d → none |  | resources MECH TECH [480 h]; MECH ENG [240 h] → MECH ENG [240 h]; MECH TECH [480 h] |
| 15211035b | ASIC Fabrication (FDC&CDC) | 2011-03-07 → 2011-03-01 A (-6d) | 2011-05-27 → 2011-08-15 A (+80d) | 60d → 118d | 0% → 100% | 77d → none |  |  |
| 15211120 | Cathode Frame Inspection (FWD Chambers) | 2011-03-15 → 2011-03-01 A (-14d) | 2011-04-13 → 2011-03-25 A (-19d) | 22d → 18d | 0% → 100% | 63d → none | 15211002b FS-233d, 15211100, 15211085 FS+0.5d → 15211002b FS-233d, 15211100, 15211085 FS-166d |  |
| 15211125 | Cell #1Assy. (FWD Chambers) | 2011-04-01 → 2011-04-02 A (+1d) | 2011-05-02 → 2011-06-20 A (+49d) | 22d → 55d | 0% → 100% | 64d → none |  | resources ELEC TECH [160 h]; SCIENTIST [160 h]; MECH TECH [720 h]; MECH DES [160 h]; MECH ENG [240 h] → MECH DES [160 h]; MECH ENG [240 h]; ELEC TECH [160 h]; SCIENTIST [160 h]; MECH TECH [720 h] |
| 15211094 | Acceptance Preamp Daughter Board (FWD Chambers) | 2011-10-03 → 2011-04-03 A (-183d) | 2012-06-22 → 2011-04-18 A (-431d) | 178d → 11d | 0% → 100% | 35d → none |  |  |
| 15211060 | Proc Cooling Sys (FWD Chambers) Part A | 2011-07-01 → 2011-04-11 A (-81d) | 2011-09-30 → 2012-12-17 A (+444d) | 64d → 490d | 0% → 100% | 346d → none | 9-110M FS+184d → 9-110M |  |
| 15211126 | Package #1 Fabrication (FWD Chambers) | 2011-04-14 → 2011-04-25 A (+11d) | 2011-09-30 → 2011-10-17 A (+17d) | 119d → 122.5d | 0% → 100% | 63d → none | 15211120, 15211080a, 15211090a, 15211022, 15211125 FS-14d, 15211002b FS-245d, 15211030a → 15211002b FS-255d, 15211090a FS-30d, 15211080a FS-30d, 15211125 FS-20d, 15211120 FS-130d, 15211022 FS-60d, 15211030a FS-30d | resources MECH DES [160 h]; MECH ENG [320 h]; SCIENTIST [160 h]; MECH TECH [3400 h]; ELEC TECH [160 h] → SCIENTIST [160 h]; ELEC TECH [160 h]; MECH DES [160 h]; MECH ENG [320 h]; MECH TECH [3400 h] |
| 15211002c | Additional Engineering Support for Assembly FY12 (FWD Chambers) | 2011-06-03 → 2011-06-01 A (-2d) | 2011-09-30 A | 84d → 86d | 0% → 100% | 628d → none |  |  |
| 15211163a | Support for procurement of parts for gas system (FWD Chambers) | 2011-06-01 A | 2011-09-01 → 2011-08-31 A (-1d) | 66d → 65d | 0% → 100% | 198d → none |  |  |
| 15211130 | Package #2 Fabrication (FWD Chambers) FY11 | 2011-09-20 → 2011-08-15 A (-36d) | 2011-09-30 → 2012-01-10 A (+102d) | 9d → 97.49d | 0% → 100% | 63d → none | 15211126 FS-9d → 15211126 FS-20d | resources MECH ENG [23.23 h]; SCIENTIST [13.27 h]; ELEC TECH [13.27 h]; MECH TECH [282.03 h]; MECH DES [6.64 h] → MECH DES [6.64 h]; MECH ENG [23.23 h]; SCIENTIST [13.27 h]; ELEC TECH [13.27 h]; MECH TECH [282.03 h] |
| 15211130a | Package #2 Fabrication (FWD Chambers) FY12 | 2011-10-03 → 2011-08-15 A (-49d) | 2012-03-05 → 2012-01-16 A (-49d) | 100.5d → 101d | 0% → 100% | 63d → none | 15211130 → 15211130 FS-100d |  |
| 15211012E | FY12 Travel (FWD Chambers) | 2011-10-03 A | 2012-09-28 A |  | 0% → 100% | 146d → none |  |  |
| 15211190 | Procurement of Consumables for Fab (2012) (FWD Chambers) | 2011-10-03 A | 2012-09-28 A |  | 0% → 100% | 71d → none |  |  |
| 15211075 | Proc Supprt Frame (FWD Chambers) Part A | 2011-10-03 → 2011-12-05 A (+63d) | 2012-02-13 → 2012-11-12 A (+273d) | 87d → 235d | 0% → 100% | 259d → none |  |  |
| 15211150 | 1st Package Final Assy. and Testing (FWD Chambers) | 2012-06-25 → 2012-01-16 A (-161d) | 2012-08-22 → 2012-10-15 A (+54d) | 43d → 191d | 0% → 100% | 20d → none | 1546090, 15211249 FS-10d, 15211164 FS-23d, 15211095 FS-80d, 15211145, 15211094 FS-15d, 15211250 FS-10d → 15211094 FS-15d, 1546090 FS-80d, 15211145, 15211164 FS-110d | was named Package #1 Final Assy. and Testing (FWD Chambers); resources MECH TECH [320 h]; MECH ENG [80 h]; SCIENTIST [160 h]; ELEC TECH [40 h] → SCIENTIST [160 h]; ELEC TECH [40 h]; MECH TECH [320 h]; MECH ENG [80 h] |
| 15211135 | Package #3 Fabrication (FWD Chambers) | 2012-02-21 → 2012-01-16 A (-36d) | 2012-08-03 → 2012-05-14 A (-81d) | 116d → 84d | 0% → 100% | 63d → none |  | resources SCIENTIST [160 h]; ELEC TECH [160 h]; MECH DES [80 h]; MECH ENG [280 h]; MECH TECH [3400 h] → MECH DES [80 h]; MECH ENG [280 h]; MECH TECH [3400 h]; SCIENTIST [160 h]; ELEC TECH [160 h] |
| 15211095 | Test Electrnc's (FWD Chambers) | 2012-03-26 → 2012-03-02 A (-24d) | 2012-09-21 → 2012-11-12 A (+52d) | 127d → 179d | 0% → 100% | 36d → none |  |  |
| 15211249 | Construct/Install/Test HV Sys (FWD Chambers) | 2012-03-12 A | 2012-06-15 → 2012-08-13 A (+59d) | 68d → 109d | 0% → 100% | 35d → none |  |  |
| 15211250 | Construct/Install/Test LV Sys ((FWD Chambers) | 2012-03-12 A | 2012-06-15 → 2013-01-14 A (+213d) | 68d → 205d | 0% → 100% | 35d → none |  |  |
| 15211141 | Package #4 Fabrication (FWD Chambers) FY12 | 2012-07-12 → 2012-04-09 A (-94d) | 2012-09-28 → 2013-02-11 A (+136d) | 55.5d → 214.5d | 0% → 100% | 63d → none | 15211135 FS-16d → 15211135 FS-70d | resources MECH ENG [270.26 h]; ELEC TECH [154.43 h]; SCIENTIST [154.43 h]; MECH TECH [3281.74 h]; MECH DES [77.22 h] → MECH TECH [3281.74 h]; MECH DES [77.22 h]; MECH ENG [270.26 h]; ELEC TECH [154.43 h]; SCIENTIST [154.43 h] |
| 15211141a | Package #4 Fabrication (FWD Chambers) FY13 | 2012-10-01 → 2012-04-09 A (-175d) | 2012-10-02 → 2013-02-11 A (+132d) | 2d → 215d | 0% → 100% | 63d → none | 15211141 → 15211141 FS-100d |  |
| 15211164 | Construct/ Test Gas System (FWD Chambers) | 2012-05-01 → 2012-04-16 A (-15d) | 2012-07-02 → 2012-09-17 A (+77d) | 43d → 108d | 0% → 100% | 37d → none |  |  |
| 15211155a | 2nd Package Final Assy. and Testing (FWD Chambers) FY12 | 2012-08-23 → 2012-10-01 A (+39d) | 2012-09-28 → 2013-01-14 A (+108d) | 26d → 50d | 0% → 100% | 20d → none | 15211150, 15211155 → 15211155, 15211150 FS-1d | was named Package #2 Final Assy. and Testing (FWD Chambers) FY12; resources MECH ENG [50.73 h]; MECH TECH [202.93 h]; SCIENTIST [101.46 h]; ELEC TECH [25.37 h] → ELEC TECH [25.37 h]; MECH ENG [50.73 h]; MECH TECH [202.93 h]; SCIENTIST [101.46 h] |
| 15211155aa | 2nd Package Final Assy. and Testing (FWD Chambers) FY13 | 2012-10-01 A | 2012-10-19 → 2013-01-14 A (+87d) | 15d → 50d | 0% → 100% | 20d → none | 15211155a → 15211155a FS-40d | was named Package #2 Final Assy. and Testing (FWD Chambers) FY13 |
| 15211191 | Procurement of Consumables for Fab (2013) (FWD Chambers) | 2012-10-01 A | 2013-03-01 → 2013-08-30 A (+182d) |  | 0% → 100% | 71d → none | 15211190 → 15211190, 9-130M |  |
| 15211195 | Cell #25 Assy. (FWD Chambers) | 2012-08-03 → 2012-10-15 A (+73d) | 2012-09-05 → 2013-03-11 A (+187d) | 22d → 53d | 0% → 100% | 468.5d → none | 15211135 → 9-130M, 15211135 |  |
| 15211200 | Cell #26 Assy. (FWD Chambers) | 2012-08-24 → 2012-10-15 A (+52d) | 2012-09-24 → 2013-03-11 A (+168d) | 20d → 53d | 0% → 100% | 468.5d → none | 15211195 FS-7d → 15211195 FS-30d |  |
| 15211160 | 3rd Package Final Assy. and Testing (FWD Chambers) | 2012-10-01 → 2012-11-12 A (+42d) | 2012-12-04 → 2013-02-11 A (+69d) | 45d → 34d | 0% → 100% | 20d → none | 15211155aa FS-15d, 15211155 → 15211155aa FS-40d, 15211155 |  |
| 15211205 | Cell #27 Assy. (FWD Chambers) | 2013-04-01 → 2012-12-03 A (-119d) | 2013-04-26 → 2013-03-11 A (-46d) | 19.5d → 11d | 0% → 100% | 337d → none | 15211200 FS-7d, 9-130M FS+120d → 15211200 FS-40d, 9-130M |  |
| 15211060a | Proc Cooling Sys (FWD Chambers) Part B | 2011-07-01 → 2012-12-10 A (+528d) | 2011-09-30 → 2013-05-13 A (+591d) | 64d → 98d | 0% → 100% | 346d → none | 9-110M FS+184d → 9-110M |  |
| 15211075a | Proc Supprt Frame (FWD Chambers) Part B | 2011-10-03 → 2013-01-02 A (+457d) | 2012-02-13 → 2013-02-11 A (+364d) | 87d → 20d | 0% → 100% | 259d → none |  |  |
| 15211165 | 4th Package Final Assy. and Testing (FWD Chambers) | 2012-12-05 → 2013-01-07 A (+33d) | 2013-03-25 → 2013-03-11 A (-14d) | 71d → 22d | 0% → 100% | 20d → none | 15211141a, 15211160 → 15211141a FS-20d, 15211249, 15211160 FS-65d, 15211250 FS-40d, 15211095 | resources MECH ENG [40 h]; SCIENTIST [120 h]; MECH TECH [320 h] → MECH TECH [320 h]; MECH ENG [40 h]; SCIENTIST [120 h] |
| 15211210 | Cell #28 Assy. (FWD Chambers) | 2013-04-19 → 2013-01-28 A (-81d) | 2013-05-23 → 2013-04-15 A (-38d) |  | 0% → 100% | 337d → none | 15211205 FS-5d → 15211205 FS-35d |  |
| 15211185 | Fiducialize complete package (FWD Chambers) | 2013-04-02 → 2013-02-11 A (-50d) | 2013-04-08 → 2013-07-15 A (+98d) | 5d → 22d | 0% → 100% | 20d → none | 15211175 FS-5d → 15211175 FS-150d | resources MECH TECH [120 h]; MECH ENG [40 h]; SCIENTIST [200 h] → MECH ENG [40 h]; SCIENTIST [200 h]; MECH TECH [120 h] |
| 15211230 | Alignment Procedures (FWD Chambers) | 2013-03-08 → 2013-02-11 A (-25d) | 2013-03-21 → 2013-07-15 A (+116d) | 10d → 76d | 0% → 100% | 32d → none | 15211175 FS-22d, 15211002c FS-245d → 15211175 FS-125d, 15211002c FS-245d |  |
| 15211175 | Complete Package Assy (FWD Chambers) | 2013-01-31 → 2013-06-01 A (+121d) | 2013-04-08 → 2013-08-30 A (+144d) | 47d → 118d | 0% → 100% | 20d → none | 15211165 FS-37d, 15211075a, 15211160, 15211075, 15211060, 15211150, 15211060a, 15211135, 15211145 → 15211060a FS-80d, 15211135, 15211075a, 15211060 FS-80d, 15211150, 15211160 FS-30d, 15211145, 15211075, 15211165 FS-52d |  |
| 15211220 | Final Testing (FWD Chambers) | 2013-02-04 → 2013-07-01 A (+147d) | 2013-04-01 → 2013-07-15 A (+105d) | 40d → 23d | 0% → 100% | 25d → none | 15211145, 15211175 FS-45d → 15211175 FS-22d, 15211145 |  |
| 15211255 | Re-Baseline Actuals Adjustment | 2013-08-30 A | 2013-08-30 A |  | 0% → 100% | 20d → none | 9-130M FS+227d → none |  |
| 25211172 | Resolution_studies_(FWD_Chambers) FY13 | 2013-09-03 A | 2013-09-30 → 2013-12-12 (+73d) | 20d → 30d | 0% → 50% | 0d → 33d |  |  |
| 25211172a | Resolution_studies_(FWD_Chambers) FY14 | 2013-10-01 → 2013-09-03 A (-28d) | 2013-10-14 → 2013-12-12 (+59d) |  | 0% → 50% | 0d → 33d | 25211172, 9-130M FS+228d → 25211172 FS-60d |  |
| 25211175 | Complete Package Mechanical Assy (FWD Chambers) FY13 | 2013-09-03 A | 2013-09-30 → 2013-10-21 A (+21d) | 20d → 30d | 0% → 100% | 56d → none |  |  |
| 25211175a | Complete Package Mechanical Assy (FWD Chambers) FY14 | 2013-10-01 → 2013-09-03 A (-28d) | 2013-10-14 → 2013-10-21 A (+7d) |  | 0% → 100% | 56d → none | 25211175, 9-130M FS+228d → 25211175 FS-25d |  |
| 25211191 | Procurement of Consumables for Fab (2013) (FWD Chambers) | 2013-09-03 A | 2013-09-30 → 2013-09-23 A (-7d) |  | 0% → 100% | 42d → none |  |  |
| 25211208 | Assemble and Electrical Test of Package R (FDC) | 2013-09-03 A | 2013-09-30 → 2013-09-23 A (-7d) |  | 0% → 100% | 1d → none |  |  |
| 25211217 | Cooling system assembly FY13 | 2013-09-03 A | 2013-09-30 → 2013-12-02 (+63d) |  |  |  |  |  |
| 25211217a | Cooling system assembly FY14 | 2013-10-01 → 2013-09-03 A (-28d) |  |  |  |  | 9-130M FS+228d, 25211217 → 25211217 FS-45d |  |
| 25211220 | Final Testing (FWD Chambers) | 2013-09-03 A | 2013-09-30 → 2013-09-23 A (-7d) |  | 0% → 100% | 56d → none |  |  |
| 25211250 | Disassembly of the construction equipment and site - labor and forklift lease | 2013-09-03 A | 2013-09-30 → 2013-09-23 A (-7d) |  | 0% → 100% | 247d → none |  |  |
| 25211255LOE | Pick-up Truck Lease | 2013-09-03 A |  |  | 0% → 31% |  |  |  |
| 25211255LOE5 | Blue Crab Cleaning (Previously Obligated) | 2013-09-03 A | 2013-09-30 A |  | 0% → 100% | 247d → none |  |  |
| 25211260 | Develop algorithm for fADC125 readout FY13 | 2013-09-03 A | 2013-09-30 → 2014-01-17 (+109d) |  | 0% → 20% |  |  |  |
| 25211260a | Develop algorithm for fADC125 readout FY14 | 2013-10-01 → 2013-09-03 A (-28d) |  |  | 0% → 20% |  | 9-130M FS+228d, 25211260 → 25211260 FS-75d |  |
| 15212009E | FY09 Travel (CENT CHAMB) | 2009-01-02 A | 2009-09-30 A |  | 0% → 100% | 119d → none |  |  |
| 15212010 | Proc Wire (CENT CHAMB) | 2009-01-05 → 2009-02-09 A (+35d) | 2009-07-09 → 2010-02-19 A (+225d) | 130d → 256d | 0% → 100% | 707d → none |  |  |
| 15212025 | Proc HV Cables (CENT CHAMB) | 2010-01-05 → 2009-04-01 A (-279d) | 2010-07-09 → 2009-04-27 A (-438d) | 130d → 19d | 0% → 100% | 482d → none |  |  |
| 15212000a | Prepare Procurements/Fabrication Packages 2009 (CENT CHAMB) | 2009-06-01 → 2009-07-03 A (+32d) | 2009-09-30 → 2009-10-26 A (+26d) | 86d → 80d | 0% → 100% | 582d → none |  |  |
| 15212015 | Proc Feedthroughs (CENT CHAMB) | 2009-06-01 → 2009-09-01 A (+92d) | 2009-12-03 → 2010-10-25 A (+326d) | 130d → 286d | 0% → 100% | 605d → none |  |  |

| ID | Task | Start | Finish | Duration | Complete | Total float | Predecessors | Other |
| --- | --- | --- | --- | --- | --- | --- | --- | --- |
| 15212040 | Proc endplates (CENT CHAMB) | 2009-06-01 → 2009-09-07 A (+98d) | 2010-01-15 → 2009-12-21 A (-25d) | 155d → 72d | 0% → 100% | 582d → none |  |  |
| 15212010E | FY10 Travel (CENT CHAMB) | 2009-10-01 A | 2010-09-30 A |  | 0% → 100% | 119d → none |  |  |
| 15212000c | Support Parts Fabrication 2010 (CENT CHAMB) | 2009-10-01 → 2009-10-19 A (+18d) | 2010-01-15 → 2010-04-26 A (+101d) | 69d → 126d | 0% → 100% | 672d → none |  |  |
| 15212020 | Proc Crimp pins (CENT CHAMB) | 2009-06-01 → 2009-11-30 A (+182d) | 2009-12-03 → 2010-05-24 A (+172d) | 130d → 118d | 0% → 100% | 617d → none |  |  |
| 15212095 | Check Wire Quality (CENT CHAMB) | 2009-07-10 → 2009-11-30 A (+143d) | 2009-08-10 → 2010-12-23 A (+500d) | 22d → 264d | 0% → 100% | 707d → none |  |  |
| 15212100 | Check Feedthroughs (CENT CHAMB) | 2009-12-04 → 2009-11-30 A (-4d) | 2010-01-12 → 2010-11-29 A (+321d) | 22d → 248d | 0% → 100% | 605d → none |  |  |
| 15212070 | Proc Epoxy (CENT CHAMB) (Frozen by CR10-007) | 2009-01-05 → 2009-12-14 A (+343d) | 2009-07-09 → 2009-12-21 A (+165d) | 130d → 5d | 0% → 100% | 306d → none |  |  |
| 15212075 | Reverse Entry per CR10-007 | 2009-12-01 → 2009-12-14 A (+13d) | 2009-12-01 → 2009-12-21 A (+20d) | 1d → 5d | 0% → 100% | 206d → none |  |  |
| 15212000d | Acceptance Checks/Documentation 2010 (CENT CHAMB) | 2010-01-19 → 2009-12-21 A (-29d) | 2010-02-16 → 2010-02-19 A (+3d) | 20d → 37d | 0% → 100% | 652d → none |  |  |
| 15212080 | Proc First Article Preamps (CENT CHAMB) | 2010-01-05 → 2010-01-11 A (+6d) | 2010-05-28 → 2010-05-24 A (-4d) | 102d → 94d | 0% → 100% | 272d → none |  |  |
| 15212050 | Proc Stand-offs (CENT CHAMB) | 2009-06-01 → 2010-01-18 A (+231d) | 2009-09-29 → 2010-02-25 A (+149d) | 85d → 27d | 0% → 100% | 672d → none |  |  |
| 15212001 | FY10 Engineering Support for Assembly Prep (CENT CHAMB) | 2010-02-02 → 2010-02-01 A (-1d) | 2010-07-13 → 2010-05-28 A (-46d) | 113d → 84d | 0% → 100% | 349d → none |  | resources MECH DES [40 h]; MECH ENG [40 h] → MECH ENG [40 h]; MECH DES [40 h] |
| 15212110 | Check endplates (CENT CHAMB) | 2010-01-19 → 2010-02-01 A (+13d) | 2010-02-01 → 2010-04-26 A (+84d) | 10d → 60d | 0% → 100% | 582d → none |  |  |
| 15212005 | Proc Straws (CENT CHAMB) | 2009-01-05 → 2010-02-08 A (+399d) | 2009-04-07 → 2011-05-23 A (+776d) | 65d → 322d | 0% → 100% | 783d → none |  |  |
| 15212120 | Clean endplates & Compnts (CENT CHAMB) | 2010-02-02 → 2010-02-09 A (+7d) | 2010-02-16 → 2010-02-22 A (+6d) | 10d → 9d | 0% → 100% | 582d → none |  |  |
| 15212035 | Proc Gas Connectors (CENT CHAMB) | 2010-01-05 → 2010-04-19 A (+104d) | 2010-04-07 → 2012-01-16 A (+649d) | 65d → 431d | 0% → 100% | 546d → none |  | resources PROCUREMENT>$50K 69; PROCUREMENT<$50K 60 → PROCUREMENT<$50K 60; PROCUREMENT>$50K 69 |
| 15212030 | Proc Signal Cables (CENT CHAMB) | 2010-05-14 → 2010-05-17 A (+3d) | 2010-11-16 → 2011-06-30 A (+226d) | 130d → 280d | 0% → 100% | 391d → none |  |  |
| 15212060 | Proc Fiber Glass shell (inner surface) (CENT CHAMB) | 2011-01-05 → 2010-05-24 A (-226d) | 2011-07-11 → 2010-07-26 A (-350d) | 130d → 44d | 0% → 100% | 254d → none |  |  |
| 15212105 | Check Crimp pins (CENT CHAMB) | 2009-12-04 → 2010-06-21 A (+199d) | 2009-12-18 → 2010-07-26 A (+220d) | 11d → 25d | 0% → 100% | 617d → none |  |  |
| 15212002 | FY10 Engineering Support for Straw Tube Install (CENT CHAMB) FY10 | 2010-07-14 → 2010-07-19 A (+5d) | 2010-09-30 A | 56d → 53d | 0% → 100% | 349d → none |  | resources MECH DES [34.46 h]; MECH ENG [17.23 h] → MECH ENG [17.23 h]; MECH DES [34.46 h] |
| 15212002a | FY10 Engineering Support for Straw Tube Install (CENT CHAMB) FY11 | 2010-10-01 → 2010-07-19 A (-74d) | 2011-01-25 → 2010-09-30 A (-117d) | 74d → 53d | 0% → 100% | 349d → none |  |  |
| 15212090 | Test Straws (CENT CHAMB) | 2009-04-08 → 2010-07-26 A (+474d) | 2009-04-22 → 2011-06-30 A (+799d) | 11d → 232d | 0% → 100% | 783d → none | 15212005 → 15212005 FS-70d |  |
| 15212003 | FY11 Engineering Support for Assembly Initial (CENT CHAMB) | 2010-10-01 A | 2010-12-31 A |  | 0% → 100% | 279d → none |  |  |
| 15212011E | FY11 Travel (CENT CHAMB) | 2010-10-01 A | 2011-09-30 A |  | 0% → 100% | 119d → none |  |  |
| 15212003a | FY11 Engineering Support for Assembly Final (CENT CHAMB) | 2011-01-04 A | 2011-09-30 A |  | 0% → 100% | 279d → none |  | resources MECH DES [680 h]; MECH ENG [160 h]; SCIENTIST [120 h] → MECH ENG [160 h]; SCIENTIST [120 h]; MECH DES [680 h] |
| 15212065 | Proc Lucite and hardware (Gas plenum) (CENT CHAMB) | 2011-03-01 A | 2011-08-01 → 2011-11-28 A (+119d) | 108d → 190d | 0% → 100% | 391d → none |  |  |
| 15212055 | Proc Aluminum shell (Outer surface) (CENT CHAMB) | 2011-06-01 → 2011-04-01 A (-61d) | 2011-09-30 → 2011-04-30 A (-153d) | 86d → 21d | 0% → 100% | 196d → none |  |  |
| 15212088 | Proc Rail Bearings (CENT CHAMB) | 2011-03-01 → 2011-04-02 A (+32d) | 2011-06-01 → 2011-06-30 A (+29d) | 66d → 63d | 0% → 100% | 386d → none |  |  |
| 15212045 | Prepare Procurement Packages for Supprt Frame (CENT CHAMB) | 2011-08-01 → 2011-04-25 A (-98d) | 2011-09-30 → 2012-05-14 A (+227d) | 44d → 263d | 0% → 100% | 303d → none | 12321018M, 15212000a FS-86d, 9-120M FS-44d → 12321018M, 15212000a FS-86d |  |
| 15212160 | Attach shell (CENT CHAMB) | 2012-05-02 → 2011-09-01 A (-244d) | 2012-05-15 → 2011-10-24 A (-204d) | 10d → 37d | 0% → 100% | 54d → none | 15212055, 15212004a FS-390d, 15212155, 15212060 → 15212155 FS-150d, 15212004a FS-390d, 15212055, 15212060 |  |
| 15212004 | FY12 Engineering Support for Assembly (CENT CHAMB) | 2011-10-03 A | 2012-09-28 A |  | 0% → 100% | 85d → none |  |  |
| 15212012E | FY12 Travel (CENT CHAMB) | 2011-10-03 A | 2012-09-28 A |  | 0% → 100% | 119d → none |  |  |
| 15212047 | Proc Supprt Frame (CENT CHAMB) Part A | 2011-10-03 → 2012-01-16 A (+105d) | 2012-02-13 → 2012-11-12 A (+273d) | 87d → 211d | 0% → 100% | 303d → none | 15212045 → 9-120M FS+21d, 15212045 FS-25d |  |
| 15212115 | Test On-Chamb Electrnc's (CENT CHAMB) | 2012-01-30 → 2012-02-01 A (+2d) | 2012-04-02 → 2012-03-19 A (-14d) | 45d → 33d | 0% → 100% | 55d → none |  | resources PD UNIV STUDNT [192 h]; SCIENTIST [160 h]; CONTRB UNIV LBR [280 h] → SCIENTIST [160 h]; CONTRB UNIV LBR [280 h]; PD UNIV STUDNT [192 h] |
| 15212145 | Gas Sys Installtn (CENT CHAMB) | 2012-04-03 → 2012-03-03 A (-31d) | 2012-04-03 → 2012-04-16 A (+13d) | 1d → 31d | 0% → 100% | 54d → none |  |  |
| 15212087 | Alignment CC (CENT CHAMB) | 2012-06-21 → 2012-03-12 A (-101d) | 2012-07-18 → 2012-05-14 A (-65d) | 20d → 46d | 0% → 100% | 172d → none | 9-120M FS+176d, 15212088, 15212160, 15212065 → 15212088, 9-120M, 15212160, 15212065 |  |
| 15212155 | Mount Signal Connectors (CENT CHAMB) | 2012-04-04 → 2012-05-01 A (+27d) | 2012-05-01 → 2012-05-14 A (+13d) | 20d → 10d | 0% → 100% | 54d → none |  |  |
| 15212004a | FY13 Engineering Support for Assembly (CENT CHAMB) | 2012-10-01 A | 2013-05-01 A |  | 0% → 100% | 85d → none |  | resources MECH DES [240 h]; SCIENTIST [120 h]; MECH ENG [160 h] → MECH ENG [160 h]; MECH DES [240 h]; SCIENTIST [120 h] |
| 15212013E | FY13 Travel (CENT CHAMB) | 2012-10-01 A | 2012-12-31 A |  | 0% → 100% | 119d → none |  |  |
| 15212047a | Proc Supprt Frame (CENT CHAMB) Part B | 2011-10-03 → 2012-12-03 A (+427d) | 2012-02-13 → 2013-01-14 A (+336d) | 87d → 20d | 0% → 100% | 303d → none | 15212045 → 15212045 FS-25d, 9-120M FS+21d |  |
| 15212185 | Resolution Studies (CENT CHAMB) | 2012-10-01 → 2013-08-30 A (+333d) | 2012-12-04 → 2013-08-30 A (+269d) | 45d → 141d | 0% → 100% | 54d → none | 15212160 FS+95d, 15212088 → 15212088, 15212160, 9-130M FS+220d | resources SCIENTIST [475.2 h]; CONTRB UNIV LBR [800 h] → CONTRB UNIV LBR [800 h]; SCIENTIST [475.2 h] |
| 15212190 | Cross talk Studies (CENT CHAMB) | 2012-12-05 → 2013-08-30 A (+268d) | 2013-01-11 → 2013-08-30 A (+231d) | 22d → 141d | 0% → 100% | 54d → none | 15212185 → 15212185 FS-141d |  |
| 15212195 | Magnetic Field Tests (CENT CHAMB) | 2013-01-14 → 2013-08-30 A (+228d) | 2013-02-13 → 2013-08-30 A (+198d) | 22d → 40d | 0% → 100% | 54d → none | 15212087, 15212190 → 15212087, 15212190 FS-40d |  |
| 15212200 | Shipping (CENT CHAMB) | 2013-02-14 → 2013-08-30 A (+197d) | 2013-04-04 → 2013-08-30 A (+148d) | 35d → 1d | 0% → 100% | 54d → none | 15212047, 15212047a, 15212195 → 15212047a, 195212260 FS-1d, 15212047 |  |
| 15212205 | Re-Baseline Actuals Adjustment | 2013-08-30 A | 2013-08-30 A |  | 0% → 100% | 20d → none | 9-130M FS+227d → none |  |
| 25212185 | Resolution Studies (CENT CHAMB) FY13 | 2013-09-03 A | 2013-09-30 → 2014-04-21 (+203d) |  | 0% → 30% | 216d → 113d |  |  |
| 25212185a | Resolution Studies (CENT CHAMB) FY14 | 2013-10-01 → 2013-09-03 A (-28d) |  |  | 0% → 30% | 216d → 855d | 9-130M FS+228d, 25212185 → 25212185 FS-140d |  |
| 25212010 | Prepare as built drawings for CDC (CENT CHAMB) | 2013-10-31 → 2013-11-01 (+1d) | 2013-12-18 → 2013-12-19 (+1d) |  |  | 192d → 191d |  |  |
| 15213000 | Prepare Fabrication Packages (START COUNTERS) | 2011-12-01 A | 2012-04-02 → 2013-02-11 A (+315d) | 80d → 297d | 0% → 100% | 189d → none |  |  |
| 15213001 | FY12 Engineering Support for Assembly (START COUNTERS) FY12 | 2012-04-03 → 2012-04-02 A (-1d) | 2012-09-28 A | 126d → 127d | 0% → 100% | 189d → none | 15213000, 9-120M → 9-120M, 15213000 FS-100d | resources MECH ENG [54.49 h]; MECH DES [81.73 h] → MECH DES [81.73 h]; MECH ENG [54.49 h] |
| 15213010 | Procure Sipms Part A | 2012-10-01 → 2012-07-09 A (-84d) | 2013-06-28 → 2013-05-13 A (-46d) | 184d → 179d | 0% → 100% | 64d → none | 9-130M → 9-130M FS-60d |  |
| 15213001a | FY12 Engineering Support for Assembly (START COUNTERS) FY13 | 2012-10-01 A | 2012-12-31 A |  | 0% → 100% | 189d → none |  |  |
| 15213010a | Procure Sipms Part B | 2012-10-01 → 2013-05-01 A (+212d) | 2013-06-28 → 2013-05-13 A (-46d) | 184d → 97d | 0% → 100% | 64d → none | 9-130M → 9-130M FS+185d |  |
| 15213005 | Fabricate Start Counter (START COUNTERS) | 2013-05-31 → 2013-08-30 A (+91d) | 2013-08-30 A | 65d → 141d | 0% → 100% | 20d → none |  |  |
| 15213015 | Re-Baseline Actuals Adjustment | 2013-08-30 A | 2013-08-30 A |  | 0% → 100% | 20d → none | 9-130M FS+227d → none |  |
| 25213005 | Fabricate (FIU) Start Counter (START COUNTERS) | 2013-09-03 A |  |  | 0% → 2% |  |  |  |
| 25213015 | All Manufacturing Drawings for start counter FY13 | 2013-09-03 A | 2013-09-30 → 2013-11-22 (+53d) |  | 0% → 18% | 154d → 158d |  |  |
| 25213015a | All Manufacturing Drawings for start counter FY14 | 2013-10-01 → 2013-09-03 A (-28d) | 2013-10-22 → 2013-11-22 (+31d) |  | 0% → 18% | 154d → 158d | 9-130M FS+228d, 25213015 → 25213015 FS-30d |  |
| 25213020 | Procure start counter support frame parts | 2013-10-23 → 2013-10-21 A (-2d) |  |  | 0% → 8% |  | 25213015, 25213015a → 25213015 FS-20d, 25213015a FS-20d |  |
| 2 | **1.5.2.2 CALORIMETRY** | 2008-12-01 → 2009-01-02 (+32d) | 2014-01-16 → 2014-03-06 (+49d) |  |  |  |  |  |
| 1 | **1.5.2.2.1 BARREL CALORIMETER** | 2008-12-01 → 2009-01-02 (+32d) | 2013-11-27 → 2014-03-06 (+99d) |  |  |  |  |  |
| 15221009E | FY09 Travel (BarCal) | 2009-01-02 A | 2009-09-30 A |  | 0% → 100% | 496d → none |  |  |
| 15221010 | Proc SciFi Mods 01-06 (BarCal) P-1 | 2008-12-01 → 2009-03-02 A (+91d) | 2009-05-29 → 2009-07-30 A (+62d) | 121d → 107d | 0% → 100% | 220d → none |  |  |
| 15221192LOE | Bcal Module Construction Manager Initial Prototype | 2009-04-01 A | 2009-08-28 A |  | 0% → 100% | 84d → none |  |  |
| 15221035 | Proc Clean Room (BarCal) | 2009-04-01 → 2009-05-01 A (+30d) | 2009-06-24 → 2009-10-26 A (+124d) | 60d → 124d | 0% → 100% | 741d → none |  | resources PROCUREMENT<$50K 60; PD UNIV STUDNT [320 h] → PD UNIV STUDNT [320 h]; PROCUREMENT<$50K 60 |
| 15221060 | Proc Lead Sheets 1-6 (BarCal) | 2009-01-05 → 2009-05-18 A (+133d) | 2009-03-31 → 2009-10-19 A (+202d) | 60d → 108d | 0% → 100% | 424d → none |  |  |
| 15221040 | Proc Fiber Handling & Sorting table (BarCal) | 2009-04-01 → 2009-06-22 A (+82d) | 2009-06-24 → 2009-08-24 A (+61d) | 60d → 45d | 0% → 100% | 741d → none |  |  |
| 15221012 | Proc SciFi Mods 25-30 (BarCal) P-2 | 2009-06-01 → 2009-07-30 A (+59d) | 2009-09-30 → 2009-10-26 A (+26d) | 86d → 62d | 0% → 100% | 220d → none |  |  |
| 15221001 | Prepare Fabrication Packages 2009 (BarCal) | 2009-06-02 → 2009-08-03 A (+62d) | 2009-08-04 → 2009-08-03 A (-1d) | 45d → 1d | 0% → 100% | 695d → none |  |  |
| 15221185 | Scifi Sorting & Bundling Mods 1-6 (BarCal) (FROZEN and Reversed BY CR09-043 Activity 15221191) | 2009-06-25 → 2009-08-03 A (+39d) | 2009-07-31 → 2009-08-03 A (+3d) | 26d → 1d | 0% → 100% | 42d → none |  |  |

| ID | Task | Start | Finish | Duration | Complete | Total float | Predecessors | Other |
| --- | --- | --- | --- | --- | --- | --- | --- | --- |
| 15221190 | Lead Cutting & Swaging Mods 1-6 (BarCal) (FROZEN and Reversed BY CR09-043 Activity 15221191) | 2009-04-01 → 2009-08-03 A (+124d) | 2009-06-24 → 2009-08-03 A (+40d) | 60d → 1d | 0% → 100% | 68d → none |  |  |
| 15221191 | Reverse Entry for Frozen Activities 15221185, 15221190 and 15221310 Per CR09-043 | 2009-08-05 → 2009-08-03 A (-2d) | 2009-08-05 → 2009-08-03 A (-2d) |  | 0% → 100% | 39d → none |  |  |
| 15221310 | Lead Cutting & Swaging Mods 25-30 (BarCal) (FROZEN and Reversed BY CR09-043 Activity 15221191) | 2009-06-25 → 2009-08-03 A (+39d) | 2009-07-31 → 2009-08-03 A (+3d) | 26d → 1d | 0% → 100% | 42d → none |  |  |
| 15221002 | Evaluate Procurements 2009 (BarCal) | 2009-06-30 → 2009-08-10 A (+41d) | 2009-09-30 → 2009-10-19 A (+19d) | 65d → 50d | 0% → 100% | 695d → none |  |  |
| 15221050 | Proc 2nd press/Frame (BarCal) | 2009-08-31 A | 2010-03-01 → 2009-10-26 A (-126d) | 120d → 40d | 0% → 100% | 595d → none |  |  |
| 15221195 | Bcal Module Construction Manager Phase 1 (LOE) | 2009-08-31 A | 2010-03-01 A |  | 0% → 100% | 84d → none | 15221192LOE → 15221192LOE FF |  |
| 15221200 | Module #1 Matrix Fabrication | 2009-08-31 → 2009-09-01 A (+1d) | 2009-12-01 → 2009-12-21 A (+20d) | 64d → 76d | 0% → 100% | 695d → none | 15221002 FS-22d, 15221035, 15221040, 9-090M FS+226d → 15221002 FS-22d, 9-090M, 15221035, 15221040 |  |
| 15221205 | Module #1 Machining and Shipping | 2009-08-31 → 2009-09-01 A (+1d) | 2010-02-10 → 2010-04-26 A (+75d) | 108d → 159d | 0% → 100% | 646d → none |  |  |
| 15221210 | Module #2 Matrix Fabrication | 2009-08-31 → 2009-09-01 A (+1d) | 2009-12-01 → 2010-01-18 A (+48d) | 64d → 90d | 0% → 100% | 695d → none |  |  |
| 15221215 | Module #2 Machining and Shipping | 2009-08-31 → 2009-09-01 A (+1d) | 2010-02-10 → 2010-04-26 A (+75d) | 108d → 159d | 0% → 100% | 646d → none |  |  |
| 15221220 | Module #3 Matrix Fabrication | 2009-08-31 → 2009-09-01 A (+1d) | 2010-01-07 → 2010-02-10 A (+34d) | 85d → 107d | 0% → 100% | 674d → none |  |  |
| 15221225 | Module #3 Machining and Shipping | 2009-08-31 → 2009-09-01 A (+1d) | 2010-02-10 → 2010-04-26 A (+75d) | 108d → 159d | 0% → 100% | 646d → none |  |  |
| 15221230 | Module #4 Matrix Fabrication | 2009-08-31 → 2009-09-01 A (+1d) | 2010-01-07 → 2010-02-26 A (+50d) | 85d → 118d | 0% → 100% | 674d → none |  |  |
| 15221235 | Module #4 Machining and Shipping | 2009-08-31 → 2009-09-01 A (+1d) | 2010-02-10 → 2010-04-26 A (+75d) | 108d → 159d | 0% → 100% | 646d → none |  |  |
| 15221240 | Module #5 Matrix Fabrication | 2009-08-31 → 2009-09-01 A (+1d) | 2010-02-12 → 2010-03-15 A (+31d) | 110d → 129d | 0% → 100% | 649d → none |  |  |
| 15221245 | Module #5 Machining and Shipping | 2009-08-31 → 2009-09-01 A (+1d) | 2010-04-27 → 2010-06-28 A (+62d) | 161d → 203d | 0% → 100% | 593d → none |  |  |
| 15221250 | Module #6 Matrix Fabrication | 2009-08-31 → 2009-09-01 A (+1d) | 2010-02-12 → 2010-03-22 A (+38d) | 110d → 134d | 0% → 100% | 649d → none |  |  |
| 15221255 | Module #6 Machining and Shipping | 2009-08-31 → 2009-09-01 A (+1d) | 2010-04-27 → 2010-06-28 A (+62d) | 161d → 203d | 0% → 100% | 593d → none |  |  |
| 15221260 | Module #7 Matrix Fabrication | 2009-08-31 → 2009-09-01 A (+1d) | 2010-03-24 → 2010-04-26 A (+33d) | 137d → 159d | 0% → 100% | 622d → none |  |  |
| 15221265 | Module #7 Machining and Shipping | 2009-08-31 → 2009-09-01 A (+1d) | 2010-04-27 → 2010-06-28 A (+62d) | 161d → 203d | 0% → 100% | 593d → none |  |  |
| 15221270 | Module #8 Matrix Fabrication | 2009-08-31 → 2009-09-01 A (+1d) | 2010-03-24 → 2010-04-26 A (+33d) | 137d → 159d | 0% → 100% | 622d → none |  |  |
| 15221275 | Module #8 Machining and Shipping | 2009-08-31 → 2009-09-01 A (+1d) | 2010-04-27 → 2010-06-28 A (+62d) | 161d → 203d | 0% → 100% | 593d → none |  |  |
| 15221014 | Proc SciFi Mods P-2 FY10 October Delivery | 2009-09-09 A | 2009-10-30 → 2009-11-30 A (+31d) | 38d → 57d | 0% → 100% | 220d → none |  |  |
| 15221016 | Proc SciFi Mods P-2 FY10 November Delivery | 2009-09-09 A | 2009-11-30 → 2009-12-21 A (+21d) | 57d → 71d | 0% → 100% | 220d → none |  |  |
| 15221018 | Proc SciFi Mods P-2 FY10 December Delivery | 2009-09-09 A | 2009-12-30 → 2010-01-22 A (+23d) | 74d → 89d | 0% → 100% | 220d → none |  |  |
| 15221018A | Proc SciFi Mods P-2 FY10 January Delivery | 2009-09-09 A | 2010-01-29 → 2010-02-09 A (+11d) | 94d → 101d | 0% → 100% | 220d → none |  |  |
| 15221018B | Proc SciFi Mods P-2 FY10 February Delivery | 2009-09-09 A | 2010-02-26 → 2010-03-22 A (+24d) | 113d → 129d | 0% → 100% | 220d → none |  |  |
| 15221018C | Proc SciFi Mods P-2 FY10 March Delivery | 2009-09-09 A | 2010-03-31 → 2010-03-29 A (-2d) | 136d → 134d | 0% → 100% | 220d → none |  |  |
| 15221018D | Proc SciFi Mods P-2 FY10 April Delivery | 2009-09-09 A | 2010-04-30 → 2010-04-26 A (-4d) | 158d → 154d | 0% → 100% | 220d → none |  |  |
| 15221018F | Proc SciFi Mods P-2 FY10 May Delivery | 2009-09-09 A | 2010-05-28 → 2010-05-24 A (-4d) | 178d → 174d | 0% → 100% | 220d → none |  |  |
| 15221018G | Proc SciFi Mods P-2 FY10 June Delivery | 2009-09-09 A | 2010-06-30 → 2010-06-28 A (-2d) | 200d → 198d | 0% → 100% | 220d → none |  |  |
| 15221018H | Proc SciFi Mods P-2 FY10 July Delivery | 2009-09-09 A | 2010-07-30 A |  | 0% → 100% | 220d → none |  |  |
| 15221018J | Proc SciFi Mods P-2 FY10 August Delivery | 2009-09-09 A | 2010-08-31 → 2010-08-27 A (-4d) | 243d → 241d | 0% → 100% | 220d → none |  |  |
| 15221018K | Proc SciFi Mods P-2 FY10 September Delivery | 2009-09-09 A | 2010-09-30 A |  | 0% → 100% | 220d → none |  |  |
| 15221012A | Proc SciFi Mods P-1 Correction to Match award per CR09-052 | 2009-09-17 → 2009-09-14 A (-3d) | 2009-09-17 → 2009-09-14 A (-3d) |  | 0% → 100% | 9d → none |  |  |
| 15221005 | FY10 Engineering Support for Procurements (BarCal) | 2009-10-01 A | 2010-09-30 A |  | 0% → 100% | 399d → none |  |  |
| 15221010E | FY10 Travel (BarCal) | 2009-10-01 A | 2010-09-30 A |  | 0% → 100% | 496d → none |  |  |
| 15221070 | Proc Lead Sheets 25-30 (BarCal) | 2009-04-01 → 2009-10-13 A (+195d) | 2009-06-24 → 2009-10-20 A (+118d) | 60d → 6d | 0% → 100% | 424d → none |  |  |
| 15221080 | Proc Lead Sheets 7-12 (BarCal) | 2009-06-25 → 2009-10-26 A (+123d) | 2009-09-18 → 2009-11-30 A (+73d) | 60d → 24d | 0% → 100% | 424d → none |  |  |
| 15221090 | Proc Lead Sheets 31-36 (BarCal) | 2009-09-21 → 2009-11-09 A (+49d) | 2009-12-15 → 2009-11-30 A (-15d) | 60d → 14d | 0% → 100% | 424d → none |  |  |
| 15221045 | Proc 2nd Swaging machine (BarCal) | 2009-04-01 → 2010-01-11 A (+285d) | 2009-06-24 → 2010-02-22 A (+243d) | 60d → 29d | 0% → 100% | 695d → none |  |  |
| 15221100 | Proc Lead Sheets 13-18 (BarCal) | 2009-12-16 → 2010-02-01 A (+47d) | 2010-03-19 → 2010-02-23 A (-24d) | 60d → 16d | 0% → 100% | 424d → none |  |  |
| 15221115 | Proc Lead Sheets 37-42 (BarCal) | 2010-03-22 → 2010-02-08 A (-42d) | 2010-06-14 → 2010-02-22 A (-112d) | 60d → 10d | 0% → 100% | 424d → none |  |  |
| 15221130 | Proc Lead Sheets 19-24 (BarCal) | 2010-06-15 → 2010-02-08 A (-127d) | 2010-09-08 → 2010-03-29 A (-163d) | 60d → 35d | 0% → 100% | 424d → none |  |  |
| 15221145 | Proc Lead Sheets 43-48 (BarCal) | 2010-09-09 → 2010-02-08 A (-213d) | 2010-12-03 → 2010-03-29 A (-249d) | 60d → 35d | 0% → 100% | 424d → none |  |  |
| 15221165 | Proc PMT's & Dividers (BarCal) | 2010-01-05 → 2010-03-01 A (+55d) | 2010-06-24 → 2010-03-19 A (-97d) | 120d → 15d | 0% → 100% | 557d → none |  |  |
| 15221003 | Prep Procur Packages for Si PM's/ Light guides 2010 (BarCal) | 2010-04-01 → 2010-03-25 A (-7d) | 2010-06-24 → 2011-04-29 A (+309d) | 60d → 274d | 0% → 100% | 278d → none |  | was named Prep Procur Packages for Si PM's/Winston Cones 2010 (BarCal); resources MECH ENG [400 h]; MECH DES [560 h] → MECH DES [560 h]; MECH ENG [400 h] |
| 15221008 | Prep Procur Packages Shipping Fixture/Support Frame 2011 (BarCal) | 2010-10-01 → 2010-06-21 A (-102d) | 2011-01-04 → 2010-09-30 A (-96d) | 60d → 72d | 0% → 100% | 539d → none |  |  |
| 15221004 | Prep Light Guide Procurement Package (BarCal) | 2010-06-25 → 2010-10-01 A (+98d) | 2010-09-17 → 2010-10-26 A (+39d) | 59d → 18d | 0% → 100% | 278d → none |  |  |
| 15221011E | FY11 Travel (BarCal) | 2010-10-01 A | 2011-09-30 A |  | 0% → 100% | 496d → none |  |  |
| 15221018N | Proc SciFi Mods P-3 FY11 December Delivery | 2010-10-01 A | 2010-12-30 → 2011-01-04 A (+5d) | 58d → 60d | 0% → 100% | 220d → none |  |  |
| 15221018P | Proc SciFi Mods P-3 FY11 January Delivery | 2010-10-01 A | 2011-01-31 A |  | 0% → 100% | 220d → none |  |  |
| 15221018Q | Proc SciFi Mods P-3 FY11 February Delivery | 2010-10-01 A | 2011-02-28 → 2011-02-25 A (-3d) | 97d → 96d | 0% → 100% | 220d → none |  |  |
| 15221018R | Proc SciFi Mods P-3 FY11 March Delivery | 2010-10-01 A | 2011-03-31 → 2011-03-25 A (-6d) | 120d → 116d | 0% → 100% | 220d → none |  | resources PROCUREMENT>$50K 69 NO ESCALATION; PROCUREMENT<$50K 60 NO ESCALATION → PROCUREMENT<$50K 60 NO ESCALATION; PROCUREMENT>$50K 69 NO ESCALATION |
| 15221018S | Proc SciFi Mods P-3 FY11 April Delivery | 2010-10-01 A | 2011-04-29 → 2011-05-27 A (+28d) | 141d → 161d | 0% → 100% | 220d → none |  |  |
| 15221018T | Proc SciFi Mods P-3 FY11 May Delivery | 2010-10-01 A | 2011-05-31 → 2011-06-20 A (+20d) | 162d → 176d | 0% → 100% | 220d → none |  |  |
| 15221018U | Proc SciFi Mods P-3 FY11 June Delivery | 2010-10-01 A | 2011-06-30 → 2011-07-26 A (+26d) | 184d → 201d | 0% → 100% | 220d → none |  | resources PROCUREMENT<$50K 60 NO ESCALATION; PROCUREMENT>$50K 69 NO ESCALATION → PROCUREMENT>$50K 69 NO ESCALATION; PROCUREMENT<$50K 60 NO ESCALATION |
| 15221018V | Proc SciFi Mods P-3 FY11 July Delivery | 2010-10-01 A | 2011-07-29 → 2011-07-26 A (-3d) | 204d → 201d | 0% → 100% | 220d → none |  | resources PROCUREMENT>$50K 69 NO ESCALATION; PROCUREMENT<$50K 60 NO ESCALATION → PROCUREMENT<$50K 60 NO ESCALATION; PROCUREMENT>$50K 69 NO ESCALATION |
| 15221018W | Proc SciFi Mods P-3 FY11 August Delivery | 2010-10-01 A | 2011-08-31 → 2011-08-15 A (-16d) | 227d → 215d | 0% → 100% | 220d → none |  |  |
| 15221018X | Proc SciFi Mods P-3 FY11 September Delivery | 2010-10-01 A | 2011-09-30 → 2011-10-15 A (+15d) | 248d → 258d | 0% → 100% | 220d → none |  |  |
| 15221160b | Mechanical Drawings (Prototype) Including Temperature Stability (BarCal) FY10 | 2010-06-25 → 2010-11-01 A (+129d) | 2010-09-30 → 2011-04-25 A (+207d) | 68d → 116d | 0% → 100% | 489d → none |  | was named Mechanical Drawings Including Temperature Stability (BarCal) (IPL 55221010 and 55221010c) FY10 |
| 15221157M | SiPM Contract Award (APP) | 2010-11-30 → 2010-11-22 A (-8d) | 2010-11-30 → 2010-11-22 A (-8d) |  | 0% → 100% | 312d → none |  |  |
| 15221158 | Vend Fab SiPMs Peg Point #1 - First Article | 2010-12-01 A | 2011-02-28 → 2011-03-25 A (+25d) | 56d → 75d | 0% → 100% | 334d → none | 9-110M FS+41d, 15221157M → 9-110M, 15221157M |  |
| 15221159 | Vend Fab SiPMs Peg Point #2 - Production Delivery #1 Qty 500 | 2010-12-01 A | 2011-07-29 → 2011-09-02 A (+35d) | 163d → 188d | 0% → 100% | 312d → none | 15221158M FS-101d → 15221158M FS-125d |  |
| 15221159a | Vend Fab SiPMs Peg Point #3 - Production Delivery #2 Qty 500 | 2010-12-01 A | 2011-08-31 → 2011-09-28 A (+28d) | 186d → 205d | 0% → 100% | 495d → none |  |  |
| 15221159b | Vend Fab SiPMs Peg Point #4 - Production Delivery #3 Qty 120 | 2010-12-01 A | 2011-09-30 → 2011-10-28 A (+28d) | 207d → 227d | 0% → 100% | 495d → none |  |  |
| 15221160a | SiPM Elec Preamp/Sum, Temp stab, Mech cooling FY10 | 2010-06-25 → 2011-01-03 A (+192d) | 2010-09-30 → 2012-02-13 A (+501d) | 68d → 276d | 0% → 100% | 437d → none |  | resources SUPPLIES & MATERIALS; ELEC DES [1065.33 h]; ELEC ENG [1065.33 h]; ELEC TECH [1065.33 h] → ELEC DES [1065.33 h]; ELEC ENG [1065.33 h]; ELEC TECH [1065.33 h]; SUPPLIES & MATERIALS |
| 15221173 | Proc Light Guides (BarCal) | 2010-09-20 → 2011-01-04 A (+106d) | 2011-08-09 → 2011-01-24 A (-197d) | 220d → 14d | 0% → 100% | 278d → none |  |  |
| 15221006 | FY11 Engineering Support for fabrication (BarCal) | 2011-01-05 A | 2011-09-30 A |  | 0% → 100% | 115d → none |  | resources MECH DES [120 h]; MECH ENG [120 h] → MECH ENG [120 h]; MECH DES [120 h] |
| 15221147 | Drawings Light Guides (BarCal) | 2011-01-05 A | 2011-06-01 → 2011-07-25 A (+54d) | 103d → 140d | 0% → 100% | 20d → none |  | was named Drawings Winston Cones (BarCal) |

| ID | Task | Start | Finish | Duration | Complete | Total float | Predecessors | Other |
| --- | --- | --- | --- | --- | --- | --- | --- | --- |
| 15221158b | SiPM First Article Test set up | 2011-02-02 → 2011-02-01 A (-1d) | 2011-03-01 → 2011-02-28 A (-1d) | 19d → 18d | 0% → 100% | 356d → none |  |  |
| 15221158a | SiPM First Article Testing | 2011-01-04 → 2011-03-01 A (+56d) | 2011-05-02 → 2011-04-25 A (-7d) | 83d → 40d | 0% → 100% | 312d → none | 15221157M FS+19d → 15221158, 15221157M FS+19d |  |
| 15221158M | SiPM Notice To Begin Production | 2011-05-03 → 2011-04-25 A (-8d) | 2011-05-03 → 2011-04-25 A (-8d) |  | 0% → 100% | 312d → none |  |  |
| 15221160ab | SiPM Elec Preamp/Sum, Temp stab, Mech cooling FY11 Part A | 2010-10-01 → 2011-06-30 A (+272d) | 2010-12-15 → 2012-11-12 A (+698d) | 52d → 343d | 0% → 100% | 437d → none | 15221160a → 15221160a FS-60d | resources ELEC ENG [814.67 h]; ELEC TECH [814.67 h]; MECH ENG [225.33 h]; PROCUREMENT<$50K 60; SUPPLIES & MATERIALS; ELEC DES [814.67 h] → ELEC DES [814.67 h]; ELEC ENG [814.67 h]; ELEC TECH [814.67 h]; MECH ENG [225.33 h]; PROCUREMENT<$50K 60; SUPPLIES & MATERIALS |
| 15221160ba | SiPM production testing FY11 | 2011-08-01 → 2011-07-18 A (-14d) | 2011-09-30 → 2012-07-09 A (+283d) | 44d → 242.4d | 0% → 100% | 312d → none | 15221159 → 15221159 FS-30d | resources ELEC TECH [159.17 h]; MECH TECH [159.17 h] → MECH TECH [159.17 h]; ELEC TECH [159.17 h] |
| 15221160baa | SiPM production testing FY12 | 2011-10-03 → 2011-07-18 A (-77d) | 2012-06-29 → 2012-07-09 A (+10d) | 183d → 243d | 0% → 100% | 312d → none | 15221160ba → 15221160ba FS-180d |  |
| 15221160bb | SiPM production testing set up (materials) | 2011-08-01 → 2011-07-25 A (-7d) | 2012-06-29 → 2012-06-11 A (-18d) | 227d → 218d | 0% → 100% | 312d → none | 15221159 → 15221159 FS-30d |  |
| 15221007 | Prepare procurement packages for assembly tooling | 2011-10-03 → 2011-08-01 A (-63d) | 2012-01-31 → 2012-01-16 A (-15d) | 78d → 111d | 0% → 100% | 273d → none | 9-120M → 9-120M FS-25d |  |
| 15221020 | Completion of BCAL assembly work in factory, exchange rate coverage | 2011-08-01 A | 2012-05-31 → 2011-10-24 A (-220d) | 207d → 60d | 0% → 100% | 78d → none |  |  |
| 15221025 | Fabrication of matrix #49 | 2011-08-01 A | 2012-05-31 → 2011-11-30 A (-183d) | 207d → 85d | 0% → 100% | 58d → none |  |  |
| 15221030 | Machining and shipping of matrix #49 | 2011-08-01 A | 2012-06-29 → 2011-12-19 A (-193d) | 227d → 98d | 0% → 100% | 58d → none |  |  |
| 15221155b | Light Tight Boxes (BarCal) | 2012-02-01 → 2011-08-01 A (-184d) | 2012-05-30 → 2012-12-17 A (+201d) | 84d → 370d | 0% → 100% | 294d → none | 9-120M FS+78d, 15221003 → 15221003, 9-120M FS-22d |  |
| 15221180 | Proc Supprt Struct and assy tooling (BarCal) Part A | 2012-02-01 → 2011-08-01 A (-184d) | 2012-06-29 → 2012-10-15 A (+108d) | 105d → 302d | 0% → 100% | 273d → none | 15221008, 15221007, 9-120M → 9-120M FS-20d, 15221007 FS-100d, 15221008 |  |
| 15221012E | FY12 Travel (BarCal) | 2011-10-03 A | 2012-09-28 A |  | 0% → 100% | 496d → none |  |  |
| 15221150 | Proc Light Guides First Article (BarCal) | 2011-08-01 → 2011-10-17 A (+77d) | 2011-09-30 → 2011-12-19 A (+80d) |  | 0% → 100% | 20d → none | 15221003, 15221147 FS+41d → 15221147 FS+64d, 15221003 | was named Proc Winston Cones First Article (Per CR12-017 This is Part of Peg Point #1) |
| 15221155 | Vend Fab Light Guides (WC) Peg Point # 1 - Materials | 2011-10-31 → 2011-10-17 A (-14d) | 2012-01-31 → 2012-01-03 A (-28d) | 58d → 49d | 0% → 100% | 20d → none | 9-110M FS+60d, 15221003, 15221150 FS+20d → 9-110M FS+60d, 15221003, 15221150 FS-44d |  |
| 15221156 | Vend Fab Light Guides (WC) Peg Point # 2 - First Article Delivery | 2011-10-31 → 2011-10-17 A (-14d) | 2012-01-31 → 2012-02-09 A (+9d) | 58d → 75d | 0% → 100% | 20d → none |  |  |
| 15221156a | Vend Fab Light Guides (WC) Peg Point # 3 - 1st Production Delivery | 2011-10-31 → 2011-10-17 A (-14d) | 2012-03-30 → 2012-10-15 A (+199d) | 100d → 248d | 0% → 100% | 20d → none |  |  |
| 15221156b | Vend Fab Light Guides (WC) Peg Point # 4 -2nd Production Delivery | 2011-10-31 → 2011-10-17 A (-14d) | 2012-04-30 → 2012-11-12 A (+196d) | 121d → 268d | 0% → 100% | 20d → none |  |  |
| 15221156c | Vend Fab Light Guides (WC) Peg Point # 5 - 3rd Production Delivery | 2011-10-31 → 2011-10-17 A (-14d) | 2012-05-31 → 2012-11-12 A (+165d) | 143d → 268d | 0% → 100% | 20d → none |  |  |
| 15221156d | Vend Fab Light Guides (WC) Peg Point # 6 - 4th Production Delivery | 2011-10-31 → 2011-10-17 A (-14d) | 2012-06-29 → 2012-12-17 A (+171d) | 163d → 306d | 0% → 100% | 20d → none |  |  |
| 15221156f | Vend Fab Light Guides (WC) Peg Point # 7 - 5th Production Delivery | 2011-10-31 → 2011-10-17 A (-14d) | 2012-06-29 → 2013-01-14 A (+199d) | 163d → 306d | 0% → 100% | 20d → none |  |  |
| 15221156g | Vend Fab Light Guides (WC) Peg Point # 8 - 6th Production Delivery | 2011-10-31 → 2011-10-17 A (-14d) | 2012-07-31 → 2013-01-14 A (+167d) | 185d → 328d | 0% → 100% | 20d → none |  |  |
| 15221156h | Vend Fab Light Guides (WC) Peg Point # 9 - 7th Production Delivery | 2011-10-31 → 2011-10-17 A (-14d) | 2012-07-31 → 2013-01-14 A (+167d) | 185d → 328d | 0% → 100% | 20d → none |  |  |
| 15221156j | Vend Fab Light Guides (WC) Peg Point # 10 - 8th Production Delivery | 2011-10-31 → 2011-10-17 A (-14d) | 2012-08-31 → 2013-01-14 A (+136d) | 208d → 347d | 0% → 100% | 20d → none |  |  |
| 15221156k | Vend Fab Light Guides (WC) Peg Point # 11 - 9th Production Delivery | 2011-10-31 → 2011-10-17 A (-14d) | 2012-08-31 → 2013-02-11 A (+164d) | 208d → 347d | 0% → 100% | 20d → none |  |  |
| 15221156n | Vend Fab Light Guides (WC) Peg Point # 12 - 10th Production Delivery | 2011-10-31 → 2011-10-17 A (-14d) | 2012-09-28 → 2013-02-11 A (+136d) | 227d → 358d | 0% → 100% | 20d → none |  |  |
| 15221055 | Fabricate BCAL Calibration System (BarCal) Labor FY11 | 2011-05-02 → 2011-12-01 A (+213d) | 2011-09-30 → 2013-01-14 A (+472d) | 107d → 283d | 0% → 100% | 100d → none | 1152055, 9-110M FS+141d → 9-110M FS+141d, 1152055, 9-120M FS+45d |  |
| 15221055a | Fabricate BCAL Calibration System (BarCal) Labor FY12 | 2011-10-03 → 2011-12-01 A (+59d) | 2012-04-30 → 2013-02-04 A (+280d) | 141d → 283d | 0% → 100% | 100d → none | 15221055 → 15221055 FS-300d |  |
| 15221055b | Fabricate BCAL Calibration System (BarCal) Procurement | 2011-05-02 → 2011-12-01 A (+213d) | 2012-04-30 → 2013-01-14 A (+259d) | 248d → 283d | 0% → 100% | 100d → none | 1152055, 9-110M FS+141d → 1152055, 9-120M FS+45d |  |
| 15221009 | FY12 Engineering Support for Fabrication (BarCal) | 2012-02-23 A | 2012-08-20 A |  | 0% → 100% | 22d → none |  |  |
| 15221160aba | SiPM Elec Preamp/Sum, Temp stab, Mech cooling FY11 Part B | 2010-10-01 → 2012-10-01 A (+731d) | 2010-12-15 → 2013-01-14 A (+761d) | 52d → 69d | 0% → 100% | 437d → none | 15221160a → 15221160a FS-60d |  |
| 15221161a | SiPM cool light guide grating | 2012-10-01 → 2012-10-14 A (+13d) | 2013-06-03 → 2012-12-16 A (-169d) | 165d → 44d | 0% → 100% | 213d → none | 9-130M, 15221160aba, 15221160ab → 15221160ab FS-60d, 9-130M, 15221160aba FS-60d |  |
| 15221161b | SiPM cool SiPM mount | 2012-10-01 → 2012-11-03 A (+33d) | 2013-06-03 → 2012-11-19 A (-196d) | 165d → 11d | 0% → 100% | 406d → none | 9-130M, 15221160aba, 15221160ab → 15221160aba FS-60d, 9-130M FS+24d, 15221160ab FS-60d |  |
| 15221161 | SiPM cool Procurement labor FY12 (FY13 @ 15221161s) | 2012-01-11 → 2012-11-05 A (+299d) | 2012-09-28 → 2013-01-14 A (+108d) | 183d → 34d | 0% → 100% | 548d → none | 15221160aba, 15221160ab, 9-120M FS+64d → 15221160ab FS-80d, 9-130M, 15221160aba FS-80d, 9-120M FS+144d |  |
| 15221161c | SiPM cool Cooling plate | 2012-10-01 → 2012-11-05 A (+35d) | 2013-06-03 → 2013-01-14 A (-140d) | 165d → 29d | 0% → 100% | 406d → none | 15221160aba, 9-130M, 15221160ab → 15221160ab FS-60d, 15221160aba FS-60d, 9-130M FS+31d | resources PROCUREMENT>$50K 69; PROCUREMENT<$50K 60 → PROCUREMENT<$50K 60; PROCUREMENT>$50K 69 |
| 15221161f | SiPM cool Electronic heat removal | 2012-10-01 → 2012-11-05 A (+35d) | 2013-05-29 → 2012-12-17 A (-163d) | 162d → 29d | 0% → 100% | 409d → none | 9-130M, 15221160aba, 15221160ab → 9-130M FS+24d, 15221160ab FS-60d, 15221160aba FS-60d |  |
| 15221161h | SiPM cool light covers | 2012-10-01 → 2012-11-05 A (+35d) | 2013-06-03 → 2012-12-16 A (-169d) | 165d → 29d | 0% → 100% | 406d → none | 15221160aba, 15221160ab, 9-130M → 9-130M FS+24d, 15221160aba FS-60d, 15221160ab FS-60d |  |
| 15221161j | SiPM cool cable supports/layout | 2012-10-01 → 2012-11-05 A (+35d) | 2013-06-03 → 2012-12-16 A (-169d) | 165d → 29d | 0% → 100% | 406d → none | 15221160aba, 9-130M, 15221160ab → 9-130M FS+24d, 15221160ab FS-60d, 15221160aba FS-60d |  |
| 15221161k | SiPM cool cooling tubes support/layout | 2012-10-01 → 2012-11-05 A (+35d) | 2013-06-03 → 2013-02-11 A (-112d) | 165d → 29d | 0% → 100% | 406d → none | 15221160ab, 15221160aba, 9-130M → 15221160ab FS-60d, 9-130M FS+24d, 15221160aba FS-60d |  |
| 15221161n | SiPM cool mechanical support | 2012-10-01 → 2012-11-05 A (+35d) | 2013-06-03 → 2012-12-16 A (-169d) | 165d → 29d | 0% → 100% | 406d → none | 9-130M, 15221160ab, 15221160aba → 15221160aba FS-60d, 15221160ab FS-60d, 9-130M FS+24d |  |
| 15221161s | SiPM cool Procurement labor FY13 (FY12 @ 15221161) | 2012-10-01 → 2012-11-05 A (+35d) | 2012-10-31 → 2013-01-14 A (+75d) | 23d → 34d | 0% → 100% | 548d → none | 15221161 → 15221161 FS-69d |  |
| 15221057 | Installation BCAL Calibration System (BarCal) FY12 | 2012-08-03 → 2013-01-07 A (+157d) | 2012-09-28 → 2013-07-15 A (+290d) |  | 0% → 100% | 203d → none | 9-120M FS+207d, 15221055b FS+60d, 15221055a FS+60d → 15221055a FS-20d, 15221055b |  |
| 15221057a | Installation BCAL Calibration System (BarCal) FY13 | 2012-10-01 → 2013-01-07 A (+98d) | 2012-12-04 → 2013-07-15 A (+223d) |  | 0% → 100% | 203d → none | 15221057 → 15221057 FS-90d |  |
| 15221057b | Installation BCAL Calibration System (BarCal) Procurements | 2012-08-03 → 2013-01-07 A (+157d) | 2012-12-04 → 2013-08-30 A (+269d) |  | 0% → 100% | 203d → none | 15221055b FS+60d, 9-120M FS+207d, 15221055a FS+60d → 15221055b, 15221055a FS-20d |  |
| 15221155a | Mechanical Support (BarCal) | 2012-02-01 → 2013-01-28 A (+362d) | 2012-05-30 → 2013-02-11 A (+257d) |  | 0% → 100% | 294d → none | 15221003, 9-120M FS+78d → 15221003, 9-120M FS+195d |  |
| 15221180a | Proc Supprt Struct and assy tooling (BarCal) Part B | 2012-02-01 → 2013-03-01 A (+394d) | 2012-06-29 → 2013-06-17 A (+353d) | 105d → 120d | 0% → 100% | 273d → none | 9-120M, 15221007, 15221008 → 9-120M FS-20d, 15221007 FS+280d, 15221008, 9-130M FS+81d |  |
| 15221182 | Procure BCAL SiPm chillers | 2013-01-03 → 2013-03-04 A (+60d) | 2013-04-26 → 2013-06-17 A (+52d) |  | 0% → 100% | 108d → none | 9-130M FS+60d → 9-130M FS+110d |  |
| 15221315 | Re-Baseline Actuals Adjustment | 2013-08-30 A | 2013-08-30 A |  | 0% → 100% | 20d → none | 9-130M FS+227d → none |  |
| 25221000 | Regina contract Decommissioning | 2013-09-03 A | 2013-10-31 → 2013-10-21 A (-10d) |  | 0% → 100% | 224d → none |  | resources PROCUREMENT>$50K 69 NO ESCALATION → PROCUREMENT<$50K 60 NO ESCALATION FY14 |
| 25221005 | Procured Labor (Designer) | 2013-09-03 A | 2013-09-30 → 2013-12-02 (+63d) |  | 0% → 50% | 247d → 204d |  |  |
| 25221010 | Athens contract Completion | 2013-09-03 A | 2013-10-31 → 2013-10-21 A (-10d) |  | 0% → 100% | 224d → none |  | resources PROCUREMENT>$50K 69 NO ESCALATION → PROCUREMENT<$50K 60 NO ESCALATION FY14 |
| 25221010LOE | Forklift Rental (ESB) | 2013-09-03 A | 2013-10-31 A |  | 0% → 100% | 224d → none |  |  |
| 25221057b | Construction BCAL Pulsing System (BarCal) Labor FY13 | 2013-09-03 A | 2013-09-30 → 2013-11-27 (+58d) | 20d → 62d | 0% → 25% |  |  |  |
| 25221057ba | Construction BCAL Pulsing System (BarCal) Labor FY14 | 2013-10-01 → 2013-09-03 A (-28d) |  |  | 0% → 25% |  | 9-130M FS+228d, 25221057b → 25221057b FS-60d |  |
| 25221057c | Construction BCAL Pulsing System (BarCal) Materials FY13 | 2013-09-03 A | 2013-09-30 → 2013-10-21 A (+21d) | 20d → 62d | 0% → 100% | 194d → none |  | was named Construction BCAL Pulsing System (BarCal) Expenses FY13 |
| 25221057ca | Construction BCAL Pulsing System (BarCal) Expenses FY14 | 2013-10-01 → 2013-09-03 A (-28d) | 2013-11-27 → 2013-10-21 A (-37d) |  | 0% → 100% | 194d → none | 9-130M FS+228d, 25221057c → 25221057c FS-45d |  |
| 25221320 | Procure BCAL cooling manifold | 2013-09-03 A | 2013-10-03 → 2013-11-05 (+33d) |  | 0% → 90% | 29d → 54d |  |  |
| 25221060 | Setup and Testing of BCAL Pulsing System FY13 | 2013-09-03 → 2013-12-05 (+93d) | 2013-09-30 → 2014-03-06 (+157d) | 20d → 57d |  | 54d → 20d | 9-130M FS+228d → 9-140M FS+45d, 9-130M FS+228d |  |
| 25221060a | Setup and Testing of BCAL Pulsing System FY14 | 2013-10-01 → 2013-12-05 (+65d) | 2013-11-27 → 2014-03-06 (+99d) | 42d → 57d |  | 54d → 20d | 25221060, 9-130M FS+228d → 25221060 FS-57d |  |
| 15222009E | FY09 Travel (FWD CAL) | 2009-01-02 A | 2009-09-30 A |  | 0% → 100% | 317d → none |  |  |
| 15222001 | Prepare Procurements/Fabrication Packages 2009 (FWD CAL) | 2009-07-01 → 2009-07-03 A (+2d) | 2009-09-30 → 2010-02-25 A (+148d) | 64d → 158d | 0% → 100% | 802d → none |  |  |
| 15222010E | FY10 Travel (FWD CAL) | 2009-10-01 A | 2010-09-30 A |  | 0% → 100% | 317d → none |  |  |
| 15222003 | FY10 Engineering Support for Fabrication (FWD CAL) | 2009-10-01 → 2009-11-02 A (+32d) | 2010-04-15 → 2010-09-30 A (+168d) | 131d → 226d | 0% → 100% | 726d → none |  |  |
| 15222025 | Setup Divider Constrctn (FWD CAL) (Frozen by CR10-007) | 2009-10-01 → 2009-12-14 A (+74d) | 2009-11-30 → 2009-12-21 A (+21d) | 41d → 5d | 0% → 100% | 207d → none |  |  |
| 15222045 | Setup Procedure & Glue LG to PMT's (FWD CAL) (Frozen by CR10-007) | 2009-11-12 → 2009-12-14 A (+32d) | 2009-11-25 → 2009-12-21 A (+26d) | 10d → 5d | 0% → 100% | 787d → none |  |  |
| 15222050 | Proc Magnetic Shields (FWD CAL) (Frozen by CR10-007) | 2009-10-01 → 2009-12-14 A (+74d) | 2009-11-04 → 2009-12-21 A (+47d) | 25d → 5d | 0% → 100% | 802d → none |  |  |
| 15222110 | Reverse Entry Per CR10-007 | 2009-12-07 → 2009-12-14 A (+7d) | 2009-12-07 → 2009-12-21 A (+14d) | 1d → 5d | 0% → 100% | 202d → none |  | resources ELEC ENG [-328 h]; VISTNG USERS [-84 h]; PROCUREMENT<$50K 60; CONTRB UNIV LBR [-50.4 h] → VISTNG USERS [-84 h]; PROCUREMENT<$50K 60; CONTRB UNIV LBR [-50.4 h]; ELEC ENG [-328 h] |
| 15222015 | Proc Replacement PMTs (FWD CAL) | 2009-07-01 → 2010-02-01 A (+215d) | 2010-01-12 → 2010-11-22 A (+314d) | 130d → 207d | 0% → 100% | 761d → none |  |  |
| 15222002 | Prepare Procurements/Fabrication Packages 2010 (FWD CAL) | 2010-07-01 → 2010-02-08 A (-143d) | 2010-09-30 → 2011-05-23 A (+235d) | 64d → 322d | 0% → 100% | 609d → none |  |  |

| ID | Task | Start | Finish | Duration | Complete | Total float | Predecessors | Other |
| --- | --- | --- | --- | --- | --- | --- | --- | --- |
| 15222011E | FY11 Travel (FWD CAL) | 2010-10-01 A | 2011-09-30 A |  | 0% → 100% | 317d → none |  |  |
| 15222055 | Proc Pb Glass Insert PR | 2011-02-01 → 2011-01-04 A (-28d) | 2011-05-02 → 2011-01-24 A (-98d) | 64d → 14d | 0% → 100% | 55d → none |  |  |
| 15222060 | Proc Pb Glass Insert | 2011-05-03 → 2011-01-04 A (-119d) | 2012-05-31 → 2011-01-24 A (-493d) | 269d → 14d | 0% → 100% | 55d → none |  |  |
| 15222007 | FY11 Engineering Support for Fabrication (FWD CAL) | 2011-01-05 A | 2011-09-30 A |  | 0% → 100% | 150d → none |  |  |
| 15222004 | Prep Support Struc Procurement Package 2011(FWD CAL) | 2011-06-30 A | 2011-09-30 A |  | 0% → 100% | 426d → none |  |  |
| 15222012E | FY12 Travel (FWD CAL) | 2011-10-03 A | 2011-12-30 A |  | 0% → 100% | 317d → none |  |  |
| 15222080 | Fabricate FCAL Monitoring System (FWD CAL) | 2012-01-05 → 2011-12-01 A (-35d) | 2012-04-05 → 2013-05-13 A (+403d) | 64d → 283d | 0% → 100% | 48d → none |  |  |
| 15222005 | FY12 Engineering Support for Fabrication (FWD CAL) | 2012-04-16 A | 2012-09-28 A |  | 0% → 100% | 20d → none | 9-120M FS+130d, 15222007 → 15222007 FS-20d, 9-120M FS+130d |  |
| 15222006 | FY13 Engineering Support for Fabrication (FWD CAL) | 2012-10-01 A | 2013-07-29 A |  | 0% → 100% | 20d → none | 15222005 → 15222005, 9-130M |  |
| 15222100 | Stacking of Blocks (FWD CAL) FY12 | 2012-07-23 → 2013-01-07 A (+168d) | 2012-09-28 → 2013-01-28 A (+122d) | 49d → 233d | 0% → 100% | 20d → none | 15222060, 15222006 FS-253d → 15222006 FS-155d, 15222060 |  |
| 15222100a | Stacking of Blocks (FWD CAL) FY13 | 2012-10-01 → 2013-01-07 A (+98d) | 2013-07-29 → 2013-06-17 A (-42d) | 204d → 233d | 0% → 100% | 20d → none | 15222100 → 15222100 FS-233d |  |
| 15222105 | Assy of Single Channel FCal Detector (FWD CAL) | 2013-01-03 → 2013-01-07 A (+4d) | 2013-04-05 → 2013-06-17 A (+73d) | 65d → 233d | 0% → 100% | 24d → none | 15222050, 195222285, 15222045, 9-130M FS+60d, 15222015, 15222080 FS+159d → 195222285 FS-110d, 15222015, 15222045, 15222050, 9-130M FS+30d |  |
| 15222115 | Re-Baseline Actuals Adjustment | 2013-08-30 A | 2013-08-30 A |  | 0% → 100% | 20d → none | 9-130M FS+227d → none |  |
| 25222085 | Fabricate and Install Monitoring Panes (FCAL) FY13 | 2013-09-03 A | 2013-09-30 → 2014-01-16 (+108d) |  | 0% → 80% | 79d → 122d |  |  |
| 25222085a | Fabricate and Install Monitoring Panes (FCAL) FY14 | 2013-10-01 → 2013-09-03 A (-28d) |  |  | 0% → 80% | 79d → 122d | 25222085, 9-130M FS+228d → 25222085 FS-80d |  |
| 25222090 | Fabricate and Install Monitoring Panes (FCAL) (Previously Obligated) | 2013-09-03 A | 2014-01-16 → 2013-09-23 A (-115d) |  | 0% → 100% | 79d → none |  |  |
| 3 | **1.5.2.3 PARTICLE ID** | 2010-08-02 → 2010-06-30 (-33d) |  |  |  |  |  |  |
| 1 | **1.5.2.3.1 TIME OF FLIGHT** | 2010-08-02 → 2010-06-30 (-33d) |  |  |  |  |  |  |
| 15231019 | Proc First Article PMTs (TOF) | 2010-08-02 → 2010-06-30 A (-33d) | 2010-09-30 → 2010-10-01 A (+1d) | 43d → 66d | 0% → 100% | 743d → none |  |  |
| 15231011E | FY11 Travel (TOF) | 2010-10-01 A | 2011-09-30 A |  | 0% → 100% | 128d → none |  |  |
| 15231001 | Prepare Procurements/Fabrication Packages 2011 (TOF) | 2011-06-01 → 2011-07-01 A (+30d) | 2011-09-30 A | 86d → 64d | 0% → 100% | 288d → none |  |  |
| 15231001a | Prepare Procurements/Fabrication Packages 2012 (TOF) | 2011-10-03 A | 2012-04-10 A |  | 0% → 100% | 288d → none |  | resources MECH DES [760 h]; MECH ENG [40 h] → MECH ENG [40 h]; MECH DES [760 h] |
| 15231012E | FY12 Travel (TOF) | 2011-10-03 A | 2012-09-28 A |  | 0% → 100% | 128d → none |  |  |
| 15231002 | Engineering Support for Testing 2012 | 2012-05-29 → 2012-05-14 A (-15d) | 2012-08-28 → 2013-02-11 A (+167d) | 65d → 156d | 0% → 100% | 270d → none |  | resources MECH DES [80 h]; MECH ENG [80 h] → MECH ENG [80 h]; MECH DES [80 h] |
| 15231020 | Proc PMTs (TOF) | 2012-04-05 → 2012-06-02 A (+58d) | 2012-09-28 → 2013-02-11 A (+136d) | 124d → 194d | 0% → 100% | 248d → none | 9-120M FS+123d, 12323040M, 15231019 FF → 12323040M, 9-120M FS+163d, 15231019 |  |
| 15231025 | Proc Dividers (TOF) | 2012-04-05 → 2012-06-02 A (+58d) | 2012-09-28 → 2013-02-11 A (+136d) | 124d → 194d | 0% → 100% | 248d → none | 9-120M FS+123d, 12323040M → 9-120M FS+163d, 12323040M |  |
| 15231075 | FSU - Scintillator Procurement Part E | 2012-09-04 A | 2013-07-31 → 2013-03-11 A (-142d) |  | 0% → 100% | 20d → none |  |  |
| 15231080 | FSU - Light Guide Material Procurement | 2012-09-04 A | 2013-07-31 → 2013-03-11 A (-142d) |  | 0% → 100% | 20d → none |  |  |
| 15231090 | FSU - Proc Supplies (TOF) Part B | 2012-09-04 A | 2013-07-31 → 2013-08-30 A (+30d) |  | 0% → 100% | 20d → none |  |  |
| 15231093 | FSU - Jig Construction | 2012-09-04 A | 2012-11-30 → 2013-08-15 A (+258d) | 62d → 82d | 0% → 100% | 20d → none |  |  |
| 15231095 | FSU - Polishing and Gluing of First 30 Units | 2012-09-04 A | 2013-05-31 → 2013-06-17 A (+17d) |  | 0% → 100% | 20d → none |  |  |
| 15231100 | FSU - Wrapping of First 30 Units | 2012-09-04 A | 2013-05-31 → 2013-07-15 A (+45d) |  | 0% → 100% | 20d → none |  |  |
| 15231105 | FSU - Mount PMT and Testing of First 30 Units | 2012-09-04 A | 2013-05-31 → 2013-08-30 A (+91d) |  | 0% → 100% | 20d → none |  |  |
| 15231110 | FSU - Polishing and Gluing of Second 30 Units | 2012-09-04 A | 2013-08-30 → 2013-07-15 A (-46d) |  | 0% → 100% | 20d → none |  |  |
| 15231115 | FSU - Wrapping of Second 30 Units | 2012-09-04 A | 2013-08-30 A |  | 0% → 100% | 20d → none |  |  |
| 15231120 | FSU - Mount PMT and Testing of Second 30 Units | 2012-09-04 A | 2013-08-30 A |  | 0% → 100% | 20d → none |  |  |
| 15231015 | FSU - Proc Supplies (TOF) Part A | 2011-11-02 → 2012-09-07 A (+310d) | 2011-12-01 → 2013-06-17 A (+564d) | 20d → 222d | 0% → 100% | 453d → none | 9-120M FS+22d, 12323040M → 9-120M FS+205d, 12323040M |  |
| 15231055 | FSU - Scintillator Procurement Part A | 2012-08-31 → 2012-09-07 A (+7d) | 2012-08-31 → 2012-12-17 A (+108d) | 1d → 222d | 0% → 100% | 267d → none |  |  |
| 15231060 | FSU - Scintillator Procurement Part B | 2012-07-20 → 2012-09-07 A (+49d) | 2012-08-31 → 2013-03-11 A (+192d) | 31d → 222d | 0% → 100% | 267d → none |  |  |
| 15231065 | FSU - Scintillator Procurement Part C | 2012-07-27 → 2012-09-07 A (+42d) | 2012-08-31 → 2013-03-11 A (+192d) | 26d → 222d | 0% → 100% | 267d → none |  |  |
| 15231070 | FSU - Scintillator Procurement Part D | 2012-07-11 → 2012-09-07 A (+58d) | 2012-08-31 → 2013-03-11 A (+192d) | 38d → 222d | 0% → 100% | 267d → none |  |  |
| 15231013E | FY13 Travel (TOF) | 2012-10-01 A | 2013-03-29 A |  | 0% → 100% | 128d → none |  |  |
| 15231030 | Proc Magnetic Shield Boxes (TOF) | 2013-01-03 → 2013-07-01 A (+179d) | 2013-04-26 → 2013-08-30 A (+126d) |  | 0% → 100% | 108d → none | 9-130M FS+60d, 15231001a, 12323040M → 9-130M FS+165d, 15231001a, 12323040M | was named Proc Magnetic Shields (TOF) |
| 15231045 | Proc Supprt Struct (TOF) | 2013-02-01 → 2013-07-01 A (+150d) | 2013-03-29 → 2013-08-30 A (+154d) |  | 0% → 100% | 128d → none | 9-130M FS+80d, 9-120M FS+22d, 15231001a, 12323040M → 9-130M FS+165d, 12323040M, 15231001a |  |
| 15231150 | Re-Baseline Actuals Adjustment | 2013-08-30 A | 2013-08-30 A |  | 0% → 100% | 20d → none | 9-130M FS+227d → none |  |
| 25231010 | FSU contract support and supervision FY13 | 2013-09-03 A | 2013-09-30 A | 20d → 57d | 0% → 100% | 269d → none |  |  |
| 25231030 | Proc Magnetic Shields (TOF) | 2013-11-01 → 2013-09-03 A (-59d) | 2013-12-20 → 2013-10-21 A (-60d) |  | 0% → 100% | 84d → none | 9-140M FS+23d → 9-140M |  |
| 25231085 | FSU - Initial wrapping and fitup | 2013-09-03 A | 2013-09-30 → 2013-09-23 A (-7d) |  | 0% → 100% | 111d → none |  | resources PROCUREMENT<$50K 60 NO ESCALATION; PROCUREMENT>$50K 69 NO ESCALATION → PROCUREMENT>$50K 69 NO ESCALATION |
| 25231090 | FSU - Proc Supplies (TOF) | 2013-09-03 A | 2013-09-30 → 2013-12-02 (+63d) |  | 0% → 60% | 111d → 68d |  |  |
| 25231105 | FSU - Mount PMT and Testing of First 30 Units | 2013-09-03 A | 2013-09-30 → 2013-09-23 A (-7d) |  | 0% → 100% | 69d → none |  |  |
| 25231115 | FSU - Wrapping of Second 30 Units | 2013-09-03 A | 2013-09-30 → 2013-09-23 A (-7d) |  | 0% → 100% | 69d → none |  |  |
| 25231120 | FSU - Mount PMT and Testing of Second 30 Units | 2013-09-03 A | 2013-09-30 → 2013-09-23 A (-7d) |  | 0% → 100% | 69d → none |  |  |
| 25231125 | FSU - Polishing and Gluing of Third 30 Units | 2013-09-03 A | 2013-10-31 → 2013-09-23 A (-38d) |  | 0% → 100% | 69d → none |  |  |
| 25231130 | FSU - Wrapping of Third 30 Units | 2013-09-03 A | 2013-10-31 → 2013-12-05 (+35d) |  | 0% → 70% | 69d → 132d |  |  |
| 25231135 | FSU - Mount PMT and Testing of Third 30 Units | 2013-09-03 A | 2013-10-31 → 2013-09-23 A (-38d) |  | 0% → 100% | 69d → none |  |  |
| 25231140 | FSU - Construction Manager | 2013-09-03 A |  |  | 0% → 69% | 69d → 112d |  |  |
| 25231145 | FSU - Shipping of TOF | 2013-09-03 A |  |  |  |  |  |  |
| 25231010a | FSU contract support and supervision FY14 | 2013-10-01 A |  | 42d → 37d | 0% → 49% |  | 25231010, 9-130M FS+228d → 25231010 |  |
| 25231045 | Proc Supprt Struct (TOF) | 2013-11-13 → 2013-10-21 A (-23d) |  |  | 0% → 8% |  | 9-140M FS+31d, 9-130M FS+228d → 9-140M |  |
| 3 | **1.5.3 COMPUTING** |  | 2014-12-11 → 2014-09-30 (-72d) |  |  |  |  |  |
| 1 | **1.5.3.1 DAQ** |  | 2014-12-11 → 2014-09-30 (-72d) |  |  |  |  |  |
| 15311011E | FY11 Travel (DAQ) | 2010-10-01 A | 2011-09-30 A |  | 0% → 100% | 189d → none |  |  |
| 1531005 | Proc Single Board Computing PR (DAQ) | 2011-04-01 → 2011-03-01 A (-31d) | 2011-06-01 → 2011-03-25 A (-68d) | 43d → 19d | 0% → 100% | 314d → none |  |  |
| 1531180 | Proc embedded computers for controls PR | 2011-04-01 → 2011-03-01 A (-31d) | 2011-05-02 → 2011-03-25 A (-38d) | 22d → 19d | 0% → 100% | 241d → none |  |  |
| 1531200 | Proc PLC comm Modules PR | 2011-02-01 → 2011-03-01 A (+28d) | 2011-03-03 → 2011-03-14 A (+11d) | 22d → 10d | 0% → 100% | 303d → none |  |  |
| 1531230 | Proc PLC Controller PR | 2011-02-01 → 2011-03-01 A (+28d) | 2011-03-03 → 2011-03-14 A (+11d) | 22d → 10d | 0% → 100% | 231d → none |  |  |
| 1531205 | Proc PLC comm Modules | 2011-03-04 → 2011-03-15 A (+11d) | 2011-06-01 → 2011-03-25 A (-68d) | 63d → 9d | 0% → 100% | 303d → none |  |  |
| 1531235 | Proc PLC Controller | 2011-03-04 → 2011-03-15 A (+11d) | 2011-05-02 → 2011-03-25 A (-38d) | 42d → 9d | 0% → 100% | 231d → none |  |  |
| 1531005a | Proc Single Board Computing First items (DAQ) | 2011-06-02 → 2011-03-25 A (-69d) | 2011-09-01 → 2011-06-20 A (-73d) | 65d → 61d | 0% → 100% | 314d → none |  |  |
| 1531185 | Proc embedded computers for controls | 2011-05-03 → 2011-03-25 A (-39d) | 2011-08-29 → 2011-08-31 A (+2d) | 83d → 112d | 0% → 100% | 241d → none |  |  |

| ID | Task | Start | Finish | Duration | Complete | Total float | Predecessors | Other |
| --- | --- | --- | --- | --- | --- | --- | --- | --- |
| 1531170 | Software Licenses and Fees FY11 | 2011-01-04 → 2011-04-02 A (+88d) | 2011-09-30 → 2011-08-31 A (-30d) | 189d → 106d | 0% → 100% | 251d → none |  |  |
| 1531005b | Proc Single Board Computing Test First items (DAQ) FY11 | 2011-09-02 → 2011-06-01 A (-93d) | 2011-09-30 → 2011-07-25 A (-67d) | 20d → 38d | 0% → 100% | 314d → none |  |  |
| 1531005ba | Proc Single Board Computing Test First items (DAQ) FY12 | 2011-10-03 → 2011-06-01 A (-124d) | 2012-02-28 → 2011-07-25 A (-218d) | 97d → 38d | 0% → 100% | 314d → none |  |  |
| 1531240 | Install PLC Controller | 2011-05-03 → 2011-07-11 A (+69d) | 2011-07-01 → 2011-07-25 A (+24d) | 43d → 11d | 0% → 100% | 231d → none | 1531235 → 1531235 FS+100d |  |
| 1531055 | Proc UPS (DAQ) PR | 2012-05-01 → 2011-08-01 A (-274d) | 2012-06-29 → 2011-08-31 A (-303d) | 42d → 23d | 0% → 100% | 187d → none | 9-120M FS+141d → 9-120M |  |
| 1531080 | Proc Racks (DAQ) PR | 2011-08-01 → 2011-09-05 A (+35d) | 2011-09-30 → 2011-09-19 A (-11d) | 44d → 10d | 0% → 100% | 377d → none |  |  |
| 1531010 | Proc Large Network Switch (DAQ) PR | 2012-06-01 → 2011-10-03 A (-242d) | 2012-07-31 → 2011-10-17 A (-288d) | 42d → 11d | 0% → 100% | 167d → none |  |  |
| 1531015 | Proc Small Network Switch (DAQ) PR | 2012-01-03 → 2011-10-03 A (-92d) | 2012-03-01 → 2011-10-17 A (-136d) | 41d → 11d | 0% → 100% | 188d → none |  |  |
| 1531057 | Proc UPS (DAQ) | 2012-07-02 → 2011-10-03 A (-273d) | 2012-10-29 → 2012-01-16 A (-287d) | 85d → 67d | 0% → 100% | 187d → none |  | resources PROCUREMENT>$50K 69 NO ESCALATION FY13; PROCUREMENT<$50K 60 NO ESCALATION FY13 → PROCUREMENT<$50K 60 NO ESCALATION FY13; PROCUREMENT>$50K 69 NO ESCALATION FY13 |
| 1531082 | Proc Racks (DAQ) | 2011-10-03 A | 2012-01-31 → 2011-11-21 A (-71d) | 78d → 36d | 0% → 100% | 377d → none |  |  |
| 15311012E | FY12 Travel (DAQ) | 2011-10-03 A | 2012-09-28 A |  | 0% → 100% | 189d → none |  |  |
| 1531145 | Proc Net Switches for Controls PR FY12 | 2012-06-27 → 2011-10-03 A (-268d) | 2012-09-28 → 2011-10-17 A (-347d) | 67d → 11d | 0% → 100% | 65d → none | 9-120M FS+180d → 9-130M |  |
| 1531145a | Proc Net Switches for Controls PR FY13 | 2012-10-01 → 2011-10-03 A (-364d) | 2012-11-14 → 2011-10-17 A (-394d) | 33d → 11d | 0% → 100% | 65d → none |  |  |
| 1531175 | Software Licenses and Fees FY12 | 2011-10-03 A | 2012-09-25 → 2012-09-28 A (+3d) | 244d → 247d | 0% → 100% | 251d → none |  |  |
| 1531210 | Proc PLC Point I/O Chassis PR | 2011-10-03 A | 2011-10-31 → 2011-11-21 A (+21d) | 21d → 36d | 0% → 100% | 105d → none |  |  |
| 1531017 | Proc Small Network Switch (DAQ) Phase 1 | 2012-03-02 → 2011-11-01 A (-122d) | 2012-06-29 → 2011-11-21 A (-221d) | 84d → 15d | 0% → 100% | 188d → none | 1531015 → 1531015 FS+40d |  |
| 1531018 | Proc Small Network Switch (DAQ) Phase 2 | 2012-07-02 → 2011-11-01 A (-244d) | 2012-10-26 → 2011-11-21 A (-340d) | 84d → 15d | 0% → 100% | 188d → none |  |  |
| 1531150 | Proc Net Switches for Controls | 2012-11-15 → 2011-11-01 A (-380d) | 2013-02-25 → 2011-11-21 A (-462d) | 63d → 15d | 0% → 100% | 65d → none | 1531145a → 1531145a, 1531145 |  |
| 1531012 | Proc Large Network Switch (DAQ) | 2012-08-01 → 2011-11-07 A (-268d) | 2012-11-28 → 2011-11-23 A (-371d) | 83d → 13d | 0% → 100% | 167d → none | 1531010 → 1531010 FS+40d |  |
| 1531215 | Proc PLC Point I/O Chassis | 2011-11-01 → 2011-11-07 A (+6d) | 2012-01-30 → 2011-11-21 A (-70d) | 56d → 11d | 0% → 100% | 105d → none |  |  |
| 1531030 | Proc Online Computers (DAQ) PR | 2012-04-02 → 2012-01-02 A (-91d) | 2012-05-31 → 2012-01-16 A (-136d) | 43d → 9d | 0% → 100% | 161d → none |  | resources SCIENTIST [40 h]; COMP SCIENT [40 h] → COMP SCIENT [40 h]; SCIENTIST [40 h] |
| 1531220 | Proc PLC Point I/O Modules PR | 2012-01-31 → 2012-01-09 A (-22d) | 2012-03-29 → 2012-06-11 A (+74d) | 42d → 107d | 0% → 100% | 105d → none | 1531215 → 1531215, 9-120M |  |
| 1531225 | Proc PLC Point I/O Modules Phase 1 | 2012-07-30 → 2012-01-09 A (-203d) | 2012-10-31 → 2012-07-16 A (-107d) | 67d → 132d | 0% → 100% | 21d → none | 1531220, 9-120M FS+203d, 1531215 FS+20d → 1531220 FS-100d |  |
| 1531005c | Proc Single Board Computing Second items (DAQ) Part A | 2012-02-29 → 2012-01-16 A (-44d) | 2012-06-27 → 2012-11-12 A (+138d) | 84d → 211d | 0% → 100% | 314d → none |  |  |
| 1531155 | Proc VME based electronic for Controls/Monitoring PR | 2011-10-03 → 2012-01-16 A (+105d) | 2011-11-30 → 2012-06-11 A (+194d) | 41d → 102d | 0% → 100% | 142d → none |  |  |
| 1531090 | Proc Test Setup Equipmnt (DAQ) PR | 2011-10-03 → 2012-02-01 A (+121d) | 2012-01-30 → 2012-05-14 A (+105d) | 77d → 73d | 0% → 100% | 230d → none | 1233040M, 9-120M → 9-120M FS+82d, 1233040M |  |
| 1531093 | Plan Installation in Counting House | 2011-10-31 → 2012-02-01 A (+93d) | 2012-02-28 → 2013-01-14 A (+321d) | 77d → 226d | 0% → 100% | 230d → none | 9-120M FS+20d → 9-120M FS+82d |  |
| 1531190 | Test embedded computers for controls | 2012-01-31 → 2012-02-01 A (+1d) | 2012-07-17 → 2013-01-14 A (+181d) | 118d → 227d | 0% → 100% | 141d → none | 1531215, 1531205, 1531185 → 1531185, 1531205, 1531215, 9-120M FS+82d |  |
| 1531060 | Proc Wireless (DAQ) PR | 2012-04-02 → 2012-02-02 A (-60d) | 2012-05-16 → 2012-02-20 A (-86d) | 33d → 12d | 0% → 100% | 219d → none |  |  |
| 1531092 | Proc Test Setup Equipmnt (DAQ) Part A | 2012-05-01 → 2012-02-06 A (-85d) | 2012-10-31 → 2012-09-28 A (-33d) | 129d → 166d | 0% → 100% | 166d → none | 9-120M FS+141d, 1531090 → 1531090 FS-100d, 9-120M |  |
| 1531062 | Proc Wireless (DAQ) | 2012-05-17 → 2012-02-13 A (-94d) | 2012-09-13 → 2012-08-20 A (-24d) | 83d → 133d | 0% → 100% | 219d → none |  |  |
| 1531050 | Proc terminal servers (DAQ) PR | 2012-05-01 → 2012-06-02 A (+32d) | 2012-07-02 → 2012-06-11 A (-21d) | 43d → 5d | 0% → 100% | 186d → none |  |  |
| 1531160 | Proc VME based electronic for Controls/Monitoring | 2012-06-01 → 2012-06-02 A (+1d) | 2012-08-31 → 2012-08-20 A (-11d) | 65d → 55d | 0% → 100% | 20d → none |  |  |
| 1531032 | Proc Online Computers (DAQ) Phase 1 Part A | 2012-03-01 → 2012-07-02 A (+123d) | 2012-10-31 → 2013-01-14 A (+75d) | 172d → 248d | 0% → 100% | 161d → none | 1531030 FS-65d → 9-120M FS+205d, 1531030 |  |
| 1531227 | Proc PLC Point I/O Modules Phase 2 Part A | 2012-11-29 → 2012-07-02 A (-150d) | 2013-03-29 → 2013-03-11 A (-18d) | 79d → 122d | 0% → 100% | 21d → none | 1531225 FS+18d → 1531225 |  |
| 1531052 | Proc terminal servers (DAQ) | 2012-07-03 → 2012-07-19 A (+16d) | 2012-10-30 → 2012-08-20 A (-71d) | 85d → 23d | 0% → 100% | 186d → none |  |  |
| 1531005ca | Proc Single Board Computing Second items (DAQ) Part B | 2012-02-29 → 2012-10-01 A (+215d) | 2012-06-27 → 2013-02-11 A (+229d) | 84d → 81d | 0% → 100% | 314d → none |  |  |
| 1531048 | Proc Fibers Installation from Rack Room to Telecom Room (DAQ) | 2012-10-01 A | 2013-04-09 → 2012-10-22 A (-169d) | 127d → 16d | 0% → 100% | 81d → none |  |  |
| 15311013E | FY13 Travel (DAQ) | 2012-10-01 A | 2012-12-31 A |  | 0% → 100% | 189d → none |  |  |
| 1531092a | Proc Test Setup Equipmnt (DAQ) Part B | 2012-05-01 → 2012-11-03 A (+186d) | 2012-10-31 → 2012-11-19 A (+19d) | 129d → 11d | 0% → 100% | 166d → none | 9-120M FS+141d, 1531090 → 9-120M, 1531090 FS-100d |  |
| 1531045 | Proc Telecom Installation (DAQ) PR | 2012-07-04 → 2013-01-02 A (+182d) | 2012-08-31 → 2013-01-30 A (+152d) | 43d → 21d | 0% → 100% | 69d → none | 9-120M FS+185d → 9-120M FS+185d, 9-130M FS+70d |  |
| 1531020 | Proc EB nodes (DAQ) PR | 2011-10-03 → 2013-01-07 A (+462d) | 2011-11-30 → 2013-01-21 A (+418d) | 41d → 21d | 0% → 100% | 354d → none | 9-120M → 9-130M FS+70d, 9-120M FS+200d | resources COMP SCIENT [40 h]; SCIENTIST [40 h] → SCIENTIST [40 h]; COMP SCIENT [40 h] |
| 1531025 | Proc RAID disks (DAQ) PR | 2013-01-03 → 2013-01-07 A (+4d) | 2013-03-01 → 2013-01-21 A (-39d) |  | 0% → 100% | 64d → none |  |  |
| 1531040 | Proc file servers (DAQ) PR | 2012-11-28 → 2013-01-07 A (+40d) | 2013-02-04 → 2013-01-21 A (-14d) | 42d → 30d | 0% → 100% | 24d → none | 9-130M FS+40d → 9-130M FS+70d | resources COMP SCIENT [40 h]; SCIENTIST [40 h] → SCIENTIST [40 h]; COMP SCIENT [40 h] |
| 1531075 | Proc Consoles (DAQ) PR | 2012-01-03 → 2013-01-07 A (+370d) | 2012-03-01 → 2013-02-11 A (+347d) | 41d → 23d | 0% → 100% | 227d → none | 9-120M FS+58d → 9-130M FS+43d, 9-120M FS+82d |  |
| 1531085 | Proc funiture (DAQ) PR | 2012-01-03 → 2013-01-28 A (+391d) | 2012-03-01 → 2013-03-11 A (+375d) | 41d → 23d | 0% → 100% | 235d → none | 9-120M FS+58d → 9-120M FS+82d, 9-130M FS+43d |  |
| 1531042 | Proc file servers (DAQ) | 2013-02-05 → 2013-01-29 A (-7d) | 2013-06-28 → 2013-02-11 A (-137d) | 102d → 65d | 0% → 100% | 24d → none |  |  |
| 1531035 | Proc large displays (DAQ) PR | 2013-07-01 → 2013-03-04 A (-119d) | 2013-08-30 → 2013-03-25 A (-158d) |  | 0% → 100% | 20d → none |  |  |
| 1531077 | Proc Consoles (DAQ) | 2012-12-19 → 2013-03-04 A (+75d) | 2013-06-28 → 2013-08-30 A (+63d) | 129d → 45d | 0% → 100% | 24d → none |  |  |
| 1531087 | Proc furniture (DAQ) | 2012-12-03 → 2013-03-04 A (+91d) | 2013-05-31 → 2013-06-17 A (+17d) | 121d → 45d | 0% → 100% | 44d → none |  | resources PROCUREMENT>$50K 69; PROCUREMENT<$50K 60 → PROCUREMENT<$50K 60; PROCUREMENT>$50K 69 |
| 1531037 | Proc large displays (DAQ) | 2013-08-30 → 2013-04-01 A (-151d) | 2013-08-30 → 2013-04-15 A (-137d) | 1d → 82d | 0% → 100% | 20d → none | 9-130M FS+227d → 1531035 FS+20d, 9-140M | was named Proc large displays (DAQ) (Future Activity Complete prior to Rebaseline) |
| 1531032a | Proc Online Computers (DAQ) Phase 1 Part B | 2012-03-01 → 2013-04-15 A (+410d) | 2012-10-31 → 2013-05-13 A (+194d) | 172d → 85d | 0% → 100% | 161d → none | 1531030 FS-65d → 1531030, 9-130M FS+140d, 9-120M FS+205d |  |
| 1531195 | Proc remaining embedded computers for controls | 2013-01-03 → 2013-05-03 A (+120d) | 2013-02-19 → 2013-05-20 A (+90d) |  | 0% → 100% | 49d → none | 9-130M FS+60d, 1531190 FS+20d → 1531190 FS+20d, 9-130M FS+150d |  |
| 1531033 | Proc Online Computers (DAQ) Phase 2 | 2013-03-04 → 2013-06-01 A (+89d) | 2013-05-31 → 2013-06-17 A (+17d) | 64d → 70d | 0% → 100% | 84d → none | 9-130M FS+100d, 1531032a, 1531032 → 9-130M FS+100d, 1531032 FS-70d, 1531032a FS-70d |  |
| 1531135 | Proc infiniband Switch PR | 2012-08-01 → 2013-06-01 A (+304d) | 2012-09-28 → 2013-06-17 A (+262d) |  | 0% → 100% | 149d → none | 9-120M FS+205d → 9-120M FS+255d, 9-130M FS+135d |  |
| 1531047 | Proc Telecom Installation (DAQ) | 2013-01-04 → 2013-08-01 A (+209d) | 2013-04-25 → 2013-08-30 A (+127d) | 78d → 32d | 0% → 100% | 69d → none | 1531045 FS+80d → 1531045 FS+30d |  |
| 1531065 | Proc Fiber Cables for Counting House to Hall (DAQ) PR | 2011-10-03 → 2013-08-01 A (+668d) | 2011-12-01 → 2013-08-26 A (+634d) |  | 0% → 100% | 291d → none | 9-120M → 9-130M FS+120d, 9-120M FS+235d | was named Proc Cables (DAQ) PR |
| 1531070 | Proc Fiber Cables for Counting House to Hall (DAQ) | 2012-11-28 → 2013-08-01 A (+246d) | 2013-05-29 → 2013-08-30 A (+93d) | 122d → 21d | 0% → 100% | 46d → none |  |  |
| 1531022 | Proc EB nodes (DAQ) Phase 1 | 2013-02-01 → 2013-08-30 A (+210d) | 2013-04-26 → 2013-08-30 A (+126d) | 60d → 63d | 0% → 100% | 68d → none | 9-130M FS+80d, 1531020 → 1531020 FS+40d, 9-130M FS+145d |  |
| 1531027 | Proc RAID disks (DAQ) | 2013-03-04 → 2013-08-30 A (+179d) | 2013-06-28 → 2013-08-30 A (+63d) |  | 0% → 100% | 64d → none | 1531025 → 1531025 FS+80d |  |
| 1531095 | Install Crates (DAQ) | 2013-01-03 → 2013-08-30 A (+239d) | 2013-03-22 → 2013-08-30 A (+161d) | 55d → 62d | 0% → 100% | 20d → none | 9-130M FS+60d, 1531093, 1562195 FS-20d, 1544005d → 1531093, 1562195 FS-20d, 9-130M FS+103d, 1544005d | resources COMP SCIENT [80 h]; ELEC TECH [360 h]; SCIENTIST [80 h] → ELEC TECH [360 h]; SCIENTIST [80 h]; COMP SCIENT [80 h] |
| 1531100 | Install Cabling (DAQ) | 2013-06-03 → 2013-08-30 A (+88d) | 2013-08-30 A |  | 0% → 100% | 20d → none |  | resources SCIENTIST [200 h]; COMP SCIENT [200 h]; ELEC TECH [160 h] → COMP SCIENT [200 h]; ELEC TECH [160 h]; SCIENTIST [200 h] |
| 1531105 | Install Trigger Electrnc's (DAQ) Phase 1 | 2013-03-25 → 2013-08-30 A (+158d) | 2013-06-14 → 2013-08-30 A (+77d) |  | 0% → 100% | 74d → none | 1531092a, 1531092, 1532007a, 1532007, 1531095, 1532005 → 1531092a, 1531092, 1531095 FS-35d, 1532007, 1532005, 1532007a | resources SCIENTIST [120 h]; ELEC TECH [120 h] → ELEC TECH [120 h]; SCIENTIST [120 h] |
| 1531110 | Install DAQ Electrnc's (DAQ) | 2013-03-25 → 2013-08-30 A (+158d) | 2013-05-20 → 2013-08-30 A (+102d) |  | 0% → 100% | 20d → none | 1531095 → 1531095, 9-130M FS+59d |  |
| 1531140 | Proc infiniband Switch | 2012-10-30 → 2013-08-30 A (+304d) | 2013-02-28 → 2013-08-30 A (+183d) | 78d → 70d | 0% → 100% | 149d → none | 1531135 FS+21d → 1531135 FS+10d |  |
| 1531165 | Install VME based electronic for Controls/Monitoring | 2012-10-02 → 2013-08-30 A (+332d) | 2013-04-01 → 2013-08-30 A (+151d) | 120d → 150d | 0% → 100% | 20d → none | 1531160 FS+20d → 9-130M FS+110d, 1531160 FS+95d |  |
| 1531227a | Proc PLC Point I/O Modules Phase 2 Part B | 2012-11-29 → 2013-08-30 A (+274d) | 2013-03-29 → 2013-08-30 A (+154d) | 79d → 64d | 0% → 100% | 21d → none | 1531225 FS+18d → 1531225, 9-130M FS+160d |  |
| 1531245 | Re-Baseline Actuals Adjustment | 2013-08-30 A | 2013-08-30 A |  | 0% → 100% | 20d → none | 9-130M FS+227d → none |  |
| 2531005f | Proc Single Board Computing Remaining items (DAQ) | 2013-09-03 A | 2014-01-10 → 2013-09-23 A (-109d) |  | 0% → 100% | 122d → none |  |  |
| 2531022 | Proc EB nodes (DAQ) | 2013-09-03 A | 2013-11-27 → 2013-10-21 A (-37d) |  | 0% → 100% | 165d → none |  | resources PROCUREMENT>$50K 69 NO ESCALATION; PROCUREMENT<$50K 60 NO ESCALATION FY14 → PROCUREMENT<$50K 60 NO ESCALATION FY14 |

| ID | Task | Start | Finish | Duration | Complete | Total float | Predecessors | Other |
| --- | --- | --- | --- | --- | --- | --- | --- | --- |
| 2531027 | Proc RAID disks (DAQ) | 2013-09-03 A | 2013-11-27 → 2013-10-21 A (-37d) |  | 0% → 100% | 165d → none |  | resources PROCUREMENT>$50K 69 NO ESCALATION → PROCUREMENT<$50K 60 NO ESCALATION FY14 |
| 2531077 | Proc Consoles (DAQ) | 2013-09-03 A | 2013-09-30 → 2013-09-23 A (-7d) |  | 0% → 100% | 54d → none |  |  |
| 2531140 | Proc infiniband Hardware | 2013-09-03 A | 2013-10-15 → 2013-10-21 A (+6d) |  | 0% → 100% | 164d → none |  | resources PROCUREMENT>$50K 69 NO ESCALATION → PROCUREMENT<$50K 60 NO ESCALATION FY14 |
| 2531227aa | Proc IO Modules (DAQ) Batch 2 (Previously Obligated) | 2013-09-03 A | 2013-10-30 → 2013-09-23 A (-37d) |  | 0% → 100% | 225d → none |  |  |
| 2531330 | Proc L3 Farm Infrastucture (DAQ) | 2013-11-01 → 2013-09-03 A (-59d) | 2013-12-16 → 2013-10-21 A (-56d) |  | 0% → 100% | 154d → none | 9-140M FS+23d → 9-140M FS-1d | resources PROCUREMENT>$50K 69 NO ESCALATION → PROCUREMENT<$50K 60 NO ESCALATION |
| 2531340 | Proc Accessories for Computing Cluster (DAQ) | 2013-11-12 → 2013-09-03 A (-70d) |  |  |  |  | 2531335 FS+19d, 2531335a FS+19d → 2531335 FS-25d, 2531335a FS-25d |  |
| 2531350 | Proc Hardware for Microscope Voltage Control (DAQ) | 2013-09-03 A |  |  |  |  |  |  |
| 2531390 | Installation Coordination | 2013-09-03 A | 2013-09-30 A |  | 0% → 100% | 216d → none |  |  |
| 2531335 | Proc Accessories for Computing Cluster (DAQ) PR FY13 | 2013-09-03 → 2013-10-01 A (+28d) | 2013-09-30 → 2013-10-21 A (+21d) | 20d → 18d | 0% → 100% | 95d → none | 9-130M FS+228d → 9-140M FS+4d, 9-130M FS+228d |  |
| 2531335a | Proc Accessories for Computing Cluster (DAQ) PR FY14 | 2013-10-01 A | 2013-10-15 → 2013-10-21 A (+6d) | 11d → 18d | 0% → 100% | 95d → none | 2531335, 9-130M FS+228d → 2531335 FS-18d |  |
| 2531375 | Check-out Counting House (DAQ) | 2013-10-15 → 2013-10-01 A (-14d) | 2013-11-26 → 2013-12-17 (+21d) |  | 0% → 50% | 206d → 193d |  |  |
| 2531227aa5 | Proc IO Modules (DAQ) Batch 2 | 2013-09-03 → 2013-10-14 A (+41d) | 2013-10-30 → 2014-01-13 (+75d) |  |  | 225d → 182d | 9-130M FS+228d → 9-130M FS+228d, 9-140M |  |
| 2531033 | Proc Servers for EPICS Archiving (DAQ) | 2014-10-01 → 2013-10-21 A (-345d) | 2014-12-11 → 2014-01-24 (-321d) |  | 0% → 50% | 447d → 671d | 9-155M → 9-140M |  |
| 2531097 | Install infiniband network (DAQ) | 2013-10-16 → 2013-10-21 A (+5d) |  |  | 0% → 30% |  | 2531140 → 2531140 FS-15d |  |
| 2531115 | Install VME CPUs FY13 | 2013-09-03 → 2013-10-21 A (+48d) | 2013-09-30 → 2014-02-18 (+141d) | 20d → 67d | 0% → 25% |  | 9-130M FS+228d → 9-130M FS+228d, 9-140M |  |
| 2531115a | Install VME CPUs FY14 | 2013-10-01 → 2013-10-21 A (+20d) |  | 90d → 67d | 0% → 25% |  | 9-130M FS+228d, 2531115 → 2531115 FS-67d |  |
| 2531315 | Install Computing Infrastructure (DAQ) FY13 | 2013-09-03 → 2013-10-21 A (+48d) | 2013-09-30 → 2013-12-16 (+77d) |  | 0% → 40% |  |  |  |
| 2531315a | Install Computing Infrastructure (DAQ) FY14 | 2013-10-01 → 2013-10-21 A (+20d) |  |  | 0% → 40% | 500d → 521d | 9-130M FS+228d, 2531315 → 2531315 FS-40d |  |
| 2531065 | Proc Fibers for Counting House to Hall (DAQ) PR FY13 | 2013-09-03 → 2013-11-01 (+59d) | 2013-09-30 → 2013-11-01 (+32d) | 20d → 1d |  | 17d → 2d | 9-130M FS+228d → 9-130M FS+228d, 9-140M FS+10d |  |
| 2531065a | Proc Fibers for Counting House to Hall (DAQ) PR FY14 | 2013-10-01 → 2013-11-01 (+31d) | 2013-10-11 → 2013-11-01 (+21d) | 9d → 1d |  | 17d → 33d | 9-130M FS+228d, 2531065 → 2531065 FS-1d |  |
| 2531178 | Software Licenses and Fees | 2013-10-01 → 2013-11-01 (+31d) |  | 246d → 223d |  | 101d → 1d |  |  |
| 2531310 | Install DAQ Equipment in Hall (DAQ) |  | 2014-03-13 → 2014-02-13 (-28d) | 84d → 64d |  | 0d → 20d |  |  |
| 2531165 | Install VME based electronic for Controls/Monitoring FY13 | 2013-09-03 → 2013-11-18 (+76d) | 2013-09-30 → 2014-01-30 (+122d) | 20d → 43d |  |  | 9-130M FS+228d → 9-140M FS+34d, 9-130M FS+228d |  |
| 2531165a | Install VME based electronic for Controls/Monitoring FY14 | 2013-10-01 → 2013-11-18 (+48d) |  | 77d → 43d |  |  | 2531165, 9-130M FS+228d → 2531165 FS-43d |  |
| 2531047 | Proc Telecom Installation (DAQ) | 2013-09-03 → 2013-12-03 (+91d) | 2013-10-31 → 2013-12-20 (+50d) | 43d → 14d |  | 31d → 23d | 9-130M FS+228d → 9-140M FS+43d, 9-130M FS+228d |  |
| 2531070 | Proc Fibers for Counting House to Hall (DAQ) | 2013-10-14 → 2013-12-19 (+66d) | 2013-11-21 → 2014-02-03 (+74d) | 29d → 24d |  | 17d → 2d | 2531065, 2531065a → 2531065a, 2531065 FS+31d |  |
| 2531360 | Patch Panels and Cu Cables to CH (DAQ) | 2013-11-27 → 2014-01-03 (+37d) | 2014-04-08 → 2014-05-01 (+23d) |  |  | 122d → 105d | 2562645 FS+5d, 9-140M FS+41d, 2562645a FS+5d → 9-140M FS+60d, 2562645 FS+5d, 2562645a FS+5d |  |
| 2531395 | Procure Small UPSs for Tagger Hall and Hall D Cables (DAQ) | 2013-11-01 → 2014-01-03 (+63d) | 2014-03-04 → 2014-04-22 (+49d) |  |  | 147d → 112d | 9-140M FS+23d → 9-140M FS+60d | was named Procure Small UPSs for Tagger Hall and Hall D (DAQ) |
| 2531365 | Sys Admin Support (DAQ) |  |  |  |  |  | 2531315 FS+6d, 2531315a FS+6d → 2531315a FS-15d, 2531315 FS+6d |  |
| 2531105 | Install Trigger Electrnc's (DAQ) FY13 | 2013-09-03 → 2014-01-10 (+129d) | 2013-09-30 → 2014-05-07 (+219d) | 20d → 83d |  |  | 9-130M FS+228d → 9-130M FS+228d, 9-140M FS+65d | resources ELEC ENG [9.64 h]; SCIENTIST [28.92 h]; ELEC TECH [38.55 h] → ELEC ENG [8.57 h]; SCIENTIST [29.99 h]; ELEC TECH [38.55 h] |
| 2531105a | Install Trigger Electrnc's (DAQ) FY14 | 2013-10-01 → 2014-01-10 (+101d) |  | 146d → 83d |  |  | 9-130M FS+228d, 2531105 → 2531105 FS-83d |  |
| 2531089 | Procure Conference Equipment (DAQ) | 2013-11-01 → 2014-02-03 (+94d) | 2014-02-28 → 2014-05-16 (+77d) |  |  | 149d → 94d | 9-140M FS+23d → 9-140M FS+80d |  |
| 2531385 | Check-out DAQ Hardware (DAQ) | 2014-04-25 → 2014-04-02 (-23d) | 2014-09-30 → 2014-09-05 (-25d) |  |  | 0d → 17d |  |  |
| 1532035b | Plan Monitoring Histograms FY11 | 2011-06-01 → 2011-04-01 A (-61d) | 2011-09-30 → 2012-06-11 A (+255d) | 86d → 296d | 0% → 100% | 290d → none | 9-110M FS+162d → 9-110M |  |
| 1532035ba | Plan Monitoring Histograms FY12 | 2011-10-03 → 2011-04-01 A (-185d) | 2012-05-31 → 2012-06-11 A (+11d) | 163d → 297d | 0% → 100% | 290d → none | 1532035b → 1532035b FS-165d |  |
| 1532060g | Plan Experiment Controls Motors FY11 | 2011-04-01 A | 2011-09-30 → 2012-05-14 A (+227d) | 128d → 278d | 0% → 100% | 20d → none |  |  |
| 1532060ga | Plan Experiment Controls Motors FY12 | 2011-10-03 → 2011-04-01 A (-185d) | 2012-03-30 → 2012-05-14 A (+45d) | 120d → 279d | 0% → 100% | 20d → none | 1532060g → 1532060g FS-120d |  |
| 1532060a | Plan Experiment Controls Display management FY11 | 2011-04-01 → 2011-05-01 A (+30d) | 2011-09-30 → 2012-09-17 A (+353d) | 128d → 344d | 0% → 100% | 157d → none |  |  |
| 1532060aa | Plan Experiment Controls Display management FY12 | 2011-10-03 → 2011-05-01 A (-155d) | 2012-03-30 → 2012-09-17 A (+171d) | 120d → 345d | 0% → 100% | 157d → none | 1532060a → 1532060a FS-120d |  |
| 1532060h | Plan Experiment Controls Gas Systems FY11 | 2011-04-01 → 2011-05-01 A (+30d) | 2011-09-30 → 2013-03-11 A (+528d) | 128d → 435d | 0% → 100% | 247d → none |  |  |
| 1532060ha | Plan Experiment Controls Gas Systems FY12 | 2011-10-03 → 2011-05-01 A (-155d) | 2012-03-30 → 2013-03-11 A (+346d) | 120d → 435d | 0% → 100% | 247d → none | 1532060h → 1532060h FS-120d |  |
| 1532045a | Plan Archiving Run Info | 2011-10-03 → 2011-06-01 A (-124d) | 2012-05-25 → 2012-06-11 A (+17d) | 160d → 255d | 0% → 100% | 207d → none | 9-120M → 9-120M FS-70d |  |
| 1532060 | Plan Experiment Controls Framework FY11 (FY12 @ 1532060p) | 2011-04-01 → 2011-06-01 A (+61d) | 2011-09-30 → 2012-11-12 A (+409d) | 128d → 363d | 0% → 100% | 48d → none |  |  |
| 1532060p | Plan Experiment Controls Framework FY12 (FY11 @ 1532060) | 2011-10-03 → 2011-06-01 A (-124d) | 2012-03-30 → 2012-11-12 A (+227d) | 120d → 364d | 0% → 100% | 48d → none | 1532060 → 1532060 FS-120d |  |
| 1532011E | FY11 Travel (ONLINE COMP) | 2011-07-01 A | 2011-09-30 A |  | 0% → 100% | 20d → none |  |  |
| 1532025 | Plan Front-End Software FY11 | 2011-08-01 → 2011-07-01 A (-31d) | 2011-09-30 → 2013-08-30 A (+700d) | 44d → 390d | 0% → 100% | 207d → none |  |  |
| 1532025a | Plan Front-End Software FY12 | 2011-10-03 → 2011-07-01 A (-94d) | 2012-04-27 → 2013-08-15 A (+475d) | 140d → 390d | 0% → 100% | 207d → none | 1532025 → 1532025 FS-140d |  |
| 1532030 | Plan DAQ Software Event Unblocking FY11 (FY12 @ 1532030d) | 2011-08-01 → 2011-07-01 A (-31d) | 2011-09-30 → 2012-05-14 A (+227d) | 44d → 214d | 0% → 100% | 235d → none |  |  |
| 1532030a | Plan DAQ Software Scripts FY11 | 2011-08-01 → 2011-07-01 A (-31d) | 2011-09-30 → 2012-01-16 A (+108d) | 44d → 131d | 0% → 100% | 145d → none |  |  |
| 1532030aa | Plan DAQ Software Scripts FY12 | 2011-10-03 → 2011-07-01 A (-94d) | 2012-04-27 → 2012-01-16 A (-102d) | 140d → 131d | 0% → 100% | 145d → none | 1532030a → 1532030a FS-140d |  |
| 1532030b | Plan DAQ Software Run Control FY11 | 2011-08-01 → 2011-07-01 A (-31d) | 2011-09-30 → 2012-06-11 A (+255d) | 44d → 232d | 0% → 100% | 135d → none |  |  |
| 1532030ba | Plan DAQ Software Run Control FY12 | 2011-10-03 → 2011-07-01 A (-94d) | 2012-04-27 → 2012-06-11 A (+45d) | 140d → 233d | 0% → 100% | 135d → none | 1532030b → 1532030b FS-140d |  |
| 1532030c | Plan DAQ Software Code Management FY11 | 2011-08-01 → 2011-07-01 A (-31d) | 2011-09-30 → 2012-01-16 A (+108d) | 44d → 131d | 0% → 100% | 234d → none |  |  |
| 1532030ca | Plan DAQ Software Code Management FY12 | 2011-10-03 → 2011-07-01 A (-94d) | 2012-04-27 → 2012-01-16 A (-102d) | 140d → 131d | 0% → 100% | 234d → none | 1532030c → 1532030c FS-140d |  |
| 1532030d | Plan DAQ Software Event Unblocking FY12 (FY11 @ 1532030) | 2011-10-03 → 2011-07-01 A (-94d) | 2012-04-27 → 2012-05-14 A (+17d) | 140d → 215d | 0% → 100% | 235d → none | 1532030 → 1532030 FS-140d |  |
| 1532035 | Plan Monitoring Framework FY11 (FY12 @ 1532035h) | 2011-06-01 → 2011-07-01 A (+30d) | 2011-09-30 → 2013-02-11 A (+500d) | 86d → 390d | 0% → 100% | 180d → none |  | was named Plan Monitoring Framework FY11(FY12 @ 1532035h) |
| 1532035a | Plan Monitoring Scalers FY11 | 2011-06-01 → 2011-07-01 A (+30d) | 2011-09-30 → 2011-12-19 A (+80d) | 86d → 117d | 0% → 100% | 379d → none |  |  |
| 1532035aa | Plan Monitoring Scalers FY12 | 2011-10-03 → 2011-07-01 A (-94d) | 2012-05-31 → 2011-12-19 A (-164d) | 163d → 118d | 0% → 100% | 379d → none | 1532035a → 1532035a FS-165d |  |
| 1532035c | Plan Monitoring Remote FY11 | 2011-06-01 → 2011-07-01 A (+30d) | 2011-09-30 → 2013-07-15 A (+654d) | 86d → 390d | 0% → 100% | 284d → none |  |  |
| 1532035ca | Plan Monitoring Remote FY12 | 2011-10-03 → 2011-07-01 A (-94d) | 2012-05-31 → 2013-07-15 A (+410d) | 163d → 390d | 0% → 100% | 284d → none | 1532035c → 1532035c FS-165d |  |
| 1532035d | Plan Monitoring Hardware Status FY11 | 2011-06-01 → 2011-07-01 A (+30d) | 2011-09-30 → 2013-08-30 A (+700d) | 86d → 390d | 0% → 100% | 290d → none |  |  |
| 1532035da | Plan Monitoring Hardware Status FY12 | 2011-10-03 → 2011-07-01 A (-94d) | 2012-05-31 → 2013-08-30 A (+456d) | 163d → 390d | 0% → 100% | 290d → none | 1532035d → 1532035d FS-165d |  |
| 1532035f | Plan Monitoring Process Status FY11 | 2011-06-01 → 2011-07-01 A (+30d) | 2011-09-30 → 2013-07-15 A (+654d) | 86d → 390d | 0% → 100% | 379d → none |  |  |
| 1532035fa | Plan Monitoring Process Status FY12 | 2011-10-03 → 2011-07-01 A (-94d) | 2012-05-31 → 2013-07-15 A (+410d) | 163d → 390d | 0% → 100% | 379d → none | 1532035f → 1532035f FS-165d |  |
| 1532035g | Plan Monitoring Trigger FY11 | 2011-06-01 → 2011-07-01 A (+30d) | 2011-09-30 → 2013-02-11 A (+500d) | 86d → 390d | 0% → 100% | 183d → none |  |  |
| 1532035ga | Plan Monitoring Trigger FY12 | 2011-10-03 → 2011-07-01 A (-94d) | 2012-05-31 → 2013-02-11 A (+256d) | 163d → 390d | 0% → 100% | 183d → none | 1532035g → 1532035g FS-165d |  |
| 1532035h | Plan Monitoring Framework FY12 (FY11 @ 1532035) | 2011-10-03 → 2011-07-01 A (-94d) | 2012-05-31 → 2013-02-11 A (+256d) | 163d → 390d | 0% → 100% | 180d → none | 1532035 → 1532035 FS-165d |  |
| 1532050 | Plan Event Display FY11 | 2011-07-01 A | 2011-09-30 → 2012-08-13 A (+318d) | 64d → 277.76d | 0% → 100% | 20d → none |  |  |
| 1532050a | Plan Event Display FY12 | 2011-10-03 → 2011-07-01 A (-94d) | 2012-03-27 → 2012-08-13 A (+139d) | 117d → 278d | 0% → 100% | 20d → none | 1532050 → 1532050 FS-120d |  |
| 1532060b | Plan Experiment Controls Backup/Restore FY11 | 2011-04-01 → 2011-07-01 A (+91d) | 2011-09-30 → 2012-12-17 A (+444d) | 128d → 390d | 0% → 100% | 247d → none |  |  |

| ID | Task | Start | Finish | Duration | Complete | Total float | Predecessors | Other |
| --- | --- | --- | --- | --- | --- | --- | --- | --- |
| 1532060ba | Plan Experiment Controls Backup/Restore FY12 | 2011-10-03 → 2011-07-01 A (-94d) | 2012-03-30 → 2012-12-17 A (+262d) | 120d → 390d | 0% → 100% | 247d → none | 1532060b → 1532060b FS-120d |  |
| 1532060c | Plan Experiment Controls Magnet PS FY11 | 2011-04-01 → 2011-07-01 A (+91d) | 2011-09-30 → 2012-09-17 A (+353d) | 128d → 301d | 0% → 100% | 247d → none |  |  |
| 1532060ca | Plan Experiment Controls Magnet PS FY12 | 2011-10-03 → 2011-07-01 A (-94d) | 2012-03-30 → 2012-09-17 A (+171d) | 120d → 302d | 0% → 100% | 247d → none | 1532060c → 1532060c FS-120d |  |
| 1532060d | Plan Experiment Controls HV FY11 | 2011-04-01 → 2011-07-01 A (+91d) | 2011-09-30 → 2012-03-19 A (+171d) | 128d → 174d | 0% → 100% | 20d → none |  |  |
| 1532060da | Plan Experiment Controls HV FY12 | 2011-10-03 → 2011-07-01 A (-94d) | 2012-03-30 → 2012-03-19 A (-11d) | 120d → 175d | 0% → 100% | 20d → none | 1532060d → 1532060d FS-120d |  |
| 1532060f | Plan Experiment Controls LV FY11 | 2011-04-01 → 2011-07-01 A (+91d) | 2011-09-30 → 2012-03-19 A (+171d) | 128d → 175d | 0% → 100% | 20d → none |  |  |
| 1532060fa | Plan Experiment Controls LV FY12 | 2011-10-03 → 2011-07-01 A (-94d) | 2012-03-30 → 2012-03-19 A (-11d) | 120d → 175d | 0% → 100% | 20d → none | 1532060f → 1532060f FS-120d |  |
| 1532060j | Plan Experiment Controls Temperature FY11 | 2011-04-01 → 2011-07-01 A (+91d) | 2011-09-30 → 2013-03-11 A (+528d) | 128d → 392d | 0% → 100% | 247d → none |  |  |
| 1532060ja | Plan Experiment Controls Temperature FY12 | 2011-10-03 → 2011-07-01 A (-94d) | 2012-03-30 → 2013-03-11 A (+346d) | 120d → 392d | 0% → 100% | 247d → none | 1532060j → 1532060j FS-120d |  |
| 1532060k | Plan Experiment Controls Target FY11 | 2011-04-01 → 2011-07-01 A (+91d) | 2011-09-30 → 2013-04-15 A (+563d) | 128d → 410d | 0% → 100% | 227d → none |  |  |
| 1532060ka | Plan Experiment Controls Target FY12 | 2011-10-03 → 2011-07-01 A (-94d) | 2012-03-30 → 2013-04-15 A (+381d) | 120d → 410d | 0% → 100% | 227d → none | 1532060k → 1532060k FS-140d |  |
| 1532060n | Plan Experiment Controls Interface with DAQ FY11 | 2011-04-01 → 2011-07-01 A (+91d) | 2011-09-30 → 2013-07-15 A (+654d) | 128d → 390d | 0% → 100% | 20d → none |  |  |
| 1532060na | Plan Experiment Controls Interface with DAQ FY12 | 2011-10-03 → 2011-07-01 A (-94d) | 2012-03-30 → 2013-07-15 A (+472d) | 120d → 390d | 0% → 100% | 20d → none | 1532060n → 1532060n FS-120d |  |
| 1532012E | FY12 Travel (ONLINE COMP) FY12 | 2011-10-03 A | 2012-09-28 A |  | 0% → 100% | 20d → none |  |  |
| 1532045b | Plan Archiving Controls | 2011-10-03 A | 2012-05-25 → 2012-10-15 A (+143d) | 160d → 258d | 0% → 100% | 207d → none |  |  |
| 1532040 | Plan Alarm Sys | 2011-10-03 → 2011-12-01 A (+59d) | 2012-06-27 → 2013-04-15 A (+292d) | 181d → 285d | 0% → 100% | 165d → none |  |  |
| 1532045 | Plan Archiving DAQ Configuration | 2011-10-03 → 2011-12-01 A (+59d) | 2012-05-25 → 2011-12-19 A (-158d) | 160d → 13d | 0% → 100% | 209d → none |  |  |
| 1532055 | Plan Storage Mngmnt | 2011-10-03 → 2012-01-07 A (+96d) | 2012-03-30 → 2012-01-23 A (-67d) | 120d → 10d | 0% → 100% | 247d → none | 9-120M → 9-120M FS+82d |  |
| 1532005 | Proc Trigger Testbed Electrnc's PR | 2012-01-03 → 2012-01-09 A (+6d) | 2012-03-30 → 2013-02-11 A (+318d) | 62d → 264d | 0% → 100% | 223d → none |  |  |
| 1532065 | Trigger Board Initialization FY11 | 2011-07-01 → 2012-02-01 A (+215d) | 2011-09-30 → 2012-11-12 A (+409d) | 64d → 200d | 0% → 100% | 20d → none | 9-110M FS+184d → 9-120M FS+60d, 9-110M FS+184d | resources COMP SCIENT [51.89 h]; SCIENTIST [134.92 h] → SCIENTIST [134.92 h]; COMP SCIENT [51.89 h] |
| 1532065a | Trigger Board Initialization FY12 Part A (Hall D grp and CODA grp) | 2011-10-03 → 2012-02-01 A (+121d) | 2012-01-31 → 2013-08-30 A (+577d) | 78d → 223d | 0% → 100% | 20d → none | 1532065 → 1532065 FS-250d |  |
| 1532065b | Trigger Board Initialization FY12 Part B (Hall D grp and CODA grp) | 2012-02-01 A | 2012-09-28 → 2013-08-30 A (+336d) | 169d → 223d | 0% → 100% | 20d → none | 1532065a → 1532065a FS-170d |  |
| 1532067 | Level 1 Verification/debugging FY11 | 2011-07-01 → 2012-02-01 A (+215d) | 2011-09-30 → 2013-06-17 A (+626d) | 64d → 260d | 0% → 100% | 20d → none | 9-110M FS+184d → 9-120M FS+65d, 9-110M FS+184d | was named Level 1 Trigger Verification/debugging FY11 |
| 1532067a | Level 1 Trigger Verification/debugging FY12 Part A | 2011-10-03 → 2012-02-01 A (+121d) | 2012-01-31 → 2013-06-17 A (+503d) | 78d → 260d | 0% → 100% | 20d → none | 1532067 → 1532067 FS-250d | resources SCIENTIST [86.67 h]; COMP SCIENT [86.67 h] → COMP SCIENT [86.67 h]; SCIENTIST [86.67 h] |
| 1532067b | Level 1 Trigger Verification/debugging FY12 Part B | 2012-02-01 A | 2012-09-28 → 2013-06-17 A (+262d) | 169d → 260d | 0% → 100% | 20d → none | 1532067a → 1532067a FS-160d | resources SCIENTIST [84.4 h]; COMP SCIENT [84.4 h] → COMP SCIENT [84.4 h]; SCIENTIST [84.4 h] |
| 1532105g | Write Experiment Control Motors FY12 | 2012-04-02 A | 2012-09-28 → 2013-08-30 A (+336d) | 127d → 355d | 0% → 100% | 20d → none | 1532060ga → 1532060ga FS+10d |  |
| 1532105ga | Write Experiment Control Motors FY13 | 2012-10-01 → 2012-04-02 A (-182d) | 2013-02-20 → 2013-08-30 A (+191d) | 93d → 355d | 0% → 100% | 20d → none | 1532105g → 1532105g FS-235d | resources SCIENTIST [135.27 h]; CONTRB UNIV LBR [67.64 h] → CONTRB UNIV LBR [67.64 h]; SCIENTIST [135.27 h] |
| 1532007 | Proc Trigger Testbed Electrnc's (coordinate with Hovanes) Part A | 2012-10-01 → 2012-07-02 A (-91d) | 2013-02-20 → 2013-01-14 A (-37d) | 93d → 292d | 0% → 100% | 96d → none | 9-130M, 1532005 → 1532005 FS-110d |  |
| 1532012Ea | FY12 Travel (ONLINE COMP) FY13 | 2012-10-01 → 2012-09-28 A (-3d) | 2012-10-01 → 2012-09-28 A (-3d) |  | 0% → 100% | 20d → none | 1532012E, 1532011E → 1532012E |  |
| 1532007a | Proc Trigger Testbed Electrnc's (coordinate with Hovanes) Part B | 2012-10-01 A | 2013-02-20 → 2013-05-20 A (+89d) | 93d → 228d | 0% → 100% | 96d → none | 9-130M, 1532005 → 1532005 FS-110d |  |
| 1532013E | FY13 Travel (ONLINE COMP) | 2012-10-02 → 2012-10-01 A (-1d) | 2013-08-30 A | 227d → 248d | 0% → 100% | 20d → none | 1532012E, 1532012Ea → 1532012Ea |  |
| 1532067c | Level 1 Trigger Verification/debugging FY13 | 2012-10-01 A | 2013-08-30 A | 228d → 248d | 0% → 100% | 20d → none | 1532067b → 1532067b FS-100d |  |
| 1532105 | Write Experiment Control Framework (FY13 @ 1532105s) | 2012-04-02 → 2012-10-01 A (+182d) | 2012-09-28 → 2013-07-15 A (+290d) | 127d → 306d | 0% → 100% | 48d → none | 1531240, 1532060p → 1532060p FS-20d, 1531240 | was named Write Experiment Control Framework FY12 (FY13 @ 1532105s) |
| 1532105s | Write Experiment Control Framework FY13 (FY12 @ 1532105) | 2012-10-01 A | 2013-02-20 → 2013-08-30 A (+191d) | 93d → 300d | 0% → 100% | 48d → none | 1532105 → 1532105 FS-350d |  |
| 1532010 | Proc L3 Farm infrastructure PR | 2011-10-03 → 2013-01-07 A (+462d) | 2011-12-30 → 2013-01-21 A (+388d) | 58d → 17d | 0% → 100% | 347d → none | 1233040M, 9-120M → 9-130M FS+70d, 1233040M, 9-120M FS+185d |  |
| 1532080 | Write Monitoring Framework FY12 | 2012-06-01 → 2013-05-01 A (+334d) | 2012-08-30 → 2013-08-30 A (+365d) | 64d → 221d | 0% → 100% | 180d → none |  |  |
| 1532082 | Write Monitoring Framework FY13 | 2013-04-29 → 2013-05-01 A (+2d) | 2013-08-30 A | 88d → 221d | 0% → 100% | 20d → none | 9-130M FS+140d, 1532080 → 1532080 FS-221d, 9-130M |  |
| 1532105d | Write Experiment Control HV FY12 | 2012-08-01 → 2013-05-01 A (+273d) | 2012-09-28 → 2013-08-30 A (+336d) | 42d → 178d | 0% → 100% | 20d → none | 1532060da FS+85d → 9-130M FS+152d, 1532060da FS+85d | resources CONTRB UNIV LBR [112.94 h]; SCIENTIST [158.12 h] → SCIENTIST [158.12 h]; CONTRB UNIV LBR [112.94 h] |
| 1532105da | Write Experiment Control HV FY13 | 2012-10-01 → 2013-05-01 A (+212d) | 2013-01-28 → 2013-08-30 A (+214d) | 77d → 178d | 0% → 100% | 20d → none | 1532105d → 9-130M FS+152d, 1532105d FS-220d |  |
| 1532105f | Write Experiment Control LV FY12 | 2012-08-01 → 2013-05-01 A (+273d) | 2012-09-28 → 2013-08-30 A (+336d) | 42d → 178d | 0% → 100% | 20d → none | 1532060fa FS+85d → 9-130M FS+152d, 1532060fa FS+85d |  |
| 1532105fa | Write Experiment Control LV FY13 | 2012-10-01 → 2013-05-01 A (+212d) | 2013-01-28 → 2013-08-30 A (+214d) | 77d → 178d | 0% → 100% | 20d → none | 1532105f → 9-130M FS+152d, 1532105f FS-220d |  |
| 1532075c | Write DAQ Software Code Management | 2012-10-15 → 2013-05-03 A (+200d) | 2013-04-15 → 2013-05-20 A (+35d) | 121d → 166d | 0% → 100% | 117d → none | 9-130M FS+10d, 1532030ca → 9-130M FS+164d, 1532030ca |  |
| 1532080b | Write Monitoring Histograms FY12 | 2012-06-01 → 2013-06-01 A (+365d) | 2012-09-28 → 2013-08-30 A (+336d) |  | 0% → 100% | 290d → none | 1532035ba → 9-130M FS+110d, 1532035ba |  |
| 1532080ba | Write Monitoring Histograms FY13 | 2012-10-01 → 2013-06-01 A (+243d) | 2013-04-22 → 2013-08-30 A (+130d) |  | 0% → 100% | 290d → none | 1532080b → 1532080b FS-120d |  |
| 1532075 | Write DAQ Software Event Unblocking | 2013-02-01 → 2013-07-01 A (+150d) | 2013-07-23 → 2013-07-15 A (-8d) | 120d → 166d | 0% → 100% | 48d → none | 1532030d, 9-130M FS+80d → 1532030d, 9-130M FS+164d |  |
| 1532080c | Write Monitoring Remote | 2013-03-04 → 2013-07-01 A (+119d) | 2013-08-28 → 2013-07-15 A (-44d) | 126d → 95d | 0% → 100% | 100d → none | 9-130M FS+100d, 1532035ca → 9-130M FS+164d, 1532035ca |  |
| 1532105n | Write Experiment Control Interface with DAQ FY12 | 2012-04-02 → 2013-07-01 A (+455d) | 2012-09-28 → 2013-07-15 A (+290d) | 127d → 143d | 0% → 100% | 20d → none | 1532060na → 1532060na FS+54d |  |
| 1532105na | Write Experiment Control Interface with DAQ FY13 | 2012-10-01 → 2013-07-01 A (+273d) | 2013-02-20 → 2013-07-15 A (+145d) | 93d → 143d | 0% → 100% | 20d → none | 1532105n → 1532105n FS-221d |  |
| 1532015 | Install L3 Farm infrastructure | 2013-07-10 → 2013-07-02 A (-8d) | 2013-08-30 A | 38d → 39d | 0% → 100% | 20d → none | 9-130M FS+190d → 1532010a FS-100d |  |
| 1532010a | Proc L3 Farm infrastructure Phase 1 | 2013-03-04 → 2013-08-30 A (+179d) | 2013-07-09 → 2013-08-30 A (+52d) | 90d → 101d | 0% → 100% | 58d → none | 9-130M FS+100d, 1532010 → 9-130M FS+100d, 1532010 FS+40d |  |
| 1532065c | Trigger Board Initialization FY13 (Hall D grp and CODA grp) | 2012-10-01 → 2013-08-30 A (+333d) | 2013-08-30 A | 228d → 109d | 0% → 100% | 20d → none |  | resources COMP SCIENT [65.38 h]; SCIENTIST [169.97 h] → SCIENTIST [184.89 h]; COMP SCIENT [71.11 h] |
| 1532070 | Write Front-End Software | 2013-02-01 → 2013-08-30 A (+210d) | 2013-07-23 → 2013-08-30 A (+38d) | 120d → 166d | 0% → 100% | 20d → none | 1532025a, 9-130M FS+80d → 1532025a, 9-130M FS+164d |  |
| 1532075a | Write DAQ Software Scripts FY12 | 2012-06-01 → 2013-08-30 A (+455d) | 2012-09-28 → 2013-08-30 A (+336d) | 84d → 166d | 0% → 100% | 122d → none | 9-120M FS+163d, 1532030aa → 1532030aa, 9-120M FS+163d, 9-130M FS+164d |  |
| 1532075b | Write DAQ Software Run Control FY12 | 2012-04-30 → 2013-08-30 A (+487d) | 2012-09-28 → 2013-08-30 A (+336d) | 107d → 166d | 0% → 100% | 135d → none | 1532030ba → 9-130M FS+164d, 1532030ba |  |
| 1532075ba | Write DAQ Software Run Control FY13 | 2012-10-01 → 2013-08-30 A (+333d) | 2013-03-20 → 2013-08-30 A (+163d) | 113d → 166d | 0% → 100% | 135d → none | 1532075b → 9-130M FS+164d, 1532075b FS-220d |  |
| 1532077 | Write DAQ Software Scripts FY13 | 2013-03-04 → 2013-08-30 A (+179d) | 2013-08-28 → 2013-08-30 A (+2d) | 126d → 166d | 0% → 100% | 22d → none | 1532075a, 9-130M FS+100d → 9-130M FS+164d, 1532075a FS-220d |  |
| 1532080a | Write Monitoring Scalers | 2012-10-01 → 2013-08-30 A (+333d) | 2013-04-01 → 2013-08-30 A (+151d) |  | 0% → 100% | 295d → none | 9-130M, 1532035aa → 9-130M FS+110d, 1532035aa FS+100d |  |
| 1532080d | Write Monitoring Hardware Status FY12 | 2012-06-01 → 2013-08-30 A (+455d) | 2012-09-28 → 2013-08-30 A (+336d) | 84d → 95d | 0% → 100% | 290d → none | 1532035da → 9-130M FS+164d, 1532035da |  |
| 1532080da | Write Monitoring Hardware Status FY13 | 2012-10-01 → 2013-08-30 A (+333d) | 2013-04-22 → 2013-08-30 A (+130d) | 136d → 95d | 0% → 100% | 290d → none | 1532080d → 9-130M FS+164d, 1532080d FS-95d |  |
| 1532080f | Write Monitoring Process Status | 2013-01-31 → 2013-08-30 A (+211d) | 2013-08-06 → 2013-08-30 A (+24d) | 131d → 129d | 0% → 100% | 216d → none | 9-130M FS+79d, 1532035fa → 1532035fa, 9-130M FS+130d |  |
| 1532080g | Write Monitoring Trigger | 2013-01-31 → 2013-08-30 A (+211d) | 2013-08-30 A | 149d → 347d | 0% → 100% | 20d → none | 9-130M FS+79d, 1532035ga → 9-130M, 1532035ga |  |
| 1532085 | Write Alarm Sys | 2013-01-31 → 2013-08-30 A (+211d) | 2013-08-13 → 2013-08-30 A (+17d) | 136d → 106d | 0% → 100% | 20d → none | 9-130M FS+79d, 1532040 → 9-130M FS+142d, 1532040 | resources SCIENTIST [256 h]; CONTRB UNIV LBR [440 h] → CONTRB UNIV LBR [440 h]; SCIENTIST [256 h] |
| 1532090 | Write Archiving DAQ Configuration | 2013-03-04 → 2013-08-30 A (+179d) | 2013-06-28 → 2013-08-30 A (+63d) | 84d → 86d | 0% → 100% | 22d → none | 1532045, 9-130M FS+100d → 9-130M FS+142d, 1532045 FS+100d |  |
| 1532090a | Write Archiving Run Info | 2013-03-04 → 2013-08-30 A (+179d) | 2013-08-28 → 2013-08-30 A (+2d) | 126d → 106d | 0% → 100% | 20d → none | 1532045a, 9-130M FS+100d → 9-130M FS+142d, 1532045a |  |
| 1532090b | Write Archiving Controls | 2013-03-04 → 2013-08-30 A (+179d) | 2013-08-28 → 2013-08-30 A (+2d) |  | 0% → 100% | 20d → none |  |  |
| 1532095 | Write Event Display FY12 | 2012-03-28 → 2013-08-30 A (+520d) | 2012-09-28 → 2013-08-30 A (+336d) | 130d → 220d | 0% → 100% | 20d → none | 9-120M, 1532050a → 1532050a, 9-130M FS+110d, 9-120M |  |
| 1532095a | Write Event Display FY13 | 2012-10-01 → 2013-08-30 A (+333d) | 2013-02-14 → 2013-08-30 A (+197d) | 90d → 220d | 0% → 100% | 20d → none | 1532095 → 1532095 FS-220d, 9-130M FS+30d |  |
| 1532100 | Write Storage Mngmnt | 2013-03-04 → 2013-08-30 A (+179d) | 2013-08-28 → 2013-08-30 A (+2d) | 126d → 200d | 0% → 100% | 20d → none |  | resources SCIENTIST [32 h]; COMP SCIENT [320 h] → COMP SCIENT [320 h]; SCIENTIST [32 h] |
| 1532105a | Write Experiment Control Display Management | 2012-10-15 → 2013-08-30 A (+319d) | 2013-04-15 → 2013-08-30 A (+137d) | 121d → 208d | 0% → 100% | 20d → none | 9-130M FS+10d, 1532060aa → 9-130M FS+110d, 1532060aa |  |
| 1532105b | Write Experiment Control Display Backup/Restore | 2013-03-04 → 2013-08-30 A (+179d) | 2013-05-30 → 2013-08-30 A (+92d) | 63d → 72d | 0% → 100% | 20d → none | 1532060ba, 9-130M FS+100d → 1532060ba, 9-130M FS+228d |  |

| ID | Task | Start | Finish | Duration | Complete | Total float | Predecessors | Other |
| --- | --- | --- | --- | --- | --- | --- | --- | --- |
| 1532105c | Write Experiment Control Magnet PS | 2013-03-04 → 2013-08-30 A (+179d) | 2013-08-28 → 2013-08-30 A (+2d) | 126d → 170d | 0% → 100% | 20d → none | 9-130M FS+100d, 1532060ca → 9-130M FS+130d, 1532060ca |  |
| 1532105h | Write Experiment Control Gas Systems | 2013-03-04 → 2013-08-30 A (+179d) | 2013-08-28 → 2013-08-30 A (+2d) | 126d → 200d | 0% → 100% | 20d → none |  |  |
| 1532105j | Write Experiment Control Temerature | 2013-03-04 → 2013-08-30 A (+179d) | 2013-08-28 → 2013-08-30 A (+2d) | 126d → 200d | 0% → 100% | 20d → none |  |  |
| 1532105k | Write Experiment Control Target | 2013-02-01 → 2013-08-30 A (+210d) | 2013-07-31 → 2013-08-30 A (+30d) | 126d → 201d | 0% → 100% | 20d → none |  |  |
| 1532210 | Re-Baseline Actuals Adjustment | 2013-08-30 A | 2013-08-30 A |  | 0% → 100% | 20d → none | 9-130M FS+227d → none |  |
| 2532000 | Purchased Labor (Sergey) | 2013-09-03 A | 2013-09-30 A |  | 0% → 100% | 247d → none |  |  |
| 2532013E | FY13 Travel (ONLINE COMP) | 2013-09-03 A | 2013-09-30 A |  | 0% → 100% | 501d → none |  |  |
| 2532020 | Coordination of online computing setup | 2013-09-03 A | 2013-09-30 A |  | 0% → 100% | 129d → none |  |  |
| 2532035 | Create scripts to launch and kill: CODA system, monitoring system FY13 | 2013-09-03 A | 2013-09-30 → 2014-01-17 (+109d) |  |  |  |  |  |
| 2532035a | Create scripts to launch and kill: CODA system, monitoring system FY14 | 2013-10-01 → 2013-09-03 A (-28d) |  |  |  |  | 9-130M FS+228d, 2532035 → 2532035 FS-80d |  |
| 2532040 | Run bookkeeping scripts (database;data files and special events) FY13 | 2013-09-03 A | 2013-09-30 → 2014-03-13 (+164d) |  |  |  |  |  |
| 2532040a | Run bookkeeping scripts (database;data files and special events) FY14 | 2013-10-01 → 2013-09-03 A (-28d) |  |  |  |  | 2532040, 9-130M FS+228d → 2532040 FS-120d |  |
| 2532050 | Readout Lists FY13 | 2013-09-03 A | 2013-09-30 → 2014-04-21 (+203d) |  |  |  |  |  |
| 2532050a | Readout Lists FY14 | 2013-10-01 → 2013-09-03 A (-28d) |  |  |  |  | 9-130M FS+228d, 2532050 → 2532050 FS-140d |  |
| 2532070 | Implement Translation Tables FY13 | 2013-09-03 A | 2013-09-30 → 2014-01-17 (+109d) |  |  |  |  |  |
| 2532070a | Implement Translation Tables FY14 | 2013-10-01 → 2013-09-03 A (-28d) |  |  |  |  | 2532030 FS-118d, 2532070 → 2532070 FS-100d |  |
| 2532075 | Farm Process Manager | 2013-12-02 → 2013-09-03 A (-90d) |  |  | 0% → 30% |  | 2532030 FS-56d → 2532030 FS-100d |  |
| 2532080 | ROOTSpy enabled Monitoring Processes FY13 | 2013-09-03 A | 2013-09-30 → 2014-02-04 (+127d) |  | 0% → 12% |  |  |  |
| 2532080a | ROOTSpy enabled Monitoring Processes FY14 | 2013-10-01 → 2013-09-03 A (-28d) |  |  | 0% → 12% |  | 2532030 FS-118d, 2532080 → 2532080 FS-80d |  |
| 2532170a | HV Controls (FDC; CDC; TOF; FCAL; HODO) Phase 2 FY13 | 2013-09-03 A | 2013-09-30 → 2014-05-30 (+242d) | 20d → 105d | 0% → 25% | 162d → 85d |  |  |
| 2532170aa | HV Controls (FDC; CDC; TOF; FCAL; HODO) Phase 2 FY14 | 2013-10-01 → 2013-09-03 A (-28d) | 2014-02-11 → 2014-05-30 (+108d) |  | 0% → 25% | 162d → 85d | 2532170a, 9-130M FS+228d → 2532170a FS-140d |  |
| 2532175 | LV Controls (BCAl; ST; FDC) FY13 | 2013-09-03 A | 2013-09-30 → 2013-09-23 A (-7d) | 20d → 140d | 0% → 100% | 0d → none |  |  |
| 2532175b | LV Controls (BCAl; ST; FDC) FY14 | 2013-10-01 → 2013-09-03 A (-28d) | 2014-04-01 → 2013-09-23 A (-190d) |  | 0% → 100% | 0d → none | 2532175, 9-130M FS+228d → 2532175 |  |
| 2532205 | Motors (radiator, converter, collimator, tagger) FY13 | 2013-09-03 A | 2013-09-30 → 2014-03-04 (+155d) |  |  |  |  |  |
| 2532205a | Motors (radiator, converter, collimator, tagger) FY14 | 2013-10-01 → 2013-09-03 A (-28d) |  |  |  |  | 9-130M FS+228d, 2532205 → 2532205 FS-100d |  |
| 2532215 | CSS Control GUIs FY13 | 2013-09-03 A | 2013-09-30 → 2014-03-17 (+168d) |  |  |  |  |  |
| 2532215a | CSS Control GUIs FY14 | 2013-10-01 → 2013-09-03 A (-28d) |  |  |  |  | 9-130M FS+228d, 2532215 → 2532215 FS-110d |  |
| 2532230 | Alarms (configuration,display, history) FY13 | 2013-09-03 A | 2013-09-30 → 2013-11-08 (+39d) | 20d → 45d | 0% → 20% | 83d → 79d |  |  |
| 2532230a | Alarms (configuration,display, history) FY14 | 2013-10-01 → 2013-09-03 A (-28d) | 2013-11-04 → 2013-11-08 (+4d) |  | 0% → 20% | 83d → 79d | 9-130M FS+228d, 2532230 → 2532230 FS-25d |  |
| 2532175a | LV Controls (BCAl; ST; FDC) Phase 2 | 2014-04-02 → 2013-09-16 A (-198d) | 2014-09-30 → 2014-07-15 (-77d) |  | 0% → 75% | 0d → 54d |  |  |
| 2532005 | Install OS system along with network settings FY13 | 2013-09-03 → 2013-10-01 A (+28d) | 2013-09-30 → 2013-12-03 (+64d) |  | 0% → 50% | 81.25d → 58d | 9-130M FS+228d → 9-130M FS+228d, 9-140M FS+10d | was named Install OS system along with network 9settings FY13 |
| 2532005a | Install OS system along with network settings FY14 | 2013-10-01 A | 2013-10-29 → 2013-12-03 (+35d) |  | 0% → 50% | 81.25d → 58.25d | 9-130M FS+228d, 2532005 → 2532005 FS-25d | was named Install OS system along with network 9settings FY14 |
| 2532014E | FY14 Travel (ONLINE COMP) | 2013-10-01 A |  |  | 0% → 9% |  |  |  |
| 2532085 | Archiving and Retrieval of Histogram Files | 2014-03-04 → 2013-10-21 A (-134d) |  |  | 0% → 30% |  | 2532030, 9-140M FS+99d → 9-140M, 2532030 FS-80d |  |
| 2532250 | EPICS Archving and Restoration FY13 | 2013-09-03 → 2013-11-01 (+59d) | 2013-09-30 → 2013-12-02 (+63d) |  |  |  |  |  |
| 2532190 | Sweeping and pair spectrometer magnet control SWT (accel Grp) | 2013-11-12 → 2013-12-02 (+20d) | 2014-02-10 → 2014-02-26 (+16d) |  |  | 36d → 24d | 2553035 FS+30d → 2553035 FS+30d, 9-140M FS+42d |  |
| 2532250a | EPICS Archving and Restoration FY14 | 2013-10-01 → 2013-12-03 (+63d) | 2014-03-31 → 2014-04-28 (+28d) | 119d → 96d |  |  | 9-130M FS+228d, 2532250 → 2532250 |  |
| 2532015 | Database web-server wiki installations | 2013-12-02 → 2013-12-04 (+2d) | 2014-01-27 → 2014-01-29 (+2d) |  |  | 60d → 58d |  |  |
| 2532185 | Tagger magnet and NMR control SWT (accel Grp) | 2013-11-05 → 2013-12-10 (+35d) | 2014-01-29 → 2014-03-07 (+37d) | 51d → 55d |  | 44d → 17d | 2562050a FS+17d, 2562050 FS+17d → 9-140M FS+42d, 2562050a FS+17d, 2562050 FS+17d |  |
| 2532135 | BCAL Gas System Controls | 2014-01-02 → 2013-12-16 (-17d) | 2014-02-19 → 2014-02-12 (-7d) |  |  | 29d → 34d |  |  |
| 2532130 | FDC/CDC Gas Systems Controls | 2013-11-12 → 2013-12-17 (+35d) | 2014-01-24 → 2014-02-26 (+33d) |  |  | 47d → 24d |  |  |
| 2532155 | Cryo Target Controls | 2014-01-09 → 2014-01-07 (-2d) | 2014-03-20 → 2014-03-18 (-2d) |  |  | 8d → 10d |  |  |
| 2532200 | Vacuum System Controls (accel Grp) | 2014-01-14 → 2014-01-10 (-4d) | 2014-03-06 → 2014-03-04 (-2d) |  |  | 18d → 20d |  |  |
| 2532110 | Archiving Run Conditions | 2014-01-15 → 2014-01-13 (-2d) | 2014-09-30 → 2014-09-26 (-4d) |  |  | 0d → 2d |  |  |
| 2532195 | Active collimator integration EPICS (Acceler grp) | 2014-01-17 → 2014-01-15 (-2d) | 2014-09-22 → 2014-09-18 (-4d) |  |  | 6d → 8d |  |  |
| 2532235 | Scaler Monitoring in EPICS | 2014-01-17 → 2014-01-15 (-2d) | 2014-09-30 → 2014-09-26 (-4d) |  |  | 0d → 2d | 9-140M FS+68d → 9-140M FS+68d, 2562830a |  |
| 2532240 | Trigger Monitoring in EPICS | 2014-01-17 → 2014-01-15 (-2d) | 2014-09-30 → 2014-09-26 (-4d) |  |  | 0d → 2d |  |  |
| 2532150 | FCAL Dark Room Controls | 2014-02-10 → 2014-02-06 (-4d) | 2014-04-08 → 2014-04-04 (-4d) |  |  | 65d → 67d |  |  |
| 2532090 | Event Display | 2014-03-05 → 2014-03-04 (-1d) | 2014-08-25 → 2014-08-22 (-3d) |  |  | 25d → 26d |  |  |
| 2532255 | Coherent Peak Alignment Software with Goniometer | 2014-04-01 → 2014-04-15 (+14d) | 2014-09-22 → 2014-09-17 (-5d) | 122d → 109d |  | 6d → 9d | 2532250a, 2532250 → 2532250a FS-10d, 2532250 |  |
| 4 | **1.5.4 ELECTRONICS** | 2008-11-03 → 2008-11-06 (+3d) |  |  |  |  |  |  |
| 1541010E | FY10 Travel (FADC) | 2009-10-01 A | 2010-09-30 A |  | 0% → 100% | 438d → none |  |  |
| 1541075 | Implement DC Features Extraction Algorithms (FADC) | 2011-12-14 → 2009-10-26 A (-779d) | 2012-01-26 → 2013-08-30 A (+582d) | 25d → 785d | 0% → 100% | 395d → none | 1541070, 9-120M → 9-120M FS-1000d, 1541070 FS-1000d |  |
| 1541029 | Vend Fab First Article fADCs for PMTs (FADC) | 2010-06-07 A | 2010-09-10 → 2011-07-25 A (+318d) | 68d → 282d | 0% → 100% | 326d → none |  | was named Vend Fab First Article fADCs for PMTs (FADC) (IPL 5541140M); resources PROCUREMENT<$50K 60; PROCUREMENT>$50K 69 → PROCUREMENT>$50K 69; PROCUREMENT<$50K 60 |
| 1541084 | First Articles fADCs for DCs (FADC) (IPL 5541170) | 2010-07-02 → 2010-06-28 A (-4d) | 2010-12-29 → 2010-11-30 A (-29d) | 120d → 108d | 0% → 100% | 467d → none |  |  |
| 1541005 | Calibrate ADC gain and linearity (FADC) 1543016 | 2010-10-01 A | 2010-11-04 → 2013-07-15 A (+984d) | 25d → 611d | 0% → 100% | 253d → none |  | was named Calibrate ADC gain and linearity (FADC); resources ELEC TECH [880 h]; SCIENTIST [440 h] → SCIENTIST [440 h]; ELEC TECH [880 h] |
| 1541011E | FY11 Travel (FADC) | 2010-10-01 A | 2011-09-30 A |  | 0% → 100% | 438d → none |  |  |
| 1541010 | Develop gain correction database for FADC in FPGA (FADC) 1543016 | 2010-11-05 → 2010-11-01 A (-4d) | 2010-12-13 → 2013-08-30 A (+991d) | 25d → 590d | 0% → 100% | 253d → none | 9-110M, 1541005 → 1541005 FS-250d, 9-110M | was named Develop gain correction database for FADC in FPGA (FADC) |
| 1541030 | fADC250 - Full Single-Crate Acceptance Test (FADC) | 2011-06-06 → 2011-07-25 A (+49d) | 2011-09-09 → 2011-08-31 A (-9d) | 68d → 28d | 0% → 100% | 147d → none | 1541015, 1541029, 9-110M FS+165d → 1541015 FS-325d, 9-110M FS+165d, 1541029 FS-40d |  |
| 1541040 | fADC250 - Production Procurement Support (FADC) FY11 | 2011-08-10 → 2011-07-25 A (-16d) | 2011-09-30 → 2011-11-14 A (+45d) | 37d → 79.36d | 0% → 100% | 147d → none | 1541030 FS-22d → 1541030 FS-70d |  |
| 1541040a | fADC250 - Production Procurement Support (FADC) FY12 | 2011-10-03 → 2011-07-25 A (-70d) | 2011-11-04 → 2011-11-14 A (+10d) | 25d → 80d | 0% → 100% | 147d → none | 1541040 → 1541040 FS-25d |  |
| 1541085 | fADC125 - Procurement Support Pre Production Modules (QTY 3) | 2011-03-07 → 2011-07-25 A (+140d) | 2011-06-10 → 2012-03-19 A (+283d) | 69d → 160d | 0% → 100% | 423d → none |  |  |
| 1541012E | FY12 Travel (FADC) | 2011-10-03 A | 2012-09-28 A |  | 0% → 100% | 438d → none |  |  |
| 1541112 | Test stand for testing/acceptance of FADC125 | 2011-11-01 → 2011-12-01 A (+30d) | 2012-04-27 → 2013-02-11 A (+290d) | 119d → 282d | 0% → 100% | 302d → none | 1541100 FS-119d, 9-120M → 9-120M, 1541100 FS-160d |  |
| 1541045 | fADC250 - Production (FADC) | 2012-01-04 → 2012-01-03 A (-1d) | 2012-11-30 → 2012-11-12 A (-18d) | 231d → 220d | 0% → 100% | 113d → none |  |  |
| 1541065 | Assemble DC Logic/Signal Analyzers (FADC) (in 6 GeV also) | 2011-10-03 → 2012-02-01 A (+121d) | 2011-11-04 → 2012-02-13 A (+101d) | 25d → 9d | 0% → 100% | 395d → none | 9-120M → 9-120M FS+61d |  |
| 1541085b | fADC125 - Pre Production Modules (QTY 3) | 2011-12-05 → 2012-02-01 A (+58d) | 2012-03-02 → 2012-04-16 A (+45d) | 57d → 53d | 0% → 100% | 302d → none | 1541085, 9-120M FS+43d → 1541085 FS-80d, 9-120M FS+43d |  |
| 1541125 | fADC125 - Procurement Support (FADC) | 2011-10-18 → 2012-02-01 A (+106d) | 2011-10-31 → 2012-06-11 A (+224d) | 10d → 91d | 0% → 100% | 343d → none | 9-120M FS+11d → 9-120M |  |
| 1541070 | Implement DC CODA Libraries (FADC) (in 6 GeV also) | 2011-11-07 → 2012-02-13 A (+98d) | 2011-12-13 → 2012-02-20 A (+69d) | 25d → 5d | 0% → 100% | 395d → none |  |  |
| 1541080 | Dry Run of Test DC Procedures (FADC) (in 6 GeV also) | 2012-01-27 → 2012-02-20 A (+24d) | 2012-03-02 → 2012-02-27 A (-4d) | 25d → 5d | 0% → 100% | 395d → none |  |  |

| ID | Task | Start | Finish | Duration | Complete | Total float | Predecessors | Other |
| --- | --- | --- | --- | --- | --- | --- | --- | --- |
| 1541015 | Implement PMT Features Extraction Algorithms (FADC) | 2010-12-14 → 2012-04-02 A (+475d) | 2010-12-31 → 2013-07-15 A (+927d) | 9d → 243d | 0% → 100% | 253d → none | 9-110M, 1541010 → 1541010 FS-200d, 9-110M |  |
| 1541100 | fADC125 - Test Pre Production Modules (QTY 3) | 2012-01-11 → 2012-04-09 A (+89d) | 2012-04-27 → 2012-07-09 A (+73d) | 76d → 64d | 0% → 100% | 302d → none | 1541085b FS-36d → 1541085b FS-213d |  |
| 1541130 | Vend Fab FADC125 Peg Points #1 and # 2 Board Samples Mezzanine and Main | 2012-07-13 → 2012-07-14 A (+1d) | 2012-08-31 → 2012-11-12 A (+73d) | 36d → 85d | 0% → 100% | 172d → none |  |  |
| 1541132 | Vend Fab FADC125 Peg Points #3 and # 4 First Article Mezzanine and Main (Qty. 1 Each) | 2012-07-13 → 2012-07-14 A (+1d) | 2012-10-31 → 2013-03-11 A (+131d) | 78d → 123d | 0% → 100% | 172d → none |  |  |
| 1541134 | Vend Fab FADC125 Peg Points #5 and # 6 Production Units Mezzanine and Main (Qty. 50 Each) | 2012-07-13 → 2012-07-14 A (+1d) | 2012-12-31 → 2013-04-15 A (+105d) | 114d → 175d | 0% → 100% | 178d → none |  |  |
| 1541136 | Vend Fab FADC125 Peg Points #7 and # 8 Production Units Mezzanine and Main (Qty. 50 Each) | 2012-07-13 → 2012-07-14 A (+1d) | 2012-12-31 → 2013-05-13 A (+133d) | 114d → 175d | 0% → 100% | 178d → none |  |  |
| 1541138 | Vend Fab FADC125 Peg Points #9 and # 10 Production Units Mezzanine and Main (Qty. 50 Each) | 2012-07-13 → 2012-07-14 A (+1d) | 2013-01-31 → 2013-06-17 A (+137d) | 135d → 199d | 0% → 100% | 178d → none |  |  |
| 1541143 | Vend Fab FADC125 Peg Points #11 and # 12 Production Units Mezzanine and Main (Qty. 66 Each) | 2012-07-13 → 2012-07-14 A (+1d) | 2013-01-31 → 2013-08-30 A (+211d) | 135d → 199d | 0% → 100% | 178d → none |  |  |
| 1541057 | UMASS - fADC250 - Production Test (FADC) Rediness Review | 2012-09-24 → 2012-09-17 A (-7d) | 2012-09-28 A | 5d → 10d | 0% → 100% | 113d → none |  |  |
| 1541013E | FY13 Travel (FADC) | 2012-10-01 A | 2012-12-21 → 2012-12-31 A (+10d) |  | 0% → 100% | 438d → none |  |  |
| 1541058M | UMASS - Begin fADC250 - Production Test (FADC) | 2012-10-31 → 2012-10-22 A (-9d) | 2012-10-31 → 2012-10-22 A (-9d) |  | 0% → 100% | 113d → none |  |  |
| 1541059 | UMASS - fADC250 - Production Test (FADC) | 2012-10-31 → 2012-10-22 A (-9d) | 2013-03-29 → 2013-02-11 A (-46d) | 98d → 105d | 0% → 100% | 113d → none |  |  |
| 1541145 | fADC125 - Test (Qty 217) (FADC) | 2013-05-03 → 2013-05-01 A (-2d) | 2013-08-30 A | 84d → 112d | 0% → 100% | 51d → none |  |  |
| 1541060 | Assy of fADC PMT as part of Trigger (FADC) | 2012-12-03 → 2013-07-01 A (+210d) | 2013-03-13 → 2013-07-15 A (+124d) |  | 0% → 100% | 140d → none | 1541045 → 9-130M FS+110d, 1541045 |  |
| 1541120 | fADC125 - Full Single-Crate Acceptance Test (FADC) | 2013-05-21 → 2013-08-30 A (+101d) | 2013-07-18 → 2013-08-30 A (+43d) |  | 0% → 100% | 51d → none | 1541145 FS-72d, 9-130M FS+80d → 1541145 FS-100d, 9-130M FS+80d |  |
| 1541150 | Re-Baseline Actuals Adjustment | 2013-08-30 A | 2013-08-30 A |  | 0% → 100% | 20d → none | 9-130M FS+227d → none |  |
| 2541000 | Vend Fab FADC-125 (Previously Obligated) | 2013-09-03 A |  |  |  |  |  | resources PROCUREMENT>$50K 69 NO ESCALATION → PROCUREMENT<$50K 60 NO ESCALATION FY14 |
| 2541015 | Rework of Production FADC Modules (FE) FY13 | 2013-09-03 A | 2013-09-30 → 2014-07-10 (+283d) |  | 0% → 30% |  |  |  |
| 2541015a | Rework of Production FADC Modules (FE) FY14 | 2013-10-01 → 2013-09-03 A (-28d) |  |  | 0% → 30% |  | 9-130M FS+228d, 2541015 → 2541015 FS-200d |  |
| 2541145 | fADC125 - Test (Qty 217) (FADC) FY13 | 2013-09-03 A | 2013-09-30 → 2013-09-23 A (-7d) |  | 0% → 100% | 111d → none |  |  |
| 2541145a | fADC125 - Test (Qty 217) (FADC) FY14 | 2013-10-01 → 2013-09-03 A (-28d) | 2013-11-27 → 2013-09-23 A (-65d) |  | 0% → 100% | 111d → none | 9-130M FS+228d, 2541145 → 2541145 |  |
| 2541150 | FADC125 Production firmware development FY13 (Hall D EE) | 2013-09-03 A | 2013-09-30 → 2013-12-20 (+81d) |  | 0% → 35% | 1d → 1.25d |  |  |
| 2541150a | FADC125 Production firmware development FY14 (Hall D EE) | 2013-10-01 → 2013-09-03 A (-28d) |  |  | 0% → 35% |  | 2541150, 9-130M FS+228d → 2541150 FS-60d |  |
| 2541120 | fADC125 - Full Single-Crate Acceptance Test (FADC) FY13 | 2013-09-09 → 2013-11-01 (+53d) | 2013-09-30 → 2013-11-22 (+53d) |  |  | 111d → 140d |  |  |
| 2541152 | Algorithm Development for DC FADC125 FY13 | 2013-09-03 → 2013-11-01 (+59d) | 2013-09-30 → 2013-12-02 (+63d) |  |  |  |  |  |
| 2541120a | fADC125 - Full Single-Crate Acceptance Test (FADC) FY14 | 2013-10-01 → 2013-11-25 (+55d) | 2013-12-20 → 2014-02-26 (+68d) |  |  | 111d → 141d | 2541120, 2541145a FS-58d, 2541145 FS-58d → 2541120, 2541145a FS-58d |  |
| 2541152a | Algorithm Development for DC FADC125 FY14 | 2013-10-01 → 2013-12-03 (+63d) |  | 219d → 176d |  |  | 9-130M FS+228d, 2541152 → 2541152 |  |
| 2 | **1.5.4.2 TDC** | 2008-11-03 → 2008-11-06 (+3d) | 2014-09-30 → 2014-08-06 (-55d) |  |  |  |  |  |
| 1542025 | Phase 1 Proc TDCs (TDC) | 2008-11-03 → 2008-11-06 A (+3d) | 2009-10-30 → 2009-03-02 A (-242d) | 247d → 73d | 0% → 100% | 370d → none |  | resources PROCUREMENT<$50K 60 NO ESCALATION FY10; PROCUREMENT>$50K 69 NO ESCALATION FY10 → PROCUREMENT>$50K 69 NO ESCALATION FY10; PROCUREMENT<$50K 60 NO ESCALATION FY10 |
| 1542010 | Measure cross talk for CFD & TDC (TDC) | 2010-12-03 → 2010-09-06 A (-88d) | 2010-12-31 → 2010-09-27 A (-95d) | 15.5d → 15d | 0% → 100% | 85d → none |  | resources ELEC TECH [313.56 h]; SCIENTIST [171.04 h] → SCIENTIST [171.04 h]; ELEC TECH [313.56 h] |
| 1542005 | Assemble Logic/Signal Analyzers (TDC) (in 6 GeV also) | 2010-10-01 → 2010-09-13 A (-18d) | 2010-12-03 → 2010-09-20 A (-74d) | 43.5d → 5.5d | 0% → 100% | 85d → none |  |  |
| 1542011E | FY11 Travel (TDC) | 2010-10-01 A | 2011-09-30 A |  | 0% → 100% | 190d → none |  |  |
| 1542025a | F1TDC - First Article Procurement Support (TDC) | 2011-01-04 → 2011-01-05 A (+1d) | 2011-05-13 → 2012-06-11 A (+395d) | 92d → 357d | 0% → 100% | 85d → none |  | resources ELEC TECH [240 h]; ELEC ENG [160 h] → ELEC ENG [160 h]; ELEC TECH [240 h] |
| 1542026 | F1TDC - Parts (TDC) | 2011-01-18 → 2011-02-01 A (+14d) | 2011-07-08 → 2012-06-11 A (+339d) | 121d → 339d | 0% → 100% | 85d → none |  |  |
| 1542012E | FY12 Travel (TDC) | 2011-10-03 A | 2012-09-28 A |  | 0% → 100% | 190d → none |  |  |
| 1542027 | F1TDC - First Article Fab V2 (QTY 2) (TDC) | 2011-08-29 → 2011-12-03 A (+96d) | 2011-09-16 → 2011-12-19 A (+94d) | 14d → 11d | 0% → 100% | 85d → none | 1542026 FS+35d → 1542026 FS-50d |  |
| 1542015 | Dry Run of Test Procedures TDC | 2011-03-10 → 2012-02-01 A (+328d) | 2011-07-29 → 2012-10-15 A (+444d) | 100d → 180d | 0% → 100% | 305d → none | 1542010 FS+45d → 1542010 FS+280d |  |
| 1542030 | F1TDC - First Article Assembly V2 (QTY 2) (TDC) | 2011-09-19 → 2012-02-01 A (+135d) | 2011-10-07 → 2012-04-16 A (+192d) | 15d → 53d | 0% → 100% | 85d → none |  |  |
| 1542030a | F1TDC - First Article Test V2 (QTY 2) (TDC) | 2012-03-26 → 2012-04-15 A (+20d) | 2012-07-13 → 2012-07-09 A (-4d) | 78d → 59d | 0% → 100% | 21d → none | 9-120M FS+115d, 1542030 → 1542030, 9-120M |  |
| 1542036 | Test stand for testing/acceptance of F1TDC | 2011-10-03 → 2012-05-01 A (+211d) | 2012-01-13 → 2013-04-15 A (+458d) | 67d → 216d | 0% → 100% | 261d → none | 1542010, 9-120M, 1542015 → 1542015 FS-40d, 9-120M, 1542010 |  |
| 1542031 | F1TDC - First Article Fab V3 (QTY 2) (TDC) | 2011-10-31 → 2012-06-02 A (+215d) | 2011-11-11 → 2012-07-09 A (+241d) | 10d → 25d | 0% → 100% | 85d → none | 1542030 FS+15d → 1542030 |  |
| 1542040 | F1TDC - Production Procurement Prep (TDC) | 2012-12-17 → 2012-07-02 A (-168d) | 2013-03-22 → 2012-09-17 A (-186d) | 62d → 55d | 0% → 100% | 58d → none | 1542037 FS-28d → 1542037 FS-150d |  |
| 1542031a | F1TDC - First Article Assembly V3 (QTY 2) (TDC) | 2011-11-21 → 2012-07-15 A (+237d) | 2012-01-27 → 2012-07-23 A (+178d) | 41d → 6d | 0% → 100% | 85d → none | 1542031 FS+5d → 1542031 |  |
| 1542031b | F1TDC - First ArticleTest V3 (QTY 2) (TDC) | 2012-04-16 → 2012-09-03 A (+140d) | 2012-06-29 → 2012-09-17 A (+80d) | 53d → 10d | 0% → 100% | 31d → none | 9-120M FS+130d, 1542031a → 9-120M, 1542031a FS-15d | resources ELEC ENG [96 h]; ELEC TECH [136 h] → ELEC TECH [136 h]; ELEC ENG [96 h] |
| 1542032 | F1TDC - First Article Fab (QTY 18) (TDC) | 2012-07-16 → 2012-09-03 A (+49d) | 2012-08-10 → 2013-02-11 A (+185d) | 20d → 85d | 0% → 100% | 21d → none |  |  |
| 1542035 | F1TDC - First Article Assembly (QTY 18) (TDC) | 2012-08-13 → 2012-09-03 A (+21d) | 2012-10-31 → 2013-02-11 A (+103d) | 57d → 85d | 0% → 100% | 21d → none | 1542032 → 1542032 FS-70d |  |
| 1542042 | F1TDC - Production (TDC) | 2013-05-02 → 2012-09-10 A (-234d) | 2013-08-30 → 2013-04-15 A (-137d) | 85d → 138d | 0% → 100% | 58d → none | 1542040 FS+28d → 1542040 |  |
| 1542013E | FY13 Travel (TDC) | 2012-10-01 A | 2012-12-21 → 2012-12-31 A (+10d) |  | 0% → 100% | 190d → none |  |  |
| 1542045 | UMASS - F1TDC - Production Test (TDC) Readiness Review | 2013-06-07 → 2012-11-06 A (-213d) | 2013-06-13 → 2012-11-12 A (-213d) |  | 0% → 100% | 21d → none | 1542042 FS-97d, 1542035a FS-5d → 1542042 FS-97d, 1542035a FS-50d |  |
| 1542050M | UMASS - Begin F1TDC - Production Test (F1TDC) | 2013-06-14 → 2012-11-13 A (-213d) | 2013-06-14 → 2012-11-13 A (-213d) |  | 0% → 100% | 21d → none |  | was named UMASS - Begin fADC250 - Production Test (FADC) |
| 1542055 | UMASS - F1TDC - Production Test (F1TDC) | 2013-06-14 → 2012-11-13 A (-213d) | 2013-08-29 → 2013-05-13 A (-108d) | 54d → 94d | 0% → 100% | 21d → none | 1542050M → 1542050M, 1542050M SS | was named UMASS - fADC250 - Production Test (FADC) |
| 1542035a | F1TDC - First ArticleTest V2 (QTY 18) (TDC) | 2012-11-01 → 2013-02-11 A (+102d) | 2013-06-13 → 2013-02-23 A (-110d) | 150d → 10d | 0% → 100% | 21d → none |  |  |
| 1542037 | F1TDC - Full Single-Crate Acceptance Test (TDC) | 2012-11-01 → 2013-04-15 A (+165d) | 2013-02-01 → 2013-08-30 A (+210d) |  | 0% → 100% | 58d → none |  |  |
| 1542060 | Re-Baseline Actuals Adjustment | 2013-08-30 A | 2013-08-30 A |  | 0% → 100% | 20d → none | 9-130M FS+227d → none |  |
| 2542037 | F1TDC - Full Single-Crate Acceptance Test (TDC) | 2013-09-03 A | 2013-09-20 → 2013-09-18 A (-2d) |  | 0% → 100% | 253d → none |  |  |
| 2542070 | F1TDC develop firmware FY13 | 2013-09-03 A | 2013-09-30 → 2013-10-21 A (+21d) |  | 0% → 100% | 0d → none |  |  |
| 2542070a | F1TDC develop firmware FY14 | 2013-10-01 → 2013-09-03 A (-28d) | 2014-01-07 → 2013-10-21 A (-78d) |  | 0% → 100% | 0d → none | 2542070, 9-130M FS+228d → 2542070 FS-75d |  |
| 2542085 | Rework of Production F1TDC modules | 2013-10-10 → 2013-09-03 A (-37d) |  |  | 0% → 40% |  | 9-140M FS+7d → 9-140M |  |
| 2542090 | F1TDC EE Hardware/Software Support FY14 | 2014-01-08 → 2013-11-01 (-68d) | 2014-09-30 → 2014-08-06 (-55d) |  |  | 0d → 38d |  |  |
| 2542075 | FPGA Coding, Hardware & Firmware Integration Tests F1TDC | 2014-01-29 → 2013-11-11 (-79d) | 2014-03-31 → 2014-01-24 (-66d) |  |  | 84d → 130d |  |  |
| 2542080 | Code Deployment and Full Readout Tests F1TDC | 2014-04-08 → 2014-02-03 (-64d) | 2014-06-02 → 2014-03-27 (-67d) |  |  | 84d → 130d |  |  |
| 1543010E | FY10 Travel (TRIGR) | 2009-10-01 A | 2010-09-30 A |  | 0% → 100% | 438d → none |  |  |
| 1543015 | Implement Features Extraction Algorithms | 2010-11-30 → 2010-09-01 A (-90d) | 2011-01-04 → 2010-09-30 A (-96d) | 20d → 21d | 0% → 100% | 606d → none |  |  |
| 1543011E | FY11 Travel (TRIGR) | 2010-10-01 A | 2011-09-30 A |  | 0% → 100% | 438d → none |  |  |
| 1543005 | Assemble Logic/Signal Analyzers for Energy Sum Tests (Trigger) | 2010-10-01 → 2011-02-01 A (+123d) | 2010-10-28 → 2011-02-28 A (+123d) | 20d → 19d | 0% → 100% | 606d → none |  |  |
| 1543010 | Implement CODA Libraries for Energy Sum (Trigger) (in 6 GeV also) | 2010-10-29 → 2011-02-01 A (+95d) | 2010-11-29 → 2011-02-28 A (+91d) | 20d → 19d | 0% → 100% | 606d → none |  |  |
| 1543140 | Develop trigger algorithms FY11 | 2011-01-04 → 2011-03-01 A (+56d) | 2011-09-30 → 2013-07-15 A (+654d) | 189d → 452d | 0% → 100% | 209d → none |  |  |
| 1543140a | Develop trigger algorithms FY12 (Hall D grp) | 2011-10-03 → 2011-03-01 A (-216d) | 2011-12-30 → 2013-08-30 A (+609d) | 58d → 452d | 0% → 100% | 209d → none | 1543140 → 1543140 FS-205d |  |
| 1543125 | Procument equipment for testing FADC250 | 2011-01-04 → 2011-04-01 A (+87d) | 2011-05-16 → 2011-12-12 A (+210d) | 93d → 177d | 0% → 100% | 451d → none |  |  |
| 1543120 | Prepare test stand for testing/acceptance of FADC250 | 2011-01-04 → 2011-04-04 A (+90d) | 2011-05-16 → 2011-04-25 A (-21d) | 93d → 16d | 0% → 100% | 451d → none | 9-110M FS+59d → 9-110M FS+143d |  |

| ID | Task | Start | Finish | Duration | Complete | Total float | Predecessors | Other |
| --- | --- | --- | --- | --- | --- | --- | --- | --- |
| 1543050 | Preparing procument of SD boards | 2011-05-09 → 2011-05-16 A (+7d) | 2011-05-27 → 2012-01-16 A (+234d) | 15d → 164d | 0% → 100% | 219d → none |  |  |
| 1543035 | Preparing procument TI-D boards | 2011-07-06 → 2011-05-23 A (-44d) | 2011-09-07 → 2011-08-31 A (-7d) | 45d → 71d | 0% → 100% | 126d → none | 9-110M FS+186d → 9-110M |  |
| 1543080 | Preparing procument of GTP boards FY11 | 2011-09-19 → 2011-05-23 A (-119d) | 2011-09-30 → 2013-02-11 A (+500d) | 10d → 430d | 0% → 100% | 108d → none | 9-110M FS+238d → 9-110M |  |
| 1543080a | Preparing procument of GTP boards FY12 | 2011-10-03 → 2011-05-23 A (-133d) | 2011-10-19 → 2013-02-11 A (+481d) | 13d → 430d | 0% → 100% | 108d → none | 1543080 → 1543080 FS-130d |  |
| 1543016 | Programing FADC250 FPGAs FY11 | 2011-04-01 → 2011-06-01 A (+61d) | 2011-09-30 → 2012-07-09 A (+283d) | 128d → 274.46d | 0% → 100% | 235d → none | 9-110M FS+120d → 9-110M |  |
| 1543016a | Programing FADC250 FPGAs FY12 | 2011-10-03 → 2011-06-01 A (-124d) | 2012-03-30 → 2012-07-09 A (+101d) | 120d → 275d | 0% → 100% | 235d → none | 1543016 → 1543016 FS-120d |  |
| 1543135 | Develop FADC250 features extraction algorithms (readout) (Hall D grp) | 2011-10-03 → 2011-06-01 A (-124d) | 2012-03-30 → 2013-06-17 A (+444d) | 120d → 387d | 0% → 100% | 147d → none | 9-120M → 9-120M FS-75d |  |
| 1543110a | Testing of multi-crate board performance FY12 | 2011-10-03 → 2011-07-01 A (-94d) | 2011-12-01 → 2011-10-17 A (-45d) | 42d → 75d | 0% → 100% | 388d → none | 1543110 → 1543110 FS-70d |  |
| 1543105 | Full crate performance testing | 2011-03-01 → 2011-07-09 A (+130d) | 2011-08-30 → 2011-10-24 A (+55d) | 129d → 75d | 0% → 100% | 452d → none | 9-110M FS+97d → 9-110M |  |
| 1543110 | Testing of multi-crate board performance FY11 | 2011-05-02 → 2011-07-11 A (+70d) | 2011-09-30 → 2011-10-17 A (+17d) | 107d → 69.26d | 0% → 100% | 388d → none | 9-110M FS+141d → 9-110M |  |
| 1543130 | Implement playback mode | 2012-06-01 → 2011-08-01 A (-305d) | 2012-09-28 → 2011-12-19 A (-284d) | 84d → 97.16d | 0% → 100% | 20d → none | 9-120M FS+163d → 9-120M FS-21d | resources ELEC ENG [240 h]; SCIENTIST [120 h] → SCIENTIST [120 h]; ELEC ENG [240 h] |
| 1543012E | FY12 Travel (TRIGR) | 2011-10-03 A | 2012-09-28 A |  | 0% → 100% | 438d → none |  |  |
| 1543095 | Preparing procument of Fiber Optics Cable/Patch Pannel | 2011-10-03 → 2011-11-07 A (+35d) | 2011-10-28 → 2013-08-30 A (+672d) | 20d → 275d | 0% → 100% | 370d → none |  |  |
| 1543017 | Preparing procument of TS board | 2012-05-07 → 2011-12-05 A (-154d) | 2012-05-30 → 2012-02-13 A (-107d) | 17d → 44d | 0% → 100% | 256d → none | 9-120M FS+145d → 9-120M |  |
| 1543085 | Procument of GTP boards (FE grp) Part A | 2012-02-01 → 2012-01-09 A (-23d) | 2013-05-30 → 2012-11-12 A (-199d) | 332d → 216d | 0% → 100% | 43d → none | 1543080a, 9-120M FS+78d → 1543080a FS-125d, 9-120M |  |
| 1543040 | Procument of TI-D boards (FE grp) Part A | 2011-10-03 → 2012-01-16 A (+105d) | 2012-10-31 → 2012-11-12 A (+12d) | 270d → 211d | 0% → 100% | 111d → none | 1543035 FS+2d, 9-120M → 1543035 FS-70d, 9-120M | resources PROCUREMENT<$50K 60 NO ESCALATION FY13; PROCUREMENT>$50K 69 NO ESCALATION FY13 → PROCUREMENT>$50K 69 NO ESCALATION FY13; PROCUREMENT<$50K 60 NO ESCALATION FY13 |
| 1543055 | Procument of SD boards (FE grp) Part A | 2011-11-01 → 2012-01-16 A (+76d) | 2012-10-31 → 2012-09-17 A (-44d) | 249d → 171d | 0% → 100% | 111d → none |  |  |
| 1543020 | Procument of TS board (FE grp) | 2012-12-03 → 2012-02-03 A (-304d) | 2013-05-31 → 2012-02-20 A (-466d) | 121d → 11d | 0% → 100% | 128d → none |  |  |
| 1543060 | Acceptance test of SD boards (FE grp) FY12 | 2012-06-14 → 2012-06-02 A (-12d) | 2012-09-28 → 2012-10-22 A (+24d) | 76d → 98.23d | 0% → 100% | 111d → none |  |  |
| 1543060a | Acceptance test of SD boards (FE grp) FY13 | 2012-10-01 → 2012-06-02 A (-121d) | 2013-01-18 → 2012-10-22 A (-88d) | 72d → 99d | 0% → 100% | 111d → none | 1543055a FS-99d, 1543055 FS-99d, 1543060 → 1543060 FS-100d |  |
| 1543065 | Preparing procument of SSP boards FY11 | 2011-06-06 → 2012-06-02 A (+362d) | 2011-09-30 → 2012-06-11 A (+255d) | 83d → 5d | 0% → 100% | 266d → none | 9-110M FS+165d → 9-120M FS+160d |  |
| 1543065a | Preparing procument of SSP boards FY12 | 2011-10-03 → 2012-06-11 A (+252d) | 2011-10-07 → 2012-06-25 A (+262d) | 5d → 11d | 0% → 100% | 266d → none |  | was named Preparing procument of SSP boards FY12 (FE grp) |
| 1543023 | Preparing procument of CTP boards | 2011-05-03 → 2012-06-12 A (+406d) | 2011-07-11 → 2012-07-09 A (+364d) | 48d → 20d | 0% → 100% | 228d → none | 9-110M FS+142d → 9-120M |  |
| 1543070 | Procument of SSP boards (FE grp) | 2012-10-05 → 2012-06-18 A (-109d) | 2013-03-29 → 2013-02-11 A (-46d) | 116d → 127d | 0% → 100% | 20d → none | 1543065a, 9-130M FS+4d → 1543065a | resources PROCUREMENT>$50K 69; PROCUREMENT<$50K 60 → PROCUREMENT<$50K 60; PROCUREMENT>$50K 69 |
| 1543141 | Procure Equipment for Algorithm Test Stand ( Hall D grp ) Part A | 2012-05-01 → 2012-08-01 A (+92d) | 2012-08-31 → 2012-11-12 A (+73d) | 87d → 73d | 0% → 100% | 39d → none |  |  |
| 1543045 | Acceptance test of TI boards (FE grp) FY12 | 2012-06-14 → 2012-09-10 A (+88d) | 2012-09-28 → 2012-12-17 A (+80d) | 76d → 95d | 0% → 100% | 111d → none |  |  |
| 1543013E | FY13 Travel (TRIGR) | 2012-10-01 A | 2012-12-21 → 2012-12-31 A (+10d) |  | 0% → 100% | 438d → none |  |  |
| 1543040a | Procument of TI-D boards (FE grp) Part B | 2011-10-03 → 2012-10-01 A (+364d) | 2012-10-31 → 2012-11-12 A (+12d) | 270d → 31d | 0% → 100% | 111d → none | 1543035 FS+2d, 9-120M → 9-120M, 1543035 FS-70d | resources PROCUREMENT>$50K 69 NO ESCALATION FY13 → PROCUREMENT>$50K 69 |
| 1543055a | Procument of SD boards (FE grp) Part B | 2011-11-01 → 2012-10-01 A (+335d) | 2012-10-31 → 2012-10-22 A (-9d) | 249d → 16d | 0% → 100% | 111d → none |  |  |
| 1543025 | Procument of CTP boards (FE grp) | 2012-10-03 → 2012-12-03 A (+61d) | 2013-03-29 → 2013-08-30 A (+154d) | 118d → 41d | 0% → 100% | 20d → none | 1543023 FS+99d, 9-130M FS+2d → 9-130M, 1543023 | resources PROCUREMENT<$50K 60; PROCUREMENT>$50K 69 → PROCUREMENT>$50K 69; PROCUREMENT<$50K 60 |
| 1543100 | Procument Fiber Optics Cable/Patch Pannel (FE grp) | 2011-10-31 → 2012-12-03 A (+399d) | 2012-01-04 → 2013-08-30 A (+604d) | 40d → 140d | 0% → 100% | 370d → none | 1543095 → 1543095 FS-70d |  |
| 1543141a | Procure Equipment for Algorithm Test Stand ( Hall D grp ) Part B | 2012-05-01 → 2013-02-01 A (+276d) | 2012-08-31 → 2013-02-11 A (+164d) | 87d → 45d | 0% → 100% | 39d → none |  |  |
| 1543115 | Performance testing of global trigger system | 2013-05-31 → 2013-03-04 A (-88d) | 2013-08-30 A | 65d → 150d | 0% → 100% | 20d → none | 1543060a, 1543100, 182443005, 1543060, 1543110a, 182443015, 1543105, 182443000 FS-150d, 9-120M FS+65d, 182443010 → 9-120M FS+65d, 1543060a, 1543110a, 182443005, 1543105, 182443015 FS-120d, 1543100 FS-70d, 182443010 FS-120d, 182443000 FS-150d | resources ELEC ENG [277.33 h]; SCIENTIST [138.67 h] → ELEC ENG [640 h]; SCIENTIST [320 h] |
| 1543085a | Procument of GTP boards (FE grp) Part B | 2012-02-01 → 2013-05-03 A (+457d) | 2013-05-30 → 2013-06-17 A (+18d) | 332d → 64d | 0% → 100% | 43d → none | 9-120M FS+78d, 1543080a → 1543080a FS-30d, 9-130M FS+120d, 9-120M |  |
| 1543142 | Prepair Test Stand for Algorithm Testing, Test Algorithms ( Hall D grp ) | 2012-10-01 → 2013-05-03 A (+214d) | 2013-08-30 → 2013-08-26 A (-4d) | 228d → 267d | 0% → 100% | 20d → none | 1543141a, 9-130M, 9-120M FS+228d, 1543141 → 1543141, 9-120M FS+228d, 1543141a | was named Prepare Test Stand for Algorithm Testing, Test Algorithms ( Hall D grp ) |
| 1543150 | Re-Baseline Actuals Adjustment | 2013-08-30 A | 2013-08-30 A |  | 0% → 100% | 20d → none | 9-130M FS+227d → none |  |
| 2543025 | Procument of CTP boards (FE grp) (Previously Obligated) | 2013-09-03 A | 2013-09-30 → 2014-01-21 (+113d) |  |  | 148d → 78d |  |  |
| 2543030 | Procument of CTP boards (FE grp) | 2013-09-03 A | 2013-09-30 → 2013-09-23 A (-7d) |  | 0% → 100% | 148d → none |  |  |
| 2543160 | Trigger Board Initialization (Hall D grp) FY13 | 2013-09-03 A | 2013-09-30 → 2014-09-19 (+354d) |  |  |  |  |  |
| 2543160a | Trigger Board Initialization (Hall D grp) FY14 | 2013-10-01 → 2013-09-03 A (-28d) |  |  |  |  | 9-130M FS+228d, 2543160 → 2543160 FS-260d |  |
| 2543185 | Procument Structural Components for Trigger Modules (FE Grp) | 2013-09-03 A | 2013-09-25 → 2013-11-25 (+61d) |  |  | 250d → 207d |  |  |
| 2543150 | Develop Level-1 Monitor (Hall D grp) FY13 | 2013-09-03 → 2013-10-01 A (+28d) | 2013-09-30 → 2014-05-30 (+242d) |  | 0% → 10% | 251d → 286d | 9-130M FS+228d → 9-130M FS+228d, 9-140M FS+15d |  |
| 2543150a | Develop Level-1 Monitor (Hall D grp) FY14 | 2013-10-01 A |  |  | 0% → 10% | 251d → 286d | 9-130M FS+228d, 2543150 → 2543150 FS-150d |  |
| 2543100 | Procument Fiber Optics Cable/Patch Pannel (FE grp) | 2013-11-01 → 2013-10-21 A (-11d) |  |  | 0% → 2% |  | 9-140M FS+23d → 9-140M |  |
| 2543165 | Level-1 Verification and Debugging (Hall D grp) FY13 | 2013-09-03 → 2013-11-15 (+73d) | 2013-09-30 → 2013-12-16 (+77d) |  |  | 62d → 9d | 9-130M FS+228d → 9-140M FS+33d, 9-130M FS+228d |  |
| 2543170 | Level-1 Trigger Testbed Electronics (Hall D grp) | 2013-10-01 → 2013-12-05 (+65d) | 2014-01-17 → 2014-02-24 (+38d) | 69d → 49d |  | 4d → 1d | 9-140M → 9-140M FS+45d |  |
| 2543115 | Performance testing of global trigger system (FE grp) | 2013-10-01 → 2013-12-12 (+72d) | 2013-12-03 → 2014-02-24 (+83d) |  |  | 128d → 78d |  |  |
| 2543144 | Study Algorithms with Test Stand (Hall D grp) FY13 | 2013-09-03 → 2013-12-17 (+105d) | 2013-09-30 → 2014-01-24 (+116d) |  |  |  | 9-130M FS+228d → 9-140M FS+53d, 9-130M FS+228d |  |
| 2543165a | Level-1 Verification and Debugging (Hall D grp) FY14 | 2013-10-01 → 2013-12-17 (+77d) | 2014-07-02 → 2014-09-17 (+77d) |  |  | 62d → 9d | 9-130M FS+228d, 2543165 → 2543165 |  |
| 2543144a | Study Algorithms with Test Stand (Hall D grp) FY14 | 2013-10-01 → 2014-01-27 (+118d) |  | 183d → 110d |  |  | 2543144, 9-130M FS+228d → 2543144 |  |
| 2543143 | Trigger Algorithms Performance Testing in the Hall (Hall D grp) | 2014-01-09 → 2014-02-11 (+33d) |  | 184d → 162d |  |  |  |  |
| 1544005 | Vend Fab Crate DAQ Type Phase 1 (CRATES/RACKS) Peg Point #1 VXS Prototype | 2010-09-30 A | 2010-12-30 → 2011-01-24 A (+25d) | 59d → 74d | 0% → 100% | 445d → none |  |  |
| 1544005a | Vend Fab Crate DAQ Type Phase 1 (CRATES/RACKS) Peg Point #2 VME64X Qty 1 | 2010-09-30 A | 2011-02-28 → 2011-02-21 A (-7d) | 98d → 93d | 0% → 100% | 445d → none |  |  |
| 1544005b | Vend Fab Crate DAQ Type Phase 1 (CRATES/RACKS) Peg Point #3 VME64X Qty 6 | 2010-09-30 A | 2011-02-28 → 2011-02-21 A (-7d) | 98d → 93d | 0% → 100% | 445d → none |  |  |
| 1544005c | Vend Fab Crate DAQ Type Phase 1 (CRATES/RACKS) Peg Point #4 VXS Qty 3 | 2010-09-30 A | 2011-03-31 → 2011-05-08 A (+38d) | 121d → 147d | 0% → 100% | 445d → none |  | resources PROCUREMENT>$50K 69 NO ESCALATION FY11; PROCUREMENT<$50K 60 NO ESCALATION FY11 → PROCUREMENT<$50K 60 NO ESCALATION FY11; PROCUREMENT>$50K 69 NO ESCALATION FY11 |
| 1544005d | Vend Fab Crate DAQ Type Phase 1 (CRATES/RACKS) Peg Point #5 VXS Qty 8 | 2010-09-30 A | 2011-03-31 → 2011-05-08 A (+38d) | 121d → 147d | 0% → 100% | 445d → none |  |  |
| 1544050 | Racks - First Article Procurement Support (CRATES/RACKS) | 2011-07-11 → 2011-04-18 A (-84d) | 2011-08-26 → 2011-05-23 A (-95d) | 35d → 26d | 0% → 100% | 270d → none | 1234180M, 9-110M FS+189d → 1234180M, 9-110M |  |
| 1544055 | Racks - First Article Parts (QTY 2) (CRATES/RACKS) | 2011-07-25 → 2011-04-18 A (-98d) | 2011-08-19 → 2011-05-23 A (-88d) | 20d → 26d | 0% → 100% | 270d → none |  |  |
| 1544060 | Racks - Cabling Development (CRATES/RACKS) FY11 | 2011-08-29 → 2011-06-01 A (-89d) | 2011-09-30 → 2012-02-13 A (+136d) | 24d → 172.51d | 0% → 100% | 270d → none |  | resources ELEC TECH [74.81 h]; ELEC ENG [49.87 h] → ELEC ENG [49.87 h]; ELEC TECH [74.81 h] |
| 1544060a | Racks - Cabling Development (CRATES/RACKS) FY12 | 2011-10-03 → 2011-06-01 A (-124d) | 2011-12-16 → 2012-02-13 A (+59d) | 53d → 173d | 0% → 100% | 270d → none | 1544060 → 1544060 FS-55d |  |
| 1544006 | Vend Fab Crate DAQ Type Phase 2 (CRATES/RACKS) VXS | 2012-01-05 → 2011-11-01 A (-65d) | 2012-06-29 → 2012-12-17 A (+171d) | 123d → 279d | 0% → 100% | 264d → none | 1544005d, 9-120M FS+60d → 1544005d, 9-120M |  |
| 1544010 | Vend Fab Crate DAQ Type Phase 2 (CRATES/RACKS) VME64X | 2011-10-03 → 2011-11-01 A (+29d) | 2012-04-13 → 2012-03-19 A (-25d) | 130d → 90d | 0% → 100% | 317d → none |  |  |
| 1544030 | Proc TDC Auxiliaries (CRATES/RACKS) | 2011-12-02 → 2011-12-03 A (+1d) | 2011-12-02 → 2011-12-05 A (+3d) |  | 0% → 100% | 415d → none |  |  |
| 1544065 | Racks - Production Procurement Support (CRATES/RACKS) | 2011-12-19 → 2012-01-16 A (+28d) | 2012-01-27 → 2012-06-11 A (+136d) | 23d → 102d | 0% → 100% | 270d → none | 1544060a → 1544060a FS-30d |  |
| 1544070 | Racks - Production Parts (QTY 55) (CRATES/RACKS) | 2012-03-05 → 2012-02-03 A (-31d) | 2012-06-29 → 2012-08-13 A (+45d) | 83d → 134d | 0% → 100% | 246d → none | 1544065, 9-120M FS+100d → 9-120M, 1544065 FS-30d |  |
| 1544075 | Racks - Production Acceptance (CRATES/RACKS) | 2012-04-12 → 2012-03-19 A (-24d) | 2012-08-20 → 2012-08-13 A (-7d) | 91d → 104d | 0% → 100% | 246d → none | 1544070 FS-55d → 1544070 FS-70d |  |
| 1544015 | Vend Fab Crate supl (5 VXS and 2 VME64) | 2012-04-26 → 2012-04-02 A (-24d) | 2012-12-31 → 2012-12-17 A (-14d) | 168d → 186d | 0% → 100% | 174d → none |  |  |
| 1544035 | Assemble TDC Crates (CRATES/RACKS) | 2011-12-05 → 2012-08-01 A (+240d) | 2011-12-19 → 2013-01-31 A (+409d) | 11d → 95d | 0% → 100% | 415d → none | 1544030 → 1544030, 1544006 FS-125d, 1544010 |  |
| 1544025 | Test ADC Crates (CRATES/RACKS) | 2012-07-17 → 2012-08-06 A (+20d) | 2012-08-15 → 2013-01-31 A (+169d) | 22d → 125d | 0% → 100% | 264d → none | 1544020 → 1544020 FS-40d |  |
| 1544040 | Test TDC Crates (CRATES/RACKS) | 2011-12-20 → 2012-08-06 A (+230d) | 2012-01-11 → 2013-01-31 A (+386d) | 11d → 125d | 0% → 100% | 415d → none | 1544035 → 1544035 FS-60d |  |

| ID | Task | Start | Finish | Duration | Complete | Total float | Predecessors | Other |
| --- | --- | --- | --- | --- | --- | --- | --- | --- |
| 1544020 | Assemble ADC Crates (CRATES/RACKS) | 2012-07-02 → 2012-08-13 A (+42d) | 2012-07-16 → 2013-01-31 A (+199d) | 11d → 87d | 0% → 100% | 264d → none | 1544010, 1544006 → 1544010, 1544006 FS-60d |  |
| 1544080 | Re-Baseline Actuals Adjustment | 2013-08-30 A | 2013-08-30 A |  | 0% → 100% | 20d → none | 9-130M FS+227d → none |  |
| 1545009E | FY09 Travel (LOGIC, HV) | 2009-01-02 A | 2009-09-30 A |  | 0% → 100% | 310d → none |  |  |
| 1545050 | High Voltage - First Article Crates (QTY 1) and Modules (QTY 10) | 2011-01-05 → 2009-04-01 A (-644d) | 2011-02-07 → 2011-06-13 A (+126d) | 23d → 547d | 0% → 100% | 432d → none |  |  |
| 1545050a | High Voltage - First Article Crates (QTY 1) and Modules (added cost) | 2011-04-01 → 2009-04-01 A (-730d) | 2011-05-11 → 2011-06-16 A (+36d) | 28d → 549.5d | 0% → 100% | 435.5d → none |  |  |
| 1545010E | FY10 Travel (LOGIC, HV) | 2009-10-01 A | 2010-09-30 A |  | 0% → 100% | 310d → none |  |  |
| 1545011E | FY11 Travel (LOGIC, HV) | 2010-10-01 A | 2011-09-30 A |  | 0% → 100% | 310d → none |  |  |
| 1545014 | Discriminator - First Article Procurement Support | 2011-01-10 → 2011-02-01 A (+22d) | 2011-05-27 → 2011-03-25 A (-63d) | 98d → 38d | 0% → 100% | 194d → none |  |  |
| 1545040 | High Voltage - First Article Procurement Support | 2011-01-04 → 2011-02-01 A (+28d) | 2011-02-07 → 2011-03-25 A (+46d) | 24d → 37d | 0% → 100% | 433d → none |  |  |
| 1545015 | Discriminator - First Article Parts Fab and Assembly (QTY 25) | 2011-03-28 → 2011-03-01 A (-27d) | 2011-10-21 → 2011-09-26 A (-25d) |  | 0% → 100% | 194d → none |  | resources PROCUREMENT<$50K 60 NO ESCALATION FY12; PROCUREMENT>$50K 69 NO ESCALATION FY12 → PROCUREMENT>$50K 69 NO ESCALATION FY12; PROCUREMENT<$50K 60 NO ESCALATION FY12 |
| 1545017 | Test stand for testing/acceptance of discriminator | 2011-04-01 → 2011-03-01 A (-31d) | 2011-06-30 → 2011-03-25 A (-97d) | 64d → 19d | 0% → 100% | 199d → none |  |  |
| 1545090 | Low Voltage - First Article Procurement Support | 2011-03-07 → 2011-05-02 A (+56d) | 2011-08-05 → 2011-06-30 A (-36d) | 108d → 43d | 0% → 100% | 230d → none |  |  |
| 1545095 | Low Voltage - First Article Crates (QTY 1) | 2011-03-07 → 2011-06-01 A (+86d) | 2011-08-05 → 2011-07-25 A (-11d) | 108d → 38d | 0% → 100% | 230d → none |  |  |
| 1545097 | Low Voltage - First Article Modules (QTY 8) | 2011-03-07 → 2011-06-01 A (+86d) | 2011-08-05 → 2012-02-13 A (+192d) | 108d → 173d | 0% → 100% | 250d → none |  |  |
| 1545051 | High Voltage - First Article Crates Acceptance Tests (QTY 1) | 2011-02-22 → 2011-07-01 A (+129d) | 2011-03-18 → 2011-07-25 A (+129d) | 19d → 16d | 0% → 100% | 432d → none |  |  |
| 1545098 | Low Voltage - First Article Crates Acceptance Tests (QTY 1) | 2011-08-08 → 2011-07-18 A (-21d) | 2011-09-02 → 2011-09-26 A (+24d) | 20d → 50d | 0% → 100% | 230d → none |  | resources ELEC TECH [40 h]; ELEC ENG [40 h] → ELEC ENG [40 h]; ELEC TECH [40 h] |
| 1545055 | High Voltage - First Article Modules Acceptance Tests (QTY 10) | 2011-03-14 → 2011-07-19 A (+127d) | 2011-04-08 → 2011-07-27 A (+110d) | 20d → 7d | 0% → 100% | 432d → none |  |  |
| 1545025 | Discriminator - Production Procurement Support | 2012-01-03 → 2011-08-01 A (-155d) | 2012-03-23 → 2011-12-19 A (-95d) | 57d → 98d | 0% → 100% | 194d → none | 1545022 → 1545022 FS-150d, 9-120M FS-21d |  |
| 1545022 | Discriminator - Full Single-Crate Acceptance Test | 2011-10-24 → 2011-09-19 A (-35d) | 2011-12-30 → 2011-09-26 A (-95d) | 43d → 6d | 0% → 100% | 194d → none | 1545020a FS-43d → 1545020a FS-43d, 1545020 FS-43d |  |
| 1545105 | Low Voltage - Production Procurement Support | 2011-10-10 → 2011-09-19 A (-21d) | 2011-12-21 → 2011-09-26 A (-86d) | 51d → 6d | 0% → 100% | 225d → none | 1545100, 9-120M FS+5d → 1545100 FS-30d |  |
| 1545020 | Discriminator - First Article Test (QTY 25) FY11 | 2011-07-11 → 2011-09-26 A (+77d) | 2011-09-30 → 2011-10-24 A (+24d) | 59d → 20.96d | 0% → 100% | 194d → none | 1545017, 1545015 FS-74d → 1545017, 1545015 |  |
| 1545020a | Discriminator - First Article Test (QTY 25) FY12 | 2011-10-03 → 2011-09-26 A (-7d) | 2011-12-30 → 2011-10-24 A (-67d) | 58d → 21d | 0% → 100% | 194d → none | 1545020 → 1545020 FS-140d | resources ELEC TECH [237.95 h]; ELEC ENG [19.83 h] → ELEC ENG [19.83 h]; ELEC TECH [237.95 h] |
| 1545100 | Low Voltage - First Article Modules Acceptance Tests (QTY 10) | 2011-09-06 → 2011-09-26 A (+20d) | 2011-09-30 → 2012-03-19 A (+171d) | 19d → 116d | 0% → 100% | 230d → none | 1545097, 1545098 → 1545098, 1545097 FS-210d |  |
| 1545110 | Low Voltage - Crates Production (QTY 7) | 2011-11-07 → 2011-09-26 A (-42d) | 2012-10-31 → 2012-03-19 A (-226d) | 245d → 116d | 0% → 100% | 205d → none | 9-120M FS+25d, 1545105 FS-51d → 9-120M FS-30d, 1545105 FS-51d |  |
| 1545115 | Low Voltage - Modules Production (QTY 38) | 2011-11-07 → 2011-09-26 A (-42d) | 2012-10-31 → 2012-05-14 A (-170d) | 245d → 156d | 0% → 100% | 205d → none | 1545110 FS-245d, 9-120M → 1545110 FS-190d, 9-120M FS-30d |  |
| 1545005 | Assemble Signal Distrbtn CFD Tests (LOGIC, HV) | 2011-10-03 A | 2011-10-28 → 2011-10-17 A (-11d) | 20d → 11d | 0% → 100% | 396d → none |  |  |
| 1545060 | High Voltage - Production Procurement Support | 2011-10-03 A | 2012-03-02 → 2011-11-14 A (-109d) | 100d → 30d | 0% → 100% | 310d → none |  |  |
| 1545010 | Dry Run of Testing Procedures for CFDs (LOGIC, HV) | 2011-10-31 → 2011-10-17 A (-14d) | 2011-11-07 → 2011-10-21 A (-17d) | 6d → 5d | 0% → 100% | 396d → none |  |  |
| 1545065 | Vend Fab - Universal Multichannel Power Supply System 750W (QTY 6) | 2011-10-03 → 2011-11-01 A (+29d) | 2012-04-13 → 2012-05-14 A (+31d) |  | 0% → 100% | 310d → none |  |  |
| 1545070 | Vend Fab - H.V Channels -3.5 KV 3 MA SHV Floating (QTY 18) | 2011-10-03 → 2011-11-01 A (+29d) | 2012-04-13 → 2011-12-19 A (-116d) | 130d → 33d | 0% → 100% | 310d → none |  |  |
| 1545071 | Vend Fab - H.V Channels +3.5 KV 3 MA Floating (QTY 8) | 2011-10-03 → 2011-11-01 A (+29d) | 2012-04-13 → 2012-02-13 A (-60d) | 130d → 66d | 0% → 100% | 310d → none |  |  |
| 1545075 | Vend Fab - H.V Channels -3.5 KV 3 MA Floating (QTY 3) | 2011-10-03 → 2011-11-01 A (+29d) | 2012-04-13 → 2011-12-19 A (-116d) | 130d → 33d | 0% → 100% | 310d → none |  |  |
| 1545066 | Vend Fab - Optional Power Supply 750W (QTY 6) | 2011-10-03 → 2011-12-01 A (+59d) | 2012-04-13 → 2012-05-14 A (+31d) | 130d → 110d | 0% → 100% | 310d → none |  |  |
| 1545026 | Discriminator - Production Parts Non-Recurring Engineering | 2012-01-04 → 2012-01-03 A (-1d) | 2012-05-31 → 2012-05-14 A (-17d) | 104d → 92d | 0% → 100% | 194d → none |  |  |
| 1545027 | Discriminator - Production Parts Fab and Assembly (QTY 70) | 2012-01-04 → 2012-01-03 A (-1d) | 2012-08-31 → 2012-08-13 A (-18d) | 169d → 156d | 0% → 100% | 194d → none | 1545026 FS-104d, 1545025 FS-56d → 1545026 FS-104d, 1545025 |  |
| 1545125 | Low Voltage - Modules Production Tests (QTY 38) FY12 | 2012-04-23 → 2012-01-09 A (-105d) | 2012-09-28 → 2012-11-12 A (+45d) | 112d → 215.3d | 0% → 100% | 205d → none | 1545115 FS-135d → 1545115 FS-190d |  |
| 1545125a | Low Voltage - Modules Production Tests (QTY 38) FY13 | 2012-10-01 → 2012-01-09 A (-266d) | 2012-10-31 → 2012-11-12 A (+12d) | 23d → 216d | 0% → 100% | 205d → none | 1545125, 1545115 FS-135d → 1545125 FS-45d |  |
| 1545080 | High Voltage - Crates Production Tests (QTY 6) | 2012-02-22 → 2012-01-16 A (-37d) | 2012-06-05 → 2012-11-12 A (+160d) | 73d → 211d | 0% → 100% | 310d → none | 1545066 FS-38d, 1545065 FS-38d → 1545066 FS-120d, 1545065 FS-80d |  |
| 1545120 | Low Voltage - Crates Production Tests (QTY 7) FY12 | 2012-04-23 → 2012-02-01 A (-82d) | 2012-09-28 → 2012-05-14 A (-137d) | 112d → 73d | 0% → 100% | 205d → none | 1545110 FS-135d → 1545110 FS-1750d |  |
| 1545120a | Low Voltage - Crates Production Tests (QTY 7) FY13 | 2012-10-01 → 2012-02-01 A (-243d) | 2012-10-31 → 2012-05-14 A (-170d) | 23d → 73d | 0% → 100% | 205d → none |  |  |
| 1545085 | High Voltage - Modules Production Tests (QTY 29) | 2012-02-22 → 2012-02-20 A (-2d) | 2012-06-05 → 2012-10-15 A (+132d) | 73d → 167d | 0% → 100% | 310d → none |  |  |
| 1545030 | Discriminator - Production Test (QTY 70) FY12 | 2012-09-04 → 2012-05-01 A (-126d) | 2012-09-28 → 2012-09-17 A (-11d) | 19d → 96.47d | 0% → 100% | 194d → none | 1545010, 1545027 → 1545027 FS-80d, 1545010 |  |
| 1545028 | Procure Discriminators (Qty.24) Supplemental BCAL and PS | 2012-08-20 → 2012-05-01 A (-111d) | 2013-01-31 → 2012-08-13 A (-171d) | 109d → 73d | 0% → 100% | 153d → none | 9-120M FS+218d → 9-120M |  |
| 1545030a | Discriminator - Production Test (QTY 70) FY13 | 2012-10-01 → 2012-05-01 A (-153d) | 2012-11-26 → 2012-09-17 A (-70d) | 39d → 97d | 0% → 100% | 194d → none | 1545030 → 1545030 FS-60d |  |
| 1545130 | Re-Baseline Actuals Adjustment | 2013-08-30 A | 2013-08-30 A |  | 0% → 100% | 20d → none | 9-130M FS+227d → none |  |
| 6 | **1.5.4.6 DETECTOR ELECTRONICS** | 2011-01-04 → 2011-01-05 (+1d) |  |  |  |  |  |  |
| 1546005 | ASIC - Procurement Support (FDC&CDC) | 2011-01-04 → 2011-01-05 A (+1d) | 2011-03-04 → 2011-02-21 A (-11d) | 42d → 32d | 0% → 100% | 77d → none |  |  |
| 1546020 | ASIC - Test Fixture Development (FDC&CDC) | 2011-01-18 → 2011-02-01 A (+14d) | 2011-03-04 → 2011-02-28 A (-4d) | 33d → 19d | 0% → 100% | 92d → none |  | resources ELEC TECH [240 h]; ELEC ENG [40 h] → ELEC ENG [40 h]; ELEC TECH [240 h] |
| 1546125 | HVB - Development Revisions (CDC) | 2011-01-24 → 2011-02-01 A (+8d) | 2011-03-24 → 2011-02-28 A (-24d) | 43d → 19d | 0% → 100% | 55d → none |  |  |
| 1546140 | HVB - First Article Procurement Support (CDC) | 2011-01-24 → 2011-02-01 A (+8d) | 2011-04-15 → 2011-06-30 A (+76d) | 59d → 106d | 0% → 100% | 55d → none |  |  |
| 1546145 | HVB - First Article Parts (CDC) | 2011-01-24 → 2011-02-01 A (+8d) | 2011-07-15 → 2011-06-30 A (-15d) | 122d → 106d | 0% → 100% | 55d → none |  |  |
| 1546025 | ASIC - Test Fixture Procurement Support (FDC&CDC) | 2011-03-07 → 2011-03-01 A (-6d) | 2011-03-25 → 2011-06-30 A (+97d) | 15d → 87d | 0% → 100% | 97d → none |  |  |
| 1546030 | ASIC - Test Fixture Parts (FDC&CDC) | 2011-03-07 → 2011-03-01 A (-6d) | 2011-03-18 → 2011-05-23 A (+66d) | 10d → 60d | 0% → 100% | 92d → none |  |  |
| 1546095 | Preamp Card - Test Fixture Development (FDC&CDC) | 2011-03-21 → 2011-03-01 A (-20d) | 2011-05-13 → 2011-08-31 A (+110d) | 40d → 130d | 0% → 100% | 59d → none |  | resources ELEC ENG [40 h]; ELEC TECH [240 h] → ELEC TECH [240 h]; ELEC ENG [40 h] |
| 1546130 | HVB - Development PCB Fab Files (CDC) | 2011-03-14 → 2011-04-02 A (+19d) | 2011-03-18 → 2011-04-18 A (+31d) | 5d → 11d | 0% → 100% | 55d → none |  |  |
| 1546135 | HVB - Development PCB Assembly Files (CDC) | 2011-03-14 → 2011-04-02 A (+19d) | 2011-03-18 → 2011-06-30 A (+104d) | 5d → 63d | 0% → 100% | 55d → none |  |  |
| 1546150 | HVB - First Article Fab 2 Units (CDC) | 2011-03-21 → 2011-04-04 A (+14d) | 2011-04-01 → 2011-05-08 A (+37d) | 10d → 25d | 0% → 100% | 55d → none | 1546135, 1546145 FS-83d → 1546135 FS-5d, 1546145 FS-90d |  |
| 1546035 | ASIC - Test Fixture Fab (FDC&CDC) | 2011-03-21 → 2011-04-11 A (+21d) | 2011-04-01 → 2011-04-27 A (+26d) | 10d → 13d | 0% → 100% | 92d → none |  |  |
| 1546155 | HVB - First Article Assembly 2 Units (CDC) | 2011-04-04 → 2011-05-09 A (+35d) | 2011-04-15 → 2011-06-30 A (+76d) | 10d → 38d | 0% → 100% | 55d → none |  |  |
| 1546160 | HVB - First Article Test 2 Units (CDC) | 2011-04-18 → 2011-05-15 A (+27d) | 2011-04-29 → 2011-06-30 A (+62d) | 10d → 33d | 0% → 100% | 55d → none | 1546155 → 1546155 FS-15d |  |
| 1546040 | ASIC - Test Fixture Assembly (FDC&CDC) | 2011-04-04 → 2011-05-16 A (+42d) | 2011-04-15 → 2011-06-30 A (+76d) | 10d → 33d | 0% → 100% | 92d → none | 1546025, 1546035 → 1546035, 1546025 FS-20d |  |
| 1546045 | ASIC - Test Fixture Test (FDC&CDC) | 2011-04-18 → 2011-05-16 A (+28d) | 2011-05-06 → 2011-06-30 A (+55d) | 15d → 33d | 0% → 100% | 92d → none | 1546040 → 1546040 FS-20d |  |
| 1546050 | Preamp Card - First Article Procurement Support (FDC&CDC) | 2011-04-11 → 2011-06-01 A (+51d) | 2011-07-01 → 2011-07-28 A (+27d) | 59d → 41d | 0% → 100% | 20d → none |  |  |
| 1546055 | Preamp Card - First Article Parts (FDC&CDC) | 2011-04-11 → 2011-06-01 A (+51d) | 2011-07-01 → 2011-06-30 A (-1d) | 59d → 22d | 0% → 100% | 20d → none | 1546050 FS-59d, 9-110M FS+126d → 1546050 FS-60d, 9-110M FS+126d |  |
| 1546165 | HVB - Production Procurement Support (CDC) | 2011-05-02 → 2011-06-01 A (+30d) | 2011-07-22 → 2011-07-25 A (+3d) | 58d → 38d | 0% → 100% | 55d → none |  |  |
| 1546185 | HVB - Test Fixture Development (CDC) | 2011-05-27 → 2011-06-01 A (+5d) | 2011-06-17 → 2011-08-31 A (+75d) | 15d → 65d | 0% → 100% | 79d → none |  | resources ELEC ENG [40 h]; ELEC TECH [40 h] → ELEC TECH [40 h]; ELEC ENG [40 h] |
| 1546075 | Preamp Card - Production Procurement Support (FDC&CDC) | 2011-10-31 → 2011-07-11 A (-112d) | 2012-01-20 → 2011-07-25 A (-179d) | 51d → 11d | 0% → 100% | 20d → none | 1546070a → 1546070a FS-65d |  |
| 1546060 | Preamp Card - First Article Fab (FDC&CDC) | 2011-06-06 → 2011-07-18 A (+42d) | 2011-07-29 → 2011-09-19 A (+52d) | 39d → 45d | 0% → 100% | 20d → none | 1546055 FS-20d → 1546055 FS+25d |  |
| 1546170 | HVB - Production Fab (CDC) | 2011-07-25 → 2011-07-18 A (-7d) | 2011-08-26 → 2011-11-15 A (+81d) | 25d → 86d | 0% → 100% | 55d → none |  |  |
| 1546175 | HVB - Production Assembly (CDC) | 2011-08-29 → 2011-07-18 A (-42d) | 2011-10-07 → 2011-11-15 A (+39d) | 29d → 86d | 0% → 100% | 55d → none | 1546170 → 1546170 FS-25d |  |

| ID | Task | Start | Finish | Duration | Complete | Total float | Predecessors | Other |
| --- | --- | --- | --- | --- | --- | --- | --- | --- |
| 1546010 | ASIC - Test (FDC&CDC) | 2011-05-31 → 2011-08-01 A (+62d) | 2011-09-02 → 2011-08-31 A (-2d) | 68d → 23d | 0% → 100% | 77d → none | 15211035b, 1546045 → 1546045, 15211035b FS-15d | resources ELEC TECH [280 h]; ELEC ENG [160 h] → ELEC ENG [160 h]; ELEC TECH [280 h] |
| 1546065 | Preamp Card - First Article Assembly (FDC&CDC) | 2011-08-01 A | 2011-09-23 → 2011-09-21 A (-2d) | 39d → 37d | 0% → 100% | 20d → none | 1546060 → 1546060 FS-38d |  |
| 1546080 | Preamp Card - Production Fab (FDC&CDC) | 2011-10-31 → 2011-08-01 A (-91d) | 2011-11-23 → 2011-10-24 A (-30d) | 18d → 60d | 0% → 100% | 20d → none | 1546075 FS-51d, 1546070a → 1546070a FS-50d, 1546075 FS-101d |  |
| 1546085 | Preamp Card - Production Assembly (FDC&CDC) | 2011-11-28 → 2011-08-01 A (-119d) | 2012-01-20 → 2011-10-18 A (-94d) | 33d → 56d | 0% → 100% | 20d → none | 1546080, 1546010 → 1546010 FS-20d, 1546080 FS-40d |  |
| 1546100 | Preamp Card - Test Fixture Procurement Support (FDC&CDC) | 2011-05-16 → 2011-08-01 A (+77d) | 2011-06-03 → 2011-08-31 A (+89d) | 14d → 23d | 0% → 100% | 59d → none |  |  |
| 1546105 | Preamp Card - Test Fixture Parts (FDC&CDC) | 2011-05-16 → 2011-08-01 A (+77d) | 2011-06-10 → 2011-10-24 A (+136d) | 19d → 60d | 0% → 100% | 59d → none |  |  |
| 1546110 | Preamp Card - Test Fixture Fab (FDC&CDC) | 2011-06-13 → 2011-08-01 A (+49d) | 2011-07-01 → 2011-08-31 A (+61d) | 15d → 23d | 0% → 100% | 59d → none | 1546105 → 1546105 FS-20d |  |
| 1546115 | Preamp Card - Test Fixture Assembly (FDC&CDC) | 2011-07-05 → 2011-08-01 A (+27d) | 2011-07-15 → 2011-08-31 A (+47d) | 9d → 23d | 0% → 100% | 59d → none |  |  |
| 1546120 | Preamp Card - Test Fixture Test (FDC&CDC) | 2011-07-18 → 2011-08-01 A (+14d) | 2011-07-29 → 2011-08-31 A (+33d) | 10d → 23d | 0% → 100% | 59d → none |  |  |
| 1546190 | HVB - Test Fixture Procurement Support (CDC) | 2011-06-20 → 2011-08-01 A (+42d) | 2011-07-08 → 2011-08-31 A (+54d) | 14d → 23d | 0% → 100% | 79d → none |  |  |
| 1546200 | HVB - Test Fixture Fab (CDC) | 2011-07-18 → 2011-08-01 A (+14d) | 2011-08-05 → 2011-08-31 A (+26d) | 15d → 23d | 0% → 100% | 79d → none | 1546195 → 1546195 FS-20d |  |
| 1546205 | HVB - Test Fixture Assembly (CDC) | 2011-08-08 → 2011-08-01 A (-7d) | 2011-08-19 → 2011-08-31 A (+12d) | 10d → 23d | 0% → 100% | 79d → none | 1546200 → 1546200 FS-20d |  |
| 1546210 | HVB - Test Fixture Test (CDC) | 2011-08-22 → 2011-08-01 A (-21d) | 2011-09-02 → 2011-08-31 A (-2d) | 10d → 23d | 0% → 100% | 79d → none |  |  |
| 1546195 | HVB - Test Fixture Parts (CDC) | 2011-06-20 → 2011-08-26 A (+67d) | 2011-07-15 → 2011-09-27 A (+74d) | 19d → 22d | 0% → 100% | 79d → none | 1546185, 1546190 FS-14d → 1546185 FS-35d, 1546190 FS-30d |  |
| 1546070 | Preamp Card - First Article Acceptance QA (FDC&CDC) FY11 | 2011-09-26 → 2011-09-24 A (-2d) | 2011-09-30 → 2011-09-27 A (-3d) | 5d → 2d | 0% → 100% | 20d → none |  |  |
| 1546070a | Preamp Card - First Article Acceptance QA (FDC&CDC) FY12 | 2011-10-03 → 2011-09-24 A (-9d) | 2011-10-28 → 2011-09-26 A (-32d) | 20d → 1d | 0% → 100% | 20d → none |  |  |
| 1546090 | Preamp Card - Production Tests (FDC&CDC) | 2012-01-23 → 2011-10-17 A (-98d) | 2012-06-22 → 2012-07-09 A (+17d) | 107d → 179d | 0% → 100% | 20d → none |  |  |
| 1546180 | HVB - Production Test (CDC) | 2011-10-10 → 2011-11-16 A (+37d) | 2012-01-27 → 2012-02-13 A (+17d) | 71d → 55d | 0% → 100% | 55d → none |  |  |
| 1546390 | Power Distribution Engineering | 2012-02-27 → 2012-03-01 A (+3d) | 2012-04-30 → 2012-05-14 A (+14d) | 46d → 53d | 0% → 100% | 300d → none |  |  |
| 1546400 | Pair Spectrometer Engineering | 2012-03-19 → 2012-03-01 A (-18d) | 2012-04-27 → 2013-07-15 A (+444d) | 30d → 216d | 0% → 100% | 160d → none |  |  |
| 1546500 | Start Counter Engineering | 2012-02-27 → 2012-03-01 A (+3d) | 2012-03-23 → 2012-05-14 A (+52d) | 20d → 53d | 0% → 100% | 216d → none |  |  |
| 1546182 | Testing/manufacturing equipment for electronic boards | 2012-03-05 → 2012-03-02 A (-3d) | 2012-09-28 → 2012-08-20 A (-39d) | 147d → 120d | 0% → 100% | 496d → none |  |  |
| 1546445 | Pair Spectrometer Power Supplies Procurement Prep | 2012-07-25 → 2012-03-06 A (-141d) | 2012-09-14 → 2012-03-19 A (-179d) | 37d → 10d | 0% → 100% | 129d → none | 1546400, 9-120M FS+200d → 1546400 FS-40d, 9-120M |  |
| 1546505 | Start Counter Prototype Procurement Prep | 2012-03-26 → 2012-04-16 A (+21d) | 2012-04-06 → 2012-05-14 A (+38d) | 10d → 21d | 0% → 100% | 216d → none | 1546500 → 1546500 FS-15d |  |
| 1546300 | BCAL Readout Procurement Support | 2012-02-21 → 2012-05-01 A (+70d) | 2012-08-31 → 2012-10-29 A (+59d) | 137d → 127d | 0% → 100% | 213d → none | 9-120M FS+91d → 9-120M FS+164d |  |
| 1546310 | Procure U-Boards (Qty.3840) | 2012-03-12 → 2012-05-01 A (+50d) | 2012-05-31 → 2012-08-13 A (+74d) | 58d → 73d | 0% → 100% | 213d → none | 1546305 FS-78d → 1546305 FS-120d | resources PROCUREMENT<$50K 60; PROCUREMENT>$50K 69 → PROCUREMENT>$50K 69; PROCUREMENT<$50K 60 |
| 1546510 | Start Counter Prototype Parts,Fab and Assembly | 2012-03-26 → 2012-05-01 A (+36d) | 2012-04-27 → 2012-06-11 A (+45d) | 25d → 28d | 0% → 100% | 216d → none |  | resources ELEC TECH [68 h]; PROCUREMENT<$50K 60 → PROCUREMENT<$50K 60; ELEC TECH [68 h] |
| 1546315 | Procure Thermistor Boards (Qty.384) | 2012-04-23 → 2012-07-02 A (+70d) | 2012-05-31 → 2012-07-23 A (+53d) | 28d → 16d | 0% → 100% | 213d → none |  |  |
| 1546320 | Procure Transition Boards (Qty.96) | 2012-05-07 → 2012-07-02 A (+56d) | 2012-06-29 → 2012-09-17 A (+80d) | 38d → 55d | 0% → 100% | 213d → none |  |  |
| 1546325 | Procure Power Distribution (Qty.18) | 2012-05-14 → 2012-07-02 A (+49d) | 2012-08-31 → 2013-08-23 A (+357d) | 78d → 140d | 0% → 100% | 213d → none | 1546320 FS-33d → 1546320 FS-40d |  |
| 1546450 | Procure LV Mod Preamp | 2012-10-01 → 2012-07-02 A (-91d) | 2013-02-28 → 2012-09-17 A (-164d) | 99d → 55d | 0% → 100% | 129d → none | 1546445 FS+10d → 1546445 FS-20d |  |
| 1546455 | Procure LV Bias | 2012-10-01 → 2012-07-02 A (-91d) | 2013-02-28 → 2012-09-17 A (-164d) | 99d → 55d | 0% → 100% | 129d → none | 1546445 FS+10d → 1546445 FS-20d |  |
| 1546460 | Procure LV Chassis | 2012-10-01 → 2012-07-02 A (-91d) | 2013-02-28 → 2012-09-17 A (-164d) | 99d → 55d | 0% → 100% | 129d → none | 1546445 FS+10d → 1546445 FS-20d |  |
| 1546515 | Test Start Counter Prototype | 2012-05-14 → 2012-07-02 A (+49d) | 2012-06-01 → 2012-07-16 A (+45d) | 14d → 11d | 0% → 100% | 216d → none | 1546510 FS+10d → 1546510 |  |
| 1546550 | Procure LV Mod Preamp | 2012-10-01 → 2012-07-02 A (-91d) | 2013-02-28 → 2012-09-17 A (-164d) | 99d → 55d | 0% → 100% | 129d → none | 9-130M → 9-130M FS-60d |  |
| 1546555 | Procure LV Bias | 2012-10-01 → 2012-07-02 A (-91d) | 2013-02-28 → 2012-09-17 A (-164d) | 99d → 55d | 0% → 100% | 129d → none | 9-130M → 9-130M FS-60d |  |
| 1546560 | Procure LV Chassis | 2012-10-01 → 2012-07-02 A (-91d) | 2013-02-28 → 2012-09-17 A (-164d) | 99d → 54d | 0% → 100% | 129d → none | 9-130M → 9-130M FS-60d |  |
| 1546365 | Test U-Boards FY12 | 2012-06-11 → 2012-08-13 A (+63d) | 2012-09-28 → 2012-09-17 A (-11d) | 79d → 24.5d | 0% → 100% | 228d → none | 1546360 FS-51d, 1546310 → 1546310, 1546360 FS-115d |  |
| 1546365a | Test U-Boards FY13 | 2012-10-01 → 2012-08-13 A (-49d) | 2012-10-08 → 2012-09-17 A (-21d) | 6d → 25d | 0% → 100% | 228d → none | 1546365 → 1546365 FS-160d |  |
| 1546370 | Test Thermistor Boards | 2012-06-25 → 2012-08-13 A (+49d) | 2012-09-21 → 2013-02-11 A (+143d) | 64d → 154d | 0% → 100% | 228d → none | 1546365a FS-75d, 1546315 → 1546315, 1546365a FS-160d |  |
| 1546375 | Test Transition Boards | 2012-07-09 → 2012-08-13 A (+35d) | 2012-08-10 → 2013-02-11 A (+185d) | 25d → 121d | 0% → 100% | 228d → none | 1546370 FS-54d, 1546320 → 1546370 FS-165d, 1546320 FS-20d |  |
| 1546305 | Procure BCAL Readout V3 (Qty.96) $$ Reside @ 15221160ab per CR12-021 | 2012-03-12 → 2012-09-03 A (+175d) | 2012-06-29 → 2012-12-17 A (+171d) | 78d → 97d | 0% → 100% | 213d → none | 15221161c FS-500d, 15221161h FS-500d, 15221161a FS-307d, 1546300 FS-123d, 15221161n FS-500d, 15221161f FS-500d, 15221161s FS-500d, 15221161j FS-500d, 15221161b FS-500d, 15221161k FS-500d → 1546300 FS-123d, 15221161n FS-205d, 15221161j FS-205d, 15221161k FS-205d, 15221161s FS-205d, 15221161f FS-205d, 15221161a FS-205d, 15221161b FS-205d, 15221161c FS-205d, 15221161h FS-205d |  |
| 1546440 | Procure Pair Spectrometer Coax Cables | 2012-08-20 → 2012-09-03 A (+14d) | 2012-11-30 → 2012-10-15 A (-46d) | 72d → 30d | 0% → 100% | 195d → none | 1546420 FS-14d → 1546420 FS-60d |  |
| 1546465 | Procure LV Cables | 2012-10-01 → 2012-09-03 A (-28d) | 2013-02-28 → 2013-08-30 A (+183d) | 99d → 103d | 0% → 100% | 129d → none | 1546445 FS+10d → 1546445 |  |
| 1546540 | Procure Start Counter Coax Cables | 2013-04-08 → 2012-09-03 A (-217d) | 2013-07-31 → 2012-09-17 A (-317d) | 81d → 10d | 0% → 100% | 42d → none |  |  |
| 1546330 | Procure Coax Cables (Qty.768) | 2012-08-06 → 2012-10-01 A (+56d) | 2012-09-28 → 2012-10-15 A (+17d) | 39d → 11d | 0% → 100% | 218d → none | 1546325 FS-20d → 1546325 FS-40d |  |
| 1546360 | Test BCAL Readout V3 | 2012-06-11 → 2013-01-07 A (+210d) | 2012-08-20 → 2013-03-11 A (+203d) |  | 0% → 100% | 228d → none |  | resources ELEC TECH [272 h]; ELEC ENG [68 h] → ELEC ENG [68 h]; ELEC TECH [272 h] |
| 1546345 | Procure Disc/TDC Cable(Qty.24) | 2013-01-25 → 2013-03-01 A (+35d) | 2013-02-28 → 2013-03-18 A (+18d) |  | 0% → 100% | 134d → none | 9-130M FS+75d → 9-130M FS+110d |  |
| 1546520 | Start Counter Production Procurement Prep | 2013-02-19 → 2013-03-04 A (+13d) | 2013-04-12 → 2013-05-13 A (+31d) |  | 0% → 100% | 42d → none | 1546515, 9-130M FS+91d → 9-130M FS+110d, 1546515 |  |
| 1546380 | Test Power Distribution FY12 | 2012-09-04 → 2013-04-15 A (+223d) | 2012-09-28 → 2013-08-30 A (+336d) |  | 0% → 100% | 213d → none | 1546325, 1546390, 1546375 → 1546325 FS-20d, 1546375, 1546390 FS-20d |  |
| 1546525 | Procure Start Counter ST Readout Board | 2013-03-25 → 2013-05-02 A (+38d) | 2013-05-31 → 2013-06-17 A (+17d) |  | 0% → 100% | 74d → none |  |  |
| 1546565 | Procure LV Cables | 2012-10-01 → 2013-05-06 A (+217d) | 2013-02-28 → 2013-08-30 A (+183d) | 99d → 91d | 0% → 100% | 129d → none |  |  |
| 1546530 | Procure Start Counter Transition Board | 2013-04-08 → 2013-05-13 A (+35d) | 2013-04-30 → 2013-06-17 A (+48d) |  | 0% → 100% | 69d → none |  |  |
| 1546535 | Procure Start Counter Power Distribution | 2013-04-08 → 2013-05-13 A (+35d) | 2013-05-31 → 2013-06-17 A (+17d) |  | 0% → 100% | 50d → none |  |  |
| 1546405 | Pair Spectrometer Prototype Procurement Prep | 2012-04-16 → 2013-07-08 A (+448d) | 2012-05-18 → 2013-08-15 A (+454d) | 25d → 11d | 0% → 100% | 160d → none | 1546400 FS-10d → 1546400 |  |
| 1546410 | Pair Spectrometer Prototype Parts,Fab and Assembly | 2012-04-23 → 2013-07-15 A (+448d) | 2012-06-15 → 2013-08-26 A (+437d) | 38d → 39d | 0% → 100% | 160d → none | 1546405 FS-20d → 1546405 FS-30d |  |
| 1546415 | Test Pair Spectrometer Prototype | 2012-06-18 → 2013-08-01 A (+409d) | 2012-07-20 → 2013-08-26 A (+402d) | 25d → 32d | 0% → 100% | 160d → none |  |  |
| 1546420 | Pair Spectrometer Production Procurement Prep | 2012-07-23 → 2013-08-01 A (+374d) | 2012-09-07 → 2013-08-21 A (+348d) | 34d → 15d | 0% → 100% | 160d → none | 1546415 → 1546415 FS-75d |  |
| 1546425 | Procure Pair Spectrometer Readout Board | 2012-07-30 → 2013-08-07 A (+373d) | 2012-08-31 → 2013-08-30 A (+364d) | 25d → 39d | 0% → 100% | 215d → none | 1546420 FS-29d → 1546420 FS-11d |  |
| 1546430 | Procure Pair Spectrometer Transition Board | 2012-08-06 → 2013-08-07 A (+366d) | 2012-09-28 → 2013-08-30 A (+336d) |  | 0% → 100% | 170d → none | 1546420 FS-24d → 1546420 FS-11d |  |
| 1546435 | Procure Pair Spectrometer Power Distribution | 2012-08-13 → 2013-08-07 A (+359d) | 2012-09-28 → 2013-08-30 A (+336d) | 34d → 39d | 0% → 100% | 160d → none | 1546420 FS-19d → 1546420 FS-11d |  |
| 1546570 | Re-Baseline Actuals Adjustment | 2013-08-30 A | 2013-08-30 A |  | 0% → 100% | 20d → none | 9-130M FS+227d → none |  |
| 2546362 | Assemble BCAL Readout V3, Power Dist. & SYST | 2013-09-03 A | 2013-09-30 → 2013-12-02 (+63d) |  | 0% → 50% | 179d → 151d |  |  |
| 2546425 | Procure Pair Spectrometer Readout Board | 2013-09-03 A | 2013-09-30 → 2013-10-21 A (+21d) |  | 0% → 100% | 199d → none |  |  |
| 2546430 | Procure Pair Spectrometer Transition Board | 2013-09-03 A | 2013-09-30 → 2013-09-23 A (-7d) |  | 0% → 100% | 199d → none |  |  |
| 2546435 | Procure Pair Spectrometer Power Distribution | 2013-09-03 A | 2013-09-30 → 2013-09-23 A (-7d) |  | 0% → 100% | 199d → none |  |  |
| 2546465 | Procure LV Cables | 2013-09-03 A | 2013-09-30 → 2013-12-02 (+63d) |  | 0% → 70% | 247d → 204d |  |  |
| 2546565 | Procure LV Cables | 2013-09-03 A | 2013-09-30 → 2013-12-02 (+63d) |  | 0% → 30% | 247d → 204d |  |  |
| 2546600 | Tagger Hodoscope PreAmp Board (233) (Previously Obligated) | 2013-09-03 A | 2013-11-08 → 2013-12-20 (+42d) |  | 0% → 80% | 158d → 130d |  |  |
| 2546615 | BCAL/FCAL Monitoring Distribution COTS Electronics | 2013-09-03 A | 2013-12-20 → 2014-02-04 (+46d) |  |  | 190d → 167d |  |  |

| ID | Task | Start | Finish | Duration | Complete | Total float | Predecessors | Other |
| --- | --- | --- | --- | --- | --- | --- | --- | --- |
| 2546625 | BCAL/FCAL Monitoring Distribution Cables (64+64) (Previously Obligated) | 2013-09-03 A | 2014-01-31 → 2013-10-21 A (-102d) |  | 0% → 100% | 169d → none |  |  |
| 2546630 | BCAL/FCAL Monitoring Distribution Cables (64+64) | 2013-09-03 A |  |  | 0% → 20% |  |  |  |
| 2546640 | Cables Type 1 (TAGH PS PSC COLLI) (350) | 2013-09-03 A | 2013-12-20 → 2013-10-21 A (-60d) |  | 0% → 100% | 190d → none |  | resources PROCUREMENT<$50K 60 NO ESCALATION FY14; PROCUREMENT>$50K 69 NO ESCALATION → PROCUREMENT<$50K 60 NO ESCALATION FY14 |
| 2546645 | Splitter Output (TOF TAGM PSC) (630) | 2013-09-03 A | 2013-11-15 → 2013-10-21 A (-25d) |  | 0% → 100% | 213d → none |  |  |
| 2546650 | Install Hardware, Labels and Tie Wraps FY13 | 2013-09-03 A | 2013-09-30 → 2014-09-30 (+365d) |  | 0% → 16% |  |  |  |
| 2546650a | Install Hardware, Labels and Tie Wraps FY14 | 2013-10-01 → 2013-09-03 A (-28d) |  |  | 0% → 16% |  | 9-130M FS+228d, 2546650 → 2546650 FS-247d |  |
| 2546660 | Twisted Pair Cables for TDCs | 2013-09-03 A |  |  | 0% → 10% |  |  |  |
| 2546470 | Pair Spectrometer Integration FY13 | 2013-09-09 → 2013-10-01 A (+22d) | 2013-09-30 → 2013-12-20 (+81d) |  | 0% → 55% |  |  |  |
| 2546470a | Pair Spectrometer Integration FY14 | 2013-10-01 A |  |  | 0% → 55% |  | 2546470, 9-130M FS+232d → 2546470 FS-40d |  |
| 2546567 | Start Counter Integration FY13 | 2013-09-03 → 2013-10-01 A (+28d) | 2013-09-30 → 2013-12-10 (+71d) |  | 0% → 55% | 208d → 188d |  |  |
| 2546567a | Start Counter Integration FY14 | 2013-10-01 A | 2013-11-08 → 2013-12-10 (+32d) |  | 0% → 55% | 208d → 188d | 9-130M FS+228d, 2546567 → 2546567 FS-30d |  |
| 2546585 | Tagger Microscope PreAmp Board (37) Procurement $ now Labor | 2013-09-03 → 2013-10-01 A (+28d) | 2013-11-15 → 2013-10-21 A (-25d) | 54d → 82d | 0% → 100% | 153d → none | 9-130M FS+228d → 9-130M FS+228d, 9-140M | was named Tagger Microscope PreAmp Board (37) Procurement |
| 2546585a | Tagger Microscope PreAmp Board (37) Labor FY13 | 2013-09-03 → 2013-10-01 A (+28d) | 2013-09-30 → 2013-12-17 (+78d) |  | 0% → 2% | 153d → 139d | 9-130M FS+228d → 9-140M |  |
| 2546585b | Tagger Microscope PreAmp Board (37) Labor FY14 | 2013-10-01 A | 2013-11-15 → 2013-12-20 (+35d) |  | 0% → 2% | 153d → 130d | 9-130M FS+228d, 2546585a → 2546585a FS-40d |  |
| 2546605 | Tagger Hodoscope PreAmp Board (233) Procurement $ now Labor | 2013-09-03 → 2013-10-01 A (+28d) | 2013-11-08 → 2013-10-21 A (-18d) | 49d → 57d | 0% → 100% | 158d → none |  | was named Tagger Hodoscope PreAmp Board (233) - Procurement |
| 2546605a | Tagger Hodoscope PreAmp Board (233) - Labor FY13 | 2013-09-03 → 2013-10-01 A (+28d) | 2013-09-30 → 2013-12-10 (+71d) |  | 0% → 30% | 158d → 139d |  |  |
| 2546605b | Tagger Hodoscope PreAmp Board (233) - Labor FY14 | 2013-10-01 A | 2013-11-08 → 2013-12-13 (+35d) |  | 0% → 30% | 158d → 135d | 9-130M FS+228d, 2546605a → 2546605a FS-30d |  |
| 2546610 | BCAL/FCAL Monitoring Distribution Sys. Procurement Support FY13 | 2013-09-03 → 2013-10-01 A (+28d) | 2013-09-30 → 2014-01-28 (+120d) |  | 0% → 60% |  |  |  |
| 2546610a | BCAL/FCAL Monitoring Distribution Sys. Procurement Support FY14 | 2013-10-01 A |  |  | 0% → 60% |  | 2546610, 9-130M FS+228d → 2546610 FS-60d |  |
| 2546620 | BCAL/FCAL Monitoring Distribution Box (10) Procurement | 2013-09-03 → 2013-10-01 A (+28d) |  |  |  |  |  | was named BCAL/FCAL Monitoring Distribution Box (10) - Procurement |
| 2546620a | BCAL/FCAL Monitoring Distribution Box (10) - Labor FY13 | 2013-09-03 → 2013-10-01 A (+28d) | 2013-09-30 → 2014-01-28 (+120d) |  |  | 172d → 180d |  |  |
| 2546620b | BCAL/FCAL Monitoring Distribution Box (10) - Labor FY4 | 2013-10-01 A |  |  |  |  | 9-130M FS+228d, 2546620a → 2546620a FS-60d |  |
| 7 | **1.5.4.7 DETECTOR CABLING** | 2011-01-11 → 2011-02-01 (+21d) |  |  |  |  |  |  |
| 1547005 | Cables - Low Voltage Cabling Development (Bcal,FDC&CDC) | 2011-01-11 → 2011-02-01 A (+21d) | 2011-03-25 → 2012-02-13 A (+325d) | 52d → 257d | 0% → 100% | 337d → none |  | was named Cables - Low Voltage Cabling Development (FDC&CDC); resources ELEC ENG [80 h]; ELEC TECH [80 h] → ELEC TECH [80 h]; ELEC ENG [80 h] |
| 1547035 | Cables - Coax Signal Procurement Support FY11 | 2011-07-07 → 2011-05-09 A (-59d) | 2011-09-30 → 2011-09-13 A (-17d) | 61d → 89d | 0% → 100% | 36d → none | 9-110M FS+187d → 9-110M |  |
| 1547035a | Cables - Coax Signal Procurement Support FY12 | 2011-10-03 → 2011-05-09 A (-147d) | 2011-12-16 → 2011-09-13 A (-94d) | 53d → 89d | 0% → 100% | 36d → none |  |  |
| 1547040 | Cables - Coax HV Procurement Support FY11 | 2011-07-07 → 2011-05-09 A (-59d) | 2011-09-30 → 2011-09-13 A (-17d) | 61d → 89d | 0% → 100% | 123d → none | 9-110M FS+187d → 9-110M |  |
| 1547040a | Cables - Coax HV Procurement Support FY12 | 2011-10-03 → 2011-05-09 A (-147d) | 2011-12-16 → 2011-09-13 A (-94d) | 53d → 89d | 0% → 100% | 123d → none |  |  |
| 1547055 | Cables - Coax HV Tagger/Hodoscope | 2012-01-03 → 2011-09-12 A (-113d) | 2012-09-28 → 2012-05-14 A (-137d) | 189d → 166d | 0% → 100% | 230d → none |  |  |
| 1547060 | Cables - Coax Signal Tagger/Hodoscope | 2012-01-03 → 2011-09-12 A (-113d) | 2012-09-28 → 2012-08-13 A (-46d) | 189d → 229d | 0% → 100% | 210d → none |  |  |
| 1547065 | Cables - Coax HV Pair Spectrometer | 2012-01-03 → 2011-09-12 A (-113d) | 2012-09-28 → 2012-06-11 A (-109d) | 189d → 184d | 0% → 100% | 220d → none |  |  |
| 1547070 | Cables - Coax Signal Pair Spectrometer | 2012-01-03 → 2011-09-12 A (-113d) | 2012-09-28 → 2012-09-17 A (-11d) | 189d → 253d | 0% → 100% | 175d → none |  |  |
| 1547075 | Cables - Coax HV Start Counter | 2012-01-03 → 2011-09-12 A (-113d) | 2012-09-28 → 2012-06-11 A (-109d) | 189d → 184d | 0% → 100% | 123d → none |  |  |
| 1547080 | Cables - Coax Signal Start Counter | 2012-01-03 → 2011-09-12 A (-113d) | 2012-09-28 → 2012-07-09 A (-81d) | 189d → 204d | 0% → 100% | 36d → none |  |  |
| 1547085 | Cables - LV BCAL | 2012-01-03 → 2011-09-12 A (-113d) | 2012-09-28 → 2012-12-17 A (+80d) | 189d → 324d | 0% → 100% | 220d → none |  |  |
| 1547090 | Cables - Bias BCAL | 2012-01-03 → 2011-09-12 A (-113d) | 2012-09-28 → 2012-12-17 A (+80d) | 189d → 324d | 0% → 100% | 228d → none | 1547045 FS-55d → 1547045 FS-35d |  |
| 1547095 | Cables - Coax Signal BCAL | 2012-01-03 → 2011-09-12 A (-113d) | 2012-09-28 → 2012-08-13 A (-46d) | 189d → 229d | 0% → 100% | 80d → none |  |  |
| 1547100 | Cables - Coax HV TOF | 2012-01-03 → 2011-09-12 A (-113d) | 2012-09-28 → 2012-09-17 A (-11d) | 189d → 253d | 0% → 100% | 229d → none |  |  |
| 1547105 | Cables - Coax Signal TOF | 2012-01-03 → 2011-09-12 A (-113d) | 2012-09-28 → 2012-07-09 A (-81d) | 189d → 204d | 0% → 100% | 228d → none |  |  |
| 1547110 | Cables - Coax Signal FCAL | 2012-01-03 → 2011-09-12 A (-113d) | 2012-09-28 → 2012-09-17 A (-11d) | 189d → 253d | 0% → 100% | 127d → none |  |  |
| 1547020 | Cables - Low Voltage Distribution Development (Bcal,FDC&CDC) | 2011-03-28 → 2011-10-17 A (+203d) | 2011-08-05 → 2012-05-14 A (+283d) | 93d → 141d | 0% → 100% | 340d → none | 1547005 → 1547005 FS-30d | was named Cables - Low Voltage Distribution Development (FDC&CDC) |
| 1547010 | Cables - Low Voltage Cabling Procurement Prep (Bcal,FDC&CDC) | 2011-03-28 → 2011-11-01 A (+218d) | 2011-08-26 → 2012-06-11 A (+290d) | 108d → 148d | 0% → 100% | 337d → none | 1547005 → 1547005 FS-15d | was named Cables - Low Voltage Cabling Procurement Support (FDC&CDC) |
| 1547045 | Cables - Coax Signal Acceptance Tests | 2012-01-10 → 2011-12-01 A (-40d) | 2012-03-21 → 2012-02-13 A (-37d) | 50d → 46d | 0% → 100% | 36d → none | 1547035a FS+10d → 1547035 FS+35d, 1547035a FS+35d |  |
| 1547050 | Cables - Coax HV Acceptance Tests | 2012-01-10 → 2011-12-01 A (-40d) | 2012-03-21 → 2012-02-13 A (-37d) | 50d → 46d | 0% → 100% | 123d → none | 1547040a FS+10d → 1547040a FS+35d |  |
| 1547015 | Cables - Low Voltage Assemblies (Bcal,FDC&CDC) | 2011-08-29 → 2012-04-16 A (+231d) | 2011-12-21 → 2012-11-12 A (+327d) | 80d → 148d | 0% → 100% | 337d → none | 1547010 → 1547010 FS-50d | was named Cables - Low Voltage Assemblies (FDC&CDC) |
| 1547030 | Cables - Low Voltage Distribution Supply Cables (Bcal,FDC&CDC) | 2011-08-29 → 2012-06-01 A (+277d) | 2011-12-16 → 2012-11-12 A (+332d) | 77d → 115d | 0% → 100% | 340d → none | 1547025 → 1547025 FS-100d | was named Cables - Low Voltage Distribution Supply Cables (FDC&CDC) |
| 1547025 | Cables - Low Voltage Distribution Chassis (Bcal,FDC&CDC) | 2011-04-18 → 2012-06-02 A (+411d) | 2011-08-26 → 2013-07-15 A (+689d) | 93d → 137d | 0% → 100% | 340d → none | 1547020 FS-78d → 1547020 | was named Cables - Low Voltage Distribution Chassis (FDC&CDC) |
| 1547185 | Cables - Signal Label and Bundle BCAL | 2013-01-03 → 2013-04-01 A (+88d) | 2013-08-06 → 2013-07-15 A (-22d) | 150d → 89d | 0% → 100% | 20d → none | 1547095, 9-130M FS+60d → 1547095, 9-130M FS+110d |  |
| 1547115 | Cables - HV Label and Bundle Tagger/Hodoscope | 2013-01-03 → 2013-06-01 A (+149d) | 2013-01-29 → 2013-07-15 A (+167d) |  | 0% → 100% | 170d → none | 1547055, 9-130M FS+60d → 1547055 FS+55d, 9-130M FS+100d |  |
| 1547120 | Cables - Signal Label and Bundle Tagger/Hodoscope | 2013-01-03 → 2013-06-01 A (+149d) | 2013-01-29 → 2013-07-15 A (+167d) |  | 0% → 100% | 150d → none | 1547060, 9-130M FS+60d → 1547060, 9-130M FS+100d |  |
| 1547125 | Cables - HV Label and Bundle Pair Spectrometer | 2013-01-03 → 2013-06-01 A (+149d) | 2013-01-16 → 2013-07-15 A (+180d) |  | 0% → 100% | 178d → none | 9-130M FS+60d, 1547065 FS+18d → 1547065 FS+18d, 9-130M FS+160d |  |
| 1547130 | Cables - Signal Label and Bundle Pair Spectrometer | 2013-01-08 → 2013-06-01 A (+144d) | 2013-01-22 → 2013-07-15 A (+174d) |  | 0% → 100% | 175d → none | 1547070 FS+63d, 9-130M FS+60d → 1547070 FS+63d, 9-130M FS+165d |  |
| 1547135 | Cables - HV Label and Bundle Start Counter | 2013-01-03 → 2013-06-01 A (+149d) | 2013-01-16 → 2013-07-15 A (+180d) |  | 0% → 100% | 96d → none | 9-130M FS+60d, 1547075 FS+33d → 9-130M FS+110d, 1547075 FS+33d |  |
| 1547140 | Cables - Signal Label and Bundle Start Counter | 2013-01-23 → 2013-06-01 A (+129d) | 2013-02-04 → 2013-07-15 A (+161d) |  | 0% → 100% | 36d → none | 1547080 FS+73d, 9-130M FS+60d → 9-130M FS+110d, 1547080 FS+73d |  |
| 1547155 | Cables - Signal Label and Bundle CDC | 2013-02-05 → 2013-06-01 A (+116d) | 2013-03-05 → 2013-07-15 A (+132d) |  | 0% → 100% | 36d → none | 1547140, 9-130M FS+60d → 1547140 FS-10d |  |
| 1547170 | Cables - Signal Label and Bundle FDC | 2013-03-06 → 2013-06-01 A (+87d) | 2013-05-10 → 2013-08-30 A (+112d) |  | 0% → 100% | 36d → none | 1547155, 9-130M FS+60d → 1547155 FS-20d |  |
| 1547195 | Cables - Signal Label and Bundle TOF | 2013-01-30 → 2013-06-01 A (+122d) | 2013-02-27 → 2013-08-30 A (+184d) |  | 0% → 100% | 150d → none | 1547105, 1547120, 9-130M FS+60d → 9-130M FS+60d, 1547105, 1547120 FS-20d |  |
| 1547200 | Cables - Signal Label and Bundle FCAL | 2013-01-03 → 2013-06-01 A (+149d) | 2013-05-21 → 2013-06-17 A (+27d) |  | 0% → 100% | 67d → none | 1547110, 9-130M FS+60d → 1547110, 9-130M FS+110d |  |
| 1547145 | Cables - LV Label and Bundle CDC | 2013-02-05 → 2013-07-01 A (+146d) | 2013-02-19 → 2013-07-15 A (+146d) |  | 0% → 100% | 64d → none | 1547030, 1547015, 1547140, 9-130M FS+60d → 1547015, 1547030, 1547140 |  |
| 1547160 | Cables - LV Label and Bundle FDC | 2013-02-20 → 2013-07-01 A (+131d) | 2013-04-02 → 2013-07-15 A (+104d) | 30d → 12d | 0% → 100% | 64d → none | 9-130M FS+60d, 1547145 → 1547145 |  |
| 1547190 | Cables - HV Label and Bundle TOF | 2013-02-15 → 2013-07-15 A (+150d) | 2013-03-14 → 2013-08-30 A (+169d) |  | 0% → 100% | 139d → none | 9-130M FS+60d, 1547100, 1547165 → 1547165 FS-25d, 1547100, 9-130M FS+60d |  |
| 1547175 | Cables - LV Label and Bundle BCAL | 2013-04-03 → 2013-08-01 A (+120d) | 2013-04-12 → 2013-08-30 A (+140d) |  | 0% → 100% | 98d → none | 1547160, 9-130M FS+60d, 1547085 → 1547160, 1547085 |  |
| 1547180 | Cables - Bias Label and Bundle BCAL | 2013-04-15 → 2013-08-13 A (+120d) | 2013-04-26 → 2013-08-30 A (+126d) |  | 0% → 100% | 98d → none | 9-130M FS+60d, 1547175, 1547090 → 1547090, 1547175 |  |
| 1547150 | Cables - HV Label and Bundle CDC | 2013-01-17 → 2013-08-30 A (+225d) | 2013-01-31 → 2013-08-30 A (+211d) |  | 0% → 100% | 96d → none |  |  |
| 1547165 | Cables - HV Label and Bundle FDC | 2013-02-01 → 2013-08-30 A (+210d) | 2013-02-14 → 2013-08-30 A (+197d) |  | 0% → 100% | 96d → none |  |  |
| 1547205 | Re-Baseline Actuals Adjustment | 2013-08-30 A | 2013-08-30 A |  | 0% → 100% | 20d → none | 9-130M FS+227d → none |  |
| 2547165 | Cables - HV Label and Bundle FDC (8) FY13 | 2013-09-16 → 2013-09-03 A (-13d) | 2013-09-30 → 2013-11-22 (+53d) |  | 0% → 50% |  |  |  |
| 2547165a | Cables - HV Label and Bundle FDC (8) FY14 | 2013-10-01 → 2013-09-03 A (-28d) | 2013-10-07 → 2013-11-22 (+46d) |  | 0% → 50% |  | 2547165, 9-130M FS+237d → 2547165 FS-20d |  |
| 2547170 | Cables - Signal Label and Bundle FDC (528) FY13 | 2013-09-03 A | 2013-09-30 → 2013-11-27 (+58d) |  | 0% → 90% | 5d → 16d |  |  |
| 2547170a | Cables - Signal Label and Bundle FDC (528) FY14 | 2013-10-01 → 2013-09-03 A (-28d) | 2013-10-25 → 2013-11-27 (+33d) |  | 0% → 90% | 5d → 16d | 9-130M FS+228d, 2547170 → 2547170 FS-20d |  |

| ID | Task | Start | Finish | Duration | Complete | Total float | Predecessors | Other |
| --- | --- | --- | --- | --- | --- | --- | --- | --- |
| 2547175 | Cables - LV Label and Bundle BCAL (24) | 2013-09-03 A | 2013-09-30 → 2013-10-21 A (+21d) |  | 0% → 100% | 58d → none |  |  |
| 2547180 | Cables - Bias Label and Bundle BCAL (36) | 2013-09-03 A | 2013-09-30 → 2013-10-21 A (+21d) |  | 0% → 100% | 58d → none |  |  |
| 2547190 | Cables - HV Label and Bundle TOF (168) FY13 | 2013-09-03 A | 2013-09-30 → 2014-01-31 (+123d) |  | 0% → 55% |  |  |  |
| 2547190a | Cables - HV Label and Bundle TOF (168) FY14 | 2013-10-01 → 2013-09-03 A (-28d) |  |  | 0% → 55% |  | 2547165a FS-25d, 2547190, 2547165 FS-25d → 2547165a FS-25d, 2547190 FS-80d |  |
| 2547200 | Cables - Signal Label and Bundle TOF (168) FY13 | 2013-09-03 A | 2013-09-30 → 2014-01-31 (+123d) |  | 0% → 50% |  | 2547190 FS-98d, 2547190a FS-98d → 2547190a FS-95.5d, 2547190 FS-98d |  |
| 2547200a | Cables - Signal Label and Bundle TOF (168) FY14 | 2013-10-01 → 2013-09-03 A (-28d) |  |  | 0% → 50% |  | 2547190 FS-98d, 2547200, 2547190a FS-98d → 2547190a FS-98d, 2547200 FS-80d |  |
| 2547135 | Cables - HV Label and Bundle CDC (6) | 2013-10-01 → 2013-11-01 (+31d) | 2013-11-04 → 2013-12-09 (+35d) |  |  | 134d → 111d |  |  |
| 8 | **1.5.4.8 FULL CRATE CHECKS** | 2012-06-06 → 2013-03-01 (+268d) | 2013-12-20 → 2014-02-27 (+69d) |  |  |  |  |  |
| 1548030 | Full Crate Check - Pre Installation,Lab,Install Mods,Test,Log&Label High Voltage | 2012-06-06 → 2013-03-01 A (+268d) | 2012-07-03 → 2013-04-15 A (+286d) |  | 0% → 100% | 310d → none | 1545080, 1545085 → 1545080, 1545085 FS+100d |  |
| 1548015 | Full Crate Check - Pre Installation,Lab,Install Mods,Test,Log&Label VXS fADC250 | 2013-04-01 → 2013-03-04 A (-28d) | 2013-04-19 → 2013-05-13 A (+24d) |  | 0% → 100% | 113d → none | 1541059, 1544015 → 1541059, 1544015, 1541057 FS-5d |  |
| 1548010 | Full Crate Check - Pre Installation,Lab,Install Mods,Test,Log&Label VME64x Discriminator | 2013-03-01 → 2013-07-01 A (+122d) | 2013-03-21 → 2013-07-15 A (+116d) | 15d → 50d | 0% → 100% | 134d → none |  | resources ELEC ENG [20 h]; ELEC TECH [80 h] → ELEC TECH [80 h]; ELEC ENG [20 h] |
| 1548035 | Full Crate Check - Pre Installation,Lab,Install Mods,Test,Log&Label Low Voltage | 2013-03-01 → 2013-07-01 A (+122d) | 2013-03-28 → 2013-08-12 A (+137d) | 20d → 8d | 0% → 100% | 129d → none | 1546555, 1546565, 1546560, 1546450, 1546460, 1545120a, 1546465, 1546550, 1545125a, 1546455, 1545125 → 1546460, 1545120a, 1546565 FS-100d, 1546465 FS-20d, 1546555, 1546560, 1545125a, 1546550, 1546450, 1546455 |  |
| 1548040 | Re-Baseline Actuals Adjustment | 2013-08-30 A | 2013-08-30 A |  | 0% → 100% | 20d → none | 9-130M FS+227d → none |  |
| 2548025 | Full Crate Check - Pre Installation,Lab,Install Mods,Test,Log&Label VXS F1TDC FY13 | 2013-09-09 → 2013-09-03 A (-6d) | 2013-09-30 → 2013-10-21 A (+21d) |  | 0% → 100% | 120d → none |  |  |
| 2548025a | Full Crate Check - Pre Installation,Lab,Install Mods,Test,Log&Label VXS F1TDC FY14 | 2013-10-01 → 2013-09-03 A (-28d) | 2013-12-13 → 2013-10-21 A (-53d) |  | 0% → 100% | 120d → none | 2548025, 9-130M FS+232d → 2548025 FS-75d | resources ELEC ENG [30.59 h]; ELEC TECH [30.59 h] → ELEC TECH [30.59 h]; ELEC ENG [30.59 h] |
| 2548020 | Full Crate Check - Pre Installation,Lab,Install Mods,Test,Log&Label VXS fADC125 FY13 | 2013-09-16 → 2013-11-11 (+56d) | 2013-09-30 → 2013-11-25 (+56d) |  |  | 111d → 140d | 2541145 FS-88d, 2541145a FS-88d, 2541120a FS-68d, 2541120 FS-68d → 2541145 FS-88d, 2541120a FS-68d, 2541145a FS-88d, 2541120 FS-10d |  |
| 2548020a | Full Crate Check - Pre Installation,Lab,Install Mods,Test,Log&Label VXS fADC125 FY14 | 2013-10-01 → 2013-11-26 (+56d) | 2013-12-20 → 2014-02-27 (+69d) |  |  | 111d → 140d | 2541145a FS-88d, 2541120 FS-68d, 2548020, 2541145 FS-88d, 2541120a FS-68d → 2548020 |  |
| 5 | **1.5.5 BEAMLINE** | 2009-04-01 → 2009-07-03 (+93d) |  |  |  |  |  |  |
| 1 | **1.5.5.1 TAGGER** | 2009-04-01 → 2009-07-03 (+93d) |  |  |  |  |  |  |
| 1 | **1.5.5.1.1 TAGGING MAGNET** | 2009-04-01 → 2009-07-03 (+93d) | 2013-10-15 → 2013-12-17 (+63d) |  |  |  |  |  |
| 15511070 | Proc Quad (TAGGING Mag) | 2009-04-01 → 2009-07-03 A (+93d) | 2009-07-16 → 2009-08-17 A (+32d) | 75d → 31d | 0% → 100% | 1118d → none |  |  |
| 15511010E | FY10 Travel (TAGGING Mag) | 2009-10-01 A | 2010-09-30 A |  | 0% → 100% | 84d → none |  |  |
| 15511002 | Prepare Procurements/Fabrication Packages 2010 ((TAGGING Mag) | 2009-10-01 → 2010-01-11 A (+102d) | 2010-09-29 → 2011-02-28 A (+152d) | 247d → 281d | 0% → 100% | 211d → none |  |  |
| 15511005 | Drawings for Yoke Steel (TAGGING Mag) | 2010-04-01 → 2010-03-29 A (-3d) | 2010-09-20 A | 120d → 123d | 0% → 100% | 274d → none |  |  |
| 15511010 | Drawings for Coils (TAGGING Mag) | 2010-04-01 → 2010-05-03 A (+32d) | 2010-08-20 → 2010-10-25 A (+66d) | 100d → 123d | 0% → 100% | 274d → none |  | resources CONTRB UNIV LBR [240 h]; PD UNIV STUDNT [880 h]; MECH ENG [160 h]; MECH DES [440 h]; VISTNG USERS [880 h] → PD UNIV STUDNT [880 h]; MECH ENG [160 h]; MECH DES [440 h]; VISTNG USERS [880 h]; CONTRB UNIV LBR [240 h] |
| 15511025 | Dsgn Stands for Mag (TAGGING Mag) | 2010-04-01 → 2010-06-21 A (+81d) | 2010-06-24 → 2012-01-16 A (+571d) | 60d → 387d | 0% → 100% | 334d → none |  |  |
| 15511030 | Dsgn Supprt for Vac Chamb (TAGGING Mag) | 2010-04-01 → 2010-06-21 A (+81d) | 2010-09-03 → 2011-12-12 A (+465d) | 110d → 369d | 0% → 100% | 284d → none |  | resources VISTNG USERS [880 h]; MECH ENG [160 h]; MECH DES [440 h] → MECH DES [440 h]; VISTNG USERS [880 h]; MECH ENG [160 h] |
| 15511040 | Write Pwr Supply Spec (TAGGING Mag) | 2010-08-23 → 2010-06-28 A (-56d) | 2010-09-27 → 2011-02-28 A (+154d) | 25d → 164d | 0% → 100% | 535d → none |  |  |
| 15511045 | EH&S Review of Dsgn before Constrctn (TAGGING Mag) | 2010-09-21 → 2010-07-01 A (-82d) | 2010-09-27 → 2010-07-12 A (-77d) | 5d → 7d | 0% → 100% | 274d → none | 15511010, 15511025, 15511015, 15511030 → 15511030 FS-50d, 15511015 FS-50d, 15511025 FS-50d, 15511010 FS-50d |  |
| 15511015 | Drawings for Vac Chamb (TAGGING Mag) | 2010-04-01 → 2010-07-19 A (+109d) | 2010-09-20 → 2011-09-10 A (+355d) | 120d → 286d | 0% → 100% | 274d → none |  | resources VISTNG USERS [880 h]; PD UNIV STUDNT [880 h]; MECH DES [440 h]; CONTRB UNIV LBR [240 h]; MECH ENG [160 h] → CONTRB UNIV LBR [240 h]; MECH ENG [160 h]; VISTNG USERS [880 h]; PD UNIV STUDNT [880 h]; MECH DES [440 h] |
| 15511035 | Dsgn Stands for Quad (TAGGING Mag) | 2011-10-03 → 2010-07-26 A (-434d) | 2011-12-20 → 2010-09-30 A (-446d) | 55d → 48d | 0% → 100% | 580d → none |  |  |
| 15511011E | FY11 Travel (TAGGING Mag) | 2010-10-01 A | 2011-09-30 A |  | 0% → 100% | 84d → none |  |  |
| 15511100 | Proc Turbo Pumps (TAGGING Mag) | 2012-10-01 → 2010-10-25 A (-707d) | 2012-10-26 → 2013-06-17 A (+234d) | 20d → 558d | 0% → 100% | 228d → none | 9-130M → 9-110M |  |
| 15511004a | Engineering Support for Component Procurements FY11 (TAGGING Mag) | 2011-01-04 → 2011-02-01 A (+28d) | 2011-09-30 A | 189d → 170d | 0% → 100% | 253d → none |  |  |
| 15511003 | Evaluate Procurements 2010 (TAGGING Mag) | 2011-01-05 → 2011-02-19 A (+45d) | 2011-08-26 → 2011-08-15 A (-11d) | 164d → 123d | 0% → 100% | 211d → none | 15511002 FS+61d → 15511002 |  |
| 15511050 | Vend Fab Tagger Magnet Peg Point #1 Submit Foundry reports | 2011-04-15 A | 2011-10-31 → 2011-11-21 A (+21d) | 139d → 154d | 0% → 100% | 141d → none | 15511003 FS-164d, 15511045, 9-110M FS+130d → 15511003 FS-250d, 15511045, 9-110M FS+100d |  |
| 15511050a | Vend Fab Tagger Magnet Peg Point #2 Winding tooling complete, conductor received | 2011-04-15 A | 2011-10-31 → 2011-11-28 A (+28d) | 139d → 157d | 0% → 100% | 141d → none | 15511050 FS-139d → 15511045, 15511003 FS-164d, 9-110M FS+120d |  |
| 15511050b | Vend Fab Tagger Magnet Peg Point #3 Submit machining sequence and initial ultrasonice inspection report | 2011-04-15 A | 2011-12-30 → 2012-03-19 A (+80d) | 176d → 229d | 0% → 100% | 141d → none |  |  |
| 15511050c | Vend Fab Tagger Magnet Peg Point #4 Twelve coil assemblies wound | 2011-04-15 A | 2011-12-30 → 2012-05-14 A (+136d) | 176d → 269d | 0% → 100% | 141d → none |  |  |
| 15511050d | Vend Fab Tagger Magnet Peg Point #5 Coil resin impregnation complete | 2011-04-15 A | 2012-03-30 → 2012-10-15 A (+199d) | 238d → 376d | 0% → 100% | 141d → none |  |  |
| 15511050f | Vend Fab Tagger Magnet Peg Point #6 Submit hydrostatic pressure test, flow and pressure test data | 2011-04-15 A | 2012-04-30 → 2012-11-12 A (+196d) | 259d → 396d | 0% → 100% | 141d → none |  |  |
| 15511050g | Vend Fab Tagger Magnet Peg Point #7 Submit dimensional and electrical test data | 2011-04-15 A | 2012-05-31 → 2012-09-17 A (+109d) | 281d → 356d | 0% → 100% | 141d → none |  |  |
| 15511050h | Vend Fab Tagger Magnet Peg Point #8 Submit coil dim. and electrical inspection tests if coil manufactured outside Everso | 2011-04-15 A | 2012-06-29 → 2012-09-17 A (+80d) | 301d → 356d | 0% → 100% | 141d → none |  |  |
| 15511050j | Vend Fab Tagger Magnet Peg Point #9 Submit dimension inspection report for core #1 and initial rep. on cores 2,3 and 4 | 2011-04-15 A | 2012-08-31 → 2012-09-17 A (+17d) | 346d → 356d | 0% → 100% | 141d → none |  |  |
| 15511050k | Vend Fab Tagger Magnet Peg Point #10 Magnet assembly complete | 2011-04-15 A | 2012-09-28 → 2012-11-12 A (+45d) | 365d → 396d | 0% → 100% | 141d → none |  |  |
| 15511050n | Vend Fab Tagger Magnet Peg Point #11 Magnet components arrive at JLab | 2011-04-15 A | 2012-11-30 → 2013-02-11 A (+73d) | 408d → 428d | 0% → 100% | 141d → none |  |  |
| 15511004 | Engineering Support for Magnet Acceptance 2012 (TAGGING Mag) | 2011-10-03 A | 2011-12-13 A |  | 0% → 100% | 431d → none |  | resources MECH DES [80 h]; MECH ENG [80 h] → MECH ENG [80 h]; MECH DES [80 h] |
| 15511004b | Engineering Support for Component Procurements FY12 (TAGGING Mag) | 2011-10-03 A | 2012-08-31 A |  | 0% → 100% | 253d → none |  |  |
| 15511012E | FY12 Travel (TAGGING Mag) | 2011-10-03 A | 2012-06-29 A |  | 0% → 100% | 84d → none |  |  |
| 15511060 | Proc Vac Chamb (TAGGING Mag) | 2012-01-05 → 2012-02-01 A (+27d) | 2012-09-28 → 2013-02-11 A (+136d) | 187d → 232d | 0% → 100% | 184d → none |  | resources PROCUREMENT<$50K 60; PROCUREMENT>$50K 69; VISTNG USERS [120 h] → VISTNG USERS [120 h]; PROCUREMENT<$50K 60; PROCUREMENT>$50K 69 |
| 15511065 | Proc Pwr Supply (TAGGING Mag) | 2012-03-05 → 2012-03-02 A (-3d) | 2012-09-28 → 2013-06-17 A (+262d) | 147d → 211d | 0% → 100% | 184d → none |  |  |
| 15511110 | Proc. Tagger magnet stands | 2012-04-03 → 2012-05-01 A (+28d) | 2012-08-31 → 2012-09-17 A (+17d) | 107d → 97d | 0% → 100% | 267d → none |  |  |
| 15511071 | Proc Quad Power Supply (TAGGING Mag) | 2012-05-07 → 2012-06-03 A (+27d) | 2012-09-28 → 2013-06-17 A (+262d) | 102d → 148d | 0% → 100% | 424d → none | 9-120M FS+145d, 15511070 → 9-120M FS+184d, 15511070 |  |
| 15511095 | Proc, calibrate, Install NMR (TAGGING Mag) FY12 | 2012-05-04 → 2012-07-02 A (+59d) | 2012-09-28 → 2013-03-11 A (+164d) | 103d → 184d | 0% → 100% | 175d → none | 9-120M FS+144d, 15511015 → 15511015, 9-120M | resources MECH TECH [29.43 h]; PD UNIV STUDNT [647.43 h]; MECH DES [88.29 h]; MECH ENG [29.43 h] → MECH DES [88.29 h]; MECH ENG [29.43 h]; MECH TECH [29.43 h]; PD UNIV STUDNT [647.43 h] |
| 15511095a | Proc, calibrate, Install NMR (TAGGING Mag) FY13 | 2012-10-01 → 2012-07-02 A (-91d) | 2013-01-09 → 2013-03-11 A (+61d) | 65d → 184d | 0% → 100% | 175d → none | 15511095 → 15511095 FS-145d | resources MECH TECH [18.57 h]; PD UNIV STUDNT [408.57 h]; MECH DES [55.71 h]; MECH ENG [18.57 h] → MECH ENG [18.57 h]; MECH TECH [18.57 h]; PD UNIV STUDNT [408.57 h]; MECH DES [55.71 h] |
| 15511095b | Proc, calibrate, Install NMR (TAGGING Mag) Procurement | 2012-05-04 → 2012-07-02 A (+59d) | 2013-01-09 → 2013-08-30 A (+233d) | 168d → 184d | 0% → 100% | 175d → none | 9-120M FS+144d, 15511015 → 9-120M, 15511015 |  |
| 15511105 | Tagger Magnet Acceptance Test (TAGGING Mag) | 2012-12-03 → 2013-01-07 A (+35d) | 2012-12-03 → 2013-01-21 A (+49d) |  | 0% → 100% | 141d → none | 15511004 FS-50d, 15511004b FS-50d, 15511065, 15511050n, 15511060 → 15511004 FS-50d, 15511065 FS-15d, 15511050n, 15511060, 15511004b FS-50d, 15511050, 15511050a |  |
| 15511115 | Proc. Tagger beamline stands | 2012-11-02 → 2013-02-04 A (+94d) | 2013-02-28 → 2013-07-15 A (+137d) |  | 0% → 100% | 325d → none | 9-130M FS+24d → 9-130M |  |
| 15511120 | Re-Baseline Actuals Adjustment | 2013-08-30 A | 2013-08-30 A |  | 0% → 100% | 20d → none | 9-130M FS+227d → none |  |
| 25511095 | Proc,Calibrate, Install NMR (TAGGING Mag) FY13 | 2013-09-03 → 2013-11-01 (+59d) | 2013-09-30 → 2013-12-02 (+63d) |  |  | 125d → 133d | 9-130M FS+228d → 9-140M, 9-130M FS+228d | was named Proc, calibrate, Install NMR (TAGGING Mag) FY13 |
| 25511095a | Proc, calibrate, Install NMR (TAGGING Mag) FY14 | 2013-10-01 → 2013-12-03 (+63d) | 2013-10-15 → 2013-12-17 (+63d) |  |  | 125d → 133d | 25511095, 9-130M FS+228d → 25511095 |  |
| 15512004 | Prepare Procurement/Fabrication Packages 2012(HODOSCP) | 2011-10-03 A | 2012-09-28 A |  | 0% → 100% | 178d → none |  |  |
| 15512012E | FY12 Travel (HODOSCP) | 2011-10-03 A | 2012-09-28 A |  | 0% → 100% | 20d → none |  |  |
| 15512136 | Design & Layout Preamp Cards (HODOSCP) | 2011-10-03 A | 2012-05-25 → 2013-01-31 A (+251d) | 160d → 304d | 0% → 100% | 335d → none |  |  |
| 15512001 | Prepare Procurements for Thin Window Test 2011 (HODOSCP) | 2012-01-05 → 2011-10-05 A (-92d) | 2012-03-12 → 2012-01-16 A (-56d) | 46d → 65d | 0% → 100% | 169d → none | 9-120M FS+60d → 9-120M |  |
| 15512020 | AL Foil for Thin Window (HODOSCP) | 2012-01-05 → 2012-01-09 A (+4d) | 2012-02-02 → 2012-02-13 A (+11d) | 20d → 25d | 0% → 100% | 135d → none |  |  |
| 15512025 | Frame & Vacuum System for Limit Test of Thin Window (HODOSCP) | 2012-04-30 → 2012-01-16 A (-105d) | 2012-10-31 → 2012-04-16 A (-198d) | 130d → 64d | 0% → 100% | 135d → none | 15512001, 15512020 FS+60d → 15512020 FS-50d, 15512001 |  |
| 15512002 | Engineering Support for Testing Thin Window (HODOSCP) | 2012-11-01 → 2012-02-01 A (-274d) | 2013-01-14 → 2012-05-14 A (-245d) | 45d → 73d | 0% → 100% | 135d → none | 9-130M FS+23d → 9-130M FS-180d |  |
| 15512030 | Test Window to limit (HODOSCP) | 2012-11-01 → 2012-02-01 A (-274d) | 2013-01-14 → 2012-04-16 A (-273d) | 45d → 53d | 0% → 100% | 135d → none | 15512025, 15512002 FS-45d → 15512002 FS-225d, 15512025 FS-180d |  |
| 15512170 | Purchase Power Supply for DAC Chips (HODOSCP) | 2012-01-05 → 2012-02-01 A (+27d) | 2012-01-19 → 2012-02-20 A (+32d) | 10d → 13d | 0% → 100% | 425d → none |  |  |

| ID | Task | Start | Finish | Duration | Complete | Total float | Predecessors | Other |
| --- | --- | --- | --- | --- | --- | --- | --- | --- |
| 15512100 | Proc Fibers for Microscope (HODOSCP) | 2012-04-02 → 2012-07-02 A (+91d) | 2012-08-27 → 2012-09-17 A (+21d) | 104d → 55d | 0% → 100% | 271d → none | 9-120M FS+120d, 12351055M → 12351055M, 9-120M FS+184d |  |
| 15512110 | Proc SiPMs for Microscope (HODOSCP) Part A | 2012-07-11 → 2012-07-02 A (-9d) | 2013-02-28 → 2013-04-15 A (+46d) | 156d → 163d | 0% → 100% | 149d → none |  |  |
| 15512013E | FY13 Travel (HODOSCP) | 2012-10-01 A | 2013-08-30 A | 228d → 248d | 0% → 100% | 20d → none |  |  |
| 15512003 | Prepare Procurement/Fabrication Packages 2013 (HODOSCP) | 2012-12-03 A | 2013-01-14 A |  | 0% → 100% | 135d → none |  |  |
| 15512035 | Fab Final Thin Exit Window & AL Flange (HODOSCP) | 2013-01-15 → 2012-12-03 A (-43d) | 2013-03-20 → 2013-08-30 A (+163d) |  | 0% → 100% | 135d → none |  |  |
| 15512120 | Proc Cables for Microscope (HODOSCP) | 2012-03-06 → 2013-02-04 A (+335d) | 2012-08-31 → 2013-02-18 A (+171d) | 127d → 65d | 0% → 100% | 267d → none | 9-120M FS+101d, 12351055M → 9-120M FS+163d, 9-130M FS+110d, 12351055M |  |
| 15512050 | Proc PMTs for Fixed Array (HODOSCP) | 2012-10-01 → 2013-02-11 A (+133d) | 2013-04-30 → 2013-05-13 A (+13d) |  | 0% → 100% | 106d → none | 9-130M → 9-120M FS+184d, 9-130M |  |
| 15512055 | Proc Dividers for Fixed Array (HODOSCP) | 2012-10-01 → 2013-02-11 A (+133d) | 2013-04-30 → 2013-08-30 A (+122d) |  | 0% → 100% | 106d → none | 9-130M → 9-130M, 9-120M FS+184d |  |
| 15512005 | Design Hodoscope Supprt (HODOSCP) | 2012-07-09 → 2013-04-01 A (+266d) | 2012-09-28 → 2013-08-30 A (+336d) |  | 0% → 100% | 71d → none | 9-120M FS+188d → 9-130M FS+110d, 9-120M FS+188d | resources PD UNIV STUDNT [640 h]; MECH DES [440 h]; MECH TECH [320 h] → MECH DES [440 h]; MECH TECH [320 h]; PD UNIV STUDNT [640 h] |
| 15512005a | Construct Hodoscope Supprt (HODOSCP) | 2013-04-08 A | 2013-06-19 → 2013-08-30 A (+72d) |  | 0% → 100% | 71d → none | 15512005 FS+125d → 15512005 FS-80d |  |
| 15512110a | Proc SiPM support Equipment for Microscope (HODOSCP) Part B | 2012-07-11 → 2013-07-01 A (+355d) | 2013-02-28 → 2013-07-15 A (+137d) | 156d → 76d | 0% → 100% | 149d → none | 9-120M FS+190d → 9-130M FS+110d, 9-120M FS+190d | was named Proc SiPMs for Microscope (HODOSCP) Part B; resources PROCUREMENT<$50K 60 NO ESCALATION FY13; PROCUREMENT>$50K 69 NO ESCALATION FY13 → PROCUREMENT>$50K 69 NO ESCALATION FY13; PROCUREMENT<$50K 60 NO ESCALATION FY13 |
| 15512175 | Re-Baseline Actuals Adjustment | 2013-08-30 A | 2013-08-30 A |  | 0% → 100% | 20d → none | 9-130M FS+227d → none |  |
| 25512005 | Design Hodoscope Supprt (HODOSCP) FY13 | 2013-09-03 A | 2013-09-30 → 2013-11-15 (+46d) | 20d → 31d |  | 147d → 148d |  | resources MECH ENG [29.03 h]; MECH DES [22.58 h] → MECH DES [22.58 h]; MECH ENG [29.03 h] |
| 25512005a | Construct Hodoscope Supprt (HODOSCP) Part A | 2013-10-15 → 2013-09-03 A (-42d) |  |  | 0% → 70% |  | 25512005 FS-1d, 25512005b FS-1d → 25512005 FS-12d, 25512005b FS-12d |  |
| 25512005b | Design Hodoscope Supprt (HODOSCP) FY14 | 2013-10-01 → 2013-09-03 A (-28d) | 2013-10-15 → 2013-11-15 (+31d) |  |  | 147d → 148d | 9-130M FS+228d, 25512005 → 25512005 FS-15d |  |
| 25512010 | Catholic University Tagger Hodoscope Fixed Array | 2013-09-03 A |  |  | 0% → 15% |  |  |  |
| 25512010a | Catholic University Tagger Hodoscope Fixed Array Oversight FY13 | 2013-09-03 A | 2013-09-30 A | 20d → 118d | 0% → 100% | 89d → none |  |  |
| 25512013LOE | FY13 Travel (HODOSCP) | 2013-09-03 A | 2013-09-30 A |  | 0% → 100% | 187d → none |  |  |
| 25512056 | Manufacturing Drawings for Hodoscope mag shield (HODOSCP) | 2013-09-03 A | 2013-09-30 → 2013-12-02 (+63d) |  | 0% → 80% | 150d → 107d |  |  |
| 25512131 | UConn TAGM Contract - Procurement of Supplies for Construction | 2013-09-03 A | 2013-09-30 → 2013-10-21 A (+21d) |  | 0% → 100% | 89d → none |  |  |
| 25512136 | UConn TAGM Contract - Production 1st Article Opt Fib Bundle | 2013-09-03 A | 2013-09-30 → 2013-11-27 (+58d) |  |  | 89d → 305d |  |  |
| 25512146 | UConn TAGM Contract - Complete Construction of TAGM Enclosure | 2013-09-03 A |  |  |  | 89d → 304d |  |  |
| 25512151 | UConn TAGM Contract - Testing of TAGM Electronic Boards | 2013-09-03 A | 2013-09-30 → 2013-12-02 (+63d) |  |  | 89d → 261d |  |  |
| 25512156 | UConn TAGM Contract - Complete 20 Optical Fiber Bundles | 2013-09-03 A |  |  |  | 89d → 261d |  |  |
| 25512161 | UConn TAGM Contract - Complete Construction of Fiber Array Enclosure | 2013-09-03 A |  |  |  | 89d → 218d |  |  |
| 25512166 | UConn TAGM Contract - Complete Assembly of Full Enclosure at UConn | 2013-09-03 A |  |  |  | 89d → 175d |  |  |
| 25512171 | UConn TAGM Contract - Disassemble TAGM and Prepare for Shipment to JLab | 2013-09-03 A |  |  |  | 89d → 132d |  |  |
| 25512176 | UConn TAGM Contract - TAGM Delivered to JLab | 2013-09-03 A |  |  |  |  |  |  |
| 25512010aa | Catholic University Tagger Hodoscope Fixed Array Oversight FY14 | 2013-10-01 A |  |  | 0% → 23% |  | 25512010a, 9-130M FS+228d → 25512010a FS-100d |  |
| 25512065 | Manufacturing Drawings for microscope cooling FY13 | 2013-09-03 → 2013-10-01 A (+28d) | 2013-09-30 → 2014-02-06 (+129d) |  | 0% → 20% |  |  |  |
| 25512065a | Manufacturing Drawings for microscope cooling FY14 | 2013-10-01 A |  |  | 0% → 20% |  | 25512065, 9-130M FS+228d → 25512065 FS-70d |  |
| 25512060 | Fab Hodoscope mag shields | 2013-10-01 → 2013-12-03 (+63d) | 2013-11-20 → 2014-02-04 (+76d) |  |  | 150d → 107d |  |  |
| 2 | **1.5.5.2 TARGET** |  | 2014-08-18 → 2014-09-03 (+16d) |  |  |  |  |  |
| 1552001 | Prepare Procurements/Fabrication Packages 2012 (TARGET) | 2011-04-01 A | 2011-09-30 → 2013-08-23 A (+693d) | 128d → 454d | 0% → 100% | 377d → none |  |  |
| 1552004 | Develop gas handling system | 2011-04-01 → 2011-05-01 A (+30d) | 2011-09-01 → 2013-02-11 A (+529d) | 108d → 407d | 0% → 100% | 486d → none |  | resources MECH TECH [240 h]; MECH DES [240 h]; MECH ENG [320 h] → MECH DES [240 h]; MECH ENG [320 h]; MECH TECH [240 h] |
| 1552032 | Develop cryo system design | 2011-06-01 → 2011-05-13 A (-19d) | 2011-09-30 → 2013-08-30 A (+700d) | 86d → 397.57d | 0% → 100% | 327d → none |  |  |
| 1552030 | Proc Liquid Helium refrigerator (TARGET) | 2011-10-03 A | 2012-02-02 → 2012-02-13 A (+11d) | 80d → 87d | 0% → 100% | 394d → none | 1552003 FS-300d, 1552002a FS-300d, 9-120M → 1552002a FS-300d, 1552003 FS-300d, 9-120M, 1552002 FS-300d |  |
| 1552003 | FY12 Engineering Support for Assembly (TARGET) | 2012-01-05 → 2012-01-03 A (-2d) | 2012-07-10 A | 130d → 132d | 0% → 100% | 267d → none |  |  |
| 1552002 | Evaluate Procuements 2012 (TARGET) FY11 | 2011-05-10 → 2012-02-01 A (+267d) | 2011-09-30 → 2012-04-16 A (+199d) | 101d → 52.5d | 0% → 100% | 377d → none | 1552001 FS-101d → 1552001 FS-300d |  |
| 1552002a | Evaluate Procuements 2012 (TARGET) FY12 | 2011-10-03 → 2012-04-17 A (+197d) | 2012-05-10 → 2013-02-11 A (+277d) | 149d → 254.5d | 0% → 100% | 377d → none | 1552002 → 1552002 FS-50d |  |
| 1552023 | Fab Target Cells (TARGET) Labor Original | 2012-01-05 → 2012-09-03 A (+242d) | 2012-01-31 → 2012-10-28 A (+271d) | 18d → 39d | 0% → 100% | 207d → none | 9-120M FS+60d → 9-120M FS+184d |  |
| 1552023a | Fab Target Cells (TARGET) Labor Revised 2012 ETC FY12 | 2012-04-02 → 2012-09-03 A (+154d) | 2012-09-28 → 2013-08-30 A (+336d) | 127d → 166d | 0% → 100% | 207d → none | 1552023 FS+42d → 1552023 FS-20d |  |
| 1552023aa | Fab Target Cells (TARGET) Labor Revised 2012 ETC FY13 | 2012-10-01 → 2012-09-03 A (-28d) | 2012-10-26 → 2013-08-30 A (+308d) | 20d → 166d | 0% → 100% | 207d → none | 1552023 FS+42d, 1552023a → 1552023a FS-150d |  |
| 1552025 | Fab Target Cells (TARGET) | 2012-10-01 → 2012-09-03 A (-28d) | 2013-05-07 → 2013-08-30 A (+115d) | 147d → 166d | 0% → 100% | 80d → none | 9-130M, 1552023aa FS-147d, 1552003 FS-130d, 1552023a FS-147d, 1552023 FS-130d → 9-130M, 1552023 FS-130d, 1552023aa FS-147d, 1552003 FS-130d |  |
| 1552027 | Burst test target cell | 2012-06-06 → 2012-10-08 A (+124d) | 2012-09-04 → 2012-10-22 A (+48d) | 64d → 11d | 0% → 100% | 245d → none | 1552025 FS-229d → 1552025 FS-102d |  |
| 1552033 | Procure heat xchngr and cryo hardware | 2013-01-03 → 2012-12-03 A (-31d) | 2013-08-01 → 2013-08-30 A (+29d) |  | 0% → 100% | 20d → none | 1552032, 9-130M FS+60d → 1552032 FS-55d, 9-130M |  |
| 1552005 | Proc Gas Handling Sys (TARGET) | 2013-02-15 → 2013-02-11 A (-4d) | 2013-08-06 → 2013-08-30 A (+24d) |  | 0% → 100% | 129d → none |  |  |
| 1552010 | Proc Controls (TARGET) | 2013-03-18 → 2013-02-11 A (-35d) | 2013-08-30 A | 118d → 120d | 0% → 100% | 20d → none | 9-130M FS+110d → 9-130M |  |
| 1552015 | Fab Isolation Vac Pumping Sys (TARGET) | 2013-03-18 → 2013-03-04 A (-14d) | 2013-07-12 → 2013-08-30 A (+49d) |  | 0% → 100% | 94d → none | 9-130M FS+110d, 1552003 FS-130d → 1552003 FS-130d, 9-130M |  |
| 1552006 | Install Gas Handling Sys (TARGET) | 2013-05-24 → 2013-08-30 A (+98d) | 2013-08-30 A | 69d → 109d | 0% → 100% | 169d → none |  |  |
| 1552018 | Fab Outer Vac/Scattering Chamb (TARGET) Labor Original | 2012-01-05 → 2013-08-30 A (+603d) | 2012-01-31 → 2013-08-30 A (+577d) |  | 0% → 100% | 207d → none | 9-120M FS+60d → 9-130M FS+150d, 9-120M FS+184d |  |
| 1552018a | Fab Outer Vac/Scattering Chamb (TARGET) Labor Revised 2012 ETC | 2012-05-07 → 2013-08-30 A (+480d) | 2012-09-28 → 2013-08-30 A (+336d) |  | 0% → 100% | 207d → none | 1552018 FS+67d → 1552018 |  |
| 1552020 | Fab Outer Vac/Scattering Chamb (TARGET) | 2012-12-03 → 2013-08-30 A (+270d) | 2013-07-09 → 2013-08-30 A (+52d) | 147d → 90d | 0% → 100% | 37d → none | 9-130M FS+43d, 1552003 FS-130d, 1552018 FS-130d, 1552018a FS-127d → 9-130M FS+100d, 1552018 FS-130d, 1552018a FS-127d, 1552003 FS-130d |  |
| 1552028 | Prepare Procurements/Fabrication Packages solid target (TARGET) | 2013-05-31 → 2013-08-30 A (+91d) | 2013-08-28 → 2013-08-30 A (+2d) |  | 0% → 100% | 189d → none |  |  |
| 1552028b | Fabricate solid target (labor) | 2013-08-29 → 2013-08-30 A (+1d) | 2013-08-30 A | 2d → 63d | 0% → 100% | 189d → none |  |  |
| 1552035 | Fab Positioning/Mounting Sys (TARGET) | 2012-11-05 → 2013-08-30 A (+298d) | 2013-05-09 → 2013-08-30 A (+113d) | 124d → 49d | 0% → 100% | 78d → none | 9-130M FS+25d → 9-130M FS+145d |  |
| 1552040 | Assemble Target (TARGET) | 2013-08-02 → 2013-08-30 A (+28d) | 2013-08-30 A | 21d → 128d | 0% → 100% | 20d → none | 1552033, 1552020, 1552030, 9-130M FS+6d, 1552045 FS-170d, 1552027, 1552028b FS-190d, 1552035, 1552025, 1552006 FS-170d, 1552015 FS-60d, 1552005 FS-112d → 1552030, 1552010 FS-112d, 1552033, 9-130M FS+6d, 1552035, 1552005 FS-112d, 1552006 FS-170d, 1552028b FS-190d, 1552020, 1552045 FS-150d, 1552015 FS-60d, 1552025, 1552027 | resources MECH ENG [13.13 h]; MECH TECH [59.06 h] → MECH TECH [59.06 h]; MECH ENG [13.13 h] |
| 1552045 | Program controls | 2013-03-08 → 2013-08-30 A (+175d) | 2013-05-22 → 2013-08-30 A (+100d) |  | 0% → 100% | 239d → none | 9-130M FS+104d → 9-130M FS+150d |  |
| 1552050 | Re-Baseline Actuals Adjustment | 2013-08-30 A | 2013-08-30 A |  | 0% → 100% | 20d → none | 9-130M FS+227d → none |  |
| 2552001 | Prepare Procurements/Fabrication Packages FY13 (TARGET) | 2013-09-03 A | 2013-09-30 → 2013-11-15 (+46d) |  | 0% → 60% | 48d → 13d |  |  |
| 2552001a | Prepare Procurements/Fabrication Packages FY14 (TARGET) | 2013-10-01 → 2013-09-03 A (-28d) | 2013-10-14 → 2013-11-15 (+32d) |  | 0% → 60% | 48d → 13d | 2552001, 9-130M FS+228d → 2552001 FS-40d |  |
| 2552005 | Proc Gas Handling Sys (TARGET) - Procurement | 2013-09-03 A | 2013-11-11 → 2013-11-15 (+4d) |  | 0% → 75% | 68d → 64d |  |  |
| 2552005a | Proc Gas Handling Sys (TARGET) - Expenses FY13 | 2013-09-03 A | 2013-09-30 → 2013-11-15 (+46d) |  | 0% → 75% | 68d → 113d |  |  |
| 2552005b | Proc Gas Handling Sys (TARGET) - Expenses FY14 | 2013-10-01 → 2013-09-03 A (-28d) | 2013-11-11 → 2013-11-15 (+4d) |  | 0% → 75% | 68d → 64d | 2552005a, 9-130M FS+228d → 2552005a FS-60d |  |
| 2552010 | Proc Controls (TARGET) - Procurement | 2013-09-03 A |  |  | 0% → 70% |  |  |  |
| 2552010a | Proc Controls (TARGET) - Expenses FY13 | 2013-09-03 A | 2013-09-30 → 2013-12-04 (+65d) |  | 0% → 70% | 167d → 220d |  |  |
| 2552010b | Proc Controls (TARGET) - Expenses FY14 | 2013-10-01 → 2013-09-03 A (-28d) |  |  | 0% → 70% |  | 2552010a, 9-130M FS+228d → 2552010a FS-75d |  |
| 2552012 | Program Target Controls | 2013-10-07 → 2013-09-03 A (-34d) |  |  | 0% → 25% |  | 2552010b FS-41d, 2552010 FS-41d, 2552010a FS-41d → 2552010b FS-70d, 2552010 FS-70d |  |
| 2552015 | Fab Isolation Vac Pumping Sys (TARGET) (Previously Obligated) | 2013-09-03 A | 2013-11-12 → 2013-09-23 A (-50d) |  | 0% → 100% | 129d → none |  |  |
| 2552015a | Fab Isolation Vac Pumping Sys (TARGET) | 2013-09-03 A |  |  | 0% → 10% |  |  |  |

| ID | Task | Start | Finish | Duration | Complete | Total float | Predecessors | Other |
| --- | --- | --- | --- | --- | --- | --- | --- | --- |
| 2552023aa | Fab Target Cells (TARGET) FY13 | 2013-09-03 A | 2013-09-30 → 2014-02-17 (+140d) | 20d → 109d | 0% → 50% |  |  |  |
| 2552023aaa | Fab Target Cells (TARGET) FY14 | 2013-10-01 → 2013-09-03 A (-28d) |  |  | 0% → 50% |  | 9-130M FS+228d, 2552023aa → 2552023aa FS-100d |  |
| 2552032 | Manufacturing Drawings for cryo system (Target) FY13 | 2013-09-03 A | 2013-09-30 → 2013-11-14 (+45d) | 20d → 30d | 0% → 45% | 100d → 97d |  |  |
| 2552032a | Manufacturing Drawings for cryo system (Target) FY14 | 2013-10-01 → 2013-09-03 A (-28d) | 2013-10-14 → 2013-11-14 (+31d) |  | 0% → 45% | 100d → 97d | 2552032, 9-130M FS+228d → 2552032 FS-15d |  |
| 2552033 | Procure heat xchngr and cryo hardware | 2013-09-03 A | 2013-09-30 → 2013-10-21 A (+21d) |  | 0% → 100% | 100d → none |  |  |
| 2552008 | Manufacturing Drawings for gas System (Target) FY13 | 2013-09-03 → 2013-10-01 A (+28d) | 2013-09-30 → 2013-12-05 (+66d) |  | 0% → 40% |  | 9-130M FS+228d → 9-130M FS+228d, 9-140M FS+23d |  |
| 2552008a | Manufacturing Drawings for gas System (Target) FY14 | 2013-10-01 A |  |  | 0% → 40% |  | 2552008, 9-130M FS+228d → 2552008 FS-30d |  |
| 2552018a | Fab Outer Vac/Scattering Chamb (TARGET) | 2013-10-15 → 2013-12-11 (+57d) | 2013-12-09 → 2014-02-13 (+66d) |  |  | 52d → 13d | 2552001a, 2552001 → 2552001a FS+15d, 2552001 FS+15d |  |
| 2552035 | Fab Positioning/Mounting Sys (TARGET) | 2013-11-01 → 2014-01-03 (+63d) | 2014-01-13 → 2014-03-04 (+50d) |  |  | 35d → 0d | 2552001, 2552001a, 9-140M FS+23d → 2552001, 2552001a, 9-140M FS+60d |  |
| 2552007 | Install Gas Tank (TARGET) | 2014-01-10 → 2014-01-08 (-2d) | 2014-02-05 → 2014-02-03 (-2d) |  |  | 19d → 21d | 2552001a, 9-140M FS+63d, 2552001, 2552005 FS-16d, 2552005a FS-16d, 2552005b FS-16d → 2552001, 2552005b FS-16d, 9-140M FS+63d, 2552001a, 2552005 FS-16d |  |
| 2552006 | Install Gas Handling Sys (TARGET) | 2014-01-10 → 2014-01-16 (+6d) | 2014-05-12 → 2014-05-16 (+4d) |  |  | 79d → 75d | 2552005a FS+33d, 2552005b FS+33d, 2552008, 2552008a, 2552005 FS+33d → 2552008, 2552005b FS+33d, 2552005 FS+33d, 2552008a |  |
| 2552028 | Prepare Procurements/Fabrication Packages solid target (TARGET) | 2014-02-03 → 2014-01-30 (-4d) | 2014-04-01 → 2014-03-28 (-4d) |  |  | 131d → 133d |  |  |
| 2552040 | Assemble Target (TARGET) | 2014-02-18 → 2014-03-05 (+15d) | 2014-08-18 → 2014-09-03 (+16d) |  |  | 11d → 0d | 2552018a, 2552010b FS-112d, 2552035, 2552006 FS-170d, 2552015 FS-60d, 2552007, 2552010 FS-112d, 2552028a FS-190d, 2552028b FS-190d, 2552015a FS-60d, 2552010a FS-112d, 2552023aaa, 2552023aa, 2552033, 2552012 FS-170d → 2552028a FS-190d, 2552015a FS-60d, 2552018a, 2552015 FS-60d, 2552033, 2552035, 2552028b FS-190d, 2552007, 2552023aaa, 2552006 FS-170d, 2552012 FS-170d, 2552010 FS-112d, 2552023aa, 2552010b FS-112d |  |
| 2552028a | Fabricate solid target (proc) | 2014-04-03 → 2014-04-01 (-2d) | 2014-05-27 → 2014-05-22 (-5d) |  |  | 131d → 133d |  |  |
| 2552028b | Fabricate solid target (labor) | 2014-04-03 → 2014-04-01 (-2d) | 2014-05-27 → 2014-05-22 (-5d) |  |  | 131d → 133d |  |  |
| 1553010E | FY10 Travel (BL Compnts) | 2009-10-01 A | 2010-09-30 A |  | 0% → 100% | 20d → none |  |  |
| 1553085 | Design Primary Collimator Support (BL Compnts) | 2012-01-05 → 2010-07-19 A (-535d) | 2012-03-23 → 2011-10-24 A (-151d) | 55d → 317d | 0% → 100% | 393d → none | 9-120M FS+60d → 9-100M |  |
| 1553001 | Engineering Support for Obtaining/Tstng Pair Spectrmtr Mag (BL Compnts) | 2010-10-01 A | 2011-01-11 A |  | 0% → 100% | 678d → none |  |  |
| 1553011E | FY11 Travel (BL Compnts) | 2010-10-01 A | 2011-09-30 A |  | 0% → 100% | 20d → none |  |  |
| 1553030 | Obtain Surplus Mag (BL Compnts) | 2010-10-01 A | 2011-01-11 → 2011-05-23 A (+132d) | 65d → 157d | 0% → 100% | 678d → none |  |  |
| 1553001a | Prepare Procurements Packages 2011 (BL Compnts) | 2011-01-05 A | 2011-09-30 → 2011-09-26 A (-4d) | 188d → 184d | 0% → 100% | 383d → none |  |  |
| 1553100 | Prepare Environment for Sweep Magnets (BL Compnts) | 2011-03-18 → 2011-03-01 A (-17d) | 2011-05-26 → 2011-08-31 A (+97d) | 50d → 130d | 0% → 100% | 552d → none |  |  |
| 1553031 | Develop magnet gap modification | 2011-08-01 A | 2011-09-30 → 2011-12-19 A (+80d) | 44d → 98d | 0% → 100% | 349d → none |  | resources MECH DES [320 h]; MECH ENG [320 h] → MECH ENG [320 h]; MECH DES [320 h] |
| 1553012E | FY12 Travel (BL Compnts) | 2011-10-03 A | 2012-09-28 A |  | 0% → 100% | 20d → none |  |  |
| 1553080 | Proc Passive Collimator Sys (BL Compnts) | 2012-01-05 → 2012-01-09 A (+4d) | 2012-07-10 → 2012-07-09 A (-1d) | 130d → 127d | 0% → 100% | 265d → none | 9-120M FS+60d → 9-120M |  |
| 1553032 | Fabricate magnet gap modification | 2011-10-03 → 2012-01-16 A (+105d) | 2012-02-03 → 2012-03-19 A (+45d) | 81d → 44d | 0% → 100% | 349d → none |  |  |
| 1553090 | Fabricate Collimator Support (BL Compnts) | 2012-03-26 → 2012-01-16 A (-70d) | 2012-05-18 → 2012-05-14 A (-4d) | 40d → 84d | 0% → 100% | 393d → none |  |  |
| 1553002 | Prepare Procurements Packages 2012 (BL Compnts) | 2012-02-01 A | 2012-07-10 → 2012-09-17 A (+69d) | 112d → 160d | 0% → 100% | 305d → none |  | resources MECH DES [480 h]; MECH ENG [240 h] → MECH ENG [240 h]; MECH DES [480 h] |
| 1553034 | Develop Pair Spec magnet support | 2012-03-05 → 2012-02-05 A (-29d) | 2012-05-03 → 2012-04-16 A (-17d) | 44d → 50d | 0% → 100% | 267d → none | 9-120M FS+100d → 9-120M |  |
| 1553036 | Build Pair Spectrometer Vacuum Box Labor (BL Compnts) Labor | 2012-02-28 → 2012-02-06 A (-22d) | 2012-05-18 → 2012-06-11 A (+24d) | 59d → 88d | 0% → 100% | 238d → none |  |  |
| 1553095 | Purchase Lead for Cave Exit Wall (BL Compnts) | 2012-05-07 → 2012-03-07 A (-61d) | 2012-08-03 → 2012-09-17 A (+45d) | 63d → 136d | 0% → 100% | 287d → none | 9-120M FS+145d → 9-120M |  |
| 1553038 | Build Pair Spectrometer Vacuum Box (BL Compnts) | 2012-04-09 → 2012-03-09 A (-31d) | 2012-07-02 → 2012-06-11 A (-21d) | 59d → 65d | 0% → 100% | 238d → none |  |  |
| 1553033 | Install magnet gap modification | 2012-05-04 → 2012-03-19 A (-46d) | 2012-08-06 → 2012-04-16 A (-112d) | 65d → 21d | 0% → 100% | 286d → none | 9-120M FS+144d, 1553032 → 1553032, 9-120M |  |
| 1553048 | Proc Pair convertor (BL Compnts) Labor Original | 2012-01-05 → 2012-04-02 A (+88d) | 2012-01-31 → 2013-02-11 A (+377d) | 18d → 190d | 0% → 100% | 270d → none | 9-120M FS+60d → 9-120M FS+125d |  |
| 1553035 | Proc Pair Spectrometer Mag Pwr Supply (BL Compnts) | 2012-04-03 → 2012-07-02 A (+90d) | 2013-01-31 → 2013-08-30 A (+211d) | 206d → 144d | 0% → 100% | 168d → none | 9-120M FS+121d → 9-120M FS+150d |  |
| 1553040 | Proc Pair Spectrometer Detctr's (BL Compnts) Part A | 2012-05-04 → 2012-07-02 A (+59d) | 2012-12-31 → 2013-05-13 A (+133d) | 162d → 117d | 0% → 100% | 128d → none | 9-120M FS+144d → 9-120M FS+163d |  |
| 1553034a | Procure Pair Spec magnet support | 2012-05-04 → 2012-09-03 A (+122d) | 2012-08-31 → 2013-01-14 A (+136d) |  | 0% → 100% | 267d → none | 1553034 → 1553034, 9-120M FS+200d |  |
| 1553013E | FY13 Travel (BL Compnts) | 2012-10-01 A | 2013-08-30 A | 228d → 248d | 0% → 100% | 20d → none |  |  |
| 1553105 | Purchase Slow Control Crate (BL Compnts) | 2012-06-06 → 2012-10-01 A (+117d) | 2012-09-05 → 2012-10-29 A (+54d) | 65d → 21d | 0% → 100% | 203d → none | 9-120M FS+165d → 9-120M FS+165d, 9-130M FS+55d |  |
| 1553015 | Proc Goniometer (BL Compnts) | 2012-11-26 → 2012-11-05 A (-21d) | 2013-05-28 → 2013-03-11 A (-78d) | 123d → 87d | 0% → 100% | 25d → none | 9-130M FS+38d → 9-130M FS+40d |  |
| 1553065 | Proc Active Collimator Compnts (BL Compnts) | 2012-01-05 → 2012-11-05 A (+305d) | 2012-07-10 → 2013-04-15 A (+279d) | 130d → 148d | 0% → 100% | 358d → none | 9-120M FS+60d → 9-120M FS+184d |  |
| 1553045 | Manufacture, Mount and Test Pair Spectrometer Detctr's (BL Compnts) | 2012-12-07 → 2013-02-04 A (+59d) | 2013-03-29 → 2013-08-30 A (+154d) |  | 0% → 100% | 128d → none | 1553040 FS-12d, 1553040a FS-12d, 1553038, 1553036 → 1553040 FS-75d, 1553038, 1553036, 1553040a FS-80d |  |
| 1553060 | Proc Roughing Pump (BL Compnts) | 2013-02-08 → 2013-03-04 A (+24d) | 2013-08-13 → 2013-06-17 A (-57d) |  | 0% → 100% | 33d → none | 9-130M FS+85d → 9-130M FS+105d |  |
| 1553040a | Proc Pair Spectrometer Detctr's (BL Compnts) Part B | 2012-05-04 → 2013-04-01 A (+332d) | 2012-12-31 → 2013-08-30 A (+242d) | 162d → 53d | 0% → 100% | 128d → none | 9-120M FS+144d → 9-130M FS+120d, 9-120M FS+163d |  |
| 1553017 | Procure vacuum guages and valves for tagger beamline | 2013-01-03 → 2013-06-01 A (+149d) | 2013-03-28 → 2013-08-30 A (+155d) |  | 0% → 100% | 129d → none |  | was named Procure vacuum gauges and valves for tagger beamline |
| 1553048a | Proc Pair convertor (BL Compnts) Labor Revised 2012 ETC | 2012-02-03 → 2013-06-01 A (+484d) | 2012-09-28 → 2013-08-26 A (+332d) | 167d → 102d | 0% → 100% | 270d → none | 1553048 FS+2d → 1553048 FS+25d |  |
| 1553020 | Write Control Software for Goniometer (BL Compnts) | 2013-05-29 → 2013-08-01 A (+64d) | 2013-08-23 → 2013-08-30 A (+7d) |  | 0% → 100% | 25d → none |  |  |
| 1553050 | Proc Pair convertor (BL Compnts) | 2013-04-08 → 2013-08-30 A (+144d) | 2013-06-28 → 2013-08-30 A (+63d) |  | 0% → 100% | 20d → none |  |  |
| 1553055 | Assemble and Test Pair convertor (BL Compnts) | 2013-07-12 → 2013-08-30 A (+49d) | 2013-08-30 A | 36d → 64d | 0% → 100% | 20d → none |  |  |
| 1553070 | Assemble Active Collimator (BL Compnts) FY12 | 2012-07-11 → 2013-08-30 A (+415d) | 2012-09-28 → 2013-08-30 A (+336d) |  | 0% → 100% | 358d → none |  |  |
| 1553070a | Assemble Active Collimator (BL Compnts) FY13 | 2012-10-01 → 2013-08-30 A (+333d) | 2013-01-22 → 2013-08-30 A (+220d) |  | 0% → 100% | 358d → none | 1553065, 1553090, 1553070 → 1553070 |  |
| 1553072 | Program & test Collimator Table (BL Components) FY12 | 2012-07-11 → 2013-08-30 A (+415d) | 2012-09-28 → 2013-08-30 A (+336d) |  | 0% → 100% | 378d → none | 1553080 → 9-130M FS+125d, 1553080 | resources VISTNG USERS [111.93 h]; MECH DES [68.4 h]; CONTRB UNIV LBR [37.31 h]; MECH ENG [24.87 h] → VISTNG USERS [111.93 h]; MECH DES [68.4 h]; MECH ENG [24.87 h]; CONTRB UNIV LBR [37.31 h] |
| 1553072a | Program & test Collimator Table (BL Components) FY13 | 2012-10-01 → 2013-08-30 A (+333d) | 2012-12-14 → 2013-08-30 A (+259d) |  | 0% → 100% | 378d → none |  |  |
| 1553075 | Test Active Collimator (BL Compnts) | 2013-01-23 → 2013-08-30 A (+219d) | 2013-04-24 → 2013-08-30 A (+128d) |  | 0% → 100% | 358d → none | 1553070, 1553070a, 1553072a → 1553072a, 1553070a |  |
| 1553110 | Re-Baseline Actuals Adjustment | 2013-08-30 A | 2013-08-30 A |  | 0% → 100% | 20d → none | 9-130M FS+227d → none |  |
| 2553011 | Diamond contractor and procurements support (BL Compnts) FY13 | 2013-09-03 A | 2013-09-30 A | 20d → 267d | 0% → 100% | 0d → none |  |  |
| 2553017 | Procure vacuum gauges and valves for tagger beamline | 2013-09-03 A | 2013-10-22 → 2013-11-22 (+31d) |  | 0% → 20% | 208d → 185d |  |  |
| 2553035 | Proc Pair Spectrometer Mag Pwr Supply (BL Compnts) | 2013-09-03 A | 2013-09-30 → 2013-09-23 A (-7d) |  | 0% → 100% | 36d → none |  |  |
| 2553036 | Proc Parts for Pair Spectrometer | 2013-09-03 A | 2013-09-30 → 2013-09-23 A (-7d) |  | 0% → 100% | 155d → none |  |  |
| 2553041 | Build PS low granularity Support Frame | 2013-09-03 A | 2013-10-01 → 2013-09-23 A (-8d) |  | 0% → 100% | 155d → none |  |  |
| 2553042 | Fabricate PS High Granularity Counters | 2013-09-03 A | 2013-09-30 → 2013-12-02 (+63d) |  | 0% → 60% | 213d → 170d |  |  |
| 2553050 | Proc Pair convertor insertion device (BL Compnts) (Previously Obligated) | 2013-09-03 A | 2013-11-12 → 2013-09-23 A (-50d) |  | 0% → 100% | 108d → none |  |  |
| 2553062 | UConn Contract - Procure Readout Electronics for Active Collimator | 2013-09-03 A | 2013-10-28 → 2013-12-02 (+35d) |  |  | 150d → 142d |  | resources PROCUREMENT<$50K 60 NO ESCALATION; PROCUREMENT>$50K 69 NO ESCALATION → PROCUREMENT>$50K 69 NO ESCALATION |
| 2553063 | UConn Contract - Assembly and Test of Active Collimator | 2013-09-03 A |  |  |  | 150d → 193d |  |  |
| 2553064 | UConn Contract - Delivery of Active Collimator to JLab | 2013-09-03 A |  |  |  |  |  |  |
| 2553110 | Manufacturing Drawings for Goniometer vacuum chamber | 2013-09-03 A | 2013-09-30 → 2013-09-23 A (-7d) |  | 0% → 100% | 95d → none |  |  |
| 2553140 | Manufacturing Drawings of Amorphous target insertion device (E-beam) FY13 | 2013-09-03 A | 2013-09-30 → 2013-10-21 A (+21d) | 20d → 53d | 0% → 100% | 117d → none |  |  |
| 2553140a | Manufacturing Drawings of Amorphous target insertion device (E-beam) FY14 | 2013-10-01 → 2013-09-03 A (-28d) | 2013-11-14 → 2013-10-21 A (-24d) |  | 0% → 100% | 117d → none | 2553140, 9-130M FS+228d → 2553140 FS-40d |  |
| 2553145 | Fab Amorphous insertion device (e-beam) (Previously Obligated) | 2013-09-03 A | 2013-12-11 → 2013-09-23 A (-79d) |  | 0% → 100% | 117d → none |  |  |
| 2553147 | Fab Amorphous insertion device (e-beam) | 2013-09-03 A |  |  | 0% → 40% |  |  |  |

| ID | Task | Start | Finish | Duration | Complete | Total float | Predecessors | Other |
| --- | --- | --- | --- | --- | --- | --- | --- | --- |
| 2553170 | Procure goniometer vacuum pump/instrumentation | 2013-09-03 A |  |  |  |  |  |  |
| 2553175 | Fab Tagger beamline components | 2013-09-03 A | 2013-09-30 → 2013-09-23 A (-7d) |  | 0% → 100% | 263d → none |  |  |
| 2553055 | Assemble and Test Pair convertor (BL Compnts) | 2013-11-26 → 2013-09-09 A (-78d) | 2014-03-18 → 2014-01-21 (-56d) |  | 0% → 23% | 108d → 148d | 2553052 FS+9d, 2553050 FS+9d → 2553050, 2553052 FS-60d |  |
| 2553011a | Diamond contractor and procurements support (BL Compnts) FY14 | 2013-10-01 A |  |  | 0% → 9% |  | 2553011, 9-130M FS+228d → 2553011 |  |
| 2553052 | Proc Pair convertor insertion device Mods (BL Compnts) | 2013-09-03 → 2013-10-01 A (+28d) | 2013-11-12 → 2013-10-21 A (-22d) |  | 0% → 100% | 108d → none |  | was named Proc Pair convertor insertion device (BL Compnts) |
| 2553130 | Manufacturing Drawings of cooling system for PS detector | 2013-10-04 → 2013-10-01 A (-3d) |  |  | 0% → 19% |  |  |  |
| 2553020 | Write Control Software for Goniometer (BL Compnts) | 2013-12-02 → 2013-10-02 A (-61d) | 2014-06-06 → 2014-05-09 (-28d) |  | 0% → 75% | 27d → 46d | 9-140M FS+42d → 9-140M |  |
| 2553016 | Build Vacuum Housing for Goniometer (BL Compnts) | 2013-11-04 → 2013-10-07 A (-28d) | 2014-02-06 → 2014-02-05 (-1d) |  |  | 71d → 72d | 9-140M FS+24d, 2553110 → 9-140M, 2553110 |  |
| 2553044 | Build PS High granularity Support Frame | 2013-10-03 → 2013-11-01 (+29d) | 2013-12-20 → 2014-01-31 (+42d) |  |  | 155d → 134d |  |  |
| 2553057 | Scientific support for Pair spectrometer characterization(BL Compnts) FY13 | 2013-09-30 → 2013-11-01 (+32d) | 2013-09-30 → 2013-11-01 (+32d) |  |  | 191d → 167d |  | was named Sientific support for Pair spectrometer characterization(BL Compnts) FY13 |
| 2553072a | Program & test Collimator Table (BL Components) FY13 | 2013-09-03 → 2013-11-01 (+59d) | 2013-09-30 → 2013-12-02 (+63d) |  |  | 156d → 113d |  |  |
| 2553095 | Design Install Feedback System for Active Collimator (Accelerator Grp) FY13 | 2013-09-03 → 2013-11-01 (+59d) | 2013-09-30 → 2013-12-02 (+63d) |  |  | 44d → 1d |  |  |
| 2553057a | Scientific support for Pair spectrometer characterization(BL Compnts) FY14 | 2013-10-01 → 2013-11-04 (+34d) | 2014-05-19 → 2014-06-23 (+35d) |  |  | 191d → 167d | 2553050 FS-32d, 2553052 FS-32d, 2553057 → 2553057 | was named Sientific support for Pair spectrometer characterization(BL Compnts) FY14 |
| 2553072b | Program & test Collimator Table (BL Components) FY14 | 2013-10-01 → 2013-12-03 (+63d) | 2013-12-12 → 2014-02-24 (+74d) |  |  | 156d → 113d | 9-130M FS+228d, 2553072a → 2553072a |  |
| 2553080 | Proc Active Collimator Control Equipment (HallD) | 2013-09-03 → 2013-12-03 (+91d) |  | 205d → 142d |  |  | 9-130M FS+228d → 9-140M FS+43d, 9-130M FS+228d |  |
| 2553090 | Proc Hardware for Active Collimator Control (Accelerator Grp) | 2013-09-03 → 2013-12-03 (+91d) |  | 183d → 120d |  |  | 9-130M FS+228d → 9-140M FS+43d, 9-130M FS+228d |  |
| 2553095a | Design Install Feedback System for Active Collimator (Accelerator Grp) FY14 | 2013-10-01 → 2013-12-03 (+63d) | 2014-06-02 → 2014-08-01 (+60d) |  |  | 44d → 1d | 9-130M FS+228d, 2553095, 2553064 FS-187d → 2553095 |  |
| 2553005 | Proc Raw Radiator Diamond Crystals (BL Compnts) | 2013-10-01 → 2013-12-05 (+65d) |  | 219d → 174d |  |  | 9-140M → 9-140M FS+45d |  |
| 2553085 | Support Control Active Collimator (HallD) FY13 | 2013-09-03 → 2014-01-03 (+122d) | 2013-09-30 → 2014-01-31 (+123d) |  |  |  | 9-130M FS+228d → 9-130M FS+228d, 9-140M FS+60d |  |
| 2553125 | Install mounting frame for low granularity PS detectors | 2013-10-21 → 2014-01-03 (+74d) | 2013-12-20 → 2014-03-05 (+75d) |  |  | 155d → 111d | 2553041 FS+13d → 2553041 FS+13d, 9-140M FS+60d |  |
| 2553085a | Support Control Active Collimator (HallD) FY14 | 2013-10-01 → 2014-02-03 (+125d) |  | 187d → 109d |  |  | 9-130M FS+228d, 2553085 → 2553085 |  |
| 2553200 | Manufacturing Drawings of Total Absorption Counter | 2014-02-05 → 2014-02-03 (-2d) | 2014-03-10 → 2014-03-06 (-4d) |  |  | 35d → 37d |  |  |
| 2553205 | Fabricate Total Absorption Counter Support | 2014-04-02 → 2014-03-31 (-2d) | 2014-07-01 → 2014-06-27 (-4d) |  |  | 35d → 37d |  |  |
| 2553210 | Install Total Absorption Counter | 2014-07-02 → 2014-06-30 (-2d) | 2014-08-11 → 2014-08-07 (-4d) |  |  | 35d → 37d |  |  |
| 2553075 | Test Active Collimator (BL Compnts) | 2014-07-08 → 2014-08-04 (+27d) | 2014-09-02 → 2014-09-29 (+27d) |  |  | 20d → 1d |  |  |
| 1 | **1.5.6.1 ASSEMBLY** | 2010-02-11 → 2010-04-26 (+74d) |  |  |  |  |  |  |
| 1561065 | Receive Modules 1-4 (Assy) | 2010-02-11 → 2010-04-26 A (+74d) | 2010-02-18 → 2010-05-24 A (+95d) | 5d → 21d | 0% → 100% | 646d → none |  | resources PROCUREMENT<$50K 60; MECH ENG [5.33 h]; PLABOR; MECH TECH [26.67 h] → MECH TECH [26.67 h]; PROCUREMENT<$50K 60; MECH ENG [5.33 h]; PLABOR |
| 1561070 | Receive Modules 5-8 (Assy) | 2010-04-28 → 2010-07-05 A (+68d) | 2010-05-04 → 2010-07-12 A (+69d) |  | 0% → 100% | 593d → none |  | resources PROCUREMENT<$50K 60; MECH ENG [5.33 h]; MECH TECH [26.67 h]; PLABOR → PLABOR; MECH TECH [26.67 h]; PROCUREMENT<$50K 60; MECH ENG [5.33 h] |
| 1561075 | Receive Modules 9-12 (Assy) | 2010-07-13 → 2010-08-13 A (+31d) | 2010-07-19 → 2010-08-17 A (+29d) | 5d → 3d | 0% → 100% | 541d → none |  |  |
| 1561080 | Receive Modules 13-16 (Assy) FY10 | 2010-09-27 → 2010-09-01 A (-26d) | 2010-09-30 → 2010-09-20 A (-10d) | 4d → 13d | 0% → 100% | 488d → none |  |  |
| 1561080a | Receive Modules 13-16 (Assy) FY11 | 2010-10-01 → 2010-09-01 A (-30d) | 2010-10-01 → 2010-09-20 A (-11d) | 1d → 13d | 0% → 100% | 488d → none |  |  |
| 1561080b | Receive Modules 13-16 (Assy) Procurement | 2010-09-27 → 2010-09-01 A (-26d) | 2010-10-01 → 2010-09-20 A (-11d) | 5d → 13d | 0% → 100% | 488d → none |  |  |
| 1561085 | Receive Modules 17-20 (Assy) | 2010-12-30 → 2010-11-15 A (-45d) | 2011-01-06 → 2010-11-29 A (-38d) | 5d → 9d | 0% → 100% | 427d → none |  | resources MECH TECH [26.67 h]; MECH ENG [5.33 h]; PLABOR; PROCUREMENT<$50K 60 → MECH ENG [5.33 h]; PLABOR; PROCUREMENT<$50K 60; MECH TECH [26.67 h] |
| 1561090 | Receive Modules 21-24 (Assy) | 2011-02-24 → 2011-01-17 A (-38d) | 2011-03-02 → 2011-02-18 A (-12d) | 5d → 24d | 0% → 100% | 390d → none |  | resources PLABOR; PROCUREMENT<$50K 60; MECH ENG [5.33 h]; MECH TECH [26.67 h] → MECH ENG [5.33 h]; MECH TECH [26.67 h]; PLABOR; PROCUREMENT<$50K 60 |
| 1561095 | Receive Modules 25-28 (Assy) | 2011-05-11 → 2011-04-10 A (-31d) | 2011-05-17 → 2011-04-29 A (-18d) | 5d → 15d | 0% → 100% | 336d → none |  | resources PLABOR; PROCUREMENT<$50K 60; MECH ENG [5.33 h]; MECH TECH [26.67 h] → MECH ENG [5.33 h]; MECH TECH [26.67 h]; PLABOR; PROCUREMENT<$50K 60 |
| 1561100 | Receive Modules 29-32 (Assy) | 2011-07-26 → 2011-05-01 A (-86d) | 2011-08-01 → 2011-05-16 A (-77d) | 5d → 11d | 0% → 100% | 284d → none |  | resources MECH TECH [26.67 h]; PLABOR; PROCUREMENT<$50K 60; MECH ENG [5.33 h] → PROCUREMENT<$50K 60; MECH ENG [5.33 h]; MECH TECH [26.67 h]; PLABOR |
| 1561101 | Receive Modules 33-36 (Assy) | 2011-10-10 → 2011-06-01 A (-131d) | 2011-10-14 → 2011-06-30 A (-106d) | 5d → 22d | 0% → 100% | 231d → none |  |  |
| 1561102 | Receive Modules 37-40 (Assy) | 2011-12-29 → 2011-08-01 A (-150d) | 2012-01-05 → 2011-08-31 A (-127d) | 5d → 23d | 0% → 100% | 180d → none |  | resources MECH TECH [26.67 h]; PLABOR; PROCUREMENT<$50K 60; MECH ENG [5.33 h] → MECH ENG [5.33 h]; MECH TECH [26.67 h]; PLABOR; PROCUREMENT<$50K 60 |
| 1561103 | Receive Modules 41-44 (Assy) | 2012-03-08 → 2011-10-01 A (-159d) | 2012-03-14 → 2011-10-07 A (-159d) |  | 0% → 100% | 133d → none |  | resources MECH ENG [5.33 h]; MECH TECH [26.67 h]; PLABOR; PROCUREMENT<$50K 60 → MECH TECH [26.67 h]; PLABOR; PROCUREMENT<$50K 60; MECH ENG [5.33 h] |
| 1561104 | Receive Modules 45-48 (Assy) | 2012-05-23 → 2011-12-12 A (-163d) | 2012-05-30 → 2011-12-19 A (-163d) | 5d → 6d | 0% → 100% | 79d → none |  | resources PLABOR; PROCUREMENT<$50K 60; MECH ENG [5.33 h]; MECH TECH [26.67 h] → MECH ENG [5.33 h]; MECH TECH [26.67 h]; PROCUREMENT<$50K 60; PLABOR |
| 1561105 | BCAL lightguide gluing, preparation for installation (Assy) FY12 | 2012-08-21 → 2013-01-07 A (+139d) | 2012-09-28 → 2013-07-15 A (+290d) | 28d → 62d | 0% → 100% | 22d → none |  | resources MECH TECH [478.97 h]; MECH DES [29.47 h]; MECH ENG [29.47 h] → MECH DES [29.47 h]; MECH ENG [29.47 h]; MECH TECH [478.97 h] |
| 1561105a | BCAL lightguide gluing, preparation for installation (Assy) FY13 | 2012-10-01 → 2013-01-07 A (+98d) | 2012-11-30 → 2013-07-15 A (+227d) | 43d → 62d | 0% → 100% | 22d → none | 1561105 → 1561105 FS-62d |  |
| 1561155 | Assemble BCal readout wedges(Assy) FY12 | 2012-08-03 → 2013-02-01 A (+182d) | 2012-09-28 → 2013-06-17 A (+262d) |  | 0% → 100% | 20d → none | 1562242, 1562240b, 15221156n FS-40d, 1561105a FS-85d, 1562240a → 1562242, 1562240b, 15221156n FS-40d, 1562240a |  |
| 1561155a | Assemble BCal readout wedges(Assy) FY13 | 2012-10-01 → 2013-02-01 A (+123d) | 2013-01-30 → 2013-06-17 A (+138d) |  | 0% → 100% | 20d → none | 1561105a FS-85d, 1562240a, 1561155, 1562242, 15221156n FS-40d, 1562240b → 1561155 FS-100d, 1561105a FS-85d |  |
| 1561155b | Assemble BCal readout wedges(Assy) Procurement | 2012-08-03 → 2013-02-01 A (+182d) | 2013-01-30 → 2013-06-17 A (+138d) |  | 0% → 100% | 130d → none | 1562242, 1562240a, 1562240b, 15221156n FS-40d, 1561105a FS-85d → 1562242, 1562240b, 1562240a, 1561105a FS-85d, 15221156n FS-40d, 9-130M |  |
| 1561040M | Delivery Complete for CDC (Assy) | 2013-04-05 → 2013-08-30 A (+147d) | 2013-04-05 → 2013-08-30 A (+147d) |  | 0% → 100% | 54d → none |  |  |
| 1561050M | Complete FDC (Assy) | 2013-03-22 → 2013-08-30 A (+161d) | 2013-03-22 → 2013-08-30 A (+161d) |  | 0% → 100% | 32d → none |  |  |
| 1561110 | Receive CDC (Assy) | 2013-04-05 → 2013-08-30 A (+147d) | 2013-04-18 → 2013-08-30 A (+134d) |  | 0% → 100% | 54d → none |  | resources PROCUREMENT<$50K 60; ELEC TECH [400 h]; ELEC ENG [200 h] → PROCUREMENT<$50K 60; ELEC ENG [200 h]; ELEC TECH [400 h] |
| 1561115 | Mounting CDC (Assy) | 2013-04-19 → 2013-08-30 A (+133d) | 2013-05-16 → 2013-08-30 A (+106d) |  | 0% → 100% | 54d → none |  |  |
| 1561120 | Alignment CDC (Assy) | 2013-05-17 → 2013-08-30 A (+105d) | 2013-06-14 → 2013-08-30 A (+77d) |  | 0% → 100% | 54d → none |  |  |
| 1561125 | Operational Checks CDC (outside Solenoid) (Assy) | 2013-06-17 → 2013-08-30 A (+74d) | 2013-07-15 → 2013-08-30 A (+46d) |  | 0% → 100% | 54d → none |  |  |
| 1561140 | Receive FDC (Assy) | 2013-04-09 → 2013-08-30 A (+143d) | 2013-04-22 → 2013-08-30 A (+130d) | 10d → 4d | 0% → 100% | 20d → none | 15211191 FS-25d, 15211220, 15211012E, 1561050M, 15211185 → 15211185, 15211191 FS-200d, 15211012E, 15211220 FS-55d, 1561050M | resources MECH TECH [320 h]; MECH ENG [80 h] → MECH ENG [80 h]; MECH TECH [320 h] |
| 1561145 | Rail Mounting for FDC (Assy) | 2013-04-23 → 2013-08-30 A (+129d) | 2013-05-06 → 2013-08-30 A (+116d) |  | 0% → 100% | 20d → none |  | resources PROCUREMENT<$50K 60; MECH ENG [283.2 h]; ELEC TECH [144 h] → MECH ENG [283.2 h]; ELEC TECH [144 h]; PROCUREMENT<$50K 60 |
| 1561170 | Re-Baseline Actuals Adjustment | 2013-08-30 A | 2013-08-30 A |  | 0% → 100% | 20d → none | 9-130M FS+227d → none |  |
| 2561145 | Rail Mounting for FDC (Assy) FY13 | 2013-09-05 → 2013-09-03 A (-2d) | 2013-09-30 → 2013-10-21 A (+21d) | 18d → 32d | 0% → 100% | 0d → none |  |  |
| 2561145a | Rail Mounting for FDC (Assy) FY14 | 2013-10-01 → 2013-09-03 A (-28d) | 2013-10-18 → 2013-10-21 A (+3d) |  | 0% → 100% | 0d → none | 2561145, 2562225 FS-18d → 2561145 FS-20d |  |
| 2561050M | Complete FDC (Assy) | 2013-10-01 → 2013-09-30 A (-1d) | 2013-10-01 → 2013-09-30 A (-1d) |  | 0% → 100% | 1d → none |  |  |
| 2561110 | Receive CDC for Storage (Assy) | 2013-10-24 → 2013-10-01 A (-23d) | 2013-11-27 → 2013-10-21 A (-37d) |  | 0% → 100% | 63d → none |  | resources MECH TECH [80 h]; SCIENTIST [40 h]; MECH ENG [40 h]; ELEC TECH [40 h]; PROCUREMENT<$50K 60 → MECH TECH [80 h]; MECH ENG [40 h]; ELEC TECH [40 h]; PROCUREMENT<$50K 60; SCIENTIST [40 h] |
| 2561140 | Receive FDC (Assy) | 2013-10-02 → 2013-10-01 A (-1d) | 2013-10-08 → 2013-10-07 A (-1d) |  | 0% → 100% | 0d → none | 25211172 FS-9d, 2561050M, 25211220 FS-55d, 25211172a FS-9d → 25211172 FS-40d, 25211220 FS-55d, 2561050M, 25211172a FS-40d |  |
| 2561060M | Delivery Complete for TOF (Assy) | 2013-12-02 → 2013-12-03 (+1d) | 2013-12-02 → 2013-12-03 (+1d) |  |  | 69d → 68d |  |  |
| 2561160 | Receive TOF Detector Units (Assy) | 2013-12-02 → 2013-12-03 (+1d) | 2013-12-13 → 2013-12-16 (+3d) |  |  | 69d → 68d |  |  |
| 1562001LOE | FY09 Work Cordinator (Installtn) | 2009-06-01 A | 2009-09-30 A |  | 0% → 100% | 20d → none |  |  |
| 1562002LOE | FY10 Work Cordinator (Installtn) | 2009-10-01 A | 2010-09-30 A |  | 0% → 100% | 20d → none |  |  |
| 1562010E | FY10 Travel (Installtn) | 2009-10-01 A | 2010-09-30 A |  | 0% → 100% | 20d → none |  |  |
| 1562003LOE | FY11 Work Cordinator (Installtn) | 2010-10-01 A | 2011-09-30 A |  | 0% → 100% | 20d → none |  |  |
| 1562011E | FY11 Travel (Installtn) | 2010-10-01 A | 2011-09-30 A |  | 0% → 100% | 20d → none |  |  |
| 1562149 | Installation Safety & Planning Platform #5 (Installtn) | 2010-05-17 → 2010-12-01 A (+198d) | 2010-07-27 → 2010-12-16 A (+142d) | 50d → 12d | 0% → 100% | 340d → none |  |  |
| 1562099d | Prepare procurement packages for col cave vacuum | 2011-01-05 A | 2011-04-01 → 2011-03-25 A (-7d) | 61d → 56d | 0% → 100% | 433d → none |  |  |
| 1562237 | Prepare procurement packages for upstream platform | 2011-01-05 A | 2011-02-28 → 2011-05-27 A (+88d) | 37d → 101d | 0% → 100% | 236d → none |  | resources MECH ENG [120 h]; MECH DES [320 h] → MECH DES [320 h]; MECH ENG [120 h] |
| 1562595 | Installation work space infrastructure (TW's Doublewide) Part A | 2011-02-04 → 2011-01-24 A (-11d) | 2011-09-30 → 2012-12-31 A (+458d) | 167d → 482d | 0% → 100% | 743d → none |  |  |

| ID | Task | Start | Finish | Duration | Complete | Total float | Predecessors | Other |
| --- | --- | --- | --- | --- | --- | --- | --- | --- |
| 1562600 | Installation Equipment infrastructure | 2011-02-04 → 2011-01-24 A (-11d) | 2011-09-30 A | 167d → 176d | 0% → 100% | 743d → none |  |  |
| 1562101 | Procure hdwre for collimator cave utilities | 2011-01-05 → 2011-02-01 A (+27d) | 2011-06-01 → 2011-08-31 A (+91d) | 103d → 149d | 0% → 100% | 558d → none |  |  |
| 1562102 | Install collimator cave utilities(Installtn) | 2011-01-20 → 2011-03-01 A (+40d) | 2011-05-20 → 2012-03-19 A (+304d) | 86d → 262d | 0% → 100% | 556d → none |  | resources MECH DES [320 h]; MECH ENG [240 h]; MECH TECH [760 h] → MECH TECH [760 h]; MECH DES [320 h]; MECH ENG [240 h] |
| 1562105 | Fab Collimator Cave Stands (Installtn) | 2011-01-05 → 2011-03-01 A (+55d) | 2011-06-01 → 2011-04-29 A (-33d) | 103d → 44d | 0% → 100% | 549d → none |  |  |
| 1562132 | Install Collimator cave stands (Installtn) | 2011-03-03 → 2011-04-01 A (+29d) | 2011-06-30 → 2011-05-23 A (-38d) | 85d → 37d | 0% → 100% | 549d → none |  | resources MECH DES [240 h]; MECH ENG [40 h]; MECH TECH [280 h] → MECH TECH [280 h]; MECH DES [240 h]; MECH ENG [40 h] |
| 1562100 | Fab Collimator Cave Vac (Installtn) | 2011-02-18 → 2011-05-01 A (+72d) | 2011-07-15 → 2012-10-22 A (+465d) | 103d → 370d | 0% → 100% | 433d → none |  |  |
| 1562394 | Prepare procurement packages for downstream platform | 2012-01-05 → 2011-05-09 A (-241d) | 2012-02-29 → 2012-03-19 A (+19d) | 38d → 213d | 0% → 100% | 570d → none | 9-120M FS+60d → 9-120M FS-150d |  |
| 1562240 | Fab Upstream Platform CDC #1 (Installtn) Expenses FY11 | 2011-05-31 → 2011-08-01 A (+62d) | 2011-09-30 → 2011-12-19 A (+80d) | 87d → 98d | 0% → 100% | 172d → none | 2-10M, 1562237, 1562425 FS-150d → 1562425 FS-160d, 1562237, 2-10M |  |
| 1562240a | Fab Upstream Platform CDC #1 (Installtn) Expenses FY12 | 2011-10-03 → 2011-08-01 A (-63d) | 2011-11-18 → 2011-12-19 A (+31d) | 35d → 98d | 0% → 100% | 172d → none | 1562240 → 1562240 FS-40d |  |
| 1562240b | Fab Upstream Platform CDC #1 (Installtn) Procurement | 2011-05-31 → 2011-08-01 A (+62d) | 2011-11-18 → 2011-12-19 A (+31d) | 122d → 98d | 0% → 100% | 172d → none | 2-10M, 1562425 FS-150d, 1562237 → 1562425 FS-160d, 1562237, 2-10M |  |
| 1562423 | Prepare solenoid and temporary platform Procurements/Fabrication Packages (Installtn) | 2011-05-02 → 2011-08-01 A (+91d) | 2011-09-30 → 2012-05-21 A (+234d) | 107d → 200d | 0% → 100% | 172d → none |  |  |
| 1562004LOE | FY12 Work Cordinator (Installtn) | 2011-10-03 A | 2012-09-28 A |  | 0% → 100% | 20d → none |  |  |
| 1562012E | FY12 Travel (Installtn) | 2011-10-03 A | 2012-09-28 A |  | 0% → 100% | 20d → none |  |  |
| 1562100b | Install col cave vacuum FY11 | 2011-07-18 → 2011-10-10 A (+84d) | 2011-09-30 → 2012-01-24 A (+116d) | 54d → 68d | 0% → 100% | 433d → none | 1562100, 1562099d → 1562099d, 1562100 FS-30d | resources MECH DES [25.41 h]; MECH TECH [304.94 h]; MECH ENG [25.41 h] → MECH ENG [25.41 h]; MECH DES [25.41 h]; MECH TECH [304.94 h] |
| 1562100ba | Install col cave vacuum FY12 | 2011-10-03 → 2011-10-10 A (+7d) | 2011-11-14 → 2012-01-27 A (+74d) | 31d → 71d | 0% → 100% | 433d → none | 1562100b → 1562100b FS-90d |  |
| 1562242 | Oversee installation for upstream platform | 2011-11-21 → 2011-11-07 A (-14d) | 2011-12-20 → 2011-12-19 A (-1d) | 20d → 29d | 0% → 100% | 172d → none | 1562240a, 1562240b → 1562240a FS-20d, 1562240b FS-20d |  |
| 1562130 | Install Collimator Mag Sweep # 1 (Installtn) | 2011-11-15 → 2011-11-14 A (-1d) | 2011-12-15 → 2011-11-28 A (-17d) | 21d → 9d | 0% → 100% | 433d → none | 1562100, 1562102, 1553100, 1562105, 1562100ba → 1562100ba, 1562100 FS-30d, 1562105, 1553100, 1562102 | resources MECH ENG [40 h]; PROCUREMENT<$50K 60; MECH TECH [240 h] → MECH TECH [240 h]; MECH ENG [40 h]; PROCUREMENT<$50K 60 |
| 1562110 | Proc Collimator #2 and Obtain SEG Blocks (Installtn) | 2012-01-05 → 2011-12-05 A (-31d) | 2012-04-06 → 2012-03-16 A (-21d) | 65d → 67d | 0% → 100% | 360d → none |  | resources PROCUREMENT>$50K 69; MECH ENG [8 h]; MECH TECH [40 h] → MECH TECH [40 h]; PROCUREMENT>$50K 69; MECH ENG [8 h] |
| 1562055 | Install LCW Connections (Installtn) | 2012-08-22 → 2011-12-12 A (-254d) | 2012-09-19 → 2013-02-11 A (+145d) | 20d → 278d | 0% → 100% | 247d → none | 1562430 FS-47d, 1562050 FS-105d → 1562050 FS-210d, 1562430 FS-200d | resources MECH ENG [40 h]; PROCUREMENT<$50K 60; MECH TECH [200 h] → MECH TECH [200 h]; MECH ENG [40 h]; PROCUREMENT<$50K 60 |
| 1562605LOE | Electrical power engineer support 2012 | 2012-02-01 A | 2012-09-28 A |  | 0% → 100% | 20d → none |  |  |
| 1562655 | Cable mock up trials | 2012-02-03 → 2012-02-01 A (-2d) | 2012-06-26 → 2012-03-19 A (-99d) | 100d → 33d | 0% → 100% | 563d → none |  | resources MECH ENG [34 h]; MECH DES [34 h]; MECH TECH [136 h] → MECH TECH [136 h]; MECH ENG [34 h]; MECH DES [34 h] |
| 1562660 | Tagger Gantry design | 2012-02-03 → 2012-02-01 A (-2d) | 2012-05-04 → 2012-06-11 A (+38d) | 65d → 91d | 0% → 100% | 538d → none |  |  |
| 1562670 | Materials for installation Part A | 2012-02-03 → 2012-02-01 A (-2d) | 2012-09-28 A | 167d → 169d | 0% → 100% | 496d → none |  |  |
| 1562675 | Tagger LCW design | 2012-02-03 → 2012-02-01 A (-2d) | 2012-05-04 → 2012-06-11 A (+38d) | 65d → 91d | 0% → 100% | 350d → none |  |  |
| 1562680 | Fiducialize and survey equipment (2012) | 2012-02-03 → 2012-02-01 A (-2d) | 2012-09-28 A | 167d → 169d | 0% → 100% | 268d → none |  |  |
| 1562391 | Develop drift chamber gas system design | 2012-03-05 → 2012-03-01 A (-4d) | 2012-06-26 → 2013-07-15 A (+384d) | 80d → 212d | 0% → 100% | 213d → none |  |  |
| 1562135 | Install Collimator #2 (Installtn) | 2012-04-09 → 2012-03-12 A (-28d) | 2012-04-20 → 2012-05-14 A (+24d) | 10d → 46d | 0% → 100% | 360d → none | 1562132, 1562110, 1562130 → 1562110 FS-20d, 1562130, 1562132 | resources MECH TECH [160 h]; PROCUREMENT<$50K 60; MECH ENG [40 h] → MECH ENG [40 h]; MECH TECH [160 h]; PROCUREMENT<$50K 60 |
| 1562185 | Install Racks Counting Room (Installtn) | 2012-05-04 → 2012-03-12 A (-53d) | 2012-06-20 → 2012-08-06 A (+47d) | 32d → 104d | 0% → 100% | 75d → none | 16332030, 9-120M FS+144d → 9-120M, 16332030 |  |
| 1562425 | Evaluate Procurements 2011 (Installtn) | 2011-10-28 → 2012-03-12 A (+136d) | 2012-01-09 → 2012-05-14 A (+126d) | 44d → 46d | 0% → 100% | 172d → none | 1562423 FS+19d → 1562423 FS-20d |  |
| 1562325 | Fab SOLENOID Platform #2 (Installtn) Original | 2012-01-10 → 2012-04-02 A (+83d) | 2012-01-31 → 2012-04-16 A (+76d) | 15d → 11d | 0% → 100% | 456d → none | 9-120M FS+62d, 1562425 → 9-120M FS+62d, 1562425 FS-60d |  |
| 1562395 | Fab Downstream Platform #3 TOF, Fcal (Installtn) | 2012-03-01 → 2012-04-09 A (+39d) | 2012-03-28 → 2012-07-09 A (+103d) | 20d → 64d | 0% → 100% | 570d → none | 9-120M FS+93d, 1562394, 1562425 → 9-120M FS+93d, 1562425 FS-50d, 1562394 |  |
| 1562115 | install Collimator Concrete Shielding (Installtn) | 2012-06-05 → 2012-04-16 A (-50d) | 2012-08-03 → 2012-06-11 A (-53d) | 44d → 39d | 0% → 100% | 248d → none | 9-120M FS+164d → 9-120M | resources MECH DES [40 h]; MECH TECH [200 h]; PROCUREMENT>$50K 69; MECH ENG [40 h] → MECH TECH [200 h]; PROCUREMENT>$50K 69; MECH ENG [40 h]; MECH DES [40 h] |
| 1562359 | Install Temporary Platform #5 (Installtn) | 2012-06-15 → 2012-04-16 A (-60d) | 2012-07-16 → 2012-05-14 A (-63d) | 22d → 21d | 0% → 100% | 301d → none | 9-120M FS+172d → 9-120M |  |
| 1562125 | Install Primary Collimator (Installtn) | 2012-07-11 → 2012-05-14 A (-58d) | 2012-09-05 → 2012-06-11 A (-86d) | 40d → 19d | 0% → 100% | 265d → none | 1553080, 9-120M → 1553080 FS-50d, 9-120M | resources MECH ENG [40 h]; PROCUREMENT<$50K 60; MECH TECH [240 h] → PROCUREMENT<$50K 60; MECH TECH [240 h]; MECH ENG [40 h] |
| 1562325a | Fab SOLENOID Platform #2 (Installtn) Revised 2012 ETC Labor | 2012-03-29 → 2012-06-03 A (+66d) | 2012-07-20 → 2012-10-15 A (+87d) | 80d → 94d | 0% → 100% | 476d → none | 1562325 FS+40d → 9-120M FS+184d, 1562325 | resources MECH ENG [24.21 h]; MECH TECH [96.84 h] → MECH TECH [96.84 h]; MECH ENG [24.21 h] |
| 1562325b | Fab SOLENOID Platform #2 (Installtn) Revised 2012 ETC Procurement | 2012-04-26 → 2012-06-03 A (+38d) | 2012-08-17 → 2012-10-15 A (+59d) | 80d → 94d | 0% → 100% | 456d → none | 1562325 FS+60d → 1562325 FS+20d, 9-120M FS+184d |  |
| 1562430 | Engineering Support for Tagger Installation 2012 (Installtn) | 2012-06-19 A | 2012-09-28 A |  | 0% → 100% | 210d → none |  |  |
| 1562020M | Shipment of Bcal Modules (Installtn) | 2012-12-03 → 2012-07-02 A (-154d) | 2012-12-03 → 2012-07-02 A (-154d) |  | 0% → 100% | 166d → none |  |  |
| 1562190 | Install Pwr to Racks Counting Room (Installtn) | 2012-06-21 → 2012-07-02 A (+11d) | 2012-08-31 → 2012-08-13 A (-18d) | 52d → 31d | 0% → 100% | 75d → none | 1562185 → 1562185 FS-20d |  |
| 1562620 | Procure Electrical Power cable/conduit Part A | 2012-10-01 → 2012-07-02 A (-91d) | 2013-03-29 → 2012-10-15 A (-165d) | 120d → 75d | 0% → 100% | 351d → none | 9-130M → 9-130M FS-60d |  |
| 1562140 | Install Collimator Concrete Shielding (Installtn) Part A | 2013-08-30 → 2012-08-01 A (-394d) | 2013-08-30 → 2012-09-28 A (-336d) | 1d → 42d | 0% → 100% | 20d → none | 9-130M FS+227d → 1562125 | was named Install Collimator Concrete Shielding (Installtn) Part A (Future Activity Complete prior to Rebaseline); resources MECH TECH; MECH ENG; PROCUREMENT<$50K 60 → MECH TECH [80 h]; MECH ENG [40 h]; PROCUREMENT<$50K 60 |
| 1562260 | Install Fire Protection (Installtn) Part A | 2012-12-04 → 2012-08-01 A (-125d) | 2013-01-08 → 2012-09-28 A (-102d) | 20d → 42d | 0% → 100% | 306d → none | 1562245 FS-81d → 1562245 FS-145d | resources PROCUREMENT>$50K 69; PROCUREMENT<$50K 60 → PROCUREMENT<$50K 60; PROCUREMENT>$50K 69 |
| 1562195 | Install Cooling to Racks in Counting Room (Installtn) | 2012-09-04 → 2012-08-06 A (-29d) | 2012-11-02 → 2012-08-20 A (-74d) | 44d → 11d | 0% → 100% | 75d → none |  |  |
| 1562200 | Install Fire Protection to Racks in Counting Room (Installtn) | 2012-11-05 → 2012-08-06 A (-91d) | 2013-01-15 → 2012-08-20 A (-148d) | 44d → 11d | 0% → 100% | 139d → none |  |  |
| 1562640 | Procure cable trays and hardware | 2012-10-01 → 2012-09-03 A (-28d) | 2013-04-05 → 2013-08-30 A (+147d) | 125d → 144d | 0% → 100% | 268d → none | 9-130M → 9-130M, 9-120M FS+184d |  |
| 1562005LOE | FY13 Work Cordinator (Installtn) | 2012-10-01 A | 2013-08-30 A | 228d → 248d | 0% → 100% | 20d → none |  |  |
| 1562013E | FY13 Travel (Installtn) | 2012-10-01 A | 2013-08-30 A | 228d → 248d | 0% → 100% | 20d → none |  |  |
| 1562120 | Install Lead Shielding for Wall (Installtn) | 2012-08-06 → 2012-10-01 A (+56d) | 2012-09-28 → 2013-02-11 A (+136d) | 39d → 63d | 0% → 100% | 248d → none | 1562115, 9-120M FS+60d → 1562115, 9-120M FS+205d | resources MECH DES [120 h]; MECH TECH [320 h]; PROCUREMENT>$50K 69; MECH ENG [120 h] → MECH ENG [120 h]; MECH DES [120 h]; MECH TECH [320 h]; PROCUREMENT>$50K 69 |
| 1562140a | Install Collimator Concrete Shielding (Installtn) Part B | 2013-08-30 → 2012-10-01 A (-333d) | 2013-08-30 → 2012-10-30 A (-304d) | 1d → 22d | 0% → 100% | 20d → none | 9-130M FS+227d → 1562125 | was named Install Collimator Concrete Shielding (Installtn) Part B (Future Activity Complete prior to Rebaseline) |
| 1562610LOE | Electrical power engineer support 2013 | 2012-10-01 A | 2013-08-30 A | 228d → 248d | 0% → 100% | 20d → none |  |  |
| 1562665 | Tagger Gantry Fab | 2012-04-30 → 2012-10-01 A (+154d) | 2012-07-31 → 2013-01-21 A (+174d) | 65d → 88d | 0% → 100% | 538d → none | 1562660 FS-5d → 1562660 FS+60d, 9-130M FS-1d |  |
| 1562670a | Materials for installation Part B | 2012-02-03 → 2012-10-01 A (+241d) | 2012-09-28 → 2013-01-21 A (+115d) | 167d → 169d | 0% → 100% | 496d → none |  |  |
| 1562685 | Fiducialize and survey equipment (2013) | 2012-10-01 A | 2013-08-30 A | 228d → 248d | 0% → 100% | 268d → none |  |  |
| 1562435 | Engineering Support for Detector Installation 2013 (Installtn) | 2012-10-24 A | 2013-08-30 A | 211d → 231d | 0% → 100% | 210d → none | 1562430 FS+17d → 9-130M, 1562430 FS+17d |  |
| 1562440 | Engineering Support for Tagger Installation 2013 (Installtn) | 2012-10-30 A | 2013-08-30 A |  | 0% → 100% | 212d → none | 9-130M FS+21d → 9-130M |  |
| 1562413 | Install Fire Protection (Installtn) | 2013-08-30 → 2012-11-05 A (-298d) | 2013-08-30 → 2012-11-12 A (-291d) | 1d → 6d | 0% → 100% | 20d → none | 9-130M FS+227d → none | was named Install Fire Protection (Installtn) (Future Activity Complete prior to Rebaseline) |
| 1562145 | Install Collimator Lead Shielding Wall (Installtn) | 2013-08-30 → 2012-12-03 A (-270d) | 2013-08-30 → 2013-01-30 A (-212d) | 1d → 10d | 0% → 100% | 20d → none | 9-130M FS+227d → 1562140a, 1562120 FS-25d, 1562140, 1553095 | was named Install Collimator Lead Shielding Wall (Installtn) (Future Activity Complete prior to Rebaseline); resources MECH ENG; MECH TECH; PROCUREMENT<$50K 60 → MECH TECH [80 h]; PROCUREMENT<$50K 60; MECH ENG [40 h] |
| 1562392 | Procure final hardware for gas systems | 2013-01-03 → 2013-01-07 A (+4d) | 2013-07-05 → 2013-08-30 A (+56d) |  | 0% → 100% | 86d → none | 9-130M FS+60d, 1562391 → 9-130M, 1562391 FS-20d |  |
| 1562465 | Erect Dark Room for Fcal (Installtn) | 2013-04-22 → 2013-01-07 A (-105d) | 2013-06-24 → 2013-08-28 A (+65d) |  | 0% → 100% | 44d → none | 1562025M → 1562025M FS-225d |  |
| 1562595a | Installation work space infrastructure (TW's Doublewide) Part B | 2011-02-04 → 2013-01-07 A (+703d) | 2011-09-30 → 2013-08-30 A (+700d) | 167d → 324d | 0% → 100% | 743d → none |  |  |
| 1562070 | Install Cooling for Tagger Electrnc's (Installtn) | 2013-06-21 → 2013-02-01 A (-140d) | 2013-07-05 → 2013-02-11 A (-144d) |  | 0% → 100% | 40d → none |  |  |
| 1562075 | Install Fire Protection for Tagger Electrnc's (Installtn) | 2013-04-19 → 2013-02-01 A (-77d) | 2013-06-20 → 2013-02-11 A (-129d) |  | 0% → 100% | 40d → none |  |  |
| 1562247 | Racks - Install Hall Lower Level North (N1) | 2013-04-22 → 2013-02-01 A (-80d) | 2013-05-01 → 2013-03-11 A (-51d) |  | 0% → 100% | 274d → none | 1562246 → 1562246 FS-40d |  |
| 1562248 | Racks - Install Hall Lower Level South (S1) | 2013-05-02 → 2013-02-01 A (-90d) | 2013-05-15 → 2013-03-11 A (-65d) |  | 0% → 100% | 274d → none | 1562247 → 1562247 FS-40d |  |
| 1562260a | Install Fire Protection (Installtn) Part B | 2012-12-04 → 2013-02-01 A (+59d) | 2013-01-08 → 2013-02-11 A (+34d) |  | 0% → 100% | 306d → none | 1562245 FS-81d → 1562245 FS-50d |  |
| 1562420 | Install Supprt Electrnc's Platform #3 (Installtn) | 2013-08-30 → 2013-02-05 A (-206d) | 2013-08-30 → 2013-02-18 A (-193d) | 1d → 45d | 0% → 100% | 20d → none | 9-130M FS+227d → 1542055 FS-1d, 1542045, 1542013E | was named Install Supprt Electrnc's Platform #3 (Installtn) (Future Activity Complete prior to Rebaseline) |
| 1562345 | Install Fire Protection (Installtn) | 2013-08-30 → 2013-02-06 A (-205d) | 2013-08-30 → 2013-02-18 A (-193d) | 1d → 20d | 0% → 100% | 20d → none | 9-130M FS+227d → none | was named Install Fire Protection (Installtn) (Future Activity Complete prior to Rebaseline) |
| 1562010M | Tagger Magnets Fabbed (Installtn) | 2012-12-04 → 2013-02-11 A (+69d) | 2012-12-04 → 2013-02-11 A (+69d) |  | 0% → 100% | 141d → none |  |  |
| 1562050 | Install Tagger Pwr Supply (Installtn) | 2012-11-28 → 2013-03-01 A (+93d) | 2013-01-29 → 2013-08-30 A (+213d) |  | 0% → 100% | 247d → none | 1562430 FS-47d, 9-130M FS+40d → 9-130M FS+110d, 1562430 FS-47d | resources ELEC ENG [16 h]; ELEC TECH [480 h]; PROCUREMENT<$50K 60 → PROCUREMENT<$50K 60; ELEC ENG [16 h]; ELEC TECH [480 h] |
| 1562045 | Install Tagger Magnets & Chamber (Installtn) | 2013-06-04 → 2013-03-04 A (-92d) | 2013-08-06 → 2013-08-30 A (+24d) |  | 0% → 100% | 20d → none | 1562010M, 1562430 FS-73d, 9-130M FS+165d, 3C-10M → 3C-10M, 1562010M, 1562430 FS-73d |  |

| ID | Task | Start | Finish | Duration | Complete | Total float | Predecessors | Other |
| --- | --- | --- | --- | --- | --- | --- | --- | --- |
| 1562400 | Racks - Install Hall Upper Level Downstream (D2) | 2013-06-06 → 2013-03-04 A (-94d) | 2013-06-19 → 2013-04-15 A (-65d) |  | 0% → 100% | 274d → none | 1544075, 1562395, 1562330 FS+4d → 1562395, 1544075, 1562330 FS-90d |  |
| 1562650 | Procure power transformers | 2013-02-01 → 2013-03-04 A (+31d) | 2013-05-20 → 2013-05-13 A (-7d) |  | 0% → 100% | 340d → none | 9-130M FS+80d → 9-130M FS+110d |  |
| 1562096 | Install Permanent Magnet Stand (Installtn) | 2013-08-30 → 2013-05-01 A (-121d) | 2013-08-30 → 2013-05-13 A (-109d) | 1d → 5d | 0% → 100% | 20d → none | 9-130M FS+227d → none | was named Install Permanent Magnet Stand (Installtn) (Future Activity Complete prior to Rebaseline); resources MECH TECH → MECH TECH [40 h] |
| 1562620a | Procure Electrical Power cable/conduit Part B | 2012-10-01 → 2013-05-03 A (+214d) | 2013-03-29 → 2013-08-30 A (+154d) |  | 0% → 100% | 351d → none | 9-130M → 9-130M FS+110d |  |
| 1562060 | Survey & Align Magnets (Installtn) | 2013-08-07 → 2013-05-06 A (-93d) | 2013-08-20 → 2013-08-30 A (+10d) |  | 0% → 100% | 20d → none | 1562440 FS-210d, 1562045 → 1562440 FS-210d, 1562045 FS-100d |  |
| 1562097 | Install Permanent Magnet (Installtn) | 2013-08-30 → 2013-05-06 A (-116d) | 2013-08-30 → 2013-05-20 A (-102d) | 1d → 20d | 0% → 100% | 20d → none | 9-130M FS+227d → 1562096 | was named Install Permanent Magnet (Installtn) (Future Activity Complete prior to Rebaseline); resources MECH TECH → MECH TECH [160 h] |
| 1562645 | Install cable trays and hardware | 2013-04-17 → 2013-05-06 A (+19d) | 2013-08-30 A | 96d → 100d | 0% → 100% | 268d → none | 1562640 FS+7d → 1562640 FS-20d |  |
| 1562085 | Racks - Install Tagger | 2013-03-11 → 2013-06-01 A (+82d) | 2013-03-22 → 2013-08-30 A (+161d) |  | 0% → 100% | 40d → none | 3C-10M FS+230d, 9-130M FS+105d → 3C-10M FS+194d, 9-130M FS+105d |  |
| 1562245 | Racks - Install Hall Lower Level Upstream (U1) | 2013-03-25 → 2013-06-03 A (+70d) | 2013-04-05 → 2013-08-30 A (+147d) |  | 0% → 100% | 103d → none | 1544075, 1562085 → 1562085 FS-15d, 1544075 |  |
| 1562625 | Install Electrical Power cable/conduit | 2012-12-03 → 2013-06-03 A (+182d) | 2013-05-03 → 2013-08-30 A (+119d) |  | 0% → 100% | 351d → none | 1562620 FS-77d, 1562620a FS-77d → 1562620a FS-80d, 1562620 FS-77d |  |
| 1562180 | Install Photon BL Tag Hall (Installtn) | 2013-04-01 → 2013-07-01 A (+91d) | 2013-06-11 → 2013-08-30 A (+80d) |  | 0% → 100% | 325d → none | 1562098 → 1562098 FS-80d | resources PROCUREMENT<$50K 60; MECH TECH [120 h] → MECH TECH [120 h]; PROCUREMENT<$50K 60 |
| 1562330 | Racks - Install Hall Upper Level Upstream (U2) | 2013-05-16 → 2013-07-01 A (+46d) | 2013-05-30 → 2013-08-30 A (+92d) |  | 0% → 100% | 274d → none | 1544075, 1562325, 1562325a, 1562248, 1562325b → 1544075, 1562325, 1562325b, 1562248, 1562325a, 9-130M FS+165d |  |
| 1562405 | Install Pwr to Racks Platform #3 (Installtn) | 2013-06-20 → 2013-07-01 A (+11d) | 2013-08-22 → 2013-08-30 A (+8d) |  | 0% → 100% | 274d → none |  |  |
| 1562470 | Register Single Channel FCAL Detector to Readout (Installtn) | 2013-04-22 → 2013-07-01 A (+70d) | 2013-07-23 → 2013-08-30 A (+38d) |  | 0% → 100% | 24d → none |  | resources MECH ENG [56 h]; MECH TECH [160 h] → MECH TECH [160 h]; MECH ENG [56 h] |
| 1562475 | Cables - Install on Trays Detector to Racks FCAL | 2013-07-30 → 2013-07-01 A (-29d) | 2013-08-30 A | 24d → 65d | 0% → 100% | 20d → none | 1547200, 15222100a, 1562465, 1562470 → 1562465 FS-45d, 1547200, 1562470 FS-65d, 15222100a FS-60d |  |
| 1562250 | Install Pwr to Racks Platform #1 (Installtn) | 2013-04-08 → 2013-07-15 A (+98d) | 2013-05-03 → 2013-08-30 A (+119d) |  | 0% → 100% | 103d → none | 1562245 → 1562245 FS-15d |  |
| 1562061 | Field Map Tagging Magnet (Installtn) | 2013-08-21 → 2013-08-01 A (-20d) | 2013-08-30 A | 8d → 60d | 0% → 100% | 20d → none | 1562055, 15511095a, 1562060, 1562045, 1562440 FS-200d, 15511095b → 1562045, 15511095b, 1562060, 15511095a, 15511095, 1562055, 1562440 FS-200d |  |
| 1562225 | Mount Bcal Modules in Solenoid (Installtn) | 2013-07-09 → 2013-08-01 A (+23d) | 2013-08-30 A | 39d → 28d | 0% → 100% | 20d → none | 1561155, 15221155a, 1561155a FS+110d, 151173n, 15221155b, 15221180, 12361010, 15221156n, 1561155b, 1562020M, 15221180a, 1562435 FS-229d → 151173n, 12361010, 15221156n, 15221155b, 15221180, 1562435 FS-229d, 15221155a, 15221180a, 1561155a, 1562020M, 1561155b | resources MECH TECH [435 h]; MECH ENG [30 h]; MECH DES [30 h]; PROCUREMENT>$50K 69 → MECH DES [30 h]; PROCUREMENT>$50K 69; MECH TECH [435 h]; MECH ENG [30 h] |
| 1562335 | Install Pwr to Racks Platform #2 (Installtn) | 2013-05-31 → 2013-08-15 A (+76d) | 2013-08-02 → 2013-08-30 A (+28d) |  | 0% → 100% | 288d → none |  |  |
| 1562015M | Assy of CDC (Installtn) | 2013-07-16 → 2013-08-30 A (+45d) | 2013-07-16 → 2013-08-30 A (+45d) |  | 0% → 100% | 54d → none |  |  |
| 1562025M | Assy of Fcal (Installtn) | 2013-04-22 → 2013-08-30 A (+130d) | 2013-04-22 → 2013-08-30 A (+130d) |  | 0% → 100% | 44d → none |  |  |
| 1562065 | Install Pwr for Tagger Electrnc's (Installtn) | 2013-07-08 → 2013-08-30 A (+53d) | 2013-08-02 → 2013-08-30 A (+28d) |  | 0% → 100% | 40d → none |  |  |
| 1562090 | Install Tagger Electrnc's (Installtn) | 2013-03-25 → 2013-08-30 A (+158d) | 2013-04-05 → 2013-08-30 A (+147d) |  | 0% → 100% | 123d → none |  |  |
| 1562098 | Install Tagger Quad Stand & Magnet (Installtn) | 2013-03-01 → 2013-08-30 A (+182d) | 2013-03-29 → 2013-08-30 A (+154d) |  | 0% → 100% | 325d → none |  |  |
| 1562205 | Install Computers in Counting Room (Installtn) Part A | 2013-07-01 → 2013-08-30 A (+60d) | 2013-07-29 → 2013-08-30 A (+32d) |  | 0% → 100% | 24d → none |  | resources ELEC TECH [80 h]; SCIENTIST [80 h] → SCIENTIST [80 h]; ELEC TECH [80 h] |
| 1562210 | Install Supprt Electrnc's in Counting Room (Installtn) | 2013-07-30 → 2013-08-30 A (+31d) | 2013-08-26 → 2013-08-30 A (+4d) |  | 0% → 100% | 24d → none |  |  |
| 1562246 | Racks - Install Hall Lower Level Upstream South (US1) | 2013-04-08 → 2013-08-30 A (+144d) | 2013-04-19 → 2013-08-30 A (+133d) |  | 0% → 100% | 274d → none |  |  |
| 1562255 | Install Cooling to Racks Platform #1 (Installtn) | 2013-04-08 → 2013-08-30 A (+144d) | 2013-05-03 → 2013-08-30 A (+119d) |  | 0% → 100% | 103d → none |  |  |
| 1562270 | Install Supprt Electrnc's, Platform #1 (Installtn) | 2013-05-06 → 2013-08-30 A (+116d) | 2013-07-09 → 2013-08-30 A (+52d) |  | 0% → 100% | 306d → none |  |  |
| 1562275 | Cables - Install on Trays Detector to Racks BCAL | 2013-08-19 → 2013-08-30 A (+11d) | 2013-08-30 A | 10d → 65d | 0% → 100% | 20d → none |  |  |
| 1562360 | Install FDC on Platform (Installtn) | 2013-05-07 → 2013-08-30 A (+115d) | 2013-05-20 → 2013-08-30 A (+102d) | 10d → 6d | 0% → 100% | 20d → none | 1561140, 1561145 → 1561140, 1561145 FS-8d | resources MECH ENG [24 h]; PROCUREMENT<$50K 60; MECH TECH [120 h] → PROCUREMENT<$50K 60; MECH TECH [120 h]; MECH ENG [24 h] |
| 1562365 | Alignment of FDC (Installtn) | 2013-05-21 → 2013-08-30 A (+101d) | 2013-06-04 → 2013-08-30 A (+87d) |  | 0% → 100% | 20d → none | 1562360 → 1562360 FS+6d | resources MECH ENG [40 h]; MECH TECH [120 h] → MECH TECH [120 h]; MECH ENG [40 h] |
| 1562370 | Cables - Install on Trays Detector to Racks FDC | 2013-06-05 → 2013-08-30 A (+86d) | 2013-08-30 A | 62d → 65d | 0% → 100% | 20d → none | 1547170, 1562365, 1547160, 1547165 → 1547160, 1547170, 1547165, 1562365 FS-50d |  |
| 1562393 | Install/test gas systems | 2013-02-05 → 2013-08-30 A (+206d) | 2013-05-29 → 2013-08-30 A (+93d) |  | 0% → 100% | 86d → none | 9-130M FS+2d, 1562392 FS-106d → 1562392 FS-106d, 9-130M FS+130d | resources MECH DES [136 h]; SCIENTIST [68 h]; MECH ENG [136 h]; MECH TECH [408 h] → SCIENTIST [68 h]; MECH ENG [136 h]; MECH TECH [408 h]; MECH DES [136 h] |
| 1562630 | Install nitrogen lines in hall D | 2013-03-04 → 2013-08-30 A (+179d) | 2013-07-08 → 2013-08-30 A (+53d) |  | 0% → 100% | 307d → none | 9-130M FS+100d → 9-130M FS+210d |  |
| 1562635 | Install air lines in hall D | 2013-05-03 → 2013-08-30 A (+119d) | 2013-08-30 A | 84d → 89d | 0% → 100% | 268d → none |  |  |
| 1562690 | Re-Baseline Actuals Adjustment | 2013-08-30 A | 2013-08-30 A |  | 0% → 100% | 20d → none | 9-130M FS+227d → none |  |
| 2562000 | Procured Labor (Bill Vulcan) | 2013-09-03 A | 2013-09-30 A |  | 0% → 100% | 0d → none |  |  |
| 2562005LOE | FY13 Work Cordinator (Installtn) | 2013-09-03 A | 2013-09-30 A |  | 0% → 100% | 2d → none |  |  |
| 2562013E | FY13 Travel (Installtn) | 2013-09-03 A | 2013-09-30 A |  | 0% → 100% | 0d → none |  |  |
| 2562045 | Install Tagger Magnets & Chamber (Installtn) FY13 | 2013-09-03 A | 2013-09-30 → 2013-11-15 (+46d) |  | 0% → 50% |  |  |  |
| 2562045a | Install Tagger Magnets & Chamber (Installtn) FY14 | 2013-10-01 → 2013-09-03 A (-28d) | 2013-10-15 → 2013-11-15 (+31d) |  | 0% → 50% |  | 2562045, 9-130M FS+228d → 2562045 FS-20d |  |
| 2562050 | Install Tagger Pwr Supply (Installtn) FY13 | 2013-09-03 A | 2013-09-30 → 2013-11-12 (+43d) |  | 0% → 30% | 44d → 17d |  |  |
| 2562050a | Install Tagger Pwr Supply (Installtn) FY14 | 2013-10-01 → 2013-09-03 A (-28d) | 2013-10-10 → 2013-11-12 (+33d) |  | 0% → 30% | 44d → 17d | 9-130M FS+228d, 2562050 → 2562050 FS-20d |  |
| 2562063 | Fab field map fixture tagging magnet | 2013-09-03 A | 2013-10-16 → 2013-10-21 A (+5d) |  | 0% → 100% | 144d → none |  |  |
| 2562225 | Mount Bcal in Solenoid (Installtn) | 2013-09-03 A | 2013-09-30 → 2013-09-23 A (-7d) |  | 0% → 100% | 0d → none |  |  |
| 2562230 | Attach readout wedges to the BCAL modules in situ (Installtn) FY13 | 2013-09-03 A | 2013-09-30 → 2014-02-11 (+134d) |  | 0% → 25% | 179d → 151d |  |  |
| 2562230a | Attach readout wedges to the BCAL modules in situ (Installtn) FY14 | 2013-10-01 → 2013-09-03 A (-28d) | 2013-12-20 → 2014-02-11 (+53d) |  | 0% → 25% | 179d → 151d | 2562225 FS-25d, 2562230, 2546362 FS-20d → 2562230 FS-80d |  |
| 2562330 | Racks - Install Hall Upper Level Upstream (U2) | 2013-09-03 A | 2013-09-30 → 2013-10-21 A (+21d) | 20d → 21d | 0% → 100% | 179d → none |  |  |
| 2562392 | Procure final hardware for Drift Chamber gas systems (Previously Obligated) | 2013-09-03 A | 2013-10-11 → 2013-10-21 A (+10d) |  | 0% → 100% | 47d → none |  |  |
| 2562392a | Procure final hardware for Drift Chamber gas systems | 2013-09-03 A | 2013-10-11 → 2013-11-13 (+33d) |  | 0% → 40% | 47d → 24d |  |  |
| 2562435 | Engineering Support for Detector Installation 2013 (Installtn) | 2013-09-03 A | 2013-09-30 A |  | 0% → 100% | 129d → none |  |  |
| 2562440 | Engineering Support for Tagger Installation 2013 (Installtn) | 2013-09-03 A | 2013-09-30 A |  | 0% → 100% | 231d → none |  |  |
| 2562445 | Engineering Support for Installation 2013 (Installtn) | 2013-09-03 A | 2013-09-30 A |  | 0% → 100% | 19d → none |  |  |
| 2562466 | Install Dark Room for Fcal (Installtn) | 2013-09-03 A | 2013-09-30 → 2013-12-04 (+65d) |  | 0% → 70% | 79d → 43d |  | resources ELEC ENG [6.8 h]; MECH ENG [13.6 h]; MECH DES [6.8 h]; SUPPLIES & MATERIALS; MECH TECH [34 h] → SUPPLIES & MATERIALS; MECH TECH [34 h]; ELEC ENG [6.8 h]; MECH ENG [13.6 h]; MECH DES [6.8 h] |
| 2562475 | Cables - Install on Trays Detector to Racks FCAL FY13 (FY14 @ 2562475d) | 2013-09-03 A | 2013-09-30 → 2013-09-23 A (-7d) |  | 0% → 100% | 79d → none | 2562466 FS-20d → 2562466 FS-25d |  |
| 2562475a | Cables - Route and Connect on Detector FCAL FY13 | 2013-09-03 A | 2013-09-30 → 2013-09-23 A (-7d) |  | 0% → 100% | 83d → none | 2562475d FS-26d, 2562475 FS-26d → 2562475 FS-26d |  |
| 2562475aa | Cables - Route and Connect on Detector FCAL FY14 | 2013-10-01 → 2013-09-03 A (-28d) | 2013-10-25 → 2013-09-23 A (-32d) |  | 0% → 100% | 83d → none | 2562475a, 2562475 FS-26d, 2562475d FS-26d → 2562475a, 2562475d FS-26d |  |
| 2562475b | Cables - Route on Racks FCAL FY13 | 2013-09-03 A | 2013-09-30 → 2013-09-23 A (-7d) |  | 0% → 100% | 83d → none |  |  |
| 2562475ba | Cables - Route on Racks FCAL FY14 | 2013-10-01 → 2013-09-03 A (-28d) | 2013-11-05 → 2013-09-23 A (-43d) |  | 0% → 100% | 83d → none | 2562475b, 2562475a FS-39d, 2562475aa FS-39d → 2562475aa FS-39d, 2562475b |  |
| 2562475c | Cables - Connect to Crate Electronics FCAL FY13 | 2013-09-03 A | 2013-09-30 → 2013-09-23 A (-7d) |  | 0% → 100% | 83d → none |  |  |
| 2562475ca | Cables - Connect to Crate Electronics FCAL FY14 | 2013-10-01 → 2013-09-03 A (-28d) | 2013-11-27 → 2013-09-23 A (-65d) |  | 0% → 100% | 83d → none | 2562475b FS-46d, 2562475ba FS-46d, 2562475c → 2562475c, 2562475ba FS-46d |  |
| 2562475d | Cables - Install on Trays Detector to Racks FCAL FY14 (FY13 @ 2562475) | 2013-10-01 → 2013-09-03 A (-28d) | 2013-10-08 → 2013-09-23 A (-15d) |  | 0% → 100% | 79d → none | 2562475, 2562466 FS-20d → none |  |
| 2562480 | Install Pulsing Sys for Fcal (Installtn) FY13 | 2013-09-03 A | 2013-09-30 → 2014-03-17 (+168d) |  | 0% → 25% |  | 25222085 FS-88d, 25222085a FS-88d, 25222090 FS-88d, 2562475 FS-26d, 2562475d FS-26d → 25222090 FS-90d, 25222085 FS-88d, 2562475 FS-30d, 25222085a FS-88d |  |
| 2562480a | Install Pulsing Sys for Fcal (Installtn) FY14 | 2013-10-01 → 2013-09-03 A (-28d) |  |  | 0% → 25% |  | 25222085 FS-88d, 2562475d FS-26d, 25222085a FS-88d, 2562480, 2562475 FS-26d, 25222090 FS-88d → 2562480 FS-120d, 2562475d FS-26d |  |
| 2562595a | Installation work space infrastructure (TW's Doublewide) | 2013-09-03 A |  |  | 0% → 16% | 0d → 250d |  | resources PROCUREMENT<$50K 60 NO ESCALATION → PROCUREMENT>$50K 69 NO ESCALATION FY14 |
| 2562610LOE | Electrical power engineer support 2013 | 2013-09-03 A | 2013-09-30 A |  | 0% → 100% | 245d → none |  |  |
| 2562620a | Procure Electrical Power cable/conduit Part B FY13 | 2013-09-03 A | 2013-09-30 → 2013-11-18 (+49d) |  | 0% → 50% | 230d → 199d |  |  |
| 2562620aa | Procure Electrical Power cable/conduit Part B FY14 | 2013-10-01 → 2013-09-03 A (-28d) | 2013-10-04 → 2013-11-18 (+45d) |  | 0% → 50% | 230d → 199d | 9-130M FS+228d, 2562620a → 2562620a FS-40d |  |
| 2562626 | Install Transformers and Panels in Hall D | 2013-09-03 A | 2013-11-27 → 2013-10-21 A (-37d) |  | 0% → 100% | 160d → none |  |  |

| ID | Task | Start | Finish | Duration | Complete | Total float | Predecessors | Other |
| --- | --- | --- | --- | --- | --- | --- | --- | --- |
| 2562640 | Procure cable trays and hardware | 2013-09-03 A | 2013-09-30 → 2013-10-21 A (+21d) |  | 0% → 100% | 124d → none |  |  |
| 2562645 | Install cable trays and hardware FY13 | 2013-09-03 A | 2013-09-30 → 2013-11-20 (+51d) |  | 0% → 20% | 124d → 121d |  |  |
| 2562645a | Install cable trays and hardware FY14 | 2013-10-01 → 2013-09-03 A (-28d) | 2013-11-15 → 2013-11-20 (+5d) |  | 0% → 20% | 124d → 121d | 2562645, 2562640 FS-20d → 2562645 FS-40d |  |
| 2562685 | Fiducialize and survey equipment (2013) | 2013-09-03 A | 2013-09-30 → 2013-09-23 A (-7d) |  | 0% → 100% | 247d → none |  |  |
| 2562705 | Manufacturing Drawings of Chilled water system for Hall D | 2013-09-03 A | 2013-09-18 → 2013-10-21 A (+33d) |  | 0% → 100% | 134d → none |  |  |
| 2562730 | Install Upstream cable trays (FDC/CDC/SC) FY13 | 2013-09-03 A | 2013-09-30 → 2013-11-13 (+44d) |  | 0% → 67% | 56d → 67d |  | resources MECH DES [4.41 h]; MECH TECH [88.28 h]; MECH ENG [6.62 h] → MECH TECH [88.28 h]; MECH ENG [6.62 h]; MECH DES [4.41 h] |
| 2562730a | Install Upstream cable trays (FDC/CDC/SC) FY14 | 2013-10-01 → 2013-09-03 A (-28d) | 2013-10-11 → 2013-11-13 (+33d) |  | 0% → 67% | 56d → 67d | 2562225 FS-20d, 2562730 → 2562730 FS-40d |  |
| 2562785 | Materials for install 2013 (Previously Obligated) | 2013-09-03 A | 2013-09-30 A |  | 0% → 100% | 747d → none |  |  |
| 2562790 | Materials for install 2013 | 2013-09-03 A | 2013-09-30 A |  | 0% → 100% | 747d → none |  |  |
| 2562805 | Manufacturing Drawings of N2 purge system FY13 | 2013-09-05 → 2013-09-03 A (-2d) | 2013-09-30 → 2013-11-14 (+45d) |  | 0% → 97% | 94d → 107d |  |  |
| 2562805a | Manufacturing Drawings of N2 purge system FY14 | 2013-10-01 → 2013-09-03 A (-28d) |  |  | 0% → 97% | 94d → 107d | 9-130M FS+230d, 2562805 → 2562805 FS-40d |  |
| 2562830 | Install BCAL cooling manifold FY13 | 2013-09-03 A | 2013-09-30 → 2013-10-21 A (+21d) |  | 0% → 100% | 29d → none |  |  |
| 2562830a | Install BCAL cooling manifold FY14 | 2013-10-01 → 2013-09-03 A (-28d) | 2013-10-28 → 2013-10-21 A (-7d) |  | 0% → 100% | 29d → none | 25221320 FS-23d, 2562830 → 2562830 FS-20d |  |
| 2562835 | Install PS shielding | 2013-10-04 → 2013-09-03 A (-31d) |  |  | 0% → 55% |  | 9-140M FS+3d → 9-140M |  |
| 2562895 | Preparing OSP ESAD documentation Rediness Review for April 14 Beam Run FY13 | 2013-09-03 A | 2013-09-30 → 2014-05-13 (+225d) |  | 0% → 4% |  |  |  |
| 2562895a | Preparing OSP ESAD documentation Rediness Review for April 14 Beam Run FY14 | 2013-10-01 → 2013-09-03 A (-28d) |  |  | 0% → 4% |  | 2562895, 9-130M FS+228d → 2562895 FS-160d |  |
| 2562098 | Install Tagger Quad Stand & Magnet (Installtn) | 2013-10-18 → 2013-09-09 A (-39d) |  |  | 0% → 9% |  | 2562045 FS+2d, 2562045a FS+2d → 2562045 FS-15d, 2562045a FS-15d |  |
| 2562710 | Procure Chilled water components | 2013-10-03 → 2013-09-09 A (-24d) |  |  | 0% → 90% | 124d → 162d | 9-140M FS+2d, 2562705 → 2562705 FS-15d, 9-140M |  |
| 2562715 | Install Chilled water sytem Hall D | 2013-10-24 → 2013-09-09 A (-45d) |  |  | 0% → 93% |  | 2562710 FS-18d → 2562710 FS-50d |  |
| 2562061 | Field Map Tagging Magnet (Installtn) | 2013-10-01 → 2013-09-16 A (-15d) |  |  | 0% → 26% |  | 2562045a FS-11d, 2562050a FS-13d, 25511095a FS-12d, 2562050 FS-13d, 2562440 FS-200d, 25511095 FS-12d, 2562063 FS-32d, 2562845 FS-120d, 2562045 FS-11d → 25511095 FS-40d, 2562063 FS-32d, 2562845 FS-120d, 25511095a FS-40d, 2562045a FS-11d, 2562050 FS-13d, 2562045 FS-11d, 2562050a FS-13d, 2562440 FS-200d | resources MECH ENG [112.8 h]; MECH TECH [188 h]; SCIENTIST [75.2 h] → MECH TECH [188 h]; SCIENTIST [75.2 h]; MECH ENG [112.8 h] |
| 2562393 | Install/test gas systems | 2013-11-01 → 2013-09-16 A (-46d) | 2014-01-28 → 2013-12-13 (-46d) |  | 0% → 31% | 4d → 68d | 2562392a FS-106d, 2562392 FS-106d, 9-140M FS+23d → 2562392 FS-106d, 9-140M, 2562392a FS-106d |  |
| 2562006LOE | FY14 Work Cordinator (Installtn) | 2013-10-01 A |  |  | 0% → 9% | 2d → 252d |  |  |
| 2562014E | FY14 Travel (Installtn) | 2013-10-01 A |  |  | 0% → 9% | 0d → 250d |  |  |
| 2562231 | Manufacturing Drawings of BCAL Lateral support | 2013-10-03 → 2013-10-01 A (-2d) | 2013-10-30 → 2013-12-02 (+33d) |  | 0% → 71% | 160d → 181d |  | resources MECH ENG [35.2 h]; MECH DES [52.8 h] → MECH DES [52.8 h]; MECH ENG [35.2 h] |
| 2562233 | Install BCAL lateral support | 2013-12-16 → 2013-10-01 A (-76d) |  |  | 0% → 24% |  | 2562232 FS+11d → 2562232 FS-60d |  |
| 2562245 | Racks - Install Hall Lower Level Upstream (U1) | 2013-10-01 A | 2013-10-10 → 2013-10-21 A (+11d) |  | 0% → 100% | 162d → none | 9-140M, 2562225 FS-4d → 2562225 FS-4d |  |
| 2562250 | Install Pwr to Racks Upstream Platform (Installtn) - Procurement | 2013-09-09 → 2013-10-01 A (+22d) |  |  | 0% → 10% |  |  |  |
| 2562250a | Install Pwr to Racks Upstream Platform (Installtn) - Labor FY13 | 2013-09-03 → 2013-10-01 A (+28d) | 2013-09-30 → 2013-11-26 (+57d) |  | 0% → 10% | 166d → 174d | 2562245 FS-28d → 2562245 FS-24d |  |
| 2562250b | Install Pwr to Racks Upstream Platform (Installtn) - Labor FY14 | 2013-10-01 A | 2013-11-20 → 2013-11-26 (+6d) |  | 0% → 10% | 166d → 162d | 2562245 FS-24d, 2562250a → 2562250a FS-30d |  |
| 2562275 | Cables - Install on Trays Detector to Racks BCAL FY13 | 2013-09-27 → 2013-10-01 A (+4d) | 2013-09-30 → 2013-10-21 A (+21d) |  | 0% → 100% | 58d → none |  |  |
| 2562275a | Cables - Route and Connect on Detector BCAL | 2013-10-28 → 2013-10-01 A (-27d) |  |  | 0% → 80% | 63d → 85d |  |  |
| 2562275b | Cables - Route on Racks BCAL | 2013-11-18 → 2013-10-01 A (-48d) |  |  | 0% → 60% | 63d → 74d | 2562275a FS-13d → 2562275a FS-35d |  |
| 2562275c | Cables - Connect to Crate Electronics BCAL | 2013-11-25 → 2013-10-01 A (-55d) |  |  | 0% → 50% |  | 2562275b FS-18d → 2562275b FS-45d |  |
| 2562275d | Cables - Install on Trays Detector to Racks BCAL FY14 | 2013-10-01 A | 2013-10-30 → 2013-10-21 A (-9d) |  | 0% → 100% | 58d → none | 2547180 FS-2d, 2562275, 2547175 FS-2d → 2562275 |  |
| 2562335 | Install Pwr to Racks Platform #2 (Installtn) - Procurement | 2013-09-03 → 2013-10-01 A (+28d) |  | 77d → 34d | 0% → 70% |  | 2562330 FS-20d → 2562330 FS+2d |  |
| 2562335a | Install Pwr to Racks Platform #2 (Installtn) - Labor FY13 | 2013-09-03 → 2013-10-01 A (+28d) | 2013-09-30 → 2013-12-20 (+81d) |  | 0% → 70% | 190d → 196d | 2562330 FS-20d → 2562330 FS+2d |  |
| 2562335b | Install Pwr to Racks Platform #2 (Installtn) - Labor FY14 | 2013-10-01 A |  |  | 0% → 70% |  | 2562330 FS-21d, 2562335a → 2562335a FS-40d |  |
| 2562360 | Install FDC on Platform (Installtn) | 2013-10-07 → 2013-10-01 A (-6d) | 2013-10-14 → 2013-10-21 A (+7d) |  | 0% → 100% | 0d → none |  |  |
| 2562405 | Install Pwr to FCAL/TOF Racks (Installtn) | 2013-09-03 → 2013-10-01 A (+28d) | 2013-12-18 → 2013-12-13 (-5d) |  | 0% → 82% | 0d → 23d |  |  |
| 2562445a | Engineering Support for Installation 2014 (Installtn) | 2013-10-01 A |  |  | 0% → 10% |  | 2562445, 9-130M FS+228d → 2562445 |  |
| 2562615LOE | Electrical power engineer support 2014 | 2013-10-01 A |  |  | 0% → 9% |  |  |  |
| 2562690 | Manufacturing Drawings of cooling system for FCAL dark room FY13 | 2013-09-03 → 2013-10-01 A (+28d) | 2013-09-30 → 2013-12-02 (+63d) |  | 0% → 70% | 190d → 193d |  |  |
| 2562690a | Manufacturing Drawings of cooling system for FCAL dark room FY14 | 2013-10-01 A | 2013-10-22 → 2013-12-02 (+41d) |  | 0% → 70% | 190d → 193d | 2562690, 9-130M FS+228d → 2562690 FS-20d |  |
| 2562740 | Manufacturing Drawings of dry air cooling upstream racks/drift chambers | 2013-10-04 → 2013-10-01 A (-3d) |  |  | 0% → 18% |  |  |  |
| 2562865 | Procure lighting fixture under US platform | 2013-09-03 → 2013-10-01 A (+28d) | 2013-10-04 → 2013-10-21 A (+17d) |  | 0% → 100% | 124d → none |  |  |
| 2562890 | Detector Readout Electronics Support Documentation and OSP | 2013-10-01 A |  |  | 0% → 8% |  |  |  |
| 2562636 | Manufacture Drawing Inst Air Sys | 2013-11-15 → 2013-10-07 A (-39d) |  |  | 0% → 78% |  | 2562805, 2562805a → 2562805a FS-40d, 2562805 FS-40d |  |
| 2562540 | Crates - Loaded (VME64x VXS HV LV) Install Hall BCAL | 2014-01-16 → 2013-10-10 A (-98d) | 2014-01-30 → 2013-11-14 (-77d) |  | 0% → 60% | 80d → 124d | 2562535 FS-25d, 2548025a FS-25d, 2548025 FS-25d → 2562535 FS-80d, 2548025 FS-25d, 2548025a FS-25d |  |
| 2562365 | Alignment of FDC (Installtn) | 2013-10-15 → 2013-10-11 A (-4d) | 2013-10-23 → 2013-11-11 (+19d) |  | 0% → 50% | 0d → 21d |  |  |
| 2562535 | Crates - Loaded (VME64x VXS HV LV) Install Hall FDC | 2013-12-02 → 2013-10-12 A (-51d) | 2014-02-20 → 2014-01-24 (-27d) |  | 0% → 10% | 80d → 114d | 9-140M FS+42d, 2548020a FS-46d, 2548025 FS-64d, 2548020 FS-46d, 2548025a FS-64d → 2548025 FS-64d, 2548020 FS-46d, 2548020a FS-100d, 2548025a FS-64d, 9-140M |  |
| 2562530 | Crates - Loaded (VME64x VXS HV LV) Install Hall CDC | 2014-01-02 → 2013-10-14 A (-80d) | 2014-02-07 → 2013-12-10 (-59d) |  | 0% → 10% | 126d → 160d | 2548020a, 2548020 → 2548020a FS-100d, 2548020 FS-20d |  |
| 2562700 | Install Cooling system for FCAL dark room | 2013-10-23 → 2013-10-14 A (-9d) | 2013-11-20 → 2013-12-03 (+13d) |  | 0% → 50% | 190d → 183d | 9-140M FS+13d, 2562690, 2562690a → 9-140M FS+13d, 2562690 FS-30d, 2562690a FS-30d |  |
| 2562810 | Procure N2 purge system | 2013-10-15 A |  |  | 0% → 60% |  |  |  |
| 2562246 | Racks - Install Hall Lower Level Upstream South (US1) | 2013-10-21 A |  |  | 0% → 60% |  |  |  |
| 2562085 | Racks - Install Tagger FY13 | 2013-09-03 → 2013-11-01 (+59d) | 2013-09-30 → 2013-12-02 (+63d) |  |  | 169d → 126d |  |  |
| 2562099 | Cables - Install on Trays Detector to Racks Pair Spectrometer | 2013-09-03 → 2013-11-01 (+59d) | 2013-09-20 → 2013-11-20 (+61d) |  |  | 215d → 172d |  |  |
| 2562181 | Install Photon BL Colli. Cave (Installtn) - Procurement | 2013-09-03 → 2013-11-01 (+59d) | 2013-12-20 → 2014-03-04 (+74d) |  |  | 190d → 147d |  |  |
| 2562181a | Install Photon BL Colli. Cave (Installtn) - Labor/Expenses FY13 | 2013-09-03 → 2013-11-01 (+59d) | 2013-09-30 → 2013-12-02 (+63d) |  |  | 190d → 147d |  |  |
| 2562214 | Fab field map fixture for PS magnet | 2013-10-11 → 2013-11-01 (+21d) | 2013-12-20 → 2014-01-23 (+34d) |  |  | 158d → 143d |  |  |
| 2562355 | Install Supprt Electrnc's Platform #2 (Installtn) - Procurement | 2013-09-03 → 2013-11-01 (+59d) | 2013-11-04 → 2013-12-09 (+35d) | 45d → 25d |  | 222d → 199d |  |  |
| 2562355a | Install Supprt Electrnc's Platform #2 (Installtn) - Labor FY13 | 2013-09-03 → 2013-11-01 (+59d) | 2013-09-30 → 2013-12-02 (+63d) |  |  | 222d → 179d |  |  |
| 2562478 | FCAL DAQ and Trigger_Setup FY13 | 2013-09-03 → 2013-11-01 (+59d) | 2013-09-30 → 2013-12-02 (+63d) |  |  | 83d → 40d | 2562475c FS-62d, 2562475ca FS-62d → 2562475ca, 2562475c FS-62d |  |
| 2562482 | Test and analyze FCAL detector FY13 | 2013-09-03 → 2013-11-01 (+59d) | 2013-09-30 → 2013-12-02 (+63d) |  |  | 83d → 40d |  |  |
| 2562745 | Fabricate dry air cooling system up racks/drift chambers | 2013-10-22 → 2013-11-01 (+10d) | 2013-12-02 → 2013-12-12 (+10d) |  |  | 143d → 135d |  |  |
| 2562770 | Manufacturing Drawings of fixture for commissioning target | 2013-10-18 → 2013-11-01 (+14d) | 2014-01-13 → 2014-01-28 (+15d) |  |  | 128d → 118d |  |  |
| 2562850 | Procure UPS system for critical controls | 2013-10-16 → 2013-11-01 (+16d) | 2014-01-31 → 2014-02-18 (+18d) |  |  | 165d → 153d |  |  |
| 2562545 | Crates - Loaded (VME64x VXS HV LV) Install Hall TOF | 2014-01-31 → 2013-11-15 (-77d) | 2014-02-06 → 2013-11-21 (-77d) |  |  | 145d → 189d |  |  |
| 2562180 | Install Photon BL Tag Hall (Installtn) | 2013-10-22 → 2013-11-22 (+31d) | 2013-11-22 → 2014-01-08 (+47d) |  |  | 208d → 185d |  |  |
| 2562232 | Fab BCAL lateral support | 2013-10-28 → 2013-11-26 (+29d) | 2013-11-26 → 2014-01-08 (+43d) |  |  | 160d → 181d |  |  |
| 2562870 | Install lighting fixtures under US platform | 2013-11-12 → 2013-11-27 (+15d) | 2013-12-16 → 2014-01-10 (+25d) |  |  | 124d → 113d |  |  |

| ID | Task | Start | Finish | Duration | Complete | Total float | Predecessors | Other |
| --- | --- | --- | --- | --- | --- | --- | --- | --- |
| 2562370 | Cables - Install on Trays Detector to Racks FDC | 2013-11-04 → 2013-12-02 (+28d) | 2013-12-03 → 2014-01-08 (+36d) |  |  | 0d → 16d |  |  |
| 2562370a | Cables - Route and Connect on Detector FDC | 2013-11-04 → 2013-12-02 (+28d) | 2013-12-13 → 2014-01-21 (+39d) |  |  | 3d → 19d |  |  |
| 2562035M | Assy of TOF (Installtn) | 2013-12-02 → 2013-12-03 (+1d) | 2013-12-02 → 2013-12-03 (+1d) |  |  | 163d → 162d |  |  |
| 2562085a | Racks - Install Tagger FY14 | 2013-10-01 → 2013-12-03 (+63d) | 2013-10-11 → 2013-12-13 (+63d) |  |  | 169d → 126d | 9-130M FS+228d, 2562085 → 2562085 |  |
| 2562181b | Install Photon BL Colli. Cave (Installtn) - Labor/Expenses FY14 | 2013-10-01 → 2013-12-03 (+63d) | 2013-12-20 → 2014-03-04 (+74d) |  |  | 190d → 147d | 2562181a, 2553055 FS-130d, 2553057 FS-175d, 2553057a FS-175d → 2562181a |  |
| 2562355b | Install Supprt Electrnc's Platform #2 (Installtn) - Labor FY14 | 2013-10-01 → 2013-12-03 (+63d) | 2013-11-04 → 2014-01-16 (+73d) |  |  | 222d → 179d | 2562355a, 9-130M FS+228d → 2562355a |  |
| 2562478a | FCAL DAQ and Trigger_Setup FY14 | 2013-10-01 → 2013-12-03 (+63d) | 2014-02-27 → 2014-04-29 (+61d) |  |  | 83d → 40d | 2562475ca FS-62d, 2562478, 2562475c FS-62d → 2562478, 2562475ca FS-62d |  |
| 2562482a | Test and analyze FCAL detector FY14 | 2013-10-01 → 2013-12-03 (+63d) | 2014-06-03 → 2014-08-04 (+62d) |  |  | 83d → 40d | 2562478 FS-117d, 2562478a FS-117d, 2562482 → 2562478a FS-117d, 2562482 |  |
| 2562060 | Survey & Align tagger beamline (Installtn) | 2013-11-01 → 2013-12-06 (+35d) | 2013-11-22 → 2014-01-08 (+47d) |  |  | 208d → 185d |  |  |
| 2562520 | Crates - Loaded (VME64x VXS HV LV) Install Hall Pair Spectrometer | 2014-02-11 → 2013-12-09 (-64d) | 2014-02-17 → 2013-12-13 (-66d) |  |  | 146d → 183d |  |  |
| 2562525 | Crates - Loaded (VME64x VXS HV LV) Install Hall Start Counter | 2014-02-18 → 2013-12-16 (-64d) | 2014-02-24 → 2013-12-20 (-66d) |  |  | 146d → 183d |  | was named Crates - Loaded (VME64x VXS HV LV) Install Hal Start Counter |
| 2562775 | Fab Fixture for commissioning target | 2013-12-05 → 2013-12-19 (+14d) | 2014-02-21 → 2014-03-07 (+14d) |  |  | 128d → 118d |  |  |
| 2562855 | Install UPS system for critical controls | 2013-12-04 → 2013-12-20 (+16d) | 2014-02-06 → 2014-02-24 (+18d) |  |  | 165d → 153d |  |  |
| 2562099a | Cables - Route and Connect on Detector Pair Spectrometer | 2014-01-06 → 2014-01-02 (-4d) | 2014-01-17 → 2014-01-15 (-2d) |  |  | 150d → 152d |  |  |
| 2562090 | Install Tagger Electrnc's (Installtn) | 2014-01-07 → 2014-01-03 (-4d) | 2014-01-21 → 2014-01-16 (-5d) |  |  | 128d → 130d |  |  |
| 2562635 | Install air lines in hall D | 2014-01-07 → 2014-01-03 (-4d) | 2014-03-11 → 2014-03-07 (-4d) |  |  | 142d → 144d |  |  |
| 2562860 | Install Electron beamline to dump | 2014-01-08 → 2014-01-06 (-2d) | 2014-02-20 → 2014-02-18 (-2d) |  |  | 155d → 157d |  |  |
| 2562065 | Install Pwr for Tagger Electrnc's (Installtn) | 2014-01-09 → 2014-01-07 (-2d) | 2014-02-06 → 2014-02-04 (-2d) |  |  | 116d → 118d |  |  |
| 2562750 | Install dry air cooling system up racks/drift chamber | 2013-12-17 → 2014-01-13 (+27d) | 2014-02-11 → 2014-02-26 (+15d) |  |  | 124d → 113d |  |  |
| 2562370b | Cables - Route on Racks FDC | 2013-12-09 → 2014-01-14 (+36d) | 2014-01-07 → 2014-02-03 (+27d) |  |  | 3d → 19d |  |  |
| 2562370c | Cables - Connect to Crate Electronics FDC | 2013-12-09 → 2014-01-14 (+36d) | 2014-02-25 → 2014-03-21 (+24d) |  |  | 3d → 19d |  |  |
| 2562099b | Cables - Route on Racks Pair Spectrometer | 2014-01-21 → 2014-01-16 (-5d) | 2014-01-27 → 2014-01-23 (-4d) |  |  | 150d → 152d |  |  |
| 2562290 | Cables - Install on Trays Detector to Racks CDC | 2013-12-05 → 2014-01-17 (+43d) | 2013-12-12 → 2014-01-27 (+46d) |  |  | 134d → 111d |  |  |
| 2562290a | Cables - Route and Connect on Detector CDC | 2013-12-09 → 2014-01-22 (+44d) | 2014-01-15 → 2014-02-18 (+34d) |  |  | 134d → 111d |  |  |
| 2562099c | Cables - Connect to Crate Electronics Pair Spectrometer | 2014-01-28 → 2014-01-24 (-4d) | 2014-02-10 → 2014-02-06 (-4d) |  |  | 150d → 152d |  |  |
| 2562216 | Field Map PS magnet | 2014-01-02 → 2014-01-24 (+22d) | 2014-02-17 → 2014-03-10 (+21d) |  |  | 158d → 143d |  |  |
| 2562170 | Install Photon Beam Profiler (Installtn) | 2014-03-26 → 2014-01-29 (-56d) | 2014-04-28 → 2014-03-03 (-56d) |  |  | 108d → 148d |  |  |
| 2562420 | Install Supprt Electrnc's FCAL/TOF Racks (Installtn) | 2014-02-03 → 2014-01-30 (-4d) | 2014-03-31 → 2014-03-27 (-4d) |  |  | 128d → 130d |  |  |
| 2562205 | Install NIM and CAEN Crates in Counting Room (Installtn) | 2013-11-21 → 2014-02-03 (+74d) | 2013-12-20 → 2014-02-28 (+70d) |  |  | 17d → 2d |  |  |
| 2562380 | Insertion of FDC (Installtn) | 2014-01-13 → 2014-02-07 (+25d) | 2014-01-22 → 2014-02-17 (+26d) |  |  | 0d → 16d |  |  |
| 2562235 | Comp B-cal Assy (Installtn) | 2014-01-30 → 2014-02-12 (+13d) | 2014-02-12 → 2014-02-25 (+13d) |  |  | 161d → 152d | 25221057b, 2562830, 25221057ba, 25221057c, 2562233, 2562225, 2562245 FS+42d, 2562230a, 2562830a, 2562230, 25221057ca → 2562230, 2562245 FS+42d, 25221057c, 2562225, 2562233, 25221057ca, 2562830, 25221057b, 25221057ba, 2562230a |  |
| 2562290b | Cables - Route on Racks CDC | 2014-01-13 → 2014-02-14 (+32d) | 2014-01-22 → 2014-02-24 (+33d) |  |  | 134d → 111d |  |  |
| 2562300 | Mounting CDC on cart align and insert into solenoid (Installtn) | 2014-01-23 → 2014-02-18 (+26d) | 2014-02-10 → 2014-03-06 (+24d) |  |  | 34d → 16d |  |  |
| 2562385 | Cooling Sys Checks for FDC (Installtn) | 2014-01-23 → 2014-02-18 (+26d) | 2014-02-03 → 2014-02-27 (+24d) |  |  | 0d → 23d |  |  |
| 2562290c | Cables - Connect to Crate Electronics CDC | 2014-01-21 → 2014-02-21 (+31d) | 2014-01-28 → 2014-02-28 (+31d) |  |  | 134d → 111d | 2562250b, 2562250a, 2562250, 2562290b FS-2d → 2562250b, 2562250, 2562290b FS-2d |  |
| 2562206 | Install Computers in Counting Room (Installtn) Part B | 2014-01-02 → 2014-03-03 (+60d) | 2014-01-27 → 2014-03-25 (+57d) |  |  | 173d → 132d |  |  |
| 2562210 | Install Supprt Electrnc's in Counting Room (Installtn) (SP) | 2014-01-02 → 2014-03-03 (+60d) | 2014-01-30 → 2014-03-28 (+57d) |  |  | 17d → 2d |  | was named Install Supprt Electrnc's in Counting Room (Installtn) |
| 2562165 | Install High Granularity Pair Spectrometer (Installtn) | 2014-01-29 → 2014-03-06 (+36d) | 2014-03-18 → 2014-04-23 (+36d) |  |  | 137d → 111d |  |  |
| 2562303 | Install FDC/CDC Alignment Check System (Installtn) | 2014-02-10 → 2014-03-06 (+24d) | 2014-02-21 → 2014-03-19 (+26d) |  |  | 51d → 33d |  |  |
| 2562301 | CDC mounting electronics and other connections in situ (Installtn) | 2014-02-11 → 2014-03-07 (+24d) | 2014-03-03 → 2014-03-27 (+24d) |  |  | 34d → 16d |  |  |
| 2562280 | Technical Support for Bcal Testing (Installtn) | 2014-01-10 → 2014-03-11 (+60d) | 2014-04-23 → 2014-06-20 (+58d) |  |  | 17d → 2d |  |  |
| 2562780 | Install Commissioning target with Start Counter | 2014-03-03 → 2014-03-17 (+14d) | 2014-03-31 → 2014-04-14 (+14d) |  |  | 128d → 118d |  |  |
| 2562505 | Install Trigger Electrnc's (Installtn) | 2014-01-07 → 2014-03-19 (+71d) | 2014-02-04 → 2014-04-15 (+70d) |  |  | 128d → 78d |  |  |
| 2562080 | Install Hodoscope (Installtn) |  |  |  |  |  | 2546585, 2546605a, 2546605b, 2546600, 2562440 FS-200d, 2562061, 25512070, 2546585b, 25512005a, 25512010aa, 25512010, 25512010a, 2546605, 2546585a, 25512060, 25512176, 25512013LOE → 2546585, 25512010a, 25512070, 2562061, 2546605b, 25512010aa, 2546600, 25512060, 25512010, 25512013LOE, 25512005a, 25512176, 2562440 FS-200d, 2546605, 2546585b |  |
| 2562515 | Crates - Loaded (VME64x VXS HV LV) Install Hall Tagger | 2014-04-22 → 2014-04-21 (-1d) | 2014-04-28 → 2014-04-25 (-3d) |  |  | 98d → 99d |  |  |
| 2562490 | Cables - Install on Trays Detector to Racks Start Counter | 2014-08-18 → 2014-09-03 (+16d) | 2014-08-19 → 2014-09-04 (+16d) |  |  | 19d → 8d |  |  |
| 2562485 | Install Start Counter Onto LH Target (Installtn) | 2014-08-19 → 2014-09-04 (+16d) | 2014-09-02 → 2014-09-17 (+15d) |  |  | 11d → 0d |  |  |
| 2562490a | Cables - Route and Connect on Detector Start Counter | 2014-08-20 → 2014-09-05 (+16d) | 2014-08-21 → 2014-09-08 (+18d) |  |  | 41d → 30d |  |  |
| 2562495 | Test Start Counter (Installtn) | 2014-08-20 → 2014-09-05 (+16d) | 2014-09-03 → 2014-09-18 (+15d) |  |  | 19d → 8d |  |  |
| 2562490b | Cables - Route on Racks Start Counter | 2014-08-22 → 2014-09-09 (+18d) | 2014-08-25 → 2014-09-10 (+16d) |  |  | 41d → 30d |  |  |
| 2562490c | Cables - Connect to Crate Electronics Start Counter | 2014-08-26 → 2014-09-11 (+16d) | 2014-08-27 → 2014-09-12 (+16d) |  |  | 41d → 30d |  |  |
| 2562175 | Install Hydrogen Target and Start Counter Inside Detector (Installtn) | 2014-09-02 → 2014-09-17 (+15d) | 2014-09-15 → 2014-09-30 (+15d) |  |  | 11d → 0d |  |  |
| 3 | **1.5.6.3 CRYOGENICS** | 2010-01-05 → 2010-05-03 (+118d) |  |  |  |  |  |  |
| 1563005 | Release U-tube Fabrication Drawings (CRYOGENICS) | 2010-01-05 → 2010-05-03 A (+118d) | 2010-07-09 → 2011-08-05 A (+392d) | 130d → 315d | 0% → 100% | 443d → none |  |  |
| 1563010 | Release Warm Gas Plumbing Fabrication Drawings (CRYOGENICS) (Frozen per CR11-036) | 2010-01-05 → 2010-05-03 A (+118d) | 2010-07-09 → 2011-08-08 A (+395d) | 130d → 316d | 0% → 100% | 454d → none |  | resources MECH TECH [320 h]; MECH ENG [40 h]; MECH DES [80 h] → MECH ENG [40 h]; MECH DES [80 h]; MECH TECH [320 h] |
| 1563015 | Release Transfer Line Fabrication Drawings (CRYOGENICS) (Frozen per CR11-036) | 2010-01-05 → 2010-05-03 A (+118d) | 2010-07-09 → 2011-08-08 A (+395d) | 130d → 316d | 0% → 100% | 408d → none |  |  |
| 1563006 | Proc U-tubes (CRYOGENICS) (Frozen per CR11-036) | 2010-07-01 → 2011-08-01 A (+396d) | 2010-12-15 → 2011-08-08 A (+236d) | 116d → 6d | 0% → 100% | 443d → none | 1563005 FS-6d → 1563005 FS-6d, 9-120M FS+80d |  |
| 1563011 | Proc Warm Gas Plumbing (CRYOGENICS) (Frozen per CR11-036) | 2010-06-16 → 2011-08-01 A (+411d) | 2010-11-30 → 2011-08-08 A (+251d) | 116d → 6d | 0% → 100% | 454d → none |  |  |
| 1563016 | Proc Transfer Line (CRYOGENICS) (Frozen per CR11-036) | 2010-06-04 → 2011-08-01 A (+423d) | 2010-12-30 → 2011-08-08 A (+221d) | 141d → 6d | 0% → 100% | 437d → none |  |  |
| 1563017 | Proc Cryo Distribution for Magnet (Labor) (CRYOGENICS) FY10 (Frozen per CR11-036) | 2010-07-12 → 2011-08-01 A (+385d) | 2010-09-30 → 2011-08-08 A (+312d) | 58d → 6d | 0% → 100% | 408d → none |  |  |
| 1563017a | Proc Cryo Distribution for Magnet (Labor) (CRYOGENICS) FY11 (Frozen per CR11-036) | 2010-10-01 → 2011-08-01 A (+304d) | 2011-02-11 → 2011-08-08 A (+178d) | 87d → 6d | 0% → 100% | 408d → none |  |  |
| 1563020 | Release Cryogenic Instrumentation Drawings (CRYOGENICS) (Frozen per CR11-036) | 2010-01-05 → 2011-08-01 A (+573d) | 2010-07-09 → 2011-08-08 A (+395d) | 130d → 6d | 0% → 100% | 437d → none |  | resources MECH ENG [80 h]; MECH TECH [320 h]; MECH DES [120 h] → MECH ENG [80 h]; MECH DES [120 h]; MECH TECH [320 h] |
| 1563025 | Proc Cryogenic Instrumentation (CRYOGENICS) (Frozen per CR11-036) | 2010-08-02 → 2011-08-01 A (+364d) | 2010-12-30 → 2011-08-08 A (+221d) | 101d → 6d | 0% → 100% | 437d → none |  |  |
| 1563030 | Reverse Entry per CR11-036 | 2011-08-01 A | 2011-08-05 A |  | 0% → 100% | 39d → none |  | resources MECH ENG [-540 h]; MECH TECH [-580 h]; PROCUREMENT<$50K 60; PROCUREMENT>$50K 69; MECH DES [-340 h] → MECH TECH [-580 h]; PROCUREMENT<$50K 60; PROCUREMENT>$50K 69; MECH DES [-340 h]; MECH ENG [-540 h] |
| 1563035 | Re-Baseline Actuals Adjustment | 2013-08-30 A | 2013-08-30 A |  | 0% → 100% | 20d → none | 9-130M FS+227d → none |  |
| 157005 | Spare Hall D Solenoid Procurement Process FY11 Labor | 2011-07-01 A | 2011-09-30 A |  | 0% → 100% | 373d → none |  |  |
| 157010 | Spare Hall D Solenoid Procurement Process FY12 Labor | 2011-10-03 A | 2011-12-30 → 2012-02-13 A (+45d) | 58d → 87d | 0% → 100% | 373d → none |  |  |
| 157020 | Spare Hall D Solenoid FY12 Oversight Labor | 2012-01-03 A | 2012-01-31 → 2012-02-03 A (+3d) | 20d → 22.98d | 0% → 100% | 373d → none | 157010 → 157010 FS-30d |  |
| 157030 | Spare Hall D Solenoid FY13 Oversight Labor | 2013-07-01 → 2013-08-30 A (+60d) | 2013-08-30 A | 44d → 20d | 0% → 100% | 20d → none |  |  |
| 157045 | Re-Baseline Actuals Adjustment | 2013-08-30 A | 2013-08-30 A |  | 0% → 100% | 20d → none | 9-130M FS+227d → none |  |

| ID | Task | Start | Finish | Duration | Complete | Total float | Predecessors | Other |
| --- | --- | --- | --- | --- | --- | --- | --- | --- |
| 6 | **1.6 CONVENTIONAL FACILITIES** | 2008-12-12 → 2007-10-01 (-438d) |  |  |  |  |  |  |
| 1 | **1.6.1 ACCELERATOR** | 2009-10-01 → 2009-10-29 (+28d) |  |  |  |  |  |  |
| 1 | **1.6.1.1 BUILDINGS** | 2009-10-01 → 2009-10-29 (+28d) |  |  |  |  |  |  |
| 1 | **1.6.1.1.1 NORTH & SOUTH ACCESS BUILDING ADDITIONS** | 2009-10-01 → 2009-10-29 (+28d) |  |  |  |  |  |  |
| 16111000M | N&S Access Addition Post Solicitation | 2009-10-01 → 2009-10-29 A (+28d) | 2009-10-01 → 2009-10-29 A (+28d) |  | 0% → 100% | 162d → none |  | was named N&S Access Addition Begin Constr |
| 16111005 | N&S Access Addition Award Contract | 2009-10-01 → 2009-10-29 A (+28d) | 2010-01-04 → 2010-01-13 A (+9d) | 60d → 47d | 0% → 100% | 278d → none | 16111000M → 16111000M FS-100d |  |
| 16111010 | N&S Access Constrctn Contract April Progress Payment | 2010-01-20 A | 2010-04-30 A |  | 0% → 100% | 278d → none | 16111005 FS+10d → 16111005 |  |
| 16111010A | N&S Access Constrctn Contract May Progress Payment | 2010-01-20 A | 2010-05-28 → 2010-06-30 A (+33d) | 92d → 114d | 0% → 100% | 278d → none |  |  |
| 16111010B | N&S Access Constrctn Contract June Progress Payment | 2010-01-20 A | 2010-06-30 A |  | 0% → 100% | 278d → none |  |  |
| 16111010C | N&S Access Constrctn Contract July Progress Payment | 2010-01-20 A | 2010-07-30 → 2010-07-28 A (-2d) | 135d → 133d | 0% → 100% | 278d → none |  |  |
| 16111010D | N&S Access Constrctn Contract August Progress Payment | 2010-01-20 A | 2010-08-31 A |  | 0% → 100% | 278d → none |  |  |
| 16111010G | N&S Access Constrctn Contract September Progress Payment | 2010-01-20 A | 2010-09-30 → 2010-08-31 A (-30d) | 178d → 157d | 0% → 100% | 278d → none |  |  |
| 16111010H | N&S Access Constrctn Contract October Progress Payment | 2010-01-20 A | 2010-10-29 → 2010-08-31 A (-59d) | 199d → 157d | 0% → 100% | 278d → none |  |  |
| 16111010J | N&S Access Constrctn Contract November Progress Payment | 2010-01-20 A | 2010-11-30 → 2010-09-30 A (-61d) | 219d → 178d | 0% → 100% | 278d → none |  |  |
| 16111010K | N&S Access Constrctn Contract December Progress Payment | 2010-01-20 A | 2010-12-30 → 2010-09-30 A (-91d) | 236d → 178d | 0% → 100% | 278d → none |  |  |
| 16111010N | N&S Access Constrctn Contract January Progress Payment | 2010-01-20 A | 2011-01-20 → 2010-09-30 A (-112d) | 249d → 178d | 0% → 100% | 278d → none |  |  |
| 16111012 | N&S Access Constrctn Contract Modifications | 2010-01-20 A | 2011-01-20 → 2010-09-30 A (-112d) | 249d → 178d | 0% → 100% | 278d → none |  |  |
| 16111020 | N&S Access Addition Constrctn Mngmnt FY10 | 2010-01-20 A | 2010-09-30 A |  | 0% → 100% | 278d → none |  | resources MECH DES [24.64 h]; PLANT ENG [813.01 h]; OFFICE [344.91 h]; ELEC ENG [49.27 h]; MECH ENG [24.64 h]; MECH TECH [862.28 h] → PLANT ENG [813.01 h]; OFFICE [344.91 h]; ELEC ENG [49.27 h]; MECH ENG [24.64 h]; MECH TECH [862.28 h]; MECH DES [24.64 h] |
| 16111020a | N&S Access Addition Constrctn Mngmnt FY11 | 2010-10-01 → 2010-01-20 A (-254d) | 2011-03-18 → 2010-09-30 A (-169d) | 111d → 178d | 0% → 100% | 278d → none | 16111020, 16111005 FS+10d → 16111005 FS+10d | resources MECH DES [15.36 h]; PLANT ENG [506.99 h]; OFFICE [215.09 h]; ELEC ENG [30.73 h]; MECH ENG [15.36 h]; MECH TECH [537.72 h] → MECH ENG [15.36 h]; MECH TECH [537.72 h]; MECH DES [15.36 h]; OFFICE [215.09 h]; ELEC ENG [30.73 h]; PLANT ENG [506.99 h] |
| 16111015 | N&S Access Addition Bldng Cmmssng | 2011-01-21 → 2010-09-01 A (-142d) | 2011-02-17 → 2010-09-30 A (-140d) | 20d → 21d | 0% → 100% | 278d → none | 16111010N, 16111012 → 16111010, 16111012, 16111010N |  |
| 16111025 | N&S Access Addition Beneficial Occupancy | 2011-02-18 → 2010-10-01 A (-140d) | 2011-03-18 → 2010-10-14 A (-155d) | 20d → 10d | 0% → 100% | 278d → none |  |  |
| 16111030M | N&S Access Addition Constr Compltn | 2011-03-18 → 2010-10-14 A (-155d) | 2011-03-18 → 2010-10-14 A (-155d) |  | 0% → 100% | 278d → none |  |  |
| 16111035 | Re-Baseline Actuals Adjustment | 2013-08-30 A | 2013-08-30 A |  | 0% → 100% | 20d → none | 9-130M FS+227d → none |  |
| 16112000 | Redesign N&S Access LCW Upgrades | 2010-02-02 A | 2010-06-30 → 2010-09-30 A (+92d) | 105d → 169d | 0% → 100% | 492d → none |  | resources MECH ENG [320 h]; ELEC ENG [160 h]; PLANT ENG [160 h]; SUPPLIES & MATERIALS → ELEC ENG [160 h]; PLANT ENG [160 h]; SUPPLIES & MATERIALS; MECH ENG [320 h] |
| 16112005 | N&S Access LCW Upgrades Award Contract | 2010-07-01 → 2010-10-18 A (+109d) | 2010-09-24 → 2010-12-20 A (+87d) | 60d → 44d | 0% → 100% | 492d → none |  |  |
| 16112000M | N&S Access LCW Upgrades Begin Constr | 2010-07-01 → 2010-10-26 A (+117d) | 2010-07-01 → 2010-10-26 A (+117d) |  | 0% → 100% | 492d → none | 16112000, 1241195M, 1241075M → 16112000 FS+10d, 1241075M, 1241195M |  |
| 16112010 | West Arc LCW Header installation | 2010-12-01 A | 2010-12-30 A |  | 0% → 100% | 625d → none | 16112005, 16111025 FS-70d → 16112005 FS-11d, 16111025 FS-70d |  |
| 16112020 | N&S Access LCW Upgrades Constrctn Mngmnt FY11 | 2010-12-01 A | 2011-09-30 → 2011-10-05 A (+5d) | 207d → 209.46d | 0% → 100% | 492d → none | 16112005 FS+45d → 16112005 FS-11d | resources OFFICE [236.57 h]; MECH DES [39.43 h]; MECH TECH [867.43 h]; ELEC ENG [394.29 h]; MECH ENG [1104 h]; PLANT ENG [276 h] → OFFICE [236.57 h]; ELEC ENG [394.29 h]; PLANT ENG [276 h]; MECH ENG [1104 h]; MECH TECH [867.43 h]; MECH DES [39.43 h] |
| 16112020a | N&S Access LCW Upgrades Constrctn Mngmnt FY12 | 2011-10-03 → 2010-12-01 A (-306d) | 2011-10-05 A | 3d → 210d | 0% → 100% | 492d → none | 16112020 → 16112020 FS-5d |  |
| 16112015 | N&S Access LCW Upgrades Bldng Cmmssng | 2011-08-05 → 2011-07-11 A (-25d) | 2011-09-30 → 2011-10-07 A (+7d) | 40d → 64d | 0% → 100% | 475d → none | 16112010, 1961000n FS-61d, 1961005 FS-61d → 1961005 FS-85d, 16112010, 1961000n FS-85d |  |
| 16112025 | N&S Access LCW Upgrades Beneficial Occupancy | 2011-10-03 → 2011-09-19 A (-14d) | 2011-10-28 → 2012-01-31 A (+95d) | 20d → 88d | 0% → 100% | 475d → none | 16112015 → 16112015 FS-20d |  |
| 16112035 | Re-Baseline Actuals Adjustment | 2013-08-30 A | 2013-08-30 A |  | 0% → 100% | 20d → none | 9-130M FS+227d → none |  |
| 26112012 | Redundant Cooling Towers |  |  |  |  | 56d → 249d |  | resources PROCUREMENT>$50K 69; PROCUREMENT<$50K 60 → PROCUREMENT<$50K 60; PROCUREMENT>$50K 69 |
| 26112013 | Redundant Cooling Towers Construction Management |  |  |  |  | 57d → 250d |  | resources MECH TECH [400 h]; MECH ENG [320 h]; OFFICE [80 h] → OFFICE [80 h]; MECH TECH [400 h]; MECH ENG [320 h] |
| 3 | **1.6.1.1.3 BEAM SWITCHYARD SERVICE BUILDING ADDITION** | 2010-10-01 → 2011-01-21 (+112d) |  |  |  |  |  |  |
| 16113000M | BSY Addition Begin Proc. Prep | 2010-10-01 → 2011-01-21 A (+112d) | 2010-10-01 → 2011-01-21 A (+112d) |  | 0% → 100% | 49d → none | 9-110M, 1241115M → 9-110M FS+75d, 1241115M | was named BSY Addition Begin Constr |
| 16113005 | BSY Addition Award Contract | 2010-10-01 → 2011-01-21 A (+112d) | 2011-01-04 → 2011-03-25 A (+80d) | 60d → 45d | 0% → 100% | 49d → none |  |  |
| 16113010 | BSY Addition Constrctn Contract Progress | 2011-01-05 → 2011-03-28 A (+82d) | 2011-11-15 → 2011-11-30 A (+15d) | 220d → 173d | 0% → 100% | 49d → none |  |  |
| 16113020 | BSY Addition Consrtuction Mngmnt FY11 | 2011-01-05 → 2011-03-28 A (+82d) | 2011-09-30 → 2011-11-30 A (+61d) | 188d → 172.1d | 0% → 100% | 956d → none |  | resources MECH TECH [644.57 h]; MECH DES [26.86 h]; PLANT ENG [617.71 h]; OFFICE [349.14 h]; ELEC ENG [53.71 h]; MECH ENG [53.71 h] → OFFICE [349.14 h]; ELEC ENG [53.71 h]; MECH ENG [53.71 h]; MECH TECH [644.57 h]; MECH DES [26.86 h]; PLANT ENG [617.71 h] |
| 16113020a | BSY Addition Consrtuction Mngmnt FY12 | 2011-10-03 → 2011-03-28 A (-189d) | 2012-02-21 → 2011-11-30 A (-83d) | 92d → 173d | 0% → 100% | 956d → none | 16113020 → 16113020 FS-100d | resources PLANT ENG [302.29 h]; OFFICE [170.86 h]; ELEC ENG [26.29 h]; MECH ENG [26.29 h]; MECH TECH [315.43 h]; MECH DES [13.14 h] → MECH DES [13.14 h]; PLANT ENG [302.29 h]; OFFICE [170.86 h]; ELEC ENG [26.29 h]; MECH ENG [26.29 h]; MECH TECH [315.43 h] |
| 16113015 | BSY Addition Bldng Cmmssng | 2011-11-16 → 2011-10-16 A (-31d) | 2012-01-23 → 2011-10-31 A (-84d) | 40d → 11d | 0% → 100% | 49d → none |  |  |
| 16113025 | BSY Addition Beneficial Occupancy | 2012-01-24 → 2011-12-01 A (-54d) | 2012-02-21 → 2011-12-06 A (-77d) | 20d → 4d | 0% → 100% | 49d → none |  |  |
| 16113030M | BSY Addition Constr Compltn | 2012-02-21 → 2011-12-06 A (-77d) | 2012-02-21 → 2011-12-06 A (-77d) |  | 0% → 100% | 956d → none |  |  |
| 16113012 | BSY Modify LCW Piping | 2011-11-16 → 2012-04-02 A (+138d) | 2011-12-15 → 2013-07-15 A (+578d) | 20d → 181d | 0% → 100% | 69d → none | 16113010 → 16113010, 9-120M | resources PROCUREMENT<$50K 60; MECH TECH [80 h]; MECH ENG [40 h] → MECH ENG [40 h]; PROCUREMENT<$50K 60; MECH TECH [80 h] |
| 16113035 | Re-Baseline Actuals Adjustment | 2013-08-30 A | 2013-08-30 A |  | 0% → 100% | 20d → none | 9-130M FS+227d → none |  |
| 16114035 | Re-Baseline Actuals Adjustment | 2013-08-30 A | 2013-08-30 A |  | 0% → 100% | 20d → none | 9-130M FS+227d → none |  |
| 5 | **1.6.1.1.5. N&S LINAC SERVICE BUILDING AIR CONDITIONING** | 2012-10-01 → 2012-09-10 (-21d) | 2013-11-07 → 2013-10-31 (-7d) |  |  |  |  |  |
| 16115005 | Design N&S Linac A/C | 2012-10-01 → 2012-09-10 A (-21d) | 2012-10-26 → 2013-01-17 A (+83d) | 20d → 64d | 0% → 100% | 20d → none |  |  |
| 16115010 | Design and Safety Review of N&S Linac A/C | 2012-10-29 → 2013-01-18 A (+81d) | 2012-11-09 → 2013-02-01 A (+84d) | 10d → 7d | 0% → 100% | 20d → none |  |  |
| 16115015 | Finalize Design N&S Linac A/C | 2012-11-12 → 2013-02-04 A (+84d) | 2012-11-27 → 2013-02-25 A (+90d) | 10d → 8d | 0% → 100% | 20d → none |  | resources MECH DES [40 h]; PLANT ENG [40 h]; MECH ENG [40 h]; ELEC ENG [40 h] → MECH ENG [40 h]; ELEC ENG [40 h]; MECH DES [40 h]; PLANT ENG [40 h] |
| 16115020 | N&S Linac A/C Award Const Contract | 2012-11-28 → 2013-02-11 A (+75d) | 2013-03-01 → 2013-04-15 A (+45d) | 60d → 47d | 0% → 100% | 20d → none |  |  |
| 16115030 | N&S Linac A/C Construction Management | 2013-03-04 A | 2013-08-30 A | 128d → 140d | 0% → 100% | 20d → none | 16115020 → 16115020 FS-125d |  |
| 16115025 | N&S Linac A/C Construction Contract Progress | 2013-03-04 → 2013-04-15 A (+42d) | 2013-08-30 A | 128d → 107d | 0% → 100% | 20d → none |  |  |
| 16115050 | Re-Baseline Actuals Adjustment | 2013-08-30 A | 2013-08-30 A |  | 0% → 100% | 20d → none | 9-130M FS+227d → none |  |
| 26115025 | N&S Linac A/C Construction Contract Progress | 2013-09-03 A | 2013-10-24 → 2013-09-16 A (-38d) |  | 0% → 100% | 523d → none |  |  |
| 26115030 | N&S Linac A/C Construction Management FY13 | 2013-09-03 A | 2013-09-30 A |  | 0% → 100% | 523d → none |  |  |
| 26115035 | N&S Linac A/C Building Commissioning | 2013-10-25 → 2013-09-18 A (-37d) | 2013-10-31 → 2013-10-30 A (-1d) |  | 0% → 100% | 523d → none |  |  |
| 26115040 | N&S Linac A/C Beneficial Occupancy | 2013-11-01 → 2013-09-18 A (-44d) | 2013-11-07 → 2013-09-27 A (-41d) |  | 0% → 100% | 523d → none |  |  |
| 26115030a | N&S Linac A/C Construction Management FY14 | 2013-10-01 A | 2013-11-07 → 2013-10-30 A (-8d) |  | 0% → 100% | 523d → none | 26115025 FS-38d, 26115030 → 26115030 |  |
| 26115045M | N&S Linac A/C Construction Complete | 2013-11-07 → 2013-10-31 A (-7d) | 2013-11-07 → 2013-10-31 A (-7d) |  | 0% → 100% | 523d → none |  |  |
| 2 | **1.6.1.2 SITEWORK** | 2010-01-21 → 2009-11-09 (-73d) |  |  |  |  |  |  |
| 2 | **1.6.1.2.2 ELECTRICAL DISTRIBUTION - N&S LINAC** | 2010-01-21 → 2009-11-09 (-73d) |  |  |  |  |  |  |
| 16122005 | N&S Linac Award Contract (ED) | 2010-10-01 → 2009-11-09 A (-326d) | 2011-01-04 → 2010-01-21 A (-348d) | 60d → 45d | 0% → 100% | 342d → none | 16122000M → 16122000M FS-1000d |  |
| 16122000M | Electrical Distrbtn N&S Linac Begin Constr | 2010-10-01 → 2009-12-01 A (-304d) | 2010-10-01 → 2009-12-01 A (-304d) |  | 0% → 100% | 342d → none | 1241195M, 9-110M → 1241195M |  |
| 16122010 | N&S Linac Constrctn Contract Progress (ED) May Progress Payment | 2010-01-21 A | 2010-05-28 → 2010-06-30 A (+33d) | 91d → 113d | 0% → 100% | 329d → none |  |  |
| 16122010A | N&S Linac Constrctn Contract Progress (ED) June Progress Payment | 2010-01-21 A | 2010-06-30 → 2010-07-28 A (+28d) | 113d → 132d | 0% → 100% | 329d → none |  |  |
| 16122010B | N&S Linac Constrctn Contract Progress (ED) July Progress Payment | 2010-01-21 A | 2010-07-30 → 2010-08-31 A (+32d) | 134d → 156d | 0% → 100% | 329d → none |  |  |
| 16122010C | N&S Linac Constrctn Contract Progress (ED) August Progress Payment | 2010-01-21 A | 2010-08-31 → 2010-09-30 A (+30d) | 156d → 177d | 0% → 100% | 329d → none |  |  |
| 16122010D | N&S Linac Constrctn Contract Progress (ED)September Progress Payment | 2010-01-21 A | 2010-09-30 → 2010-10-08 A (+8d) | 177d → 183d | 0% → 100% | 329d → none |  |  |
| 16122012 | N&S Linac Constrctn Contract Modifications (ED) | 2010-01-21 A | 2010-09-30 → 2010-10-25 A (+25d) | 177d → 194d | 0% → 100% | 329d → none | 16122010D FS-177d → 16122010D FS-177d, 16122010 FS-113d |  |

| ID | Task | Start | Finish | Duration | Complete | Total float | Predecessors | Other |
| --- | --- | --- | --- | --- | --- | --- | --- | --- |
| 16122020 | N&S Linac Constrctn Mngmnt (ED) | 2010-01-21 A | 2010-09-24 → 2010-10-25 A (+31d) | 173d → 194d | 0% → 100% | 1300d → none |  | resources MECH TECH [200 h]; MECH DES [40 h]; ELEC ENG [440 h]; OFFICE [120 h] → ELEC ENG [440 h]; MECH TECH [200 h]; MECH DES [40 h]; OFFICE [120 h] |
| 16122015 | N&S Linac Bldng Cmmssng (ED) | 2010-10-01 → 2010-09-01 A (-30d) | 2010-11-29 → 2010-10-25 A (-35d) | 40d → 38d | 0% → 100% | 329d → none | 16122010D, 16122012, 16122010 → 16122012 FS-6d, 16122010, 16122010D FS-6d |  |
| 16122025 | N&S Linac Beneficial Occupancy (ED) | 2010-11-30 → 2010-10-18 A (-43d) | 2011-01-04 → 2010-10-25 A (-71d) | 20d → 6d | 0% → 100% | 329d → none |  |  |
| 16122030M | Electrical Distrbtn N&S Linac Constr Comp | 2011-01-04 → 2010-10-25 A (-71d) | 2011-01-04 → 2010-10-25 A (-71d) |  | 0% → 100% | 1236d → none |  |  |
| 16122035 | Re-Baseline Actuals Adjustment | 2013-08-30 A | 2013-08-30 A |  | 0% → 100% | 20d → none | 9-130M FS+227d → none |  |
| 2 | **1.6.2 CHL** | 2008-12-12 → 2008-12-15 (+3d) |  |  |  |  |  |  |
| 1 | **1.6.2.1 CHL BUILDING ADDITION** | 2008-12-12 → 2008-12-15 (+3d) |  |  |  |  |  |  |
| 1621005 | Prcrmnt Prep for CHL Addition to Award Contract | 2009-01-02 → 2008-12-15 A (-18d) | 2009-01-16 → 2008-12-19 A (-28d) | 11d → 5d | 0% → 100% | 72d → none |  |  |
| 1621009 | CHL Addition Constrctn Contract Award (BONDS) | 2008-12-12 → 2009-01-05 A (+24d) | 2008-12-18 → 2009-01-09 A (+22d) |  | 0% → 100% | 141d → none | 3C-04M FS-20d, 1621005 FS-20d → 1621005 FS-12d, 3C-04M FS-12d | resources PROCUREMENT<$50K 60; PROCUREMENT>$50K 69 → PROCUREMENT>$50K 69; PROCUREMENT<$50K 60 |
| 1621015 | CHL Addition Constrctn Mngmnt FY09 | 2008-12-12 → 2009-01-13 A (+32d) | 2009-09-30 A | 198d → 181d | 0% → 100% | 334d → none | 1621005 FS-20d → 1621005 FS-12d | resources ELEC ENG [29.33 h]; MECH ENG [29.33 h]; PLANT ENG [674.67 h]; OFFICE [176 h]; MECH TECH [1114.67 h]; MECH DES [29.33 h] → OFFICE [176 h]; MECH TECH [1114.67 h]; MECH ENG [29.33 h]; MECH DES [29.33 h]; ELEC ENG [29.33 h]; PLANT ENG [674.67 h] |
| 1621010 | CHL Addition Constrctn Contract Progress | 2008-12-19 → 2009-02-02 A (+45d) | 2009-12-08 → 2010-04-26 A (+139d) | 240d → 307d | 0% → 100% | 141d → none |  | resources PROCUREMENT<$50K 60 NO ESCALATION; PROCUREMENT>$50K 69 NO ESCALATION → PROCUREMENT>$50K 69 NO ESCALATION; PROCUREMENT<$50K 60 NO ESCALATION |
| 1621020 | CHL Addition A/E Supprt | 2008-12-12 → 2009-02-02 A (+52d) | 2010-01-21 → 2010-09-15 A (+237d) | 270d → 406d | 0% → 100% | 334d → none | 1621005 FS-20d → 1621005 FS-12d | resources PROCUREMENT<$50K 60 NO ESCALATION; PROCUREMENT>$50K 69 NO ESCALATION → PROCUREMENT>$50K 69 NO ESCALATION; PROCUREMENT<$50K 60 NO ESCALATION |
| 1621011LOE | PPI Adjustment FY09 | 2009-06-01 A | 2009-09-30 A |  | 0% → 100% | 575d → none |  |  |
| 1621011LOEb | PPI Adjustment FY10 | 2009-10-01 A | 2009-12-08 A |  | 0% → 100% | 575d → none |  |  |
| 1621015b | CHL Addition Constrctn Mngmnt FY10 | 2009-10-01 A | 2010-01-21 A |  | 0% → 100% | 334d → none |  | resources MECH TECH [405.33 h]; MECH DES [10.67 h]; ELEC ENG [10.67 h]; MECH ENG [10.67 h]; PLANT ENG [245.33 h]; OFFICE [64 h] → ELEC ENG [10.67 h]; PLANT ENG [245.33 h]; OFFICE [64 h]; MECH ENG [10.67 h]; MECH DES [10.67 h]; MECH TECH [405.33 h] |
| 1621025 | CHl Addition Cmmssng | 2009-12-09 → 2010-04-26 A (+138d) | 2010-01-13 → 2010-05-10 A (+117d) | 20d → 11d | 0% → 100% | 575d → none |  |  |
| 1621030 | CHL Addition Beneficial Occupancy | 2010-01-14 → 2010-04-26 A (+102d) | 2010-01-21 → 2010-05-14 A (+113d) | 5d → 15d | 0% → 100% | 1472d → none | 1621025 → 1621025 FS-15d |  |
| 1621035 | Re-Baseline Actuals Adjustment | 2013-08-30 A | 2013-08-30 A |  | 0% → 100% | 20d → none | 9-130M FS+227d → none |  |
| 2 | **1.6.2.2 SITEWORK** | 2009-10-01 → 2010-02-01 (+123d) |  |  |  |  |  |  |
| 1622000 | Re-Baseline Actuals Adjustment | 2013-08-30 A | 2013-08-30 A |  | 0% → 100% | 20d → none | 9-130M FS+227d → none |  |
| 2 | **1.6.2.2.2 ELECTRICAL DISTRIBUTION** | 2009-10-01 → 2010-02-02 (+124d) | 2011-05-27 → 2011-10-12 (+138d) |  |  |  |  |  |
| 16222000 | Redesign CHL Utilities Upgrades | 2010-02-01 → 2010-02-02 A (+1d) | 2010-04-13 → 2010-03-22 A (-22d) | 51d → 34d | 0% → 100% | 23d → none |  | resources ELEC ENG [120 h]; PLANT ENG [40 h]; PROCUREMENT<$50K 60; PROCUREMENT>$50K 69; MECH ENG [240 h] → MECH ENG [240 h]; ELEC ENG [120 h]; PLANT ENG [40 h]; PROCUREMENT>$50K 69; PROCUREMENT<$50K 60 |
| 16222007 | Elect Distrbtn Original Labor | 2009-10-01 → 2010-02-02 A (+124d) | 2010-04-14 → 2010-05-14 A (+30d) | 130d → 73d | 0% → 100% | 62d → none |  |  |
| 16222000M | Electrical Distrbtn Post Solicitation | 2009-10-01 → 2010-03-25 A (+175d) | 2009-10-01 → 2010-03-25 A (+175d) |  | 0% → 100% | 62d → none |  | was named Electrical Distrbtn Begin Constr |
| 16222005 | Elect Distrbtn Award Contract | 2010-04-14 → 2010-03-25 A (-20d) | 2010-06-09 → 2010-05-17 A (-23d) | 40d → 38d | 0% → 100% | 23d → none |  |  |
| 16222032 | Elect Distrbtn 40 MVA Switchgear Modification Labor Original | 2010-02-01 → 2010-06-01 A (+120d) | 2010-05-28 → 2010-06-28 A (+31d) | 84d → 20d | 0% → 100% | 270d → none |  | resources MECH TECH [118.59 h]; ELEC ENG [138.35 h]; OFFICE [39.53 h] → ELEC ENG [138.35 h]; OFFICE [39.53 h]; MECH TECH [118.59 h] |
| 16222009 | CHL Utility Upgrades Modifications | 2010-06-10 → 2010-07-01 A (+21d) | 2011-04-29 → 2011-05-31 A (+32d) | 220d → 226d | 0% → 100% | 23d → none |  |  |
| 16222010 | CHL Utility Upgrades Contract Progress July 2010 | 2010-06-10 → 2010-07-01 A (+21d) | 2010-07-30 A | 36d → 21d | 0% → 100% | 23d → none |  | resources PROCUREMENT>$50K 69 NO ESCALATION; PROCUREMENT<$50K 60 NO ESCALATION → PROCUREMENT<$50K 60 NO ESCALATION; PROCUREMENT>$50K 69 NO ESCALATION |
| 16222010A | CHL Utility Upgrades Contract Progress August 2010 | 2010-06-10 → 2010-07-01 A (+21d) | 2010-08-31 → 2010-07-30 A (-32d) | 58d → 21d | 0% → 100% | 23d → none |  |  |
| 16222010B | CHL Utility Upgrades Contract Progress September 2010 | 2010-06-10 → 2010-07-01 A (+21d) | 2010-09-30 → 2010-07-30 A (-62d) | 79d → 21d | 0% → 100% | 23d → none |  |  |
| 16222010C | CHL Utility Upgrades Contract Progress October 2010 | 2010-06-10 → 2010-07-01 A (+21d) | 2010-10-29 → 2010-07-30 A (-91d) | 100d → 21d | 0% → 100% | 23d → none |  |  |
| 16222010D | CHL Utility Upgrades Contract Progress November 2010 | 2010-06-10 → 2010-07-01 A (+21d) | 2010-11-30 → 2010-09-30 A (-61d) | 120d → 64d | 0% → 100% | 23d → none |  |  |
| 16222010F | CHL Utility Upgrades Contract Progress December 2010 | 2010-06-10 → 2010-07-01 A (+21d) | 2010-12-30 → 2010-11-22 A (-38d) | 137d → 101d | 0% → 100% | 23d → none |  |  |
| 16222010G | CHL Utility Upgrades Contract Progress January 2011 | 2010-06-10 → 2010-07-01 A (+21d) | 2011-01-31 → 2010-12-31 A (-31d) | 157d → 123d | 0% → 100% | 23d → none |  | was named CHL Utility Upgrades Contract Progress January 2010 |
| 16222010H | CHL Utility Upgrades Contract Progress February 2011 | 2010-06-10 → 2010-07-01 A (+21d) | 2011-02-28 A | 176d → 161d | 0% → 100% | 23d → none |  | was named CHL Utility Upgrades Contract Progress February 2010 |
| 16222010J | CHL Utility Upgrades Contract Progress March 2011 | 2010-06-10 → 2010-07-01 A (+21d) | 2011-03-31 → 2011-05-10 A (+40d) | 199d → 212d | 0% → 100% | 23d → none |  | was named CHL Utility Upgrades Contract Progress March 2010 |
| 16222010K | CHL Utility Upgrades Contract Progress April 2011 | 2010-06-10 → 2010-07-01 A (+21d) | 2011-04-29 → 2011-08-31 A (+124d) | 220d → 291d | 0% → 100% | 23d → none |  | was named CHL Utility Upgrades Contract Progress April 2010 |
| 16222015 | CHL Utility Upgrades Mngmnt FY10 | 2010-06-10 → 2010-07-01 A (+21d) | 2010-09-30 → 2011-05-27 A (+239d) | 79d → 224.88d | 0% → 100% | 23d → none |  | resources MECH DES [26.33 h]; MECH TECH [434.96 h]; OFFICE [92.32 h]; ELEC ENG [59.79 h]; MECH ENG [276.5 h]; PLANT ENG [13.17 h] → MECH ENG [276.5 h]; MECH DES [26.33 h]; MECH TECH [434.96 h]; OFFICE [92.32 h]; ELEC ENG [59.79 h]; PLANT ENG [13.17 h] |
| 16222015a | CHL Utility Upgrades Mngmnt FY11 | 2010-10-01 → 2010-07-01 A (-92d) | 2011-05-27 A | 161d → 225d | 0% → 100% | 23d → none | 16222015 → 16222015 FS-161d | resources MECH DES [53.67 h]; MECH TECH [886.45 h]; OFFICE [188.15 h]; ELEC ENG [121.86 h]; MECH ENG [563.5 h]; PLANT ENG [26.83 h] → PLANT ENG [26.83 h]; MECH ENG [563.5 h]; MECH DES [53.67 h]; MECH TECH [886.45 h]; OFFICE [188.15 h]; ELEC ENG [121.86 h] |
| 16222020 | CHL Utility Upgrades A/E Supprt | 2010-06-10 → 2010-07-01 A (+21d) | 2011-05-27 → 2011-05-23 A (-4d) | 240d → 221d | 0% → 100% | 23d → none |  |  |
| 16222025 | CHL Utility Upgrades Cmmssng | 2011-04-04 → 2011-01-03 A (-91d) | 2011-04-29 → 2011-09-30 A (+154d) | 20d → 189d | 0% → 100% | 23d → none | 16222009 FS-20d, 16222010K FS-20d → 16222010K FS-60d, 16222009 FS-60d |  |
| 16222030 | CHL Utility Upgrades Beneficial Occupancy | 2011-05-02 → 2011-10-01 A (+152d) | 2011-05-27 → 2011-10-12 A (+138d) | 20d → 8d | 0% → 100% | 23d → none |  |  |
| 16222035M | CHL Utility Upgrades Complete | 2011-05-27 → 2011-10-12 A (+138d) | 2011-05-27 → 2011-10-12 A (+138d) |  | 0% → 100% | 23d → none | 16222030, 16222032, 16223007, 16222015a, 16222020, 16223005 → 16222030 FS+10d, 16222020, 16223007, 16222032, 16222015a, 16223005 |  |
| 3 | **1.6.2.2.3 COOLING WATER** | 2009-10-01 → 2010-02-01 (+123d) | 2010-02-03 → 2010-06-01 (+118d) |  |  |  |  |  |
| 16223007 | Cooling Water Tower Original Labor | 2009-10-01 → 2010-02-01 A (+123d) | 2010-02-02 A | 80d → 2d | 0% → 100% | 352d → none |  | resources PROCUREMENT>$50K 69; MECH ENG [80 h] → MECH ENG [80 h]; PROCUREMENT>$50K 69 |
| 16223008 | Reverse Entry per CR10-021 P6 5% Spread Fix | 2010-02-03 → 2010-02-01 A (-2d) | 2010-02-03 → 2010-02-02 A (-1d) | 1d → 2d | 0% → 100% | 167d → none |  |  |
| 16223000M | Cooling Water Tower Post Solicitation | 2009-10-01 → 2010-03-25 A (+175d) | 2009-10-01 → 2010-03-25 A (+175d) |  | 0% → 100% | 352d → none | 9-100M, 16222000 FS-130d → 16222000 FS-130d, 9-100M FS+120d | was named Cooling Water Tower Begin Constr |
| 16223005 | Cooling Water Tower Award Contract | 2009-10-15 → 2010-03-25 A (+161d) | 2010-02-02 → 2010-06-01 A (+119d) | 70d → 48d | 0% → 100% | 352d → none | 16223000M FS+10d → 16223000M |  |
| 3 | **1.6.3 HALL D** | 2009-02-02 → 2007-10-01 (-490d) |  |  |  |  |  |  |
| 3 | **1.6.3.3 CONSTRUCTION** | 2009-02-02 → 2007-10-01 (-490d) |  |  |  |  |  |  |
| 1 | **1.6.3.3.1 PHASE 1** | 2009-02-02 → 2007-10-01 (-490d) |  |  |  |  |  |  |
| 16331005 | H-D Complex P- I Award Contract (BONDS) | 2009-02-02 → 2007-10-01 A (-490d) | 2009-02-02 → 2009-02-12 A (+10d) | 1d → 336d | 0% → 100% | 62d → none | 1243050b, 1243050, 1243055, 16331000M, 1243045 → 16331000M, 1243050b, 1243050, 1243045 FS-40d, 1243055 |  |
| 16331020 | H-D Complex P- I Constrctn Mngmnt Labor FY09 | 2009-02-03 → 2009-01-05 A (-29d) | 2009-09-30 A | 168d → 187d | 0% → 100% | 1402d → none |  | resources OFFICE [65.03 h]; MECH TECH [541.94 h]; ELEC ENG [43.35 h]; MECH ENG [21.68 h]; MECH DES [43.35 h]; PLANT ENG [173.42 h] → MECH TECH [541.94 h]; OFFICE [65.03 h]; ELEC ENG [43.35 h]; MECH ENG [21.68 h]; MECH DES [43.35 h]; PLANT ENG [173.42 h] |
| 16331020c | H-D Complex P- I Constrctn Mngmnt Procurement | 2009-02-03 → 2009-01-05 A (-29d) | 2010-04-30 A | 310d → 330d | 0% → 100% | 1402d → none |  |  |
| 16331000M | H-D Complex P- I Begin Constr | 2009-02-02 → 2009-01-21 A (-12d) | 2009-02-02 → 2009-01-21 A (-12d) |  | 0% → 100% | 62d → none |  |  |
| 16331025 | H-D Complex P- I A-E Constrctn Supprt | 2009-02-03 → 2009-02-11 A (+8d) | 2010-04-30 → 2010-12-28 A (+242d) | 310d → 466d | 0% → 100% | 1402d → none |  |  |
| 16331010 | H-D Complex P- I Constrctn Contract Progress August 09 | 2009-02-03 → 2009-08-06 A (+184d) | 2009-08-31 → 2009-10-15 A (+45d) | 147d → 50d | 0% → 100% | 253d → none |  | resources PROCUREMENT>$50K 69; PROCUREMENT<$50K 60 → PROCUREMENT<$50K 60; PROCUREMENT>$50K 69 |
| 16331010A | H-D Complex P- I Constrctn Contract Progress September 09 | 2009-02-03 → 2009-08-06 A (+184d) | 2009-09-30 → 2009-11-30 A (+61d) | 168d → 80d | 0% → 100% | 232d → none | 9-090M FS+80d → 9-090M FS+80d, 16331010 FS-61d |  |
| 16331010B | H-D Complex P- I Constrctn Contract Progress October 09 | 2009-02-03 → 2009-08-06 A (+184d) | 2009-10-30 → 2010-01-29 A (+91d) | 190d → 117d | 0% → 100% | 210d → none | 9-090M FS+80d → 16331010A FS-80d |  |
| 16331010C | H-D Complex P- I Constrctn Contract Progress November 09 | 2009-02-03 → 2009-08-06 A (+184d) | 2009-11-30 → 2010-02-26 A (+88d) | 209d → 136d | 0% → 100% | 191d → none | 9-090M FS+80d → 16331010B FS-99d |  |
| 16331010D | H-D Complex P- I Constrctn Contract Progress December 09 | 2009-02-03 → 2009-08-06 A (+184d) | 2009-12-30 → 2010-03-31 A (+91d) | 226d → 159d | 0% → 100% | 174d → none | 9-090M FS+80d → 16331010C FS-118d |  |
| 16331010F | H-D Complex P- I Constrctn Contract Progress January 10 | 2009-02-03 → 2009-08-06 A (+184d) | 2010-01-29 → 2010-04-26 A (+87d) | 246d → 177d | 0% → 100% | 154d → none | 9-090M FS+80d → 16331010D FS-141d |  |
| 16331010G | H-D Complex P- I Constrctn Contract Progress February 10 | 2009-02-03 → 2009-08-06 A (+184d) | 2010-02-26 → 2010-05-10 A (+73d) | 265d → 187d | 0% → 100% | 135d → none | 9-090M FS+80d → 16331010F FS-163d |  |
| 16331010H | H-D Complex P- I Constrctn Contract Progress March 10 | 2009-02-03 → 2009-08-06 A (+184d) | 2010-03-31 → 2010-05-17 A (+47d) | 288d → 192d | 0% → 100% | 112d → none | 9-090M FS+80d → 16331010G FS-183d |  |
| 16331010J | H-D Complex P- I Constrctn Contract Progress April 10 | 2009-02-03 → 2009-08-06 A (+184d) | 2010-04-30 → 2010-07-26 A (+87d) | 310d → 240d | 0% → 100% | 90d → none | 9-090M FS+80d → 16331010H FS-205d |  |
| 16331010K | H-D Complex P- I Constrctn Contract Progress May 10 | 2009-02-03 → 2009-08-06 A (+184d) | 2010-05-28 → 2010-08-31 A (+95d) | 330d → 266d | 0% → 100% | 70d → none | 9-090M FS+80d → 16331010J FS-226d |  |
| 16331010L | H-D Complex P- I Constrctn Contract Progress June 10 | 2009-02-03 → 2009-08-06 A (+184d) | 2010-06-30 → 2010-10-29 A (+121d) | 352d → 308d | 0% → 100% | 48d → none | 9-090M FS+80d → 16331010K FS-248d |  |
| 16331010N | H-D Complex P- I Constrctn Contract Progress July 10 Original | 2009-02-03 → 2009-08-06 A (+184d) | 2010-06-30 → 2010-10-29 A (+121d) | 352d → 308d | 0% → 100% | 19d → none | 9-090M FS+80d → 16331010L FS-269d |  |
| 16331010N5 | H-D Complex P- I Constrctn Contract Progress July 10 Revised Delivery per CR10-061 | 2009-02-03 → 2009-08-06 A (+184d) | 2010-07-27 → 2010-10-29 A (+94d) | 370d → 308d | 0% → 100% | 1d → none |  |  |
| 16331010P | H-D Complex P- I Constrctn Contract Progress August 10 | 2009-02-03 → 2009-08-06 A (+184d) | 2010-08-31 → 2010-11-22 A (+83d) | 395d → 324d | 0% → 100% | 1d → none |  |  |

| ID | Task | Start | Finish | Duration | Complete | Total float | Predecessors | Other |
| --- | --- | --- | --- | --- | --- | --- | --- | --- |
| 16331010Q | H-D Complex P- I Constrctn Contract Progress September 10 | 2009-02-03 → 2009-08-06 A (+184d) | 2010-09-30 → 2010-11-22 A (+53d) | 416d → 324d | 0% → 100% | 1d → none |  |  |
| 16331010R | H-D Complex P- I Constrctn Contract Progress October 10 | 2009-02-03 → 2009-08-06 A (+184d) | 2010-10-29 → 2010-11-22 A (+24d) | 437d → 324d | 0% → 100% | 1d → none |  |  |
| 16331010S | H-D Complex P- I Constrctn Contract Progress November 10 | 2009-02-03 → 2009-08-06 A (+184d) | 2010-11-24 → 2010-12-28 A (+34d) | 455d → 343d | 0% → 100% | 1d → none |  |  |
| 16331012 | H-D Complex P- I ARRA Funds | 2009-08-06 A | 2010-07-27 A |  | 0% → 100% | 1342d → none |  |  |
| 16331011 | H-D Complex P- I Constrctn Contract Modifications | 2009-02-03 → 2009-09-01 A (+210d) | 2010-07-27 → 2010-12-28 A (+154d) | 370d → 325d | 0% → 100% | 90d → none |  | resources PROCUREMENT>$50K 69 NO ESCALATION; PROCUREMENT>$50K 69; PROCUREMENT>$50K 69 NO ESCALATION FY10 → PROCUREMENT>$50K 69 NO ESCALATION FY10; PROCUREMENT>$50K 69 NO ESCALATION; PROCUREMENT>$50K 69 |
| 16331020b | H-D Complex P- I Constrctn Mngmnt Labor FY10 | 2009-10-01 A | 2010-04-30 A | 142d → 141.07d | 0% → 100% | 1402d → none |  |  |
| 16331013 | H-D Complex P- I Floor Slab Contract Modification | 2010-04-01 A | 2010-04-30 A |  | 0% → 100% | 90d → none |  | resources PROCUREMENT>$50K 69 NO ESCALATION; PROCUREMENT<$50K 60 → PROCUREMENT<$50K 60; PROCUREMENT>$50K 69 NO ESCALATION |
| 16331015 | H-D Complex P- I Cmmssng Original | 2010-05-03 A | 2010-06-28 → 2010-07-19 A (+21d) | 40d → 54d | 0% → 100% | 90d → none | 16331011 FS-60d, 16331010G, 16331010L FS-42d, 16331010A, 16331010K FS-20d, 16331010N FS-60d, 16331010D, 16331010C, 16331010H, 16331010B, 16331013, 16331010F, 16331010J, 16331010 → 16331010B, 16331010J, 16331010C, 16331010D, 16331010G, 16331013 FS-70d, 16331010F, 16331010K FS-20d, 16331010A, 16331010, 16331010L FS-42d, 16331011 FS-80d, 16331010N FS-90d, 16331010H |  |
| 16331014 | H-D Complex P- I Settlement Agreement and Release | 2010-07-01 A | 2010-07-30 → 2010-07-23 A (-7d) | 21d → 16d | 0% → 100% | 27d → none |  |  |
| 16331017 | Reverse Entry Per CR10-061 | 2010-07-01 A | 2010-07-01 → 2010-07-26 A (+25d) | 1d → 17d | 0% → 100% | 63d → none |  | resources PROCUREMENT<$50K 60 NO ESCALATION; PROCUREMENT>$50K 69 NO ESCALATION; PLANT ENG [-4 h] → PLANT ENG [-4 h]; PROCUREMENT<$50K 60 NO ESCALATION; PROCUREMENT>$50K 69 NO ESCALATION |
| 16331030 | H-D Complex P- I Beneficial Occupancy Original | 2010-06-29 → 2010-07-01 A (+2d) | 2010-06-30 → 2010-07-26 A (+26d) | 2d → 17d | 0% → 100% | 104d → none | 16331010N FS-22d, 16331010N5 FS-22d, 16331010G, 16331010L FS-2d, 16331010B, 16331010H, 16331010J, 16331010D, 16331010K, 16331015 FS-4d, 16331010A, 16331010F, 16331010, 16331010C → 16331010A, 16331010C, 16331010G, 16331010B, 16331010N FS-22d, 16331010D, 16331010J, 16331015 FS-40d, 16331010N5 FS-22d, 16331010H, 16331010K FS-55d, 16331010L FS-75d, 16331010F, 16331010 |  |
| 16331016 | H-D Complex P- I Cmmssng Revised Date per CR10-061 | 2010-09-01 → 2010-09-14 A (+13d) | 2010-10-27 → 2010-11-22 A (+26d) | 40d → 50d | 0% → 100% | 5d → none | 16331013, 16331010F, 16331011 FS-60d, 16331010D, 16331010K, 16331010A, 16331014, 16331010, 16331010G, 16331010H, 16331010R FS-42d, 16331010B, 16331010J, 16331010L, 16331010C → 16331010B, 16331010C, 16331010K, 16331010R FS-62d, 16331010A, 16331011 FS-60d, 16331010H, 16331014, 16331010D, 16331010F, 16331010L, 16331010G, 16331013, 16331010, 16331010J |  |
| 16331032 | H-D Complex P- I Beneficial Occupancy Revised Date per CR10-061 | 2010-10-28 → 2010-12-23 A (+56d) | 2010-11-24 → 2010-12-28 A (+34d) | 20d → 8d | 0% → 100% | 1d → none |  |  |
| 16331035M | H-D Complex P- I Constr Comp | 2010-11-24 → 2010-12-28 A (+34d) | 2010-11-24 → 2010-12-28 A (+34d) |  | 0% → 100% | 1257d → none |  |  |
| 16331040 | Re-Baseline Actuals Adjustment | 2013-08-30 A | 2013-08-30 A |  | 0% → 100% | 20d → none | 9-130M FS+227d → none |  |
| 16332005 | H-D Complex P- II Award Contract | 2009-08-06 A | 2009-08-06 A |  | 0% → 100% | 6d → none |  |  |
| 16332010 | H-D Complex P- II Contract Progress June 2010 Progress Payment | 2009-08-06 A | 2010-06-30 A |  | 0% → 100% | 6d → none |  |  |
| 16332010B | H-D Complex P- II Contract Progress July 2010 Progress Payment | 2009-08-06 A | 2010-07-30 A |  | 0% → 100% | 6d → none |  |  |
| 16332010C | H-D Complex P- II Contract Progress August 2010 Progress Payment | 2009-08-06 A | 2010-08-31 → 2010-07-30 A (-32d) | 266d → 244d | 0% → 100% | 6d → none |  |  |
| 16332010D | H-D Complex P- II Contract Progress September 2010 Progress Payment | 2009-08-06 A | 2010-09-30 → 2010-07-30 A (-62d) | 287d → 244d | 0% → 100% | 6d → none |  |  |
| 16332010F | H-D Complex P- II Contract Progress October 2010 Progress Payment | 2009-08-06 A | 2010-10-29 → 2010-09-30 A (-29d) | 308d → 287d | 0% → 100% | 6d → none |  |  |
| 16332010G | H-D Complex P- II Contract Progress November 2010 Progress Payment | 2009-08-06 A | 2010-11-30 → 2010-10-25 A (-36d) | 328d → 304d | 0% → 100% | 6d → none |  |  |
| 16332010H | H-D Complex P- II Contract Progress December 2010 Progress Payment | 2009-08-06 A | 2010-12-30 → 2010-10-25 A (-66d) | 345d → 304d | 0% → 100% | 6d → none |  |  |
| 16332010J | H-D Complex P- II Contract Progress January 2011 Progress Payment | 2009-08-06 A | 2011-01-31 → 2010-11-22 A (-70d) | 365d → 324d | 0% → 100% | 6d → none |  |  |
| 16332010K | H-D Complex P- II Contract Progress February 2011 Progress Payment | 2009-08-06 A | 2011-02-28 → 2010-11-22 A (-98d) | 384d → 324d | 0% → 100% | 6d → none |  |  |
| 16332010N | H-D Complex P- II Contract Progress March 2011 Progress Payment | 2009-08-06 A | 2011-03-31 → 2010-12-31 A (-90d) | 407d → 346d | 0% → 100% | 6d → none |  |  |
| 16332010P | H-D Complex P- II Contract Progress April 2011 Progress Payment | 2009-08-06 A | 2011-04-29 → 2011-02-25 A (-63d) | 428d → 383d | 0% → 100% | 6d → none |  |  |
| 16332010Q | H-D Complex P- II Contract Progress May 2011 Progress Payment | 2009-08-06 A | 2011-05-31 → 2011-05-23 A (-8d) | 449d → 444d | 0% → 100% | 6d → none |  |  |
| 16332010R | H-D Complex P- II Contract Progress June 2011 Progress Payment | 2009-08-06 A | 2011-06-30 → 2011-05-31 A (-30d) | 471d → 449d | 0% → 100% | 6d → none |  |  |
| 16332010S | H-D Complex P- II Contract Progress July 2011 Progress Payment | 2009-08-06 A | 2011-07-29 A |  | 0% → 100% | 6d → none |  |  |
| 16332010T | H-D Complex P- II Contract Progress August 2011 Progress Payment | 2009-08-06 A | 2011-08-31 → 2011-08-30 A (-1d) | 514d → 513d | 0% → 100% | 6d → none |  |  |
| 16332010U | H-D Complex P- II Contract Progress September 2011 Progress Payment | 2009-08-06 A | 2011-09-30 → 2011-10-21 A (+21d) | 535d → 550d | 0% → 100% | 6d → none |  |  |
| 16332010V | H-D Complex P- II Contract Progress October 2011 Progress Payment | 2009-08-06 A | 2011-10-31 → 2012-01-31 A (+92d) | 556d → 613d | 0% → 100% | 6d → none |  |  |
| 16332000M | H-D Complex P- II Begin Constr | 2010-01-05 → 2010-01-22 A (+17d) | 2010-01-05 → 2010-01-22 A (+17d) |  | 0% → 100% | 87d → none | 9-100M FS+60d → 9-100M FS+108d |  |
| 16332008 | H-D Complex P- II Notice to Proceed | 2010-01-05 → 2010-01-22 A (+17d) | 2010-02-02 → 2010-01-29 A (-4d) | 20d → 6d | 0% → 100% | 87d → none |  |  |
| 16332011 | H-D Complex & Cryo Plant P- II Contract Modifications | 2010-02-03 A | 2011-04-18 → 2011-11-03 A (+199d) | 300d → 440d | 0% → 100% | 97d → none |  |  |
| 16332012 | H-D Complex P- II ARRA Funds | 2010-02-03 A | 2011-04-18 A |  | 0% → 100% | 97d → none |  |  |
| 16332020 | H-D Complex P- II Constrctn Mngmnt Labor FY10 | 2010-02-03 A | 2010-09-30 → 2011-08-10 A (+314d) | 168d → 379.23d | 0% → 100% | 1084d → none |  | resources MECH TECH [442.11 h]; MECH DES [123.79 h]; PLANT ENG [194.53 h]; OFFICE [88.42 h]; ELEC ENG [53.05 h]; MECH ENG [123.79 h] → MECH ENG [123.79 h]; MECH TECH [442.11 h]; MECH DES [123.79 h]; PLANT ENG [194.53 h]; OFFICE [88.42 h]; ELEC ENG [53.05 h] |
| 16332020b | H-D Complex P- II Constrctn Mngmnt Labor FY11 | 2010-10-01 → 2010-02-03 A (-240d) | 2011-08-10 A | 212d → 379.09d | 0% → 100% | 1084d → none | 16332020 → 16332020 FS-212d | resources MECH TECH [557.89 h]; MECH DES [156.21 h]; PLANT ENG [245.47 h]; OFFICE [111.58 h]; ELEC ENG [66.95 h]; MECH ENG [156.21 h] → MECH ENG [156.21 h]; MECH TECH [557.89 h]; MECH DES [156.21 h]; PLANT ENG [245.47 h]; OFFICE [111.58 h]; ELEC ENG [66.95 h] |
| 16332020ba | H-D Complex P- II Constrctn Mngmnt Labor Procurement | 2010-02-03 A | 2011-08-10 A |  | 0% → 100% | 1084d → none |  | was named H-D Complex P- II Constrctn Mngmnt Procurement |
| 16332025 | H-D Complex P- II A-E Constrctn Supprt | 2010-02-03 A | 2011-08-10 A |  | 0% → 100% | 1084d → none |  |  |
| 16332010A | H-D Complex P- II Contract Progress 2010 ETC FY10 | 2010-03-01 → 2010-04-01 A (+31d) | 2010-09-30 → 2012-01-31 A (+488d) | 151d → 453.29d | 0% → 100% | 97d → none |  | resources MECH TECH [384.17 h]; MECH ENG [42.69 h] → MECH ENG [42.69 h]; MECH TECH [384.17 h] |
| 16332010Ab | H-D Complex P- II Contract Progress 2010 ETC FY11 | 2010-10-01 → 2010-04-01 A (-183d) | 2011-04-18 → 2012-01-31 A (+288d) | 132d → 454d | 0% → 100% | 97d → none | 16332010A → 16332010A FS-132d | resources MECH TECH [335.83 h]; MECH ENG [37.31 h] → MECH ENG [37.31 h]; MECH TECH [335.83 h] |
| 16332020A | H-D Complex P- II Constrctn Mngmnt 2010 ETC Labor FY10 | 2010-03-01 → 2010-04-01 A (+31d) | 2010-09-30 → 2011-08-10 A (+314d) | 151d → 339.72d | 0% → 100% | 1084d → none |  | was named H-D Complex P- II Constrctn Mngmnt 2010 ETC Labor FY11 |
| 16332020Aa | H-D Complex P- II Constrctn Mngmnt 2010 ETC Labor FY11 | 2010-10-01 → 2010-04-01 A (-183d) | 2011-08-10 A | 212d → 339.46d | 0% → 100% | 1084d → none | 16332020A → 16332020A FS-212d |  |
| 16332020Ab | H-D Complex P- II Constrctn Mngmnt 2010 ETC Procurement | 2010-03-01 → 2010-04-01 A (+31d) | 2011-08-10 A | 363d → 340d | 0% → 100% | 1084d → none |  |  |
| 16332040 | H-D Complex Cryo Plant P- II Contract Progress September 2010 Progress Payment | 2010-02-03 → 2010-04-01 A (+57d) | 2010-09-30 → 2010-10-25 A (+25d) | 168d → 145d | 0% → 100% | 87d → none |  |  |
| 16332040A | H-D Complex Cryo Plant P- II Contract Progress October 2010 Progress Payment | 2010-02-03 → 2010-04-01 A (+57d) | 2010-10-29 A | 189d → 149d | 0% → 100% | 87d → none |  |  |
| 16332040B | H-D Complex Cryo Plant P- II Contract Progress November 2010 Progress Payment | 2010-02-03 → 2010-04-01 A (+57d) | 2010-11-30 → 2010-11-22 A (-8d) | 209d → 165d | 0% → 100% | 87d → none |  |  |
| 16332040C | H-D Complex Cryo Plant P- II Contract Progress December 2010 Progress Payment | 2010-02-03 → 2010-04-01 A (+57d) | 2010-12-30 → 2010-11-22 A (-38d) | 226d → 165d | 0% → 100% | 87d → none |  |  |
| 16332040D | H-D Complex Cryo Plant P- II Contract Progress January 2011 Progress Payment | 2010-02-03 → 2010-04-01 A (+57d) | 2011-01-31 → 2011-03-25 A (+53d) | 246d → 244d | 0% → 100% | 87d → none |  |  |
| 16332040F | H-D Complex Cryo Plant P- II Contract Progress February 2011 Progress Payment | 2010-02-03 → 2010-04-01 A (+57d) | 2011-02-28 → 2011-09-30 A (+214d) | 265d → 376d | 0% → 100% | 87d → none |  |  |
| 16332015 | H-D Complex P- II Cmmssng | 2011-08-05 → 2011-03-25 A (-133d) | 2011-09-30 → 2012-01-31 A (+123d) | 40d → 211d | 0% → 100% | 21d → none | 16332010Ab, 16332011, 16332040F, 16332010U FS-40d, 16332040, 16332010, 16332012 → 16332010, 16332012, 16332040, 16332040F FS-20d, 16332011 FS-500d, 16332010U FS-500d, 16332010Ab FS-40d |  |
| 16332045 | H-D Elect Utilities Proc Telecomm Cable & Equip | 2011-03-16 → 2011-05-02 A (+47d) | 2011-08-04 → 2011-08-24 A (+20d) | 100d → 81d | 0% → 100% | 27d → none |  |  |
| 16332050 | H-D Elect Utilities Install Telecomm Cable & Equip | 2011-08-05 → 2011-05-02 A (-95d) | 2011-09-30 → 2011-12-22 A (+83d) | 40d → 163d | 0% → 100% | 27d → none | 16332010U FS-40d, 16332010, 16332045 → 16332045 FS-40d, 16332010, 16332010U FS-110d | resources PROCUREMENT<$50K 60; PROCUREMENT>$50K 69 → PROCUREMENT>$50K 69; PROCUREMENT<$50K 60 |
| 16332010W | H-D Complex P-II Contractor Claim #2 | 2012-01-04 → 2012-01-02 A (-2d) | 2012-01-31 A | 19d → 20d | 0% → 100% | 1030d → none |  |  |
| 16332030 | H-D Complex P- II Beneficial Occupancy | 2011-11-01 → 2012-01-09 A (+69d) | 2011-11-30 → 2012-01-31 A (+62d) | 20d → 16d | 0% → 100% | 6d → none | 16332010U, 16332050, 16332010, 16332015, 16332010V → 16332050 FS-22d, 16332010U, 16332010, 16332015 FS-15d, 16332010V FS-15d |  |
| 16332035 | H-D Complex P- II Constr Comp | 2011-11-30 → 2012-01-31 A (+62d) | 2011-11-30 → 2012-01-31 A (+62d) |  | 0% → 100% | 1007d → none | 16332025, 16332020b, 16332020ba, 16332030, 16332020Ab, 16332020Aa, 16332010W FS-60d, 13455145, 13455135 → 16332025, 16332030, 16332020Aa, 16332020ba, 13455135, 16332020Ab, 16332020b, 16332010W FS-60d |  |
| 16332055 | Re-Baseline Actuals Adjustment | 2013-08-30 A | 2013-08-30 A |  | 0% → 100% | 20d → none | 9-130M FS+227d → none |  |
| 16333005 | H-D Complex P- III Award Contract | 2009-08-06 A | 2009-08-06 A |  | 0% → 100% | 184d → none |  |  |
| 16333010 | H-D Complex P- III Contract Progress June 2011 | 2009-08-06 A | 2011-06-30 → 2011-07-25 A (+25d) | 471d → 487d | 0% → 100% | 184d → none |  | resources PROCUREMENT>$50K 69 NO ESCALATION; PROCUREMENT<$50K 60 NO ESCALATION → PROCUREMENT<$50K 60 NO ESCALATION; PROCUREMENT>$50K 69 NO ESCALATION |
| 16333010A | H-D Complex P- III Contract Progress July 2011 | 2009-08-06 A | 2011-07-29 → 2011-08-26 A (+28d) | 491d → 511d | 0% → 100% | 184d → none |  |  |
| 16333010B | H-D Complex P- III Contract Progress August 2011 | 2009-08-06 A | 2011-08-31 → 2011-09-15 A (+15d) | 514d → 524d | 0% → 100% | 184d → none |  |  |
| 16333010C | H-D Complex P- III Contract Progress September 2011 | 2009-08-06 A | 2011-09-30 → 2011-10-07 A (+7d) | 535d → 540d | 0% → 100% | 184d → none |  |  |
| 16333010D | H-D Complex P- III Contract Progress October 2011 | 2009-08-06 A | 2011-10-31 → 2011-11-02 A (+2d) | 556d → 558d | 0% → 100% | 184d → none |  |  |
| 16333000M | H-D Complex P- III Begin Constr | 2011-01-05 → 2010-12-20 A (-16d) | 2011-01-05 → 2010-12-20 A (-16d) |  | 0% → 100% | 232d → none |  |  |
| 16333015 | H-D Complex P- III Cmmssng | 2011-09-21 → 2011-03-01 A (-204d) | 2011-10-18 → 2011-10-31 A (+13d) | 20d → 172d | 0% → 100% | 183d → none | 16333012, 16333011, 16333010D FS-30d → 16333012 FS-150d, 16333010D FS-150d, 16333011 FS-150d |  |
| 16333020 | H-D Complex P- III Constrctn Mngmnt | 2011-03-18 → 2011-03-01 A (-17d) | 2011-09-20 → 2011-11-02 A (+43d) | 130d → 174d | 0% → 100% | 1056d → none |  | resources OFFICE [40 h]; MECH TECH [1080 h]; PLANT ENG [200 h]; PROCUREMENT>$50K 69 NO ESCALATION; ELEC ENG [40 h]; MECH ENG [200 h]; PROCUREMENT<$50K 60 NO ESCALATION; MECH DES [40 h] → ELEC ENG [40 h]; MECH ENG [200 h]; MECH DES [40 h]; OFFICE [40 h]; MECH TECH [1080 h]; PLANT ENG [200 h]; PROCUREMENT<$50K 60 NO ESCALATION; PROCUREMENT>$50K 69 NO ESCALATION |
| 16333025 | H-D Complex P- III A-E Constrctn Supprt | 2011-03-18 → 2011-03-01 A (-17d) | 2011-09-20 → 2011-11-02 A (+43d) | 130d → 174d | 0% → 100% | 1056d → none |  |  |
| 16333011 | H-D Complex P- III Contract Modifications | 2011-03-18 A | 2011-09-20 A |  | 0% → 100% | 183d → none |  |  |

| ID | Task | Start | Finish | Duration | Complete | Total float | Predecessors | Other |
| --- | --- | --- | --- | --- | --- | --- | --- | --- |
| 16333012 | H-D Complex P- III ARRA Funds | 2011-03-18 A | 2011-09-20 A |  | 0% → 100% | 183d → none |  |  |
| 16333008 | H-D Complex P- III Notice to Proceed | 2011-01-05 → 2011-05-13 A (+128d) | 2011-01-05 → 2011-05-16 A (+131d) | 1d → 2d | 0% → 100% | 232d → none |  |  |
| 16333030 | H-D Complex P- III Beneficial Occupancy | 2011-10-19 → 2011-11-02 A (+14d) | 2011-11-01 → 2011-11-02 A (+1d) | 10d → 1d | 0% → 100% | 183d → none | 16333015, 16333011, 16333010D FS-556d → 16333010D FS-556d, 16333011, 16333015 FS-10d |  |
| 16333035 | H-D Complex P- III Constr Comp | 2011-11-01 → 2011-11-02 A (+1d) | 2011-11-01 → 2011-11-02 A (+1d) |  | 0% → 100% | 1026d → none |  |  |
| 16333010F | H-D Complex P-III Contractor Claim #2 | 2011-12-01 A | 2011-12-07 A |  | 0% → 100% | 1062d → none |  |  |
| 16333040 | Re-Baseline Actuals Adjustment | 2013-08-30 A | 2013-08-30 A |  | 0% → 100% | 20d → none | 9-130M FS+227d → none |  |
| 171909LOE | FY09 Constrctn Proj Office Proj Mngmnt | 2009-01-02 A | 2009-09-30 A |  | 0% → 100% | 20d → none |  | resources ELEC ENG [2682.58 h]; SR STAFF [5365.16 h]; SCIENTIST [670.65 h]; ADMIN [1341.29 h]; OFFICE [1341.29 h]; SUPPLIES & MATERIALS; DIRECTORATE [548.71 h] → DIRECTORATE [548.71 h]; SUPPLIES & MATERIALS; SCIENTIST [670.65 h]; SR STAFF [5365.16 h]; ADMIN [1341.29 h]; ELEC ENG [2682.58 h]; OFFICE [1341.29 h] |
| 171910LOE | FY10 Constrctn Proj Office Proj Mngmnt | 2009-10-01 A | 2010-09-30 A |  | 0% → 100% | 20d → none |  | resources ADMIN [1760 h]; SR STAFF [7040 h]; SCIENTIST [880 h]; ELEC ENG [3520 h]; SUPPLIES & MATERIALS; DIRECTORATE [720 h]; OFFICE [1760 h] → SR STAFF [7040 h]; SCIENTIST [880 h]; OFFICE [1760 h]; ELEC ENG [3520 h]; SUPPLIES & MATERIALS; DIRECTORATE [720 h]; ADMIN [1760 h] |
| 171910ALOE | FY10 Constrctn Proj Office Proj Mngmnt (Accelerator Work Coordinator) | 2010-03-01 A | 2010-09-30 A |  | 0% → 100% | 20d → none |  |  |
| 171910BLOE | FY10 Constrctn Proj Office Proj Mngmnt (CR 10-050) | 2010-04-01 A | 2010-09-30 A |  | 0% → 100% | 20d → none |  |  |
| 171911LOE | FY11 Constrctn Proj Office Proj Mngmnt | 2010-10-01 A | 2011-09-30 A |  | 0% → 100% | 20d → none |  | resources ELEC ENG [3520 h]; SCIENTIST [880 h]; SR STAFF [5544 h]; MECH ENG [1760 h]; DIRECTORATE [2216 h]; ADMIN [1760 h]; SUPPLIES & MATERIALS; OFFICE [1760 h] → DIRECTORATE [2216 h]; SUPPLIES & MATERIALS; OFFICE [1760 h]; SCIENTIST [880 h]; MECH ENG [1760 h]; ADMIN [1760 h]; ELEC ENG [3520 h]; SR STAFF [5544 h] |
| 171911LOEA | FY11 Constrctn Proj Office Proj Mngmnt CR11-007 Reductions | 2010-11-01 A | 2011-09-30 A |  | 0% → 100% | 20d → none |  | resources SUPPLIES & MATERIALS; ELEC ENG [-1760 h]; SCIENTIST [-704 h] → ELEC ENG [-1760 h]; SCIENTIST [-704 h]; SUPPLIES & MATERIALS |
| 171911LOEB | FY11 Constrctn Proj Office Proj Mngmnt CR11-007 | 2010-11-01 A | 2011-09-30 A |  | 0% → 100% | 20d → none |  | resources OFFICE [880 h]; SR STAFF [352 h]; MECH ENG [5016 h]; DIRECTORATE [688 h] → SR STAFF [352 h]; MECH ENG [5016 h]; DIRECTORATE [688 h]; OFFICE [880 h] |
| 171912LOE | FY12 Constrctn Proj Office Proj Mngmnt Part A | 2011-10-03 A | 2012-03-30 → 2012-04-02 A (+3d) | 120d → 120.82d | 0% → 100% | 20d → none |  | resources DIRECTORATE [1410.85 h]; SUPPLIES & MATERIALS; MECH ENG [3291.98 h]; SR STAFF [2864.45 h]; ADMIN [855.06 h]; OFFICE [1710.12 h]; ELEC ENG [855.06 h] → OFFICE [1710.12 h]; ELEC ENG [855.06 h]; SUPPLIES & MATERIALS; MECH ENG [3291.98 h]; DIRECTORATE [1410.85 h]; ADMIN [855.06 h]; SR STAFF [2864.45 h] |
| 171912LOEA | FY12 Constrctn Proj Office Proj Mngmnt Part B | 2012-04-02 A | 2012-09-28 A |  | 0% → 100% | 20d → none |  | resources OFFICE [1760 h]; ELEC ENG [880 h]; DIRECTORATE [1452 h]; SUPPLIES & MATERIALS; MECH ENG [1760 h]; SR STAFF [2200 h]; ADMIN [880 h] → SR STAFF [2200 h]; ADMIN [880 h]; OFFICE [1760 h]; ELEC ENG [880 h]; DIRECTORATE [1452 h]; SUPPLIES & MATERIALS; MECH ENG [1760 h] |
| 171913LOE | FY13 Constrctn Proj Office Proj Mngmnt Part A | 2012-10-01 A | 2013-03-29 A |  | 0% → 100% | 20d → none |  | resources ELEC ENG [880 h]; OFFICE [1760 h]; SUPPLIES & MATERIALS; SR STAFF [2200 h]; DIRECTORATE [1452 h]; ADMIN [880 h]; MECH ENG [1760 h] → ADMIN [880 h]; ELEC ENG [880 h]; SUPPLIES & MATERIALS; SR STAFF [2200 h]; DIRECTORATE [1452 h]; MECH ENG [1760 h]; OFFICE [1760 h] |
| 171913LOEA | FY13 Constrctn Proj Office Proj Mngmnt Part B | 2013-04-01 A | 2013-08-30 A | 108d → 128d | 0% → 100% | 20d → none |  | resources OFFICE [1485 h]; SUPPLIES & MATERIALS; SR STAFF [1856.25 h]; DIRECTORATE [1225.13 h]; ADMIN [742.5 h]; ELEC ENG [742.5 h]; MECH ENG [1485 h] → OFFICE [1485 h]; SUPPLIES & MATERIALS; SR STAFF [1856.25 h]; DIRECTORATE [1225.13 h]; ADMIN [742.5 h]; MECH ENG [1485 h]; ELEC ENG [742.5 h] |
| 171950 | Re-Baseline Actuals Adjustment | 2013-08-30 A | 2013-08-30 A |  | 0% → 100% | 20d → none | 9-130M FS+227d → none |  |
| 271913LOEB | FY13 Constrctn Proj Office Proj Mngmnt Part B | 2013-09-03 A | 2013-09-30 A |  | 0% → 100% | 311d → none |  | resources PROCUREMENT<$50K 60; SCIENTIST [14.07 h]; OFFICE [140.79 h]; SUPPLIES & MATERIALS; SR STAFF [179.51 h]; DIRECTORATE [123.18 h]; ADMIN [70.4 h]; ELEC ENG [35.2 h]; MECH ENG [140.79 h] → SCIENTIST [14.07 h]; OFFICE [140.79 h]; SUPPLIES & MATERIALS; SR STAFF [179.51 h]; DIRECTORATE [123.18 h]; ADMIN [70.4 h]; ELEC ENG [35.2 h]; MECH ENG [140.79 h]; PROCUREMENT<$50K 60 |
| 271914LOE | FY14 Constrctn Proj Office Proj Mngmnt | 2013-10-01 A |  |  | 0% → 9% |  |  |  |
| 172909LOE | FY09 OPM Proj Mngmnt | 2008-10-01 A | 2009-09-30 A |  | 0% → 100% | 20d → none |  |  |
| 172910LOE | FY10 OPM Proj Mngmnt | 2009-10-01 A | 2010-09-30 A |  | 0% → 100% | 20d → none |  |  |
| 172911LOE | FY11 OPM Proj Mngmnt | 2010-10-01 A | 2011-09-30 A |  | 0% → 100% | 20d → none |  |  |
| 172912LOE | FY12 OPM Proj Mngmnt | 2011-10-03 A | 2012-09-28 A |  | 0% → 100% | 20d → none |  |  |
| 172913LOE | FY13 OPM Proj Mngmnt | 2012-10-01 A | 2013-08-30 A | 228d → 248d | 0% → 100% | 20d → none |  |  |
| 8 | **1.8 CONSTRUCTION PRE-OPS** | 2006-10-02 → 2012-10-01 (+2191d) | 2017-08-02 → 2017-12-19 (+139d) |  |  |  |  |  |
| 28005 | Hall A Schedule Contingency Activity | 2014-03-06 → 2014-03-13 (+7d) | 2015-03-03 → 2015-03-10 (+7d) |  |  | 643d → 638d |  |  |
| 28015 | Hall B Schedule Contingency Activity | 2016-02-11 → 2016-06-27 (+137d) | 2017-08-02 → 2017-12-19 (+139d) |  |  | 41d → -55d |  |  |
| 1 | **1.8.1 CONSTRUCTION ACCELERATOR PRE-OPS** | 2006-10-02 → 2012-12-17 (+2268d) | 2016-02-10 → 2016-06-24 (+135d) |  |  |  |  |  |
| 1 | **1.8.1.1 CONSTRUCTION ACCELERATOR PRE-OPS BEAM COMMISIONING** | 2006-10-02 → 2013-08-30 (+2524d) | 2016-02-10 → 2016-06-24 (+135d) |  |  |  |  |  |
| 1811019 | H-A ARR Process | 2012-11-15 → 2013-08-30 A (+288d) | 2012-12-14 → 2013-08-30 A (+259d) |  | 0% → 100% | 1185d → none | 14132020, 14151010a, 14153020, 14152025 → 3A-43M |  |
| 1811070 | Re-Baseline Actuals Adjustment | 2013-08-30 A | 2013-08-30 A |  | 0% → 100% | 20d → none | 9-130M FS+227d → none |  |
| 2811001 | Accel ARR Process | 2013-10-11 → 2013-09-03 A (-38d) | 2013-12-13 → 2013-10-31 A (-43d) |  | 0% → 100% | 0d → none | 2812000 FS-52d, 2811000 FS-40d → 2812000 FS-67d, 2811000 FS-60d |  |
| 2811000 | Accel Hot Check-out | 2013-10-15 A |  |  |  | 0d → 62d |  |  |
| 2811005 | Accel Beam Commisioning | 2013-11-14 → 2013-11-13 (-1d) | 2013-12-20 → 2013-12-19 (-1d) |  |  | 0d → 19d |  | was named Accel Commisioning |
| 2811019 | H-A ARR Process | 2013-10-14 → 2014-01-02 (+80d) | 2013-11-08 → 2014-01-30 (+83d) |  |  | 87d → 39d |  |  |
| 2811020 | H-A Beam Cmmssng | 2014-03-03 → 2014-03-10 (+7d) | 2014-03-05 → 2014-03-12 (+7d) |  |  | 18d → 13d |  |  |
| 2811034 | H-B ARR Process | 2015-11-19 → 2016-04-15 (+148d) | 2016-01-27 → 2016-06-10 (+135d) |  |  | 36d → -60d |  |  |
| 2811035 | H-B Beam Cmmssng | 2016-01-28 → 2016-06-13 (+137d) | 2016-02-10 → 2016-06-24 (+135d) |  |  | 36d → -60d |  |  |
| 2 | **1.8.1.2 CONSTRUCTION ACCELERATOR PRE-OPS UTILITIES** |  | 2016-02-10 → 2016-06-24 (+135d) |  |  |  |  |  |
| 2812000 | Accel Hot Check-out Accelerator Commissioning (Utilities) | 2013-10-15 A |  | 32d → 20d |  | 18d → 75d | 4A-10M → 4A-10M FS-40d | was named Accel Hot Check-out (Utilities) |
| 2812005 | Accel Beam Commissioning (Utilities) | 2013-11-14 → 2013-11-13 (-1d) | 2013-12-20 → 2013-12-19 (-1d) |  |  | 0d → 19d |  |  |
| 2812065 | H-A Beam Cmmssng (Utilities) | 2014-02-28 → 2014-02-26 (-2d) | 2014-03-04 → 2014-02-28 (-4d) |  |  | 19d → 21d |  |  |
| 2812020 | H-B Beam Cmmssng (Utilities) | 2016-01-28 → 2016-06-13 (+137d) | 2016-02-10 → 2016-06-24 (+135d) |  |  | 36d → -60d |  |  |
| 3 | **1.8.1.3 ACCELERATOR PRE-OPS CHECKOUT** | 2012-10-01 → 2012-12-17 (+77d) |  |  |  |  |  |  |
| 1 | **1.8.1.3.1 CRYOMODULES ACCELERATOR PRE-OPS** | 2013-01-29 → 2013-04-01 (+62d) |  |  |  |  |  |  |
| 5 | **1.8.1.3.1.5 CRYOMODULES IN-TUNNEL CHECKOUT** | 2013-01-29 → 2013-04-01 (+62d) |  |  |  |  |  |  |
| 181315000 | In-Tunnel Checkout and Commisioning Cryomodule #3 5th | 2013-01-29 → 2013-04-01 A (+62d) | 2013-03-04 → 2013-05-17 A (+74d) | 24d → 35d | 0% → 100% | 35d → none |  |  |
| 181315005 | In-Tunnel Checkout and Commisioning Cryomodule #6 | 2013-03-05 → 2013-04-01 A (+27d) | 2013-04-05 → 2013-07-15 A (+101d) | 24d → 73d | 0% → 100% | 35d → none | 181321005, 181315000, 131506000 → 181315010 FS-55d, 131506000, 181321005 FS-15d |  |
| 181315010 | In-Tunnel Checkout and Commisioning Cryomodule #7 | 2013-04-08 → 2013-04-01 A (-7d) | 2013-05-10 → 2013-06-20 A (+41d) | 25d → 54d | 0% → 100% | 35d → none | 131507000, 181315005, 181321010 → 181315000 FS-35d, 131507000, 181321010 FS-20d | resources SR STAFF [40 h]; COMP SCIENT [16 h]; ELEC ENG [240 h]; ELEC TECH [120 h]; MECH ENG [80 h]; MECH TECH [160 h]; SUPPLIES & MATERIALS; SCIENTIST [40 h] → SUPPLIES & MATERIALS; SCIENTIST [40 h]; SR STAFF [40 h]; MECH TECH [160 h]; COMP SCIENT [16 h]; ELEC ENG [240 h]; ELEC TECH [120 h]; MECH ENG [80 h] |
| 181315015 | In-Tunnel Checkout and Commisioning Cryomodule #8 | 2013-05-13 → 2013-05-03 A (-10d) | 2013-06-14 → 2013-08-30 A (+77d) | 24d → 83d | 0% → 100% | 35d → none | 181315010, 181321015, 131508000 → 181315005 FS-75d, 181321015 FS-70d, 131508000 FS-45d |  |
| 181315020 | In-Tunnel Checkout and Commisioning Cryomodule #9 | 2013-06-17 → 2013-05-03 A (-45d) | 2013-07-19 → 2013-08-16 A (+28d) | 24d → 44d | 0% → 100% | 35d → none | 131509000, 181315015, 181321020 → 181315015 FS-95d, 131509000 FS+6d, 181321020 FS-95d |  |
| 181315025 | In-Tunnel Checkout and Commisioning Cryomodule #10 | 2013-07-22 → 2013-07-15 A (-7d) | 2013-08-23 → 2013-08-30 A (+7d) | 25d → 27d | 0% → 100% | 35d → none | 181315020, 181321025, 131510000 → 181321025 FS-45d, 131510000, 181315020 FS-13d | resources MECH ENG [80 h]; ELEC ENG [240 h]; SUPPLIES & MATERIALS; SCIENTIST [40 h]; SR STAFF [40 h]; ELEC TECH [120 h]; COMP SCIENT [16 h]; MECH TECH [160 h] → SUPPLIES & MATERIALS; SCIENTIST [40 h]; SR STAFF [40 h]; ELEC TECH [120 h]; COMP SCIENT [16 h]; MECH TECH [160 h]; MECH ENG [80 h]; ELEC ENG [240 h] |
| 181315030 | Re-Baseline Actuals Adjustment | 2013-08-30 A | 2013-08-30 A |  | 0% → 100% | 20d → none | 9-130M FS+227d → none |  |
| 281315025 | In-Tunnel Checkout and Commisioning Cryomodule #10 FY13 | 2013-09-03 A | 2013-09-30 → 2013-09-23 A (-7d) | 20d → 29d | 0% → 100% | 21d → none |  |  |
| 281315025a | In-Tunnel Checkout and Commisioning Cryomodule #10 FY14 | 2013-10-01 → 2013-09-03 A (-28d) | 2013-10-11 → 2013-09-23 A (-18d) |  | 0% → 100% | 21d → none | 281315025, 281321025 FS-5d → 281315025 |  |
| 281315030 | Installation & Test of Individual Heater Control & Piezo Operation FY13 | 2013-09-03 A | 2013-09-30 → 2014-02-28 (+151d) | 20d → 118d | 0% → 30% |  |  |  |
| 281315030a | Installation & Test of Individual Heater Control & Piezo Operation FY14 | 2013-10-01 → 2013-09-03 A (-28d) |  |  | 0% → 30% |  | 9-130M FS+228d, 281315030 → 281315030 FS-98d |  |
| 281315015 | In-Tunnel Checkout and Commisioning Cryomodule #8 | 2013-09-03 → 2013-10-01 A (+28d) | 2013-09-20 → 2013-11-20 (+61d) |  | 0% → 50% | 36d → 24d |  |  |
| 2 | **1.8.1.3.2 POWER PRE-OPS CHECKOUT** | 2012-10-30 → 2013-01-15 (+77d) |  |  |  |  |  |  |
| 1 | **1.8.1.3.2.1 RF PRE-OPS CHECKOUT** | 2012-10-30 → 2013-01-15 (+77d) | 2013-11-06 → 2013-12-13 (+37d) |  |  |  |  |  |
| 181321000 | RF Sys Tests #5 (Install & SYS COMMIS) | 2012-10-30 → 2013-01-15 A (+77d) | 2012-11-19 → 2013-02-15 A (+88d) | 15d → 11d | 0% → 100% | 76d → none |  | resources ELEC DES [56 h]; ELEC ENG [16 h]; ELEC TECH [100 h]; COMP SCIENT [16 h]; OFFICE [8 h]; SUPPLIES & MATERIALS → ELEC ENG [16 h]; ELEC TECH [100 h]; COMP SCIENT [16 h]; OFFICE [8 h]; SUPPLIES & MATERIALS; ELEC DES [56 h] |
| 181321005 | RF Sys Tests #6 (Install & SYS COMMIS) | 2013-01-17 → 2013-03-04 A (+46d) | 2013-02-07 → 2013-04-15 A (+67d) | 15d → 11d | 0% → 100% | 51d → none | 132112086M, 132121066M → 132112086M FS-20d, 132121066M |  |
| 181321010 | RF Sys Tests #7 (Install & SYS COMMIS) | 2013-02-07 → 2013-03-11 A (+32d) | 2013-02-28 → 2013-06-17 A (+109d) | 15d → 6d | 0% → 100% | 61d → none | 132121067M, 132112087M → 132112087M FS-30d, 132121067M |  |
| 181321030 | RF Cavity Tests Cryomodule #3 (Install & SYS COMMIS) | 2013-02-06 → 2013-04-15 A (+68d) | 2013-03-04 → 2013-06-17 A (+105d) |  | 0% → 100% | 157d → none | 181315000 FS-18d, 181321000 → 181321000, 181315000 FS-40d | resources ELEC ENG [56 h]; ELEC DES [64 h]; ELEC TECH [60 h]; SCIENTIST [16 h]; OFFICE [8 h]; SUPPLIES & MATERIALS → OFFICE [8 h]; SUPPLIES & MATERIALS; ELEC ENG [56 h]; ELEC DES [64 h]; ELEC TECH [60 h]; SCIENTIST [16 h] |
| 181321040 | RF Cavity Tests Cryomodule #7 (Install & SYS COMMIS) | 2013-04-17 → 2013-06-01 A (+45d) | 2013-05-10 → 2013-06-17 A (+38d) |  | 0% → 100% | 108d → none |  | resources OFFICE [8 h]; SUPPLIES & MATERIALS; ELEC ENG [56 h]; ELEC DES [64 h]; ELEC TECH [60 h]; SCIENTIST [16 h] → ELEC TECH [60 h]; SCIENTIST [16 h]; OFFICE [8 h]; SUPPLIES & MATERIALS; ELEC ENG [56 h]; ELEC DES [64 h] |
| 181321015 | RF Sys Tests #8 (Install & SYS COMMIS) | 2013-02-27 → 2013-06-09 A (+102d) | 2013-03-19 → 2013-07-15 A (+118d) |  | 0% → 100% | 73d → none | 132121068M, 132112088M → 132121068M, 132112088M FS-10d |  |
| 181321035 | RF Cavity Tests Cryomodule #6 (Install & SYS COMMIS) | 2013-03-13 → 2013-06-10 A (+89d) | 2013-04-05 → 2013-07-15 A (+101d) |  | 0% → 100% | 133d → none |  |  |
| 181321020 | RF Sys Tests #9 (Install & SYS COMMIS) | 2013-03-18 → 2013-07-07 A (+111d) | 2013-04-05 → 2013-08-23 A (+140d) |  | 0% → 100% | 84d → none | 132112089M, 132121069M → 132121069M, 132112089M FS-20d | resources ELEC ENG [16 h]; ELEC TECH [100 h]; COMP SCIENT [16 h]; OFFICE [8 h]; SUPPLIES & MATERIALS; ELEC DES [56 h] → OFFICE [8 h]; SUPPLIES & MATERIALS; ELEC DES [56 h]; ELEC ENG [16 h]; ELEC TECH [100 h]; COMP SCIENT [16 h] |
| 181321045 | RF Cavity Tests Cryomodule #8 (Install & SYS COMMIS) | 2013-05-21 → 2013-08-03 A (+74d) | 2013-06-14 → 2013-08-19 A (+66d) |  | 0% → 100% | 84d → none |  | resources SUPPLIES & MATERIALS; ELEC ENG [56 h]; ELEC DES [64 h]; ELEC TECH [60 h]; SCIENTIST [16 h]; OFFICE [8 h] → ELEC DES [64 h]; ELEC TECH [60 h]; SCIENTIST [16 h]; OFFICE [8 h]; SUPPLIES & MATERIALS; ELEC ENG [56 h] |

| ID | Task | Start | Finish | Duration | Complete | Total float | Predecessors | Other |
| --- | --- | --- | --- | --- | --- | --- | --- | --- |
| 181321050 | RF Cavity Tests Cryomodule #9 (Install & SYS COMMIS) | 2013-06-25 → 2013-08-05 A (+41d) | 2013-07-19 → 2013-08-30 A (+42d) |  | 0% → 100% | 60d → none |  | resources ELEC ENG [56 h]; ELEC TECH [60 h]; ELEC DES [64 h]; SCIENTIST [16 h]; OFFICE [8 h]; SUPPLIES & MATERIALS → SCIENTIST [16 h]; OFFICE [8 h]; SUPPLIES & MATERIALS; ELEC ENG [56 h]; ELEC TECH [60 h]; ELEC DES [64 h] |
| 181321025 | RF Sys Tests #10 (Install & SYS COMMIS) | 2013-04-04 → 2013-08-19 A (+137d) | 2013-04-24 → 2013-08-30 A (+128d) |  | 0% → 100% | 95d → none | 132121070M, 132112090M → 132121070M, 132112090M FS-15d |  |
| 181321055 | RF Cavity Tests Cryomodule #10 (Install & SYS COMMIS) | 2013-07-31 → 2013-08-30 A (+30d) | 2013-08-23 → 2013-08-30 A (+7d) | 18d → 15d | 0% → 100% | 35d → none |  |  |
| 181321060 | Re-Baseline Actuals Adjustment | 2013-08-30 A | 2013-08-30 A |  | 0% → 100% | 20d → none | 9-130M FS+227d → none |  |
| 281321025 | RF Sys Tests #10 (Install & SYS COMMIS) | 2013-09-03 A | 2013-09-09 A |  | 0% → 100% | 21d → none |  |  |
| 281321050 | RF Cavity Tests Cryomodule #9 (Install & SYS COMMIS) | 2013-09-03 A | 2013-09-16 → 2013-12-13 (+88d) |  | 0% → 50% | 65d → 78d |  | resources ELEC TECH [42 h]; ELEC DES [44.8 h]; SCIENTIST [11.2 h]; OFFICE [5.6 h]; SUPPLIES & MATERIALS; ELEC ENG [39.2 h] → SCIENTIST [11.2 h]; OFFICE [5.6 h]; SUPPLIES & MATERIALS; ELEC ENG [39.2 h]; ELEC TECH [42 h]; ELEC DES [44.8 h] |
| 281321055 | RF Cavity Tests Cryomodule #10 (Install & SYS COMMIS) | 2013-10-14 → 2013-11-01 (+18d) | 2013-11-06 → 2013-11-26 (+20d) |  |  | 28d → 89d | 281315025a, 281315025, 281321025 → 281315025 FS-13d, 281321025 |  |
| 1813221000 | Re-Baseline Actuals Adjustment | 2013-08-30 A | 2013-08-30 A |  | 0% → 100% | 20d → none | 9-130M FS+227d → none |  |
| 2813221005 | Test Arc 1 and Hall A PS w/ Dummy Load FY13 | 2013-09-09 A | 2013-09-30 → 2014-01-17 (+109d) |  | 0% → 50% | 62d → 110d |  |  |
| 2813221005a | Test Arc 1 and Hall A PS w/ Dummy Load FY14 | 2013-10-01 → 2013-09-09 A (-22d) | 2013-12-05 → 2014-01-17 (+43d) |  | 0% → 50% | 62d → 110d | 2813221005, 23221133 FS-55d, 23221133a FS-55d → 2813221005 FS-60d |  |
| 2813221000 | Test Magnet System Box Power Supplies w/Dummy Load FY13 | 2013-09-09 → 2013-10-01 A (+22d) | 2013-09-30 → 2014-06-25 (+268d) |  | 0% → 8% |  |  |  |
| 2813221000a | Test Magnet System Box Power Supplies w/Dummy Load FY14 | 2013-10-01 A |  | 180d → 159d | 0% → 8% |  | 3A-23M, 2813221000, 23221024ba FS-194d → 2813221000 FS-160d |  |
| 4 | **1.8.1.3.2.2.4 POWER SUPPLY INTEGRATED TESTING** | 2013-09-19 → 2013-09-30 (+11d) |  |  |  |  |  |  |
| 2813224005 | Intergation Testing- Trim PS | 2013-10-01 → 2013-09-30 A (-1d) | 2014-02-04 → 2014-03-07 (+31d) |  | 0% → 10% | 36d → 13d | 23224085Aa FS-22d, 23224085A FS-23d → 23224085Aa FS-23d, 23224085A FS-23d |  |
| 2813224000 | Integration Testing- Box PS FY13 | 2013-09-19 → 2013-10-01 A (+12d) | 2013-09-30 → 2014-05-30 (+242d) |  | 0% → 4% |  |  |  |
| 2813224000a | Integration Testing- Box PS FY14 | 2013-10-01 A |  |  | 0% → 4% |  | 23224055 FS-35d, 2813224000, 23224055a FS-35d → 2813224000 FS-150d |  |
| 3 | **1.8.1.3.3 CRYOGENICS PRE-OPS CHECKOUT** | 2012-10-01 → 2012-12-17 (+77d) |  |  |  |  |  |  |
| 1 | **1.8.1.3.3.1 CHL II PRE-OPS CHECKOUT** | 2013-01-02 → 2012-12-17 (-16d) |  |  |  |  |  |  |
| 181331000 | Cmmssn CHL Helium Plant Revised | 2013-01-02 → 2012-12-17 A (-16d) | 2013-05-03 → 2013-06-17 A (+45d) | 86d → 46d | 0% → 100% | 146d → none | 1331.11000 FS+165d → 1331.11000 FS-50d |  |
| 181331005 | Re-Baseline Actuals Adjustment | 2013-08-30 A | 2013-08-30 A |  | 0% → 100% | 20d → none | 9-130M FS+227d → none |  |
| 2 | **1.8.1.3.3.2 HALL D CRYOGENICS PRE-OPS CHECKOUT** | 2012-10-01 → 2012-12-17 (+77d) |  |  |  |  |  |  |
| 181332000 | Commission Solenoid Distribution Can | 2012-10-01 → 2012-12-17 A (+77d) | 2012-10-12 → 2013-04-15 A (+185d) | 10d → 20d | 0% → 100% | 28d → none | 13321050, 13321070 → 13321050 FS-15d, 13321070 | was named Commission Solenoid Distribution Can (Header) |
| 181332005 | Re-Baseline Actuals Adjustment | 2013-08-30 A | 2013-08-30 A |  | 0% → 100% | 20d → none | 9-130M FS+227d → none |  |
| 2 | **1.8.2 HALLS PRE-OPS** |  | 2016-02-10 → 2016-06-24 (+135d) |  |  |  |  |  |
| 1 | **1.8.2.1 HALL A CHECKOUT AND BEAM COMMISSIONING** | 2014-02-28 → 2014-02-26 (-2d) | 2014-03-04 → 2014-02-28 (-4d) |  |  |  |  |  |
| X | **1.8.2.1.X HALL A COMMISSIONING WITH BEAM** | 2014-02-28 → 2014-02-26 (-2d) | 2014-03-04 → 2014-02-28 (-4d) |  |  |  |  |  |
| 2821X000 | H-A PRE-OPS Cmmssn with Beam | 2014-02-28 → 2014-02-26 (-2d) | 2014-03-04 → 2014-02-28 (-4d) |  |  | 19d → 21d |  |  |
| 2 | **1.8.2.2 HALL B CHECKOUT AND BEAM COMMISSIONING** | 2012-10-01 → 2012-12-03 (+63d) | 2016-02-10 → 2016-06-24 (+135d) |  |  |  |  |  |
| X | **1.8.2.2.X HALL B COMMISSIONING WITH BEAM** | 2016-01-28 → 2016-06-13 (+137d) | 2016-02-10 → 2016-06-24 (+135d) |  |  |  |  |  |
| 2822X000 | H-B PRE-OPS Cmmssn with Beam | 2016-01-28 → 2016-06-13 (+137d) | 2016-02-10 → 2016-06-24 (+135d) |  |  | 36d → -60d |  |  |
| 3 | **1.8.2.2.3 HALL B TRIGGER, DAQ AND ONLINE SOFTWARE CHECKOUT** | 2012-10-01 → 2012-12-03 (+63d) |  |  |  |  |  |  |
| 18223015 | TI testing of 52 boards | 2013-01-02 → 2012-12-03 A (-30d) | 2013-08-30 → 2012-12-17 A (-256d) | 169d → 189d | 0% → 100% | 20d → none |  | resources SCIENTIST [109.04 h] → SCIENTIST [121.94 h] |
| 18223020 | TD testing of 10 boards | 2013-01-02 → 2012-12-03 A (-30d) | 2013-08-30 → 2012-12-17 A (-256d) | 169d → 189d | 0% → 100% | 20d → none |  | resources SCIENTIST [27.25 h] → SCIENTIST [30.48 h] |
| 18223025 | DAQ Commissioning | 2013-01-03 → 2012-12-03 A (-31d) | 2013-08-30 A | 168d → 188d | 0% → 100% | 20d → none |  |  |
| 18223030 | CLAS12 DAQ/online software updates FY13 | 2012-10-01 → 2012-12-03 A (+63d) | 2013-08-30 A | 228d → 248d | 0% → 100% | 20d → none |  |  |
| 18223000 | CTP testing of 22 boards | 2013-03-01 → 2013-08-30 A (+182d) | 2013-08-30 A | 129d → 149d | 0% → 100% | 20d → none |  |  |
| 18223005 | SSP testing of 15 boards | 2013-04-15 → 2013-08-30 A (+137d) | 2013-08-30 A | 98d → 118d | 0% → 100% | 20d → none |  |  |
| 18223010 | GTP testing of 2 boards | 2013-06-24 → 2013-08-30 A (+67d) | 2013-08-30 A | 49d → 69d | 0% → 100% | 20d → none |  |  |
| 18223035 | Re-Baseline Actuals Adjustment | 2013-08-30 A | 2013-08-30 A |  | 0% → 100% | 20d → none | 9-130M FS+227d → none |  |
| 28223010 | GTP testing of 2 boards | 2014-02-03 → 2014-03-06 (+31d) | 2014-04-29 → 2014-06-02 (+34d) |  |  | 351d → 328d |  |  |
| 28223025 | DAQ Commissioning | 2014-09-04 → 2014-09-03 (-1d) | 2015-10-02 → 2015-10-01 (-1d) |  |  | 56d → 57d |  |  |
| 28223030 | CLAS12 DAQ/online software updates | 2014-09-04 → 2014-09-03 (-1d) | 2015-10-02 → 2015-10-01 (-1d) |  |  | 56d → 57d |  |  |
| 28223040 | Trigger system commissioning |  |  |  |  |  |  | resources SCIENTIST [640 h]; PLABOR → PLABOR; SCIENTIST [640 h] |
| 6 | **1.8.2.2.6 HALL B MAGNET INSTALLATION TESTING** | 2015-07-14 → 2015-07-01 (-13d) | 2015-10-02 → 2016-02-29 (+150d) |  |  |  |  |  |
| 28226000 | Commission Cryogenic System | 2015-07-14 → 2015-07-01 (-13d) | 2015-07-27 → 2015-07-15 (-12d) |  |  | 17d → 25d |  |  |
| 28226005 | Cooldown | 2015-07-28 → 2015-07-16 (-12d) | 2015-08-24 → 2015-08-12 (-12d) |  |  | 17d → 25d |  |  |
| 28226010 | Torus Operational Tests | 2015-08-25 → 2015-08-13 (-12d) | 2015-09-08 → 2015-08-26 (-13d) |  |  | 17d → 25d |  |  |
| 28226015 | Map CLAS12 Torus Field both polarities | 2015-09-09 → 2015-08-27 (-13d) | 2015-09-30 → 2015-09-18 (-12d) |  |  | 17d → 25d |  |  |
| 28226020 | Solenoid Cool Down | 2015-08-18 → 2016-01-13 (+148d) | 2015-09-11 → 2016-02-08 (+150d) |  |  | 3d → -93d |  |  |
| 28226025 | Solenoid Acceptance Tests and Mapping | 2015-09-14 → 2016-02-09 (+148d) | 2015-10-02 → 2016-02-29 (+150d) |  |  | 3d → -93d |  |  |
| 3 | **1.8.2.3 HALL C CHECKOUT AND BEAM COMMISSIONING** | 2014-07-15 → 2014-08-11 (+27d) |  |  |  |  |  |  |
| 1 | **1.8.2.3.1 HALL C HB AND Q1 TESTING** | 2014-07-15 → 2014-08-11 (+27d) | 2014-09-30 → 2014-10-27 (+27d) |  |  |  |  |  |
| 28231005 | Q1 Cooldown and Acceptance Test | 2014-07-15 → 2014-08-11 (+27d) | 2014-08-25 → 2014-09-22 (+28d) |  |  | 269d → 250d |  |  |
| 28231010 | Q1 Harmonic Coil Test | 2014-08-26 → 2014-09-23 (+28d) | 2014-09-02 → 2014-09-29 (+27d) |  |  | 289d → 270d |  |  |
| 28231000 | HB-Acceptance Test | 2014-09-03 → 2014-09-30 (+27d) | 2014-09-30 → 2014-10-27 (+27d) |  |  | 269d → 250d |  |  |
| 28236010 | Q2 Cooldown and Acceptance Test |  |  |  |  |  | 24368325, 24315037ba, 24368185, 24368265, 24368340, 24315037b → 24368265, 24368340, 24368185, 24315037b, 24368325 |  |
| 28236020 | Q3 Cooldown and Acceptance Test |  |  |  |  |  | 24315037b, 24315037ba, 24368265, 24368360, 24368185, 24368370 → 24368370, 24368265, 24368185, 24368360, 24315037b |  |
| 2824X000 | H-D PRE-OPS Cmmssn with Beam |  |  |  |  |  |  | resources MECH ENG [270 h]; CONTRB UNIV LBR [1440 h]; MECH TECH [160 h]; VISTNG USERS [960 h]; SCIENTIST [1440 h] → SCIENTIST [1440 h]; MECH ENG [270 h]; CONTRB UNIV LBR [1440 h]; MECH TECH [160 h]; VISTNG USERS [960 h] |
| 1 | **1.8.2.4.1 HALL D SOLENOID COMMISSIONING** |  | 2014-10-06 → 2014-12-08 (+63d) |  |  |  |  |  |
| 18241000 | Install cryo/magnet elect/pipe interface | 2012-10-01 A | 2012-12-21 → 2012-12-17 A (-4d) |  | 0% → 100% | 126d → none | 9-130M, 151173a, 151173aa → 151173a, 151173aa FS-60d, 9-130M |  |
| 18241005 | Prepare for Solenoid Readiness review | 2012-10-12 → 2012-10-01 A (-11d) | 2012-12-21 → 2012-11-12 A (-39d) | 49d → 31d | 0% → 100% | 126d → none |  |  |
| 18241010 | Cooldown Controls Test (SOLENOID) | 2012-10-30 → 2012-11-12 A (+13d) | 2012-12-03 → 2012-12-16 A (+13d) | 23d → 36d | 0% → 100% | 8d → none | 151080, 151185 FS+21d → 151080, 151185 FS-15d | was named Controls Test (SOLENOID); resources MECH DES [305 h]; SCIENTIST [305 h]; MECH TECH [305 h]; MECH ENG [305 h] → MECH TECH [305 h]; MECH ENG [305 h]; MECH DES [305 h]; SCIENTIST [305 h] |
| 18241015 | Cooldown to 100 K (SOLENOID) | 2012-11-12 → 2012-12-08 A (+26d) | 2012-11-30 → 2013-01-21 A (+52d) |  | 0% → 100% | 91d → none |  |  |
| 18241035 | Controls Test Solenoid (SOLENOID) | 2013-01-10 → 2013-01-14 A (+4d) | 2013-01-28 → 2013-05-13 A (+105d) |  | 0% → 100% | 91d → none | 18241030 → 18241030 FS-40d |  |
| 18241020 | Cooldown to 4 K (SOLENOID) | 2012-12-03 → 2013-03-04 A (+91d) | 2012-12-11 → 2013-04-15 A (+125d) |  | 0% → 100% | 91d → none |  |  |
| 18241025 | Fill with LHE (SOLENOID) | 2012-12-13 → 2013-04-13 A (+121d) | 2012-12-21 → 2013-04-21 A (+121d) |  | 0% → 100% | 91d → none |  |  |
| 18241040 | Pwr Test Solenoid (SOLENOID) | 2013-01-29 → 2013-04-15 A (+76d) | 2013-02-20 → 2013-08-22 A (+183d) |  | 0% → 100% | 91d → none | 18241035 → 18241035 FS-20d |  |
| 18241030 | Static Test Coils (SOLENOID) | 2012-12-31 → 2013-04-22 A (+112d) | 2013-01-09 → 2013-04-29 A (+110d) |  | 0% → 100% | 91d → none |  |  |
| 18241050 | Re-Baseline Actuals Adjustment | 2013-08-30 A | 2013-08-30 A |  | 0% → 100% | 20d → none | 9-130M FS+227d → none |  |
| 25213030 | Consultant Fee (Quench Study WS) | 2013-09-03 A | 2013-09-30 → 2013-09-23 A (-7d) |  | 0% → 100% | 247d → none |  |  |

| ID | Task | Start | Finish | Duration | Complete | Total float | Predecessors | Other |
| --- | --- | --- | --- | --- | --- | --- | --- | --- |
| 28241000 | Maintanence Support Solenoid | 2013-09-03 → 2013-11-01 (+59d) | 2013-09-30 → 2013-12-02 (+63d) |  |  | 54d → 11d |  | was named Maintanence Support Solenoid FY13 |
| 28241000a | Maintanence Support Solenoid FY14 | 2013-10-01 → 2013-12-03 (+63d) | 2014-10-06 → 2014-12-08 (+63d) |  |  | 54d → 11d | 28241000, 9-130M FS+228d, 251250M FS-20d → 28241000 |  |
| 3 | **1.8.2.4.3 HALL D ONLINE CHECKOUT** | 2013-01-29 → 2013-07-01 (+153d) |  |  |  |  |  |  |
| 1 | **1.8.2.4.3.1 HALL D DAQ CHECKOUT** | 2013-04-22 → 2013-08-30 (+130d) |  |  |  |  |  |  |
| 182431000 | Check-out Counting House & Equip (DAQ) | 2013-04-22 → 2013-08-30 A (+130d) | 2013-06-19 → 2013-08-30 A (+72d) |  | 0% → 100% | 71d → none |  |  |
| 182431010 | Check-out DAQ Electrnc's (DAQ) | 2013-05-21 → 2013-08-30 A (+101d) | 2013-08-30 A | 72d → 84d | 0% → 100% | 20d → none |  |  |
| 182431015 | Re-Baseline Actuals Adjustment | 2013-08-30 A | 2013-08-30 A |  | 0% → 100% | 20d → none | 9-130M FS+227d → none |  |
| 2 | **1.8.2.4.3.2 HALL D SOFTWARE CHECKOUT** | 2013-01-29 → 2013-07-01 (+153d) |  |  |  |  |  |  |
| 182432080 | Check-out Experiment Control Software DAQ Interface | 2013-02-21 → 2013-07-01 A (+130d) | 2013-08-30 → 2013-07-15 A (-46d) | 135d → 10d | 0% → 100% | 20d → none |  | resources SCIENTIST [39.27 h] → SCIENTIST [45.09 h] |
| 182432000 | Check-out Front-End Software | 2013-03-04 → 2013-08-30 A (+179d) | 2013-08-30 A | 128d → 110d | 0% → 100% | 20d → none |  |  |
| 182432005 | Check-out Monitoring | 2013-08-01 → 2013-08-30 A (+29d) | 2013-08-30 A | 22d → 42d | 0% → 100% | 20d → none | 1532080ba FS-200d, 1532080f FS-200d, 1532082 FS-22d, 1532080c FS-100d, 1532080da FS-200d, 1532080a FS-190d, 1532080g FS-22d, 1532080 → 1532082 FS-140d, 1532080c FS-100d, 1532080f FS-200d, 1532080da FS-200d, 1532080a FS-190d, 1532080g FS-220d, 1532080ba FS-200d, 1532080 |  |
| 182432010 | Check-out Alarm Sys | 2013-07-17 → 2013-08-30 A (+44d) | 2013-08-30 A | 33d → 53d | 0% → 100% | 20d → none |  |  |
| 182432015 | Check-out Archiving Sys | 2013-04-09 → 2013-08-30 A (+143d) | 2013-08-30 A | 102d → 122d | 0% → 100% | 20d → none |  |  |
| 182432020 | Check-out Event Displays | 2013-02-15 → 2013-08-30 A (+196d) | 2013-08-30 A | 138d → 10d | 0% → 100% | 20d → none |  |  |
| 182432025 | Check-out Storage Mngmnt Software | 2013-04-09 → 2013-08-30 A (+143d) | 2013-08-30 A | 102d → 122d | 0% → 100% | 20d → none |  |  |
| 182432030 | Check-out Experiment Control Software Framework | 2013-04-02 → 2013-08-30 A (+150d) | 2013-08-30 A | 107d → 10d | 0% → 100% | 20d → none |  |  |
| 182432035 | Check-out Experiment Control Software Display Manegement | 2013-04-16 → 2013-08-30 A (+136d) | 2013-08-30 A | 97d → 10d | 0% → 100% | 20d → none |  |  |
| 182432040 | Check-out Experiment Control Software Backup/Restore | 2013-04-04 → 2013-08-30 A (+148d) | 2013-08-30 A | 105d → 50d | 0% → 100% | 20d → none |  |  |
| 182432045 | Check-out Experiment Control Software Magnet PS | 2013-04-09 → 2013-08-30 A (+143d) | 2013-08-30 A | 102d → 110d | 0% → 100% | 20d → none |  |  |
| 182432050 | Check-out Experiment Control Software HV | 2013-01-29 → 2013-08-30 A (+213d) | 2013-08-30 A | 151d → 10d | 0% → 100% | 20d → none |  |  |
| 182432055 | Check-out Experiment Control Software LV | 2013-01-29 → 2013-08-30 A (+213d) | 2013-08-30 A | 151d → 10d | 0% → 100% | 20d → none |  |  |
| 182432060 | Check-out Experiment Control Software Motors | 2013-02-21 → 2013-08-30 A (+190d) | 2013-08-30 A | 135d → 82d | 0% → 100% | 20d → none |  |  |
| 182432065 | Check-out Experiment Control Software Gas Systems | 2013-04-09 → 2013-08-30 A (+143d) | 2013-08-30 A | 102d → 110d | 0% → 100% | 20d → none |  |  |
| 182432070 | Check-out Experiment Control Software Temperature | 2013-04-09 → 2013-08-30 A (+143d) | 2013-08-30 A | 102d → 110d | 0% → 100% | 20d → none |  |  |
| 182432075 | Check-out Experiment Control Software Target | 2013-03-12 → 2013-08-30 A (+171d) | 2013-08-30 A | 122d → 110d | 0% → 100% | 20d → none |  |  |
| 182432085 | Level 1 Trigger Expert Software | 2013-04-10 → 2013-08-30 A (+142d) | 2013-08-30 A | 101d → 121d | 0% → 100% | 20d → none | 9-130M FS+127d → none |  |
| 182432090 | Re-Baseline Actuals Adjustment | 2013-08-30 A | 2013-08-30 A |  | 0% → 100% | 20d → none | 9-130M FS+227d → none |  |
| 282432010 | Check-out Alarm Sys | 2013-11-20 → 2013-11-26 (+6d) | 2014-06-03 → 2014-06-09 (+6d) |  |  | 83d → 79d |  |  |
| 282432015 | Check-out Archiving Sys | 2014-04-01 → 2014-04-29 (+28d) |  | 128d → 108d |  |  |  |  |
| 4 | **1.8.2.4.4 HALL D TRIGGER AND ELECTRONICS CHECKOUT** |  | 2014-09-30 → 2014-09-26 (-4d) |  |  |  |  |  |
| 3 | **1.8.2.4.4.3 HALL D TRIGGER BOARDS ACCEPTANCE TESTING** |  | 2014-09-30 → 2014-09-26 (-4d) |  |  |  |  |  |
| 182443000 | Acceptance test of TS board (FE grp) | 2013-03-01 → 2012-10-01 A (-151d) | 2013-07-30 → 2012-10-15 A (-288d) | 106d → 11d | 0% → 100% | 128d → none |  |  |
| 182443005 | Acceptance test of TI boards (FE grp) FY13 | 2012-10-01 → 2012-11-05 A (+35d) | 2013-01-18 → 2012-11-19 A (-60d) |  | 0% → 100% | 111d → none |  |  |
| 182443015 | Acceptance test of SSP boards (FE grp) | 2013-01-10 → 2013-03-04 A (+53d) | 2013-05-30 → 2013-05-13 A (-17d) |  | 0% → 100% | 20d → none |  |  |
| 182443010 | Acceptance test of CTP boards (FE grp) | 2013-01-10 → 2013-05-06 A (+116d) | 2013-05-30 → 2013-08-30 A (+92d) | 98d → 74d | 0% → 100% | 20d → none | 1543025 FS-55d → 1543025 FS-40d |  |
| 182443020 | Acceptance test of GTP boards (FE grp) | 2013-05-09 → 2013-08-30 A (+113d) | 2013-07-30 → 2013-08-30 A (+31d) |  | 0% → 100% | 43d → none |  |  |
| 182443025 | Trigger Calibration (Hall D grp) | 2012-10-01 → 2013-08-30 A (+333d) | 2013-08-30 A | 228d → 178d | 0% → 100% | 20d → none |  |  |
| 182443030 | Re-Baseline Actuals Adjustment | 2013-08-30 A | 2013-08-30 A |  | 0% → 100% | 20d → none | 9-130M FS+227d → none |  |
| 282443010 | Acceptance test of CTP boards (FE grp) FY13 | 2013-09-03 A | 2013-09-30 → 2014-01-31 (+123d) |  | 0% → 70% | 214d → 150d | 2543025 FS-20d, 2543030 FS-20d → 2543025 FS-80d, 2543030 FS-20d |  |
| 282443010a | Acceptance test of CTP boards (FE grp) FY14 | 2013-10-01 → 2013-09-03 A (-28d) | 2013-10-18 → 2014-01-31 (+105d) |  | 0% → 70% | 214d → 150d | 282443010, 2543025 FS-20d, 2543030 FS-20d → 282443010 FS-55d |  |
| 282443020 | Acceptance test of GTP boards (FE grp) FY13 | 2013-09-03 A | 2013-09-30 → 2013-09-23 A (-7d) | 20d → 57d | 0% → 100% | 151d → none |  |  |
| 282443020a | Acceptance test of GTP boards (FE grp) FY14 | 2013-10-01 → 2013-09-03 A (-28d) | 2013-11-20 → 2013-09-23 A (-58d) |  | 0% → 100% | 151d → none | 9-130M FS+228d, 282443020 → 282443020 |  |
| 282443025a5 | Acceptance test of TS boards (FE_grp) FY13 | 2013-09-03 → 2013-10-01 A (+28d) | 2013-09-30 → 2013-10-21 A (+21d) |  | 0% → 100% | 232d → none |  |  |
| 282443025a5a | Acceptance test of TS boards (FE_grp) FY14 | 2013-10-01 A | 2013-10-21 A |  | 0% → 100% | 232d → none | 282443025a5, 9-130M FS+228d, 2543155 FS-286d → 282443025a5 |  |
| 282443025a | Trigger Calibration (Hall D grp) | 2014-01-10 → 2014-01-08 (-2d) | 2014-09-30 → 2014-09-26 (-4d) |  |  | 0d → 2d |  |  |
| 6 | **1.8.2.4.4.6 HALL D DETECTOR ELECTRONICS BOARDS CHECKOUT** | 2012-10-01 → 2012-11-05 (+35d) | 2013-11-21 → 2013-11-22 (+1d) |  |  |  |  |  |
| 182446005 | Test BCAL Readout System | 2012-10-08 → 2012-11-05 A (+28d) | 2012-11-16 → 2013-08-30 A (+287d) |  | 0% → 100% | 213d → none | 182446000 FS-5d, 1546330 → 1546330, 182446000 FS-90d |  |
| 182446000 | Test Power Distribution FY13 | 2012-10-01 → 2013-08-30 A (+333d) | 2012-10-12 → 2013-08-30 A (+322d) |  | 0% → 100% | 213d → none |  |  |
| 182446010 | Test Pair Spectrometer PS Readout Board | 2012-12-05 → 2013-08-30 A (+268d) | 2013-01-23 → 2013-08-30 A (+219d) |  | 0% → 100% | 151d → none |  | resources ELEC TECH [68 h]; ELEC ENG [34 h] → ELEC ENG [34 h]; ELEC TECH [68 h] |
| 182446015 | Test Pair Spectrometer Transition Board | 2012-11-05 → 2013-08-30 A (+298d) | 2012-12-18 → 2013-08-30 A (+255d) |  | 0% → 100% | 170d → none | 1546430 FS+25d → 1546430 FS-15d |  |
| 182446020 | Test Pair Spectrometer Power Distribution | 2012-11-19 → 2013-08-30 A (+284d) | 2013-01-09 → 2013-08-30 A (+233d) |  | 0% → 100% | 160d → none | 1546435 FS+35d → 1546435 FS-5d |  |
| 182446025 | Test Pair Spectrometer System | 2013-01-24 → 2013-08-30 A (+218d) | 2013-02-26 → 2013-08-30 A (+185d) |  | 0% → 100% | 151d → none |  |  |
| 182446030 | Test Start Counter Readout Board | 2013-05-13 → 2013-08-30 A (+109d) | 2013-06-14 → 2013-08-30 A (+77d) |  | 0% → 100% | 74d → none |  |  |
| 182446035 | Test Start Counter Transition Board | 2013-05-20 → 2013-08-30 A (+102d) | 2013-06-21 → 2013-08-30 A (+70d) |  | 0% → 100% | 69d → none |  |  |
| 182446040 | Test Start Counter Power Distribution | 2013-06-10 → 2013-08-30 A (+81d) | 2013-07-19 → 2013-08-30 A (+42d) |  | 0% → 100% | 50d → none |  |  |
| 182446045 | Re-Baseline Actuals Adjustment | 2013-08-30 A | 2013-08-30 A |  | 0% → 100% | 20d → none | 9-130M FS+227d → none |  |
| 282446000 | Test Power Distribution FY13 | 2013-09-09 → 2013-10-01 A (+22d) | 2013-09-30 → 2013-11-15 (+46d) |  | 0% → 55% |  |  |  |
| 282446000a | Test Power Distribution FY14 | 2013-10-01 A |  |  | 0% → 55% |  | 9-130M FS+232d, 282446000 → 282446000 FS-40d |  |
| 282446010 | Test Pair Spectrometer PS Readout Board | 2013-10-07 → 2013-10-01 A (-6d) |  |  | 0% → 50% | 199d → 219d |  |  |
| 282446015a | Test Pair Spectrometer Transition Board | 2013-10-07 → 2013-10-01 A (-6d) |  |  | 0% → 50% | 199d → 219d |  |  |
| 282446020 | Test Pair Spectrometer Power Distribution | 2013-10-07 → 2013-10-01 A (-6d) | 2013-11-21 → 2013-11-20 (-1d) |  | 0% → 50% | 199d → 220d |  |  |
| 282446025 | Test Pair Spectrometer System | 2013-10-07 → 2013-10-01 A (-6d) | 2013-11-21 → 2013-11-20 (-1d) |  | 0% → 30% | 199d → 200d |  |  |
| 282446030 | Test Start Counter Readout Board FY13 | 2013-09-09 → 2013-10-01 A (+22d) | 2013-09-30 → 2013-11-22 (+53d) |  | 0% → 40% | 199d → 198d |  |  |
| 282446030a | Test Start Counter Readout Board FY14 | 2013-10-01 A | 2013-11-21 → 2013-11-22 (+1d) |  | 0% → 40% | 199d → 198d | 282446030, 9-130M FS+232d → 282446030 FS-20d |  |
| 282446035 | Test Start Counter Transition Board FY13 | 2013-09-09 → 2013-10-01 A (+22d) | 2013-09-30 → 2013-11-22 (+53d) |  | 0% → 25% | 228d → 198d |  |  |
| 282446035a | Test Start Counter Transition Board FY14 | 2013-10-01 A | 2013-10-11 → 2013-11-22 (+42d) |  | 0% → 25% | 228d → 198d | 9-130M FS+232d, 282446035 → 282446035 FS-20d |  |
| 282446040 | Test Start Counter Power Distribution FY13 | 2013-09-09 → 2013-10-01 A (+22d) | 2013-09-30 → 2013-11-22 (+53d) |  | 0% → 50% | 213d → 198d |  |  |
| 282446040a | Test Start Counter Power Distribution FY14 | 2013-10-01 A | 2013-11-01 → 2013-11-22 (+21d) |  | 0% → 50% | 213d → 198d | 9-130M FS+232d, 282446040 → 282446040 FS-20d |  |
| 5 | **1.8.2.4.5 HALL D BEAMLINE** | 2013-09-03 → 2013-11-01 (+59d) |  |  |  |  |  |  |
| 3 | **1.8.2.4.5.3 HALL D BEAMLINE COMPONENT TESTING** | 2013-09-03 → 2013-11-01 (+59d) |  |  |  |  |  |  |

| ID | Task | Start | Finish | Duration | Complete | Total float | Predecessors | Other |
| --- | --- | --- | --- | --- | --- | --- | --- | --- |
| 282453010 | Test PS High Granularity Counters FY13 | 2013-09-03 → 2013-11-01 (+59d) | 2013-09-30 → 2013-12-02 (+63d) |  |  | 213d → 170d |  |  |
| 282453010a | Test PS High Granularity Counters FY14 | 2013-10-01 → 2013-12-03 (+63d) | 2013-11-01 → 2014-01-15 (+75d) |  |  | 213d → 170d | 2553042 FS-20d, 282453010 → 282453010 |  |
| 6 | **1.8.2.4.6 HALL D INFRASTUCTURE** | 2013-12-02 → 2013-12-04 (+2d) | 2014-09-30 → 2014-08-29 (-32d) |  |  |  |  |  |
| 2 | **1.8.2.4.6.2 HALL D INSTALLATION TESTING** | 2013-12-02 → 2013-12-04 (+2d) | 2014-09-30 → 2014-08-29 (-32d) |  |  |  |  |  |
| 282462050 | System Check-out Install Hall FCAL | 2013-12-02 → 2013-12-04 (+2d) | 2014-01-08 → 2014-01-10 (+2d) |  |  | 185d → 183d | 2562700, 2562475ca, 2562475c → 2562475c, 2562700 |  |
| 282462040 | System Check-out Install Hall BCAL | 2014-01-31 → 2014-01-02 (-29d) | 2014-06-06 → 2014-05-08 (-29d) |  |  | 80d → 100d |  |  |
| 282462005 | Operation Checks FDC (outside Solenoid) (Installtn) | 2013-12-02 → 2014-01-07 (+36d) | 2014-01-10 → 2014-02-06 (+27d) |  |  | 0d → 16d | 2562370c FS-56d, 25211191, 2562370 FS-2d → 25211191 FS-100d, 2562370 FS-2d, 2562370c FS-56d |  |
| 282462020 | System Check-out Install Hall Pair Spectrometer | 2014-02-18 → 2014-02-12 (-6d) | 2014-03-03 → 2014-02-25 (-6d) |  |  | 148d → 152d |  |  |
| 282462010 | Operation Checks FDC (Inside Solenoid) (Installtn) | 2014-02-04 → 2014-02-28 (+24d) | 2014-09-30 → 2014-08-27 (-34d) | 168d → 127d |  | 0d → 23d |  |  |
| 282462030 | System Check-out Install Hall CDC | 2014-02-12 → 2014-03-03 (+19d) | 2014-04-04 → 2014-04-23 (+19d) |  |  | 124d → 111d |  |  |
| 282462035 | System Check-out Install Hall FDC | 2014-02-26 → 2014-03-24 (+26d) | 2014-05-20 → 2014-06-16 (+27d) |  |  | 92d → 74d |  |  |
| 282462000 | Operational Checks CDC (Inside Solenoid) (Installtn) | 2014-03-28 → 2014-04-18 (+21d) | 2014-08-08 → 2014-08-29 (+21d) |  |  | 17d → 2d | 2562280 FS-19d, 2562303 FS-10d, 2562300, 2562301 FS+1d → 2562301 FS+1d, 2562300, 2562280 FS-45d, 2562303 FS-10d |  |
| 282462025 | System Check-out Install Hall Start Counter | 2014-07-24 → 2014-08-08 (+15d) | 2014-08-01 → 2014-08-18 (+17d) |  |  | 41d → 30d |  |  |
| 1831950 | Re-Baseline Actuals Adjustment | 2013-08-30 A | 2013-08-30 A |  | 0% → 100% | 20d → none | 9-130M FS+227d → none |  |
| 2831913LOE | FY13 Pre-Ops Supprt - Proj Office | 2013-09-03 A | 2013-09-30 A |  | 0% → 100% | 311d → none |  |  |
| 2831914LOE | FY14 Pre-Ops Supprt - Proj Office | 2013-10-01 A |  |  | 0% → 9% |  |  |  |
| 2831916LOE | FY16 Pre-Ops Supprt - Proj Office |  |  |  |  |  |  | resources SR STAFF [3366 h]; OFFICE [2640 h]; ELEC ENG [660 h]; DIRECTORATE [2310 h]; SUPPLIES & MATERIALS; ADMIN [1320 h]; SCIENTIST [264 h]; MECH ENG [2640 h] → MECH ENG [2640 h]; SR STAFF [3366 h]; OFFICE [2640 h]; ELEC ENG [660 h]; DIRECTORATE [2310 h]; SUPPLIES & MATERIALS; ADMIN [1320 h]; SCIENTIST [264 h] |
| 9 | **1.9 VA STATE** |  | 2013-10-31 → 2013-12-05 (+35d) |  |  |  |  |  |
| 5 | **1.9.5 HALL D - VA STATE** |  | 2013-10-31 → 2013-12-05 (+35d) |  |  |  |  |  |
| 1951000 | Re-Baseline Actuals Adjustment | 2013-08-30 A | 2013-08-30 A |  | 0% → 100% | 20d → none | 9-130M FS+227d → none |  |
| 2 | **1.9.5.2 HALL D DETECTORS** |  | 2013-10-31 → 2013-12-05 (+35d) |  |  |  |  |  |
| 1 | **1.9.5.2.1 HALL D TRACKING** |  | 2013-10-31 → 2013-12-05 (+35d) |  |  |  |  |  |
| 2 | **1.9.5.2.1.2 HALL D CENTRAL CHAMBERS** |  | 2013-10-31 → 2013-12-05 (+35d) |  |  |  |  |  |
| 195212010 | Procurement epoxy with delivery in phases (P1 Construction Setup & Straw Penetration) | 2010-04-06 A | 2010-07-30 → 2011-10-10 A (+437d) | 82d → 379d | 0% → 100% | 58d → none |  |  |
| 195212015 | Installation mandril and end plates (P1 Construction Setup & Straw Penetration) | 2010-04-06 A | 2010-07-30 → 2010-08-31 A (+32d) | 82d → 103d | 0% → 100% | 58d → none |  |  |
| 195212020 | Aligned and fix end plates (P1 Construction Setup & Straw Penetration) (P2 Straw Insertion) | 2010-04-06 A | 2010-07-30 → 2010-09-29 A (+61d) | 82d → 124d | 0% → 100% | 58d → none |  |  |
| 195212025 | Straw Preparation Axial section I (P2 Straw Insertion) | 2010-04-06 A | 2010-08-31 → 2010-11-22 A (+83d) | 104d → 162d | 0% → 100% | 58d → none |  | resources PROCUREMENT>$50K 69 NO ESCALATION; PROCUREMENT<$50K 60 NO ESCALATION → PROCUREMENT<$50K 60 NO ESCALATION; PROCUREMENT>$50K 69 NO ESCALATION |
| 195212030 | Insert straws Axial section I (P2 Straw Insertion) | 2010-04-06 A | 2010-08-31 → 2011-01-24 A (+146d) | 104d → 198d | 0% → 100% | 58d → none |  |  |
| 195212035 | Straw preparation Stereo section I-L (P2 Straw Insertion) | 2010-04-06 A | 2010-08-31 → 2011-01-24 A (+146d) | 104d → 198d | 0% → 100% | 58d → none |  |  |
| 195212040 | Insert straws Stereo section 1-L (Phase 2 Straw Insertion) | 2010-04-06 A | 2010-08-31 → 2011-01-24 A (+146d) | 104d → 198d | 0% → 100% | 58d → none |  |  |
| 195212045 | Straw preparation Stereo section 1-R (P2 Straw Insertion) | 2010-04-06 A | 2010-09-30 → 2011-02-28 A (+151d) | 125d → 222d | 0% → 100% | 58d → none |  |  |
| 195212050 | Insert straws Stereo section 1-R (P2 Straw Insertion) | 2010-04-06 A | 2010-09-30 → 2011-04-25 A (+207d) | 125d → 261d | 0% → 100% | 58d → none |  |  |
| 195212055 | Straw preparation Axial section 2 (P2 Straw Insertion) | 2010-04-06 A | 2010-09-30 → 2011-04-30 A (+212d) | 125d → 266d | 0% → 100% | 58d → none |  |  |
| 195212060 | Insert straws axial section 2 (P2 Straw Insertion) | 2010-04-06 A | 2010-10-29 → 2011-04-30 A (+183d) | 146d → 266d | 0% → 100% | 58d → none |  |  |
| 195212065 | Straw preparation stereo section 2-R-1 (P2 Straw Insertion) | 2010-04-06 A | 2010-11-30 → 2011-04-21 A (+142d) | 166d → 260d | 0% → 100% | 58d → none |  |  |
| 195212070 | Insert strwas stereo section 2-R-1 (P2 Straw Insertion) | 2010-04-06 A | 2010-11-30 → 2011-04-21 A (+142d) | 166d → 260d | 0% → 100% | 58d → none |  |  |
| 195212075 | Straw preparation stereo section 2-R-2 (P2 Straw Insertion) | 2010-04-06 A | 2010-12-30 → 2011-06-18 A (+170d) | 183d → 300d | 0% → 100% | 58d → none |  |  |
| 195212080 | Insert straws stereo section 2-R-2 (P2 Straw Insertion) | 2010-04-06 A | 2010-12-30 → 2011-06-15 A (+167d) | 183d → 298d | 0% → 100% | 58d → none |  |  |
| 195212085 | Straw preparation stereo section 2-L-1 (P2 Straw Insertion) | 2010-04-06 A | 2011-01-31 → 2011-06-12 A (+132d) | 203d → 295d | 0% → 100% | 58d → none |  |  |
| 195212090 | Insert straws stereo section 2-L-1 (P2 Straw Insertion) | 2010-04-06 A | 2011-01-31 → 2011-06-20 A (+140d) | 203d → 301d | 0% → 100% | 58d → none |  |  |
| 195212095 | Straw preparation stereo section 2-L-2 (P2 Straw Insertion) | 2010-04-06 A | 2011-01-31 → 2011-07-18 A (+168d) | 203d → 320d | 0% → 100% | 58d → none |  |  |
| 195212100 | Insert straws stereo section 2-L-2 (P2 Straw Insertion) | 2010-04-06 A | 2011-01-31 → 2011-07-18 A (+168d) | 203d → 320d | 0% → 100% | 58d → none |  |  |
| 195212105 | Straw preparation Axial Section 3-1 (P2 Straw Insertion) | 2010-04-06 A | 2011-02-28 → 2011-08-30 A (+183d) | 222d → 351d | 0% → 100% | 58d → none |  |  |
| 195212110 | Insert straws axial section 3-1 (P2 Straw Insertion) | 2010-04-06 A | 2011-02-28 → 2011-08-30 A (+183d) | 222d → 351d | 0% → 100% | 58d → none |  |  |
| 195212115 | Straw preparation Axial Section 3-2 (P2 Straw Insertion) | 2010-04-06 A | 2011-03-31 → 2011-09-19 A (+172d) | 245d → 364d | 0% → 100% | 58d → none |  |  |
| 195212120 | Insert Straws Axial Section 3-2 (P2 Straw Insertion) | 2010-04-06 A | 2011-03-31 → 2011-09-19 A (+172d) | 245d → 364d | 0% → 100% | 58d → none |  |  |
| 195212125 | Install Gas lines in CDC volume (P3 Shell Installation) | 2010-04-06 A | 2011-04-29 → 2011-09-19 A (+143d) | 266d → 364d | 0% → 100% | 58d → none |  |  |
| 195212130 | Install sensors in CDC Volume (P3 Shell Installation) | 2010-04-06 A | 2011-04-29 → 2011-10-17 A (+171d) | 266d → 384d | 0% → 100% | 58d → none |  |  |
| 195212135 | Installation outer shell (P3 Shell Installation) | 2010-04-06 A | 2011-05-31 → 2011-10-17 A (+139d) | 287d → 384d | 0% → 100% | 58d → none |  |  |
| 195212140 | String 1st axial section (P3 Chamber stringing) | 2010-04-06 A | 2011-05-31 → 2011-06-21 A (+21d) | 287d → 302d | 0% → 100% | 58d → none |  |  |
| 195212145 | String 1st stereo section (P3 Chamber stringing) | 2010-04-06 A | 2011-06-30 → 2011-12-19 A (+172d) | 309d → 427d | 0% → 100% | 58d → none |  |  |
| 195212150 | String 2nd stereo section (P3 Chamber stringing) | 2010-04-06 A | 2011-05-31 → 2011-12-19 A (+202d) | 287d → 427d | 0% → 100% | 58d → none |  |  |
| 195212155 | String 2nd axial section (P3 Chamber stringing) | 2010-04-06 A | 2011-08-31 → 2011-10-17 A (+47d) | 352d → 384d | 0% → 100% | 58d → none |  |  |
| 195212160 | String 3rd stereo section (inner) (P3 Chamber stringing) | 2010-04-06 A | 2011-08-31 → 2012-02-13 A (+166d) | 352d → 460d | 0% → 100% | 58d → none |  |  |
| 195212165 | String 3rd stereo section (outer) (P3 Chamber stringing) | 2010-04-06 A | 2011-09-30 → 2012-02-13 A (+136d) | 373d → 460d | 0% → 100% | 58d → none |  |  |
| 195212170 | String 4th stereo section (inner) (P3 Chamber stringing) | 2010-04-06 A | 2011-10-31 → 2012-02-20 A (+112d) | 394d → 464d | 0% → 100% | 58d → none |  |  |
| 195212175 | String 4th stereo section (outer) (P3 Chamber stringing) | 2010-04-06 A | 2011-11-30 → 2012-02-20 A (+82d) | 414d → 464d | 0% → 100% | 58d → none |  |  |
| 195212180 | String 3rd axial section (inner) (P3 Chamber stringing) | 2010-04-06 A | 2011-12-30 → 2011-11-30 A (-30d) | 431d → 414d | 0% → 100% | 58d → none |  |  |
| 195212185 | String 3rd axial section (outer) (P3 Chamber stringing) | 2010-04-06 A | 2012-01-31 → 2011-11-30 A (-62d) | 451d → 414d | 0% → 100% | 58d → none |  |  |
| 195212190 | Electronics installation 1st axial section (P4 Chamber instrumentation) | 2010-04-06 A | 2012-01-31 → 2012-05-14 A (+104d) | 451d → 524d | 0% → 100% | 58d → none |  |  |
| 195212195 | Electronics installation 1st stereo section (P4 Chamber instrumentation) | 2010-04-06 A | 2012-02-29 → 2012-06-11 A (+103d) | 471d → 542d | 0% → 100% | 58d → none |  |  |
| 195212200 | Electronics installation 2nd stereo section (P4 Chamber instrumentation) | 2010-04-06 A | 2012-02-29 → 2012-06-11 A (+103d) | 471d → 542d | 0% → 100% | 58d → none |  |  |
| 195212205 | Electronics installation 2nd axial section (P4 Chamber instrumentation) | 2010-04-06 A | 2012-03-30 → 2012-07-16 A (+108d) | 493d → 567d | 0% → 100% | 58d → none |  |  |
| 195212210 | Electronics installation 3rd stereo section (inner) (P4 Chamber instrumentation) | 2010-04-06 A | 2012-03-30 → 2012-07-16 A (+108d) | 493d → 567d | 0% → 100% | 58d → none |  |  |
| 195212215 | Electronics installation 3rd stereo section (outer) (P4 Chamber instrumentation) | 2010-04-06 A | 2012-04-30 → 2012-07-16 A (+77d) | 514d → 567d | 0% → 100% | 58d → none |  |  |
| 195212220 | Electronics installation 4th stereo section (inner) (P4 Chamber instrumentation) | 2010-04-06 A | 2012-04-30 → 2012-08-13 A (+105d) | 514d → 587d | 0% → 100% | 58d → none |  |  |
| 195212225 | Electronics installation 4th stereo section (outer) (P4 Chamber instrumentation) | 2010-04-06 A | 2012-05-31 → 2012-10-15 A (+137d) | 536d → 631d | 0% → 100% | 58d → none |  |  |
| 195212230 | Electronics installation 3rd axial section (inner) (P4 Chamber instrumentation) | 2010-04-06 A | 2012-05-31 → 2012-10-22 A (+144d) | 536d → 636d | 0% → 100% | 58d → none |  |  |
| 195212235 | Electronics installation 3rd axial section (outer) (P4 Chamber instrumentation) | 2010-04-06 A | 2012-06-29 → 2012-11-12 A (+136d) | 556d → 651d | 0% → 100% | 58d → none |  |  |
| 195212240 | Close up gas upstream and downstream gas plenum (P5 Chamber operational tests) | 2010-04-06 A | 2012-07-31 → 2013-03-11 A (+223d) | 578d → 751d | 0% → 100% | 58d → none |  |  |

| ID | Task | Start | Finish | Duration | Complete | Total float | Predecessors | Other |
| --- | --- | --- | --- | --- | --- | --- | --- | --- |
| 195212245 | Gas leak tests (P5 Chamber operational tests) | 2010-04-06 A | 2012-08-31 → 2013-03-11 A (+192d) | 601d → 761d | 0% → 100% | 58d → none |  |  |
| 195212250 | HV tests (P5 Chamber operational tests) | 2010-04-06 A | 2012-10-31 → 2013-05-13 A (+194d) | 643d → 806d | 0% → 100% | 58d → none |  |  |
| 195212255 | Operations Test (P5 Chamber operational tests) | 2010-04-06 A | 2013-02-28 → 2013-08-30 A (+183d) | 719d → 802d | 0% → 100% | 58d → none |  |  |
| 195212260 | Phase 7 Chamber shipping | 2010-04-06 A | 2013-03-29 → 2013-08-30 A (+154d) | 740d → 802d | 0% → 100% | 58d → none |  |  |
| 195212265 | Re-Baseline Actuals Adjustment | 2013-08-30 A | 2013-08-30 A |  | 0% → 100% | 20d → none | 9-130M FS+227d → none |  |
| 295212255 | Operations Test (P5 Chamber operational tests) | 2013-09-03 A | 2013-10-31 → 2013-12-05 (+35d) |  | 0% → 20% | 63d → 102d |  | resources PROCUREMENT<$50K 60 NO ESCALATION; PROCUREMENT>$50K 69 NO ESCALATION → PROCUREMENT>$50K 69 NO ESCALATION |
| 295212260 | Phase 7 Chamber shipping | 2013-09-03 A | 2013-10-31 → 2013-10-21 A (-10d) |  | 0% → 100% | 63d → none |  |  |
| 2 | **1.9.5.2.2 HALL D CALORIMETRY** |  | 2013-10-31 → 2013-09-23 (-38d) |  |  |  |  |  |
| 195221015 | Bcal Module Construction Manager Phase 2 (LOE) | 2010-03-02 A | 2010-12-31 A |  | 0% → 100% | 84d → none |  | resources PROCUREMENT<$50K 60 NO ESCALATION; PROCUREMENT>$50K 69 NO ESCALATION → PROCUREMENT>$50K 69 NO ESCALATION; PROCUREMENT<$50K 60 NO ESCALATION |
| 195221030 | Module #9 Matrix Fabrication | 2010-03-02 A | 2010-04-30 → 2010-05-24 A (+24d) | 44d → 60d | 0% → 100% | 595d → none |  |  |
| 195221035 | Module #9 Machining and Shipping | 2010-03-02 A | 2010-07-12 → 2010-08-10 A (+29d) | 93d → 114d | 0% → 100% | 541d → none |  |  |
| 195221040 | Module #10 Matrix Fabrication | 2010-03-02 A | 2010-04-30 → 2010-05-24 A (+24d) | 44d → 60d | 0% → 100% | 595d → none |  |  |
| 195221045 | Module #10 Machining and Shipping | 2010-03-02 A | 2010-07-12 → 2010-08-10 A (+29d) | 93d → 114d | 0% → 100% | 541d → none |  |  |
| 195221050 | Module #11 Matrix Fabrication | 2010-03-02 A | 2010-06-08 A |  | 0% → 100% | 569d → none |  |  |
| 195221055 | Module #11 Machining and Shipping | 2010-03-02 A | 2010-07-12 → 2010-08-10 A (+29d) | 93d → 114d | 0% → 100% | 541d → none |  |  |
| 195221060 | Module #12 Matrix Fabrication | 2010-03-02 A | 2010-06-08 A |  | 0% → 100% | 569d → none |  |  |
| 195221065 | Module #12 Machining and Shipping | 2010-03-02 A | 2010-07-12 → 2010-08-10 A (+29d) | 93d → 114d | 0% → 100% | 541d → none |  |  |
| 195221070 | Module #13 Matrix Fabrication | 2010-03-02 A | 2010-07-15 → 2010-07-26 A (+11d) | 96d → 103d | 0% → 100% | 543d → none |  |  |
| 195221075 | Module #13 Machining and Shipping | 2010-03-02 A | 2010-09-24 → 2010-09-20 A (-4d) | 146d → 142d | 0% → 100% | 488d → none |  |  |
| 195221080 | Module #14 Matrix Fabrication | 2010-03-02 A | 2010-07-15 → 2010-07-26 A (+11d) | 96d → 103d | 0% → 100% | 543d → none |  |  |
| 195221085 | Module #14 Machining and Shipping | 2010-03-02 A | 2010-09-24 → 2010-09-20 A (-4d) | 146d → 142d | 0% → 100% | 488d → none |  |  |
| 195221090 | Module #15 Matrix Fabrication | 2010-03-02 A | 2010-08-23 A |  | 0% → 100% | 516d → none |  |  |
| 195221095 | Module #15 Machining and Shipping | 2010-03-02 A | 2010-09-24 → 2010-09-20 A (-4d) | 146d → 142d | 0% → 100% | 488d → none |  |  |
| 195221100 | Module #16 Matrix Fabrication | 2010-03-02 A | 2010-08-23 A |  | 0% → 100% | 516d → none |  |  |
| 195221105 | Module #16 Machining and Shipping | 2010-03-02 A | 2010-09-24 → 2010-09-20 A (-4d) | 146d → 142d | 0% → 100% | 488d → none |  |  |
| 195221110 | Module #17 Matrix Fabrication | 2010-03-02 A | 2010-09-29 → 2010-08-30 A (-30d) | 149d → 128d | 0% → 100% | 490d → none |  |  |
| 195221115 | Module #17 Machining and Shipping | 2010-03-02 A | 2010-12-09 A |  | 0% → 100% | 436d → none |  |  |
| 195221120 | Module #18 Matrix Fabrication | 2010-03-02 A | 2010-09-29 → 2010-08-31 A (-29d) | 149d → 129d | 0% → 100% | 490d → none |  |  |
| 195221125 | Module #18 Machining and Shipping | 2010-03-02 A | 2010-12-09 A |  | 0% → 100% | 436d → none |  |  |
| 195221130 | Module #19 Matrix Fabrication | 2010-03-02 A | 2010-11-05 → 2010-09-20 A (-46d) | 176d → 142d | 0% → 100% | 463d → none |  |  |
| 195221135 | Module #19 Machining and Shipping | 2010-03-02 A | 2010-12-29 A |  | 0% → 100% | 427d → none |  |  |
| 195221140 | Module #20 Matrix Fabrication | 2010-03-02 A | 2010-11-05 → 2010-09-20 A (-46d) | 176d → 142d | 0% → 100% | 463d → none |  |  |
| 195221145 | Module #20 Machining and Shipping | 2010-03-02 A | 2010-12-09 A |  | 0% → 100% | 436d → none |  |  |
| 195221150 | Module #21 Matrix Fabrication | 2010-03-02 A | 2010-12-14 → 2010-10-25 A (-50d) | 201d → 167d | 0% → 100% | 438d → none |  |  |
| 195221155 | Module #21 Machining and Shipping | 2010-03-02 A | 2011-02-23 → 2010-12-16 A (-69d) | 244d → 203d | 0% → 100% | 390d → none |  |  |
| 195221160 | Module #22 Matrix Fabrication | 2010-03-02 A | 2010-12-14 → 2010-10-25 A (-50d) | 201d → 167d | 0% → 100% | 438d → none |  |  |
| 195221165 | Module #22 Machining and Shipping | 2010-03-02 A | 2011-02-23 → 2010-12-17 A (-68d) | 244d → 204d | 0% → 100% | 390d → none |  |  |
| 195221170 | Module #23 Matrix Fabrication | 2010-03-02 A | 2011-01-20 → 2010-11-22 A (-59d) | 221d → 187d | 0% → 100% | 418d → none |  |  |
| 195221175 | Module #23 Machining and Shipping | 2010-03-02 A | 2011-02-23 → 2010-12-17 A (-68d) | 244d → 204d | 0% → 100% | 390d → none |  |  |
| 195221180 | Module #24 Matrix Fabrication | 2010-03-02 A | 2011-01-20 → 2010-11-22 A (-59d) | 221d → 187d | 0% → 100% | 418d → none |  |  |
| 195221185 | Module #24 Machining and Shipping | 2010-03-02 A | 2011-02-23 → 2011-01-24 A (-30d) | 244d → 223d | 0% → 100% | 390d → none |  |  |
| 195221000 | Proc SciFi Mods P-3 FY11 October Delivery | 2010-10-01 A | 2010-10-29 → 2010-10-25 A (-4d) | 21d → 17d | 0% → 100% | 220d → none |  | resources PROCUREMENT<$50K 60 NO ESCALATION; PROCUREMENT>$50K 69 NO ESCALATION → PROCUREMENT>$50K 69 NO ESCALATION; PROCUREMENT<$50K 60 NO ESCALATION |
| 195221001 | Proc SciFi Mods P-3 FY11 November Delivery | 2010-10-01 A | 2010-11-30 A |  | 0% → 100% | 220d → none |  |  |
| 195221020 | Bcal Module Construction Manager Phase 3 (LOE) | 2011-01-04 → 2010-10-01 A (-95d) | 2011-12-30 A | 247d → 306d | 0% → 100% | 84d → none | 195221015 → 195221015 FS-40d | resources PROCUREMENT>$50K 69 NO ESCALATION; PROCUREMENT<$50K 60 NO ESCALATION → PROCUREMENT<$50K 60 NO ESCALATION; PROCUREMENT>$50K 69 NO ESCALATION |
| 195221025 | Bcal Module Construction Manager Phase 4 (LOE) | 2012-01-03 → 2010-10-01 A (-459d) | 2012-05-22 A | 99d → 405d | 0% → 100% | 84d → none | 195221020 → 195221020 FS-295d |  |
| 195221190 | Module #25 Matrix Fabrication | 2011-01-04 → 2010-10-01 A (-95d) | 2011-02-28 → 2010-12-17 A (-73d) | 38d → 54d | 0% → 100% | 392d → none | 9-110M FS+59d → 9-110M |  |
| 195221195 | Module #25 Machining and Shipping | 2011-01-04 → 2010-10-01 A (-95d) | 2011-05-10 → 2011-04-25 A (-15d) | 89d → 137d | 0% → 100% | 336d → none | 9-110M FS+59d → 9-110M |  |
| 195221200 | Module #26 Matrix Fabrication | 2011-01-04 → 2010-10-01 A (-95d) | 2011-02-28 → 2010-12-22 A (-68d) | 38d → 56d | 0% → 100% | 392d → none | 9-110M FS+59d → 9-110M |  |
| 195221205 | Module #26 Machining and Shipping | 2011-01-04 → 2010-10-01 A (-95d) | 2011-05-10 → 2011-04-25 A (-15d) | 89d → 137d | 0% → 100% | 336d → none | 9-110M FS+59d → 9-110M |  |
| 195221210 | Module #27 Matrix Fabrication | 2011-01-04 → 2010-10-01 A (-95d) | 2011-04-06 → 2011-01-17 A (-79d) | 65d → 68d | 0% → 100% | 365d → none | 9-110M FS+59d → 9-110M |  |
| 195221215 | Module #27 Machining and Shipping | 2011-01-04 → 2010-10-01 A (-95d) | 2011-05-10 → 2011-04-25 A (-15d) | 89d → 137d | 0% → 100% | 336d → none | 9-110M FS+59d → 9-110M |  |
| 195221220 | Module #28 Matrix Fabrication | 2011-01-04 → 2010-10-01 A (-95d) | 2011-04-06 → 2011-01-24 A (-72d) | 65d → 73d | 0% → 100% | 365d → none | 9-110M FS+59d → 9-110M |  |
| 195221225 | Module #28 Machining and Shipping | 2011-01-04 → 2010-10-01 A (-95d) | 2011-05-10 → 2011-04-25 A (-15d) | 89d → 137d | 0% → 100% | 336d → none | 9-110M FS+59d → 9-110M |  |
| 195221230 | Module #29 Matrix Fabrication | 2011-01-04 → 2010-10-01 A (-95d) | 2011-05-13 → 2011-02-28 A (-74d) | 92d → 97d | 0% → 100% | 338d → none | 9-110M FS+59d → 9-110M |  |
| 195221235 | Module #29 Machining and Shipping | 2011-01-04 → 2010-10-01 A (-95d) | 2011-07-25 → 2011-05-09 A (-77d) | 141d → 147d | 0% → 100% | 284d → none | 9-110M FS+59d → 9-110M |  |
| 195221240 | Module #30 Matrix Fabrication | 2011-01-04 → 2010-10-01 A (-95d) | 2011-05-13 → 2011-02-28 A (-74d) | 92d → 97d | 0% → 100% | 338d → none | 9-110M FS+59d → 9-110M |  |
| 195221245 | Module #30 Machining and Shipping | 2011-01-04 → 2010-10-01 A (-95d) | 2011-07-25 → 2011-05-09 A (-77d) | 141d → 147d | 0% → 100% | 284d → none | 9-110M FS+59d → 9-110M |  |
| 195221250 | Module #31 Matrix Fabrication | 2011-01-04 → 2010-10-01 A (-95d) | 2011-06-21 → 2011-03-21 A (-92d) | 118d → 112d | 0% → 100% | 312d → none | 9-110M FS+59d → 9-110M |  |
| 195221255 | Module #31 Machining and Shipping | 2011-01-04 → 2010-10-01 A (-95d) | 2011-07-25 → 2011-05-09 A (-77d) | 141d → 147d | 0% → 100% | 284d → none | 9-110M FS+59d → 9-110M |  |
| 195221260 | Module #32 Matrix Fabrication | 2011-01-04 → 2010-10-01 A (-95d) | 2011-06-21 → 2011-03-21 A (-92d) | 118d → 112d | 0% → 100% | 312d → none | 9-110M FS+59d → 9-110M |  |
| 195221265 | Module #32 Machining and Shipping | 2011-01-04 → 2010-10-01 A (-95d) | 2011-07-25 → 2011-05-09 A (-77d) | 141d → 147d | 0% → 100% | 284d → none | 9-110M FS+59d → 9-110M |  |
| 195221270 | Module #33 Matrix Fabrication | 2011-01-04 → 2010-10-01 A (-95d) | 2011-07-28 → 2011-04-25 A (-94d) | 144d → 137d | 0% → 100% | 286d → none | 9-110M FS+59d → 9-110M |  |
| 195221275 | Module #33 Machining and Shipping | 2011-01-04 → 2010-10-01 A (-95d) | 2011-10-07 → 2011-06-13 A (-116d) | 194d → 171d | 0% → 100% | 231d → none | 9-110M FS+59d → 9-110M |  |
| 195221285 | Module #34 Matrix Fabrication | 2011-01-04 → 2010-10-01 A (-95d) | 2011-07-28 → 2011-04-25 A (-94d) | 144d → 137d | 0% → 100% | 286d → none | 9-110M FS+59d → 9-110M |  |
| 195221290 | Module #34 Machining and Shipping | 2011-01-04 → 2010-10-01 A (-95d) | 2011-10-07 → 2011-06-13 A (-116d) | 194d → 171d | 0% → 100% | 231d → none | 9-110M FS+59d → 9-110M |  |
| 195221295 | Module #35 Matrix Fabrication | 2011-01-04 → 2010-10-01 A (-95d) | 2011-09-06 → 2011-05-02 A (-127d) | 171d → 142d | 0% → 100% | 259d → none | 9-110M FS+59d → 9-110M |  |
| 195221300 | Module #35 Machining and Shipping | 2011-01-04 → 2010-10-01 A (-95d) | 2011-10-07 → 2011-06-13 A (-116d) | 194d → 171d | 0% → 100% | 231d → none | 9-110M FS+59d → 9-110M |  |
| 195221305 | Module #36 Matrix Fabrication | 2011-01-04 → 2010-10-01 A (-95d) | 2011-09-06 → 2011-05-05 A (-124d) | 171d → 145d | 0% → 100% | 259d → none | 9-110M FS+59d → 9-110M |  |
| 195221310 | Module #36 Machining and Shipping | 2011-01-04 → 2010-10-01 A (-95d) | 2011-10-07 → 2011-06-13 A (-116d) | 194d → 171d | 0% → 100% | 231d → none | 9-110M FS+59d → 9-110M |  |
| 195221315 | Module #37 Matrix Fabrication | 2011-01-04 → 2010-10-01 A (-95d) | 2011-10-12 → 2011-05-26 A (-139d) | 197d → 160d | 0% → 100% | 233d → none | 9-110M FS+59d → 9-110M |  |

| ID | Task | Start | Finish | Duration | Complete | Total float | Predecessors | Other |
| --- | --- | --- | --- | --- | --- | --- | --- | --- |
| 195221320 | Module #37 Machining and Shipping | 2011-01-04 → 2010-10-01 A (-95d) | 2011-12-21 → 2011-08-23 A (-120d) | 245d → 221d | 0% → 100% | 180d → none | 9-110M FS+59d → 9-110M |  |
| 195221325 | Module #38 Matrix Fabrication | 2011-01-04 → 2010-10-01 A (-95d) | 2011-10-12 → 2011-05-31 A (-134d) | 197d → 162d | 0% → 100% | 233d → none | 9-110M FS+59d → 9-110M |  |
| 195221330 | Module #38 Machining and Shipping | 2011-01-04 → 2010-10-01 A (-95d) | 2011-12-21 → 2011-08-23 A (-120d) | 245d → 221d | 0% → 100% | 180d → none | 9-110M FS+59d → 9-110M |  |
| 195221335 | Module #39 Matrix Fabrication | 2011-01-04 → 2010-10-01 A (-95d) | 2011-11-18 → 2011-06-30 A (-141d) | 224d → 184d | 0% → 100% | 206d → none | 9-110M FS+59d → 9-110M |  |
| 195221340 | Module #39 Machining and Shipping | 2011-01-04 → 2010-10-01 A (-95d) | 2011-12-21 → 2011-08-23 A (-120d) | 245d → 221d | 0% → 100% | 180d → none | 9-110M FS+59d → 9-110M |  |
| 195221345 | Module #40 Matrix Fabrication | 2011-01-04 → 2010-10-01 A (-95d) | 2011-11-18 → 2011-06-30 A (-141d) | 224d → 184d | 0% → 100% | 206d → none | 9-110M FS+59d → 9-110M |  |
| 195221350 | Module #40 Machining and Shipping | 2011-01-04 → 2010-10-01 A (-95d) | 2011-12-21 → 2011-08-23 A (-120d) | 245d → 221d | 0% → 100% | 180d → none | 9-110M FS+59d → 9-110M |  |
| 195221355 | Module #41 Matrix Fabrication | 2011-01-04 → 2010-10-01 A (-95d) | 2011-12-29 → 2011-07-11 A (-171d) | 246d → 190d | 0% → 100% | 184d → none | 9-110M FS+59d → 9-110M |  |
| 195221360 | Module #41 Machining and Shipping | 2011-01-04 → 2010-10-01 A (-95d) | 2012-03-07 → 2011-10-17 A (-142d) | 292d → 259d | 0% → 100% | 133d → none | 9-110M FS+59d → 9-110M |  |
| 195221365 | Module #42 Matrix Fabrication | 2011-01-04 → 2010-10-01 A (-95d) | 2011-12-29 → 2011-07-11 A (-171d) | 246d → 190d | 0% → 100% | 184d → none | 9-110M FS+59d → 9-110M |  |
| 195221370 | Module #42 Machining and Shipping | 2011-01-04 → 2010-10-01 A (-95d) | 2012-03-07 → 2011-10-15 A (-144d) | 292d → 258d | 0% → 100% | 133d → none | 9-110M FS+59d → 9-110M |  |
| 195221375 | Module #43 Matrix Fabrication | 2012-01-04 → 2010-10-01 A (-460d) | 2012-02-02 → 2011-08-22 A (-164d) | 21d → 220d | 0% → 100% | 161d → none | 9-120M FS+59d, 15221145, 15221018X → 15221018X FS-200d, 15221145 |  |
| 195221380 | Module #43 Machining and Shipping | 2012-01-04 → 2010-10-01 A (-460d) | 2012-03-07 → 2011-10-17 A (-142d) | 44d → 258d | 0% → 100% | 133d → none | 9-120M FS+59d → 9-110M |  |
| 195221385 | Module #44 Matrix Fabrication | 2012-01-04 → 2010-10-01 A (-460d) | 2012-02-02 → 2011-08-22 A (-164d) | 21d → 220d | 0% → 100% | 161d → none | 9-120M FS+59d → 9-110M |  |
| 195221390 | Module #44 Machining and Shipping | 2012-01-04 → 2010-10-01 A (-460d) | 2012-03-07 → 2011-10-17 A (-142d) | 44d → 259d | 0% → 100% | 133d → none | 9-120M FS+59d → 9-110M |  |
| 195221395 | Module #45 Matrix Fabrication | 2012-01-04 → 2010-10-01 A (-460d) | 2012-03-12 → 2011-08-23 A (-202d) | 47d → 221d | 0% → 100% | 135d → none | 9-120M FS+59d → 9-110M |  |
| 195221400 | Module #45 Machining and Shipping | 2012-01-04 → 2010-10-01 A (-460d) | 2012-05-22 → 2011-12-19 A (-155d) | 98d → 302d | 0% → 100% | 79d → none | 9-120M FS+59d → 9-110M |  |
| 195221405 | Module #46 Matrix Fabrication | 2012-01-04 → 2010-10-01 A (-460d) | 2012-03-12 → 2011-08-23 A (-202d) | 47d → 221d | 0% → 100% | 135d → none | 9-120M FS+59d → 9-110M |  |
| 195221410 | Module #46 Machining and Shipping | 2012-01-04 → 2010-10-01 A (-460d) | 2012-05-22 → 2011-12-19 A (-155d) | 98d → 302d | 0% → 100% | 79d → none | 9-120M FS+59d → 9-110M |  |
| 195221415 | Module #47 Matrix Fabrication | 2012-01-04 → 2010-10-01 A (-460d) | 2012-04-18 → 2011-10-17 A (-184d) | 74d → 259d | 0% → 100% | 108d → none | 9-120M FS+59d → 9-110M |  |
| 195221420 | Module #47 Machining and Shipping | 2012-01-04 → 2010-10-01 A (-460d) | 2012-05-22 → 2011-12-19 A (-155d) | 98d → 302d | 0% → 100% | 79d → none | 9-120M FS+59d → 9-110M |  |
| 195221425 | Module #48 Matrix Fabrication | 2012-01-04 → 2010-10-01 A (-460d) | 2012-04-18 → 2011-10-24 A (-177d) | 74d → 264d | 0% → 100% | 108d → none | 9-120M FS+59d → 9-110M |  |
| 195221430 | Module #48 Machining and Shipping | 2012-01-04 → 2010-10-01 A (-460d) | 2012-05-22 → 2011-12-19 A (-155d) | 98d → 302d | 0% → 100% | 79d → none | 9-120M FS+59d → 9-110M |  |
| 195221450 | USM Peg Point # 1 Initial Order Placed | 2011-06-09 A | 2011-07-29 A |  | 0% → 100% | 312d → none |  | resources PROCUREMENT>$50K 69 NO ESCALATION; PROCUREMENT<$50K 60 NO ESCALATION → PROCUREMENT<$50K 60 NO ESCALATION; PROCUREMENT>$50K 69 NO ESCALATION |
| 195221455 | USM Peg Point # 2 On-site Review passed | 2011-06-09 A | 2011-11-30 → 2011-12-19 A (+19d) | 121d → 134d | 0% → 100% | 312d → none |  |  |
| 195221460 | USM Peg Point # 3 Batch #1 Arrival at USM | 2011-06-09 A | 2011-12-30 → 2011-12-19 A (-11d) | 138d → 134d | 0% → 100% | 312d → none |  |  |
| 195221465 | USM Peg Point # 4 Batch #2 Arrival at USM | 2011-06-09 A | 2012-01-31 → 2012-01-16 A (-15d) | 158d → 147d | 0% → 100% | 312d → none |  |  |
| 195221470 | USM Peg Point # 5 Qty. 500 MPPCs tested and shipped to JLab | 2011-06-09 A | 2012-01-31 → 2012-05-14 A (+104d) | 158d → 231d | 0% → 100% | 312d → none |  |  |
| 195221475 | USM Peg Point # 6 Batch #3 Arrival at USM | 2011-06-09 A | 2012-02-29 → 2012-05-14 A (+75d) | 178d → 231d | 0% → 100% | 312d → none |  |  |
| 195221480 | USM Peg Point # 7 Qty. 500 MPPCs tested and shipped to JLab | 2011-06-09 A | 2012-02-29 → 2012-08-13 A (+166d) | 178d → 294d | 0% → 100% | 312d → none |  |  |
| 195221485 | USM Peg Point # 8 Batch #4 Arrival at USM | 2011-06-09 A | 2012-03-30 → 2013-03-11 A (+346d) | 200d → 388d | 0% → 100% | 312d → none |  |  |
| 195221490 | USM Peg Point # 9 Qty. 500 MPPCs tested and shipped to JLab | 2011-06-09 A | 2012-03-30 → 2012-09-17 A (+171d) | 200d → 318d | 0% → 100% | 312d → none |  |  |
| 195221495 | USM Peg Point # 10 Qty. 500 MPPCs tested and shipped to JLab | 2011-06-09 A | 2012-04-30 → 2013-03-11 A (+315d) | 221d → 392d | 0% → 100% | 312d → none |  |  |
| 195221500 | USM Peg Point # 11 Qty. 500 MPPCs tested and shipped to JLab | 2011-06-09 A | 2012-05-31 → 2013-04-15 A (+319d) | 243d → 388d | 0% → 100% | 312d → none |  |  |
| 195221505 | USM Peg Point # 12 Qty. 300 MPPCs tested and shipped to JLab | 2011-06-09 A | 2012-06-29 → 2013-04-15 A (+290d) | 263d → 411d | 0% → 100% | 312d → none |  |  |
| 195221435M | All Barrel Cal Mods Comptd & Shipped | 2012-05-22 → 2011-12-19 A (-155d) | 2012-05-22 → 2011-12-19 A (-155d) |  | 0% → 100% | 84d → none | 195221115, 195221050, 195221430, 195221285, 195221100, 195221230, 195221140, 195221320, 195221415, 195221195, 15221205, 15221220, 195221365, 195221120, 195221330, 195221175, 195221185, 195221235, 195221395, 195221375, 195221130, 15221265, 15221225, 195221025, 195221145, 195221170, 195221055, 195221225, 195221340, 195221190, 195221110, 15221275, 195221310, 195221355, 195221350, 195221210, 195221380, 195221245, 195221075, 195221095, 195221125, 195221390, 15221230, 15221240, 15221200, 195221370, 195221275, 195221425, 195221300, 195221410, 195221250, 195221090, 195221295, 195221400, 15221260, 15221055a, 15221255, 15221250, 15221245, 195221325, 195221035, 195221135, 195221220, 195221080, 195221105, 195221290, 195221150, 195221345, 195221200, 195221420, 195221040, 15221055b, 15221215, 195221385, 195221180, 195221335, 195221215, 195221160, 195221030, 195221085, 195221060, 195221065, 195221260, 195221165, 195221255, 195221305, 195221240, 15221235, 15221270, 15221173, 195221270, 195221360, 195221045, 195221070, 195221155, 195221405, 195221265, 195221205, 195221315, 15221210 → 195221245, 195221250, 195221100, 195221165, 195221140, 195221170, 195221095, 195221045, 195221210, 195221285, 195221375, 195221310, 195221315, 195221220, 195221110, 195221345, 15221173, 15221265, 195221360, 195221370, 195221030, 195221320, 195221135, 195221300, 195221150, 195221425, 195221410, 195221200, 195221085, 195221125, 195221160, 195221155, 195221040, 195221365, 195221215, 195221120, 195221115, 195221415, 195221350, 15221215, 15221235, 15221200, 195221075, 195221145, 195221290, 195221025, 195221225, 195221195, 195221235, 195221385, 195221180, 195221355, 15221250, 15221210, 15221240, 15221270, 15221255, 195221270, 195221105, 195221070, 195221230, 195221255, 195221295, 15221230, 15221225, 195221330, 195221400, 195221055, 195221060, 195221090, 195221275, 195221405, 195221065, 195221380, 195221175, 195221340, 15221220, 195221335, 195221240, 195221420, 195221205, 195221265, 195221035, 195221050, 195221395, 195221305, 15221260, 15221275, 15221205, 15221245, 195221080, 195221325, 195221260, 195221430, 195221390, 195221130, 195221185, 195221190 |  |
| 195221510 | Re-Baseline Actuals Adjustment | 2013-08-30 A | 2013-08-30 A |  | 0% → 100% | 20d → none | 9-130M FS+227d → none |  |
| 2 | **1.9.5.2.2.2 HALL D FORWARD CALORIMETER** |  | 2013-10-31 → 2013-09-23 (-38d) |  |  |  |  |  |
| 195222010 | Prepare top level drawing documentation | 2010-03-01 A | 2010-04-28 → 2010-06-01 A (+34d) | 43d → 66d | 0% → 100% | 148d → none |  |  |
| 195222020 | Build Steel Tubes (fab) | 2010-03-01 A | 2010-06-30 → 2010-10-25 A (+117d) | 87d → 168d | 0% → 100% | 148d → none |  |  |
| 195222025 | Build Steel Tubes (coat) | 2010-03-01 A | 2010-07-30 → 2010-12-01 A (+124d) | 108d → 193d | 0% → 100% | 148d → none |  |  |
| 195222030 | Build Tube Straps (procure material) | 2010-03-01 A | 2010-06-30 → 2010-08-02 A (+33d) | 87d → 109d | 0% → 100% | 148d → none |  |  |
| 195222035 | Build Tube Straps (shear) | 2010-03-01 A | 2010-07-30 → 2010-07-12 A (-18d) | 108d → 94d | 0% → 100% | 148d → none |  |  |
| 195222040 | Build Jack Plates | 2010-03-01 A | 2010-07-30 → 2010-08-16 A (+17d) | 108d → 119d | 0% → 100% | 148d → none |  |  |
| 195222045 | Build Face Plates | 2010-03-01 A | 2010-05-28 → 2010-07-09 A (+42d) | 65d → 93d | 0% → 100% | 148d → none |  |  |
| 195222050 | Pb Glass Preparation (weld straps) | 2010-03-01 A | 2010-10-29 → 2010-09-15 A (-44d) | 172d → 140d | 0% → 100% | 148d → none |  |  |
| 195222055 | Pb Glass Preparation (clean and wrap glass) | 2010-03-01 A | 2010-12-30 → 2011-03-21 A (+81d) | 209d → 263d | 0% → 100% | 148d → none |  |  |
| 195222060 | Pb Glass Preparation (attach sheild) | 2010-03-01 A | 2011-02-28 → 2011-03-21 A (+21d) | 248d → 263d | 0% → 100% | 148d → none |  |  |
| 195222065 | Pb Glass Preparation (prepare shippment) | 2010-03-01 A | 2011-03-31 → 2011-03-21 A (-10d) | 271d → 263d | 0% → 100% | 148d → none |  |  |
| 195222070 | Replacement pmts Testing | 2010-03-01 A | 2010-03-05 → 2010-11-22 A (+262d) | 5d → 188d | 0% → 100% | 148d → none |  |  |
| 195222075 | PMT Base Rods (procure) | 2010-03-01 A | 2010-07-30 → 2011-05-23 A (+297d) | 108d → 308d | 0% → 100% | 148d → none | 195222070 FS-5d → 195222070 FS-130d |  |
| 195222080 | PMT Base Housing (procure tubes) | 2010-03-01 A | 2010-06-30 → 2011-02-28 A (+243d) | 87d → 248d | 0% → 100% | 148d → none |  |  |
| 195222085 | PMT Base Housing (machine tubes) | 2010-03-01 A | 2010-08-31 → 2011-08-31 A (+365d) | 130d → 378d | 0% → 100% | 148d → none |  |  |
| 195222090 | PMT Base Housing (fabricate sockets) | 2010-03-01 A | 2010-07-30 → 2010-10-25 A (+87d) | 108d → 168d | 0% → 100% | 148d → none |  |  |
| 195222095 | PMT Base Housing (insert pins) | 2010-03-01 A | 2010-08-31 → 2011-03-21 A (+202d) | 130d → 263d | 0% → 100% | 148d → none |  |  |
| 195222100 | PMT Base Housing (package for assembly) | 2010-03-01 A | 2010-08-31 → 2011-03-21 A (+202d) | 130d → 263d | 0% → 100% | 148d → none |  |  |
| 195222105 | PMT Base Housing (back plate) | 2010-03-01 A | 2010-07-30 → 2011-03-21 A (+234d) | 108d → 263d | 0% → 100% | 148d → none |  |  |
| 195222110 | PMT Base Housing assembly | 2010-03-01 A | 2010-03-31 → 2010-11-22 A (+236d) | 23d → 188d | 0% → 100% | 148d → none |  |  |
| 195222115 | Prepare Base Circuit Fabrication Drawings | 2010-03-01 A | 2010-07-30 → 2010-10-25 A (+87d) | 108d → 168d | 0% → 100% | 148d → none | 195222110 FS-23d → 195222110 FS-40d |  |
| 195222125 | First Circuit Board Run PCB's (1/6 total) | 2010-03-01 A | 2010-09-30 → 2010-12-20 A (+81d) | 151d → 206d | 0% → 100% | 148d → none |  |  |
| 195222130 | First Circuit Board Run Parts (1/6 total) | 2010-03-01 A | 2010-08-31 → 2010-10-15 A (+45d) | 130d → 162d | 0% → 100% | 148d → none |  |  |
| 195222135 | First Circuit Board Run Populate (1/6 total) | 2010-03-01 A | 2010-09-30 → 2011-01-10 A (+102d) | 151d → 215d | 0% → 100% | 148d → none |  |  |
| 195222140 | First Circuit Board Tester (1/6 total) | 2010-03-01 A | 2010-08-31 → 2010-12-20 A (+111d) | 130d → 206d | 0% → 100% | 148d → none |  |  |
| 195222145 | First Circuit Board Run Assembly (1/6 total) | 2010-03-01 A | 2010-12-30 → 2011-03-21 A (+81d) | 209d → 263d | 0% → 100% | 148d → none |  |  |
| 195222150 | First Circuit Board Run Testing (1/6 total) | 2010-03-01 A | 2011-03-31 → 2011-07-12 A (+103d) | 271d → 342d | 0% → 100% | 148d → none |  |  |
| 195222155 | Second Circuit Board Run PCBs (5/6 total) | 2010-03-01 A | 2011-12-30 → 2011-11-14 A (-46d) | 457d → 430d | 0% → 100% | 148d → none |  |  |
| 195222160 | Second Circuit Board Run Parts (5/6 total) | 2010-03-01 A | 2011-08-31 → 2011-09-26 A (+26d) | 378d → 395d | 0% → 100% | 148d → none | 195222155 FS-457d → 195222155 FS-292d |  |
| 195222165 | Second Circuit Board Run Populate (5/6 total) | 2010-03-01 A | 2011-12-30 → 2012-09-17 A (+262d) | 457d → 637d | 0% → 100% | 148d → none | 195222160 FS-378d → 195222160 FS-292d |  |
| 195222170 | Second Circuit Board Run Assemble and Test (5/6 total) | 2010-03-01 A | 2012-03-30 → 2013-02-11 A (+318d) | 519d → 700d | 0% → 100% | 148d → none | 195222165 FS-457d → 195222165 FS-313d |  |
| 195222175 | Prepare Pb Glass Drawings | 2010-03-01 A | 2010-05-28 → 2011-03-15 A (+291d) | 65d → 259d | 0% → 100% | 148d → none | 195222170 FS-519d → 195222170 FS-457d |  |

| ID | Task | Start | Finish | Duration | Complete | Total float | Predecessors | Other |
| --- | --- | --- | --- | --- | --- | --- | --- | --- |
| 195222185 | Procure Materials for PB Glass Support | 2010-03-01 A | 2010-09-30 → 2012-03-19 A (+536d) | 151d → 510d | 0% → 100% | 148d → none |  |  |
| 195222190 | Machine Componets for PB Glass Support | 2010-03-01 A | 2011-04-29 → 2012-06-13 A (+411d) | 292d → 570d | 0% → 100% | 148d → none | 195222185 FF, 195222185 FS-151d → 195222185 FS-151d | was named Machine Componants for PB Glass Support |
| 195222195 | Assemble Pb Glass Support Structure | 2010-03-01 A | 2011-05-31 → 2012-12-14 A (+563d) | 313d → 698d | 0% → 100% | 148d → none |  |  |
| 195222200 | Light Guide Material Procurement | 2010-03-01 A | 2010-07-30 → 2011-08-31 A (+397d) | 108d → 378d | 0% → 100% | 148d → none |  |  |
| 195222205 | Glue and Wrap Light Guides | 2010-03-01 A | 2012-02-29 → 2012-05-14 A (+75d) | 497d → 550d | 0% → 100% | 148d → none | 195222200 FS-108d → 195222200 FS-290d |  |
| 195222210 | Slow Control (procure CAN/ethernet devices) | 2010-03-01 A | 2012-05-31 → 2011-07-25 A (-311d) | 562d → 351d | 0% → 100% | 148d → none |  |  |
| 195222215 | Slow Control (procure cables) | 2010-03-01 A | 2012-05-31 → 2012-07-15 A (+45d) | 562d → 592d | 0% → 100% | 148d → none |  |  |
| 195222220 | Slow Control (assemble and test slow control) | 2010-03-01 A | 2012-06-29 → 2012-09-17 A (+80d) | 582d → 637d | 0% → 100% | 148d → none |  |  |
| 195222225 | Final PMT Test (test fixture) | 2010-03-01 A | 2010-07-30 → 2012-05-14 A (+654d) | 108d → 550d | 0% → 100% | 148d → none |  |  |
| 195222230 | Final PMT Test (test PMT and bases) | 2010-03-01 A | 2012-04-30 → 2012-05-14 A (+14d) | 540d → 550d | 0% → 100% | 148d → none | 195222225 FS-108d → 195222225 FS-325d |  |
| 195222235 | Final PMT Test (package and shipment) | 2010-03-01 A | 2012-04-30 → 2012-05-14 A (+14d) | 540d → 550d | 0% → 100% | 148d → none |  |  |
| 195222240 | Fabricate Optical Cookies (material) | 2010-03-01 A | 2012-05-31 → 2012-05-18 A (-13d) | 562d → 554d | 0% → 100% | 148d → none |  |  |
| 195222245 | Fabricate Optical Cookies (cut cookies) | 2010-03-01 A | 2012-06-29 → 2012-05-18 A (-42d) | 582d → 554d | 0% → 100% | 148d → none |  |  |
| 195222250 | Fabricate Optical Cookies (Package for shipment) | 2010-03-01 A | 2012-06-29 → 2012-05-18 A (-42d) | 582d → 554d | 0% → 100% | 148d → none |  |  |
| 195222255 | Cable Refurbishment (locate and acquire cables) | 2010-03-01 A | 2010-12-30 → 2011-08-22 A (+235d) | 209d → 371d | 0% → 100% | 148d → none |  |  |
| 195222260 | Cable Refurbishment (procure connectors) | 2010-03-01 A | 2010-12-30 → 2011-02-28 A (+60d) | 209d → 248d | 0% → 100% | 148d → none |  |  |
| 195222265 | Cable Refurbishment (install connectors) | 2010-03-01 A | 2011-01-31 → 2011-04-25 A (+84d) | 229d → 288d | 0% → 100% | 148d → none |  |  |
| 195222270 | Cable Refurbishment (package for shipment) | 2010-03-01 A | 2011-01-31 → 2011-08-28 A (+209d) | 229d → 375d | 0% → 100% | 148d → none |  |  |
| 195222275 | Procure Magnetic Sheilds | 2010-03-01 A | 2012-06-29 → 2012-03-19 A (-102d) | 582d → 510d | 0% → 100% | 148d → none |  |  |
| 195222280 | Procure Shipping Materials | 2010-03-01 A | 2010-08-31 → 2012-12-16 A (+838d) | 130d → 700d | 0% → 100% | 148d → none |  |  |
| 195222285 | Shipping to Jlab | 2010-03-01 A | 2012-06-29 → 2013-07-15 A (+381d) | 582d → 714d | 0% → 100% | 148d → none | 195222280 FS-130d → 195222280 FS-431.5d |  |
| 195222015M | Readiness Review | 2010-04-29 → 2010-06-21 A (+53d) | 2010-04-29 → 2010-06-21 A (+53d) |  | 0% → 100% | 148d → none | 195222010 SS, 195222010 → 195222010 |  |
| 195222120M | Jlab Reveiw and Approval of Base Circuit Design | 2010-07-21 → 2010-10-25 A (+96d) | 2010-07-21 → 2010-10-25 A (+96d) |  | 0% → 100% | 156d → none |  |  |
| 195222180M | Jlab Reveiw and Approval of Support Drawings | 2010-03-01 → 2011-07-01 A (+487d) | 2010-03-01 → 2011-07-01 A (+487d) |  | 0% → 100% | 213d → none |  |  |
| 195222290 | Re-Baseline Actuals Adjustment | 2013-08-30 A | 2013-08-30 A |  | 0% → 100% | 20d → none | 9-130M FS+227d → none |  |
| 295222000 | Indiana Contract Completion | 2013-09-03 A | 2013-10-31 → 2013-09-23 A (-38d) |  | 0% → 100% | 224d → none |  | resources PROCUREMENT<$50K 60 NO ESCALATION; PROCUREMENT>$50K 69 NO ESCALATION → PROCUREMENT>$50K 69 NO ESCALATION |
| 19524000 | Re-Baseline Actuals Adjustment | 2013-08-30 A | 2013-08-30 A |  | 0% → 100% | 20d → none | 9-130M FS+227d → none |  |
| 1961000 | N&S Access LCW Upgrades Constrctn Contract Progress December 2010 | 2010-12-01 A | 2010-12-30 A |  | 0% → 100% | 475d → none |  |  |
| 1961000a | N&S Access LCW Upgrades Constrctn Contract Progress January 2011 | 2010-12-01 A | 2011-01-31 A |  | 0% → 100% | 475d → none |  |  |
| 1961000b | N&S Access LCW Upgrades Constrctn Contract Progress February 2011 | 2010-12-01 A | 2011-02-28 A |  | 0% → 100% | 475d → none |  |  |
| 1961000c | N&S Access LCW Upgrades Constrctn Contract Progress March 2011 | 2010-12-01 A | 2011-03-31 → 2011-03-25 A (-6d) | 79d → 75d | 0% → 100% | 475d → none |  |  |
| 1961000d | N&S Access LCW Upgrades Constrctn Contract Progress April 2011 | 2010-12-01 A | 2011-04-29 → 2011-03-25 A (-35d) | 100d → 75d | 0% → 100% | 475d → none |  |  |
| 1961000f | N&S Access LCW Upgrades Constrctn Contract Progress May 2011 | 2010-12-01 A | 2011-05-31 → 2011-04-29 A (-32d) | 121d → 100d | 0% → 100% | 475d → none |  |  |
| 1961000g | N&S Access LCW Upgrades Constrctn Contract Progress June 2011 | 2010-12-01 A | 2011-06-30 A |  | 0% → 100% | 475d → none |  |  |
| 1961000h | N&S Access LCW Upgrades Constrctn Contract Progress July 2011 | 2010-12-01 A | 2011-07-29 → 2011-06-30 A (-29d) | 163d → 143d | 0% → 100% | 475d → none |  |  |
| 1961000j | N&S Access LCW Upgrades Constrctn Contract Progress August 2011 | 2010-12-01 A | 2011-08-31 → 2011-06-30 A (-62d) | 186d → 143d | 0% → 100% | 475d → none |  |  |
| 1961000k | N&S Access LCW Upgrades Constrctn Contract Progress September 2011 | 2010-12-01 A | 2011-09-30 A |  | 0% → 100% | 475d → none |  |  |
| 1961000n | N&S Access LCW Upgrades Constrctn Contract Progress October 2011 | 2010-12-01 A | 2011-10-31 → 2011-10-21 A (-10d) | 228d → 222d | 0% → 100% | 475d → none |  |  |
| 1961005 | N&S Access LCW Upgrades Contract Modifications | 2010-12-01 A | 2011-10-31 → 2011-11-30 A (+30d) | 228d → 248d | 0% → 100% | 475d → none |  |  |
| 1961010 | Re-Baseline Actuals Adjustment | 2013-08-30 A | 2013-08-30 A |  | 0% → 100% | 20d → none | 9-130M FS+227d → none |  |
| 7 | **1.9.7 12 Gev Infastructure** | 2010-07-01 → 2010-10-01 (+92d) | 2013-10-31 → 2013-10-21 (-10d) |  |  |  |  |  |
| 1 | **1.9.7.1 12 Gev Misc Infastructure** | 2010-07-01 → 2010-10-01 (+92d) | 2013-10-31 → 2013-10-21 (-10d) |  |  |  |  |  |
| 197111060 | Blue Crab Lease October-2010 | 2010-10-01 A | 2010-10-29 A |  | 0% → 100% | 6d → none |  |  |
| 197111065 | Blue Crab Lease | 2010-10-01 A | 2013-08-22 A |  | 0% → 100% | 6d → none |  | resources PROCUREMENT<$50K 60 NO ESCALATION; PROCUREMENT>$50K 69 NO ESCALATION → PROCUREMENT>$50K 69 NO ESCALATION; PROCUREMENT<$50K 60 NO ESCALATION |
| 197111080 | Blue Crab Utilities October-2010 | 2010-10-01 A | 2010-10-29 A |  | 0% → 100% | 6d → none |  |  |
| 197111085 | Blue Crab Utilities | 2010-10-01 A | 2013-08-22 A |  | 0% → 100% | 6d → none |  |  |
| 197111100 | Blue Crab Fork Lift-2010 | 2010-10-01 A | 2010-10-29 A |  | 0% → 100% | 355d → none |  |  |
| 197111105 | Blue Crab Fork Lift-FY11/12 | 2010-10-01 A | 2012-03-30 A |  | 0% → 100% | 355d → none |  |  |
| 197111110 | Blue Crab Shelving | 2010-10-01 A | 2010-10-29 A |  | 0% → 100% | 702d → none |  |  |
| 197111115 | Blue Crab Janitorial October-2010 | 2010-10-01 A | 2010-10-29 A |  | 0% → 100% | 64d → none |  |  |
| 197111001M | Space rented for Chamber Work | 2010-08-02 → 2010-11-01 A (+91d) | 2010-08-02 → 2010-11-01 A (+91d) |  | 0% → 100% | 126.5d → none |  |  |
| 197111005 | Procure 2000 Sq. Ft. CLASS 10,000 Clean Room | 2010-07-01 → 2010-11-01 A (+123d) | 2010-10-29 → 2011-01-28 A (+91d) | 85d → 56d | 0% → 100% | 126.5d → none |  | resources PROCUREMENT<$50K 60 NO ESCALATION FY11; PROCUREMENT>$50K 69 NO ESCALATION FY11 → PROCUREMENT>$50K 69 NO ESCALATION FY11; PROCUREMENT<$50K 60 NO ESCALATION FY11 |
| 197111010 | Procure HVAC Unit | 2010-07-01 → 2010-11-01 A (+123d) | 2010-08-31 → 2010-11-29 A (+90d) | 43d → 19d | 0% → 100% | 148.5d → none |  |  |
| 197111055 | Blue Crab Phone Lines FY11 | 2010-11-01 A | 2011-10-31 A |  | 0% → 100% | 6d → none |  |  |
| 197111015 | Install HVAC Unit | 2010-09-01 → 2010-11-22 A (+82d) | 2010-09-29 → 2011-01-28 A (+121d) | 20d → 41d | 0% → 100% | 148.5d → none |  |  |
| 197111020 | Modify Building Electrical Distribution FY10 | 2010-08-02 → 2010-11-30 A (+120d) | 2010-09-30 → 2011-01-28 A (+120d) | 43d → 37d | 0% → 100% | 126.5d → none |  |  |
| 197111020a | Modify Building Electrical Distribution FY11 | 2010-10-01 → 2010-11-30 A (+60d) | 2010-10-29 → 2011-01-28 A (+91d) | 21d → 37d | 0% → 100% | 126.5d → none | 197111020 → 197111020 FS-50d |  |
| 197111135 | Blue Crab Misc. Supplies FY11 | 2010-12-01 A | 2011-09-30 A |  | 0% → 100% | 6d → none |  |  |
| 197111045 | Blue Crab Phone Lines Upfront Costs | 2010-11-01 → 2011-01-01 A (+61d) | 2010-11-30 → 2011-01-28 A (+59d) | 20d → 18d | 0% → 100% | 6d → none |  |  |
| 197111120 | Blue Crab Janitorial FY11 | 2011-01-04 → 2011-01-03 A (-1d) | 2011-09-30 A |  | 0% → 100% | 64d → none |  |  |
| 197111030M | Space Ready | 2010-11-01 → 2011-01-28 A (+88d) | 2010-11-01 → 2011-01-28 A (+88d) |  | 0% → 100% | 126.5d → none |  |  |
| 197111125 | Blue Crab Janitorial FY12 | 2011-10-03 A | 2012-09-28 A |  | 0% → 100% | 64d → none |  |  |
| 197111140 | Blue Crab Misc. Supplies FY12 | 2011-10-03 A | 2012-09-28 A |  | 0% → 100% | 6d → none |  |  |
| 197111058 | Blue Crab Phone Lines FY12 | 2011-11-01 A | 2012-09-28 A |  | 0% → 100% | 6d → none |  |  |
| 197111059 | Blue Crab Phone Lines FY13 | 2012-10-01 A | 2013-08-22 A |  | 0% → 100% | 6d → none |  |  |
| 197111130 | Blue Crab Janitorial FY13 | 2012-10-01 A | 2013-05-31 A |  | 0% → 100% | 64d → none |  |  |
| 197111145 | Blue Crab Misc. Supplies FY13 | 2012-10-01 A | 2013-08-22 A |  | 0% → 100% | 6d → none |  |  |
| 197111150 | Re-Baseline Actuals Adjustment | 2013-08-30 A | 2013-08-30 A |  | 0% → 100% | 20d → none | 9-130M FS+227d → none |  |
| 2971000 | Blue Crab Cleanroom Completion | 2013-09-03 A | 2013-10-31 → 2013-10-21 A (-10d) |  | 0% → 100% | 224d → none |  | resources PROCUREMENT<$50K 60 NO ESCALATION; PROCUREMENT>$50K 69 NO ESCALATION → PROCUREMENT>$50K 69 NO ESCALATION |
| 2 | **1.10.2 HALL B NSF-FUNDED DETECTORS** |  | 2010-09-30 → 2010-10-25 (+25d) |  |  |  |  |  |

| ID | Task | Start | Finish | Duration | Complete | Total float |
| --- | --- | --- | --- | --- | --- | --- |
| 2 | **1.10.2.2 HALL B NSF-FUNDED DETECTORS-CALORIMETERS** |  | 2010-09-30 → 2010-10-25 (+25d) |  |  |  |
| 3 | **1.10.2.2.3 NSF-MRI ACTIVITIES FOR CLAS 12 PRESHOWER CALORIMETER** |  | 2010-09-30 → 2010-10-25 (+25d) |  |  |  |
| 1 | **1.10.2.2.3.1 WAVELENGTH SHIFTING FIBERS** | 2009-12-01 → 2010-02-01 (+62d) | 2010-09-30 → 2010-10-25 (+25d) |  |  |  |
| 1102231000 | Placeholder NSF Wavelength Shifting Fiber Procurement | 2009-12-01 → 2010-02-01 A (+62d) | 2010-09-30 → 2010-10-25 A (+25d) | 207d → 187d | 0% → 100% | 0d → none |
| 1 | **1.10.2.2.3.2.1 PHOTOMULTIPLIER TUBES** |  | 2010-09-30 → 2009-12-21 (-283d) |  |  |  |
| 11022321000 | Placeholder NSF Photomultiplier Tube Procurement | 2009-12-01 A | 2010-09-30 → 2009-12-21 A (-283d) | 207d → 14d | 0% → 100% | 0d → none |
| 2 | **1.10.2.2.3.2.2 MU-METAL SHIELDS** | 2009-12-01 → 2010-02-01 (+62d) |  |  |  |  |
| 11022322000 | Placeholder NSF Mu-Metal Shield Procurement | 2009-12-01 → 2010-02-01 A (+62d) | 2010-09-30 A | 207d → 170d | 0% → 100% | 0d → none |
| 3 | **1.10.2.2.3.2.3 HIGH VOLTAGE CABLES** |  | 2010-09-30 → 2009-12-21 (-283d) |  |  |  |
| 11022323000 | Placeholder NSF High Voltage Cable Procurement | 2009-12-01 A | 2010-09-30 → 2009-12-21 A (-283d) | 207d → 14d | 0% → 100% | 0d → none |
| 4 | **1.10.2.2.3.2.4 SIGNAL SPLITTERS** |  | 2010-09-30 → 2009-12-21 (-283d) |  |  |  |
| 11022324000 | Placeholder NSF Signal Splitters Procurement | 2009-12-01 A | 2010-09-30 → 2009-12-21 A (-283d) | 207d → 14d | 0% → 100% | 0d → none |
| 5 | **1.10.2.2.3.2.5 ELECTRONICS CABLES** | 2009-12-01 → 2010-02-01 (+62d) | 2010-09-30 → 2010-02-26 (-216d) |  |  |  |
| 11022325000 | Placeholder NSF Electronics Cables Procurement | 2009-12-01 → 2010-02-01 A (+62d) | 2010-09-30 → 2010-02-26 A (-216d) | 207d → 19d | 0% → 100% | 0d → none |
| 110324000 | Fab Heavy Gas Cerenkov | 2010-10-01 A | 2013-06-21 A |  | 0% → 100% | 69d → none |
